# 3GPP_Release-2000

Schedule from MS Project, 1985-07-05 to 2018-12-20, A marks actual dates.

## Calendars

- Standard: Mon-Fri 08:00-12:00, 13:00-17:00; Sat-Sun off. Exceptions (off unless hours are given): 2000-01-15 08:00-12:00, 13:00-17:00, 2009-05-30 08:00-12:00, 13:00-17:00, 2011-08-27 to 2011-08-28 08:00-12:00, 13:00-17:00, 2011-09-24 08:00-12:00, 13:00-17:00, 2012-06-02 08:00-12:00, 13:00-17:00, 2012-09-01 08:00-12:00, 13:00-17:00, 2012-11-18 08:00-12:00, 13:00-17:00, 2012-11-24 08:00-12:00, 13:00-17:00, 2013-02-16 08:00-12:00, 13:00-17:00, 2013-06-02 08:00-12:00, 13:00-17:00, 2013-08-10 to 2013-08-11 08:00-12:00, 13:00-17:00, 2013-09-14 08:00-12:00, 13:00-17:00, 2014-03-01 08:00-12:00, 13:00-17:00, 2014-08-24 08:00-12:00, 13:00-17:00, 2014-09-21 08:00-12:00, 13:00-17:00, 2014-10-05 08:00-12:00, 13:00-17:00, 2016-06-18 08:00-12:00, 13:00-17:00.

## Resources

| Resource |
| --- |
| NP |
| N1 |
| N2 |
| N3 |
| N4 |
| N5 |
| TP |
| T1 |
| T2 |
| T3 |
| RP |
| R1 |
| R2 |
| R3 |
| R4 |
| SP |
| S1 |
| S2 |
| S3 |
| S4 |
| S5 |
| PCG |
| GP |
| No |
| CN4 |
| ? |
| WG G2 |
| G2 |
| G1 |
| G4 |
| G3 |
| All |
| Generic |
| MLST |
| G5 |
| S3, G2 |
| WG T2 |
| GP,G1 |
| G4,G5 |
| OMA |
| GP-G2 |
| Yes |
| GP, |
| N4, |
| GP, N1 |
| CT5 |
| C5 |
| C1 |
| C4 |
| C3 |
| C6 |
| G1, |
| 4 |
| ct |
| c,s,r |
| CT,RAN,SA |
| G2, |
| G1, G3 |
| CT6 |
| CT1 |
| CT1, CT3, CT4 |
| C1, C3, C4 |
| CP |
| R5 |
| C |
| Rel-8 |
| GP, G2 |
| R1,R4 |
| S5,C1 |
| CT,RAN,SA,GERAN |
| S3,C1,C4 |
| 5 |
| S1,C1,C3,C4,S5 |
| S1,C1,C3,C5 |
| S1,C1,C3,C4 |
| S1,S5 |
| S2,S3 |
| RAN,SA |
| RP,S5 |
| S2,CT |
| S1,CT |
| S1,CT,GERAN |
| S1,C5 |
| S3,CT |
| S4,CT |
| C1,SA |
| S1,S2 |
| S1,S4 |
| S2,S2,S3,CT |
| S2,S3,CT |
| S1,CT,GX |
| S1,S4,CT |
| S2,S2,S3,S5,CT |
| S1,S2,CT |
| S1,S2,S3,CT |
| S1,S2,S3,S5CT |
| S1,S2,S3,S5,CT |
| S2,S5,CT |
| S4,S3 |
| S1,C1 |
| CP,C1 |
| C1,C3 |
| C1,C3,C4 |
| S1,S5,CT |
| C4,C3 |
| CP,RAN,SA,GERAN |
| S1,S2,S3,S5,CP |
| S2,S3,CP |
| S2,CP |
| S1,CP,GX |
| S1,CP |
| S1,S4,CP |
| S1,S2,CP |
| S1,S2,S3,CP |
| S2,S5,CP |
| S3,CP |
| S1,S5,CP |
| RAN,SA,GERAN |
| S1,S2,S3,S5,C1,C3,C4,C6 |
| S2,S3,C1,C3,C4 |
| S2,C4 |
| S2,C1,C3,C4 |
| S2,C1,C4 |
| S2,S3,C1,C4 |
| S1,C1,C4,G2 |
| C1,C4 |
| S1,C1,C3 |
| S1,S4,C1,C3,C4 |
| S1,S2,S3,C1,C3,C4 |
| S2,S5,C3 |
| S1,S2,C1,C4 |
| S2,C1 |
| S2,C1,C3 |
| S3,C1,C3,C4 |
| S1,S5,C1,C3,C4 |
| S2,C3,C4 |
| C3,C1 |
| R2,R4 |
| R2,R5 |
| RP,R5 |
| RP,S5,R5 |
| R1,R5 |
| S1,C1,R5 |
| S1,C1,S4,R5 |
| GERAN |
| G3new |
| G1, G3new |
| C4,C1,C3 |
| R1.R4 |
| R1, R4 |
| R2,R3 |
| C3,C4 |
| S4,C3 |
| S4,C3,C1,C4 |
| S1,S2,C1 |
| S1,S2<C1,C3,C4 |
| S1,S2,C1,C3,C4 |
| S5,C1,C3,C4 |
| GP,C4 |
| C4,C1 |
| S2,S1 |
| RP,SP,GP |
| RP,SP,CP,GP |
| CP,GP,RP,SP |
| GP,C4,S4 |
| S1,C1,C4 |
| S1,S2,C3,C1 |
| R2,R4,R3 |
| CP,GP, RP,SP |
| S2,S1,C1,S5 |
| S2,S1,C1 |
| S1,C1,S4 |
| S1,S2,GP,C4,R2 |
| S1,GP,R2 |
| S1,C6 |
| S1,S2,C1,S4 |
| S2,S3,S5,C1,C3,C4 |
| S2,S5,C1 |
| S2,S3,S5 |
| CP,GP, RP,SP,TP |
| S2,C4,C1 |
| S1,C1,C4,S3 |
| S2,S5 |
| S3,C1 |
| S3,C4 |
| S1,C4 |
| S2,S5,C3,C1 |
| S2,S1,S5,C1,C4 |
| S1,R1,C3 |
| S1,C1,R2 |
| S2,S1,C1,C4 |
| S1,C1,C6 |
| GP,S4,C4,C1,C3 |
| C3,C1,C4 |
| S1,C4,C1 |
| S1,S3 |
| S1,S2,S5,C3,C4 |
| R4,G1 |
| G1,R4 |
| RP,GP |
| R4,GP |
| R3,R2 |
| C6,RP,SP |
| R5,C6 |
| CP,RP,SP |
| RP,SP,CP |
| R3,S5 |
| S1,S2,RP |
| S1,S2,S5,RP |
| S2,S1,RP |
| Rel-9 |
| S3,C6 |
| S1,S2,S3,S5,RP |
| S2,S1,S3 |
| S1,S2,S3 |
| S1,S2,S3,S5 |
| C6,R5 |
| S1,S2,RP,GP |
| S1,S2,S4,S5,RP,GP |
| GP,G2 |
| GP,GP, N1 |
| GP,S2,G1,G2 |
| GP,R2,R3,S2,G1,G2 |
| GP,S2,S5,R2,R3,G2,G1 |
| GP,R3 |
| N4,S2 |
| GP,RP |
| GP,S2,RP |
| G5,G4 |
| G4,R3 |
| S2,R2,R4 |
| S1,S2,R2,R4 |
| GP,S5 |
| S1,S2,S5 |
| R4,R5 |
| R4,R2,R3,R5 |
| S2,S5,N4,RP |
| S1,S2,S3,S5,NP |
| S2,S4,S5 |
| T2,S1,S4,S5 |
| SP,RP |
| S2,RP |
| S1,S2,CP,G2 |
| CP,SP |
| S1,G2 |
| SP,CP |
| S1,S2,S5,C3 |
| S1,C1,S3 |
| G1,G3new |
| C4, C3, C1C4 |
| C4,C3,C1 |
| S1,S2,S3,S5,R2,R3,R4 |
| S1,S2,S3,R2 |
| S2,S3,S5,C4,R2 |
| S1,S5,C1 |
| S1,S2,S3,C1,C3,C4,R2 |
| Ggp |
| S3,S2,C1,C4,G2 G3new |
| R1,R2,R3,R4 |
| R4,R1,R2,R3 |
| R4,R2,R3 |
| S1,C1,C4,R2 |
| R4,R2 |
| S2,C4,R2,R4 |
| S2,C4,R2 |
| S2,S3,S5,C3,C4,R2 |
| S1,S2,S4,T2 |
| S1,S2,S4 |
| S1,S2,S4,R5 |
| S3,S2,C1,C4,G2,G3new |
| GP,C1 |
| S1,S5,C4 |
| S1,S2,S3,S5,R2,R3,R4,GP |
| GP,C4,C3,C1 |
| SMG9 |
| SMG1 |
| SMG2 |
| N3,R5 |
| N1, N2, N4, G1, G2, R3, S1, SMG2 |
| S1,SMG1 |
| SMG1,N4 |
| N1,C1,N4,S1,T2,G2,SMG1,SMG2,SMG3,SMG7,SMG9 |
| SMG1,N2 |
| S1,S2,N2,N4 |
| N4,N2 |
| G1,G2 |
| G1,G2,C1 |
| G1,G2,N1 |
| SMG2, SMG1, SMG3, SMG4, SMG7, SMG9, SMG10, G1, G2, G3, N1, N3, T2 |
| SMG2,G1 |
| S1,G1,G2 |
| SMG1,N1,G1,G2 |
| G2,G1 |
| G1,G2,G3,S1,S2,SMG1,SMG2,SMG7,N1,N2,N3,N4,T2 |
| 23.003, 23.008, 29.060 |
| S1, S2, SMG1, SMG2, SMG12, G2, N1, N2, N4 |
| S1,S2,SMG1,SMG2,SMG12,G2,N1,N2,N4 |
| S1,SMG2,N1,N2,N4 |
| SMG1,T2 |
| S1,N1,N2,N4 |
| S1,S2,N5 |
| SMG2,SMG7,G2,T2 |
| S3,N1,N2,N3 |
| S3,N1,N2,N4 |
| SMG9,T3 |
| SMG2,SMG3,SMG7,G2,N2 |
| SMG2,N1,G1,G2 |
| S1,N2 |
| N1,N3 |
| S2,N1 |
| N1,N2,N4 |
| N2,N1,N4 |
| N2,N4 |
| S1,T3 |
| T2,N3 |
| S3,N2 |
| T2,S1 |
| S1,N4 |
| SMG1,SMG2,SMG7 |
| N1,S1,T1 |
| SMG1,SMG3 |
| N4,S2,N1 |
| S1,S2,SMG1,SMG2,SMG7,G1,G2,G3,N1,N2,N3,N4,T2 |
| SMG1,N3 |
| S1,N3 |
| CP,SP,SMG |
| CP,SP,TP,GP,SMG |
| NP,SP,TP,GP,SMG |
| NP,GP, RP,SP,TP |
| SMG2,SMG1,SMG3,SMG4,SMG7,SMG9,SMG10,G1,G2,G3,N1,N3,T2 |
| S1,N2,N4 |
| S1,S2,S3,C1,C3,C4,R2,R3 |
| R2,R3,R1,R4 |
| R2,R3,R4 |
| R2,R1,R3,R4 |
| S2,C4,R2,R3,R4 |
| S2,C4,R2,R1,R3,R4 |
| S2,S3,S5,C3,C4,R2,R3,R4 |
| R1,R2,R4 |
| R3,R1,R4 |
| S2, |
| S2,G2, |
| S1,S2,G2, |
| S1,S2,G2,R2,R3, |
| S1,S2,C4,G2,R2,R3 |
| S1,S2,N4,G2,R2,R3 |
| S1,S2,SMG1,SMG2,SMG12,G2,N1,N2,N4,R2,R3 |
| S1,SMG1,T2 |
| S1,SMG1,S2 |
| S1,N4,N2 |
| T2,N1,N3 |
| S3,N2,N4 |
| SMG1,SMG2,SMG3,SMG7,SMG9,N1,C1,N4,S1,T2,G2 |
| SMG1,N2,N4 |
| S2,T2,N1,N2,N4 |
| S1,T2 |
| S1,S2,C4 |
| S1,S2,N4,RP |
| S2,N4 |
| S1,S2,N3,N4,RP |
| S1,S2,SMG1,SMG2,SMG12,T2,G2,N1,N2,N4,R2,R3 |
| S1,T2,N1,N3 |
| S1,S2,SMG1,SMG2,SMG12,T2,G2,N1,N2,N3,N4,R2,R3 |
| S1,S2,S3,SMG1,SMG2,SMG12,G2,N1,N2,N4,R2,R3 |
| S1,S2,SMG,G1,G2,G3,N1,N2,N3,N4,T2 |
| S1,S2,SMG,T2,G2,N1,N2,N3,N4,R2,R3 |
| S1,S3,SMG,G1,G2,G3,N1,N2,N3,N4,T2 |
| S1,S3,T2,N2,N4 |
| S1,S2,SMG,T2,G1,G2,G3,N1,N2,N3,N4 |
| G2,S2 |
| T1,R5 |
| R5,T1 |
| S1,S2,S4,T1,R5 |
| S1,S2,S4,S5,T1,RP,GP |
| S1,S2,S3,S5,R2,R3,R4,GP,C1 |
| S1,S2,S3,SMG1,SMG2,SMG12,N1,N2,N4,R2,R3 |
| S1,S2,SMG,T2,N1,N2,N3,N4,R2,R3 |
| NP,SP,TP,SMG |
| S1,S2,SMG,T2,N1,N2,N3,N4 |
| SMG,N1 |
| SMG |
| S1,S2,SMG1,SMG2,SMG7,N1,N2,N3,N4,T2 |
| SMG2,SMG1,SMG3,SMG4,SMG7,SMG9,SMG10,N1,N3,T2 |
| S1,SMG |
| SMG2,SMG7,T2 |
| SMG2,S2 |
| N1,N2,N4,R3,S1,SMG |
| SMG2,SMG3,SMG7,N2 |
| SMG1,SMG2,SMG3,SMG7,SMG9,N1,C1,N4,S1,T2 |
| S1,S2,SMG,N3,N4,RP |
| S1,S2,S4,SMG,N3,N4,RP |
| S2,C1,C4,R2,R1,R3,R4 |
| R2,S2,S4 |
| G3new,R5 |
| GP,R4 |
| S2,S4,R2 |
| SP,GP |
| RP,SP |
| S2,S1,S3,S5 |
| S3,S1 |
| N4,N1,N2,S2 |
| S2,G1,G2,R2,R3 |
| S2,G1,G2 |
| G1,G2,R2,R3 |
| N4,T3 |
| S3,S2,N1,N4,T3,OMA |
| T2,S1,S4,S5,OMA |
| S2,N3 |
| S4,S1 |
| N4,N3,S1 |
| R5,G3new |
| R4,R2,R1 |
| S2,R2 |
| C3, C4,C1 |
| S3,C1,C4,C3 |
| C1,C4,C3 |
| S2,C1,C4,C3 |
| R3,R5 |
| S1,S2,C3 |
| R1,R2 |
| S3,C1,C4,G2,G3new |
| R1,R3 |
| GP,N1 |
| R1,R2,R3 |
| R3,R2,R4 |
| R4,R3 |
| S1,S2,R2,R3 |
| S1,S2,S3,C1,C3,C4,R2,R3,R5 |
| S2,S1,S5 |
| C4, C1 |
| C3, C1, C4 |
| S2,S1,S3,S5,C4,C1 |
| S2,C3,C1,C4 |
| S2,S1,S5,C3 |
| GP,S2,C1 |
| GP,S2,C1,G2 |
| G2,S2,C1 |
| v |
| G3new,G1,G2 |
| G1,G2,C1,G3new |
| S2,S1,S5,C1,C3 |
| C1,C3,C4,R5 |
| R2,R1 |
| S1<S2,N1,R2,R5 |
| S1,S2,N1,R2,R5 |
| S2,R5 |
| S1,S2,S5,R5 |
| S2,C1,C4,R2,R1,R3,R4,R5 |
| S1,S2,S3,S5,NP,R5 |
| S1,S2,S4,S5,RP,R5,GP |
| S1,S2,S3,S5,C1,C6,R2,R3,R4 |
| S1,S2,S3,S5,C1,C6,R2,R3,R4,GP |
| S4,R2 |
| S1,S2,C1,C4,G2 |
| S4,C3,C4 |
| S5,C1,C4 |
| S2,C4,C3,C1 |
| C4, C3, C1 |
| S2,S4,R2,C4,C3,C1 |
| GP1,GP2 |
| GP,GP1,GP2 |
| GP,G1,G2 |
| G2,R3 |
| S1,S2,S3,C1,C3,C4,G2 |
| GP,G1,C1 |
| S1,S2,C4,C3,C1 |
| - |
| GP,G1,G2,G3new |
| S1,S2,S3,C1,C3,C4,G2,R2,R3 |
| S1,S2,C1,C3,C4,G2,R2,R3 |
| C1,C6 |
| GP,G2,C4 |
| S2,C3 |
| R5,R4 |
| C4,GP,G2 |
| S1,S2,C1,C4,G2,R2,R3 |
| R1,R2,R4,S3 |
| S2,S5,C3,C1,C4 |
| S2,S4,C4,C3,C1 |
| S2,S4 |
| S3,S1,S2 |
| S1,S2,S3,C1,R2 |
| S3,S1,S2,C1,R2 |
| S2,C3,S5 |
| S1,S2,C1,C4,C3,G2,R2,R3 |
| S5,C4 |
| S2,S1,C3 |
| C1,C4,C3,C6 |
| S1,S2,C1,C4,C3,C6,G2,R2,R3 |
| R1,R2,R4,S3,C4,C6 |
| R4,R1,R4,R1,R2,R3,R3 |
| S2,R3,R2 |
| S1,S2,S5,CP |
| S1,S3,CP |
| C6,C1 |
| R4,R2,R1,R3 |
| R3,R1,R2 |
| R1,R4,R2,R3 |
| S2,C4,C1,C3 |
| R3,R1,R2,R4 |
| C4,S1 |
| S2,S5,R3,GP, |
| S2,S5,R3,GP |
| S1,S2,S3,S5,C1,C3,C4 |
| S2,S3,S5,C1,C3,C4,C6 |
| S5,S1 |
| 03.06.2011 |
| CT1 CT3, CT4 |
| CT3, |
| CT4 |
| CT3 |
| GP,G2,G1 |
| S5,S1,C1 |
| SP,RP,CP |
| SP,CP,GP,RP |
| R1,R2,R4,R3 |
| R4,R2,R5 |
| R2,R4,R5 |
| R1,R2,R4,S2,S3,C4,C6 |
| C1-IETF |
| S4-IETF |
| C1-IETF, C3-IETF, C4-IETF |
| S3-IETF |
| C4-IETF |
| C1-IETF, C3-IETF |
| S2,S4,C1,R2 |
| S2,S4,C3,C4 |
| S2,S4,C1,C3,R2 |
| S1,S2,C1,IETF |
| S4,IETF |
| C1,C4,IETF |
| S2,S4,C1,C3,R2,IETF |
| S3,C1,C4,C3,IETF |
| S3,C4,IETF |
| C1,IETF |
| S1,S2,S3,S5,C1,C3,C4,C6,IETF |
| S2,S3,C1,C4,IETF |
| S1,S2,C1,C3,C4,IETF |
| C1,C3,C4,IETF |
| S1,S5,C1,C3,C4,IETF |
| C1,C3,IETF |
| S2,C1,C3,C4,IETF |
| S2,S4,C3,C4,IETF |
| S5,C1,C4,IETF |
| S5,C1,C3,C4,IETF |
| S2,S3,S5,C1,C3,C4,IETF |
| S2,IETF |
| S3,C1,C3,C4,IETF |
| S2,S3,C1,C3,C4,IETF |
| S3,S2 |
| S3,S2,C1 |
| S3,S1,S2,C1 |
| S2,S5,N3 |
| S1,S2,S3,S5,N1,N3,N4,T3 |
| S5,N4,R3 |
| S1,S2,S5,C1,C4,C3,C6,G2,R2,R3 |
| S2,N1,N4,R3,GP |
| T2,S3 |
| S3,N4,N1 |
| S2,N3,N4 |
| S3,T2 |
| S2,S1,S3,S5,RP,GP |
| S1,S2,S3,S5,R5 |
| S1,S2,S3,S5,NP,T3,T1,R5 |
| S3,T3 |
| GP,S3 |
| S1,S2,S3,S4,S5,RP,R5,GP |
| N1,N4 |
| S1,S2,S3,S4,N1,N3,N4,OMA |
| S2,C1,C3,C4,G2,R2,R3 |
| S1,C4,C3 |
| S2,S1,C1,C4,IETF |
| C1,C3,C4,C6 |
| C4,C1,C6 |
| S1,S2,S3,C1,C3,C4,C6 |
| S2,S1,C1,C3,C4 |
| S1,S2,C1,C3 |
| C1.IETF |
| C1-IETF,C4-IETF |
| G1,C1 |
| G1,S2,C4 |
| G2,S2,C4 |
| R1,R2,R3,R4,R5 |
| R2,R4,R3,R5 |
| R3,R2,R5 |
| R2,R3,C1,C6 |
| S1,S2,S3,C1,C3,C4,C6,R2,R3 |
| R4,R1 |
| S2,S4,C4,C3,C1,IETF |
| S2,C4,C3 |
| S3.C4,C1 |
| G2,C4 |
| R4,G1,G3new |
| C4,G2 |
| S3,C4,C1 |
| R2,R3,R5 |
| R1,R2,R4,R5 |
| S1,S2,S3,S5,C1,C6,R2,R3,R4,R5,GP |
| S1,C1,C4,R2,R5 |
| S2,S3,S5,C3,C4,R2,R3,R4,R5 |
| R2,R1,R3,R4,R5 |
| S3-IETF, C1-IETF |
| S3-IETF,C1-IETF |
| C1-IETF,C3-IETF |
| S2-IETF |
| S2,S1,C1,C3,C4,IETF |
| 25.101, 25.104, 25.141, 25.317 |
| S1,G2,S2,C1 |
| S1,C1,C4,R2,R3,R5 |
| S5,S2 |
| S4,C3,C4,IETF |
| S4,S3,C3,C4,IETF |
| S4,S3,C3,C4 |
| S4,S3,IETF |
| S1,S2,S3,S5,C1,C3,C4,C6,R2,R3 |
| C1,C4,C6 |
| S1,S2,S5,C1,C4,C6,G2,R2,R3 |
| GP,G1,C1,G3new |
| S2,S5,C1,C3 |
| C4,C3,G2 |
| S2,S1,S5,C3,C1,C4 |
| C3,C4,C1 |
| S2,S1,S5,C3,C4,C1 |
| RAN1 |
| RAN2 |
| RAN3 |
| RAN4 |
| R4,R2,R3, |
| Feasibility Study on LTE Device to Device Communications – Radio Aspects |
| SMG1,SMG2,SMG3,SMG7,SMG9,N1,N4,S1,T2 |
| C3-IETF, C4-IETF |
| S3-IETF,C1-IETF,C3-IETF |
| C3-IETF |
| C3,IETF |
| S2,C1,C4,C3,IETF |
| S1,S2,S3,C1,C3,C4,R2,R3,R5,IETF |
| C1-IETF,C3-IETF,C4-IETF |
| C4,C1,C3,IETF |
| S2,C4,C1,C3,IETF |
| C1,C4,C3,IETF |
| S2,S1,T2,N1,N4,R3,R2 |
| S2,S1,S2,S1,N1,N4 |
| S2,S1,N1,N4 |
| S2,R2,G1 |
| S2,S1,S3,S5,N4,R2,R3,GP |
| S1,S2,N4 |
| S2,OMA |
| S2,N4,OMA |
| S2,S5,N4,R2,R4 |
| S2,S5,N4,R2,R4,OMA |
| GP,R2 |
| S1,S2,GP,R2 |
| G1,G3 |
| S1,G2,R2 |
| S2,S5,N4,R2,R4,R5,OMA |
| SR5 |
| S3,C4,C1,R5 |
| S3,S1,C1 |
| S2,C4,C3,G2 |
| SP,CP,RP |
| S3,R5 |
| GP,G2,G3new |
| S1,S2,S3,S4,S5,N1,N3,RP,R5,GP |
| S1,S2,S3,S4,S5,N1,N3,RP,R5,T1,GP |
| S1,S2,S3,S4,S5,N1,N3,RP,R5,T1,GP,G2,G3new |
| S1,S2,S3,S4,S5,N1,N3,R2,R4,R5,T1,GP,G2,G3new |
| S1,S2,S5,C1,C4,C6,G2,R2,R3,G3new |
| SP,CP,RP,GP |
| G2,G1,G3new |
| G2,G1,C1,G3new |
| RAN |
| R |
| S2,S1,S3,S5,R2 |
| S2,S1,S3,S5,R2,R3 |
| S1,S2,S5,C1,C4,C6,G2,R2,R3,R5,G3new |
| C1,C4,R5,IETF |
| C1,R5 |
| R3,R1 |
| R3,GP |
| S3,IETF |
| S1,S2,S5,C1,C3,C4,C6,R2,R3 |
| S3,C4,C1,C3 |
| C1,C4,S1 |
| C1,C4,R3 |
| R2,R1,R3 |
| R1,R4,R2,R3,R5 |
| RAN5 |
| S2,C4,C1,R3 |
| G1,G2,G3new |
| S4,C1 |
| S4,C4,C1,C3 |
| 14/06/2013 08:00 |
| S2,C1,C3,IETF |
| C3, C1 |
| R3,C4 |
| S2,S1,C1,C3 |
| R3,S2,C4 |
| R% |
| G1,C1,G3new |
| R3,S2,C4,G2 |
| S1,S3,N4 |
| S1,OMA |
| S1,S2,S4,OMA |
| S5,S2,N3 |
| S3,C4,C1,C3,IETF |
| S1,S2,S5,C1,C3,C4,C6,R2,R3,R5 |
| S2,S1,S5<c3 |
| S2,C1,C4,C6 |
| S2,S1,S3,C1,C4,C6 |
| S2,S1,S3,C1 |
| R2,R3,R4,G2,G1,G3new |
| C1,C3,R5 |
| ,C4,C6 |
| S2,S1,S3,C1,C4,C6,R2 |
| S2,S1,S3,C1,C4,C6,R2,R3 |
| S2,S1,S3,C1,C3,C4,C6,R2,R3 |
| S1,S2,S3,IETF |
| S1,S2,S3,C1,C3 |
| S1,S2,S3,C4,C1,C3 |
| C1,S1 |
| C34 |
| S1,S2,S3,C1,C4,IETF |
| IETF |
| SMG12 |
| SMG7 |
| SMG3 |
| SMG4 |
| SMG10 |
| C3-IETF,C4-IETF |
| NP,GP,RP,SP,TP |
| S3,G2 |
| R2,S2 |
| R2,S2,C1 |
| R2,C1 |
| S1` |
| R2,S1,C1 |
| C1-IET |
| 18/06/2014 08:00 |
| C4-IET |
| RAN1 (primary) |
| C3.S2 |
| C3-IET |
| S6 |
| ` |
| SA5 |
| Rel-13 |
| Rel-14 |
| 18/06/2015 |
| SA2 |
| S3-IET |
| SA1 |
| SA4-IETF |
| R6 |
| S3LI |
| ITU-R AH |

## Schedule

| ID | WBS | Task | Type | Duration | Start | Finish | Complete | Remaining | Total slack | Constraint | Resources | Work | Actual work | Release | Acronym | WI rapporteur name | WI rapporteur e-mail | PCG approved | TSG approved |
| --- | --- | --- | --- | --- | --- | --- | --- | --- | --- | --- | --- | --- | --- | --- | --- | --- | --- | --- | --- |
| 1 | 1 | Work Plan 3GPP version March 21st 2017 |  | 1d? | 2000-01-03 | 2000-01-03 |  |  | 4967d |  |  |  |  |  |  |  |  |  |  |
| 2 | 2 | This version includes the results from TSG#75 |  | 1d? | 2000-01-03 | 2000-01-03 |  |  | 4967d |  |  |  |  |  |  |  |  |  |  |
| 3 | 3 | Rel-14 Stage 3 was March 17, several exceptions ongoing |  | 1d? | 2000-01-03 | 2000-01-03 |  |  | 4967d |  |  |  |  |  |  |  |  |  |  |
| 4 | 4 | Next targets: Rel-15: St.1: 06/17; St.2: 12/17; St.3: 06/18 |  | 1d? | 2000-01-03 | 2000-01-03 |  |  | 4967d |  |  |  |  |  |  |  |  |  |  |
| 6 | 5 | Release 16 Studies | milestone | 0d? | 2016-03-15 A | 2016-03-15 A | 100% |  |  | start no earlier than 2016-03-15 |  |  |  | Rel-16 |  |  |  |  |  |
| 7 | 6 | Study on self-evaluation towards IMT-2020 submission |  | 393d? | 2017-03-15 | 2018-09-15 |  |  | 69d | finish no earlier than 2018-09-15 | ITU-R AH | 3144h |  | Rel-16 | FS_5G_eval | Huawei |  |  |  |
| 8 | 7 | Release 15 Features | milestone | 0d? | 2016-03-15 A | 1985-07-05 A | 100% |  |  | start no earlier than 2016-03-15 |  |  |  | Rel-15 |  |  |  |  |  |
| 9 | 8 | Release 15 Features on 5G | milestone | 0d? | 2016-06-09 A | 2016-06-09 A | 100% |  |  | finish no earlier than 2016-06-09 |  |  |  | Rel-15 |  |  |  |  |  |
| 10 | 9 | **5G System - Phase 1** |  | 462d? | 2016-06-09 A | 2018-03-15 | 17% | 384.5d? | 200d |  | S2 | 17840h | 3312.3h | Rel-15 | 5GS_Ph1 | China Mobile, Tao Sun | suntao@chinamobile.com |  |  |
| 11 | 9.1 | (Stage 1 of 5G) New Services and Markets Technology Enablers |  | 201d? | 2016-06-09 A | 2017-03-15 | 90% | 20.1d? | 461d | finish no earlier than 2017-03-15 | S1 | 1608h | 1447.2h | Rel-15 | SMARTER | Li, Alice | alice.li@vodafone.com | PCG-37 | TSG#72 |
| 12 | 9.2 | Stage 2 of 5G System - Phase 1 |  | 271d? | 2016-12-01 A | 2017-12-14 | 30% | 189.7d? | 265d | finish no earlier than 2017-12-14 | S2 | 2168h | 650.4h | Rel-15 | 5GS_Ph1 | China Mobile, Tao Sun | suntao@chinamobile.com |  |  |
| 13 | 9.3 | Security aspects of 5G System - Phase 1 |  | 271d? | 2017-03-02 | 2018-03-15 |  |  | 200d | finish no earlier than 2018-03-15 | S3 | 2168h |  | Rel-15 | 5GS_Ph1-SEC | NTT DOCOMO, Alf Zugenmaier | alf.zugenmaier@hm.edu |  |  |
| 14 | 9.4 | **CT aspects on 5G System - Phase 1** |  | 205d? | 2017-03-03 | 2017-12-14 |  |  | 265d |  | ct | 8200h |  | Rel-15 | 5GS_Ph1-CT | Zhang Hao (China Mobile) | Zhanghao at chinamobile.com |  |  |
| 15 | 9.4.1 | CT1 aspects on 5G System - Phase 1 |  | 205d? | 2017-03-03 | 2017-12-14 |  |  | 265d | finish no earlier than 2017-12-14 | C1 | 1640h |  | Rel-15 | 5GS_Ph1-CT | Herrero Veron, Christian (Huawei) | Christian.Herrero at huawei.com |  |  |
| 16 | 9.4.2 | CT3 aspects on 5G System - Phase 1 |  | 205d? | 2017-03-03 | 2017-12-14 |  |  | 265d | finish no earlier than 2017-12-14 | C3 | 1640h |  | Rel-15 | 5GS_Ph1-CT | Fernandez, Susana (Ericsson) | Susana.Fernandez at ericsson.com |  |  |
| 17 | 9.4.3 | CT4 aspects on 5G System - Phase 1 |  | 205d? | 2017-03-03 | 2017-12-14 |  |  | 265d | finish no earlier than 2017-12-14 | C4 | 1640h |  | Rel-15 | 5GS_Ph1-CT | Landais, Bruno (Nokia) | Bruno.Landais at nokia.com |  |  |
| 18 | 9.4.4 | CT6 aspects on 5G System - Phase 1 |  | 205d? | 2017-03-03 | 2017-12-14 |  |  | 265d | finish no earlier than 2017-12-14 | C6 | 1640h |  | Rel-15 | 5GS_Ph1-CT | Berionne, Michele (Qualcomm) | Michele.Berionne at qti.qualcomm.com |  |  |
| 19 | 10 | **EPC enhancements to support 5G New Radio via Dual Connectivity** |  | 141d? | 2017-03-02 | 2017-09-14 |  |  | 330d |  |  | 2256h |  | Rel-15 | EDCE5 | Chris Pudney, Vodafone Group | Chris Pudney, Vodafone Group |  |  |
| 20 | 10.1 | SA2 aspects of EDCE5 |  | 141d? | 2017-03-02 | 2017-09-14 |  |  | 330d | finish no earlier than 2017-09-14 | S2 | 1128h |  | Rel-15 | EDCE5 | Chris Pudney, Vodafone Group |  |  |  |
| 21 | 10.2 | SA3 aspects of EDCE5 |  | 141d? | 2017-03-02 | 2017-09-14 |  |  | 330d | finish no earlier than 2017-09-14 | S3 | 1128h |  | Rel-15 | EDCE5 | Adrian Escott, Qualcomm Incorporated |  |  |  |
| 22 | 11 | **New Radio Access Technology** |  | 458d? | 2017-03-15 | 2018-12-15 |  |  | 4d |  | R1 | 9952h |  | Rel-15 | NR_newRAT | NTT DOCOMO |  |  |  |
| 23 | 11.1 | Core part: New Radio Access Technology |  | 328d? | 2017-03-15 | 2018-06-15 |  |  | 134d | finish no earlier than 2018-06-15 | R1 | 2624h |  | Rel-15 | NR_newRAT-Core | NTT DOCOMO |  |  |  |
| 24 | 11.2 | Perf. part: New Radio Access Technology |  | 458d? | 2017-03-15 | 2018-12-15 |  |  | 4d | finish no earlier than 2018-12-15 | R4 | 3664h |  | Rel-15 | NR_newRAT-Perf | NTT DOCOMO |  |  |  |
| 25 | 12 | **LTE connectivity to 5G-CN** |  | 328d? | 2017-03-15 | 2018-06-15 |  |  | 134d |  | R2 | 5248h |  | Rel-15 | LTE_5GCN_connect | Huawei |  |  |  |
| 26 | 12.1 | Core part: LTE connectivity to 5G-CN |  | 328d? | 2017-03-15 | 2018-06-15 |  |  | 134d | finish no earlier than 2018-06-15 | R2 | 2624h |  | Rel-15 | LTE_5GCN_connect-Core | Huawei |  |  |  |
| 27 | 13 | Release 15 Features on V2X | milestone | 0d? | 2016-06-09 A | 2016-06-09 A | 100% |  |  | finish no earlier than 2016-06-09 |  |  |  | Rel-15 |  |  |  |  |  |

Notes:
- 6: -
- 7: TR 38.9XX
- 8: -
- 9: -
- 10: Impacted TSs and TRs: TS 23.228, TS 23.401, TS 23.167, TS 23.271, TS 23.002, 23.502, 23.501
- 11: Resulting from FS_SMARTER; 19/9/16: 0%->55; 6/10/16: 22.261 added; 1/12/16: FCD:09/16->03/20; 1/12/16: 55%->75; 2/3/17: 75%->90 / Impacted TSs and TRs: 22.261
- 12: 3/3/17: 0%->30 / Impacted TSs and TRs: TS 23.228, TS 23.401, TS 23.167, TS 23.271, TS 23.002
- 22: follow-up WI of REL-14 SI FS_NR_newRAT completed at RAN #75
- 23: follow-up WI of REL-14 SI FS_NR_newRAT completed at RAN #75
- 24: follow-up WI of REL-14 SI FS_NR_newRAT completed at RAN #75
- 25: no Perf. part
- 26: no Perf. part
- 27: -

| ID | WBS | Task | Type | Duration | Start | Finish | Complete | Remaining | Total slack | Constraint | Resources | Work | Actual work | Acronym | WI rapporteur name | WI rapporteur e-mail | Release | PCG approved | Impacted TSs and TRs | TSG approved |
| --- | --- | --- | --- | --- | --- | --- | --- | --- | --- | --- | --- | --- | --- | --- | --- | --- | --- | --- | --- | --- |
| 28 | 14 | **Enhancement of 3GPP support for V2X scenarios** |  | 206d? | 2016-06-09 A | 2017-03-22 | 97% | 5.74d? | 456d |  |  | 1520h | 1477.6h | eV2X | Chun, SungDuck, LG Electronics | sungduck.chun@lge.com | Rel-15 |  |  |  |
| 29 | 14.1 | Study on Enhancement of 3GPP support for V2X services |  | 137d? | 2016-06-09 A | 2016-12-15 A | 100% |  |  | finish no earlier than 2016-12-15 | S1 | 1096h | 1096h | FS_eV2X | LG Electronics, SungDuck Chun | sungduck.chun@lge.com | Rel-15 | PCG-37 | 22.886 | TSG#72 |
| 30 | 14.2 | Stage 1 of Enhancement of 3GPP support for V2X scenarios |  | 53d? | 2017-01-09 A | 2017-03-22 | 90% | 5.3d? | 456d | finish no earlier than 2017-03-22 | S1 | 424h | 381.6h | eV2X | Chun, SungDuck, LG Electronics | sungduck.chun@lge.com | Rel-15 |  | 22.186 |  |
| 31 | 15 | **V2X new band combinations for LTE** |  | 198d? | 2017-03-15 | 2017-12-15 |  |  | 264d |  | R4 | 3168h |  | LTE_V2X_CA_bands | LG Electronics |  | Rel-15 |  |  |  |
| 32 | 15.1 | Core part: V2X new band combinations for LTE |  | 198d? | 2017-03-15 | 2017-12-15 |  |  | 264d | finish no earlier than 2017-12-15 | R4 | 1584h |  | LTE_V2X_CA_bands-Core | LG Electronics |  | Rel-15 |  |  |  |
| 33 | 16 | **Enhancements on LTE-based V2X Services** |  | 458d? | 2017-03-15 | 2018-12-15 |  |  | 4d |  | R1 | 9952h |  | LTE_eV2X | Huawei |  | Rel-15 |  |  |  |
| 34 | 16.1 | Core part: Enhancements on LTE-based V2X Services |  | 328d? | 2017-03-15 | 2018-06-15 |  |  | 134d | finish no earlier than 2018-06-15 | R1 | 2624h |  | LTE_eV2X-Core | Huawei |  | Rel-15 |  |  |  |
| 35 | 16.2 | Perf. part: Enhancements on LTE-based V2X Services |  | 458d? | 2017-03-15 | 2018-12-15 |  |  | 4d | finish no earlier than 2018-12-15 | R4 | 3664h |  | LTE_eV2X-Perf | Huawei |  | Rel-15 |  |  |  |
| 36 | 17 | Study on security aspects for LTE support of V2X services |  | 465d? | 2015-09-07 A | 2017-06-15 | 90% | 46.5d? | 395d | finish no earlier than 2017-06-15 | S3 | 3720h | 3348h | FS_V2XLTE | Huawei, Marcus Wong | mwong@huawei.com | Rel-15 | PCG-36 | TR 33.885 | SP-70 |
| 37 | 18 | Release 15 Features on improvements of Mission Critical | milestone | 0d? | 2016-06-09 A | 2016-06-09 A | 100% |  |  | finish no earlier than 2016-06-09 |  |  |  |  |  |  | Rel-15 |  |  |  |
| 38 | 19 | Enhancements for functional architecture and information flows for MCPTT |  | 205d? | 2017-03-03 | 2017-12-14 |  |  | 265d | finish no earlier than 2017-12-14 | S6 | 1640h |  | enhMCPTT | Dom Lazara, Motorola Solutions | dom.lazara@motorolasolutions.com | Rel-15 |  | TS 23.280 + TS 23.379 |  |
| 39 | 20 | Enhancements to Functional architecture and information flows for Mission Critical Data |  | 205d? | 2017-03-03 | 2017-12-14 |  |  | 265d | finish no earlier than 2017-12-14 | S6 | 1640h |  | eMCData | Howell, Andrew, Home Office | ahowell@cellulartechnologies.co.uk | Rel-15 |  | 23.280 + TS 23.282 |  |
| 40 | 21 | MBMS usage for mission critical communication services |  | 140d? | 2017-03-03 A | 2017-09-14 |  | 140d? | 330d | finish no earlier than 2017-09-14 | S6 | 1120h |  | MBMS_Mcservices | Magnus Tränk, Ericsson | magnus.trank@ericsson.com | Rel-15 |  | TS 23.280 + TS 23.281 + TS 23.282 + TS 23.379 |  |
| 41 | 22 | Release 15 Features on MTC-IoT | milestone | 0d? | 2016-06-09 A | 2016-06-09 A | 100% |  |  | finish no earlier than 2016-06-09 |  |  |  |  |  |  | Rel-15 |  |  |  |
| 42 | 23 | Battery Efficient Security for very low Throughput MTC Devices |  | 260d? | 2016-09-19 A | 2017-09-15 | 20% | 208d? | 329d | finish no earlier than 2017-09-15 | S3 | 2080h | 416h | BEST_MTC_Sec | Evans, Tim, VODAFONE Group Plc. |  | Rel-15 | PCG-37 | 33.401, 43.020, 33.220; 33.163 | TSG-73 |
| 43 | 24 | **Even further enhanced MTC for LTE** |  | 458d? | 2017-03-15 | 2018-12-15 |  |  | 4d |  | R1 | 9952h |  | LTE_eMTC4 | Ericsson |  | Rel-15 |  |  |  |
| 44 | 24.1 | Core part: Even further enhanced MTC for LTE |  | 328d? | 2017-03-15 | 2018-06-15 |  |  | 134d | finish no earlier than 2018-06-15 | R1 | 2624h |  | LTE_eMTC4-Core | Ericsson |  | Rel-15 |  |  |  |
| 45 | 24.2 | Perf. part: Even further enhanced MTC for LTE |  | 458d? | 2017-03-15 | 2018-12-15 |  |  | 4d | finish no earlier than 2018-12-15 | R4 | 3664h |  | LTE_eMTC4-Perf | Ericsson |  | Rel-15 |  |  |  |
| 46 | 25 | **Further NB-IoT enhancements** |  | 458d? | 2017-03-15 | 2018-12-15 |  |  | 4d |  | R1 | 9952h |  | NB_IOTenh2 | Huawei |  | Rel-15 |  |  |  |
| 47 | 25.1 | Core part: Further NB-IoT enhancements |  | 328d? | 2017-03-15 | 2018-06-15 |  |  | 134d | finish no earlier than 2018-06-15 | R1 | 2624h |  | NB_IOTenh2-Core | Huawei |  | Rel-15 |  |  |  |
| 48 | 25.2 | Perf. part: Further NB-IoT enhancements |  | 458d? | 2017-03-15 | 2018-12-15 |  |  | 4d | finish no earlier than 2018-12-15 | R4 | 3664h |  | NB_IOTenh2-Perf | Huawei |  | Rel-15 |  |  |  |
| 49 | 26 | Release 15 Features | milestone | 0d? | 2016-06-09 A | 2016-06-09 | 39% | 0d? | 662d |  |  |  |  |  |  |  | Rel-15 |  |  |  |
| 50 | 27 | **Mobile Communication System for Railways** |  | 397d? | 2016-06-09 A | 2017-12-14 | 39% | 242.26d? | 265d |  |  | 4384h | 1708.8h | MONASTERY | Merkel, Juergen, Nokia | juergen.merkel@nokia.com | Rel-15 |  |  |  |
| 51 | 27.1 | Study on Future Railway Mobile Communication System |  | 267d? | 2016-06-09 A | 2017-06-15 | 80% | 53.4d? | 395d | finish no earlier than 2017-06-15 | S1 | 2136h | 1708.8h | FS_FRMCS | Merkel, Juergen | Merkel, Juergen - Nokia Networks | Rel-15 | PCG-37 | 22.989 | TSG#72 |
| 52 | 27.2 | Study on Application Architecture for the Future Railway Mobile Communication System (stage 2) |  | 205d? | 2017-03-03 | 2017-12-14 |  |  | 265d | finish no earlier than 2017-12-14 | S6 | 1640h |  | FS_FRMCS_ARCH | Oettl, Martin, Nokia | martin(dot)oettl(at)nokia(dot)com | Rel-15 |  | new TR 23.790 |  |
| 53 | 27.3 | Mobile Communication System for Railways |  | 76d? | 2017-03-02 | 2017-06-15 |  |  | 395d | finish no earlier than 2017-06-15 | S1 | 608h |  | MONASTERY | Merkel, Juergen, Nokia | juergen.merkel@nokia.com | Rel-15 |  |  |  |

Notes:
- 29: 19/9/16: 30%->70; 6/10/16: 22.886 added; 1/12/16: 70%->95; 2/3/17: 95%->100
- 31: no Perf. part
- 32: no Perf. part
- 33: follow-up WI of REL-14 WI LTE_V2X for which the Core part was completed at RAN #75
- 34: follow-up WI of REL-14 WI LTE_V2X for which the Core part was completed at RAN #75
- 35: follow-up WI of REL-14 WI LTE_V2X for which the Core part was completed at RAN #75
- 36: 11/12/15: WID:SP-150715->SP-150743. 28/01/16: typo on name corrected, WD corrected (was SP-150743); 7/3/16: 0%->10; 19/9/16: 10%->65; 1/12/16: 65%->85; 6/3/17: 85%->90; 21/3/17: FCD shifted, moved from Rel-14; 21/3/17: FCD:09/16->06/17
- 37: -
- 38: 21/3/17: impacted TS/TR added
- 39: 21/3/17: impacted TS/TR added
- 40: 21/3/17: impacted TS/TR added
- 41: -
- 42: 6/10/16: 33.163 added 6/3/17: FCD:12/16->09/17; 6/3/17: 0%->20. Moved from Rel-14.
- 43: WI LTE_feMTC-Core got a 3 months exception granted by RAN #75 to complete in REL-14; note: RAN #75 approved WID RP-170732 with working agreement
- 44: WI LTE_feMTC-Core got a 3 months exception granted by RAN #75 to complete in REL-14; note: RAN #75 approved WID RP-170732 with working agreement
- 45: note: RAN #75 approved WID RP-170732 with working agreement
- 46: follow-up WI of REL-14 WI NB_IOTenh which got an exception granted at RAN #75 to complete by RAN #76; note: RAN #75 approved WID RP-170852 with working agreement
- 47: follow-up WI of REL-14 WI NB_IOTenh which got an exception granted at RAN #75 to complete by RAN #76; note: RAN #75 approved WID RP-170852 with working agreement
- 48: follow-up WI of REL-14 WI NB_IOTenh which got an exception granted at RAN #75 to complete by RAN #76; note: RAN #75 approved WID RP-170852 with working agreement
- 49: -
- 51: 19/9/16: 0%->25; 6/10/16: 22.989 added; 1/12/16: 25%->40; 1/12/16: WID:SP-160371->SP-160903; 9/12/16: FCD:12/16->3/201. WID was in SP-160903; 2/3/17: 40%->80; 2/3/17: FCD:03/17->06/17
- 52: 21/3/17: added impacted TR

| ID | WBS | Task | Type | Duration | Start | Finish | Complete | Remaining | Baseline start | Baseline finish | Baseline duration | Total slack | Constraint | Resources | Work | Actual work | Acronym | Impacted TSs and TRs | WI rapporteur name | WI rapporteur e-mail | Release | PCG approved | TSG approved | MCC resp | Acronym_3GU_Export |
| --- | --- | --- | --- | --- | --- | --- | --- | --- | --- | --- | --- | --- | --- | --- | --- | --- | --- | --- | --- | --- | --- | --- | --- | --- | --- |
| 54 | 28 | **Inclusion of WLAN direct discovery technologies as an alternative for ProSe direct discovery** |  | 153d? | 2016-11-15 A | 2017-06-15 | 65% | 52.85d? |  |  |  | 395d |  |  | 792h | 518.4h | ProSe_WLAN_DD | 22.278 | Intel Corporation; Ana Lucia Pinheiro | ana.lucia.a.pinheiro@intel.com | Rel-15 |  |  |  |  |
| 55 | 28.1 | Stage 1 of ProSe_WLAN_DD |  | 23d? | 2016-11-15 A | 2016-12-15 A | 100% |  |  |  |  |  | finish no earlier than 2016-12-15 | S1 | 184h | 184h | ProSe_WLAN_DD | 22.278 | Intel Corporation; Ana Lucia Pinheiro | ana.lucia.a.pinheiro@intel.com | Rel-15 |  |  |  |  |
| 56 | 28.2 | Stage 2 of ProSe_WLAN_DD |  | 76d? | 2017-03-02 A | 2017-06-15 | 55% | 34.2d? |  |  |  | 395d | finish no earlier than 2017-06-15 | S2 | 608h | 334.4h | ProSe_WLAN_DD_Stage2 |  | Intel, Sašo Stojanovski | saso.stojanovski@intel.com | Rel-15 |  |  |  |  |
| 57 | 29 | PS Data Off Phase 2 |  | 142d? | 2017-03-02 | 2017-09-15 |  |  |  |  |  | 329d | finish no earlier than 2017-09-15 | S2 | 1136h |  | PS_DATA_OFF2 |  | Murhammer, Leopold, Deutsche Telekom AG | leopold.murhammer@t-mobile.at | Rel-15 |  |  |  |  |
| 58 | 30 | Northbound APIs for SCEF – SCS/AS Interworking |  | 142d? | 2017-03-02 A | 2017-09-15 | 10% | 127.8d? |  |  |  | 329d | start no earlier than 2017-03-02 | S2 | 1136h | 113.6h | NAPS |  | Vaidya, Maulik, Huawei | Maulik.vaidya@huawei.com | Rel-15 |  |  |  |  |
| 59 | 31 | Security Assurance Specification for eNB network product class |  | 194d? | 2016-09-19 A | 2017-06-15 | 25% | 145.5d? |  |  |  | 395d | finish no earlier than 2017-06-15 | S3 | 1552h | 388h | SCAS_eNB | TS 33.117, TR 33.926; 33.216 | Marcus Wong, Huawei Technologies | mwong@huawei.com | Rel-15 | PCG-37 | TSG-73 |  |  |
| 60 | 32 | Enhanced Calling Name Service |  | 66d? | 2016-09-15 A | 2016-12-15 A | 100% |  |  |  |  |  | finish no earlier than 2016-12-15 | S1 | 528h | 528h | eCNAM | 22.173 | Hala Mowafy, Ericsson |  | Rel-15 | PCG-37 | TSG-73 |  |  |
| 61 | 33 | Enhancement of background data transfer |  | 38d? | 2017-01-16 A | 2017-03-08 A | 100% |  |  |  |  |  | finish no earlier than 2017-03-08 | S1 | 304h | 304h | eBT | 22.101 | Atsushi Minokuchi, NTT DOCOMO | minokuchi at nttdocomo dot com | Rel-15 |  |  |  |  |
| 62 | 34 | **Security Assurance Specification for 3GPP network products** |  | 924d? | 2013-12-09 A | 2017-06-15 | 95% | 43d? | 2013-12-09 | 2015-03-18 | 334d? | 395d |  | S3 | 23192h | 15716.5h | SCAS | 33.199; 33.926, 33.117; 33.250 | NTT DOCOMO | Alf Zugenmaier (alf.zugenmaier@hm.edu) | Rel-15 | PCG-32 | SP-62 | Mirko | SCAS |
| 63 | 34.1 | STOPPED - TR on Pilot development of Security Assurance Specification for MME network product class |  | 266d? | 2013-12-09 A | 2014-12-12 A | 100% |  | 2013-12-09 | 2014-12-10 | 264d? |  | finish no earlier than 2014-12-12 | S3 | 2120h | 2120h | SCAS-SA3Pil_TR | New TR 33.806 | NTT DOCOMO | Alf Zugenmaier (alf.zugenmaier@hm.edu) | Rel-14 | PCG-32 | SP-62 | Mirko |  |
| 64 | 34.2 | TR on Security Assurance scheme for 3GPP network products |  | 791d? | 2013-12-09 A | 2016-12-15 A | 100% |  | 2013-12-09 | 2014-12-10 | 264d? |  | finish no earlier than 2016-12-15 | S3 | 6320h | 6320h | SCAS-SA3TR | New TR 33.916; 33.216 | NTT DOCOMO | Alf Zugenmaier (alf.zugenmaier@hm.edu) | Rel-14 | PCG-32 | SP-62 | Mirko |  |
| 65 | 34.3 | Security Assurance Specification for 3GPP network product classes |  | 920d? | 2013-12-13 A | 2017-06-15 | 90% | 92d? | 2013-12-10 | 2015-03-18 | 333d? | 395d | finish no earlier than 2017-06-15 | S3 | 7360h | 6624h | SCAS-SA3 | New TS 33.116, 33.117; 33.250 | China Mobile | Judy Zhu (zhuhongru@chinamobile.com) | Rel-15 | PCG-32 | SP-62 | Mirko |  |
| 66 | 35 | HPLMN Radio Access Technology deployment Optimisation in Network Selection |  | 76d? | 2017-03-02 A | 2017-06-15 | 75% | 19d? |  |  |  | 395d | finish no earlier than 2017-06-15 | S1 | 608h | 456h | HORNS |  | Eddy Hall, Qualcomm Incorporated | edhall@qti.qualcomm.com | Rel-15 |  |  |  |  |
| 67 | 36 | **Lawful Interception Rel-15** |  | 467d? | 2017-03-02 | 2018-12-14 |  |  |  |  |  | 4d |  |  | 6424h |  | LI15 |  | Alex Leadbeater, BT | alex.leadbeater@bt.com | Rel-15 |  |  |  |  |
| 68 | 36.1 | Study on R15 Lawful Interception Service |  | 336d? | 2017-03-02 | 2018-06-14 |  |  |  |  |  | 135d | finish no earlier than 2018-06-14 | S3LI | 2688h |  | FS_15LIS |  | Gerry McQuaid, Vodafone | Gerald.McQuaid@vodafone.com | Rel-15 |  |  |  |  |
| 69 | 36.2 | Normative work on Lawful Interception Rel-15 |  | 467d? | 2017-03-02 | 2018-12-14 |  |  |  |  |  | 4d | finish no earlier than 2018-12-14 | S3LI | 3736h |  | LI15 |  | Alex Leadbeater, BT | alex.leadbeater@bt.com | Rel-15 |  |  |  |  |
| 70 | 37 | Security Assurance Specification for PGW network product class |  | 261d? | 2016-06-17 A | 2017-06-15 | 80% | 52.2d? |  |  |  | 395d | finish no earlier than 2017-06-15 | S3 | 2088h | 1670.4h | SCAS_PGW | 33.250; 33.216 | Peng Jin, China Mobile | pengjin@chinamobile.com | Rel-15 | PCG-37 | SP-72 |  |  |
| 71 | 38 | Server and Network Assisted DASH for 3GPP Multimedia Services |  | 206d? | 2016-12-01 A | 2017-09-14 | 15% | 175.1d? |  |  |  | 330d | finish no earlier than 2017-09-14 | S4 | 1648h | 247.2h | SAND | TS 26.247, 26.233 | Ozgur Oyman, Intel | ozgur.oyman@intel.com | Rel-15 |  |  |  |  |
| 72 | 39 | **DL interference mitigation for UMTS** |  | 67d? | 2017-03-15 | 2017-06-15 |  |  |  |  |  | 395d |  | R2 | 1072h |  | UTRA_DL_IM |  | Qualcomm |  | Rel-15 |  |  |  |  |
| 73 | 39.1 | Core part: DL interference mitigation for UMTS |  | 67d? | 2017-03-15 | 2017-06-15 |  |  |  |  |  | 395d | finish no earlier than 2017-06-15 | R2 | 536h |  | UTRA_DL_IM-Core |  | Qualcomm |  | Rel-15 |  |  |  |  |
| 74 | 40 | (Small) Technical Enhancements and Improvements for Rel-15 |  | 29d? | 2017-03-17 A | 2017-04-26 A | 100% |  |  |  |  |  | start no earlier than 2015-05-11 | SP; CP; RP; R4 | 928h | 928h | TEI15 |  |  |  | Rel-15 | PCG-35 | SP-68 |  |  |
| 75 | 41 | (Small) Test Technical Enhancements and Improvements for Rel-15 |  | 29d? | 2017-03-17 A | 2017-04-26 A | 100% |  |  |  |  |  | start no earlier than 2017-03-17 | SP; CP; RP; GP | 928h | 928h | TEI15_Test |  |  |  | Rel-15 |  |  |  |  |
| 76 | 42 | Release 15 Features on LTE improvements | milestone | 0d? | 2016-06-09 A | 2016-06-09 A | 100% |  |  |  |  |  | finish no earlier than 2016-06-09 |  |  |  |  |  |  |  | Rel-15 |  |  |  |  |
| 77 | 43 | **Signalling reduction to enable light connection for LTE** |  | 329d? | 2016-03-15 A | 2017-06-15 | 57% | 142.3d? |  |  |  | 395d |  | R2 | 8192h | 4559.56h | LTE_LIGHT_CON |  | Huawei |  | Rel-15 | PCG-36 | TSG#71 |  |  |
| 78 | 43.1 | Core part: Signalling reduction to enable light connection for LTE |  | 329d? | 2016-03-15 A | 2017-06-15 | 79% | 69.09d? |  |  |  | 395d | finish no earlier than 2017-06-15 | R2 | 2632h | 2079.28h | LTE_LIGHT_CON-Core |  | Huawei |  | Rel-15 | PCG-36 | TSG#71 |  |  |
| 79 | 43.2 | Study on Stage 2 of core network aspects of signalling reduction to enable light connection for LTE |  | 70d? | 2017-03-10 | 2017-06-15 |  |  |  |  |  | 395d | finish no earlier than 2017-06-15 | S2 | 560h |  | FS_LTE_LIGHT_CON | 23.723 | Sašo Stojanovski , intel | saso.stojanovski@intel.com | Rel-15 |  |  |  |  |

Notes:
- 54: 1/12/16: 0%->100
- 55: 1/12/16: 0%->100
- 56: 6/3/17: 0%->55
- 58: 6/3/17: 0%->10
- 59: 6/10/16: 33.216 added; 1/12/16: 0%->5; 6/3/17: 5%->25. Moved from Rel-14.
- 60: 1/12/16: 0%->100
- 62: Triggered by Rel-12 TR 33.805 Study on Security Assurance Methodology for 3GPP Network Elements (FS_SECAM); June2015: WID:SP-130718->SP-150292. Aug 15: TR numb added; 28/1/16: 33.926 added; 28/7/16: 33.250 added;06/10/16: moved to Rel-14 as per John/Mir
- 63: This TR collects input for the new TS 33.116. Dec.14: 55->70%. 3/3/15: 70->55%. 10/03/15: 55->75%; June2015: Compl:75%->80; 7/12/15: STOPPED AT 80% (marked as 100% here since no more work expected)
- 64: This TR contains results of the second WID objective. Dec.14: 75->85%; June2015: Compl:85%->90; 7/12/15: 90%->92; 10/12/15: WID:SP-130718->SP-150716; 19/9/16: 92%->98. FCD set to 12.16 (was 03/16); 6/10/16: 33.216 added; 1/12/16: 81%->100
- 65: This TS contains results of the first WID objective; June2015: Compl:0%->5; 7/12/15: 5%->72.; 10/12/15: WID:SP-130718->SP-150716; 7/3/16: 72%->75; 28/7/16: 33.250 added; 19/9/16: 75%->90. FCD set to 12.16 (was 03/16). 6/3/17: moved from Rel-14.; 21/3/17: FCD:12/16->06/17
- 70: 28/7/16: 33.250 added; 19/9/16: 0%->10; 6/10/16: 33.216 added; 1/12/16: 10%->40. 06/03/17: moved from Rel-14.; 6/3/17: 40%->80
- 71: 3/3/17: WID:SP-160779->SP-170031; 6/3/17: 0%->15
- 72: no Perf. part
- 73: no Perf. part
- 75: Created upon demand of RAN5
- 76: -
- 77: no Perf. part
- 78: no Perf. part; 1/7/16: Compl:0%->10%; 1/7/16: CD:Thu 15/12/16->Wed 15/03/17; 1/7/16: WID: RP-160540->RP-16093726/9/16: Compl:10%->30%; 20/12/16: Compl:30%->75%; 20/12/16: Stat Rep: --> 21/3/17: Compl:75%->79% 21/3/17: CD:W...
- 79: 21/3/17: 23.723 added;

| ID | WBS | Task | Duration | Start | Finish | Complete | Remaining | Total slack | Constraint | Resources | Work | Actual work | Acronym | WI rapporteur name | WI rapporteur e-mail | Release | Impacted TSs and TRs | PCG approved | TSG approved |
| --- | --- | --- | --- | --- | --- | --- | --- | --- | --- | --- | --- | --- | --- | --- | --- | --- | --- | --- | --- |
| 80 | 43.3 | **Stage 3 of Signalling reduction to enable light connection for LTE** | 74d? | 2016-12-01 A | 2017-03-14 | 42% | 43.17d? | 462d |  | ct | 2368h | 986.67h | LTE_LIGHT_CON-CT | Herrero Veron, Christian (Huawei) | Christian.Herrero at huawei.com | Rel-15 |  |  |  |
| 81 | 43.3.1 | CT1 aspects of Signalling reduction to enable light connection for LTE | 74d? | 2016-12-01 A | 2017-03-14 | 25% | 55.5d? | 462d | finish no earlier than 2017-03-14 | C1 | 592h | 148h | LTE_LIGHT_CON-CT | Herrero Veron, Christian (Huawei) | Christian.Herrero at huawei.com | Rel-15 | 24.008, 24.301, 29.118, 24.368, 27.007 |  |  |
| 82 | 43.3.2 | CT4 aspects of Signalling reduction to enable light connection for LTE | 74d? | 2016-12-01 | 2017-03-14 |  |  | 462d | finish no earlier than 2017-03-14 | C4 | 592h |  | LTE_LIGHT_CON-CT | Herrero Veron, Christian (Huawei) | Christian.Herrero at huawei.com | Rel-15 | 29.274, 29.272 |  |  |
| 83 | 43.3.3 | CT6 aspects of Signalling reduction to enable light connection for LTE | 74d? | 2016-12-01 A | 2017-03-14 A | 100% |  |  | finish no earlier than 2017-03-14 | C6 | 592h | 592h | LTE_LIGHT_CON-CT | Herrero Veron, Christian (Huawei) | Christian.Herrero at huawei.com | Rel-15 | 31.102 |  |  |
| 84 | 44 | **Enhancements of Base Station (BS) RF and EMC requirements for Active Antenna System (AAS)** | 590d? | 2016-03-15 A | 2018-06-15 | 23% | 453.46d? | 134d |  |  | 8400h | 1944h | AASenh_BS_LTE_UTRA | Huawei |  | Rel-15 | 37.843 | PCG-36 | TSG#71 |
| 85 | 44.1 | Core part: Enhancements of Base Station (BS) RF and EMC requirements for Active Antenna System (AAS) | 460d? | 2016-03-15 A | 2017-12-15 | 40% | 276d? | 264d | finish no earlier than 2017-12-15 | R4 | 3680h | 1472h | AASenh_BS_LTE_UTRA-Core | Huawei |  | Rel-15 |  | PCG-36 | TSG#71 |
| 86 | 44.2 | Perf. part: Enhancements of Base Station (BS) RF and EMC requirements for Active Antenna System (AAS) | 590d? | 2016-03-15 A | 2018-06-15 | 10% | 531d? | 134d | finish no earlier than 2018-06-15 | R4 | 4720h | 472h | AASenh_BS_LTE_UTRA-Perf | Huawei |  | Rel-15 |  | PCG-36 | TSG#71 |
| 87 | 45 | **Shortened TTI and processing time for LTE** | 458d? | 2016-06-15 A | 2018-03-15 | 13% | 400.57d? | 200d |  |  | 6296h | 789.6h | LTE_sTTIandPT | Ericsson |  | Rel-15 |  | PCG-37 | TSG#72 |
| 88 | 45.1 | Core part: Shortened TTI and processing time for LTE | 329d? | 2016-06-15 A | 2017-09-15 | 30% | 230.3d? | 329d | finish no earlier than 2017-09-15 | R1 | 2632h | 789.6h | LTE_sTTIandPT-Core | Ericsson |  | Rel-15 |  | PCG-37 | TSG#72 |
| 89 | 45.2 | Perf. part: Shortened TTI and processing time for LTE | 458d? | 2016-06-15 | 2018-03-15 |  |  | 200d | finish no earlier than 2018-03-15 | R4 | 3664h |  | LTE_sTTIandPT-Perf | Ericsson |  | Rel-15 |  | PCG-37 | TSG#72 |
| 90 | 46 | **450MHz E-UTRA FDD Band for LTE PPDR and PMR/PAMR in Europe** | 197d? | 2016-12-15 A | 2017-09-15 | 5% | 187.16d? | 329d |  |  | 3152h | 157.6h | LTE450_Europe_PPDR | Airbus |  | Rel-15 | 36.748 |  |  |
| 91 | 46.1 | Core part: 450MHz E-UTRA FDD Band for LTE PPDR and PMR/PAMR in Europe | 197d? | 2016-12-15 A | 2017-09-15 | 10% | 177.3d? | 329d | finish no earlier than 2017-09-15 | R4 | 1576h | 157.6h | LTE450_Europe_PPDR-Core | Airbus |  | Rel-15 |  |  |  |
| 92 | 46.2 | Perf. part: 450MHz E-UTRA FDD Band for LTE PPDR and PMR/PAMR in Europe | 197d? | 2016-12-15 | 2017-09-15 |  |  | 329d | finish no earlier than 2017-09-15 | R4 | 1576h |  | LTE450_Europe_PPDR-Perf | Airbus |  | Rel-15 |  |  |  |
| 93 | 47 | **E-UTRA 700MHz in Europe for Broadband-PPDR (Public Protection and Disaster Relief)** | 197d? | 2016-12-15 A | 2017-09-15 | 19% | 159.97d? | 329d |  |  | 2096h | 394h | LTE700_Europe_PPDR | Airbus |  | Rel-15 |  |  |  |
| 94 | 47.1 | Core part: E-UTRA 700MHz in Europe for Broadband-PPDR | 197d? | 2016-12-15 A | 2017-09-15 | 25% | 147.75d? | 329d | finish no earlier than 2017-09-15 | R4 | 1576h | 394h | LTE700_Europe_PPDR-Core | Airbus |  | Rel-15 |  |  |  |
| 95 | 47.2 | Perf. part: E-UTRA 700MHz in Europe for Broadband-PPDR | 65d? | 2016-12-15 | 2017-03-15 |  |  | 461d | finish no earlier than 2017-03-15 | R4 | 520h |  | LTE700_Europe_PPDR-Perf | Airbus |  | Rel-15 |  |  |  |
| 96 | 48 | **FDD operating band in the L-band for LTE** | 131d? | 2016-12-15 A | 2017-06-15 | 25% | 98.25d? | 395d |  |  | 2096h | 524h | LTE_FDD_L_Band | NTT DOCOMO |  | Rel-15 | 36.751 |  |  |
| 97 | 48.1 | Core part: FDD operating band in the L-band for LTE | 131d? | 2016-12-15 A | 2017-06-15 | 50% | 65.5d? | 395d | finish no earlier than 2017-06-15 | R4 | 1048h | 524h | LTE_FDD_L_Band-Core | NTT DOCOMO |  | Rel-15 |  |  |  |
| 98 | 48.2 | Perf. part: FDD operating band in the L-band for LTE | 131d? | 2016-12-15 | 2017-06-15 |  |  | 395d | finish no earlier than 2017-06-15 | R4 | 1048h |  | LTE_FDD_L_Band-Perf | NTT DOCOMO |  | Rel-15 |  |  |  |
| 99 | 49 | **LTE Extended 1.5 GHz SDL band (1427 – 1518 MHz) and LTE Carrier Aggregation (2DL/1UL) with Band 20** | 131d? | 2016-12-15 A | 2017-06-15 | 10% | 117.91d? | 395d |  |  | 2096h | 209.6h | LTE_SDL_1500ext | Qualcomm |  | Rel-15 | 36.934; 36.753 |  |  |
| 100 | 49.1 | Core part: LTE Extended 1.5 GHz SDL band (1427 – 1518 MHz) and LTE Carrier Aggregation (2DL/1UL) with Band 20 | 131d? | 2016-12-15 A | 2017-06-15 | 20% | 104.8d? | 395d | finish no earlier than 2017-06-15 | R4 | 1048h | 209.6h | LTE_SDL_1500ext-Core | Qualcomm |  | Rel-15 |  |  |  |
| 101 | 49.2 | Perf. part: LTE Extended 1.5 GHz SDL band (1427 – 1518 MHz) and LTE Carrier Aggregation (2DL/1UL) with Band 20 | 131d? | 2016-12-15 | 2017-06-15 |  |  | 395d | finish no earlier than 2017-06-15 | R4 | 1048h |  | LTE_SDL_1500ext-Perf | Qualcomm |  | Rel-15 |  |  |  |
| 102 | 50 | **Add UE Power Class 2 to band 41 intra-band contiguous LTE Carrier Aggregation** | 131d? | 2016-12-15 A | 2017-06-15 | 5% | 124.46d? | 395d |  |  | 1048h | 52.4h | LTE_CA_C_B41_PC2 | Sprint |  | Rel-15 |  |  |  |
| 103 | 50.1 | Core part: Add UE Power Class 2 to band 41 intra-band contiguous LTE Carrier Aggregation | 131d? | 2016-12-15 A | 2017-06-15 | 5% | 124.45d? | 395d | finish no earlier than 2017-06-15 | R4 | 1048h | 52.4h | LTE_CA_C_B41_PC2-Core | Sprint |  | Rel-15 |  |  |  |

Notes:
- 81: 6/3/17: 0%->25
- 83: 7/3/17: 0%->100
- 84: follow-up WI of REL-13 WI AAS_BS_LTE_UTRA
- 85: follow-up WI of REL-13 WI AAS_BS_LTE_UTRA1/7/16: Compl:0%->5%1/7/16: CD:Fri 15/09/17->Wed 15/03/1726/9/16: Compl:5%->10% 20/12/16: Compl:10%->20%; ; 21/3/17: Compl:20%->40%; ; ...
- 86: 1/7/16: WID: RP-160548->RP-1609401/7/16: Release: Rel-15->Rel-14; 26/9/16: WID: RP-160940->RP-161668 20/12/16: Stat Rep: -->; 21/3/17: Compl:0%->10%; ;...
- 88: 26/9/16: Compl:0%->5%; 20/12/16: Compl:5%->10%; ; 21/3/17: Compl:10%->30%; ; ...
- 89: ; 26/9/16: WID: RP-161299->RP-161922; 20/12/16: WID: RP-161922->RP-162014; ; 21/3/17: WID: RP-162014->RP-170113
- 90: 21/3/17: 36.748 added;
- 91: ; ; 21/3/17: Compl:0%->10%
- 94: ; ; 21/3/17: Compl:0%->25%; ...
- 95: ; ; 21/3/17: CD:Thu 15/06/17->Wed 15/03/17 ...
- 96: 21/3/17: 36.751 added;
- 97: ; ; 21/3/17: Compl:0%->50%
- 99: 21/3/17: 36.934 added;; 21/3/17: 36.753 added;
- 100: ; ; 21/3/17: Compl:0%->20%
- 103: ; ; 21/3/17: Compl:0%->5%

| ID | WBS | Task | Duration | Start | Finish | Complete | Remaining | Total slack | Constraint | Resources | Work | Actual work | Acronym | PCG approved | WI rapporteur name | Release | TSG approved | Impacted TSs and TRs |
| --- | --- | --- | --- | --- | --- | --- | --- | --- | --- | --- | --- | --- | --- | --- | --- | --- | --- | --- |
| 104 | 51 | **Addition of Power Class 1 UE to bands B3/B20/B28 for LTE** | 196d? | 2016-09-15 A | 2017-06-15 | 70% | 58.8d? | 395d |  |  | 1568h | 1097.6h | LTE_HPUE_B3_B20_B28 | PCG-37 | Motorola Solutions | Rel-15 | TSG-73 |  |
| 105 | 51.1 | Core part: Addition of Power Class 1 UE to bands B3/B20/B28 for LTE | 196d? | 2016-09-15 A | 2017-06-15 | 70% | 58.8d? | 395d | finish no earlier than 2017-06-15 | R4 | 1568h | 1097.6h | LTE_HPUE_B3_B20_B28-Core | PCG-37 | Motorola Solutions | Rel-15 | TSG-73 |  |
| 106 | 52 | **TDD operating band in the L-band for LTE** | 131d? | 2016-12-15 A | 2017-06-15 | 7% | 121.18d? | 395d |  |  | 2096h | 157.2h | LTE_TDD_L_Band |  | Huawei | Rel-15 |  | 36.753 |
| 107 | 52.1 | Core part: TDD operating band in the L-band for LTE | 131d? | 2016-12-15 A | 2017-06-15 | 15% | 111.35d? | 395d | finish no earlier than 2017-06-15 | R4 | 1048h | 157.2h | LTE_TDD_L_Band-Core |  | Huawei | Rel-15 |  |  |
| 108 | 52.2 | Perf. part: TDD operating band in the L-band for LTE | 131d? | 2016-12-15 | 2017-06-15 |  |  | 395d | finish no earlier than 2017-06-15 | R4 | 1048h |  | LTE_TDD_L_Band-Perf |  | Huawei | Rel-15 |  |  |
| 109 | 53 | **Further enhancements to Coordinated Multi-Point (CoMP) Operation for LTE** | 262d? | 2017-03-15 | 2018-03-15 |  |  | 200d |  | R1 | 5256h |  | feCOMP_LTE |  | Intel | Rel-15 |  |  |
| 110 | 53.1 | Core part: Further enhancements to Coordinated Multi-Point (CoMP) Operation for LTE | 133d? | 2017-03-15 | 2017-09-15 |  |  | 329d | finish no earlier than 2017-09-15 | R1 | 1064h |  | feCOMP_LTE-Core |  | Intel | Rel-15 |  |  |
| 111 | 53.2 | Perf. part: Further enhancements to Coordinated Multi-Point (CoMP) Operation for LTE | 262d? | 2017-03-15 | 2018-03-15 |  |  | 200d | finish no earlier than 2018-03-15 | R4 | 2096h |  | feCOMP_LTE-Perf |  | Intel | Rel-15 |  |  |
| 112 | 54 | **Highly Reliable Low Latency Communication for LTE** | 458d? | 2017-03-15 | 2018-12-15 |  |  | 4d |  | R1 | 9952h |  | LTE_HRLLC |  | Ericsson | Rel-15 |  |  |
| 113 | 54.1 | Core part: Highly Reliable Low Latency Communication for LTE | 328d? | 2017-03-15 | 2018-06-15 |  |  | 134d | finish no earlier than 2018-06-15 | R1 | 2624h |  | LTE_HRLLC-Core |  | Ericsson | Rel-15 |  |  |
| 114 | 54.2 | Perf. part: Highly Reliable Low Latency Communication for LTE | 458d? | 2017-03-15 | 2018-12-15 |  |  | 4d | finish no earlier than 2018-12-15 | R4 | 3664h |  | LTE_HRLLC-Perf |  | Ericsson | Rel-15 |  |  |
| 115 | 55 | **UE Positioning Accuracy Enhancements for LTE** | 328d? | 2017-03-15 | 2018-06-15 |  |  | 134d |  | R2 | 6832h |  | LCS_LTE_acc_enh |  | Nokia | Rel-15 |  |  |
| 116 | 55.1 | Core part: UE Positioning Accuracy Enhancements for LTE | 198d? | 2017-03-15 | 2017-12-15 |  |  | 264d | finish no earlier than 2017-12-15 | R2 | 1584h |  | LCS_LTE_acc_enh-Core |  | Nokia | Rel-15 |  |  |
| 117 | 55.2 | Perf. part: UE Positioning Accuracy Enhancements for LTE | 328d? | 2017-03-15 | 2018-06-15 |  |  | 134d | finish no earlier than 2018-06-15 | R4 | 2624h |  | LCS_LTE_acc_enh-Perf |  | Nokia | Rel-15 |  |  |
| 118 | 56 | **Enhancements for high capacity stationary wireless link and introduction of 1024 QAM for LTE DL** | 458d? | 2017-03-15 | 2018-12-15 |  |  | 4d |  | R1 | 10992h |  | LTE_1024QAM_DL |  | Huawei | Rel-16 |  |  |
| 119 | 56.1 | Core part: Enhancements for high capacity stationary wireless link and introduction of 1024 QAM for LTE DL | 458d? | 2017-03-15 | 2018-12-15 |  |  | 4d | finish no earlier than 2018-12-15 | R1 | 3664h |  | LTE_1024QAM_DL-Core |  | Huawei | Rel-16 |  |  |
| 120 | 56.2 | Perf. part: Enhancements for high capacity stationary wireless link and introduction of 1024 QAM for LTE DL | 458d? | 2017-03-15 | 2018-12-15 |  |  | 4d | finish no earlier than 2018-12-15 | R4 | 3664h |  | LTE_1024QAM_DL-Perf |  | Huawei | Rel-16 |  |  |
| 121 | 57 | **Enhancements to LTE operation in unlicensed spectrum** | 262d? | 2017-03-15 | 2018-03-15 |  |  | 200d |  | R1 | 5256h |  | LTE_unlic |  | Nokia | Rel-15 |  |  |
| 122 | 57.1 | Core part: Enhancements to LTE operation in unlicensed spectrum | 133d? | 2017-03-15 | 2017-09-15 |  |  | 329d | finish no earlier than 2017-09-15 | R1 | 1064h |  | LTE_unlic-Core |  | Nokia | Rel-15 |  |  |
| 123 | 57.2 | Perf. part: Enhancements to LTE operation in unlicensed spectrum | 262d? | 2017-03-15 | 2018-03-15 |  |  | 200d | finish no earlier than 2018-03-15 | R4 | 2096h |  | LTE_unlic-Perf |  | Nokia | Rel-15 |  |  |
| 124 | 58 | **Further video enhancements for LTE** | 198d? | 2017-03-15 | 2017-12-15 |  |  | 264d |  | R2 | 3168h |  | LTE_ViLTE_enh2 |  | CMCC | Rel-15 |  |  |
| 125 | 58.1 | Core part: Further video enhancements for LTE | 198d? | 2017-03-15 | 2017-12-15 |  |  | 264d | finish no earlier than 2017-12-15 | R2 | 1584h |  | LTE_ViLTE_enh2-Core |  | CMCC | Rel-15 |  |  |
| 126 | 59 | **Quality of Experience (QoE) Measurement Collection for streaming services in E-UTRAN** | 198d? | 2017-03-15 | 2017-12-15 |  |  | 264d |  | R2 | 3168h |  | LTE_QMC_Streaming |  | China Unicom | Rel-15 |  |  |
| 127 | 59.1 | Core part: Quality of Experience (QoE) Measurement Collection for streaming services in E-UTRAN | 198d? | 2017-03-15 | 2017-12-15 |  |  | 264d | finish no earlier than 2017-12-15 | R2 | 1584h |  | LTE_QMC_Streaming-Core |  | China Unicom | Rel-15 |  |  |

Notes:
- 105: ; 20/12/16: Compl:0%->15%; 20/12/16: CD:Wed 15/03/17->Thu 15/06/17; ; 21/3/17: Compl:15%->70%
- 106: 21/3/17: 36.753 added;
- 107: ; ; 21/3/17: Compl:0%->15%; ...
- 108: ; ; 21/3/17: WID: RP-162557->RP-170304
- 109: follow-up WI of REL-14 SI FS_feCOMP_LTE completed at RAN #75
- 110: follow-up WI of REL-14 SI FS_feCOMP_LTE completed at RAN #75
- 111: follow-up WI of REL-14 SI FS_feCOMP_LTE completed at RAN #75
- 121: note: The is actually a further LAA enhancement
- 122: note: The is actually a further LAA enhancement
- 124: no Perf. part; compare REL-14 WI LTE_VoLTE_ViLTE_enh
- 125: no Perf. part; compare REL-14 WI LTE_VoLTE_ViLTE_enh
- 126: compare REL-14 WI UMTS_QMC_Streaming-Core
- 127: compare REL-14 WI UMTS_QMC_Streaming-Core

| ID | WBS | Task | Type | Duration | Start | Finish | Complete | Remaining | Baseline start | Baseline finish | Baseline duration | Total slack | Constraint | Resources | Work | Actual work | Acronym | WI rapporteur name | Release | PCG approved | Impacted TSs and TRs | WI rapporteur e-mail | TSG approved | MCC resp | Acronym_3GU_Export |
| --- | --- | --- | --- | --- | --- | --- | --- | --- | --- | --- | --- | --- | --- | --- | --- | --- | --- | --- | --- | --- | --- | --- | --- | --- | --- |
| 128 | 60 | **Enhancing LTE CA Utilization** |  | 328d? | 2017-03-15 | 2018-06-15 |  |  |  |  |  | 134d |  | R2 | 6832h |  | LTE_euCA | Nokia | Rel-15 |  |  |  |  |  |  |
| 129 | 60.1 | Core part: Enhancing LTE CA Utilization |  | 198d? | 2017-03-15 | 2017-12-15 |  |  |  |  |  | 264d | finish no earlier than 2017-12-15 | R2 | 1584h |  | LTE_euCA-Core | Nokia | Rel-15 |  |  |  |  |  |  |
| 130 | 60.2 | Perf. part: Enhancing LTE CA Utilization |  | 328d? | 2017-03-15 | 2018-06-15 |  |  |  |  |  | 134d | finish no earlier than 2018-06-15 | R4 | 2624h |  | LTE_euCA-Perf | Nokia | Rel-15 |  |  |  |  |  |  |
| 131 | 61 | **450 MHz Band for LTE in Region 3** |  | 198d? | 2017-03-15 | 2017-12-15 |  |  |  |  |  | 264d |  | R4 | 4752h |  | LTE450_Reg3 | China Unicom | Rel-15 |  |  |  |  |  |  |
| 132 | 61.1 | Core part: 450 MHz Band for LTE in Region 3 |  | 198d? | 2017-03-15 | 2017-12-15 |  |  |  |  |  | 264d | finish no earlier than 2017-12-15 | R4 | 1584h |  | LTE450_Reg3-Core | China Unicom | Rel-15 |  |  |  |  |  |  |
| 133 | 61.2 | Perf. part: 450 MHz Band for LTE in Region 3 |  | 198d? | 2017-03-15 | 2017-12-15 |  |  |  |  |  | 264d | finish no earlier than 2017-12-15 | R4 | 1584h |  | LTE450_Reg3-Perf | China Unicom | Rel-15 |  |  |  |  |  |  |
| 134 | 62 | **US 600 MHz Band for LTE** |  | 133d? | 2017-03-15 | 2017-09-15 |  |  |  |  |  | 329d |  | R4 | 3192h |  | LTE600_US | Ericsson | Rel-15 |  |  |  |  |  |  |
| 135 | 62.1 | Core part: US 600 MHz Band for LTE |  | 133d? | 2017-03-15 | 2017-09-15 |  |  |  |  |  | 329d | finish no earlier than 2017-09-15 | R4 | 1064h |  | LTE600_US-Core | Ericsson | Rel-15 |  |  |  |  |  |  |
| 136 | 62.2 | Perf. part: US 600 MHz Band for LTE |  | 133d? | 2017-03-15 | 2017-09-15 |  |  |  |  |  | 329d | finish no earlier than 2017-09-15 | R4 | 1064h |  | LTE600_US-Perf | Ericsson | Rel-15 |  |  |  |  |  |  |
| 137 | 63 | **LAA/eLAA for the CBRS 3.5GHz band in the United States** |  | 198d? | 2017-03-15 | 2017-12-15 |  |  |  |  |  | 264d |  | R4 | 4752h |  | LTE_TDD_3550_CBRS_US_LAA | AT&T | Rel-15 |  |  |  |  |  |  |
| 138 | 63.1 | Core part: LAA/eLAA for the CBRS 3.5GHz band in the United States |  | 198d? | 2017-03-15 | 2017-12-15 |  |  |  |  |  | 264d | start no earlier than 2017-03-15 | R4 | 1584h |  | LTE_TDD_3550_CBRS_US_LAA-Core | AT&T | Rel-15 |  |  |  |  |  |  |
| 139 | 63.2 | Perf. part: LAA/eLAA for the CBRS 3.5GHz band in the United States |  | 198d? | 2017-03-15 | 2017-12-15 |  |  |  |  |  | 264d | start no earlier than 2017-03-15 | R4 | 1584h |  | LTE_TDD_3550_CBRS_US_LAA-Perf | AT&T | Rel-15 |  |  |  |  |  |  |
| 140 | 64 | Release 15 Studies | milestone | 0d? | 2016-06-09 A | 1985-07-05 A | 100% |  |  |  |  |  | start no earlier than 2016-06-09 |  |  |  |  |  | Rel-15 |  |  |  |  |  |  |
| 141 | 65 | Release 15 Studies on 5G | milestone | 0d? | 2016-06-09 A | 2016-06-09 A | 100% |  |  |  |  |  | finish no earlier than 2016-06-09 |  |  |  |  |  | Rel-15 |  |  |  |  |  |  |
| 142 | 66 | Study on management aspects of virtualized network functions that are part of the NR |  | 259d? | 2016-09-19 A | 2017-09-14 | 10% | 233.1d? |  |  |  | 330d | finish no earlier than 2017-09-14 | S5 | 2072h | 207.2h | FS_MA_RNVNF | Intel (Joey Chou | Rel-15 | PCG-37 | TR 32.864 | joey.chou@intel.com | TSG-73 |  |  |
| 143 | 67 | Study on Charging Aspects of 5G System Architecture Phase 1 |  | 206d? | 2017-03-03 | 2017-12-15 |  |  |  |  |  | 264d | finish no earlier than 2017-12-15 | S5 | 1648h |  | FS_5GS_Ph1_CH | Chen, Shan, Huawei | Rel-15 |  |  | chenshan@huawei.com |  |  |  |
| 144 | 68 | Other Release 15 Studies | milestone | 0d? | 2016-06-09 A | 2016-06-09 A | 100% |  |  |  |  |  | finish no earlier than 2016-06-09 |  |  |  |  |  | Rel-15 |  |  |  |  |  |  |
| 145 | 69 | Study on enhancements of Public Warning System |  | 259d? | 2016-09-19 A | 2017-09-14 | 45% | 142.45d? |  |  |  | 330d | finish no earlier than 2017-09-14 | S1 | 2072h | 932.4h | FS_ePWS | SyncTechno Inc., Hyounhee Koo | Rel-15 | PCG-37 |  | koo at synctechno dot com | TSG-73 |  |  |
| 146 | 70 | Study on Communication for Automation in Vertical Domains |  | 206d? | 2017-03-02 | 2017-12-14 |  |  |  |  |  | 265d | finish no earlier than 2017-12-14 | S1 | 1648h |  | FS_CAV | Walewski, Joachim, Siemens AG | Rel-15 |  |  | joachim.walewski@siemens.com |  |  |  |
| 147 | 71 | Study on mission critical system migration and interconnect between MCPTT systems |  | 262d? | 2016-06-13 A | 2017-06-12 | 60% | 104.8d? |  |  |  | 398d | finish no earlier than 2017-06-12 | S6 | 2096h | 1257.6h | FS_MCSMI | Chater-Lea, David | Rel-15 | PCG-37 | New TR 23.781 |  | SP-72 |  |  |
| 148 | 72 | Study on Mission Critical Communication Interworking between LTE and non-LTE Systems |  | 262d? | 2016-06-13 A | 2017-06-12 | 50% | 131d? |  |  |  | 398d | finish no earlier than 2017-06-12 | S6 | 2096h | 1048h | FS_MCCI | Monnes, Peter (Harris Corp.) | Rel-15 | PCG-37 | New TR 23.782 |  | TSG#72 |  |  |
| 149 | 73 | Study on architecture enhancements to ProSe UE-to-Network Relay |  | 206d? | 2016-12-01 A | 2017-09-14 | 30% | 144.2d? |  |  |  | 330d | finish no earlier than 2017-09-14 | S2 | 1648h | 494.4h | FS_REAR | Dario Serafino Tonesi, Huawei | Rel-15 |  | 23.733 | dario.tonesi@huawei.com |  |  |  |
| 150 | 74 | Study on security aspects of enhancements to ProSe UE-to-Network Relay |  | 271d? | 2017-03-02 | 2018-03-15 |  |  |  |  |  | 200d | finish no earlier than 2018-03-15 | S3 | 2168h |  | FS_REAR_Sec |  | Rel-15 |  |  | lihe2@huawei.com |  |  |  |
| 151 | 75 | Study on unlicensed spectrum offloading system enhancements |  | 141d? | 2016-12-01 A | 2017-06-15 | 30% | 98.7d? |  |  |  | 395d | finish no earlier than 2017-06-15 | S2 | 1128h | 338.4h | FS_USOS | Haris Zisimopoulos, Qualcomm Incorporated | Rel-15 |  | TR 23.729 | harisz@qti.qualcomm.com |  |  |  |
| 152 | 76 | Study on enhanced VoLTE performance |  | 206d? | 2016-12-01 A | 2017-09-14 | 50% | 103d? |  |  |  | 330d | finish no earlier than 2017-09-14 | S2 | 1648h | 824h | FS_eVoLP | Xiaobo Wu, Huawei | Rel-15 |  | 23.759 | wuxiaobo@ huawei.com |  |  |  |
| 153 | 77 | Study on Complementary Features for Voice services over WLAN |  | 199d? | 2016-06-13 A | 2017-03-15 | 80% | 39.8d? |  |  |  | 461d | finish no earlier than 2017-03-15 | S2 | 1592h | 1273.6h | FS_VoWLAN | Nokia (Nicolas Drevon | Rel-15 | PCG-37 | 23.751 | nicolas.drevon@nokia.com | SP-72 |  |  |
| 154 | 78 | Study on Enhanced Isolated E-UTRAN Operation for Public Safety |  | 205d? | 2016-03-07 A | 2016-12-15 | 50% | 102.5d? |  |  |  | 525d | finish no earlier than 2016-12-15 | S2 | 1640h | 820h | FS_IOPS_LB | Antoine Mouquet, Orange | Rel-15 | PCG-36 | 23.798 | antoine.mouquet@orange.com | TSG#71 |  |  |
| 155 | 79 | Study on Maritime Communication Services over 3GPP system |  | 455d? | 2016-09-19 A | 2018-06-15 | 15% | 386.75d? |  |  |  | 134d | finish no earlier than 2018-06-15 | S1 | 3640h | 546h | FS_MARCOM | SyncTechno Inc., Hyounhee Koo | Rel-15 | PCG-37 | 22.819 | koo at synctechno dot com | TSG-73 |  |  |
| 156 | 80 | Study on LTE bandwidth flexibility enhancements |  | 263d? | 2016-03-15 A | 2017-03-15 | 50% | 131.5d? |  |  |  | 461d | finish no earlier than 2017-03-15 | R4 | 2104h | 1052h | FS_LTE_BW_flex | Huawei | Rel-15 | PCG-36 | 36.740 |  | TSG#71 |  |  |
| 157 | 81 | Study on Provision of Access to Local Operator Services |  | 75d? | 2016-12-01 A | 2017-03-15 A | 100% |  |  |  |  |  | finish no earlier than 2017-03-15 | S1 | 600h | 600h | FS_PARLOS | Covell, Betsy | Rel-15 |  | 22.xxx | betsy.covell@nokia.com |  |  |  |
| 158 | 82 | Study on Enhancement of LTE for Efficient delivery of Streaming Service |  | 206d? | 2016-12-01 A | 2017-09-14 | 20% | 164.8d? |  |  |  | 330d | finish no earlier than 2017-09-14 | S1 | 1648h | 329.6h | FS_ eLESTR | China Telecommunications, XIA Xu | Rel-15 |  | 22.xxx | xiaxu@ctbri.com.cn |  |  |  |
| 159 | 83 | Study on a RESTful HTTP-based Solution Set |  | 194d? | 2016-09-19 A | 2017-06-15 | 5% | 184.3d? |  |  |  | 395d | finish no earlier than 2017-06-15 | S5 | 1552h | 77.6h | FS_OAM_RESTFUL | Nokia: Pollakowski, Olaf | Rel-15 | PCG-37 | 32.866 |  | TSG-73 |  |  |
| 160 | 84 | Study on interference cancellation receiver for LTE BS |  | 196d? | 2016-09-15 A | 2017-06-15 | 65% | 68.6d? |  |  |  | 395d | finish no earlier than 2017-06-15 | R4 | 1568h | 1019.2h | FS_LTE_IC_BS | China Telecom | Rel-15 | PCG-37 | 36.766 |  | TSG-73 |  |  |
| 161 | 85 | Study on Management Enhancement of CUPS of EPC Nodes |  | 206d? | 2016-12-01 A | 2017-09-14 | 5% | 195.7d? |  |  |  | 330d | finish no earlier than 2017-09-14 | S5 | 1648h | 82.4h | FS_MECUPS | Huawei; Jiang, Junyi | Rel-15 |  | 32.867 | jiangjunyi@huawei.com |  |  |  |
| 162 | 86 | Study on Policy and Charging for Volume Based Charging |  | 140d? | 2016-12-01 A | 2017-06-14 | 30% | 98d? |  |  |  | 396d | finish no earlier than 2017-06-14 | C3 | 1120h | 336h | FS_PC_VBC | Huang, Zhenning, China Mobile | Rel-15 |  | TR 29.xxx; 29.827 | huangzhenning <at> chinamobile <dot> com |  |  |  |
| 163 | 87 | Study on uplink data compression in LTE |  | 131d? | 2016-12-15 | 2017-06-15 |  |  |  |  |  | 395d | finish no earlier than 2017-06-15 | R2 | 1048h |  | FS_LTE_UDC | CATT | Rel-15 |  | 36.754 |  |  |  |  |
| 164 | 88 | Study on further enhancements to LTE Device to Device (D2D), UE to network relays for IoT (Internet of Things) and wearables |  | 395d? | 2016-03-15 A | 2017-09-15 | 35% | 256.75d? |  |  |  | 329d | finish no earlier than 2017-09-15 | R2 | 3160h | 1106h | FS_feD2D_IoT_relay_wearable | Qualcomm | Rel-15 | PCG-36 | 36.746 |  | TSG#71 |  |  |
| 165 | 89 | Study on Virtual Reality |  | 402d? | 2016-03-01 A | 2017-09-12 | 55% | 180.9d? |  |  |  | 332d | finish no earlier than 2017-09-12 | S4 | 3216h | 1768.8h | FS_VR | Gilles TENIOU, Orange | Rel-15 | PCG-36 | TR 26.918 | gilles.teniou@orange.com | TSG#71 |  |  |
| 166 | 90 | Study on technical requirements for a new secure platform for 3GPP applications |  | 140d? | 2017-03-03 | 2017-09-14 |  |  |  |  |  | 330d | finish no earlier than 2017-09-14 | C6 | 1120h |  | FS_NG_SP2 | Heiko Kruse | Rel-15 |  | 31.801 | heiko.kruse@safrangroup.com |  |  |  |
| 167 | 91 | Study on Common API Framework for 3GPP Northbound APIs |  | 135d? | 2017-03-10 | 2017-09-14 |  |  |  |  |  | 330d | finish no earlier than 2017-09-14 | S6 | 1080h |  | FS_CAPIF |  | Rel-15 |  | new TR 23.722 |  |  |  |  |
| 168 | 92 | Study on NR to support non-terrestrial networks |  | 198d? | 2017-03-15 | 2017-12-15 |  |  |  |  |  | 264d | finish no earlier than 2017-12-15 | R1 | 1584h |  | FS_NR_nonterr_nw | Thales | Rel-15 |  |  |  |  |  |  |
| 169 | 93 | Study on scheduling enhancements with carrier aggregation for UMTS |  | 67d? | 2017-03-15 | 2017-06-15 |  |  |  |  |  | 395d | finish no earlier than 2017-06-15 | R1 | 536h |  | FS_UTRA_CA_sched_enh | Huawei | Rel-15 |  |  |  |  |  |  |
| 170 | 94 | Study on enhanced LTE Support for Aerial Vehicles |  | 198d? | 2017-03-15 | 2017-12-15 |  |  |  |  |  | 264d | finish no earlier than 2017-12-15 | R2 | 1584h |  | FS_LTE_Aerial | NTT DOCOMO | Rel-15 |  |  |  |  |  |  |
| 171 | 95 | Study on CU-DU lower layer split for New Radio |  | 198d? | 2017-03-15 | 2017-12-15 |  |  |  |  |  | 264d | finish no earlier than 2017-12-15 | R3 | 1584h |  | FS_NR_CU_DU_LLS | NTT DOCOMO | Rel-15 |  |  |  |  |  |  |
| 172 | 96 | Study of test methods for New Radio |  | 262d? | 2017-03-15 | 2018-03-15 |  |  |  |  |  | 200d | finish no earlier than 2018-03-15 | R4 | 2096h |  | FS_NR_test_methods | Intel | Rel-15 |  |  |  |  |  |  |
| 173 | 97 | Study on NR-based access to unlicensed spectrum |  | 328d? | 2017-03-15 | 2018-06-15 |  |  |  |  |  | 134d | finish no earlier than 2018-06-15 | R1 | 2624h |  | FS_NR_unlic | Qualcomm | Rel-15 |  |  |  |  |  |  |
| 174 | 98 | Study on Non-Orthogonal Multiple Access (NOMA) for NR |  | 328d? | 2017-03-15 | 2018-06-15 |  |  |  |  |  | 134d | finish no earlier than 2018-06-15 | R1 | 2624h |  | FS_NR_NOMA | ZTE | Rel-15 |  |  |  |  |  |  |
| 175 | 99 | Study on integrated access and backhaul for NR |  | 328d? | 2017-03-15 | 2018-06-15 |  |  |  |  |  | 134d | finish no earlier than 2018-06-15 | R2 | 2624h |  | FS_NR_IAB | Qualcomm | Rel-15 |  |  |  |  |  |  |
| 176 | 100 | Study on evaluation methodology of new V2X use cases for LTE and NR |  | 198d? | 2017-03-15 | 2017-12-15 |  |  |  |  |  | 264d | finish no earlier than 2017-12-15 | R1 | 1584h |  | FS_LTE_NR_V2X_eval | LG Electronics | Rel-15 |  |  |  |  |  |  |
| 177 | 101 | Study on Architecture Evolution for E-UTRAN |  | 198d? | 2017-03-15 | 2017-12-15 |  |  |  |  |  | 264d | finish no earlier than 2017-12-15 | R3 | 1584h |  | FS_LTE_arch_evo | China Unicom | Rel-15 |  |  |  |  |  |  |
| 178 | 102 | Study on a simplified HS-SCCH for UMTS |  | 328d? | 2017-03-15 | 2018-06-15 |  |  |  |  |  | 134d | start no earlier than 2017-03-15 | R1 | 2624h |  | FS_UTRA_simple_HSSCCH | gerardo.agni.medina.acosta@ericsson.com | Rel-15 |  |  | gerardo.agni.medina.acosta@ericsson.com |  |  |  |
| 179 | 103 | Study on UE characteristics and performance for Video |  | 339d? | 2016-03-01 A | 2017-06-15 | 30% | 237.3d? |  |  |  | 395d | finish no earlier than 2017-06-15 | S4 | 2712h | 813.6h | FS_UE_VTPerf | Stéphane PROUST, Orange | Rel-15 | PCG-36 | TR 26.932 | stephane.proust@orange.com | TSG#71 |  |  |
| 180 | 104 | Study on Enhanced Acoustic Test Specifications |  | 1114d? | 2013-03-18 A | 2017-06-09 | 80% | 222.8d? | 2013-03-06 | 2014-09-17 | 401d? | 399d | finish no earlier than 2017-06-09 | S4 | 8912h | 7129.6h | FS_SEATS | Knowles, Intel | Rel-15 | PCG-30 | 26.931 | Scott Isabelle (Knowles), David Isherwood (Intel) | SP-59 | Paolo | FS_SEATS |
| 181 | 105 | Study on User Services Enhancements in 3GPP for TV Services |  | 261d? | 2016-06-13 A | 2017-06-09 | 75% | 65.25d? |  |  |  | 399d | finish no earlier than 2017-06-09 | S4 | 2088h | 1566h | FS_USE_3GPP_4_TV | Thomas Stockhammer, Qualcomm Incorporated | Rel-15 | PCG-37 | TR 26.9xx; 26.917 | tsto@qti.qualcomm.com | TSG#72 |  |  |
| 182 | 106 | Study on Management aspects of selected IoT-related features |  | 194d? | 2016-09-19 A | 2017-06-15 | 5% | 184.3d? |  |  |  | 395d | finish no earlier than 2017-06-15 | S5 | 1552h | 77.6h | FS_OAM_IOT | Cisco Systems / Yanover, Vladimir | Rel-15 | PCG-37 | 32.857 |  | TSG-73 |  |  |
| 183 | 107 | Study on Overload Control for Diameter Charging Applications |  | 653d? | 2015-06-18 A | 2017-12-15 | 10% | 587.7d? |  |  |  | 264d | finish no earlier than 2017-12-15 | S5 | 5224h | 522.4h | FS_DOCME_CH | GUO Wenjie, ZTE | Rel-15 | PCG-35 | New TR 32.869 | guo.wenjie1@zte.com.cn | SP-68 |  |  |
| 184 | 108 | Study on forward compatibility for 3GPP Diameter Charging Applications |  | 194d? | 2016-09-19 A | 2017-06-15 | 10% | 174.6d? |  |  |  | 395d | finish no earlier than 2017-06-15 | S5 | 1552h | 155.2h | FS_FWDCA | Nokia, Maryse <dot> Gardella <at> Nokia <dot> com | Rel-15 | PCG-37 | 32.870 | Nokia, Maryse <dot> Gardella <at> Nokia <dot> com | TSG-73 |  |  |
| 185 | 109 | Study on OAM support for assessment of energy efficiency in mobile access networks |  | 421d? | 2015-11-02 A | 2017-06-09 | 90% | 42.1d? |  |  |  | 399d | finish no earlier than 2017-06-09 | S5 | 3368h | 3031.2h | FS_OAM_EE | Cornily,Jean-Michel, ORANGE | Rel-15 | PCG-36 | TR 32.856 | jeanmichel.cornily@orange.com | SP-70 |  |  |
| 186 | 110 | Study on OAM aspects of SON for AAS-based deployments |  | 421d? | 2015-11-02 A | 2017-06-09 | 70% | 126.3d? |  |  |  | 399d | finish no earlier than 2017-06-09 | S5 | 3368h | 2357.6h | FS_OAM_SON_AAS | Nokia Networks (Yizhi Yao) | Rel-15 | PCG-36 | TR (new) | Yizhi.yao@nokia.com | SP-70 |  |  |
| 187 | 111 | Study on Implementation for the Partitioning of Itf-N |  | 534d? | 2016-03-01 A | 2018-03-15 | 40% | 320.4d? |  |  |  | 200d | finish no earlier than 2018-03-15 | S5 | 4272h | 1708.8h | FS_IMP_ITFN | Hu, Yaxi, China Mobile | Rel-15 | PCG-36 | New TR 32.880 | huyaxi@cmdi.chinamobile.com | TSG#71 |  |  |
| 188 | 112 | Study on Management Aspects of Next Generation Network architecture and features |  | 261d? | 2016-06-13 A | 2017-06-09 | 40% | 156.6d? |  |  |  | 399d | finish no earlier than 2017-06-09 | S5 | 2088h | 835.2h | FS_MAN_NGNAF | Nokia Networks, Yizhi Yao | Rel-15 | PCG-37 | TR (new); 28.802 | Yizhi.yao@nokia.com | TSG#72 |  |  |
| 189 | 113 | Study on Management and Orchestration Architecture of Next Generation Network and Service |  | 261d? | 2016-06-13 A | 2017-06-09 | 10% | 234.9d? |  |  |  | 399d | finish no earlier than 2017-06-09 | S5 | 2088h | 208.8h | FS_NGNS_MOA | Huawei Technologies, Zou Lan | Rel-15 | PCG-37 | TR xy.abc; 28.800 | zoulan@huawei.com | TSG#72 |  |  |
| 190 | 114 | Study on management and orchestration of network slicing for next generation network |  | 261d? | 2016-06-13 A | 2017-06-09 | 60% | 104.4d? |  |  |  | 399d | finish no earlier than 2017-06-09 | S5 | 2088h | 1252.8h | FS_MONETS | Ericsson , Robert Petersen | Rel-15 | PCG-37 | 32.8xx; 28.801 |  | TSG#72 |  |  |
| 191 | 115 | Study on SON for eCoMP for LTE |  | 263d? | 2016-06-15 A | 2017-06-15 | 60% | 105.2d? |  |  |  | 395d | finish no earlier than 2017-06-15 | R3 | 2104h | 1262.4h | FS_LTE_SON_eCOMP | Nokia | Rel-15 | PCG-37 |  |  | TSG#72 |  |  |
| 192 | 116 | Study on IMS Enhanced Spoofed Call Prevention and Detection |  | 849d? | 2014-09-19 A | 2017-12-15 | 30% | 594.3d? |  |  |  | 264d | finish no earlier than 2017-12-15 | S3 | 6792h | 2037.6h | FS_ESCAPADES | Sprint | Rel-15 | PCG-33 | 33.832 | Gregory.schumacher@sprint.com | SP-64 |  | FS_ESCAPADES |
| 193 | 117 | Study on Compliance of 3GPP SA5 specifications to the NGMN NGCOR |  | 1442d? | 2012-06-26 A | 2017-12-15 | 60% | 576.8d? | 2012-06-20 | 2015-09-16 | 854d? | 264d | finish no earlier than 2017-12-15 | S5 | 11536h | 6921.6h | FS_OAM_NGMN_NGCOR | Huawei | Rel-15 | PCG-29 | TR 32.837, TR 28.821 | zoulan@huawei.com | SP-56 | Mirko | FS_OAM_NGMN_NGCOR |
| 194 | 118 | Release 14 Features | milestone | 0d? | 2014-12-12 A | 1986-07-04 A | 100% |  |  |  |  |  | start no earlier than 2014-12-12 |  |  |  |  |  | Rel-14 |  |  |  |  |  |  |
| 195 | 119 | Release 14 on Mission Critical | milestone | 0d? | 2016-06-09 A | 2016-06-09 A | 100% |  |  |  |  |  | finish no earlier than 2016-06-09 |  |  |  |  |  | Rel-14 |  |  |  |  |  |  |

Notes:
- 137: compare REL-14 WI LTE_TDD_3550_CBRS_US; related to LTE band 48, intending a new band definition; includes 2DL/2UL CA with B2
- 138: compare REL-14 WI LTE_TDD_3550_CBRS_US; related to LTE band 48, intending a new band definition; includes 2DL/2UL CA with B2
- 139: compare REL-14 WI LTE_TDD_3550_CBRS_US; related to LTE band 48, intending a new band definition; includes 2DL/2UL CA with B2
- 140: -
- 141: -
- 142: 6/10/16: Acronym FS_MA_RVNF ->FS_MA_RNVNF ; 6/10/16: 32.864 added; 1/12/16: 0%->5; 6/3/17: 5%->10
- 144: -
- 145: 22.xxx; 1/12/16: 0%->5; 2/3/17: 5%->45
- 147: 28/7/16: 23.781 added; 19/9/16: WID:SP-160340->SP-160526; FCD: 09/16->12/16; 19/9/16: 0%->40; 1/12/16: WID:SP-160526->SP-160880; 1/12/16: 40%->48; 9/12/16: FCD:12/16->06/17, Rel-14->Rel-15; 3/3/17: 48%->60
- 148: 28/7/16: 23.782 added; 19/9/16: WID:SP-160341->SP-160527; 19/9/16: 0%->20; 1/12/16: WID:SP-160527->SP-160881; 1/12/16: 20%->22; 9/12/16: FCD:12/16->06/17, Rel-14->Rel-15; 3/3/17: 22%->50
- 149: 1/12/16: 0%->5. Study on Stage 2 for REAR. When normative work completed, Stage 1 and Stage 2 shall be in the same release; 6/3/17: 5%->30
- 151: 1/12/16: 0%->10; 6/3/17: 10%->30
- 152: 1/12/16: 0%->5; 6/3/17: 5%->50
- 153: 28/7/16: 23.751 added; 19/9/16: 0%->10., 7/12/16: moved from Rel-14, according to SP-160806; 6/3/17: 10%->80
- 154: 9/6/16: 0%->6; 28/7/16: 23.798 added; 1/12/16: FCD:09/16->12/16; 1/12/16: 6%->15. 7/12/16: Moved from Rel-14 according to SP-160806.; 6/3/17: 15%->50
- 155: 22.xxx; 1/12/16: 0%->10; 2/3/17: 10%->15; 2/3/17: WID:SP-160556->SP-170166; 10/3/17: FCD:06/17->06/20; 21/3/17: 22.819 added;
- 156: 1/7/16: Compl:0%->50%; 28/7/16: 36.740 added; 26/9/16: WID: RP-161328->RP-161670; 20/12/16: CD:Thu 15/0;21/3/17: CD:Fri 15...
- 157: 1/12/16: 0%->75; 2/3/17: 75%->100
- 158: 2/3/17: 0%->20
- 159: 6/10/16: 32.866 added; 1/12/16: 0%->5
- 160: 6/10/16: 36.766 added; 20/12/16: Compl:0%->35% 21/3/17: Compl:35%->65%
- 161: 6/3/17: 0%->5
- 162: 6/3/17: 0%->30; 21/3/17: 29.827 added;
- 163: ; 21/3/17: WID: RP-162541->RP-170403; 21/3/17: 36.754 added;
- 164: 1/7/16: Compl:0%->2%;26/9/16: Compl:2%->5%; 6/10/16: 36.746 added; 20/12/16: Compl:5%->15%;21/3/17: Compl:15%->35%; ; …
- 165: 11/6/16: 0%->10; 19/9/16: 10%->40, FCD: 12/16->03/17; 1/12/16: FCD:03/17->06/17; 1/12/16: 40%->35; 14/12/16: 35%->45; 14/12/16: FCD:06/17->09/17; 6/3/17: 45%->55
- 166: 21/3/17: 31.801 added;
- 167: 21/3/17: added impacted TR
- 168: TR 38.8XX
- 169: TR 25.7XX
- 170: TR 36.7XX
- 171: CU = central unit, DU = distributed unit; results will be captured in existing TR 38.801
- 172: TR 38.8XX
- 173: TR 38.8XX
- 174: TR 38.8XX
- 175: TR 38.8XX
- 176: TR 38.8XX
- 177: TR 36.8XX
- 179: 11/6/16: 0%->10; 19/9/16: 10%->30, FCD: 12/16->06/17; 21/3/17: Moved from Rel-14 (not completed on time)
- 180: SP#65 completion 09/14=>12/14. Moved to Rel-13. Dec.14: 30->35%, CD 12/14->03/15. Mar.15: CD: 06/16. 40%; June2015: Compl:40%->45. . 15/4/16: moved from R...; 21/3/17: Moved from Rel-14 (not completed on time)
- 181: 19/9/16: 0%->30; 6/10/16: 26.917 added; 1/12/16: 30%->60; 1/12/16: FCD:12/16->03/17; 6/3/17: 60%->75; 6/3/17: FCD:03/17->06/17; 21/3/17: Moved from Rel-14 (not completed on time)
- 182: 6/10/16: 32.857 added; 1/12/16: 0%->5; 21/3/17: moved from Rel-14
- 183: Aug2015: moved to Rel-14 (email CT and EG); 07/09/15: 0%->5; 7/3/16: 5%->10; 13/6/16: FCD:03/16->09/16; 19/9/16: FCD: 09/16->06/17; 6/3/17: FCD:03/17->12/17; 21/3/17: moved from rel-14
- 184: 6/10/16: 32.870 added; 1/12/16: 0%->10; 21/3/17: moved from rel-14
- 185: 13/6/16: WID:SP-150674->SP-160430; 13/6/16: 0%->55; 1/12/16: 55%->80; 6/3/17: FCD:03/17->06/17; 6/3/17: 80%->90; 21/3/17: moved from rel-14
- 186: 13/6/16: 0%->40; 19/9/16: FCD:09/16->12/16; 19/9/16: 40%->60; 1/12/16: FCD:12/16->03/17; 1/12/16: 60%->70; 6/3/17: FCD:03/17->06/17; 21/3/17: moved from rel-14
- 187: 13/6/16: 0%->10; 19/9/16: 10%->35; 1/12/16: 35%->40; 6/3/17: FCD:03/17->03/18; 21/3/17: moved from rel-14
- 188: 28/7/16: 28.802 added; 19/9/16: 0%->5; 1/12/16: 5%->10; 6/3/17: FCD:03/17->06/17; 6/3/17: 10%->40; 21/3/17: moved from rel-14
- 189: 28/7/16: 28.800 added; 19/9/16: 0%->10; 6/3/17: FCD:03/17->06/17; 21/3/17: moved from rel-14
- 190: 28/7/16: 28.801 added; 19/9/16: 0%->10; 1/12/16: 10%->25; 6/3/17: FCD:03/17->06/17; 6/3/17: 25%->60; 21/3/17: moved from rel-14
- 191: 26/9/16: Compl:0%->10%. ; 20/12/16: Compl:10%->40%21/3/17: Compl:40%->60%;...
- 192: Dec.14: TR number added. 3/3/15: 0->5%; June2015: Compl:5%->25; 9/12/15: 25%->30; 21/3/17: moved from Rel-13; 21/3/17: FCD:09/15->12/17
- 193: SP#65 updated WID SP-140349=>SP-140539. Dec.14: 35->45, 12/14: 28.821 added. Mar 15: 45->50%; June2015: Compl:50%->60. 07/09/15: FCD: 09/15->12/15; 7/12/15: FCD:12/15->03/16; 21/3/17: moved from Rel-13; 21/3/17: FCD:03/16->12/17
- 194: -
- 195: -

| ID | WBS | Task | Duration | Start | Finish | Complete | Remaining | Total slack | Constraint | Resources | Work | Actual work | Acronym | PCG approved | Release | TSG approved | Impacted TSs and TRs | WI rapporteur name | WI rapporteur e-mail |
| --- | --- | --- | --- | --- | --- | --- | --- | --- | --- | --- | --- | --- | --- | --- | --- | --- | --- | --- | --- |
| 196 | 120 | **Mission Critical Improvements** | 569d? | 2015-04-14 A | 2017-06-15 | 64% | 205.68d? | 395d |  |  | 29232h | 17305.2h | MCImp | PCG-36 | Rel-14 | SP-70 |  |  |  |
| 197 | 120.1 | Mission Critical Push to Talk over LTE Realignment | 138d? | 2015-12-07 A | 2016-06-15 A | 100% |  |  | finish no earlier than 2016-06-15 | S1 | 1104h | 1104h | MCImp-MCPTTR | PCG-36 | Rel-14 | SP-70 | 22.179 | Andrew Thiessen | andrew (at) its (dot) bldrdoc (dot) gov |
| 198 | 120.2 | **Enhancements for Mission Critical Push To Talk** | 264d? | 2016-06-13 A | 2017-06-14 | 42% | 152.87d? | 396d |  |  | 5624h | 2162.92h | MCImp-eMCPTT | PCG-37 | Rel-14 | TSG#72 | TS 23.379, TS 23.280, TS 23.281, TS 23.282; 23.379 | Lazara, Dom | dom.lazara@motorolasolutions.com |
| 199 | 120.2.1 | Stage 2 of Enhancements for Mission Critical Push To Talk | 135d? | 2016-06-13 A | 2016-12-15 A | 100% |  |  | finish no earlier than 2016-12-15 | S6 | 1080h | 1080h | MCImp-eMCPTT | PCG-37 | Rel-14 | TSG#72 | TS 23.379, TS 23.280, TS 23.281, TS 23.282; 23.379 | Lazara, Dom | dom.lazara@motorolasolutions.com |
| 200 | 120.2.2 | **Stage 3 of Enhancements for Mission Critical Push To Talk** | 140d? | 2016-12-01 A | 2017-06-14 | 24% | 106.64d? | 396d |  | ct | 4544h | 1082.92h | MCImp-eMCPTT-CT |  | Rel-14 |  |  | FREDERICKS, Bob | bobfredericks@motorolasolutions.com |
| 201 | 120.2.2.1 | CT1 aspects of Enhancements for Mission Critical Push To Talk | 140d? | 2016-12-01 A | 2017-06-14 | 20% | 112d? | 396d | finish no earlier than 2017-06-14 | C1 | 1120h | 224h | MCImp-eMCPTT-CT |  | Rel-14 |  | 24.379, 24.380, 24.381, 24.382, 24.383, 24.384 | FREDERICKS, Bob | bobfredericks@motorolasolutions.com |
| 202 | 120.2.2.2 | CT3 aspects of Enhancements for Mission Critical Push To Talk | 74d? | 2016-12-01 | 2017-03-14 |  |  | 462d | finish no earlier than 2017-03-14 | C3 | 592h |  | MCImp-eMCPTT-CT |  | Rel-14 |  | 29.165, 29.213, 29.214 | FREDERICKS, Bob | bobfredericks@motorolasolutions.com |
| 203 | 120.2.2.3 | CT4 aspects of Enhancements for Mission Critical Push To Talk | 74d? | 2016-12-01 A | 2017-03-14 A | 100% |  |  | finish no earlier than 2017-03-14 | C4 | 592h | 592h | MCImp-eMCPTT-CT |  | Rel-14 |  | 23.003, 29.228, 23.335, 29.283 | FREDERICKS, Bob | bobfredericks@motorolasolutions.com |
| 204 | 120.2.2.4 | CT6 aspects of Enhancements for Mission Critical Push To Talk | 140d? | 2016-12-01 | 2017-06-14 |  |  | 396d | finish no earlier than 2017-06-14 | C6 | 1120h |  | MCImp-eMCPTT-CT |  | Rel-14 |  | 31.102, 31.103 | FREDERICKS, Bob | bobfredericks@motorolasolutions.com |
| 205 | 120.3 | Mission Critical Services Common Requirements | 138d? | 2015-12-07 A | 2016-06-15 A | 100% |  |  | finish no earlier than 2016-06-15 | S1 | 1104h | 1104h | MCImp-MCCoRe | PCG-36 | Rel-14 | SP-70 | New TS 22.280 | Andrew Thiessen | andrew (at) its (dot) bldrdoc (dot) gov |
| 206 | 120.4 | Common functional architecture to support mission critical services | 135d? | 2016-06-13 A | 2016-12-15 A | 100% |  |  | finish no earlier than 2016-12-15 | S6 | 1080h | 1080h | MCImp-MC_ARCH | PCG-37 | Rel-14 | TSG#72 | TS 23.280, TS 23.379, TS 23.281, TS 23.282; 23.280 | Niranth Amogh, Huawei Telecommunications India | namogh@huawei.com |
| 207 | 120.5 | **Mission Critical Video over LTE** | 568d? | 2015-04-14 A | 2017-06-14 | 65% | 196.28d? | 396d |  |  | 8528h | 5134.51h | MCImp-MCVideo | PCG-36 | Rel-14 | SP-70 |  | Emmanuelle Villebrun | Emmanuelle.villebrun@gendarmerie.interieur.gouv.fr |
| 208 | 120.5.1 | Study on Mission Critical Video over LTE | 176d? | 2015-04-14 A | 2015-12-15 A | 100% |  |  | finish no earlier than 2015-12-15 | S1 | 1408h | 1408h | FS_MCVideo | PCG-34 | Rel-14 | SP-67 | New TR 22.879 | Villebrun, Emmanuelle (French MoI) | emmanuelle.villebrun@gendarmerie.interieur.gouv.fr |
| 209 | 120.5.2 | Stage 1 of MCVideo | 138d? | 2015-12-07 A | 2016-06-15 A | 100% |  |  | finish no earlier than 2016-06-15 | S1 | 1104h | 1104h | MCImp-MCVideo | PCG-36 | Rel-14 | SP-70 | New TR 22.281 | Emmanuelle Villebrun | Emmanuelle.villebrun@gendarmerie.interieur.gouv.fr |
| 210 | 120.5.3 | Stage 2 for MCVideo | 135d? | 2016-06-13 A | 2016-12-15 A | 100% |  |  | finish no earlier than 2016-12-15 | S6 | 1080h | 1080h | MCImp-MCVideo | PCG-37 | Rel-14 | TSG#72 | TS 23.281, TS 23.280, TS 23.379, TS 23.282; 23.281 | Niranth Amogh, Huawei Telecommunications India | namogh@huawei.com |
| 211 | 120.5.4 | MCVideo codecs and media handling | 47d? | 2017-01-11 A | 2017-03-16 A | 100% |  |  | finish no earlier than 2017-03-16 | S4 | 376h | 376h | MCImp-MCVideo |  | Rel-14 |  | 26.281 | John Lambrou (Motorola Solutions) | john (dot) lambrou (at) motorolasolutions (dot) com |
| 212 | 120.5.5 | **Stage 3 of MCVideo** | 140d? | 2016-12-01 A | 2017-06-14 | 26% | 104.19d? | 396d |  | ct | 4560h | 1166.51h | MCImp-MCVIDEO-CT |  | Rel-14 |  | 24.581, 24.281 | PATEL, Milan | milan.patel@huawei.com |
| 213 | 120.5.5.1 | CT1 aspects 3 of MCVideo | 140d? | 2016-12-01 A | 2017-06-14 | 25% | 105d? | 396d | finish no earlier than 2017-06-14 | C1 | 1120h | 280h | MCImp-MCVIDEO-CT |  | Rel-14 |  | 24.381, 24.382, 24.383, 24.384 | PATEL, Milan | milan.patel@huawei.com |
| 214 | 120.5.5.2 | CT3 aspects 3 of MCVideo | 75d? | 2016-12-01 | 2017-03-15 |  |  | 461d | finish no earlier than 2017-03-15 | C3 | 600h |  | MCImp-MCVIDEO-CT |  | Rel-14 |  | 29.165, 29.213, 29.214 | PATEL, Milan | milan.patel@huawei.com |
| 215 | 120.5.5.3 | CT4 aspects 3 of MCVideo | 75d? | 2016-12-01 A | 2017-03-15 A | 100% |  |  | finish no earlier than 2017-03-15 | C4 | 600h | 600h | MCImp-MCVIDEO-CT |  | Rel-14 |  | 23.003, 23.335, 29.283 | PATEL, Milan | milan.patel@huawei.com |
| 216 | 120.5.5.4 | CT6 aspects 3 of MCVideo | 140d? | 2016-12-01 | 2017-06-14 |  |  | 396d | finish no earlier than 2017-06-14 | C6 | 1120h |  | MCImp-MCVIDEO-CT |  | Rel-14 |  | 31.102, 31.103 | PATEL, Milan | milan.patel@huawei.com |
| 217 | 120.6 | **Mission Critical Data over LTE** | 568d? | 2015-04-14 A | 2017-06-14 | 61% | 220.35d? | 396d |  |  | 8152h | 4535.81h | MCImp-MCData | PCG-36 | Rel-14 | SP-70 |  | Emmanuelle Villebrun | Emmanuelle.villebrun@gendarmerie.interieur.gouv.fr |
| 218 | 120.6.1 | Study on Mission Critical Data Communications | 176d? | 2015-04-14 A | 2015-12-15 A | 100% |  |  | finish no earlier than 2015-12-15 | S1 | 1408h | 1408h | FS_MCDATA | PCG-34 | Rel-14 | SP-67 | New TR 22.880 | Villebrun, Emmanuelle (French MoI) | emmanuelle.villebrun@gendarmerie.interieur.gouv.fr |
| 219 | 120.6.2 | Stage 1 of MCData | 138d? | 2015-12-07 A | 2016-06-15 A | 100% |  |  | finish no earlier than 2016-06-15 | S1 | 1104h | 1104h | MCImp-MCData | PCG-36 | Rel-14 | SP-70 | New TR 22.282 | Emmanuelle Villebrun | Emmanuelle.villebrun@gendarmerie.interieur.gouv.fr |
| 220 | 120.6.3 | Stage 2 for MCData | 135d? | 2016-06-13 A | 2016-12-15 A | 100% |  |  | start no earlier than 2016-06-13 | S6 | 1080h | 1080h | MCImp-MCData | PCG-37 | Rel-14 | TSG#72 | 23.282 | David Freeman (UK Home Office) | david@dnf-consulting.co.uk |

Notes:
- 196: Umbrella Feature
- 197: 2/3/16: FCD: 03/16->06/16. ES in SP-160102; 0->75%; 9/6/16: 75%->100
- 198: 28/7/16: 23.379 added; 19/9/16: 0%->35; 1/12/16: 35%->100
- 199: 28/7/16: 23.379 added; 19/9/16: 0%->35; 1/12/16: 35%->100
- 201: 6/3/17: 0%->20
- 203: 6/3/17: 0%->100
- 205: 2/3/16: FCD: 03/16->06/16. ES in SP-160104; 0->75%; 9/6/16: 75%->100
- 206: 28/7/16: 23.280 added; 19/9/16: 0%->40; 1/12/16: 40%->95; 3/3/17: 95%->100
- 207: 2/3/16: FCD: 03/16->06/16. ES in SP-160106; 0->80%; 9/6/16: 80%->100
- 208: 1/4/15:TR number added; June2015: Compl:0%->50; 07/09/15: 50%->70; 7/12/15: 70%->100
- 209: 2/3/16: FCD: 03/16->06/16. ES in SP-160106; 0->80%; 9/6/16: 80%->100
- 210: 28/7/16: 23.281 added; 19/9/16: 0%->25; 1/12/16: 25%->95; 3/3/17: 95%->100
- 211: 6/3/17: 0%->100
- 213: 6/3/17: 0%->25
- 215: 6/3/17: 0%->100
- 217: 2/3/16: FCD: 03/16->06/16. ES in SP-160109; 0->80%; 9/6/16: 80%->100
- 218: 1/4/15:TR number added; June2015: Compl:0%->20; 07/09/15: 20%->90; 7/12/15: 90%->100
- 219: 2/3/16: FCD: 03/16->06/16. ES in SP-160109; 0->80%; 9/6/16: 80%->100
- 220: 28/7/16: 23.282 added; 19/9/16: 0%->10; 1/12/16: 10%->95; 3/3/17: 95%->100

| ID | WBS | Task | Type | Duration | Start | Finish | Complete | Remaining | Total slack | Constraint | Resources | Work | Actual work | Acronym | WI rapporteur name | WI rapporteur e-mail | Release | PCG approved | TSG approved | Status Report |
| --- | --- | --- | --- | --- | --- | --- | --- | --- | --- | --- | --- | --- | --- | --- | --- | --- | --- | --- | --- | --- |
| 221 | 120.6.4 | **Stage 3 of MCData** |  | 140d? | 2016-12-01 A | 2017-06-14 | 21% | 111.02d? | 396d |  | ct | 4560h | 943.81h | MCImp-MCDATA-CT | HASON, Baruh | baruh.hason@motorolasolutions.com | Rel-14 |  |  |  |
| 222 | 120.6.4.1 | CT1 aspects of MCData |  | 140d? | 2016-12-01 A | 2017-06-14 | 10% | 126d? | 396d | finish no earlier than 2017-06-14 | C1 | 1120h | 112h | MCImp-MCDATA-CT | HASON, Baruh | baruh.hason@motorolasolutions.com | Rel-14 |  |  |  |
| 223 | 120.6.4.2 | CT3 aspects of MCData |  | 75d? | 2016-12-01 | 2017-03-15 |  |  | 461d | finish no earlier than 2017-03-15 | C3 | 600h |  | MCImp-MCDATA-CT | HASON, Baruh | baruh.hason@motorolasolutions.com | Rel-14 |  |  |  |
| 224 | 120.6.4.3 | CT4 aspects of MCData |  | 75d? | 2016-12-01 A | 2017-03-15 A | 100% |  |  | finish no earlier than 2017-03-15 | C4 | 600h | 600h | MCImp-MCDATA-CT | HASON, Baruh | baruh.hason@motorolasolutions.com | Rel-14 |  |  |  |
| 225 | 120.6.4.4 | CT6 aspects of MCData |  | 140d? | 2016-12-01 | 2017-06-14 |  |  | 396d | finish no earlier than 2017-06-14 | C6 | 1120h |  | MCImp-MCDATA-CT | HASON, Baruh | baruh.hason@motorolasolutions.com | Rel-14 |  |  |  |
| 226 | 120.7 | Security of the Mission Critical Service |  | 194d? | 2016-09-19 A | 2017-06-15 | 60% | 77.6d? | 395d | finish no earlier than 2017-06-15 | S3 | 1552h | 931.2h | MCSec | Haigh, Peter, CESG | peter.haigh@cesg.gsi.gov.uk | Rel-14 | PCG-37 | TSG-73 |  |
| 227 | 120.8 | Study on Mission Critical Security Enhancements |  | 261d? | 2016-06-17 A | 2017-06-15 | 60% | 104.4d? | 395d | finish no earlier than 2017-06-15 | S3 | 2088h | 1252.8h | FS_MC_Sec | Haigh, Peter, CESG | peter.haigh@cesg.gsi.gov.uk | Rel-14 | PCG-37 | SP-72 |  |
| 228 | 121 | **Protocol enhancements for MCPTT over LTE** |  | 129d? | 2016-09-16 A | 2017-03-15 | 75% | 32.25d? | 461d |  | ct | 5160h | 3870h | MCPTTProtoc1 | Ricky Kaura | ricky.kaura@samsung.com | Rel-14 | PCG-37 | TSG-73 |  |
| 229 | 121.1 | CT1 aspects of MCPTTProtoc1 |  | 129d? | 2016-09-16 A | 2017-03-15 A | 100% |  |  | finish no earlier than 2017-03-15 | C1 | 1032h | 1032h | MCPTTProtoc1 | Ricky Kaura | ricky.kaura@samsung.com | Rel-14 | PCG-37 | TSG-73 |  |
| 230 | 121.2 | CT3 aspects of MCPTTProtoc1 |  | 129d? | 2016-09-16 A | 2017-03-15 A | 100% |  |  | finish no earlier than 2017-03-15 | C3 | 1032h | 1032h | MCPTTProtoc1 | Ricky Kaura | ricky.kaura@samsung.com | Rel-14 | PCG-37 | TSG-73 |  |
| 231 | 121.3 | CT4 aspects of MCPTTProtoc1 |  | 129d? | 2016-09-16 A | 2017-03-15 A | 100% |  |  | finish no earlier than 2017-03-15 | C4 | 1032h | 1032h | MCPTTProtoc1 | Ricky Kaura | ricky.kaura@samsung.com | Rel-14 | PCG-37 | TSG-73 |  |
| 232 | 121.4 | CT6 aspects of MCPTTProtoc1 |  | 129d? | 2016-09-16 | 2017-03-15 |  |  | 461d | finish no earlier than 2017-03-15 | C6 | 1032h |  | MCPTTProtoc1 | Ricky Kaura | ricky.kaura@samsung.com | Rel-14 | PCG-37 | TSG-73 |  |
| 233 | 122 | Release 14 on V2X | milestone | 0d? | 2016-06-09 A | 2016-06-09 A | 100% |  |  | finish no earlier than 2016-06-09 |  |  |  |  |  |  | Rel-14 |  |  |  |
| 234 | 123 | **LTE support for V2X services** |  | 681d? | 2015-02-09 A | 2017-09-15 | 78% | 147.03d? | 329d |  |  | 16440h | 13010h | V2XLTE |  |  | Rel-14 | PCG-35 | SP-68 |  |
| 235 | 123.1 | Stage 1 for LTE support for V2X services |  | 137d? | 2015-09-09 A | 2016-03-17 A | 100% |  |  | finish no earlier than 2016-03-17 | S1 | 1096h | 1096h | V2XLTE |  |  | Rel-14 | PCG-35 | SP-68 |  |
| 236 | 123.2 | Architecture enhancements for LTE support of V2X services |  | 137d? | 2016-06-09 A | 2016-12-15 A | 100% |  |  | finish no earlier than 2016-12-15 | S2 | 1096h | 1096h | V2XARC | LG Electronics, LaeYoung Kim | laeyoung.kim@lge.com | Rel-14 | PCG-37 | TSG#72 |  |
| 237 | 123.3 | Security aspect of LTE support of V2X services |  | 141d? | 2016-12-01 A | 2017-06-15 | 75% | 35.25d? | 395d | finish no earlier than 2017-06-15 | S3 | 1128h | 846h | V2XLTE-Sec | Huawei, Marcus Wong | mwong@huawei.com | Rel-14 |  |  |  |
| 238 | 123.4 | **RAN aspects of LTE-based V2X Services** |  | 329d? | 2016-06-15 A | 2017-09-15 | 37% | 205.78d? | 329d |  |  | 4208h | 1576h | LTE_V2X | LG Electronics |  | Rel-14 | PCG-37 | TSG#72 |  |
| 239 | 123.4.1 | Core part: LTE-based V2X Services |  | 197d? | 2016-06-15 A | 2017-03-15 A | 100% |  |  | finish no earlier than 2017-03-15 | R1 | 1576h | 1576h | LTE_V2X-Core | LG Electronics |  | Rel-14 | PCG-37 | TSG#72 | RP-170237 |
| 240 | 123.4.2 | Perf. part: LTE-based V2X Services |  | 329d? | 2016-06-15 | 2017-09-15 |  |  | 329d | finish no earlier than 2017-09-15 | R4 | 2632h |  | LTE_V2X-Perf | LG Electronics |  | Rel-14 | PCG-37 | TSG#72 |  |
| 241 | 123.5 | **CT aspects of V2X Services** |  | 129d? | 2016-09-16 A | 2017-03-15 | 90% | 12.9d? | 461d |  | ct | 5160h | 4644.03h | V2X-CT | Taehun Kim | taehun78.kim@lge.com | Rel-14 | PCG-37 | TSG-73 |  |
| 242 | 123.5.1 | CT1 aspects of V2X Services |  | 129d? | 2016-09-16 A | 2017-03-15 A | 100% |  |  | finish no earlier than 2017-03-15 | C1 | 1032h | 1032h | V2X-CT | Taehun Kim | taehun78.kim@lge.com | Rel-14 | PCG-37 | TSG-73 |  |
| 243 | 123.5.2 | CT3 aspects of V2X Services |  | 129d? | 2016-09-16 A | 2017-03-15 | 60% | 51.6d? | 461d | finish no earlier than 2017-03-15 | C3 | 1032h | 619.2h | V2X-CT | Taehun Kim | taehun78.kim@lge.com | Rel-14 | PCG-37 | TSG-73 |  |
| 244 | 123.5.3 | CT4 aspects of V2X Services |  | 129d? | 2016-09-16 A | 2017-03-15 A | 100% |  |  | finish no earlier than 2017-03-15 | C4 | 1032h | 1032h | V2X-CT | Taehun Kim | taehun78.kim@lge.com | Rel-14 | PCG-37 | TSG-73 |  |
| 245 | 123.5.4 | CT6 aspects of V2X Services |  | 129d? | 2016-09-16 A | 2017-03-15 A | 100% |  |  | finish no earlier than 2017-03-15 | C6 | 1032h | 1032h | V2X-CT | Taehun Kim | taehun78.kim@lge.com | Rel-14 | PCG-37 | TSG-73 |  |

Notes:
- 221: Impacted TSs and TRs: 24.582, 24.282
- 222: 6/3/17: 0%->10 / Impacted TSs and TRs: 24.381, 24.382, 24.383, 24.384
- 223: Impacted TSs and TRs: 29.165, 29.213, 29.214
- 224: 6/3/17: 0%->100 / Impacted TSs and TRs: 23.003, 23.335, 29.283
- 225: Impacted TSs and TRs: 31.102, 31.103
- 226: 6/10/16: 33.180 added; 1/12/16: 0%->25; 6/3/17: 25%->60 / Impacted TSs and TRs: 33.180
- 227: 28/7/16: 33.280 added; 28/7/16: 39.880 added; 19/9/16: WID:SP-160374->SP-160567. FCD: 12/16->03/17; 1/12/16: 0%->35; 6/3/17: FCD:03/17->06/17; 6/3/17: 35%->60 / Impacted TSs and TRs: TR 33.xxx; 33.280; 39.880
- 228: This Feature is a stage-3 only feature that fixes/enhances MCPTT protocol level (not visible from stage2). Not to be confused with Rel-14 MCPTT Stage 3.
- 229: 6/3/17: 5%->100 / Impacted TSs and TRs: 24.229, 24.379, 24.380, 24.381, 24.382, 24.383, 24.384, 24.980
- 230: 2/12/16: 0%->20; 6/3/17: 20%->100 / Impacted TSs and TRs: 29.165, 29.212, 29.213, 29.214
- 231: 6/3/17: 0%->100 / Impacted TSs and TRs: 23.003, 23.008, 29.283
- 232: Impacted TSs and TRs: 31.102
- 233: -
- 234: 7/12/15: 0%->5; 28/1/16: 22.185 added; 2/3/16: 5%->90; 9/6/16: 90%->100 / Impacted TSs and TRs: 22.278; 22.185
- 235: 7/12/15: 0%->5; 28/1/16: 22.185 added; 2/3/16: 5%->90; 9/6/16: 90%->100 / Impacted TSs and TRs: 22.278; 22.185
- 236: 28/7/16: 23.285 added; 19/9/16: 0%->85; 1/12/16: FCD:09/16->12/16; 1/12/16: 85%->100 / Impacted TSs and TRs: 23.285
- 237: 6/3/17: 0%->75 / Impacted TSs and TRs: 33.185
- 238: follow-up WI of REL-14 SI FS_LTE_V2X
- 239: follow-up WI of REL-14 SI FS_LTE_V2X26/9/16: Compl:0%->15%26/9/16: WID: RP-161298->RP-161894; 6/10/16: 36.786 added; 6/10/16: added; 20/12/16: Compl:15%->75% 21/3/17: Compl:75%->100%; ; ... / Impacted TSs and TRs: 36.786;
- 240: ; 26/9/16: WID: RP-161298->RP-161894; 20/12/16: WID: RP-161894->RP-162519; 20/12/16: Stat Rep: ->RP-162519
- 242: 6/10/16: 24.385 added; 6/10/16: 24.386 added; 2/12/16: 0%->65; 6/3/17: 65%->100 / Impacted TSs and TRs: 23.122, 24.301, 24.334; 24.385; 24.386
- 243: 6/10/16: 29.387 added; 2/12/16: 0%->40; 6/3/17: 40%->60 / Impacted TSs and TRs: 29.212, 29.468; 29.387
- 244: 6/10/16: 29.388 added; 6/10/16: 29.389 added; 2/12/16: 0%->80; 6/3/17: 80%->100 / Impacted TSs and TRs: 23.003, 23.007, 23.008, 29.272; 29.388; 29.389
- 245: 7/3/17: 0%->100 / Impacted TSs and TRs: 31.102, 31.111

| ID | WBS | Task | Type | Duration | Start | Finish | Complete | Remaining | Total slack | Constraint | Resources | Work | Actual work | Acronym | PCG approved | WI rapporteur name | WI rapporteur e-mail | Release | TSG approved |
| --- | --- | --- | --- | --- | --- | --- | --- | --- | --- | --- | --- | --- | --- | --- | --- | --- | --- | --- | --- |
| 246 | 123.6 | **Study on LTE support for V2X services** |  | 355d? | 2015-02-09 A | 2016-06-17 A | 100% |  |  |  |  | 3752h | 3752h | FS_V2XLTE | PCG-34 | Ki-Dong Lee (LG electronics) | kidong.lee@lge.com | Rel-14 | SP-67 |
| 247 | 123.6.1 | Study on Stage 1 of LTE support for V2X services |  | 1d? | 2015-02-09 A | 2015-02-09 A | 100% |  |  | start no earlier than 2015-09-07 | S1 | 8h | 8h | FS_V2XLTE | PCG-34 | Ki-Dong Lee (LG electronics) | kidong.lee@lge.com | Rel-14 | SP-67 |
| 248 | 123.6.2 | Study on Stage 2 of LTE support for V2X services |  | 205d? | 2015-09-07 A | 2016-06-17 A | 100% |  |  | finish no earlier than 2016-06-17 | S2 | 1640h | 1640h | FS_V2XARC | PCG-36 | LG Electronics, LaeYoung Kim | laeyoung.kim@lge.com | Rel-14 | SP-70 |
| 249 | 123.6.3 | RAN1 Study on LTE-based V2X Services |  | 263d? | 2015-06-15 A | 2016-06-15 A | 100% |  |  | finish no earlier than 2016-09-15 | R1 | 2104h | 2104h | FS_LTE_V2X | PCG-35 | LG Electronics |  | Rel-14 | TSG-68 |
| 250 | 124 | **Support for V2V services based on LTE sidelink** |  | 460d? | 2015-12-15 A | 2017-09-15 | 65% | 162.21d? | 329d |  |  | 6840h | 4428h | LTE_SL_V2V | PCG-36 | LG Electronics |  | Rel-14 | RP-70 |
| 251 | 124.1 | Core part: Support for V2V services based on LTE sidelink |  | 199d? | 2015-12-15 A | 2016-09-15 A | 100% |  |  | finish no earlier than 2016-09-15 | R1 | 1592h | 1592h | LTE_SL_V2V-Core | PCG-36 | LG Electronics |  | Rel-14 | RP-70 |
| 252 | 124.2 | Perf. part: Support for V2V services based on LTE sidelink |  | 394d? | 2015-12-15 A | 2017-06-15 | 80% | 78.8d? | 395d | finish no earlier than 2017-06-15 | R4 | 3152h | 2521.6h | LTE_SL_V2V-Perf | PCG-36 | LG Electronics |  | Rel-14 | RP-70 |
| 253 | 124.3 | UE Conformance Test Aspects - Support for V2V services based on LTE sidelink |  | 262d? | 2016-09-15 A | 2017-09-15 | 15% | 222.7d? | 329d | finish no earlier than 2017-09-15 | R5 | 2096h | 314.4h | LTE_SL_V2V-UEConTest | PCG-37 | Huawei |  | Rel-14 | TSG-73 |
| 254 | 125 | Release 14 on CIoT | milestone | 0d? | 2016-06-09 A | 2016-06-09 A | 100% |  |  | finish no earlier than 2016-06-09 |  |  |  |  |  |  |  | Rel-14 |  |
| 255 | 126 | **Non-IP for Cellular Internet of Things (CIoT) for 2G/3G-GPRS(EC-EGPRS)** |  | 143d? | 2016-03-02 A | 2016-09-15 A | 100% |  |  |  |  | 4040h | 4040h | NonIP_GPRS | PCG-36 |  |  | Rel-14 | TSG#71 |
| 256 | 126.1 | Non-IP for Cellular IoT for EC-EGPRS |  | 76d? | 2016-03-02 A | 2016-06-15 A | 100% |  |  | start no earlier than 2016-03-02 | S2 | 608h | 608h | NonIP_GPRS | PCG-36 | Hans Ronneke, Ericsson | hans . Ronneke (a) ericsson . Com | Rel-14 | TSG#71 |
| 257 | 126.2 | **CT aspects for Non-IP for Cellular Internet of Things for EC-EGPRS** |  | 143d? | 2016-03-02 A | 2016-09-15 A | 100% |  |  |  |  | 3432h | 3432h | NonIP_GPRS-CT | PCG-36 | Orange, Youssef CHADLI | youssef.chadli@orange.com | Rel-14 | TSG#71 |
| 258 | 126.2.1 | CT1 aspects for Non-IP for Cellular Internet of Things for EC-EGPRS |  | 143d? | 2016-03-02 A | 2016-09-15 A | 100% |  |  | finish no earlier than 2016-09-15 | C1 | 1144h | 1144h | NonIP_GPRS-CT | PCG-36 | Orange, Youssef CHADLI | youssef.chadli@orange.com | Rel-14 | TSG#71 |
| 259 | 126.2.2 | CT3 aspects for Non-IP for Cellular Internet of Things for EC-EGPRS |  | 143d? | 2016-03-02 A | 2016-09-15 A | 100% |  |  | finish no earlier than 2016-09-15 | C3 | 1144h | 1144h | NonIP_GPRS-CT | PCG-37 | Orange, Youssef CHADLI | youssef.chadli@orange.com | Rel-14 | CT-72 |
| 260 | 126.2.3 | CT4 aspects for Non-IP for Cellular Internet of Things for EC-EGPRS |  | 143d? | 2016-03-02 A | 2016-09-15 A | 100% |  |  | finish no earlier than 2016-09-15 | C4 | 1144h | 1144h | NonIP_GPRS-CT | PCG-36 | Orange, Youssef CHADLI | youssef.chadli@orange.com | Rel-14 | TSG#71 |
| 261 | 127 | **Further enhanced MTC for LTE** |  | 394d? | 2016-06-15 A | 2017-12-15 | 38% | 244.17d? | 264d |  |  | 5256h | 1998.8h | LTE_feMTC | PCG-37 | Ericsson |  | Rel-14 | TSG#72 |
| 262 | 127.1 | Core part: Further enhanced MTC for LTE |  | 263d? | 2016-06-15 A | 2017-06-15 | 95% | 13.15d? | 395d | finish no earlier than 2017-06-15 | R1 | 2104h | 1998.8h | LTE_feMTC-Core | PCG-37 | Ericsson |  | Rel-14 | TSG#72 |
| 263 | 127.2 | Perf. part: Further enhanced MTC for LTE |  | 394d? | 2016-06-15 | 2017-12-15 |  |  | 264d | finish no earlier than 2017-12-15 | R4 | 3152h |  | LTE_feMTC-Perf | PCG-37 | Ericsson |  | Rel-14 | TSG#72 |
| 264 | 128 | **Enhancements of NB-IoT** |  | 394d? | 2016-06-15 A | 2017-12-15 | 38% | 244.17d? | 264d |  |  | 5256h | 1998.8h | NB_IOTenh | PCG-37 | Huawei |  | Rel-14 | TSG#72 |
| 265 | 128.1 | Core part: Enhancements of NB-IoT |  | 263d? | 2016-06-15 A | 2017-06-15 | 95% | 13.15d? | 395d | finish no earlier than 2017-06-15 | R1 | 2104h | 1998.8h | NB_IOTenh-Core | PCG-37 | Huawei |  | Rel-14 | TSG#72 |
| 266 | 128.2 | Perf. part: Enhancements of NB-IoT |  | 394d? | 2016-06-15 | 2017-12-15 |  |  | 264d | finish no earlier than 2017-12-15 | R4 | 3152h |  | NB_IOTenh-Perf | PCG-37 | Huawei |  | Rel-14 | TSG#72 |
| 267 | 129 | AT Commands for CIoT |  | 65d? | 2016-09-16 A | 2016-12-15 A | 100% |  |  | finish no earlier than 2016-12-15 | C1 | 520h | 520h | AT_CIoT | PCG-37 | John-Luc Bakker |  | Rel-14 | TSG-73 |
| 268 | 130 | **Extended architecture support for Cellular Internet of Things** |  | 194d? | 2016-06-17 A | 2017-03-14 | 87% | 24.89d? | 462d |  |  | 3360h | 2827.19h | CIoT_Ext | PCG-37 | Intel : Puneet Jain | puneet.jain@intel.com | Rel-14 | TSG-73 |
| 269 | 130.1 | Study on extended architecture support for Cellular Internet of Things |  | 131d? | 2016-06-17 A | 2016-12-15 A | 100% |  |  | finish no earlier than 2016-12-15 | S2 | 1048h | 1048h | FS_CIoT_Ext | PCG-37 | Intel : Puneet Jain | puneet.jain@intel.com | Rel-14 | SP-72 |
| 270 | 130.2 | Stage 2 of Extended architecture support for Cellular Internet of Things |  | 67d? | 2016-09-15 A | 2016-12-16 A | 100% |  |  | finish no earlier than 2016-12-16 | S2 | 536h | 536h | CIoT_Ext | PCG-37 | Intel : Puneet Jain | puneet.jain@intel.com | Rel-14 | TSG-73 |

Notes:
- 246: 1/4/15:TR number added; June2015: Compl:25%->50; 07/09/15: 50%->75 / Impacted TSs and TRs: New TR 22.885
- 247: 1/4/15:TR number added; June2015: Compl:25%->50; 07/09/15: 50%->75; 7/12/15: 75%->100 / Impacted TSs and TRs: New TR 22.885
- 248: 11/12/15: WID:SP-150625->SP-150743; 7/3/16: 10%->22; 7/3/16: WID:SP-150743->SP-150852; 9/6/16: 22%->80; 19/9/16: 80%->100 / Impacted TSs and TRs: TR 23.785
- 249: 29/09/15: Compl:0%->5% 29/09/15: Stat Rep: -->RP-151311 ; 28/1/16: 33.885 added;22/3/16: Compl:35%->50%22/3/16: CD:Wed 15/06/16->Thu 15/09/1622/3/16: WID: RP-15; / Impacted TSs and TRs: 33.885
- 251: 22/3/16: Compl:0%->15%22/3/16: WID: RP-152293->RP-1606491/7/16: Compl:15%->60%1/7/16: WID: RP-160649->RP-161272; 28/7/16: 36.785 added; 26/9/16: Compl:60%->100%; 26/9/16: WID: RP-161272->RP-161603 / Impacted TSs and TRs: 36.785
- 252: 22/3/16: WID: RP-152293->RP-1606491/7/16: WID: RP-160649->RP-16127226/9/16: WID: RP-161272->RP-161603; 20/12/16: Compl:0%->50% 21/3/17: Compl:50%->80% 21/3/17: CD:Wed 15/03/17->Thu 15/06/17
- 253: ; 20/12/16: Compl:0%->5% 21/3/17: Compl:5%->15%
- 254: -
- 256: 9/6/16: 0%->50; 19/9/16: 50%->100 / Impacted TSs and TRs: 23.060, 23.682, 23.401?
- 257: 11/6/16: WID:CP-160161->CP-160293
- 258: 11/6/16: 0%->50; 11/6/16: WID:CP-160161->CP-160293; 16/9/16: 50%->65; 2/12/16: 65%->100 / Impacted TSs and TRs: 24.008
- 259: 11/6/16: WID:CP-160161->CP-160293; 13/6/16: 0%->65; 20/9/16: 0%->100 / Impacted TSs and TRs: 29.060, 29.274, 29.002, 29.303, 23.008, 29.128, 29.272, 23.007
- 260: 11/6/16: WID:CP-160161->CP-160293; 13/6/16: 0%->65; 2/12/16: 65%->100 / Impacted TSs and TRs: 29.060, 29.274, 29.002, 29.303, 23.008, 29.128, 29.272, 23.007
- 262: 26/9/16: Compl:0%->12%26/9/16: WID: RP-161321->RP-161464; 20/12/16: Compl:12%->70%; 20/12/16: WID: RP-161464->RP-16252021/3/17: Compl:70%->95% ; 21/3/17: CD...
- 263: ; 26/9/16: WID: RP-161321->RP-161464; 20/12/16: WID: RP-161464->RP-162520; 20/12/16: Stat Rep: ->RP-16252021/3/17: CD:Fri 15/09/17->Fri 15/12/1721/3/17...
- 265: 26/9/16: Compl:0%->13%26/9/16: WID: RP-161324->RP-161901; 20/12/16: Compl:13%->70%; 21/3/17: Compl:70%->95%; 21/3/17: CD:Wed 15/03/17->Thu 15/06/17
- 266: 26/9/16: WID: RP-161324->RP-161901; ; 21/3/17: CD:Fri 15/09/17->Fri 15/12/17
- 267: 2/12/16: 10%->95; 6/3/17: 95%->100
- 268: Impacted TSs and TRs: 23.401, 23.682, 23.060
- 269: 28/7/16: 23.730 added; 19/9/16: 0%->70; 1/12/16: FCD:03/17->12/16; 1/12/16: 70%->100 / Impacted TSs and TRs: 23.730
- 270: 1/12/16: 0%->100; 1/12/16: WID:SP-160732->SP-160830 / Impacted TSs and TRs: 23.401, 23.682, 23.060, 23.271

| ID | WBS | Task | Type | Duration | Start | Finish | Complete | Remaining | Total slack | Constraint | Resources | Work | Actual work | Acronym | WI rapporteur name | WI rapporteur e-mail | Release | PCG approved | TSG approved | Status Report |
| --- | --- | --- | --- | --- | --- | --- | --- | --- | --- | --- | --- | --- | --- | --- | --- | --- | --- | --- | --- | --- |
| 271 | 130.3 | **Stage 3 of extended architecture enhancements for Cellular Internet of Things** |  | 74d? | 2016-12-01 A | 2017-03-14 | 70% | 22.2d? | 462d |  | ct | 1776h | 1243.19h | CIoT_Ext-CT | Intel, Vivek Gupta | vivek.g.gupta@intel.com | Rel-14 |  |  |  |
| 272 | 130.3.1 | CT1 aspects of extended architecture enhancements for Cellular Internet of Things |  | 74d? | 2016-12-01 A | 2017-03-14 | 50% | 37d? | 462d | finish no earlier than 2017-03-14 | C1 | 592h | 296h | CIoT_Ext-CT | Intel, Vivek Gupta | vivek.g.gupta@intel.com | Rel-14 |  |  |  |
| 273 | 130.3.2 | CT4 aspects of extended architecture enhancements for Cellular Internet of Things |  | 74d? | 2016-12-01 A | 2017-03-14 | 90% | 7.4d? | 462d | finish no earlier than 2017-03-14 | C4 | 592h | 532.8h | CIoT_Ext-CT | Intel, Vivek Gupta | vivek.g.gupta@intel.com | Rel-14 |  |  |  |
| 274 | 131 | **Radio Interface Enhancements for Extended Coverage GSM for support of Cellular Internet of Things** |  | 196d? | 2016-09-15 A | 2017-06-15 | 80% | 39.19d? | 395d |  | R6 | 4704h | 3028.8h | CIoT_EC_GSM_radio_enh | Nokia |  | Rel-14 | PCG-37 | TSG-73 |  |
| 275 | 131.1 | Core part: Radio Interface Enhancements for Extended Coverage GSM for support of Cellular Internet of Things |  | 196d? | 2016-09-15 A | 2017-06-15 | 80% | 39.2d? | 395d | finish no earlier than 2017-06-15 | R6 | 1568h | 1254.4h | CIoT_EC_GSM_radio_enh-Core | Nokia |  | Rel-14 | PCG-37 | TSG-73 |  |
| 276 | 131.2 | Perf. part: Radio Interface Enhancements for Extended Coverage GSM for support of Cellular Internet of Things |  | 196d? | 2016-09-15 A | 2017-06-15 | 80% | 39.2d? | 395d | finish no earlier than 2017-06-15 | R6 | 1568h | 1254.4h | CIoT_EC_GSM_radio_enh-Perf | Nokia |  | Rel-14 | PCG-37 | TSG-73 |  |
| 277 | 132 | **New band support for Rel-14 Narrowband Internet of Things (NB-IOT)** |  | 327d? | 2016-09-15 A | 2017-12-15 | 56% | 143.42d? | 264d |  | R4 | 7336h | 3679.59h | NB_IOT_R14_bands | Ericsson |  | Rel-14 | PCG-37 | TSG-73 |  |
| 278 | 132.1 | Core part: New band support for Rel-14 Narrowband Internet of Things (NB-IOT) |  | 196d? | 2016-09-15 A | 2017-06-15 | 99% | 1.96d? | 395d | finish no earlier than 2017-06-15 | R4 | 1568h | 1552.32h | NB_IOT_R14_bands-Core | Ericsson |  | Rel-14 | PCG-37 | TSG-73 |  |
| 279 | 132.2 | Perf. part: New band support for Rel-14 Narrowband Internet of Things (NB-IOT) |  | 196d? | 2016-09-15 A | 2017-06-15 | 70% | 58.8d? | 395d | finish no earlier than 2017-06-15 | R4 | 1568h | 1097.6h | NB_IOT_R14_bands-Perf | Ericsson |  | Rel-14 | PCG-37 | TSG-73 |  |
| 280 | 132.3 | UE Conformance Test Aspects - New band support for Rel-14 NB-IoT |  | 198d? | 2017-03-15 | 2017-12-15 |  |  | 264d | finish no earlier than 2017-12-15 | R5 | 1584h |  | NB_IOT_R14_bands-UEConTest | Ericsson |  | Rel-14 |  |  |  |
| 281 | 133 | **Enhancements of Dedicated Core Networks selection mechanism** |  | 391d? | 2015-09-17 A | 2017-03-15 | 97% | 10.95d? | 461d |  |  | 4752h | 4613.33h | eDecor | Roland Gustafsson | Roland.Gustafsson@ericsson.com | Rel-14 | PCG-35 | SP-69 |  |
| 282 | 133.1 | Study on Enhancements of Dedicated Core Networks selection mechanism |  | 132d? | 2015-09-17 A | 2016-03-18 A | 100% |  |  | finish no earlier than 2016-03-18 | S2 | 1056h | 1056h | FS_eDecor | Roland Gustafsson | Roland.Gustafsson@ericsson.com | Rel-14 | PCG-35 | SP-69 |  |
| 283 | 133.2 | Enhancements of Dedicated Core Networks selection mechanism |  | 72d? | 2016-06-09 A | 2016-09-15 A | 100% |  |  | finish no earlier than 2016-09-15 | S2 | 576h | 576h | eDecor | Roland Gustafsson | Roland.Gustafsson@ericsson.com | Rel-14 | PCG-37 | TSG#72 |  |
| 284 | 133.3 | **CT aspects of eDecor** |  | 65d? | 2016-09-16 A | 2016-12-15 | 93% | 4.33d? | 525d |  | ct | 2080h | 1941.33h | eDecor-CT | Mikael Wass | Mikael.wass@ericsson.com | Rel-14 | PCG-37 | TSG-73 |  |
| 285 | 133.3.1 | CT1 aspects of eDecor |  | 65d? | 2016-09-16 A | 2016-12-15 | 95% | 3.25d? | 525d | finish no earlier than 2016-12-15 | C1 | 520h | 494h | eDecor-CT | Mikael Wass | Mikael.wass@ericsson.com | Rel-14 | PCG-37 | TSG-73 |  |
| 286 | 133.3.2 | CT4 aspects of eDecor |  | 65d? | 2016-09-16 A | 2016-12-15 A | 100% |  |  | finish no earlier than 2016-12-15 | C4 | 520h | 520h | eDecor-CT | Mikael Wass | Mikael.wass@ericsson.com | Rel-14 | PCG-37 | TSG-73 |  |
| 287 | 133.3.3 | CT6 aspects of eDecor |  | 65d? | 2016-09-16 A | 2016-12-15 | 85% | 9.75d? | 525d | finish no earlier than 2016-12-15 | C6 | 520h | 442h | eDecor-CT | Mikael Wass | Mikael.wass@ericsson.com | Rel-14 | PCG-37 | TSG-73 |  |
| 288 | 133.4 | **RAN aspects of eDECOR for UMTS and LTE** |  | 65d? | 2016-12-15 A | 2017-03-15 A | 100% |  |  |  | R3 | 1040h | 1040h | eDECOR-UTRA_LTE | Ericsson |  | Rel-14 |  |  |  |
| 289 | 133.4.1 | Core part: RAN aspects of eDECOR for UMTS and LTE |  | 65d? | 2016-12-15 A | 2017-03-15 A | 100% |  |  | finish no earlier than 2017-03-15 | R3 | 520h | 520h | eDECOR-UTRA_LTE-Core | Ericsson |  | Rel-14 |  |  | RP-170547 |
| 290 | 134 | **Addition of band 25 and 26 to LTE MTC cat.0** |  | 65d? | 2016-12-15 A | 2017-03-15 A | 100% |  |  |  | R4 | 1040h | 1040h | LC_MTC_LTE_cat0_B25_B26 | Sprint |  | Rel-14 |  |  |  |
| 291 | 134.1 | Core part: Addition of band 25 and 26 to LTE MTC cat.0 |  | 65d? | 2016-12-15 A | 2017-03-15 A | 100% |  |  | finish no earlier than 2017-03-15 | R4 | 520h | 520h | LC_MTC_LTE_cat0_B25_B26-Core | Sprint |  | Rel-14 |  |  |  |
| 292 | 135 | Addition of bands 25 and 40 to LTE MTC cat.1 |  | 65d? | 2016-12-15 A | 2017-03-15 A | 100% |  |  | finish no earlier than 2017-03-15 | R4 | 520h | 520h | LTE_MTCe2_L1_cat1_B25_B40-Core | Sprint |  | Rel-14 |  |  |  |
| 293 | 136 | Release 14 on WLAN | milestone | 0d? | 2016-06-09 A | 2016-06-09 A | 100% |  |  | finish no earlier than 2016-06-09 |  |  |  |  |  |  | Rel-14 |  |  |  |
| 294 | 137 | **EIR check for WLAN access to EPC** |  | 230d? | 2015-11-02 A | 2016-09-15 A | 100% |  |  |  |  | 3000h | 3000h | EWE | Alcatel-Lucent, Nicolas Drevon | Nicolas.Drevon@alcatel-lucent.com | Rel-14 | PCG-36 | SP-70 |  |
| 295 | 137.1 | Stage 2 of EWE |  | 165d? | 2015-11-02 A | 2016-06-17 A | 100% |  |  | finish no earlier than 2016-06-17 | S2 | 1320h | 1320h | EWE | Alcatel-Lucent, Nicolas Drevon | Nicolas.Drevon@alcatel-lucent.com | Rel-14 | PCG-36 | SP-70 |  |

Notes:
- 271: 21/3/17: 24.250 added; / Impacted TSs and TRs: 24.250
- 272: 6/3/17: 0%->50 / Impacted TSs and TRs: 24.301, 24.008
- 273: 6/3/17: 0%->90 / Impacted TSs and TRs: 23.008, 29.272, 29.002, 29.336, 29.128, 29.171, 29.172, 29.173
- 275: ; 20/12/16: Compl:0%->50% 21/3/17: Compl:50%->80%; ; ...
- 276: ; 20/12/16: Compl:0%->20% ; 21/3/17: Compl:20%->80%; ...
- 278: ; 20/12/16: Compl:0%->99% 21/3/17: CD:Wed 15/03/17->Thu 15/06/17; ;...
- 279: ; 20/12/16: Compl:0%->99% 21/3/17: Compl:99%->70% ...
- 280: tested: REL-14 NB_IOT_R14_bands-Core (which got an exception at RAN #75 to still complete in REL-14 by RAN #76);
- 281: 7/12/15: 0%->70; 7/3/16: 70%->80; 9/6/16: 80%->95 / Impacted TSs and TRs: 23.711
- 282: 7/12/15: 0%->70; 7/3/16: 70%->80; 9/6/16: 80%->95; 19/9/16: 95%->100 / Impacted TSs and TRs: 23.711
- 283: 19/9/16: 70%->100 / Impacted TSs and TRs: 23.401, 23.060, 23.251
- 285: 2/12/16: 0%->80; 6/3/17: 80%->95 / Impacted TSs and TRs: 24.301, 24.008, 24.368
- 286: 2/12/16: 0%->10; 6/3/17: 10%->100 / Impacted TSs and TRs: 29.303, 23.003, 23.008
- 287: 14/12/16: 0%->15; 7/3/17: 15%->85 / Impacted TSs and TRs: 31.102, 31.111
- 289: ; ; 21/3/17: Compl:0%->100%; ; 21/3/17: Stat Rep: ->RP-170547
- 291: ; 21/3/17: Compl:0%->100%
- 292: ; 21/3/17: Compl:0%->100%
- 293: -
- 294: 7/3/16: 45%->60; 9/6/16: 60%->100 / Impacted TSs and TRs: 23.002, 23.402
- 295: 7/3/16: 45%->60; 9/6/16: 60%->100 / Impacted TSs and TRs: 23.002, 23.402

| ID | WBS | Task | Type | Duration | Start | Finish | Complete | Remaining | Total slack | Constraint | Resources | Work | Actual work | Acronym | PCG approved | WI rapporteur name | WI rapporteur e-mail | Release | TSG approved | Impacted TSs and TRs | Status Report |
| --- | --- | --- | --- | --- | --- | --- | --- | --- | --- | --- | --- | --- | --- | --- | --- | --- | --- | --- | --- | --- | --- |
| 296 | 137.2 | **CT aspects of EWE** |  | 70d? | 2016-06-13 A | 2016-09-15 A | 100% |  |  |  | ct | 1680h | 1680h | EWE-CT | PCG-37 | Nokia, Bruno Landais | bruno.landais@nokia.com | Rel-14 | TSG#72 |  |  |
| 297 | 137.2.1 | CT1 aspects of EWE |  | 70d? | 2016-06-13 A | 2016-09-15 A | 100% |  |  | finish no earlier than 2016-09-15 | C1 | 560h | 560h | EWE-CT | PCG-37 | Nokia, Bruno Landais | bruno.landais@nokia.com | Rel-14 | TSG#72 | 24.302 |  |
| 298 | 137.2.2 | CT4 aspects of EWE |  | 70d? | 2016-06-13 A | 2016-09-15 A | 100% |  |  | finish no earlier than 2016-09-15 | C4 | 560h | 560h | EWE-CT | PCG-37 | Nokia, Bruno Landais | bruno.landais@nokia.com | Rel-14 | TSG#72 | 29.273 |  |
| 299 | 138 | **Support of EAP Re-authentication Protocol for WLAN Interworking** |  | 130d? | 2016-09-16 A | 2017-03-16 | 97% | 4.34d? | 460d |  |  | 4152h | 3762h | ERP | PCG-37 | ORANGE, Todor Gamishev | Todor dot Gamishev at Orange dot com | Rel-14 | TSG-73 |  |  |
| 300 | 138.1 | Support of EAP Re-authentication Protocol for WLAN Interworking |  | 129d? | 2016-09-16 A | 2017-03-15 A | 100% |  |  | finish no earlier than 2017-03-15 | S3 | 1032h | 1032h | ERP | PCG-37 | ORANGE, Todor Gamishev | Todor dot Gamishev at Orange dot com | Rel-14 | TSG-73 | 33.402 |  |
| 301 | 138.2 | **CT aspects of ERP** |  | 130d? | 2016-09-16 A | 2017-03-16 | 95% | 6.5d? | 460d |  | ct | 3120h | 2730h | ERP-CT | PCG-37 | Orange, Julien Bournelle | Julien.bournelle@orange.com | Rel-14 | TSG-73 |  |  |
| 302 | 138.2.1 | CT1 aspects of ERP |  | 130d? | 2016-09-16 A | 2017-03-16 | 95% | 6.5d? | 460d | finish no earlier than 2017-03-16 | C1 | 1040h | 988h | ERP-CT | PCG-37 | Orange, Julien Bournelle | Julien.bournelle@orange.com | Rel-14 | TSG-73 | 24.302 |  |
| 303 | 138.2.2 | CT4 aspects of ERP |  | 130d? | 2016-09-16 A | 2017-03-16 | 95% | 6.5d? | 460d | finish no earlier than 2017-03-16 | C4 | 1040h | 988h | ERP-CT | PCG-37 | Orange, Julien Bournelle | Julien.bournelle@orange.com | Rel-14 | TSG-73 | 29.273, 23.008, 23.003 |  |
| 304 | 139 | **Phase 2 of the Support of Emergency services over WLAN** |  | 403d? | 2015-09-01 A | 2017-03-15 | 99% | 4.83d? | 461d |  |  | 5328h | 5250.75h | SEW2 | PCG-37 | Nicolas Drevon | nicolas.drevon@nokia.com | Rel-14 | TSG#72 | new 23.771, TS 23.402, TS 23.167 |  |
| 305 | 139.1 | Study on Phase 2 of the Support of Emergency services over WLAN |  | 208d? | 2015-09-01 A | 2016-06-16 A | 100% |  |  | finish no earlier than 2016-06-16 | S2 | 1664h | 1664h | FS_SEW2 | PCG-34 | Laurent Thiebaut, Alcatel Lucent | Laurent.thiebaut@alcatel-lucent.com | Rel-14 | SP-67 | new 23.771 |  |
| 306 | 139.2 | Support of Emergency services over WLAN - phase 2 |  | 70d? | 2016-06-13 A | 2016-09-15 A | 100% |  |  | finish no earlier than 2016-09-15 | S2 | 560h | 560h | SEW2 | PCG-37 | Nicolas Drevon | nicolas.drevon@nokia.com | Rel-14 | TSG#72 | TS 23.402, TS 23.167 |  |
| 307 | 139.3 | **CT aspects of SEW2** |  | 129d? | 2016-09-16 A | 2017-03-15 | 98% | 3.21d? | 461d |  | ct | 3104h | 3026.75h | SEW2-CT | PCG-37 | Jennifer Liu | jennifer.liu@nokia.com | Rel-14 | TSG-73 |  |  |
| 308 | 139.3.1 | CT1 aspects of SEW2 |  | 129d? | 2016-09-16 A | 2017-03-15 | 95% | 6.45d? | 461d | finish no earlier than 2017-03-15 | C1 | 1032h | 980.4h | SEW2-CT | PCG-37 | Jennifer Liu | jennifer.liu@nokia.com | Rel-14 | TSG-73 | 24.302, 24.312, 24.301, 24.244, 24.229, 24.237 |  |
| 309 | 139.3.2 | CT4 aspects of SEW2 |  | 129d? | 2016-09-16 A | 2017-03-15 A | 100% |  |  | finish no earlier than 2017-03-15 | C4 | 1032h | 1032h | SEW2-CT | PCG-37 | Jennifer Liu | jennifer.liu@nokia.com | Rel-14 | TSG-73 | 23.003, 29.272, 29.273, 29.274, 29.328 |  |
| 310 | 139.3.3 | Deleted - CT6 aspects of SEW2 |  | 1d? | 2016-12-14 A | 2016-12-14 A | 100% |  |  | finish no earlier than 2016-12-14 | C6 | 8h | 8h | SEW2-CT | PCG-37 | Jennifer Liu | jennifer.liu@nokia.com | Rel-14 | TSG-73 | 31.102 |  |
| 311 | 140 | T-ADS supporting WLAN Access |  | 134d? | 2016-03-15 A | 2016-09-15 A | 100% |  |  | finish no earlier than 2016-09-15 | S2 | 1072h | 1072h | TADS_WLAN | PCG-37 | Jiang Yi | jiangyi (at) chinamobile (dot) com | Rel-14 | SP-72 | TS 23.292, TS 23.221, TS 23.402 |  |
| 312 | 141 | **Enhanced LTE-WLAN Aggregation (LWA)** |  | 263d? | 2016-03-15 A | 2017-03-15 A | 100% |  |  |  | R2 | 4208h | 4208h | LTE_WLAN_aggr | PCG-36 | Intel |  | Rel-14 | TSG#71 |  |  |
| 313 | 141.1 | Core part: Enhanced LTE-WLAN Aggregation (LWA) |  | 263d? | 2016-03-15 A | 2017-03-15 A | 100% |  |  | finish no earlier than 2017-03-15 | R2 | 2104h | 2104h | LTE_WLAN_aggr-Core | PCG-36 | Intel |  | Rel-14 | TSG#71 |  | RP-170330 |
| 314 | 142 | Release 14 on IMS | milestone | 0d? | 2016-06-09 A | 2016-06-09 A | 100% |  |  | finish no earlier than 2016-06-09 |  |  |  |  |  |  |  | Rel-14 |  |  |  |
| 315 | 143 | **Evolution to and Interworking with eCall in IMS** |  | 355d? | 2015-05-11 A | 2016-09-15 | 83% | 60.22d? | 590d |  |  | 4720h | 3919.2h | EIEI | PCG-35 | Kurt Bischinger |  | Rel-14 | SP-68 | 22.101 |  |
| 316 | 143.1 | Stage 1 of Evolution to and Interworking with eCall in IMS |  | 30d? | 2015-05-11 A | 2015-06-19 A | 100% |  |  | start no earlier than 2015-05-11 | S1 | 240h | 240h | EIEI | PCG-35 | Kurt Bischinger |  | Rel-14 | SP-68 | 22.101 |  |
| 317 | 143.2 | Stage 2 of Evolution to and Interworking with eCall in IMS |  | 131d? | 2015-12-11 A | 2016-06-10 A | 100% |  |  | finish no earlier than 2016-06-10 | S2 | 1048h | 1048h | EIEI | PCG-35 | Haris Zisimopoulos, Qualcomm Incorporated | harisz@qti.qualcomm.com | Rel-14 | SP-68 | 23.167, 23.401 |  |
| 318 | 143.3 | **CT aspects of evolution to and interworking with eCall in IMS** |  | 143d? | 2016-03-02 A | 2016-09-15 | 77% | 33.36d? | 590d |  |  | 3432h | 2631.2h | EIEI-CT | PCG-36 | Lena Chaponniere | lguellec@qti.qualcomm.com | Rel-14 | TSG#71 |  |  |
| 319 | 143.3.1 | CT1 aspects of evolution to and interworking with eCall in IMS |  | 143d? | 2016-03-02 A | 2016-09-15 A | 100% |  |  | finish no earlier than 2016-09-15 | C1 | 1144h | 1144h | EIEI-CT | PCG-36 | Lena Chaponniere | lguellec@qti.qualcomm.com | Rel-14 | TSG#71 | 24.229, 24.301 |  |
| 320 | 143.3.2 | (IETF) Next-Generation Pan-European eCall (draft-ietf-ecrit-ecall) |  | 143d? | 2016-03-02 A | 2016-09-15 | 30% | 100.1d? | 590d | finish no earlier than 2016-09-15 | C1-IETF | 1144h | 343.2h | EIEI-CT | PCG-37 |  |  | Rel-14 | TSG#72 | draft-ietf-ecrit-ecall |  |
| 321 | 143.3.3 | CT6 aspects of evolution to and interworking with eCall in IMS |  | 143d? | 2016-03-02 A | 2016-09-15 A | 100% |  |  | finish no earlier than 2016-09-15 | C6 | 1144h | 1144h | EIEI-CT | PCG-36 | Lena Chaponniere | lguellec@qti.qualcomm.com | Rel-14 | TSG#71 | 31.102 |  |

Notes:
- 297: 16/9/16: 0%->100
- 298: 2/12/16: 0%->100
- 300: 1/12/16: 0%->90; 6/3/17: 90%->100
- 302: 2/12/16: 0%->80; 6/3/17: 80%->95
- 303: 2/12/16: 0%->50; 6/3/17: 50%->95
- 305: June2015: Compl:0%->100, SP-150151->SP-150251; 7/12/15: 0%->30, FCD: 12/15->06/16; 7/3/16: 30%->75; 7/3/16: WID:SP-150251->SP-160173; 9/6/16: 75%->100
- 306: 11/6/16: 0%->45; 19/9/16: 45%->100
- 307: 5/12/16: WID:CP-160476->CP-160694
- 308: 2/12/16: 20%->95
- 309: 2/12/16: 0%->100
- 310: Deleted at CT6#82
- 311: 19/9/16: 0%->100
- 312: follow-up WI of REL-13 WI LTE_WLAN_radio; no Perf. part
- 313: follow-up WI of REL-13 WI LTE_WLAN_radio; no Perf. part1/7/16: Compl:0%->25%1/7/16: WID: RP-160600->RP-160923; 26/9/16: Compl:25%->45%; 20/12/16: Compl:45%->75%; 20/12/16: Stat Rep: --> ; 21/3/17: Compl:75%->100% ; 21/3/17...
- 314: -
- 315: 12/15: created by MCC to distinguish Stage 1 from Stage 2
- 317: 7/3/16: 0%->20; 9/6/16: 20%->100. FCD: 03/16->06/16
- 319: 11/6/16: 0%->35; 16/9/16: 35%->85; 2/12/16: 85%->100
- 321: 16/9/16: 0%->100

| ID | WBS | Task | Type | Duration | Start | Finish | Complete | Remaining | Baseline start | Baseline finish | Baseline duration | Total slack | Constraint | Resources | Work | Actual work | Acronym | PCG approved | Impacted TSs and TRs | WI rapporteur name | Release | TSG approved | WI rapporteur e-mail | MCC resp | Acronym_3GU_Export |
| --- | --- | --- | --- | --- | --- | --- | --- | --- | --- | --- | --- | --- | --- | --- | --- | --- | --- | --- | --- | --- | --- | --- | --- | --- | --- |
| 322 | 144 | **Password based service activation for IMS Multimedia Telephony service** |  | 463d? | 2015-03-11 A | 2016-12-15 | 51% | 228.96d? |  |  |  | 525d |  |  | 3264h | 1185h | PWDIMS | PCG-34 | 22.173 | Peter Bleckert (Ericsson) | Rel-14 | SP-67 |  |  |  |
| 323 | 144.1 | Stage 1 for PWDIMS |  | 3d? | 2015-03-11 A | 2015-03-13 A | 100% |  |  |  |  |  | finish no earlier than 2015-03-13 | S1 | 24h | 24h | PWDIMS | PCG-34 | 22.173 | Peter Bleckert (Ericsson) | Rel-14 | SP-67 |  |  |  |
| 324 | 144.2 | **CT aspects for PWDIMS** |  | 135d? | 2016-06-13 A | 2016-12-15 | 50% | 67.5d? |  |  |  | 525d |  | ct | 3240h | 1161h | PWDIMS-CT | PCG-37 |  | Axell, Jörgen | Rel-14 | TSG#72 |  |  |  |
| 325 | 144.2.1 | CT1 aspects for PWDIMS |  | 135d? | 2016-06-13 A | 2016-12-15 A | 100% |  |  |  |  |  | finish no earlier than 2016-12-15 | C1 | 1080h | 1080h | PWDIMS-CT | PCG-37 | 24.623, 24.611 | Axell, Jörgen | Rel-14 | TSG#72 |  |  |  |
| 326 | 144.2.2 | CT3 aspects for PWDIMS |  | 135d? | 2016-06-13 | 2016-12-15 |  |  |  |  |  | 525d | finish no earlier than 2016-12-15 | C3 | 1080h |  | PWDIMS-CT | PCG-37 | 29.292 | Axell, Jörgen | Rel-14 | TSG#72 |  |  |  |
| 327 | 145 | **IMS Signalling Activated Trace** |  | 531d? | 2014-03-05 A | 2016-03-11 | 28% | 380.74d? | 2014-03-05 | 2014-09-12 | 138d? | 725d |  |  | 22056h | 6241.44h | ISAT | PCG-32 |  | Vodafone | Rel-14 | CP-63 | peter.dawes @vodafone.com | Frederic | ISAT |
| 328 | 145.1 | CT1 part of IMS Signalling Activated Trace |  | 528d? | 2014-03-10 | 2016-03-11 |  |  | 2014-03-05 | 2014-09-12 | 138d? | 725d | finish no earlier than 2016-03-11 | C1 | 4224h |  | ISAT | PCG-32 | 24.229, 24.323 | Vodafone | Rel-14 | CP-63 | peter.dawes @vodafone.com | Frederic |  |
| 329 | 145.2 | (IETF) IMS Signalling Activated Trace (draft-dawes-sipping-debug) |  | 391d? | 2014-09-12 A | 2016-03-11 | 28% | 281.52d? |  |  |  | 725d | finish no earlier than 2016-03-11 | C1-IETF | 3128h | 875.84h | ISAT | PCG-33 | draft-dawes-sipping-debug | Vodafone | Rel-14 | CP-65 | peter.dawes @vodafone.com |  |  |
| 330 | 145.3 | (IETF) IMS Signalling Activated Trace (draft-dawes-sipping-debug) |  | 391d? | 2014-09-12 A | 2016-03-11 | 25% | 293.25d? |  |  |  | 725d | finish no earlier than 2016-03-11 | C3-IETF | 3128h | 782h | ISAT | PCG-33 | draft-dawes-sipping-debug | Vodafone | Rel-14 | CP-65 | peter.dawes @vodafone.com |  |  |
| 331 | 145.4 | (IETF) IMS Signalling Activated Trace (draft-dawes-sipping-debug) |  | 391d? | 2014-09-12 A | 2016-03-11 | 25% | 293.25d? |  |  |  | 725d | finish no earlier than 2016-03-11 | C4-IETF | 3128h | 782h | ISAT | PCG-33 | draft-dawes-sipping-debug | Vodafone | Rel-14 | CP-65 | peter.dawes @vodafone.com |  |  |
| 332 | 145.5 | CT3 part of IMS Signalling Activated Trace |  | 528d? | 2014-03-10 | 2016-03-11 |  |  | 2014-03-05 | 2014-06-13 | 73d? | 725d | finish no earlier than 2016-03-11 | C3 | 4224h |  | ISAT | PCG-32 | 29.165 | Vodafone | Rel-14 | CP-63 | peter.dawes @vodafone.com | Adrian |  |
| 333 | 145.6 | CT4 part of IMS Signalling Activated Trace |  | 528d? | 2014-03-05 A | 2016-03-11 | 90% | 52.8d? | 2014-03-05 | 2014-09-12 | 138d? | 725d | finish no earlier than 2016-03-11 | C4 | 4224h | 3801.6h | ISAT | PCG-32 | 23.008, 29.228, 29.229, 29.328, 29.329 | Vodafone | Rel-14 | CP-63 | peter.dawes @vodafone.com | Kimmo |  |
| 334 | 146 | UE Conformance Test Aspects – IMS for Converged IP Communications |  | 262d? | 2016-12-14 | 2017-12-14 |  |  |  |  |  | 265d | finish no earlier than 2017-12-14 | R5 | 2096h |  | IMS_CONV_IP_COM-UEConTest |  | TS 34.229-1, TS 34.229-2, TS 34.229-3 | Rohnert, Hans | Rel-14 |  | Hans.Rohnert.ext@rohde-schwarz.com |  |  |
| 335 | 147 | Other Release 14 | milestone | 0d? | 2016-06-09 A | 2016-06-09 A | 100% |  |  |  |  |  | finish no earlier than 2016-06-09 |  |  |  |  |  |  |  | Rel-14 |  |  |  |  |
| 336 | 148 | **User Controlled Spoofed Call Treatment** |  | 146d? | 2016-08-23 A | 2017-03-14 | 99% | 1.22d? |  |  |  | 462d |  |  | 760h | 753.6h | SPECTRE | PCG-37 |  | Greg Schumacher, Sprint | Rel-14 | TSG-73 |  |  |  |
| 337 | 148.1 | Stage 1 of User Controlled Spoofed Call Treatment |  | 20d? | 2016-08-23 A | 2016-09-19 A | 100% |  |  |  |  |  | finish no earlier than 2016-09-19 | S1 | 160h | 160h | SPECTRE | PCG-37 | 22.228, 22.173 | Greg Schumacher, Sprint | Rel-14 | TSG-73 |  |  |  |
| 338 | 148.2 | Stage 3 of User Controlled Spoofed Call Treatment |  | 74d? | 2016-12-01 A | 2017-03-14 A | 100% |  |  |  |  |  | finish no earlier than 2017-03-14 | C1 | 592h | 592h | SPECTRE-CT |  | 24.229, 29.165 | Dolly, Martin | Rel-14 |  | md3135@att.com |  |  |
| 339 | 148.3 | (IETF) A SIP Response Code for Unwanted Calls (draft-ietf-sipcore-status-unwanted) |  | 1d? | 2017-03-14 A | 2017-03-14 | 20% | 0.8d? |  |  |  | 462d | finish no earlier than 2017-03-14 | C1-IETF | 8h | 1.6h | SPECTRE-CT |  |  | Ericsson | Rel-14 |  |  |  |  |
| 340 | 149 | **Enhancement for TV service** |  | 565d? | 2015-04-14 A | 2017-06-09 | 78% | 124.22d? |  |  |  | 399d |  |  | 7800h | 6030.2h | EnTV | PCG-36 | 22.101 | Zhiming Li | Rel-14 | SP-70 | Lizhiming@huawei.com |  |  |
| 341 | 149.1 | Study on 3GPP Enhancement for TV Video service |  | 176d? | 2015-04-14 A | 2015-12-15 A | 100% |  |  |  |  |  | finish no earlier than 2015-12-15 | S1 | 1408h | 1408h | FS_EnTV | PCG-34 | TR 22.816 | Zhiming Li (Huawei) | Rel-14 | SP-67 | lizhiming@huawei.com |  |  |
| 342 | 149.2 | **System Architecture Enhancements to eMBMS for TV Video Service** |  | 201d? | 2016-03-11 A | 2016-12-15 A | 100% |  |  |  |  |  |  |  | 1736h | 1736h | AE_enTV | PCG-36 |  |  | Rel-14 | TSG#71 |  |  |  |
| 343 | 149.2.1 | Study on System Architecture Enhancements to eMBMS for TV Video Service |  | 136d? | 2016-03-11 A | 2016-09-15 A | 100% |  |  |  |  |  | finish no earlier than 2016-09-15 | S2 | 1088h | 1088h | FS_AE_enTV | PCG-36 | TR 23.746 | Miguel Griot, Qualcomm | Rel-14 | TSG#71 | mgriot@qti.qualcomm.com |  |  |
| 344 | 149.2.2 | System Architecture Enhancements for TV service |  | 81d? | 2016-08-25 A | 2016-12-15 A | 100% |  |  |  |  |  | finish no earlier than 2016-12-15 | S2 | 648h | 648h | AE_enTV | PCG-37 | TS 23.246 | Miguel Griot, Qualcomm | Rel-14 | TSG-73 | mgriot@qti.qualcomm.com |  |  |
| 345 | 149.3 | Mobile Network Interface for MBMS Delivery of Media and TV services |  | 80d? | 2016-08-22 A | 2016-12-09 A | 100% |  |  |  |  |  | finish no earlier than 2016-12-09 | S4 | 640h | 640h | AE_enTV-MI_MTV | PCG-37 | 26.346 | Thorsten Lohmar | Rel-14 | TSG-73 | Thorsten.lohmar@ericsson.com |  |  |
| 346 | 149.4 | Codec aspects for eMBMS Delivery of Media and TV Services |  | 132d? | 2016-12-08 A | 2017-06-09 | 20% | 105.6d? |  |  |  | 399d | finish no earlier than 2017-06-09 | S4 | 1056h | 211.2h | AE_enTV-S4 |  | 26.347, 26.346 | Imed Bouazizi | Rel-14 |  | i.bouazizi@samsung.com |  |  |

Notes:
- 322: 1/4/15: rapporteur added, Impacted TS added. 31/07/15: 100%
- 323: 1/4/15: rapporteur added, Impacted TS added. 31/07/15: 100%
- 325: 2/12/16: 0%->15; 6/3/17: 15%->100
- 327: Mar 15: WID: CP-140195->CP-150091. ES in CP-150637. 8/3/16: Moved from Rel-13 at CT#71
- 328: CP66: moved to Rel-13. Mar 15: WID: CP-140195->CP-150091. ES in CP-150728
- 329: CP66: moved to Rel-13. Mar 15: WID: CP-140195->CP-150091. ES in CP-150637; 13/6/16: 25%->28
- 330: CP66: moved to Rel-13. Mar 15: WID: CP-140195->CP-150091. ES in CP-150637
- 331: CP66: moved to Rel-13. Mar 15: WID: CP-140195->CP-150091. ES in CP-150637
- 332: CP66: moved to Rel-13. Mar 15: WID: CP-140195->CP-150091. ES in CP-150637
- 333: CP66: moved to Rel-13. Mar.15: 90%. ES in CP-150615. 7/3/16: Rel-13->Rel-14
- 335: -
- 336: 1/12/16: moved from Rel-15 to Rel-14; 1/12/16: WID:SP-160729->SP-160898
- 337: 1/12/16: moved from Rel-15 to Rel-14; 1/12/16: WID:SP-160729->SP-160898
- 338: 2/12/16: 0%->25; 6/3/17: 25%->100
- 340: 2/3/16: 0%->100
- 341: 1/4/15:TR number added; June2015: Compl:0%->20; 07/09/15: 20%->75; 7/12/15: 75%->100
- 343: 9/6/16: 0%->70; 28/7/16: 23.746 added; 19/9/16: 70%->100
- 344: 19/9/16: 0%->85; 1/12/16: FCD:09/16->12/16; 1/12/16: 85%->100
- 345: 06/10/16: Acronym: SA_enTV-MI_MTV -> AE_enTV-MI_MTV; 1/12/16: FCD:09/16->2/16; 1/12/16: 0%->50; 8/12/16: 50%->100
- 346: 6/3/17: 0%->20; 6/3/17: FCD:03/17->06/17

| ID | WBS | Task | Duration | Start | Finish | Complete | Remaining | Total slack | Constraint | Resources | Work | Actual work | Acronym | WI rapporteur name | WI rapporteur e-mail | Release | PCG approved | TSG approved |
| --- | --- | --- | --- | --- | --- | --- | --- | --- | --- | --- | --- | --- | --- | --- | --- | --- | --- | --- |
| 347 | 149.5 | **Stage 3 of system architecture enhancements for TV service** | 74d? | 2016-12-01 A | 2017-03-14 | 69% | 23.12d? | 462d |  | ct | 2960h | 2035h | AE_enTV-CT | Catovic, Amer | amerc@qti.qualcomm.com | Rel-14 |  |  |
| 348 | 149.5.1 | CT1 aspects of system architecture enhancements for TV service | 74d? | 2016-12-01 A | 2017-03-14 | 75% | 18.5d? | 462d | finish no earlier than 2017-03-14 | C1 | 592h | 444h | AE_enTV-CT | Catovic, Amer | amerc@qti.qualcomm.com | Rel-14 |  |  |
| 349 | 149.5.2 | CT3 aspects of system architecture enhancements for TV service | 74d? | 2016-12-01 A | 2017-03-14 A | 100% |  |  | finish no earlier than 2017-03-14 | C3 | 592h | 592h | AE_enTV-CT | Catovic, Amer | amerc@qti.qualcomm.com | Rel-14 |  |  |
| 350 | 149.5.3 | CT4 aspects of system architecture enhancements for TV service | 74d? | 2016-12-01 | 2017-03-14 |  |  | 462d | finish no earlier than 2017-03-14 | C4 | 592h |  | AE_enTV-CT | Catovic, Amer | amerc@qti.qualcomm.com | Rel-14 |  |  |
| 351 | 149.5.4 | CT6 aspects of system architecture enhancements for TV service | 74d? | 2016-12-01 A | 2017-03-14 A | 100% |  |  | finish no earlier than 2017-03-14 | C6 | 592h | 592h | AE_enTV-CT | Catovic, Amer | amerc@qti.qualcomm.com | Rel-14 |  |  |
| 352 | 150 | MBMS Transport Protocol and APIs | 330d? | 2015-12-11 A | 2017-03-15 A | 100% |  |  | finish no earlier than 2017-03-15 | S4 | 2640h | 2640h | TRAPI | Samsung, Imed Bouazizi | i.bouazizi@samsung.com | Rel-14 | PCG-36 | SP-70 |
| 353 | 151 | Multimedia Priority Service Modifications | 331d? | 2015-03-11 A | 2016-06-15 A | 100% |  |  | finish no earlier than 2016-06-15 | S1 | 2648h | 2648h | MPS_Mods | Ray P. Singh (Applied Communications Science) | rsingh@appcomsci.com | Rel-14 | PCG-34 | SP-67 |
| 354 | 152 | Lawful Interception Rel-14 | 394d? | 2016-06-15 A | 2017-12-15 | 20% | 315.2d? | 264d | finish no earlier than 2017-12-15 | S3LI | 3152h | 630.4h | LI14 | Koen JASPERS, PIDS |  | Rel-14 | PCG-37 | TSG#72 |
| 355 | 153 | **SIP Reason header extension** | 129d? | 2016-09-16 A | 2017-03-15 | 43% | 74.17d? | 461d |  | ct | 3096h | 1315.82h | REAS_EXT | Mohali, Marianne | marianne.mohali@orange.com | Rel-14 | PCG-37 | TSG-73 |
| 356 | 153.1 | CT1 aspects of SIP Reason header extension | 129d? | 2016-09-16 A | 2017-03-15 | 85% | 19.35d? | 461d | finish no earlier than 2017-03-15 | C1 | 1032h | 877.2h | REAS_EXT | Mohali, Marianne | marianne.mohali@orange.com | Rel-14 | PCG-37 | TSG-73 |
| 357 | 153.2 | CT3 aspects of SIP Reason header extension | 129d? | 2016-09-16 | 2017-03-15 |  |  | 461d | finish no earlier than 2017-03-15 | C3 | 1032h |  | REAS_EXT | Mohali, Marianne | marianne.mohali@orange.com | Rel-14 | PCG-37 | TSG-73 |
| 358 | 154 | Enhancements to User Location Reporting Support | 73d? | 2015-09-09 A | 2015-12-18 A | 100% |  |  | finish no earlier than 2015-12-18 | S1 | 584h | 584h | eULRS |  |  | Rel-14 | PCG-35 | SP-68 |
| 359 | 155 | **Diameter Load Control Mechanism** | 597d? | 2014-12-03 A | 2017-03-15 | 98% | 10.85d? | 461d |  | ct | 8032h | 7448.03h | DLoCMe | Nokia, Ulrich Wiehe | ulrich.wiehe@nokia.com | Rel-14 | PCG-37 | TSG-73 |
| 360 | 155.1 | CT3 aspects of Diameter Load Control Mechanism | 65d? | 2016-09-16 A | 2016-12-15 A | 100% |  |  | finish no earlier than 2016-12-15 | C3 | 520h | 520h | DLoCMe | Nokia, Ulrich Wiehe | ulrich.wiehe@nokia.com | Rel-14 | PCG-37 | TSG-73 |
| 361 | 155.2 | CT4 aspects of Diameter Load Control Mechanism | 65d? | 2016-09-16 A | 2016-12-15 A | 100% |  |  | finish no earlier than 2016-12-15 | C4 | 520h | 520h | DLoCMe | Nokia, Ulrich Wiehe | ulrich.wiehe@nokia.com | Rel-14 | PCG-37 | TSG-73 |
| 362 | 155.3 | (IETF) Diameter Load Information Conveyance (draft-ietf-dime-load-03) | 74d? | 2016-12-02 A | 2017-03-15 | 90% | 7.4d? | 461d | finish no earlier than 2017-03-15 | C4-IETF | 592h | 532.8h | DLoCMe |  |  | Rel-14 |  |  |
| 363 | 155.4 | Study on Diameter Load Control Mechanisms | 203d? | 2014-12-03 A | 2015-09-11 A | 100% |  |  | finish no earlier than 2015-09-11 | C4 | 1624h | 1624h | FS_DLoCME | Alcatel-Lucent |  | Rel-13 | PCG-34 | CT-66 |
| 364 | 156 | **Diameter Base Protocol Specification Update** | 74d? | 2016-12-01 A | 2017-03-14 A | 100% |  |  |  |  | 2352h | 2352h | DBPU | Huawei, Peter Schmitt | Peter.Schmitt@huawei.com | Rel-14 |  |  |
| 365 | 156.1 | **CT aspects of Diameter Base Protocol Specification Update** | 74d? | 2016-12-01 A | 2017-03-14 A | 100% |  |  |  | ct | 1776h | 1776h | DBPU | Huawei, Peter Schmitt | Peter.Schmitt@huawei.com | Rel-14 |  |  |
| 366 | 156.1.1 | CT3 aspects of Diameter Base Protocol Specification Update | 74d? | 2016-12-01 A | 2017-03-14 A | 100% |  |  | finish no earlier than 2017-03-14 | C3 | 592h | 592h | DBPU | Huawei, Peter Schmitt | Peter.Schmitt@huawei.com | Rel-14 |  |  |
| 367 | 156.1.2 | CT4 aspects of Diameter Base Protocol Specification Update | 74d? | 2016-12-01 A | 2017-03-14 A | 100% |  |  | finish no earlier than 2017-03-14 | C4 | 592h | 592h | DBPU | Huawei, Peter Schmitt | Peter.Schmitt@huawei.com | Rel-14 |  |  |
| 368 | 156.2 | Charging aspects for Diameter Base Protocol Specification Update | 72d? | 2016-12-01 A | 2017-03-10 A | 100% |  |  | finish no earlier than 2017-03-10 | S5 | 576h | 576h | DBPU-CH | Nokia | Nokia, Maryse <dot> Gardella <at> Nokia <dot> com | Rel-14 |  |  |
| 369 | 157 | **Enhancements to Multi-stream Multiparty Conferencing Media Handling** | 276d? | 2016-03-02 A | 2017-03-21 | 93% | 18.86d? | 457d |  |  | 10320h | 9547.39h | MMCMH_Enh | Nikolai Leung | nleung@qti.qualcomm.com | Rel-14 | PCG-37 | TSG#72 |
| 370 | 157.1 | Overall aspects of MMCMH_Enh | 196d? | 2016-06-13 A | 2017-03-10 A | 100% |  |  | finish no earlier than 2017-03-10 | S4 | 1568h | 1568h | MMCMH_Enh | Nikolai Leung | nleung@qti.qualcomm.com | Rel-14 | PCG-37 | TSG#72 |

Notes:
- 347: 21/3/17: 29.116 added; / Impacted TSs and TRs: 24.116, 24.117; 29.116
- 348: 2/12/16: 0%->40; 6/3/17: 40%->75 / Impacted TSs and TRs: 24.008
- 349: 6/3/17: 0%->80; 6/3/17: 80%->100 / Impacted TSs and TRs: 29.061
- 350: Impacted TSs and TRs: 29.274, 23.003
- 351: 7/3/17: 0%->100 / Impacted TSs and TRs: 31.102
- 352: 28/1/16: 26.347 added; 7/3/16: 0%->20; 11/6/16: 20%->35; 19/9/16: 35%->60. FCD: 09/16->03/17; 1/12/16: 60%->70; 6/3/17: 70%->100 / Impacted TSs and TRs: 26.346, 26.852, New TS; 26.347
- 353: 1/4/15: rapporteur added, Impacted TS added. 6/15: 0->25%; 07/09/15: 25%->40; 7/12/15: 40%->70; 2/3/16: 70%->80; 9/6/16: 80%->100 / Impacted TSs and TRs: 22.153
- 354: 1/12/16: 0%->10; 2/3/17: WID:SP-160375->SP-1570038; 3/3/17: 8%->15; 6/3/17: 15%->20; 9/3/17: WID:SP-1570038->SP-170038
- 356: 2/12/16: 0%->50; 6/3/17: 50%->85 / Impacted TSs and TRs: 24.229
- 357: Impacted TSs and TRs: 29.163, 29.292
- 358: 2/3/16: 0%->100
- 359: 5/12/16: WID:CP-160412->CP-160645
- 360: 2/12/16: 0%->100 / Impacted TSs and TRs: 29.272, 29.273, 29.228, 29.229, 29.328, 29.329, 29.336, 29.344, 29.345, 29.128, 29.283
- 361: 2/12/16: 0%->100 / Impacted TSs and TRs: 29.153, 29.154, 29.212, 29.214, 29.215, 29.217, 29.219, 29.213
- 362: 2/12/16: 0%->90
- 363: 0->5%. Mar. 15: 10%; 7/12/15: 10%->40; 13/6/16: 40%->100 / Impacted TSs and TRs: New 29.810
- 366: 6/3/17: 0%->100 / Impacted TSs and TRs: 29.061, 29.153, 29.154, 29.212, 29.214, 29.215, 29.217, 29.219, 29.368, 29.468, 29.213, 29.155, 29.201
- 367: 2/12/16: 0%->10; 6/3/17: 10%->100 / Impacted TSs and TRs: 29.109, 29.128, 29.172, 29.173, 29.228, 29.229, 29.272, 29.273, 29.283, 29.328, 29.329, 29.336, 29.337, 29.338, 29.343, 29.344, 29.345
- 368: 6/3/17: 0%->100 / Impacted TSs and TRs: 32.240, 32.251, 32.260, 32.270, 32.271, 32.272, 32.273, 32.274, 32.275, 32.278, 32.280, 32.295, 32.296, 32.297, 32.299
- 369: Impacted TSs and TRs: TS 26.114
- 370: 19/9/16: WID:SP-160272->SP-160785; 19/9/16: 0%->50; 1/12/16: 50%->80; 1/12/16: FCD:12/16->03/17; 6/3/17: 80%->100 / Impacted TSs and TRs: TS 26.114, TR 26.980

| ID | WBS | Task | Duration | Start | Finish | Complete | Remaining | Total slack | Constraint | Resources | Work | Actual work | Acronym | PCG approved | WI rapporteur e-mail | Release | TSG approved | TSG stopped |
| --- | --- | --- | --- | --- | --- | --- | --- | --- | --- | --- | --- | --- | --- | --- | --- | --- | --- | --- |
| 371 | 157.2 | **CT aspects of MMCMH_Enh** | 276d? | 2016-03-02 A | 2017-03-21 | 92% | 23.38d? | 457d |  | ct | 8752h | 7979.39h | MMCMH_Enh-CT | PCG-37 | nevenka.biondic@ericsson.com | Rel-14 | TSG#72 |  |
| 372 | 157.2.1 | CT1 aspects of MMCMH_Enh | 272d? | 2016-03-02 A | 2017-03-15 A | 100% |  |  | finish no earlier than 2017-03-15 | C1 | 2176h | 2176h | MMCMH_Enh-CT | PCG-37 | nevenka.biondic@ericsson.com | Rel-14 | TSG#72 |  |
| 373 | 157.2.2 | CT3 aspects of MMCMH_Enh | 272d? | 2016-03-02 A | 2017-03-15 A | 100% |  |  | finish no earlier than 2017-03-15 | C3 | 2176h | 2176h | MMCMH_Enh-CT | PCG-37 | nevenka.biondic@ericsson.com | Rel-14 | TSG#72 |  |
| 374 | 157.2.3 | CT4 aspects of MMCMH_Enh | 272d? | 2016-03-02 A | 2017-03-15 | 75% | 68d? | 461d | finish no earlier than 2017-03-15 | C4 | 2176h | 1632h | MMCMH_Enh-CT | PCG-37 | nevenka.biondic@ericsson.com | Rel-14 | TSG#72 |  |
| 375 | 157.2.4 | (IETF) Using Simulcast in SDP and RTP Sessions (draft-ietf-mmusic-sdp-simulcast) | 1d? | 2017-03-21 A | 2017-03-21 | 50% | 0.5d? | 457d | start no earlier than 2017-03-21 | C1-IETF | 8h | 4h | MMCMH_Enh-CT |  | tomas.frankkila@ericsson.com | Rel-14 |  |  |
| 376 | 157.2.5 | (IETF) RTP Payload Format Restrictions (draft-ietf-mmusic-rid) | 1d? | 2017-03-21 A | 2017-03-21 | 20% | 0.8d? | 457d | start no earlier than 2017-03-21 | C1-IETF | 8h | 1.6h | MMCMH_Enh-CT |  |  | Rel-14 |  |  |
| 377 | 158 | **Deleted - CT aspects of (or "Enhancements of") MTSI Extension on Multi-stream** | 143d? | 2016-03-02 A | 2016-09-15 A | 100% |  |  |  | ct | 4576h | 4576h | MMCMH-CT | PCG-36 | nevenka.biondic@ericsson.com | Rel-14 | TSG#71 | CP-72 |
| 378 | 158.1 | deleted -CT1 aspects of MTSI Extension on Multi-stream | 143d? | 2016-03-02 A | 2016-09-15 A | 100% |  |  | start no earlier than 2016-03-02 | C1 | 1144h | 1144h | MMCMH-CT | PCG-36 | nevenka.biondic@ericsson.com | Rel-14 | TSG#71 | CP-72 |
| 379 | 158.2 | deleted -CT3 aspects of MTSI Extension on Multi-stream | 143d? | 2016-03-02 A | 2016-09-15 A | 100% |  |  | start no earlier than 2016-03-02 | C3 | 1144h | 1144h | MMCMH-CT | PCG-36 | nevenka.biondic@ericsson.com | Rel-14 | TSG#71 | CP-72 |
| 380 | 158.3 | deleted -CT4 aspects of MTSI Extension on Multi-stream | 143d? | 2016-03-02 A | 2016-09-15 A | 100% |  |  | start no earlier than 2016-03-02 | C4 | 1144h | 1144h | MMCMH-CT | PCG-36 | nevenka.biondic@ericsson.com | Rel-14 | TSG#71 | CP-72 |
| 381 | 159 | **Control and User Plane Separation of EPC nodes** | 391d? | 2015-09-17 A | 2017-03-15 | 69% | 119.64d? | 461d |  |  | 5248h | 3313h | CUPS | PCG-35 | mirko.schramm@huawei.com | Rel-14 | SP-69 |  |
| 382 | 159.1 | Study on Control and User Plane Separation of EPC nodes | 197d? | 2015-09-17 A | 2016-06-17 A | 100% |  |  | finish no earlier than 2016-06-17 | S2 | 1576h | 1576h | FS_CUPS | PCG-35 | mirko.schramm@huawei.com | Rel-14 | SP-69 |  |
| 383 | 159.2 | Control and User Plane Separation of EPC nodes | 72d? | 2016-06-09 A | 2016-09-15 A | 100% |  |  | finish no earlier than 2016-09-15 | S2 | 576h | 576h | CUPS | PCG-37 | mirko.schramm@huawei.com | Rel-14 | TSG#72 |  |
| 384 | 159.3 | **CT aspects for CUPS** | 129d? | 2016-09-16 A | 2017-03-15 | 38% | 80.62d? | 461d |  | ct | 3096h | 1161h | CUPS-CT | PCG-37 | peter.schmitt@huawei.com | Rel-14 | TSG-73 |  |
| 385 | 159.3.1 | CT3 aspects for CUPS | 129d? | 2016-09-16 | 2017-03-15 |  |  | 461d | finish no earlier than 2017-03-15 | C3 | 1032h |  | CUPS-CT | PCG-37 | peter.schmitt@huawei.com | Rel-14 | TSG-73 |  |
| 386 | 159.3.2 | CT4 aspects for CUPS | 129d? | 2016-09-16 A | 2017-03-15 | 75% | 32.25d? | 461d | finish no earlier than 2017-03-15 | C4 | 1032h | 774h | CUPS-CT | PCG-37 | peter.schmitt@huawei.com | Rel-14 | TSG-73 |  |
| 387 | 160 | **OAM14 Rel-14 Operations, Administration, Maintenance and Provisioning (OAM&P)** | 589d? | 2015-03-12 A | 2017-06-12 | 82% | 107.84d? | 398d |  | S5 | 32033.6h | 19491.2h | OAM14 | PCG-35 |  | Rel-14 | SP-68 |  |
| 388 | 160.1 | **Management of mobile networks that include virtualized network functions** | 521d? | 2015-06-15 A | 2017-06-09 | 83% | 89.54d? | 399d |  | S5 | 21856h | 14964.8h | OAM14-MAMO_VNF | PCG-35 | liujinglei@chinamobile.com | Rel-14 | SP-68 |  |
| 389 | 160.1.1 | Management concept, architecture and requirements for mobile networks that include virtualized network functions | 395d? | 2015-06-15 A | 2016-12-15 | 90% | 39.5d? | 525d | finish no earlier than 2016-12-15 | S5 | 3160h | 2844h | OAM14-MAMO_VNF-MCAR | PCG-35 | liujinglei@chinamobile.com | Rel-14 | SP-68 |  |
| 390 | 160.1.2 | Configuration Management for mobile networks that include virtualized network functions | 454d? | 2015-09-16 A | 2017-06-09 | 80% | 90.8d? | 399d | finish no earlier than 2017-06-09 | S5 | 3632h | 2905.6h | OAM14-MAMO_VNF-CM | PCG-35 | zhu.weihong@zte.com.cn | Rel-14 | SP-69 |  |
| 391 | 160.1.3 | Fault Management for mobile networks that include virtualized network functions | 454d? | 2015-09-16 A | 2017-06-09 | 90% | 45.4d? | 399d | finish no earlier than 2017-06-09 | S5 | 3632h | 3268.8h | OAM14-MAMO_VNF-FM | PCG-35 | kai.zhangkai@huawei.com | Rel-14 | SP-69 |  |
| 392 | 160.1.4 | Performance management for mobile networks that include virtualized network functions | 454d? | 2015-09-16 A | 2017-06-09 | 75% | 113.5d? | 399d | finish no earlier than 2017-06-09 | S5 | 3632h | 2724h | OAM14-MAMO_VNF-PM | PCG-35 | joey.chou@intel.com | Rel-14 | SP-69 |  |
| 393 | 160.1.5 | Lifecycle management for mobile networks that include virtualized network functions | 454d? | 2015-09-16 A | 2017-06-09 | 80% | 90.8d? | 399d | finish no earlier than 2017-06-09 | S5 | 3632h | 2905.6h | OAM14-MAMO_VNF-LCM | PCG-35 | anatoly.andrianov@nokia.com | Rel-14 | SP-69 |  |
| 394 | 160.2 | Filtering of PM measurements and data volume | 199d? | 2016-03-01 A | 2016-12-01 A | 100% |  |  | start no earlier than 2016-03-01 | S5 | 1592h | 1592h | OAM14-FILMEAS | PCG-36 | robert.petersen@ericsson.com | Rel-14 | TSG#71 |  |
| 395 | 160.3 | Study on OAM support for Licensed Shared Access (LSA) | 262d? | 2015-03-12 A | 2016-03-11 A | 100% |  |  | finish no earlier than 2016-03-11 | S5 | 2096h | 2096h | FS_OAM_LSA | PCG-34 | anatoly<dot>andrianov<at>nokia<dot>com | Rel-14 | SP-67 |  |
| 396 | 160.4 | OAM support for Licensed Shared Access (LSA) | 262d? | 2016-06-13 A | 2017-06-12 | 40% | 157.2d? | 398d | start no earlier than 2016-06-13 | S5 | 2096h | 838.4h | OAM14-LSA | PCG-37 |  | Rel-14 | TSG#72 |  |
| 397 | 161 | Development of super-wideband and fullband P.835 | 524d? | 2015-06-16 A | 2017-06-15 | 80% | 104.8d? | 395d | finish no earlier than 2017-06-15 | S4 | 4192h | 3353.6h | DESUDAPS | PCG-35 | sisabelle@audience.com | Rel-14 | SP-68 |  |
| 398 | 162 | Enhancing Location Capabilities for Indoor and Outdoor Emergency Communications | 200d? | 2015-03-11 A | 2015-12-15 A | 100% |  |  | finish no earlier than 2015-12-15 | S1 | 1600h | 1600h | ELIOT | PCG-34 | Gregory.schumacher@sprint.com | Rel-14 | SP-67 |  |
| 399 | 163 | Enhancements to Domain Selection between VoLTE and CDMA CS | 69d? | 2015-03-11 A | 2015-06-15 A | 100% |  |  | finish no earlier than 2015-06-15 | S1 | 552h | 552h | eDSVCC | PCG-34 | zhuhongmei@gsta.com | Rel-14 | SP-67 |  |
| 400 | 164 | Control of Applications when Third party Servers encounter difficulties | 93d? | 2015-05-11 A | 2015-09-16 A | 100% |  |  | finish no earlier than 2015-09-16 | S1 | 744h | 744h | CATS | PCG-35 | er-yoshida (at) kddi (dot) com | Rel-14 | SP-68 |  |

Notes:
- 371: To be checked at SA4 if a part can stay in Rel-13 (now Stages 1 and 2 by SA4 in UID660050), while the CT aspects are in Rel-14. 06/16: Name changed from "CT aspects of (or "Enhancements of") MTSI Extension on Multi-stream". Acronym changed from "MMCMH- / WI rapporteur name: Ericsson, Nevenka Biondic
- 372: Name changed from "CT1 aspects of MTSI Extension on Multi-stream". Acronym changed from "MMCMH-CT"; 13/6/16: WID:CP-160117->CP-160250. FCD: 09/16->03/17; 13/6/16: WID:CP-160250->CP-160369; 2/12/16: 0%->95; 6/3/17: 95%->100 / Impacted TSs and TRs: 24.229 / WI rapporteur name: Ericsson, Nevenka Biondic
- 373: Acronym changed from "MMCMH-CT"; 13/6/16: WID:CP-160117->CP-160250. FCD: 09/16->03/17; 13/6/16: WID:CP-160250->CP-160369; 6/3/17: 0%->100 / Impacted TSs and TRs: 29.162, 29.213, 29.214, 29.165 / WI rapporteur name: Ericsson, Nevenka Biondic
- 374: 3/6/16: WID:CP-160117->CP-160250. FCD: 09/16->03/17; 13/6/16: WID:CP-160250->CP-160369; 2/12/16: 0%->35; 6/3/17: 35%->75 / Impacted TSs and TRs: 23.333, 29.333, 23.334, 29.334, 29.238 / WI rapporteur name: Ericsson, Nevenka Biondic
- 375: WI rapporteur name: Ericsson
- 376: WI rapporteur name: Ericsson
- 377: Deleted, "replaced" by MMCMH_Enh-CT / WI rapporteur name: Ericsson, Nevenka Biondic
- 378: Deleted, "replaced" by MMCMH_Enh-CT / Impacted TSs and TRs: 24.229 / WI rapporteur name: Ericsson, Nevenka Biondic
- 379: Deleted, "replaced" by MMCMH_Enh-CT / Impacted TSs and TRs: 29.162, 29.213, 29.214, 29.165 / WI rapporteur name: Ericsson, Nevenka Biondic
- 380: Deleted, "replaced" by MMCMH_Enh-CT / Impacted TSs and TRs: 23.333, 29.333, 23.334, 29.334, 29.238 / WI rapporteur name: Ericsson, Nevenka Biondic
- 381: 7/12/15: 0%->20; 7/3/16: 20%->40; 9/6/16: 40%->100; 28/7/16: 23.214 added; / Impacted TSs and TRs: 23.714; 23.214 / WI rapporteur name: Huawei, Mirko Schramm
- 382: 7/12/15: 0%->20; 7/3/16: 20%->40; 9/6/16: 40%->100 / Impacted TSs and TRs: 23.714 / WI rapporteur name: Huawei, Mirko Schramm
- 383: 19/9/16: 0%->80; 1/12/16: 80%->100 / Impacted TSs and TRs: 23.214, 23.002, 23.203, 23.401, 23.402 / WI rapporteur name: Huawei, Mirko Schramm
- 384: WI rapporteur name: Huawei, Peter Schmitt
- 385: Impacted TSs and TRs: 29.212, 29.213 / WI rapporteur name: Huawei, Peter Schmitt
- 386: 2/12/16: 0%->40; 6/3/17: 40%->75 / Impacted TSs and TRs: 23.007, 29.274, 29.281, 29.303, 23.008 / WI rapporteur name: Huawei, Peter Schmitt
- 388: June2015: WID:SP-150308->SP-150362 / WI rapporteur name: Jinglei Liu, China Mobile
- 389: June2015: WID:SP-150309->SP-150363. Aug2015: FCD: Mar 2016; 07/09/15: 0%->20. 15/09/15: FCD: Mar 16->Dec 16, moved to Rel-14; 7/12/15: 20%->40; 7/3/16: 40%->50; 7/3/16: WID:SP-150363->SP-160023 ( FCD: Dec16->Sep16); 13/6/16: 50%->70; 19/9/16: FCD:09/16; 21/3/17: 100%->90 / Impacted TSs and TRs: 28.xyz, 32.101 / WI rapporteur name: Jinglei Liu, China Mobile (liujinglei@chinamobile.com)
- 390: 5/10/15: 28.513; 28.512; 28.511; 28.510 added; 7/12/15: 0%->15; 7/3/16: 15%->20; 13/6/16: 20%->30; 19/9/16: 30%->50; 1/12/16: 50%->60; 1/12/16: FCD:12/16->03/17; 6/3/17: FCD:03/17->06/17; 6/3/17: 60%->80 / Impacted TSs and TRs: 28.513; 28.512; 28.511; 28.510; 28.621, 28.622, 28.623, 28.704, 28.707 / WI rapporteur name: ZTE Corporation (Zhu Weihong, zhu.weihong@zte.com.cn)
- 391: 5/10/15: 28.518; 28.517; 28.516; 28.515 added; 7/12/15: 0%->10; 7/3/16: 10%->15; 13/6/16: 15%->50; 13/6/16: WID:SP-150404->SP-160403; 19/9/16: 50%->75; 1/12/16: 75%->80; 1/12/16: 80%->; 1/12/16: FCD:12/16->03/17; 6/3/17: FCD:03/17->06/17; 6/3/17: 80%->90 / Impacted TSs and TRs: 28.515, 28.516, 28.517, 28.518, 32.111-1, 32.111-2, 32.111-6 / WI rapporteur name: Huawei (Kai ZHANG, kai.zhangkai@huawei.com)
- 392: 5/10/15: 28.523; 28.522; 28.521; 28.520 added; 7/12/15: 0%->10; 7/3/16: 10%->15; 13/6/16: 15%->30; 13/6/16: WID:SP-150401->SP-160402; 19/9/16: 30%->60; 1/12/16: FCD:12/16->03/17; 6/3/17: FCD:03/17->06/17; 6/3/17: 60%->75 / Impacted TSs and TRs: 28.523; 28.522; 28.521; 28.520; 32.426, 32.409, 32.401 / WI rapporteur name: Intel (Joey Chou, joey.chou@intel.com)
- 393: 5/10/15: 28.528; 28.527; 28.526; 28.525 added; 7/12/15: 0%->10; 7/3/16: 10%->15; 13/6/16: 15%->25; 13/6/16: WID:SP-150403->SP-160427; 19/9/16: 25%->40; 1/12/16: 40%->60; 1/12/16: FCD:12/16->03/17; 6/3/17: FCD:03/17->06/17; 6/3/17: 60%->80 / Impacted TSs and TRs: 28.525, 28.526, 28.527, 28.528, 28.704, 28.705, 28.706, 28.707, 28.708, 28.709 / WI rapporteur name: Anatoly Andrianov (anatoly.andrianov@nokia.com), Nokia Networks
- 394: 13/6/16: 0%->15; 19/9/16: WID:SP-160022->SP-160610; 19/9/16: 15%->60; 1/12/16: 60%->95; 6/3/17: 95%->100 / Impacted TSs and TRs: New 32.817, 32.425, 32.412, 32.416, 32.130 / WI rapporteur name: Ericsson: Robert Petersen
- 395: June2015: Compl:0%->15; 07/09/15: 15%->70; 7/12/15: 70%->75; 7/3/16: 75%->100. 22/3/16: FCD: 09/15->03/16. Rel-13->Rel-14; 28/7/16: 28.303 added; 28/7/16: 28.302 added; 28/7/16: 28.301 added; 28/7/16: 33.250 added; 28/7/16: added; / Impacted TSs and TRs: 28.303; 28.302; 28.301; / WI rapporteur name: Nokia Networks, Anatoly Andrianov
- 396: 28/7/16: 28.303 added; 28/7/16: 28.302 added; 28/7/16: 28.301 added; 19/9/16: 0%->20; 1/12/16: 20%->30; 6/3/17: 30%->40 / Impacted TSs and TRs: 32.101; 28.303; 28.302; 28.301 / WI rapporteur name: Nokia: Olaf Pollakowski
- 397: 06/15: FCD corrected to Dec.15; Aug2015: 0%->5; 07/09/15: 5%->20, FCD: 12/15->06.16; 7/12/15: 20%->40, MOVED TO REL-14; 7/3/16: 40%->50. 15/4/16: 6/16->12/16; 11/6/16: 50%->60; 19/9/16: 60%->70, fcd: 12/16->06/17; 1/12/16: 70%->75; 6/3/17: 75%->80 / Impacted TSs and TRs: 26.131, 26.132 / WI rapporteur name: Scott Isabelle (Knowles, Inc.)
- 398: 1/4/15: rapporteur added, Impacted TS added; June2015: Compl:0%->25; 07/09/15: 25%->80; 2/3/16: 80%->100 / Impacted TSs and TRs: 22.101, 22.071 / WI rapporteur name: Greg Schumacher
- 399: 1/4/15: rapporteur added, Impacted TS added; June2015: Compl:0%->100 / Impacted TSs and TRs: 22.101 / WI rapporteur name: China Telecom, Hongmei Zhu
- 400: 07/09/15: 0%->100 / Impacted TSs and TRs: 22.011 / WI rapporteur name: Eriko Yoshida, KDDI

| ID | WBS | Task | Duration | Start | Finish | Complete | Remaining | Total slack | Constraint | Resources | Work | Actual work | Acronym | PCG approved | WI rapporteur name | WI rapporteur e-mail | Release | TSG approved |
| --- | --- | --- | --- | --- | --- | --- | --- | --- | --- | --- | --- | --- | --- | --- | --- | --- | --- | --- |
| 401 | 165 | **PS Data Off Services** | 416d? | 2015-11-09 A | 2017-06-09 | 88% | 51.3d? | 399d |  |  | 5416h | 4732.06h | PS_Data_Off | PCG-36 | Orange, Bruno Tossou | bruno.tossou@orange.com | Rel-14 | SP-70 |
| 402 | 165.1 | PS Data Off Services | 92d? | 2015-11-09 A | 2016-03-15 A | 100% |  |  | finish no earlier than 2016-03-15 | S1 | 736h | 736h | PS_Data_Off | PCG-36 | Orange, Bruno Tossou | bruno.tossou@orange.com | Rel-14 | SP-70 |
| 403 | 165.2 | Study on Stage 2 of PS Data off function | 131d? | 2016-06-17 A | 2016-12-15 A | 100% |  |  | finish no earlier than 2016-12-15 | S2 | 1048h | 1048h | FS_PS_DATA_OFF | PCG-37 | Orange, david <dot> cailliere <at> orange <dot> com | david <dot> cailliere <at> orange <dot> com | Rel-14 | SP-72 |
| 404 | 165.3 | Stage 2 of PS Data Off | 21d? | 2016-11-17 A | 2016-12-15 A | 100% |  |  | finish no earlier than 2016-12-15 | S2 | 168h | 168h | PS_DATA_OFF |  | Christophe Petit (Orange) | kris (dot) petit (at) orange (dot) com | Rel-14 |  |
| 405 | 165.4 | **Stage 3 of PS Data Off** | 74d? | 2016-12-01 A | 2017-03-14 | 85% | 11.09d? | 462d |  | ct | 2368h | 2012.86h | PS_DATA_OFF-CT |  | Herrero Veron, Christian (Huawei) | Christian.Herrero at huawei.com | Rel-14 |  |
| 406 | 165.4.1 | CT1 aspects of PS Data Off | 74d? | 2016-12-01 A | 2017-03-14 | 95% | 3.7d? | 462d | finish no earlier than 2017-03-14 | C1 | 592h | 562.4h | PS_DATA_OFF-CT |  | Herrero Veron, Christian (Huawei) | Christian.Herrero at huawei.com | Rel-14 |  |
| 407 | 165.4.2 | CT3 aspects of PS Data Off | 74d? | 2016-12-01 A | 2017-03-14 | 60% | 29.6d? | 462d | finish no earlier than 2017-03-14 | C3 | 592h | 355.2h | PS_DATA_OFF-CT |  | Herrero Veron, Christian (Huawei) | Christian.Herrero at huawei.com | Rel-14 |  |
| 408 | 165.4.3 | CT6 aspects of PS Data Off | 74d? | 2016-12-01 A | 2017-03-14 A | 100% |  |  | finish no earlier than 2017-03-14 | C6 | 592h | 592h | PS_DATA_OFF-CT |  | Herrero Veron, Christian (Huawei) | Christian.Herrero at huawei.com | Rel-14 |  |
| 409 | 165.5 | Charging Aspect for 3GPP PS Data off Function | 137d? | 2016-12-01 A | 2017-06-09 | 70% | 41.1d? | 399d | finish no earlier than 2017-06-09 | S5 | 1096h | 767.2h | PS_DATA_OFF-CH |  | Huawei， Chen, Shan | chenshan@huawei.com | Rel-14 |  |
| 410 | 166 | SCC AS Restoration | 208d? | 2016-03-02 A | 2016-12-15 A | 100% |  |  | finish no earlier than 2016-12-15 | C4 | 1664h | 1664h | SCCAS_RES | PCG-36 | China Mobile, Hao Zhang, | zhanghao@chinamobile.com | Rel-14 | TSG#71 |
| 411 | 167 | Paging Policy Enhancements and Procedure | 22d? | 2016-02-01 A | 2016-03-01 A | 100% |  |  | finish no earlier than 2016-03-01 | S1 | 176h | 176h | PPEPO_LTE | PCG-36 | China Unicom, Zhuoyun Zhang | zhangzy910@chinaunicom.cn | Rel-14 | TSG#71 |
| 412 | 168 | **Enhancement to Flexible Mobile Service Steering** | 355d? | 2015-05-11 A | 2016-09-15 A | 100% |  |  |  |  | 1968h | 1968h | eFMSS | PCG-37 | China Mobile, Lu Lu | lulu@chinamobile.com | Rel-14 | SP-72 |
| 413 | 168.1 | Study on enhancement to FMSS for Rel 14 | 158d? | 2015-05-11 A | 2015-12-16 A | 100% |  |  | finish no earlier than 2015-12-16 | S1 | 1264h | 1264h | FS_eFMSS | PCG-35 | Lu Lu, China Mobile | lulu@chinamobile.com | Rel-14 | SP-68 |
| 414 | 168.2 | Stage 1 of Enhancement to Flexible Mobile Service Steering | 22d? | 2016-02-01 A | 2016-03-01 A | 100% |  |  | start no earlier than 2016-02-01 | S1 | 176h | 176h | eFMSS | PCG-36 | China Mobile, Lu Lu | lulu@chinamobile.com | Rel-14 | TSG#71 |
| 415 | 168.3 | Stage 2 of Enhancement to Flexible Mobile Service Steering | 66d? | 2016-06-17 A | 2016-09-15 A | 100% |  |  | finish no earlier than 2016-09-15 | S2 | 528h | 528h | eFMSS | PCG-37 | ZTE, Tricci So |  | Rel-14 | SP-72 |
| 416 | 169 | Unlicensed Spectrum Offloading System | 22d? | 2016-02-01 A | 2016-03-01 A | 100% |  |  | start no earlier than 2016-02-01 | S1 | 176h | 176h | USOS | PCG-36 | Edward Hall, Qualcomm Incorporated | edhall@qti.qualcomm.com | Rel-14 | TSG#71 |
| 417 | 170 | **Media Handling Extensions of IMS-based Telepresence** | 199d? | 2016-03-01 A | 2016-12-01 | 50% | 99.5d? | 535d |  |  | 3184h | 1592h | IMS_TELEP_EXT | PCG-36 | Ozgur Oyman, Intel | ozgur.oyman@intel.com | Rel-14 | TSG#71 |
| 418 | 170.1 | S4 aspects of Media Handling Extensions of IMS-based Telepresence | 199d? | 2016-03-01 A | 2016-12-01 A | 100% |  |  | finish no earlier than 2016-12-01 | S4 | 1592h | 1592h | IMS_TELEP_EXT | PCG-37 | Ozgur Oyman, Intel | ozgur.oyman@intel.com | Rel-14 | TSG#72 |
| 419 | 170.2 | (IETF) Other IETF aspects of IMS_TELEP_EXT | 199d? | 2016-03-01 | 2016-12-01 |  |  | 535d | finish no earlier than 2016-12-01 | S4-IETF | 1592h |  | IMS_TELEP_EXT | PCG-37 |  | ozgur.oyman@intel.com | Rel-14 | TSG#72 |
| 420 | 171 | Improved Streaming QoE Reporting in 3GPP | 273d? | 2016-03-01 A | 2017-03-15 A | 100% |  |  | finish no earlier than 2017-03-15 | S4 | 2184h | 2184h | IQoE | PCG-36 | Zhiming Li, Huawei | Lizhiming@huawei.com | Rel-14 | TSG#71 |
| 421 | 172 | New GPRS algorithms for EASE | 67d? | 2016-03-15 A | 2016-06-15 A | 100% |  |  | start no earlier than 2016-03-15 | S3 | 536h | 536h | EASE_ALGOs_SA3 | PCG-36 | Tim Evans, Vodafone |  | Rel-14 | TSG#71 |
| 422 | 173 | **S8 Home Routing Architecture for VoLTE** | 518d? | 2015-06-18 A | 2017-06-09 | 81% | 98.24d? | 399d |  |  | 7832h | 6445.2h | V8 | PCG-36 |  |  | Rel-14 | TSG#71 |
| 423 | 173.1 | Study on S8 Home Routing Architecture | 191d? | 2015-06-18 A | 2016-03-10 A | 100% |  |  | finish no earlier than 2016-03-10 | S2 | 1528h | 1528h | FS_V8 | PCG-35 | Motohiro ABE | motohiro(dot)abe(dot)cu(at) nttdocomo (dot) com | Rel-14 | SP-68 |
| 424 | 173.2 | Study on LI in S8 Home Routing Architecture for VoLTE | 197d? | 2015-09-17 A | 2016-06-17 | 65% | 68.95d? | 655d | finish no earlier than 2016-06-17 | S3 | 1576h | 1024.4h | FS_LIV8 | PCG-35 | Greg Schumacher (SPRINT) Gregory | Schumacher@sprint.com | Rel-14 | SP-69 |
| 425 | 173.3 | S8 Home Routing Architecture for VoLTE | 135d? | 2016-06-13 A | 2016-12-15 A | 100% |  |  | finish no earlier than 2016-12-15 | S2 | 1080h | 1080h | V8 | PCG-37 | Motohiro ABE | motohiro(dot)abe(dot)cu(at) nttdocomo (dot) com | Rel-14 | TSG#72 |

Notes:
- 401: 2/3/16: 0%->100 / Impacted TSs and TRs: 22.030
- 402: 2/3/16: 0%->100 / Impacted TSs and TRs: 22.030
- 403: 28/7/16: 23.702 added; 19/9/16: 0%->60; 1/12/16: FCD:09/16->12/16; 1/12/16: 60%->100 / Impacted TSs and TRs: TR 23.702
- 404: 1/12/16: 0%->100 / Impacted TSs and TRs: 23.401, 23.203, 23.060, 23.228, 23.292, 23.221
- 406: 6/3/17: 0%->95 / Impacted TSs and TRs: 24.008, 24.301, 27.007, 24.229, 24.368, 24.167
- 407: 6/3/17: 0%->60 / Impacted TSs and TRs: 29.212, 29.213
- 408: 7/3/17: 0%->100 / Impacted TSs and TRs: 31.102, 31.103, 31.111
- 409: 6/3/17: 0%->70; 6/3/17: FCD:03/17->06/17 / Impacted TSs and TRs: TS 32.251, TS 32.298, TS 32.299
- 410: 13/6/16: 0%->100 / Impacted TSs and TRs: 23.380
- 411: Impacted TSs and TRs: 22.101
- 412: Impacted TSs and TRs: 22.115, 22.101
- 413: 7/12/15: 70%->100 / Impacted TSs and TRs: 22.808
- 414: Impacted TSs and TRs: 22.115, 22.101
- 415: 19/9/16: 0%->100 / Impacted TSs and TRs: 23.203
- 416: Impacted TSs and TRs: 22.101, 22.115
- 417: 11/6/16: 0%->10 / Impacted TSs and TRs: 26.223
- 418: 11/6/16: 0%->10; 19/9/16: 10%->60; 1/12/16: 60%->100 / Impacted TSs and TRs: 26.223
- 419: Impacted TSs and TRs: draft-ietf-payload-rtp-h265, -flexible-fec-scheme , draft-ietf-clue-framework , -datachannel, -signalling, -data-model-schema, -protocol, -rtp-mapping, draft-ietf-mmusic-sctp-sdp, -data-channel-sdpneg, draft-ietf-tsvwg-sctp-dtls-encaps
- 420: 11/6/16: 0%->10; 19/9/16: 10%->55. FDC: 12/16->03/17; 1/12/16: 55%->65; 6/3/17: 65%->100 / Impacted TSs and TRs: New 26.909, 26.247, 26.346
- 421: Discussion whether it should be Rel-13. To be concluded at SA#72.; 13/6/16: 0%->60; 1/12/16: 60%->70; 6/3/17: 70%->100 / Impacted TSs and TRs: 55.241, 55.242, 55.243, 55.251, 55.252, 55.253
- 422: Umbrella, created by MCC to group SA2 and SA3 activities
- 423: 07/09/15: 0%->10; 07/09/15: 10%->100; 7/12/15: 100%->10% (mistake?) then 10%->70, FCD: 12/15-?03/16; 7/3/16: 70%->80; 9/6/16: 80%->100 / Impacted TSs and TRs: New TR 23.xxx
- 424: 7/12/15: 0%->45; 28/1/16: 33.827 added; 7/3/16: 45%->55; 19/9/16: 55%->65 / Impacted TSs and TRs: TR 33.827
- 425: 11/6/16: 0%->60; 19/9/16: 60%->95; 1/12/16: FCD:09/16->12/16; 1/12/16: 95%->100 / Impacted TSs and TRs: TS 23.228, TS 23.167, TS 23.203

| ID | WBS | Task | Duration | Start | Finish | Complete | Remaining | Total slack | Constraint | Resources | Work | Actual work | Acronym | PCG approved | WI rapporteur name | WI rapporteur e-mail | Release | TSG approved |
| --- | --- | --- | --- | --- | --- | --- | --- | --- | --- | --- | --- | --- | --- | --- | --- | --- | --- | --- |
| 426 | 173.4 | **CT Aspects of V8** | 65d? | 2016-09-16 A | 2016-12-15 A | 100% |  |  |  | ct | 1560h | 1560h | V8-CT | PCG-37 | Tsuyoshi Takakura (NTT DOCOMO) | tsuyoshi.takakura.ey@s1.nttdocomo.com | Rel-14 | TSG-73 |
| 427 | 173.4.1 | CT1 Aspects of V8 | 65d? | 2016-09-16 A | 2016-12-15 A | 100% |  |  | finish no earlier than 2016-12-15 | C1 | 520h | 520h | V8-CT | PCG-37 | Tsuyoshi Takakura (NTT DOCOMO) | tsuyoshi.takakura.ey@s1.nttdocomo.com | Rel-14 | TSG-73 |
| 428 | 173.4.2 | CT3 Aspects of V8 | 65d? | 2016-09-16 A | 2016-12-15 A | 100% |  |  | finish no earlier than 2016-12-15 | C3 | 520h | 520h | V8-CT | PCG-37 | Tsuyoshi Takakura (NTT DOCOMO) | tsuyoshi.takakura.ey@s1.nttdocomo.com | Rel-14 | TSG-73 |
| 429 | 173.5 | Charging Aspects of S8 Home Routing Architecture for VoLTE | 261d? | 2016-06-13 A | 2017-06-09 | 60% | 104.4d? | 399d | finish no earlier than 2017-06-09 | S5 | 2088h | 1252.8h | CH14-V8 | PCG-37 | Chen, Ai (China Mobile) | chenai(at) chinamobile (dot) com | Rel-14 | TSG#72 |
| 430 | 174 | **Improvements of awareness of user location change** | 453d? | 2015-09-17 A | 2017-06-09 | 94% | 29.08d? | 399d |  |  | 5256h | 4952h | AULC | PCG-37 | Yang Xu | xuyang49@chinaunicom.cn | Rel-14 | TSG#72 |
| 431 | 174.1 | Study on improvement of awareness of user location change | 197d? | 2015-09-17 A | 2016-06-17 A | 100% |  |  | finish no earlier than 2016-06-17 | S2 | 1576h | 1576h | FS_AULC | PCG-35 | Yang Xu | xuyang49@chinaunicom.cn | Rel-14 | SP-69 |
| 432 | 174.2 | Improvements of awareness of user location change | 75d? | 2016-06-06 A | 2016-09-15 A | 100% |  |  | finish no earlier than 2016-09-15 | S2 | 600h | 600h | AULC | PCG-37 | Yang Xu | xuyang49@chinaunicom.cn | Rel-14 | TSG#72 |
| 433 | 174.3 | **CT Aspect of AULC** | 65d? | 2016-09-16 A | 2016-12-15 A | 100% |  |  |  | ct | 1560h | 1560h | AULC-CT | PCG-37 | Huawei, Wu Yizhuang | wuyizhuang@huawei.com | Rel-14 | TSG-73 |
| 434 | 174.3.1 | CT3 Aspect of AULC | 65d? | 2016-09-16 A | 2016-12-15 A | 100% |  |  | finish no earlier than 2016-12-15 | C3 | 520h | 520h | AULC-CT | PCG-37 | Huawei, Wu Yizhuang | wuyizhuang@huawei.com | Rel-14 | TSG-73 |
| 435 | 174.3.2 | CT4 Aspect of AULC | 65d? | 2016-09-16 A | 2016-12-15 A | 100% |  |  | finish no earlier than 2016-12-15 | C4 | 520h | 520h | AULC-CT | PCG-37 | Huawei, Wu Yizhuang | wuyizhuang@huawei.com | Rel-14 | TSG-73 |
| 436 | 174.4 | Charging Aspects of Improvements of AULC | 190d? | 2016-09-19 A | 2017-06-09 | 80% | 38d? | 399d | finish no earlier than 2017-06-09 | S5 | 1520h | 1216h | AULC-CH | PCG-37 | Huawei， Chen, Shan | chenshan@huawei.com | Rel-14 | TSG-73 |
| 437 | 175 | **Service Domain Centralization** | 232d? | 2015-11-02 A | 2016-09-19 A | 100% |  |  |  | S2 | 3896h | 3896h | SeDoC | PCG-37 | Chris Joul (T-Mobile USA) | chris (dot) joul (at) t (dash) mobile (dot) com | Rel-14 | TSG#72 |
| 438 | 175.1 | Study on Service Domain Centralization | 230d? | 2015-11-02 A | 2016-09-15 A | 100% |  |  | finish no earlier than 2016-09-15 | S2 | 1840h | 1840h | FS_SeDoC | PCG-36 | Chris Joul (T-Mobile USA) | chris (dot) joul (at) t (dash) mobile (dot) com | Rel-14 | SP-70 |
| 439 | 175.2 | Service Domain Centralization | 25d? | 2016-08-16 A | 2016-09-19 A | 100% |  |  | finish no earlier than 2016-09-19 | S2 | 200h | 200h | SeDoC | PCG-37 | Chris Joul (T-Mobile USA) | chris (dot) joul (at) t (dash) mobile (dot) com | Rel-14 | TSG-73 |
| 440 | 176 | **Sponsored data connectivity improvements** | 295d? | 2015-11-02 A | 2016-12-15 | 96% | 13d? | 525d |  |  | 2880h | 2672h | SDCI | PCG-37 | Yang Xu | xuyang49@chinaunicom.cn | Rel-14 | TSG#72 |
| 441 | 176.1 | Study on sponsored data connectivity improvements | 160d? | 2015-11-02 A | 2016-06-10 A | 100% |  |  | finish no earlier than 2016-06-10 | S2 | 1280h | 1280h | FS_SDCI | PCG-36 | Yang Xu | xuyang49@chinaunicom.cn | Rel-14 | SP-70 |
| 442 | 176.2 | Sponsored data connectivity improvements | 70d? | 2016-06-13 A | 2016-09-15 A | 100% |  |  | finish no earlier than 2016-09-15 | S2 | 560h | 560h | SDCI | PCG-37 | Yang Xu | xuyang49@chinaunicom.cn | Rel-14 | TSG#72 |
| 443 | 176.3 | **CT Aspects of SDCI** | 65d? | 2016-09-16 A | 2016-12-15 | 80% | 13d? | 525d |  | ct | 1040h | 832h | SDCI-CT | PCG-37 | China Unicom, Xu, Yang | xuyang49@chinaunicom.cn | Rel-14 | TSG-73 |
| 444 | 176.3.1 | CT3 Aspects of SDCI | 65d? | 2016-09-16 A | 2016-12-15 | 80% | 13d? | 525d | finish no earlier than 2016-12-15 | C3 | 520h | 416h | SDCI-CT | PCG-37 | China Unicom, Xu, Yang | xuyang49@chinaunicom.cn | Rel-14 | TSG-73 |
| 445 | 177 | **Stage-3 SAE Protocol Development - Phase 5** | 272d? | 2016-03-02 A | 2017-03-15 A | 100% |  |  |  | C1 | 8704h | 8704h | SAES5 | PCG-36 | Interdigital, Aghili, Behrouz | Behrouz.aghili@interdigital.com | Rel-14 | TSG#71 |
| 446 | 177.1 | SAES5 CS Fallback in EPS | 272d? | 2016-03-02 A | 2017-03-15 A | 100% |  |  | start no earlier than 2016-03-02 | C1 | 2176h | 2176h | SAES5-CSFB | PCG-36 | Interdigital, Aghili, Behrouz | Behrouz.aghili@interdigital.com | Rel-14 | TSG#71 |
| 447 | 177.2 | SAES5 for support for non-3GPP accesses | 272d? | 2016-03-02 A | 2017-03-15 A | 100% |  |  | start no earlier than 2016-03-02 | C1 | 2176h | 2176h | SAES5-non3GPP | PCG-36 | Interdigital, Aghili, Behrouz | Behrouz.aghili@interdigital.com | Rel-14 | TSG#71 |
| 448 | 177.3 | SAE Protocol Development (Stage 3) - Phase 5 | 272d? | 2016-03-02 A | 2017-03-15 A | 100% |  |  | start no earlier than 2016-03-02 | C1 | 2176h | 2176h | SAES5 | PCG-37 |  |  | Rel-14 | CT-72 |
| 449 | 178 | **Group based enhancements in the network capability exposure functions** | 296d? | 2015-11-02 A | 2016-12-16 A | 100% |  |  |  | S2 | 4752h | 4752h | GENCEF | PCG-36 | Samsung, Sung Hwan Won | sunghwan.won@samsung.com | Rel-14 | SP-70 |
| 450 | 178.1 | Study on group based enhancements in the network capability exposure functions | 160d? | 2015-11-02 A | 2016-06-10 A | 100% |  |  | start no earlier than 2015-11-02 | S2 | 1280h | 1280h | FS_GENCEF | PCG-36 | Samsung, Sung Hwan Won | sunghwan.won@samsung.com | Rel-14 | SP-70 |
| 451 | 178.2 | Group based enhancements in the network capability exposure functions | 138d? | 2016-06-09 A | 2016-12-16 A | 100% |  |  | finish no earlier than 2016-12-16 | S2 | 1104h | 1104h | GENCEF | PCG-37 | Samsung, Sunghoon Kim | s.hun.kim@samsung.com | Rel-14 | TSG#72 |

Notes:
- 427: 2/12/16: 40%->100 / Impacted TSs and TRs: 24.229
- 428: 2/12/16: 40%->100 / Impacted TSs and TRs: 29.212, 29.213, 29.214
- 429: 19/9/16: 0%->15; 1/12/16: FCD:12/16->03/17; 1/12/16: 15%->60; 1/12/16: WID:SP-160429->SP-160838; 6/3/17: FCD:03/17->06/17 / Impacted TSs and TRs: 32.240, 32.251, 32.260
- 431: 7/12/15: 0%->40; 7/3/16: 40%->70; 9/6/16: 70%->100 / Impacted TSs and TRs: 23.710
- 432: 11/6/16: 0%->10; 19/9/16: 10%->100 / Impacted TSs and TRs: 23.401, 23.203, 23.060
- 434: 2/12/16: 0%->10; 6/3/17: 10%->100 / Impacted TSs and TRs: 29.212, 29.213
- 435: 2/12/16: 0%->95; 6/3/17: 95%->100 / Impacted TSs and TRs: 29.274
- 436: 1/12/16: 0%->40; 6/3/17: 40%->80; 6/3/17: FCD:03/17->06/17 / Impacted TSs and TRs: TS32.251, TS32.298, TS32.299
- 438: Comes back from previous release; 28/1/16: 23.719 added; 7/3/16: 0%->30; 7/3/16: WID:SP-150626->SP-1601679/6/16: 30%->70; 11/6/16: WID:SP-160167->SP-160306. FCD: 06/16->09/16; 1/12/16: 70%->100 / Impacted TSs and TRs: 23.719
- 439: 19/9/16: 0%->100 / Impacted TSs and TRs: 23.292, 23.167
- 441: 28/1/16: 23.721 added; 7/3/16: 10%->40; 9/6/16: 40%->100 / Impacted TSs and TRs: 23.721
- 442: 19/9/16: 0%->100 / Impacted TSs and TRs: 23.203, 23.682
- 443: 6/10/16: 29.251 added; / Impacted TSs and TRs: 29.251
- 444: 6/10/16: 29.250 added; 2/12/16: 10%->30; 6/3/17: 30%->80 / Impacted TSs and TRs: 29.212, 29.213, 29.214, 29.201, 29.250
- 445: Impacted TSs and TRs: 23.122, 24.008, 24.167, 24.229, 24.301, 24.302, 24.303, 24.304, 24.305, 24.312, 29.018, 29.118
- 446: 11/6/16: 0%->5; 16/9/16: 5%->20; 2/12/16: 20%->70; 6/3/17: 70%->100 / Impacted TSs and TRs: 23.122, 24.008, 24.167, 24.229, 24.301, 24.302, 24.303, 24.304, 24.305, 24.312, 29.018, 29.118
- 447: 11/6/16: 0%->15; 16/9/16: 15%->20; 2/12/16: 20%->85; 6/3/17: 85%->100 / Impacted TSs and TRs: 23.122, 24.008, 24.167, 24.229, 24.301, 24.302, 24.303, 24.304, 24.305, 24.312, 29.018, 29.118
- 448: Added following CT1's chair e-mail 14/06/16; 16/9/16: 0%->20; 2/12/16: 20%->85; 6/3/17: 85%->100
- 450: 28/1/16: 23.773 added; 28/1/16: 23.742 added; 7/3/16: 0%->10; 9/6/16: 10%->100 / Impacted TSs and TRs: 23.xyz; 23.773; 23.742
- 451: 19/9/16: 0%->90; 1/12/16: FCD:09/16->12/16; 1/12/16: 90%->100 / Impacted TSs and TRs: 23.682

| ID | WBS | Task | Duration | Start | Finish | Complete | Remaining | Total slack | Constraint | Resources | Work | Actual work | Acronym | PCG approved | Release | TSG approved | WI rapporteur name | WI rapporteur e-mail | Status Report |
| --- | --- | --- | --- | --- | --- | --- | --- | --- | --- | --- | --- | --- | --- | --- | --- | --- | --- | --- | --- |
| 452 | 179 | **Robust Call Setup for VoLTE subscriber in LTE** | 421d? | 2015-11-02 A | 2017-06-09 | 92% | 32.4d? | 399d |  |  | 6024h | 5640.4h | RobVoLTE | PCG-37 | Rel-14 | SP-72 |  |  |  |
| 453 | 179.1 | Study on Robust Call Setup for VoLTE subscriber in LTE | 160d? | 2015-11-02 A | 2016-06-10 A | 100% |  |  | start no earlier than 2015-11-02 | S2 | 1280h | 1280h | FS_RobVoLTE | PCG-36 | Rel-14 | SP-70 | Xiaobo Wu, Huawei | wuxiaobo@ huawei.com |  |
| 454 | 179.2 | Robust Call Setup for VoLTE subscriber in LTE | 66d? | 2016-06-17 A | 2016-09-15 A | 100% |  |  | finish no earlier than 2016-09-15 | S2 | 528h | 528h | RobVoLTE |  | Rel-14 | SP-72 | Xiaobo Wu, Huawei | wuxiaobo@ huawei.com |  |
| 455 | 179.3 | CT Aspects of RobVoLTE | 130d? | 2016-09-16 A | 2017-03-16 A | 100% |  |  | finish no earlier than 2017-03-16 | C1 | 1040h | 1040h | RobVoLTE-CT | PCG-37 | Rel-14 | TSG-73 | PATEL, Milan | Milan.Patel@huawei.com |  |
| 456 | 179.4 | **Voice and Video Enhancement for LTE** | 130d? | 2016-09-15 A | 2017-03-15 A | 100% |  |  |  | R2 | 2080h | 2080h | LTE_VoLTE_ViLTE_enh | PCG-37 | Rel-14 | TSG-73 | CMCC |  |  |
| 457 | 179.4.1 | Core part: Voice and Video Enhancement for LTE | 130d? | 2016-09-15 A | 2017-03-15 A | 100% |  |  | finish no earlier than 2017-03-15 | R2 | 1040h | 1040h | LTE_VoLTE_ViLTE_enh-Core | PCG-37 | Rel-14 | TSG-73 | CMCC |  | RP-170323 |
| 458 | 179.5 | RAN-Assisted Codec Adaptation in MTSI | 137d? | 2016-12-01 A | 2017-06-09 | 65% | 47.95d? | 399d | finish no earlier than 2017-06-09 | S4 | 1096h | 712.4h | LTE_VoLTE_ViLTE_enh-S4 |  | Rel-14 |  | Ozgur Oyman, Intel | ozgur.oyman@intel.com |  |
| 459 | 180 | Extension of UE Delay test methods and requirements | 261d? | 2016-06-13 A | 2017-06-09 | 60% | 104.4d? | 399d | finish no earlier than 2017-06-09 | S4 | 2088h | 1252.8h | EXT_UED | PCG-37 | Rel-14 | TSG#72 | Stéphane Ragot, ORANGE | stephane.ragot@orange.com |  |
| 460 | 181 | **Improved operator control using new UE configuration parameters** | 199d? | 2016-06-13 A | 2017-03-15 | 93% | 14.92d? | 461d |  |  | 3184h | 2945.2h | IOC_UE_conf | PCG-37 | Rel-14 | TSG#72 | Sedlacek, Ivo | ivo.sedlacek@ericsson.com |  |
| 461 | 181.1 | CT1 aspects of IOC_UE_conf | 199d? | 2016-06-13 A | 2017-03-15 A | 100% |  |  | finish no earlier than 2017-03-15 | C1 | 1592h | 1592h | IOC_UE_conf | PCG-37 | Rel-14 | TSG#72 | Sedlacek, Ivo | ivo.sedlacek@ericsson.com |  |
| 462 | 181.2 | CT6 aspects of IOC_UE_conf | 199d? | 2016-06-13 A | 2017-03-15 | 85% | 29.85d? | 461d | finish no earlier than 2017-03-15 | C6 | 1592h | 1353.2h | IOC_UE_conf | PCG-37 | Rel-14 | TSG#72 | Adrian Buckley | abuckley@blackberry.com |  |
| 463 | 182 | Shared Subscription Data Update | 135d? | 2016-06-13 A | 2016-12-15 A | 100% |  |  | finish no earlier than 2016-12-15 | C4 | 1080h | 1080h | eSDU | PCG-37 | Rel-14 | TSG#72 | Nokia, Ulrich Wiehe | ulrich.wiehe@nokia.com |  |
| 464 | 183 | **Rel-14 Charging** | 335d? | 2016-03-01 A | 2017-06-09 | 69% | 104.56d? | 399d |  | S5 | 8544h | 5389.84h | CH14 | PCG-36 | Rel-14 | TSG#71 |  |  |  |
| 465 | 183.1 | Resource Optimization for PS Domain Online | 335d | 2016-03-01 A | 2017-06-09 | 80% | 67d | 399d | finish no earlier than 2017-06-09 | S5 | 2680h | 2144h | CH14-ROPOCH | PCG-36 | Rel-14 | TSG#71 | Shrader, David(Ericsson) | david.shrader@ericsson.com |  |
| 466 | 183.2 | Charging for SMS via T4 | 137d? | 2016-12-01 A | 2017-06-09 | 20% | 109.6d? | 399d | finish no earlier than 2017-06-09 | S5 | 1096h | 219.2h | CH14-SMST4 |  | Rel-14 |  | Nokia | Maryse <dot> Gardella <at> Nokia <dot> com |  |
| 467 | 183.3 | Charging Aspects of Enhanced Proximity-based Services | 261d? | 2016-06-13 A | 2017-06-09 | 80% | 52.2d? | 399d | finish no earlier than 2017-06-09 | S5 | 2088h | 1670.4h | CH14-ProSe | PCG-37 | Rel-14 | TSG#72 | Chen, Shan | chenshan@huawei.com |  |
| 468 | 184 | **Determination of Completeness of Charging Information in IMS** | 261d? | 2016-06-13 A | 2017-06-09 | 13% | 227.83d? | 399d |  | S5 | 5952h | 729.71h | CH14-DCCII | PCG-37 | Rel-14 | TSG#72 | Jesske, Roland (Deutsche Telekom) |  |  |
| 469 | 184.1 | Determination of Completeness of Charging Information in IMS | 261d? | 2016-06-13 A | 2017-06-09 | 10% | 234.9d? | 399d | finish no earlier than 2017-06-09 | S5 | 2088h | 208.8h | CH14-DCCII | PCG-37 | Rel-14 | TSG#72 | Jesske, Roland (Deutsche Telekom) |  |  |
| 470 | 184.2 | **CT Aspects of Determination of Completeness of Charging Information in IMS** | 74d? | 2016-12-01 A | 2017-03-14 | 17% | 61.05d? | 462d |  | ct | 1776h | 310.8h | CH14-DCCII-CT |  | Rel-14 |  | Michael KREIPL, Deutsche Telekom | michael(dot)kreipl(at)telekom(dot)de |  |
| 471 | 184.2.1 | CT1 Aspects of Determination of Completeness of Charging Information in IMS | 74d? | 2016-12-01 A | 2017-03-14 | 35% | 48.1d? | 462d | finish no earlier than 2017-03-14 | C1 | 592h | 207.2h | CH14-DCCII-CT |  | Rel-14 |  | Michael KREIPL, Deutsche Telekom | michael(dot)kreipl(at)telekom(dot)de |  |
| 472 | 184.2.2 | CT3 Aspects of Determination of Completeness of Charging Information in IMS | 74d? | 2016-12-01 | 2017-03-14 |  |  | 462d | finish no earlier than 2017-03-14 | C3 | 592h |  | CH14-DCCII-CT |  | Rel-14 |  | Michael KREIPL, Deutsche Telekom | michael(dot)kreipl(at)telekom(dot)de |  |
| 473 | 185 | **Enhanced LAA for LTE** | 460d? | 2015-12-15 A | 2017-09-15 | 48% | 239.77d? | 329d |  |  | 7872h | 3768.96h | LTE_eLAA | PCG-36 | Rel-14 | RP-70 | Ericsson |  |  |
| 474 | 185.1 | Core part: Enhanced LAA for LTE | 328d? | 2015-12-15 A | 2017-03-15 A | 100% |  |  | finish no earlier than 2017-03-15 | R1 | 2624h | 2624h | LTE_eLAA-Core | PCG-36 | Rel-14 | RP-70 | Ericsson |  | RP-170269 |
| 475 | 185.2 | Perf. part: Enhanced LAA for LTE | 394d? | 2015-12-15 A | 2017-06-15 | 33% | 263.98d? | 395d | finish no earlier than 2017-06-15 | R4 | 3152h | 1040.16h | LTE_eLAA-Perf | PCG-36 | Rel-14 | RP-70 | Ericsson |  |  |
| 476 | 185.3 | UE Conformance Test Aspects - Enhanced LAA for LTE | 262d? | 2016-09-15 A | 2017-09-15 | 5% | 248.9d? | 329d | finish no earlier than 2017-09-15 | R5 | 2096h | 104.8h | LTE_eLAA-UEConTest | PCG-37 | Rel-14 | TSG-73 | Intel |  |  |

Notes:
- 453: 28/1/16: 23.750 added; 7/3/16: 0%->20; 9/6/16: 20%->100 / Impacted TSs and TRs: 23.8xx; 23.750
- 454: 19/9/16: 0%->100. 1/12/16: UID changed: 720085 -> 720301 (720085 was also used for RP-161181) / Impacted TSs and TRs: 23.228, 23.237
- 455: 2/12/16: 0%->80; 6/3/17: 80%->100 / Impacted TSs and TRs: 24.229, 24.292
- 457: ; 20/12/16: Compl:0%->80%; 21/3/17: Compl:80%->100%; 21/3/17: Stat Rep: ->RP-170323
- 458: 6/3/17: 0%->65; 6/3/17: FCD:03/17->06/17
- 459: 19/9/16: WID:SP-160271->SP-160600; 19/9/16: 0%->20; 1/12/16: 20%->30; 14/12/16: 30%->50; 6/3/17: 50%->60; 6/3/17: FCD:03/17->06/17 / Impacted TSs and TRs: TR 26.954, 26.131, 26.132
- 460: 11/6/16: 0%->10; 17/10/16: WID:CP-160296->CP-160374; 5/12/16: WID:CP-160374->CP-160828 / Impacted TSs and TRs: 24.167, 24.229, 24.301, 24.302, 24.312, 24.341, 24.368, 24.607, 24.623, TS 24.XXX, TS 24.YYY
- 461: 11/6/16: 0%->10; 16/9/16: 10%->20; 17/10/16: WID:CP-160296->CP-160374; 2/12/16: 20%->75; 6/3/17: 75%->100 / Impacted TSs and TRs: 24.167, 24.229, 24.301, 24.302, 24.312, 24.341, 24.368, 24.607, 24.623, 24.275
- 462: 11/6/16: 0%->10; 14/12/16: 0%->15; 7/3/17: 15%->85 / Impacted TSs and TRs: 31.102, 31.103
- 463: 13/6/16: 0%->25; 2/12/16: 25%->100; 5/12/16: WID:CP-160243->CP-160644 / Impacted TSs and TRs: 29.272, 29.002, 29.305, 29.230
- 464: Umbrella Feature
- 465: 13/6/16: 0%->10. FCD:09/16->03/17; 19/9/16: FCD: 09/16->03/17; 19/9/16: 10%->20; 1/12/16: 20%->50; 6/3/17: 50%->80; 6/3/17: FCD:03/17->06/20 / Impacted TSs and TRs: 32.251, 32.299
- 466: 6/3/17: 0%->20; 6/3/17: FCD:03/17->06/17 / Impacted TSs and TRs: TS 32.274, TS 32.250 , TS 32.298, TS 32.299
- 467: 19/9/16: 0%->40; 1/12/16: 40%->60; 6/3/17: FCD:03/17->06/17; 6/3/17: 60%->80 / Impacted TSs and TRs: 32.240, 32.251, 32.277, 32.298, 32.299
- 468: 19/9/16: 0%->10 / Impacted TSs and TRs: 32.240, 32.260, 32.298, 32.299
- 469: 19/9/16: 0%->10; 6/3/17: FCD:03/17->06/17 / Impacted TSs and TRs: 32.240, 32.260, 32.298, 32.299
- 471: 2/12/16: 0%->10; 6/3/17: 10%->35 / Impacted TSs and TRs: 24.229
- 472: Impacted TSs and TRs: 29.165
- 474: 22/3/16: Compl:0%->20%22/3/16: WID: RP-152272->RP-1604071/7/16: Compl:20%->60%1/7/16: WID: RP-160407->RP-160881; 26/9/16: Compl:60%->92%; 26/9/16: CD:Thu 15/09/16->Thu 15/12/16; 26/9/16: WID: ; 20/12/16: Compl:92%->97%; 20/12/16:; ; 21/3/17: Compl:...
- 475: 22/3/16: WID: RP-152272->RP-160407; 1/7/16: WID: RP-160407->RP-16088126/9/16: CD:Wed 15/03/17->Thu 15/06/1726/9/16: WID: RP-160881->RP-161832; 20/12/16: WID: RP-161832->RP-162235;21/3/17: Compl:0%->33%
- 476: ; 21/3/17: Compl:0%->5% ;...

| ID | WBS | Task | Duration | Start | Finish | Complete | Remaining | Total slack | Constraint | Resources | Work | Actual work | Acronym | PCG approved | WI rapporteur name | Release | TSG approved | Status Report | Impacted TSs and TRs | WI rapporteur e-mail |
| --- | --- | --- | --- | --- | --- | --- | --- | --- | --- | --- | --- | --- | --- | --- | --- | --- | --- | --- | --- | --- |
| 477 | 186 | **RRC optimization for UMTS** | 199d? | 2015-12-15 A | 2016-09-15 A | 100% |  |  |  | R2 | 3184h | 3184h | UTRA_RRCopt | PCG-36 | Ericsson | Rel-14 | RP-70 |  |  |  |
| 478 | 186.1 | Core part: RRC optimization for UMTS | 199d? | 2015-12-15 A | 2016-09-15 A | 100% |  |  | finish no earlier than 2016-09-15 | R2 | 1592h | 1592h | UTRA_RRCopt-Core | PCG-36 | Ericsson | Rel-14 | RP-70 |  |  |  |
| 479 | 187 | **DTX/DRX enhancements in CELL_FACH** | 264d? | 2015-12-15 A | 2016-12-15 A | 100% |  |  |  | R2 | 4224h | 4224h | FACH_DTXDRX | PCG-36 | Huawei | Rel-14 | RP-70 |  |  |  |
| 480 | 187.1 | Core part: DTX/DRX enhancements in CELL_FACH | 264d? | 2015-12-15 A | 2016-12-15 A | 100% |  |  | finish no earlier than 2016-12-15 | R2 | 2112h | 2112h | FACH_DTXDRX-Core | PCG-36 | Huawei | Rel-14 | RP-70 | RP-162132 |  |  |
| 481 | 188 | **AWS-3/4 Band for LTE** | 264d? | 2015-12-15 A | 2016-12-15 A | 100% |  |  |  |  | 2640h | 2640h | LTE_AWS_3_4 | PCG-36 | Dish Network | Rel-14 | RP-70 |  |  |  |
| 482 | 188.1 | Core part: AWS-3/4 Band for LTE | 132d? | 2015-12-15 A | 2016-06-15 A | 100% |  |  | finish no earlier than 2016-09-15 | R4 | 1056h | 1056h | LTE_AWS_3_4-Core | PCG-36 | Dish Network | Rel-14 | RP-70 |  | 36.749 |  |
| 483 | 188.2 | Perf. part: AWS-3/4 Band for LTE | 132d? | 2015-12-15 A | 2016-06-15 A | 100% |  |  | finish no earlier than 2016-09-15 | R4 | 1056h | 1056h | LTE_AWS_3_4-Perf | PCG-36 | Dish Network | Rel-14 | RP-70 |  |  |  |
| 484 | 188.3 | UE Conformance Test Aspects – AWS-3/4 Band for LTE (Band 70) | 66d? | 2016-09-15 A | 2016-12-15 A | 100% |  |  | finish no earlier than 2017-03-15 | R5 | 528h | 528h | LTE_AWS_3_4-UEConTest | PCG-37 | Dish Network | Rel-14 | TSG-73 |  |  |  |
| 485 | 189 | **LTE FDD in the Bands 1980-2010 MHz and 2170-2200MHz for Region 3** | 1d? | 2015-12-15 | 2015-12-15 |  |  | 788d |  | R4 | 16h |  | LTE_1980_2170_REG3 | PCG-36 | KT Corp. | Rel-14 | RP-70 |  |  |  |
| 486 | 189.1 | Core part: LTE FDD in the Bands 1980-2010 MHz and 2170-2200MHz for Region 3 | 1d? | 2015-12-15 | 2015-12-15 |  |  | 788d | finish no earlier than 2015-12-15 | R4 | 8h |  | LTE_1980_2170_REG3-Core | PCG-36 | KT Corp. | Rel-14 | RP-70 |  |  |  |
| 487 | 190 | **Addition of 1.4 and 3 MHz Channel Bandwidth to E-UTRA operating band 65 for CGC (Complementary Ground Component) operations in Region 1** | 65d? | 2016-12-15 A | 2017-03-15 A | 100% |  |  |  | R4 | 1040h | 1040h | LTE_1980_2170_REG1_addBWs |  | Hughes Network Systems | Rel-14 |  |  |  |  |
| 488 | 190.1 | Core part: Addition of 1.4 and 3 MHz Channel Bandwidth to E-UTRA operating band 65 for CGC (Complementary Ground Component) operations in Region 1 | 65d? | 2016-12-15 A | 2017-03-15 A | 100% |  |  | finish no earlier than 2017-03-15 | R4 | 520h | 520h | LTE_1980_2170_REG1_addBWs-Core |  | Hughes Network Systems | Rel-14 |  |  |  |  |
| 489 | 191 | **LTE 2.6 GHz FDD Supplemental DL band (2570-2620 MHz) and LTE Carrier Aggregation (2DL/1UL) with Band 3 for region 1** | 132d? | 2015-12-15 A | 2016-06-15 A | 100% |  |  |  | R4 | 3168h | 3168h | LTE_FDD_2600_CA_B3 | PCG-36 | Orange | Rel-14 | RP-70 |  |  |  |
| 490 | 191.1 | Core part: LTE 2.6 GHz FDD Supplemental DL band (2570-2620 MHz) and LTE Carrier Aggregation (2DL/1UL) with Band 3 for region 1 | 132d? | 2015-12-15 A | 2016-06-15 A | 100% |  |  | finish no earlier than 2016-09-15 | R4 | 1056h | 1056h | LTE_FDD_2600_CA_B3-Core | PCG-36 | Orange | Rel-14 | RP-70 |  | 36.858 |  |
| 491 | 191.2 | Perf. part: LTE 2.6 GHz FDD Supplemental DL band (2570-2620 MHz) and LTE Carrier Aggregation (2DL/1UL) with Band 3 for region 1 | 132d? | 2015-12-15 A | 2016-06-15 A | 100% |  |  | finish no earlier than 2016-09-15 | R4 | 1056h | 1056h | LTE_FDD_2600_CA_B3-Perf | PCG-36 | Orange | Rel-14 | RP-70 |  |  |  |
| 492 | 192 | **Multi-Band Base Station testing with three or more bands** | 264d? | 2015-12-15 A | 2016-12-15 | 99% | 0d? | 0d |  | R4 | 6336h | 5219.02h | MB_BS_test_3B | PCG-36 | Alcatel-Lucent | Rel-14 | RP-70 |  |  |  |
| 493 | 192.1 | Core part: Multi-Band Base Station testing with three or more bands | 264d? | 2015-12-15 A | 2016-12-15 A | 100% |  |  | finish no earlier than 2016-12-15 | R4 | 2112h | 2112h | MB_BS_test_3B-Core | PCG-36 | Alcatel-Lucent | Rel-14 | RP-70 | RP-162032 | 37.871 |  |
| 494 | 192.2 | Perf. part: Multi-Band Base Station testing with three or more bands | 264d? | 2015-12-15 A | 2016-12-15 A | 100% |  |  | finish no earlier than 2016-12-15 | R4 | 2112h | 2112h | MB_BS_test_3B-Perf | PCG-36 | Alcatel-Lucent | Rel-14 | RP-70 |  |  |  |
| 495 | 193 | **Performance enhancements for high speed scenario in LTE** | 655d? | 2015-12-15 A | 2018-06-15 | 55% | 296.41d? | 134d |  | R4 | 13128h | 6904.23h | LTE_high_speed | PCG-36 | NTT DOCOMO | Rel-14 | RP-70 |  |  |  |
| 496 | 193.1 | Core part: Performance enhancements for high speed scenario in LTE | 264d? | 2015-12-15 A | 2016-12-15 A | 100% |  |  | finish no earlier than 2016-12-15 | R4 | 2112h | 2112h | LTE_high_speed-Core | PCG-36 | NTT DOCOMO | Rel-14 | RP-70 | RP-162222 |  |  |
| 497 | 193.2 | Perf. part: Performance enhancements for high speed scenario in LTE | 394d? | 2015-12-15 A | 2017-06-15 | 70% | 118.2d? | 395d | finish no earlier than 2017-06-15 | R4 | 3152h | 2206.4h | LTE_high_speed-Perf | PCG-36 | NTT DOCOMO | Rel-14 | RP-70 |  |  |  |
| 498 | 193.3 | UE Conformance Test Aspects - Performance enhancements for high speed scenario in LTE | 328d? | 2017-03-15 | 2018-06-15 |  |  | 134d | finish no earlier than 2018-06-15 | R5 | 2624h |  | LTE_high_speed-UEConTest |  | CMCC | Rel-14 |  |  |  |  |
| 499 | 194 | Remote UE access via relay UE | 77d? | 2016-03-01 A | 2016-06-15 A | 100% |  |  | finish no earlier than 2016-06-15 | S1 | 616h | 616h | REAR | PCG-36 | Huawei, Laurence Meriau | Rel-14 | TSG#71 |  | 22.278, 22.115 | laurence.meriau@huawei.com |
| 500 | 195 | **Further Indoor Positioning Enhancements for UTRA and LTE** | 460d? | 2016-03-15 A | 2017-12-15 | 50% | 229.68d? | 264d |  | R2 | 9488h | 3451.77h | UTRA_LTE_iPos_enh2 | PCG-36 | Huawei | Rel-14 | TSG#71 |  |  |  |
| 501 | 195.1 | Core part: Further Indoor Positioning Enhancements for UTRA and LTE | 199d? | 2016-03-15 A | 2016-12-15 A | 100% |  |  | finish no earlier than 2016-12-15 | R2 | 1592h | 1592h | UTRA_LTE_iPos_enh2-Core | PCG-36 | Huawei | Rel-14 | TSG#71 | RP-162506 |  |  |
| 502 | 195.2 | Perf. part: Further Indoor Positioning Enhancements for UTRA and LTE | 329d? | 2016-03-15 A | 2017-06-15 | 50% | 164.5d? | 395d | finish no earlier than 2017-06-15 | R4 | 2632h | 1316h | UTRA_LTE_iPos_enh2-Perf | PCG-36 | Huawei | Rel-14 | TSG#71 |  |  |  |
| 503 | 195.3 | UE Conformance Test Aspects - RAT Independent Further Indoor Positioning Enhancements for LTE | 198d? | 2017-03-15 | 2017-12-15 |  |  | 264d | finish no earlier than 2017-12-15 | R5 | 1584h |  | LTE_iPos_enh2_RI-UEConTest |  | NextNav | Rel-14 |  |  |  |  |

Notes:
- 478: 22/3/16: Compl:0%->8%; 1/7/16: Compl:8%->70%26/9/16: Compl:70%->100%
- 480: 22/3/16: Compl:0%->20%; 1/7/16: Compl:20%->50%26/9/16: Compl:50%->65%; 20/12/16: Compl:65%->100%;
- 482: ; 22/3/16: Compl:0%->60%; 1/7/16: Compl:60%->100%; 1/7/16: CD:Th
- 483: 1/7/16: Compl:0%->100%1/7/16: CD:Thu 15/09/16->Wed 15/06
- 484: ; 20/12/16: Compl:0%->100%;
- 488: ; 21/3/17: Compl:0%->100% ; 2...
- 490: 28/1/16: 36.858 added;22/3/16: Compl:0%->40%22/3/16: WID: RP-152253->RP-160378; 1/7/16: Compl:40%->100%;
- 491: ; 22/3/16: WID: RP-152253->RP-1603781/7/16: Compl:0%->100%1/7/16
- 493: 22/3/16: Compl:0%->50%22/3/16: WID: RP-152205->RP-1600631/7/16: Compl:50%->90%; 26/9/16: Compl:90%->95%; 26/9/16; 20/12/16: Compl:95%->100%;
- 494: 22/3/16: Compl:0%->5%22/3/16: WID: RP-152205->RP-160063; 1/7/16: Compl:5%->30%26/9/16: Compl:30%->60%26/; 20/12/16: Compl:60%->100%;
- 496: 22/3/16: Compl:0%->5%22/3/16: WID: RP-152263->RP-160172; 1/7/16: Compl:5%->25%26/9/16: Compl:25%->45%20/12/16: Compl:45%->100%20/12/16: Stat Rep: ->RP-162222
- 497: 22/3/16: WID: RP-152263->RP-1601721/7/16: Compl:0%->20%; 26/9/16: Compl:20%->25%; 20/12/16: Compl:25%->35% ; 21/3/17: Compl:35%->70%
- 498: tested: REL-14 LTE_high_speed-Core;
- 499: Previously known as "wearable devices"; 9/6/16: 0%->100; 9/6/16: WID:SP-160231->SP-160371
- 500: follow-up WI of REL-13 WI UTRA_LTE_iPos_enh
- 501: follow-up WI of REL-13 WI UTRA_LTE_iPos_enh1/7/16: Compl:0%->30%; 26/9/16: Compl:30%->60%; 26/9/16: WID:; 20/12/16: Compl:60%->100%;
- 502: 26/9/16: CD:Wed 15/03/17->Thu 15/06/1726/9/16: WID: RP-160538->RP-161850; 20/12/16: Compl:0%->30%; 20/12/16: WI21/3/17: Compl:30%->50%
- 503: tested: REL-14 UTRA_LTE_iPos_enh2-Core (but only RAT independent aspects for LTE);

| ID | WBS | Task | Duration | Start | Finish | Complete | Remaining | Total slack | Constraint | Resources | Work | Actual work | Acronym | PCG approved | WI rapporteur name | Release | TSG approved | Status Report | WI rapporteur e-mail | Impacted TSs and TRs |
| --- | --- | --- | --- | --- | --- | --- | --- | --- | --- | --- | --- | --- | --- | --- | --- | --- | --- | --- | --- | --- |
| 504 | 196 | **Radiated performance requirements for the verification of multi-antenna reception of UEs in LTE** | 329d? | 2016-03-15 A | 2017-06-15 | 28% | 236.4d? | 395d |  | R4 | 6832h | 1497.68h | LTE_MIMO_OTA | PCG-36 | Intel | Rel-14 | TSG#71 |  |  |  |
| 505 | 196.1 | Core part: Radiated performance requirements for the verification of multi-antenna reception of UEs in LTE | 329d? | 2016-03-15 A | 2017-06-15 | 33% | 220.43d? | 395d | finish no earlier than 2017-06-15 | R4 | 2632h | 868.56h | LTE_MIMO_OTA-Core | PCG-36 | Intel | Rel-14 | TSG#71 |  |  |  |
| 506 | 196.2 | UE Conformance Test Aspects - Radiated Performance of Multiple-antenna Receivers in the LTE UE | 196d? | 2016-09-15 A | 2017-06-15 | 20% | 156.8d? | 395d | finish no earlier than 2017-06-15 | R5 | 1568h | 313.6h | LTE_MIMO_OTA-UEConTest | PCG-37 | Intel | Rel-14 | TSG-73 |  |  |  |
| 507 | 197 | **Enhancements on Full-Dimension (FD) MIMO for LTE** | 395d? | 2016-03-15 A | 2017-09-15 | 40% | 237.12d? | 329d |  | R1 | 8424h | 3367.04h | LTE_eFDMIMO | PCG-36 | Samsung | Rel-14 | TSG#71 |  |  |  |
| 508 | 197.1 | Core part: Enhancements on Full-Dimension (FD) MIMO for LTE | 263d? | 2016-03-15 A | 2017-03-15 A | 100% |  |  | finish no earlier than 2017-03-15 | R1 | 2104h | 2104h | LTE_eFDMIMO-Core | PCG-36 | Samsung | Rel-14 | TSG#71 | RP-170173 |  |  |
| 509 | 197.2 | Perf. part: Enhancements on Full-Dimension (FD) MIMO for LTE | 395d? | 2016-03-15 | 2017-09-15 |  |  | 329d | finish no earlier than 2017-09-15 | R4 | 3160h |  | LTE_eFDMIMO-Perf | PCG-36 | Samsung | Rel-14 | TSG#71 |  |  |  |
| 510 | 198 | **Further mobility enhancements in LTE** | 263d? | 2016-03-15 A | 2017-03-15 A | 100% |  |  |  | R2 | 4208h | 4208h | LTE_eMob | PCG-36 | ZTE | Rel-14 | TSG#71 |  |  |  |
| 511 | 198.1 | Core part: Further mobility enhancements in LTE | 263d? | 2016-03-15 A | 2017-03-15 A | 100% |  |  | finish no earlier than 2017-03-15 | R2 | 2104h | 2104h | LTE_eMob-Core | PCG-36 | ZTE | Rel-14 | TSG#71 | RP-170369 |  |  |
| 512 | 199 | **Uplink Capacity Enhancements for LTE** | 395d? | 2016-03-15 A | 2017-09-15 | 52% | 189.7d? | 329d |  | R1 | 8424h | 4378.43h | LTE_UL_CAP_enh | PCG-36 | Ericsson | Rel-14 | TSG#71 |  |  |  |
| 513 | 199.1 | Core part: Uplink Capacity Enhancements for LTE | 263d? | 2016-03-15 A | 2017-03-15 A | 100% |  |  | finish no earlier than 2017-03-15 | R1 | 2104h | 2104h | LTE_UL_CAP_enh-Core | PCG-36 | Ericsson | Rel-14 | TSG#71 | RP-170115 |  |  |
| 514 | 199.2 | Perf. part: Uplink Capacity Enhancements for LTE | 395d? | 2016-03-15 A | 2017-09-15 | 20% | 316d? | 329d | finish no earlier than 2017-09-15 | R4 | 3160h | 632h | LTE_UL_CAP_enh-Perf | PCG-36 | Ericsson | Rel-14 | TSG#71 |  |  |  |
| 515 | 200 | **L2 latency reduction techniques for LTE** | 134d? | 2016-03-15 A | 2016-09-15 A | 100% |  |  |  | R2 | 2144h | 2144h | LTE_LATRED_L2 | PCG-36 | Ericsson | Rel-14 | TSG#71 |  |  |  |
| 516 | 200.1 | Core part: L2 latency reduction techniques for LTE | 134d? | 2016-03-15 A | 2016-09-15 A | 100% |  |  | finish no earlier than 2016-09-15 | R2 | 1072h | 1072h | LTE_LATRED_L2-Core | PCG-36 | Ericsson | Rel-14 | TSG#71 |  |  |  |
| 517 | 201 | **eMBMS enhancements for LTE** | 395d? | 2016-03-15 A | 2017-09-15 | 41% | 233.46d? | 329d |  | R1 | 8952h | 2536.44h | MBMS_LTE_enh2 | PCG-36 | Ericsson | Rel-14 | TSG#71 |  |  |  |
| 518 | 201.1 | Core part: eMBMS enhancements for LTE | 329d? | 2016-03-15 A | 2017-06-15 | 90% | 32.9d? | 395d | finish no earlier than 2017-06-15 | R1 | 2632h | 2368.8h | MBMS_LTE_enh2-Core | PCG-36 | Ericsson | Rel-14 | TSG#71 |  |  |  |
| 519 | 201.2 | Perf. part: eMBMS enhancements for LTE | 395d? | 2016-03-15 | 2017-09-15 |  |  | 329d | finish no earlier than 2017-09-15 | R4 | 3160h |  | MBMS_LTE_enh2-Perf | PCG-36 | Ericsson | Rel-14 | TSG#71 |  |  |  |
| 520 | 202 | **SRS (sounding reference signal) switching between LTE component carriers** | 524d? | 2016-03-15 A | 2018-03-15 | 36% | 337.45d? | 200d |  | R1 | 10512h | 3455.7h | LTE_SRS_switch | PCG-36 | Huawei | Rel-14 | TSG#71 |  |  |  |
| 521 | 202.1 | Core part: SRS (sounding reference signal) switching between LTE component carriers | 199d? | 2016-03-15 A | 2016-12-15 A | 100% |  |  | finish no earlier than 2016-12-15 | R1 | 1592h | 1592h | LTE_SRS_switch-Core | PCG-36 | Huawei | Rel-14 | TSG#71 | RP-162137 |  |  |
| 522 | 202.2 | Perf. part: SRS (sounding reference signal) switching between LTE component carriers | 329d? | 2016-03-15 A | 2017-06-15 | 25% | 246.75d? | 395d | finish no earlier than 2017-06-15 | R4 | 2632h | 658h | LTE_SRS_switch-Perf | PCG-36 | Huawei | Rel-14 | TSG#71 |  |  |  |
| 523 | 202.3 | UE Conformance Test Aspects - SRS (sounding reference signal) switching between LTE component carriers | 262d? | 2017-03-15 | 2018-03-15 |  |  | 200d | finish no earlier than 2018-03-15 | R5 | 2096h |  | LTE_SRS_switch-UEConTest |  | Huawei | Rel-14 |  |  |  |  |
| 524 | 203 | **Downlink Multiuser Superposition Transmission for LTE** | 329d? | 2016-03-15 A | 2017-06-15 | 53% | 153.75d? | 395d |  | R1 | 6856h | 2885.19h | LTE_MUST | PCG-36 | MediaTek | Rel-14 | TSG#71 |  |  |  |
| 525 | 203.1 | Core part: Downlink Multiuser Superposition Transmission for LTE | 199d? | 2016-03-15 A | 2016-12-15 A | 100% |  |  | finish no earlier than 2016-12-15 | R1 | 1592h | 1592h | LTE_MUST-Core | PCG-36 | MediaTek | Rel-14 | TSG#71 | RP-162504 |  |  |
| 526 | 203.2 | Perf. part: Downlink Multiuser Superposition Transmission for LTE | 329d? | 2016-03-15 A | 2017-06-15 | 25% | 246.75d? | 395d | finish no earlier than 2017-06-15 | R4 | 2632h | 658h | LTE_MUST-Perf | PCG-36 | MediaTek | Rel-14 | TSG#71 |  |  |  |
| 527 | 204 | **IMS Stage-3 IETF Protocol Alignment** | 198d? | 2016-06-14 A | 2017-03-15 | 67% | 66d? | 461d |  | C1 | 6336h | 3406.8h | IMSProtoc8 | PCG-37 |  | Rel-14 | TSG#72 |  |  |  |
| 528 | 204.1 | CT1 aspects of IMS Stage-3 IETF Protocol Alignment | 198d? | 2016-06-14 A | 2017-03-15 A | 100% |  |  | finish no earlier than 2017-03-15 | C1 | 1584h | 1584h | IMSProtoc8 | PCG-37 | Alcatel-Lucent | Rel-14 | CT-72 |  | Keith Drage |  |
| 529 | 204.2 | (IETF) CT1 aspects of IMS Stage-3 IETF Protocol Alignment | 198d? | 2016-06-14 | 2017-03-15 |  |  | 461d | start no earlier than 2016-06-14 | C1-IETF | 1584h |  | IMSProtoc8 | PCG-37 | Alcatel-Lucent | Rel-14 | CT-72 |  | Keith Drage | draft-ietf-mmusic-dtls-sdp, draft-ietf-mmusic-4572-update |
| 530 | 204.3 | CT3 aspects of IMS Stage-3 IETF Protocol Alignment | 198d? | 2016-06-14 A | 2017-03-15 A | 100% |  |  | start no earlier than 2016-06-14 | C3 | 1584h | 1584h | IMSProtoc8 | PCG-37 | Alcatel-Lucent | Rel-14 | CT-72 |  | Keith Drage |  |

Notes:
- 504: follow-up WI of REL-13 WI UTRA_LTE_MIMO_OTA-Core; no Perf. part
- 505: follow-up WI of REL-13 WI UTRA_LTE_MIMO_OTA-Core; no Perf. part1/7/16: Compl:0%->10%1/7/16: WID: RP-160603->RP-16091426/9/16: Compl:10%->15%; 20/12/16: Compl:15%->25%; 20/12/16: WID: RP-160914->RP-162306;21/3/17: Compl:25%->33%;...
- 506: ; 20/12/16: Compl:0%->5%21/3/17: Compl:5%->20%
- 508: ; 1/7/16: Compl:0%->25%26/9/16: Compl:25%->40%; 20/12/16: Compl:40%->80%; 20/12/16: Stat Rep: -->; 21/3/17: Compl:80%->100%; 21/3/17: Stat Rep: ->RP-170173
- 509: ; 20/12/16: Stat Rep: -->
- 510: no Perf. part
- 511: no Perf. part; 1/7/16: Compl:0%->25%; 1/7/16: WID: RP-160636->RP-160921; 26/9/16: Compl:25%->50%; 20/12/16: Compl:50%->90%; 20/12/16: CD:Thu 15/12/16->Wed 15/03/17; ; 21/3/17: Compl:90%->100%; 21/3/17: St...
- 513: 1/7/16: Compl:0%->25%26/9/16: Compl:25%->40%; 20/12/16: Compl:40%->85%; 20/12/16: WID: RP-160664->RP-162488; 20/12/16: Stat Rep: -->; ; 21/3/17: Compl:85%->100%; ; 21/3/17: Stat Rep: ->RP-170115
- 514: ; 20/12/16: WID: RP-160664->RP-162488; 20/12/16: Stat Rep: -->;21/3/17: Compl:0%->20%
- 515: no Perf. part; follow-up WI of SI FS_LTE_LATRED
- 516: no Perf. part; follow-up WI of SI FS_LTE_LATRED; 1/7/16: Compl:0%->80%; 26/9/16: Compl:80%->100%
- 518: 1/7/16: Compl:0%->10%1/7/16: CD:Tue 15/03/16->Wed 15/03/171/7/16: WID: RP-160675->RP-16129726/9/16: Compl:10%->55%; 20/12/16: Compl:55%->80%; 20/12/16: WID: RP-161297->RP-162231 ; 21/3/17: Compl:80%->90% ;...
- 519: ; 1/7/16: CD:Wed 15/06/16->Fri 15/09/17; 1/7/16: WID: RP-160675->RP-161297; 20/12/16: WID: RP-161297->RP-162231; 20/12/16: Stat Rep: --> ; 21/3/17: WID: RP-162231->RP-170199
- 521: 1/7/16: Compl:0%->35%1/7/16: WID: RP-160676->RP-160935; 26/9/16: Compl:35%->55%; 20/12/16: Compl:55%->100%; 20/12/16: Stat Rep: -->RP-162137
- 522: 1/7/16: WID: RP-160676->RP-160935; 20/12/16: Stat Rep: --> 21/3/17: Compl:0%->25% 21/3/17: CD:Wed 15/03/17->Thu 15/06/17
- 523: tested: REL-14 LTE_SRS_switch-Core;
- 525: ; 1/7/16: Compl:0%->40%; 1/7/16: WID: RP-160680->RP-16101926/9/16: Compl:40%->60%; 20/12/16: Compl:60%->100%; 20/12/16: Stat Rep: -->RP-162504
- 526: 1/7/16: WID: RP-160680->RP-161019; 26/9/16: CD:Fri 15/09/17->Thu 15/06/17; 20/12/16: Stat Rep: --> ; 21/3/17: Compl:0%->25%
- 527: 11/6/16: 0%->15
- 528: Mar.15: 0->10%; June2015: Compl:10%->30; 07/09/15: 30%->70; 7/12/15: 70%->100; 16/9/16: 0%->30; 2/12/16: 30%->75; 6/3/17: 75%->100
- 530: 2/4/15: added, following CT3 chair's info that the WID also has a CT3 part; June2015: Compl:0%->20; 07/09/15: 20%->40; 7/12/15: 40%->100; 20/9/16: 0%->10; 2/12/16: 10%->30; 6/3/17: 30%->100

| ID | WBS | Task | Duration | Start | Finish | Complete | Remaining | Baseline start | Baseline finish | Baseline duration | Total slack | Constraint | Resources | Work | Actual work | Acronym | PCG approved | WI rapporteur name | Release | TSG approved | Impacted TSs and TRs | Status Report | WI rapporteur e-mail | MCC resp | Acronym_3GU_Export |
| --- | --- | --- | --- | --- | --- | --- | --- | --- | --- | --- | --- | --- | --- | --- | --- | --- | --- | --- | --- | --- | --- | --- | --- | --- | --- |
| 531 | 205 | **Multi-Carrier Enhancements for UMTS** | 264d? | 2015-12-15 A | 2016-12-15 A | 100% |  |  |  |  |  |  | R2 | 4232h | 4232h | UTRA_MCe | PCG-37 | Huawei, HiSilicon | Rel-14 | TSG#72 |  |  |  |  |  |
| 532 | 205.1 | Study on Multi-Carrier Enhancements for UMTS | 132d? | 2015-12-15 A | 2016-06-15 A | 100% |  |  |  |  |  | finish no earlier than 2016-06-15 | R1 | 1056h | 1056h | FS_UTRA_MCe | PCG-36 | Huawei | Rel-14 | RP-70 | 25.707 |  |  |  |  |
| 533 | 205.2 | Core part: Multi-Carrier Enhancements for UMTS | 133d? | 2016-06-15 A | 2016-12-15 A | 100% |  |  |  |  |  | finish no earlier than 2016-12-15 | R2 | 1064h | 1064h | UTRA_MCe-Core | PCG-37 | Huawei, HiSilicon | Rel-14 | TSG#72 |  | RP-162129 |  |  |  |
| 534 | 206 | **Citizens Broadband Radio Service (CBRS) 3.5GHz band for LTE in the United States** | 263d? | 2016-06-15 A | 2017-06-15 | 87% | 34.71d? |  |  |  | 395d |  | R4 | 5280h | 3820.8h | LTE_TDD_3550_CBRS_US | PCG-37 | Nokia | Rel-14 | TSG#72 |  |  |  |  |  |
| 535 | 206.1 | Core part: Citizens Broadband Radio Service (CBRS) 3.5GHz band for LTE in the United States | 133d? | 2016-06-15 A | 2016-12-15 A | 100% |  |  |  |  |  | finish no earlier than 2016-12-15 | R4 | 1064h | 1064h | LTE_TDD_3550_CBRS_US-Core | PCG-37 | Nokia | Rel-14 | TSG#72 | 36.744 |  |  |  |  |
| 536 | 206.2 | Perf. part: Citizens Broadband Radio Service (CBRS) 3.5GHz band for LTE in the United States | 133d? | 2016-06-15 A | 2016-12-15 A | 100% |  |  |  |  |  | finish no earlier than 2016-12-15 | R4 | 1064h | 1064h | LTE_TDD_3550_CBRS_US-Perf | PCG-37 | Nokia | Rel-14 | TSG#72 |  |  |  |  |  |
| 537 | 206.3 | UE Conformance Test Aspects – Citizens Broadband Radio Service (CBRS) 3.5GHz Band for LTE in the United States (Band 48) | 131d? | 2016-12-15 A | 2017-06-15 | 60% | 52.4d? |  |  |  | 395d | finish no earlier than 2017-06-15 | R5 | 1048h | 628.8h | LTE_TDD_3550_CBRS_US-UEConTest |  | Nokia | Rel-14 |  |  |  |  |  |  |
| 538 | 207 | **LTE Band 41 UE power class 2 operation** | 197d? | 2016-06-15 A | 2017-03-15 | 99% | 0d? |  |  |  | 0d |  | R4 | 4744h | 4158.02h | LTE_B41_UE_PC2 | PCG-37 | Sprint | Rel-14 | TSG#72 |  |  |  |  |  |
| 539 | 207.1 | Core part: LTE Band 41 UE power class 2 operation | 133d? | 2016-06-15 A | 2016-12-15 A | 100% |  |  |  |  |  | finish no earlier than 2016-12-15 | R4 | 1064h | 1064h | LTE_B41_UE_PC2-Core | PCG-37 | Sprint | Rel-14 | TSG#72 |  |  |  |  |  |
| 540 | 207.2 | Perf. part: LTE Band 41 UE power class 2 operation | 133d? | 2016-06-15 A | 2016-12-15 A | 100% |  |  |  |  |  | finish no earlier than 2016-12-15 | R4 | 1064h | 1064h | LTE_B41_UE_PC2-Perf | PCG-37 | Sprint | Rel-14 | TSG#72 |  |  |  |  |  |
| 541 | 207.3 | UE Conformance Test Aspects – LTE Band 41 UE power class 2 operation | 130d? | 2016-09-15 A | 2017-03-15 A | 100% |  |  |  |  |  | finish no earlier than 2017-03-15 | R5 | 1040h | 1040h | LTE_B41_UE_PC2-UEConTest | PCG-37 | Sprint | Rel-14 | TSG-73 |  |  |  |  |  |
| 542 | 208 | **LTE UE Total Radiated Power (TRP) and Total Radiated Sensitivity (TRS) and UTRA Hand Phantom related UE TRP and TRS Requirements** | 1250d? | 2012-12-15 A | 2017-09-15 | 76% | 301.19d? | 2013-03-15 | 2015-06-12 | 591d? | 329d |  |  | 16248h | 12332.9h | LTE_UTRA_TRP_TRS | PCG-30 | Nokia | Rel-14 | RP-58 | UTRA, LTE |  | petri.j.vasenkari@nokia.com | Issam | LTE_UTRA_TRP_TRS |
| 543 | 208.1 | Core part: LTE UE TRP and TRS and UTRA Hand Phantom related UE TRP and TRS Requirements | 1113d? | 2012-12-15 A | 2017-06-15 | 75% | 278.25d? | 2013-03-15 | 2014-09-12 | 393d? | 395d | finish no earlier than 2017-06-15 | R4 | 8904h | 6678h | LTE_UTRA_TRP_TRS-Core | PCG-30 | Nokia | Rel-14 | RP-58 | 25.144, New TS 37.144 |  | petri.j.vasenkari@nokia.com | Issam | LTE_UTRA_TRP_TRS-Core |
| 544 | 208.2 | Test part: LTE UE TRP and TRS and UTRA Hand Phantom | 918d? | 2014-03-15 A | 2017-09-15 | 77% | 211.14d? | 2014-03-06 | 2015-06-12 | 332d? | 329d | finish no earlier than 2017-09-15 | R5 | 7344h | 5654.88h | LTE_UTRA_TRP_TRS-UEConTest | PCG-32 | ZTE | Rel-14 | RP-63 | New TS 37.544 |  | TAYLOR Carolyn (carolyn.tayl@zte.com.cn) | Ingbert | LTE_UTRA_TRP_TRS-UEConTest |
| 545 | 209 | **Dedicated Core Networks for GERAN** | 68d? | 2016-06-15 A | 2016-09-15 A | 100% |  |  |  |  |  |  | R6 | 1088h | 1088h | DECOR_GERAN | PCG-37 | Ericsson | Rel-14 | TSG#72 |  |  |  |  |  |
| 546 | 209.1 | Core part: Dedicated Core Networks for GERAN | 68d? | 2016-06-15 A | 2016-09-15 A | 100% |  |  |  |  |  | finish no earlier than 2016-12-15 | R6 | 544h | 544h | DECOR_GERAN-Core | PCG-37 | Ericsson | Rel-14 | TSG#72 |  | RP-170194 |  |  |  |
| 547 | 210 | **Positioning Enhancements for GERAN** | 263d? | 2016-06-15 A | 2017-06-15 | 80% | 52.59d? |  |  |  | 395d |  | R6 | 6312h | 4390.79h | ePOS_GERAN | PCG-37 | Ericsson | Rel-14 | TSG#72 |  |  |  |  |  |
| 548 | 210.1 | Core part: Positioning Enhancements for GERAN | 263d? | 2016-06-15 A | 2017-06-15 | 80% | 52.6d? |  |  |  | 395d | finish no earlier than 2017-06-15 | R6 | 2104h | 1683.2h | ePOS_GERAN-Core | PCG-37 | Ericsson | Rel-14 | TSG#72 |  |  |  |  |  |
| 549 | 210.2 | Perf. part: Positioning Enhancements for GERAN | 263d? | 2016-06-15 A | 2017-06-15 | 80% | 52.6d? |  |  |  | 395d | finish no earlier than 2017-06-15 | R6 | 2104h | 1683.2h | ePOS_GERAN-Perf | PCG-37 | Ericsson | Rel-14 | TSG#72 |  |  |  |  |  |
| 550 | 211 | **Quality of Experience (QoE) Measurement Collection for streaming services in UTRAN** | 794d? | 2014-12-03 A | 2017-12-15 | 70% | 237.84d? |  |  |  | 264d |  | R2 | 11640h | 8480h | UMTS_QMC_Streaming | PCG-37 | China Unicom | Rel-14 | TSG-73 |  |  |  |  |  |
| 551 | 211.1 | Study on KQIs for Service Experience | 333d? | 2014-12-03 A | 2016-03-11 A | 100% |  |  |  |  |  | finish no earlier than 2016-03-11 | S5 | 2664h | 2664h | FS_KQISE | PCG-34 | Li, Hui (hui.li(at)huawei.com) | Rel-14 | SP-66 | TR 32.8xy |  | hui.li(at)huawei.com |  |  |
| 552 | 211.2 | Core part: Quality of Experience (QoE) Measurement Collection for streaming services in UTRAN | 130d? | 2016-09-15 A | 2017-03-15 A | 100% |  |  |  |  |  | finish no earlier than 2017-03-15 | R2 | 1040h | 1040h | UMTS_QMC_Streaming-Core | PCG-37 | China Unicom | Rel-14 | TSG-73 |  | RP-170259 |  |  |  |
| 553 | 211.3 | UE Conformance Test Aspects - Quality of Experience (QoE) Measurement Collection for streaming services in UTRAN | 198d? | 2017-03-15 | 2017-12-15 |  |  |  |  |  | 264d | finish no earlier than 2017-12-15 | R5 | 1584h |  | UMTS_QMC_Streaming-UEConTest |  | Huawei | Rel-14 |  |  |  |  |  |  |
| 554 | 212 | **Flexible eNB-ID and Cell-ID in E-UTRAN** | 263d? | 2016-03-15 A | 2017-03-15 A | 100% |  |  |  |  |  |  | R3 | 4216h | 4216h | LTE_FNBID | PCG-37 | China Telecom | Rel-14 | TSG-73 |  |  |  |  |  |
| 555 | 212.1 | Study on flexible eNB-ID and Cell-ID in E-UTRAN | 134d? | 2016-03-15 A | 2016-09-15 A | 100% |  |  |  |  |  | finish no earlier than 2016-09-15 | R3 | 1072h | 1072h | FS_LTE_FNBID | PCG-36 | China Telecom | Rel-14 | TSG#71 | New TR 36.896 |  |  |  |  |
| 556 | 212.2 | Core part: Flexible eNB-ID and Cell-ID in E-UTRAN | 130d? | 2016-09-15 A | 2017-03-15 A | 100% |  |  |  |  |  | finish no earlier than 2017-03-15 | R3 | 1040h | 1040h | LTE_FNBID-Core | PCG-37 | China Telecom | Rel-14 | TSG-73 |  | RP-170478 |  |  |  |

Notes:
- 531: no Perf. part; follow-up WI of REL-14 SI FS_UTRA_MCe
- 532: 22/3/16: Compl:0%->20%; 1/7/16: Compl:20%->100%; 28/7/16: 25.707 added;
- 533: no Perf. part; follow-up WI of REL-14 SI FS_UTRA_MCe; 26/9/16: Compl:0%->35%; 20/12/16: Compl:35%->100%;
- 535: 26/9/16: Compl:0%->70%; 6/10/16: 36.744 added; 20/12/16: Compl:70%->100%;
- 536: ; 20/12/16: Compl:0%->100%;
- 537: 21/3/17: Compl:0%->60% ; ...
- 538: follow-up WI of SI FS_LTE_B41_HPUE
- 539: follow-up WI of SI FS_LTE_B41_HPUE; 26/9/16: Compl:0%->80%; 20/12/16: Compl:80%->100%
- 540: 26/9/16: Compl:0%->80%; 20/12/16: Compl:80%->100%
- 541: ; 20/12/16: Compl:0%->65% 21/3/17: Compl:65%->100%
- 542: Triggered by Rel-11 TR 37.902 Study on Measurements of radio performances for LTE terminals - TRP and TRS test methodology (FS_LTE_OTA) UID_550022
- 543: ; CD:Wed 18/03/15->Sun 15/03/15; Rel-12->Rel-13; Stat Rep: RP-141158->RP-141973 1st Apr 15: Compl:35%->40% 1st Apr 15: Stat Rep: RP-141973->RP-150104 03/07/15: Stat Rep: RP-150104->RP-150615 29/09/15: Compl:40%->50% 29/09/15: Stat Rep: RP-150615->RP-15; ; ; ; ; ; ; ; ; ; ; ; ; ; ; ; ; ; ; ; ; ; ; ; ; ; ; ; ; ; ; ; ; ; ; ; ; ; 21/3/17: Compl:65%->75%; ; ; ; ; ; ; ; ; ; ; ; ; ; ; ; ; ; ; ; ; ; ; ; ; ; ; ; ; ; ; ; ; ; ; ; ; ; 21/3/17: CD:Wed 15/03/17->Thu 15/06/17; ; ; ; ; ; ; ; ; ; ; ; ; ; ; ; ; ; ; ; ; ; ; ; ; ; ; ; ; ; ; ; ; ; ; ; ; ; 21/3/17: WID: RP-162061->RP-170223
- 544: Stat Rep: RP-141132->RP-141848; Rel 12->Rel13 1st Apr 15: Compl:15%->20% 1st Apr 15: CD:Mon 15/06/15->Wed 15/06/16 1st Apr 15: WID: RP-140090->RP-150070 1st Apr 15: Stat Rep: RP-141848->RP-150069 03/07/15: Compl:20%->25% 03/07/15: Stat Rep: RP-150069->; ; ; ; ; ; ; ; ; ; ; ; ; ; ; ; ; ; ; ; ; ; ; ; ; ; ; ; ; ; ; ; ; ; ; ; ; ; ; ; ; ; ; ; ; ; ; ; ; ; ; ; ; ; ; ; ; ; ; ; ; ; ; ; ; ; ; ; ; ; ; ; ; ; ; ; ; ; ; ; ; ; ; ; ; ; ; ; ; ; ; ; ; 21/3/17: CD:Wed 15/03/17->Fri 15/09/17
- 545: no Perf. part; DECOR was a REL-13 SA2 feature
- 546: no Perf. part; DECOR was a REL-13 SA2 feature; 26/9/16: Compl:0%->100%21/3/17: Stat Rep: ->RP-170194
- 548: 26/9/16: Compl:0%->30%; 20/12/16: Compl:30%->50% 21/3/17: Compl:50%->80% ; ...
- 549: ; 20/12/16: Compl:0%->50% ; 21/3/17: Compl:50%->80%;...
- 551: Mar 15: 0->5%; June2015: Compl:0%->40; 07/09/15: 40%->50; 14/09/15: WID:SP-140784->SP-150405; 7/12/15: 50%->75; 7/12/15: WID:SP-150405->SP-150676 ; 7/3/16: 75%->100. 22/3/16: FCD: 09/15->03/16. Rel-13->Rel-14
- 552: ; 20/12/16: Compl:0%->60% ; 21/3/17: Compl:60%->100%...
- 553: tested: REL-14 UMTS_QMC_Streaming-Core;
- 555: 1/7/16: Compl:0%->60%26/9/16: Compl:60%->100%
- 556: ; 20/12/16: Compl:0%->80%; ; 21/3/17: Compl:80%->100%; ; 21/3/17: Stat Rep: ->RP-170478

| ID | WBS | Task | Duration | Start | Finish | Complete | Remaining | Baseline start | Baseline finish | Baseline duration | Total slack | Constraint | Resources | Work | Actual work | Acronym | PCG approved | WI rapporteur name | Release | TSG approved | Status Report | Impacted TSs and TRs | MCC resp | Special Focus Doc | Acronym_3GU_Export |
| --- | --- | --- | --- | --- | --- | --- | --- | --- | --- | --- | --- | --- | --- | --- | --- | --- | --- | --- | --- | --- | --- | --- | --- | --- | --- |
| 557 | 213 | **4 receiver (4Rx) antenna ports with Carrier Aggregation (CA) for LTE downlink (DL)** | 391d? | 2016-09-15 A | 2018-03-15 | 42% | 227.33d? |  |  |  | 200d |  | R4 | 11504h | 4511.74h | LTE_4Rx_AP_DL_CA | PCG-37 | Ericsson | Rel-14 | TSG-73 |  |  |  |  |  |
| 558 | 213.1 | Core part: 4 receiver (RX) antenna ports with Carrier Aggregation (CA) for LTE downlink (DL) | 66d? | 2016-09-15 A | 2016-12-15 A | 100% |  |  |  |  |  | finish no earlier than 2016-12-15 | R4 | 528h | 528h | LTE_4Rx_AP_DL_CA-Core | PCG-37 | Ericsson | Rel-14 | TSG-73 | RP-162059 |  |  |  |  |
| 559 | 213.2 | Perf. part: 4 receiver (RX) antenna ports with Carrier Aggregation (CA) for LTE downlink (DL) | 262d? | 2016-09-15 A | 2017-09-15 | 50% | 131d? |  |  |  | 329d | finish no earlier than 2017-09-15 | R4 | 2096h | 1048h | LTE_4Rx_AP_DL_CA-Perf | PCG-37 | Ericsson | Rel-14 | TSG-73 |  |  |  |  |  |
| 560 | 213.3 | **Introduction of new band support for 4Rx antenna ports for LTE** | 326d? | 2016-12-15 A | 2018-03-15 | 27% | 239.07d? |  |  |  | 200d |  | R4 | 5752h | 1676.87h | LTE_4Rx_AP_DL_bands |  | Huawei | Rel-14 |  |  |  |  |  |  |
| 561 | 213.3.1 | Core part: Introduction of new band support for 4Rx antenna ports for LTE | 131d? | 2016-12-15 A | 2017-06-15 | 80% | 26.2d? |  |  |  | 395d | finish no earlier than 2017-06-15 | R4 | 1048h | 838.4h | LTE_4Rx_AP_DL_bands-Core |  | Huawei | Rel-14 |  |  |  |  |  |  |
| 562 | 213.3.2 | UE Conformance Test Aspects - 4 Rx antenna ports with CA for LTE DL | 262d? | 2017-03-15 | 2018-03-15 |  |  |  |  |  | 200d | finish no earlier than 2018-03-15 | R5 | 2096h |  | LTE_4Rx_AP_DL_CA-UEConTest |  | Ericsson | Rel-14 |  |  |  |  |  |  |
| 563 | 214 | **Requirements for a new UE category with single receiver based on Category 1 for LTE** | 262d? | 2016-09-15 A | 2017-09-15 | 81% | 50.56d? |  |  |  | 329d |  | R4 | 5760h | 3583.02h | LTE_UE_cat_1RX | PCG-37 | Qualcomm | Rel-14 | TSG-73 |  |  |  |  |  |
| 564 | 214.1 | Core part: Requirements for a new UE category with single receiver based on Category 1 for LTE | 196d? | 2016-09-15 A | 2017-06-15 | 95% | 9.8d? |  |  |  | 395d | finish no earlier than 2017-06-15 | R4 | 1568h | 1489.6h | LTE_UE_cat_1RX-Core | PCG-37 | Qualcomm | Rel-14 | TSG-73 |  |  |  |  |  |
| 565 | 214.2 | Perf. part: Requirements for a new UE category with single receiver based on Category 1 for LTE | 262d? | 2016-09-15 A | 2017-09-15 | 70% | 78.6d? |  |  |  | 329d | finish no earlier than 2017-09-15 | R4 | 2096h | 1467.2h | LTE_UE_cat_1RX-Perf | PCG-37 | Qualcomm | Rel-14 | TSG-73 |  |  |  |  |  |
| 566 | 215 | **Enhanced LTE WLAN Radio Level Integration with IPsec Tunnel (eLWIP)** | 130d? | 2016-09-15 A | 2017-03-15 A | 100% |  |  |  |  |  |  | R3 | 2080h | 2080h | LTE_WLAN_eLWIP | PCG-37 | Nokia | Rel-14 | TSG-73 |  |  |  |  |  |
| 567 | 215.1 | Core part: Enhanced LTE WLAN Radio Level Integration with IPsec Tunnel (eLWIP) | 130d? | 2016-09-15 A | 2017-03-15 A | 100% |  |  |  |  |  | finish no earlier than 2017-03-15 | R3 | 1040h | 1040h | LTE_WLAN_eLWIP-Core | PCG-37 | Nokia | Rel-14 | TSG-73 | RP-170706 |  |  |  |  |
| 568 | 216 | **LTE Measurement Gap Enhancement** | 329d? | 2016-03-15 A | 2017-06-15 | 58% | 139.82d? |  |  |  | 395d |  |  | 5264h | 3026.8h | LTE_meas_gap_enh | PCG-36 | Intel | Rel-14 | TSG#71 |  |  |  |  |  |
| 569 | 216.1 | Core part: LTE Measurement Gap Enhancement | 329d? | 2016-03-15 A | 2017-06-15 | 95% | 16.45d? |  |  |  | 395d | finish no earlier than 2017-06-15 | R4 | 2632h | 2500.4h | LTE_meas_gap_enh-Core | PCG-36 | Intel | Rel-14 | TSG#71 |  |  |  |  |  |
| 570 | 216.2 | Perf. part: LTE Measurement Gap Enhancement | 329d? | 2016-03-15 A | 2017-06-15 | 20% | 263.2d? |  |  |  | 395d | finish no earlier than 2017-06-15 | R4 | 2632h | 526.4h | LTE_meas_gap_enh-Perf | PCG-36 | Intel | Rel-14 | TSG#71 |  |  |  |  |  |
| 571 | 217 | **Enhanced CRS and SU-MIMO Interference Mitigation Performance Requirements for LTE** | 262d? | 2016-09-15 A | 2017-09-15 | 50% | 131d? |  |  |  | 329d |  |  | 2096h | 1048h | LTE_eCRSIM_eSUMIMO | PCG-37 | Intel | Rel-14 | TSG-73 |  | 39.747 |  |  |  |
| 572 | 217.1 | Perf. part: Enhanced CRS and SU-MIMO Interference Mitigation Performance Requirements for LTE | 262d? | 2016-09-15 A | 2017-09-15 | 50% | 131d? |  |  |  | 329d | finish no earlier than 2017-09-15 | R4 | 2096h | 1048h | LTE_eCRSIM_eSUMIMO-Perf | PCG-37 | Intel | Rel-14 | TSG-73 |  | 36.176 |  |  |  |
| 573 | 218 | (Small) Technical Enhancements and Improvements for Rel-14 | 29d? | 2015-05-11 A | 2015-06-18 A | 100% |  |  |  |  |  | start no earlier than 2015-05-11 | SP; CP; RP; R4 | 928h | 928h | TEI14 | PCG-35 |  | Rel-14 | SP-68 |  |  |  |  |  |
| 574 | 219 | (Small) Test Technical Enhancements and Improvements for Rel-14 | 593d? | 2016-09-13 A | 2018-12-20 A | 100% |  |  |  |  |  | start no earlier than 2016-09-13 | SP; CP; RP; GP | 18976h | 18976h | TEI14_Test |  |  | Rel-14 |  |  |  |  |  |  |
| 575 | 220 | **Rel-14 LTE Carrier Aggregation** | 131d? | 2015-09-15 A | 2016-03-15 | 90% | 13.09d? | 2014-03-06 | 2015-06-12 | 332d? | 723d |  | R4 | 9968h | 8897.13h | LTE_CA_Rel14 | PCG-30 |  | Rel-14 | RP-58 |  |  | Issam | CA | LTE_CA_Rel-13 |
| 576 | 220.1 | **LTE Advanced 4 Band Carrier Aggregation (4DL/1UL) of Band 4, Band 5, Band 12 and Band 12** | 131d? | 2015-09-15 A | 2016-03-15 | 90% | 13.09d? |  |  |  | 723d |  | R4 | 3144h | 2829.72h | LTE_CA_B4_B5_B12_B12 | PCG-35 | US Cellular | Rel-14 | RP-69 |  |  |  |  |  |
| 577 | 220.1.1 | Core part: LTE Advanced 4 Band Carrier Aggregation (4DL/1UL) of Band 4, Band 5, Band 12 and Band 12 | 131d? | 2015-09-15 A | 2016-03-15 | 90% | 13.1d? |  |  |  | 723d | finish no earlier than 2016-03-15 | R4 | 1048h | 943.2h | LTE_CA_B4_B5_B12_B12-Core | PCG-35 | US Cellular | Rel-14 | RP-69 |  |  |  |  |  |
| 578 | 220.1.2 | Perf. part: LTE Advanced 4 Band Carrier Aggregation (4DL/1UL) of Band 4, Band 5, Band 12 and Band 12 | 131d? | 2015-09-15 A | 2016-03-15 | 90% | 13.1d? |  |  |  | 723d | finish no earlier than 2016-03-15 | R4 | 1048h | 943.2h | LTE_CA_B4_B5_B12_B12-Perf | PCG-35 | US Cellular | Rel-14 | RP-69 |  |  |  |  |  |
| 579 | 220.2 | **LTE Advanced 4 Band Carrier Aggregation (4DL/1UL) of Band 4, Band 4, Band 12 and Band 12** | 131d? | 2015-09-15 A | 2016-03-15 | 90% | 13.09d? |  |  |  | 723d |  | R4 | 3144h | 2829.72h | LTE_CA_B4_B4_B12_B12 | PCG-35 | US Cellular | Rel-14 | RP-69 |  |  |  |  |  |
| 580 | 220.2.1 | Core part: LTE Advanced 4 Band Carrier Aggregation (4DL/1UL) of Band 4, Band 4, Band 12 and Band 12 | 131d? | 2015-09-15 A | 2016-03-15 | 90% | 13.1d? |  |  |  | 723d | finish no earlier than 2016-03-15 | R4 | 1048h | 943.2h | LTE_CA_B4_B4_B12_B12-Core | PCG-35 | US Cellular | Rel-14 | RP-69 |  |  |  |  |  |
| 581 | 220.2.2 | Perf. part: LTE Advanced 4 Band Carrier Aggregation (4DL/1UL) of Band 4, Band 4, Band 12 and Band 12 | 131d? | 2015-09-15 A | 2016-03-15 | 90% | 13.1d? |  |  |  | 723d | finish no earlier than 2016-03-15 | R4 | 1048h | 943.2h | LTE_CA_B4_B4_B12_B12-Perf | PCG-35 | US Cellular | Rel-14 | RP-69 |  |  |  |  |  |

Notes:
- 558: ; 20/12/16: Compl:0%->100%; 20/12/16: Stat Rep: ->RP-162059
- 559: ; 20/12/16: Compl:0%->30%;21/3/17: Compl:30%->50%
- 560: Pending acronym
- 561: ; 21/3/17: Compl:0%->80% ; 21...
- 562: tested: REL-14 LTE_4Rx_AP_DL_CA-Core
- 564: ; 20/12/16: Compl:0%->70%; 20/12/16: CD:Thu 15/12/16->Wed 15/03/17 ; 21/3/17: Compl:70%->95% 21/3/17: CD:Wed 15/03/17->Thu 15/06/1...
- 565: ; 20/12/16: Compl:0%->20%; 20/12/16: CD:Thu 15/06/17->Fri 15/09/17 21/3/17: Compl:20%->70% ; 21/3/17: WID: RP-162570->RP-170791
- 567: ; 20/12/16: Compl:0%->60% 21/3/17: Compl:60%->100% 21/3/17: Stat Rep: ->RP-170706
- 569: ; 1/7/16: Compl:0%->10%; 1/7/16: CD:Thu 15/06/17->Wed 15/03/17; 1/7/16: WID: RP-160678->RP-160912; 26/9/16: Compl:10%->25%26/9/16: R; 20/12/16: Compl:25%->60% 21/3/17: Compl:60%->95%; ; ...
- 570: 1/7/16: WID: RP-160678->RP-1609121/7/16: Release: Rel-15->Rel-14; 20/12/16: Stat Rep: -->; 20/12/16: Release: Rel-15->Rel-14 21/3/17: Compl:0%->20% 21/3/17: Release: Rel...
- 572: 6/10/16: 36.176 added; 20/12/16: Compl:0%->30%21/3/17: Compl:30%->50% ; 21/3/17: Release: Rel-15->Rel-14
- 574: Created upon demand of RAN5
- 575: Acronym changed from "LTE_CA_Rel-13" to "LTE_CA_Rel13"

| ID | WBS | Task | Duration | Start | Finish | Complete | Remaining | Baseline start | Baseline finish | Baseline duration | Total slack | Constraint | Resources | Work | Actual work | Acronym | PCG approved | WI rapporteur name | Release | TSG approved | MCC resp | Special Focus Doc | Acronym_3GU_Export | Impacted TSs and TRs |
| --- | --- | --- | --- | --- | --- | --- | --- | --- | --- | --- | --- | --- | --- | --- | --- | --- | --- | --- | --- | --- | --- | --- | --- | --- |
| 582 | 220.3 | **LTE Advanced 4 Band Carrier Aggregation (4DL/1UL) of Band 2, Band 4, Band 12 and Band 12** | 131d? | 2015-09-15 A | 2016-03-15 | 90% | 13.09d? |  |  |  | 723d |  | R4 | 3144h | 2829.72h | LTE_CA_B2_B4_B12_B12 | PCG-35 | US Cellular | Rel-14 | RP-69 |  |  |  |  |
| 583 | 220.3.1 | Core part: LTE Advanced 4 Band Carrier Aggregation (4DL/1UL) of Band 2, Band 4, Band 12 and Band 12 | 131d? | 2015-09-15 A | 2016-03-15 | 90% | 13.1d? |  |  |  | 723d | finish no earlier than 2016-03-15 | R4 | 1048h | 943.2h | LTE_CA_B2_B4_B12_B12-Core | PCG-35 | US Cellular | Rel-14 | RP-69 |  |  |  |  |
| 584 | 220.3.2 | Perf. part: LTE Advanced 4 Band Carrier Aggregation (4DL/1UL) of Band 2, Band 4, Band 12 and Band 12 | 131d? | 2015-09-15 A | 2016-03-15 | 90% | 13.1d? |  |  |  | 723d | finish no earlier than 2016-03-15 | R4 | 1048h | 943.2h | LTE_CA_B2_B4_B12_B12-Perf | PCG-35 | US Cellular | Rel-14 | RP-69 |  |  |  |  |
| 585 | 221 | **Rel-14 LTE Advanced inter-band Carrier Aggregation** | 589d? | 2015-12-15 A | 2018-03-15 | 79% | 121.38d? | 2014-03-06 | 2015-06-12 | 332d? | 200d |  | R4 | 81928h | 59718.1h | LTE_AIBCA_Rel14 | PCG-30 |  | Rel-14 | RP-58 | Issam | CA | LTE_CA_Rel-13 |  |
| 586 | 221.1 | **LTE Advanced inter-band Carrier Aggregation Rel-14 for 5DL/1UL** | 394d? | 2015-12-15 A | 2017-06-15 | 95% | 19.69d? |  |  |  | 395d |  | R4 | 9456h | 8416.04h | LTE_CA_R14_5DL1UL | PCG-36 | Nokia Networks | Rel-14 | RP-70 |  |  |  |  |
| 587 | 221.1.1 | Core part: LTE Advanced inter-band Carrier Aggregation Rel-14 for 5DL/1UL | 394d? | 2015-12-15 A | 2017-06-15 | 95% | 19.7d? |  |  |  | 395d | finish no earlier than 2017-06-15 | R4 | 3152h | 2994.4h | LTE_CA_R14_5DL1UL-Core | PCG-36 | Nokia Networks | Rel-14 | RP-70 |  |  |  | 36.714-05-01 |
| 588 | 221.1.2 | Perf. part: LTE Advanced inter-band Carrier Aggregation Rel-14 for 5DL/1UL | 394d? | 2015-12-15 A | 2017-06-15 | 95% | 19.7d? |  |  |  | 395d | finish no earlier than 2017-06-15 | R4 | 3152h | 2994.4h | LTE_CA_R14_5DL1UL-Perf | PCG-36 | Nokia Networks | Rel-14 | RP-70 |  |  |  |  |
| 589 | 221.2 | **LTE Advanced inter-band Carrier Aggregation Rel-14 for 2DL/1UL** | 394d? | 2015-12-15 A | 2017-06-15 | 80% | 78.8d? |  |  |  | 395d |  | R4 | 9456h | 7076.85h | LTE_CA_R14_2DL1UL | PCG-36 | Qualcomm | Rel-14 | RP-70 |  |  |  |  |
| 590 | 221.2.1 | Core part: LTE Advanced inter-band Carrier Aggregation Rel-14 for 2DL/1UL | 394d? | 2015-12-15 A | 2017-06-15 | 80% | 78.8d? |  |  |  | 395d | finish no earlier than 2017-06-15 | R4 | 3152h | 2521.6h | LTE_CA_R14_2DL1UL-Core | PCG-36 | Qualcomm | Rel-14 | RP-70 |  |  |  | 36.714-02-01 |
| 591 | 221.2.2 | Perf. part: LTE Advanced inter-band Carrier Aggregation Rel-14 for 2DL/1UL | 394d? | 2015-12-15 A | 2017-06-15 | 80% | 78.8d? |  |  |  | 395d | finish no earlier than 2017-06-15 | R4 | 3152h | 2521.6h | LTE_CA_R14_2DL1UL-Perf | PCG-36 | Qualcomm | Rel-14 | RP-70 |  |  |  |  |
| 592 | 221.3 | **LTE Advanced inter-band Carrier Aggregation Rel-14 for 2DL/2UL** | 394d? | 2015-12-15 A | 2017-06-15 | 90% | 39.4d? |  |  |  | 395d |  | R4 | 9456h | 7904.07h | LTE_CA_R14_2DL2UL | PCG-36 | Huawei | Rel-14 | RP-70 |  |  |  |  |
| 593 | 221.3.1 | Core part: LTE Advanced inter-band Carrier Aggregation Rel-14 for 2DL/2UL | 394d? | 2015-12-15 A | 2017-06-15 | 90% | 39.4d? |  |  |  | 395d | finish no earlier than 2017-06-15 | R4 | 3152h | 2836.8h | LTE_CA_R14_2DL2UL-Core | PCG-36 | Huawei | Rel-14 | RP-70 |  |  |  | 36.714-02-02 |
| 594 | 221.3.2 | Perf. part: LTE Advanced inter-band Carrier Aggregation Rel-14 for 2DL/2UL | 394d? | 2015-12-15 A | 2017-06-15 | 90% | 39.4d? |  |  |  | 395d | finish no earlier than 2017-06-15 | R4 | 3152h | 2836.8h | LTE_CA_R14_2DL2UL-Perf | PCG-36 | Huawei | Rel-14 | RP-70 |  |  |  |  |
| 595 | 221.4 | **LTE Advanced inter-band Carrier Aggregation Rel-14 for 3DL/3UL** | 328d? | 2015-12-15 A | 2017-03-15 A | 100% |  |  |  |  |  |  | R4 | 7872h | 7872h | LTE_CA_R14_3DL3UL | PCG-36 | Nokia Networks | Rel-14 | RP-70 |  |  |  |  |
| 596 | 221.4.1 | Core part: LTE Advanced inter-band Carrier Aggregation Rel-14 for 3DL/3UL | 328d? | 2015-12-15 A | 2017-03-15 A | 100% |  |  |  |  |  | finish no earlier than 2017-03-15 | R4 | 2624h | 2624h | LTE_CA_R14_3DL3UL-Core | PCG-36 | Nokia Networks | Rel-14 | RP-70 |  |  |  | 36.714-03-03 |
| 597 | 221.4.2 | Perf. part: LTE Advanced inter-band Carrier Aggregation Rel-14 for 3DL/3UL | 328d? | 2015-12-15 A | 2017-03-15 A | 100% |  |  |  |  |  | finish no earlier than 2017-03-15 | R4 | 2624h | 2624h | LTE_CA_R14_3DL3UL-Perf | PCG-36 | Nokia Networks | Rel-14 | RP-70 |  |  |  |  |
| 598 | 221.5 | **LTE Advanced inter-band Carrier Aggregation Rel-14 for xDL/2UL with x=3,4,5** | 394d? | 2015-12-15 A | 2017-06-15 | 48% | 206.85d? |  |  |  | 395d |  | R4 | 9456h | 4240.77h | LTE_CA_R14_xDL2UL | PCG-36 | LG Electronics | Rel-14 | RP-70 |  |  |  |  |
| 599 | 221.5.1 | Core part: LTE Advanced inter-band Carrier Aggregation Rel-14 for xDL/2UL with x=3,4,5 | 394d? | 2015-12-15 A | 2017-06-15 | 95% | 19.7d? |  |  |  | 395d | finish no earlier than 2017-06-15 | R4 | 3152h | 2994.4h | LTE_CA_R14_xDL2UL-Core | PCG-36 | LG Electronics | Rel-14 | RP-70 |  |  |  | 36.714-00-02 |
| 600 | 221.5.2 | Perf. part: LTE Advanced inter-band Carrier Aggregation Rel-14 for xDL/2UL with x=3,4,5 | 394d? | 2015-12-15 | 2017-06-15 |  |  |  |  |  | 395d | finish no earlier than 2017-06-15 | R4 | 3152h |  | LTE_CA_R14_xDL2UL-Perf | PCG-36 | LG Electronics | Rel-14 | RP-70 |  |  |  |  |
| 601 | 221.6 | **LTE Advanced inter-band Carrier Aggregation Rel-14 for 4DL/1UL** | 394d? | 2015-12-15 A | 2017-06-15 | 95% | 19.69d? |  |  |  | 395d |  | R4 | 9456h | 8481.62h | LTE_CA_R14_4DL1UL | PCG-36 | Ericsson | Rel-14 | RP-70 |  |  |  |  |
| 602 | 221.6.1 | Core part: LTE Advanced inter-band Carrier Aggregation Rel-14 for 4DL/1UL | 394d? | 2015-12-15 A | 2017-06-15 | 95% | 19.7d? |  |  |  | 395d | finish no earlier than 2017-06-15 | R4 | 3152h | 2994.4h | LTE_CA_R14_4DL1UL-Core | PCG-36 | Ericsson | Rel-14 | RP-70 |  |  |  | 36.714-04-01 |
| 603 | 221.6.2 | Perf. part: LTE Advanced inter-band Carrier Aggregation Rel-14 for 4DL/1UL | 394d? | 2015-12-15 A | 2017-06-15 | 95% | 19.7d? |  |  |  | 395d | finish no earlier than 2017-06-15 | R4 | 3152h | 2994.4h | LTE_CA_R14_4DL1UL-Perf | PCG-36 | Ericsson | Rel-14 | RP-70 |  |  |  |  |
| 604 | 221.7 | **LTE Advanced intra-band Carrier Aggregation for xDL/yUL including contiguous and non-contiguous spectrum** | 394d? | 2015-12-15 A | 2017-06-15 | 82% | 70.92d? |  |  |  | 395d |  | R4 | 9456h | 7084.9h | LTE_CA_R14_intra | PCG-36 | Ericsson | Rel-14 | RP-70 |  |  |  |  |
| 605 | 221.7.1 | Core part: LTE Advanced intra-band Carrier Aggregation for xDL/yUL including contiguous and non-contiguous spectrum | 394d? | 2015-12-15 A | 2017-06-15 | 82% | 70.92d? |  |  |  | 395d | finish no earlier than 2017-06-15 | R4 | 3152h | 2584.64h | LTE_CA_R14_intra-Core | PCG-36 | Ericsson | Rel-14 | RP-70 |  |  |  | 36.714-00-00 |
| 606 | 221.7.2 | Perf. part: LTE Advanced intra-band Carrier Aggregation for xDL/yUL including contiguous and non-contiguous spectrum | 394d? | 2015-12-15 A | 2017-06-15 | 82% | 70.92d? |  |  |  | 395d | finish no earlier than 2017-06-15 | R4 | 3152h | 2584.64h | LTE_CA_R14_intra-Perf | PCG-36 | Ericsson | Rel-14 | RP-70 |  |  |  |  |

Notes:
- 585: Acronym changed from "LTE_CA_Rel-13" to "LTE_CA_Rel13"
- 587: 28/1/16: 36.714-05-01 added; 22/3/16: Compl:0%->15%; 22/3/16: WID: RP-151671->RP-1606151/7/16: Compl:15%->40%; 26/9/16: Compl:40%->60%; 20/12/16: Compl ; 21/3/17...
- 588: 22/3/16: WID: RP-151671->RP-1606151/7/16: WID: RP-160615->RP-16105226/9/16: WID: RP-161052->RP-161496; 20/12/16: Compl:0%->90% ; 21/3/17: Compl:90%->95%;...
- 590: 28/1/16: 36.714-02-01 added; 22/3/16: Compl:0%->20%; 22/3/16: WID: RP-152196->RP-160616; 1/7/16: Compl:20%->30%; 1/7/16: WI26/9/16: Compl:30%->50%; 20/12/16: Com 21/3/17: ...
- 591: 22/3/16: WID: RP-152196->RP-1606161/7/16: Compl:0%->30%1/7/16: WID: RP-160616->RP-161202; 26/9/16: Compl:30%->50% 20/12/16: Compl:50%->75% 21/3/17: Compl:75%->80%; ;...
- 593: 28/1/16: 36.714-02-02 added;22/3/16: Compl:0%->20%22/3/16: WID: RP-152237->RP-160192; 1/7/16: Compl:20%->40%; 26/9/16: Compl:40%->60%; 20/12/16: C ; 21/3/17:...
- 594: ; 22/3/16: WID: RP-152237->RP-1601921/7/16: WID: RP-160192->RP-16094726/9/16: WID: RP-160947->RP-161676; 20/12/16: Compl:0%->80%; 21/3/17: Compl:80%->90...
- 596: 28/1/16: 36.714-03-03 added;22/3/16: Compl:0%->1%1/7/16: Compl:1%->15%; 21/3/17: Compl:15%->100%
- 597: ; 1/7/16: Compl:0%->15%; ; 21/3/17: Compl:15%->100%
- 599: 28/1/16: 36.714-00-02 added; 22/3/16: Compl:0%->10%; 22/3/16: WID: RP-152246->RP-160148; 1/7/16: Compl:10%->40%; 26/9/16: Compl:40%->70%; 20/; 21/3/17: ...
- 600: 22/3/16: WID: RP-152246->RP-1601481/7/16: WID: RP-160148->RP-160748; 26/9/16: WID: RP-160748->RP-161487; 20/12/16: WID: RP-161487->RP-162036; ; 21/3/17:...
- 602: 28/1/16: 36.714-04-01 added;22/3/16: Compl:0%->30%22/3/16: WID: RP-152249->RP-1606141/7/16: Compl:30%->38%; 26/9/16: Compl:38%->74%; 20/12/16: Compl:74%->9521/3/1...
- 603: ; 22/3/16: WID: RP-152249->RP-160614; 1/7/16: Compl:0%->38%; 1/7/16: WID: RP-160614->RP-16082126/9/16: Compl:38%->0%; 20/12/16: Compl:0%->95% ; 21/3/17: CD:Wed 1...
- 605: 28/1/16: 36.714-00-00 added;22/3/16: Compl:0%->60%22/3/16: WID: RP-152250->RP-160613; 1/7/16: Compl:60%->50%; 1/7/16: WID: RP-160613; 26/9/16: Compl:50%->44%; 20/12/16:; ; 21/3/1...
- 606: ; 22/3/16: WID: RP-152250->RP-1606131/7/16: Compl:0%->50%1/7/16: WID: RP-160613->RP-16082226/9/16: WID: RP-160822->RP-161473; 20/12/16: Compl:50%->64% 21/3/17: Compl:64%->...

| ID | WBS | Task | Duration | Start | Finish | Complete | Remaining | Baseline start | Baseline finish | Baseline duration | Total slack | Constraint | Resources | Work | Actual work | Acronym | PCG approved | WI rapporteur name | Release | TSG approved | Impacted TSs and TRs | WI rapporteur e-mail | MCC resp | Acronym_3GU_Export | Special Focus Doc |
| --- | --- | --- | --- | --- | --- | --- | --- | --- | --- | --- | --- | --- | --- | --- | --- | --- | --- | --- | --- | --- | --- | --- | --- | --- | --- |
| 607 | 221.8 | **LTE Advanced inter-band Carrier Aggregation Rel-14 for 3DL/1UL** | 394d? | 2015-12-15 A | 2017-06-15 | 90% | 39.4d? |  |  |  | 395d |  | R4 | 9456h | 7904.07h | LTE_CA_R14_3DL1UL | PCG-36 | Huawei | Rel-14 | RP-70 |  |  |  |  |  |
| 608 | 221.8.1 | Core part: LTE Advanced inter-band Carrier Aggregation Rel-14 for 3DL/1UL | 394d? | 2015-12-15 A | 2017-06-15 | 90% | 39.4d? |  |  |  | 395d | finish no earlier than 2017-06-15 | R4 | 3152h | 2836.8h | LTE_CA_R14_3DL1UL-Core | PCG-36 | Huawei | Rel-14 | RP-70 | 36.714-03-01 |  |  |  |  |
| 609 | 221.8.2 | Perf. part: LTE Advanced inter-band Carrier Aggregation Rel-14 for 3DL/1UL | 394d? | 2015-12-15 A | 2017-06-15 | 90% | 39.4d? |  |  |  | 395d | finish no earlier than 2017-06-15 | R4 | 3152h | 2836.8h | LTE_CA_R14_3DL1UL-Perf | PCG-36 | Huawei | Rel-14 | RP-70 |  |  |  |  |  |
| 610 | 221.9 | UE Conformance Test Aspects – Rel-14 CA configurations | 458d? | 2016-06-15 A | 2018-03-15 | 9% | 416.78d? |  |  |  | 200d | finish no earlier than 2018-03-15 | R5 | 3664h | 329.76h | LTE_CA_R14-UEConTest | PCG-37 | Ericsson | Rel-14 | TSG#72 |  |  |  |  |  |
| 611 | 222 | Release 14 Studies | 323d? | 2014-09-17 A | 2015-12-11 A | 100% |  |  |  |  |  | finish no earlier than 2015-12-11 | SP; RP; CP; GP | 10336h | 10336h |  |  |  | Rel-14 |  |  |  |  |  |  |
| 612 | 223 | Study on channel model for frequency spectrum above 6 GHz | 197d? | 2015-09-15 A | 2016-06-15 A | 100% |  |  |  |  |  | finish no earlier than 2016-06-15 | R1 | 1576h | 1576h | FS_6GHz_CH_model | PCG-35 | Samsung | Rel-14 | RP-69 | 38.900 |  |  |  |  |
| 613 | 224 | Study on Scenarios and Requirements for Next Generation Access Technologies | 264d? | 2015-12-15 A | 2016-12-15 A | 100% |  |  |  |  |  | finish no earlier than 2016-12-15 | RP | 2112h | 2112h | FS_NG_SReq | PCG-36 | CMCC | Rel-14 | RP-70 | 38.xxx |  |  |  |  |
| 614 | 225 | Study on NB-IoT RF requirement for coexistence with CDMA | 133d? | 2016-06-15 A | 2016-12-15 A | 100% |  |  |  |  |  | finish no earlier than 2016-12-15 | R4 | 1064h | 1064h | FS_NB_IOT_CDMA_coex | PCG-37 | China Telecom | Rel-14 | TSG#72 | 36.752 |  |  |  |  |
| 615 | 226 | Study on need for Multiple Access Point Names | 464d? | 2013-09-12 A | 2015-06-19 A | 100% |  | 2013-09-12 | 2014-12-10 | 327d? |  | finish no earlier than 2015-06-19 | S1 | 3704h | 3704h | FS_MAPN | PCG-31 | Giesecke & Devrient | Rel-14 | SP-61 | 22.802 | Ilario.macchi@gi-de.com | Alain | FS_MAPN |  |
| 616 | 227 | Study on Multimedia Broadcast Supplement for Public Warning System | 264d? | 2013-12-11 A | 2014-12-12 A | 100% |  | 2013-12-11 | 2014-09-17 | 202d? |  | finish no earlier than 2014-12-12 | S1 | 2104h | 2104h | FS_MBSP | PCG-32 | Qualcomm | Rel-14 | SP-62 | 22.815 | Eddy Hall (edhall@qti.qualcomm.com) | Alain | FS_MBSP | Public Safety (I-A) |
| 617 | 228 | Study on service aspects for dealing with User Control over spoofed calls | 271d? | 2014-03-07 A | 2015-03-20 A | 100% |  | 2014-03-07 | 2014-12-10 | 199d? |  | finish no earlier than 2015-03-20 | S1 | 2168h | 2168h | FS_UC_SPOOF | PCG-32 | Sprint | Rel-14 | SP-63 | 22.898 | Gregory.schumacher@sprint.com | Alain | FS_UC_SPOOF |  |
| 618 | 229 | Study on User Location Reporting Support enhancements | 261d? | 2014-06-19 A | 2015-06-17 A | 100% |  | 2014-06-18 | 2015-06-17 | 261d? |  | finish no earlier than 2015-06-17 | S1 | 2088h | 2088h | FS_eULRS | PCG-33 | China Unicom | Rel-14 | SP-64 | 22.899 | Zhuoyun Zhang ( zhangzy910@chinaunicom.cn) |  | FS_eULRS |  |
| 619 | 230 | Study on Control of Applications when Third party Servers encounter difficulties | 259d? | 2014-06-19 A | 2015-06-15 A | 100% |  | 2014-06-18 | 2014-12-10 | 126d? |  | finish no earlier than 2015-06-15 | S1 | 2072h | 2072h | FS_CATS | PCG-33 | KDDI | Rel-14 | SP-64 | 22.818 | Eriko Yoshida (er-yoshida@kddi.com) |  | FS_CATS |  |
| 620 | 231 | Study on Paging Policy Enhancements and Procedure Optimizations in LTE | 176d? | 2015-04-14 A | 2015-12-15 A | 100% |  |  |  |  |  | finish no earlier than 2015-12-15 | S1 | 1408h | 1408h | FS_PPEPO_LTE | PCG-34 | Zhuoyun Zhang (China Unicom) | Rel-14 | SP-67 | New TR 22.838 | zhangzy910@chinaunicom.cn |  |  |  |
| 621 | 232 | Study on Latency reduction techniques for LTE | 328d? | 2015-03-16 A | 2016-06-15 A | 100% |  |  |  |  |  | finish no earlier than 2016-06-15 | R2 | 2624h | 2624h | FS_LTE_LATRED | PCG-34 | Ericsson | Rel-14 | RP-67 | 36.881 |  |  |  |  |
| 622 | 233 | Study on High Power LTE UE for Band 41 | 263d? | 2015-06-15 A | 2016-06-15 A | 100% |  |  |  |  |  | finish no earlier than 2016-12-15 | R4 | 2104h | 2104h | FS_LTE_B41_HPUE | PCG-35 | Sprint | Rel-14 | TSG-68 | 36.886 |  |  |  |  |
| 623 | 234 | Study on Media and Quality Aspects of SRVCC Enhancements | 192d? | 2015-06-18 A | 2016-03-11 A | 100% |  |  |  |  |  | finish no earlier than 2016-03-11 | S4 | 1536h | 1536h | FS_SETA_S4 | PCG-35 | Frédéric Gabin, Ericsson LM | Rel-14 | CP-68 | New TR 26.9xx, TS 26.114 | frederic . gabin @ ericsson . com |  |  |  |
| 624 | 235 | Deleted - Study on SON for eCoMP for LTE | 3d? | 2016-06-14 A | 2016-06-16 A | 100% |  |  |  |  |  | start no earlier than 2016-06-14 | R3 | 24h | 24h | delFS_LTE_SON_eCOMP | PCG-37 | Nokia | Rel-14 | SP-72 | 23.228, 23.237 |  |  |  |  |
| 625 | 236 | Study on UICC power optimization for MTC | 133d? | 2016-06-15 A | 2016-12-15 | 71% | 38d? |  |  |  | 525d |  | C6 | 1064h | 760h | FS_UICC_MTC_OPT | PCG-36 | Berionne, Michele | Rel-14 | CP-70 | 31.970 | micheleb [at] qti [dot] qualcomm [dot] com |  |  |  |
| 626 | 237 | Study on Server and Network Assisted DASH for 3GPP | 209d? | 2016-03-01 A | 2016-12-15 A | 100% |  |  |  |  |  | finish no earlier than 2016-12-15 | S4 | 1672h | 1672h | FS_SAND | PCG-36 | Ozgur Oyman, Intel | Rel-14 | TSG#71 | TR26.957 | ozgur.oyman@intel.com |  |  |  |
| 627 | 238 | Study on MBMS usage for mission critical communication services | 209d? | 2016-03-01 A | 2016-12-15 A | 100% |  |  |  |  |  | finish no earlier than 2016-12-15 | S6 | 1672h | 1672h | FS_MBMS_MCservices | PCG-36 | Magnus Tränk, Ericsson LM | Rel-14 | TSG#71 | TR 23.780 | magnus.trank@ericsson.com |  |  |  |
| 628 | 239 | Study on Energy Efficiency Aspects of 3GPP Standards | 201d? | 2016-03-11 | 2016-12-15 |  |  |  |  |  | 525d | finish no earlier than 2016-12-15 | SP | 1608h |  | FS_ENEFF | PCG-36 | Orange, Xiaobao Chen | Rel-14 | TSG#71 | TR 21.866 | xiaobao.chen@orange.com |  |  |  |
| 629 | 240 | Study on enhancement of VoLTE | 134d? | 2016-03-15 A | 2016-09-15 A | 100% |  |  |  |  |  | finish no earlier than 2016-09-15 | R2 | 1072h | 1072h | FS_LTE_eVoLTE | PCG-36 | CMCC | Rel-14 | TSG#71 | 36.750 |  |  |  |  |
| 630 | 241 | Study on HSPA and LTE Joint Operation | 199d? | 2016-03-15 A | 2016-12-15 A | 100% |  |  |  |  |  | finish no earlier than 2016-12-15 | R3 | 1592h | 1592h | FS_UTRA_LTE_JOP | PCG-36 | China Unicom | Rel-14 | TSG#71 | New 37.805 |  |  |  |  |
| 631 | 242 | Study on LTE Advanced Carrier Aggregation of Band 3 and Band 39 | 263d? | 2016-03-15 A | 2017-03-15 A | 100% |  |  |  |  |  | finish no earlier than 2017-03-15 | R4 | 2104h | 2104h | FS_LTE_CA_B3_B39 | PCG-36 | ZTE | Rel-14 | TSG#71 |  |  |  |  |  |
| 632 | 243 | Study on Context Aware Service Delivery in RAN for LTE | 263d? | 2016-03-15 A | 2017-03-15 A | 100% |  |  |  |  |  | finish no earlier than 2017-03-15 | R3 | 2104h | 2104h | FS_LTE_context | PCG-36 | CMCC | Rel-14 | TSG#71 |  |  |  |  |  |
| 633 | 244 | Study on further enhancements to Coordinated Multi-Point (CoMP) Operation for LTE | 263d? | 2016-03-15 A | 2017-03-15 A | 100% |  |  |  |  |  | finish no earlier than 2017-03-15 | R1 | 2104h | 2104h | FS_feCOMP_LTE | PCG-36 | Intel | Rel-14 | TSG#71 |  |  |  |  |  |
| 634 | 245 | Study on Determination of Completeness of Charging Information in IMS | 267d? | 2015-03-05 A | 2016-03-11 A | 100% |  |  |  |  |  | finish no earlier than 2016-03-11 | S5 | 2136h | 2136h | FS_DCCHII | PCG-34 | Jesske, Roland | Rel-14 | SP-67 | 32.xyz | r.jesske@telekom.de |  |  |  |
| 635 | 246 | Study on Interactivity Support for 3GPP-based Streaming and Download Services | 587d? | 2014-12-12 A | 2017-03-10 A | 100% |  |  |  |  |  | finish no earlier than 2017-03-10 | S4 | 4696h | 4696h | FS_IS3 | PCG-34 | Lo, Charles, Qualcomm | Rel-14 | SP-66 | 26.953 | clo@qti.qualcomm.com |  |  |  |
| 636 | 247 | Study on MBMS usage and codecs for MCPTT call and MC Video Service | 199d? | 2016-06-13 A | 2017-03-15 A | 100% |  |  |  |  |  | finish no earlier than 2017-03-15 | S4 | 1592h | 1592h | FS_MCP_V | PCG-37 | Zhiming Li, Huawei | Rel-14 | TSG#72 | 26.880 | lizhiming@huawei.com |  |  |  |
| 637 | 248 | Study on MBMS Extensions for Provisioning and Content Ingestion | 196d? | 2016-06-13 A | 2017-03-10 A | 100% |  |  |  |  |  | finish no earlier than 2017-03-10 | S4 | 1568h | 1568h | FS_xMBMS | PCG-37 | Kyungmo Park, Samsung Electronics Co., Ltd | Rel-14 | TSG#72 | TR 26.981 | kyungmo.park@samsung.com |  |  |  |
| 638 | 249 | Study on Technical Requirements for a new secure platform for 3GPP applications | 135d? | 2016-06-13 A | 2016-12-15 | 15% | 114.75d? |  |  |  | 525d | finish no earlier than 2016-12-15 | C6 | 1080h | 162h | FS_NG_SP | PCG-37 | Heiko Kruse | Rel-14 | TSG#72 | TR 31.xxx | heiko.kruse@safrangroup.com |  |  |  |
| 639 | 250 | Study on global application of LTE Band 11 and of LTE Band 21 UEs | 133d? | 2016-06-15 A | 2016-12-15 A | 100% |  |  |  |  |  | finish no earlier than 2016-12-15 | R4 | 1064h | 1064h | FS_LTE_B11_B21_global | PCG-37 | SoftBank | Rel-14 | TSG#72 | 36.745 |  |  |  |  |
| 640 | 251 | Study on Downlink MIMO for GERAN | 68d? | 2016-06-15 A | 2016-09-15 A | 100% |  |  |  |  |  | finish no earlier than 2016-09-15 | R6 | 544h | 544h | FS_DOMIMO_RAN6 | PCG-37 | Nokia, Alcatel-Lucent Shanghai Bell | Rel-14 | TSG#72 |  |  |  |  |  |
| 641 | 252 | Release 14 studies on 5G MObile Network for Advanced communications | 490d? | 2015-02-02 A | 2016-12-15 | 28% | 355d? |  |  |  | 525d |  | S1 | 2160h | 1080h |  | PCG-34 | Adrian Neal (Vodafone) | Rel-14 | SP-67 | New TR 22.891 | adrian.neal@vodafone.com |  |  |  |

Notes:
- 608: 28/1/16: 36.714-03-01 added;22/3/16: Compl:0%->15%22/3/16: WID: RP-152278->RP-1605821/7/16: Compl:15%->40%1/7/1626/9/16: Compl:40%->60%; 20/12/16: Compl:60%->80 21/3/1...
- 609: 22/3/16: WID: RP-152278->RP-160582; 1/7/16: WID: RP-160582->RP-160945; 26/9/16: WID: RP-160945->RP-161674; 20/12/16: Compl:0%->80%21/3/17: Compl:80%->90%;...
- 610: testing REL-14 CA basket WIs: LTE_CA_R14_intra-Core, LTE_CA_R14_2DL1UL-Core, LTE_CA_R14_3DL1UL-Core, LTE_CA_R14_4DL1UL-Core, LTE_CA_R14_5DL1UL-Core, LTE_CA_R14_2DL2UL-Core, LTE_CA_R14_xDL2UL-Core, LTE_CA_R14_3DL3UL-Core; ; ...
- 611: -
- 612: will start only in RAN in Q4/15; 28/1/16: 38.900 added; 22/3/16: Compl:10%->20%; 22/3/16: WID: RP-151606->RP-160210; 1/7/16: Compl:20%->100%. 2/12/16: Moved to Rel-15 according JMM email to move all 38.xxx related WIDs to Rel-15; 21/3/17: Stat Rep: -->; 21/3/17: Release: Rel-15->Rel-14
- 613: 22/3/16: Compl:0%->80%1/7/16: WID: RP-152257->RP-160811. 18/9/16: FCD: Sept 16, 80->95%26/9/16: Compl:95%->100%; 14/12/16: FCD:09/16->12/16; 14/12/16: 100%->9820/12/16: Compl:98%->100%20/12/16: CD:Mon 12/12/16->Thu 15/12/1620/12/16: Release: Rel-15->Re
- 614: ; 26/9/16: Compl:0%->35%; 6/10/16: 36.752 added; 20/12/16: Compl:35%->100%
- 615: SP#65 moved to Rel-14. Completion 12/14=>03/15. Triggered by S1-133134 LS on GSMA Connected Living Programme Request for APN Storage in the SIM. Dec.14: 50->70%, CD: 03/15->06/15. Mar.15: 90%; June2015: Compl:90%->100
- 616: SP#65 completion 09/14=>12/14. Moved to Rel-14. TR 22.815v100 for Information. Linked to Rel-9 Feature PWS. Dec.14:70->100%
- 617: SP#65 moved to Rel-14. Linked to SA3 Rel-11 TR 33.838 PUCI and Rel-12 ongoing study TR 33.831 (FS_SPOOF). Dec.14: 70->90, CD: 12/14->03/15. Mar.15: 100%
- 618: SP#65 moved to Rel-14. Linked to Rel-12 SA2 TR 23.843 Study on Core Network Overload solutions (FS_CNO) and Rel-13 Feature Service Exposure and Enablement Support (SEES). Dec.14: 30->70%. Mar.15: 90%; June2015: Compl:90%->100
- 619: SP#65 completion 12/14=>03/15. Moved to Rel-14. Linked to Rel-13 Feature SEES and Rel-13 TR 22.806 (FS_ACDC). Dec.14: 30->60%, WID SP-140246->SP-140758, CD: 12/14->03/15. Mar.15: CD: 03/13->06/15. 60->90%; June2015: Compl:90%->100
- 620: 1/4/15:TR number added; June2015: Compl:0%->40; 07/09/15: 40%->60; 7/12/15: 60%->100
- 621: 03/07/15: Compl:0%->10% 03/07/15: Stat Rep: -->RP-150780 03/07/15: Release: Rel-13->Rel-14 29/09/15: Compl:10%->25% 29/09/15: Stat Rep: RP-150780->RP-151286 22/3/16: Compl:50%->60%;
- 622: 7/9/15: TR added 29/09/15: Compl:0%->1% 29/09/15: Stat Rep: -->RP-151436 ; 22/3/16: Compl:10%->40%; 22/3/16: WID: RP-151104->RP-1600921/7/16: Compl
- 623: Aug2015: 0%->25; 07/09/15: 25%->30; 7/12/15: 30%->80, FCD: 12/15->03/16, MOVED TO REL-14; 7/3/16: 80%->100
- 624: 26/9/16: Compl:0%->10%. 1/12/16: Deleted: 720085 was allocated twice: to FS_LTE_SON-ECOMP (now in 720063) and to ROBVOLTE (now in 720301)
- 625: 7/3/16: 0%->100
- 626: 11/6/16: 0%->10; 19/9/16: 10%->60; 1/12/16: 60%->100
- 627: 11/6/16: 0%->35. Name corrected; 19/9/16: WID:SP-160201->SP-160525; FCD: 09/16->12/16; 19/9/16: 35%->60; 23/9/16: WID:SP-160525->SP-160728; 1/12/16: 60%->95; 3/3/17: 95%->100
- 628: 28/7/16: 21.866 added;
- 629: 1/7/16: Compl:0%->75%1/7/16: WI; 28/7/16: 36.750 added; 26/9/16: Compl:75%->100%
- 630: ; 1/7/16: Compl:0%->30%; 26/9/16: Compl:30%->80%; 20/12/16: Compl:80%->100%;
- 631: intention to capture results in existing TR 36.714-02-01 ; 1/7/16: Compl:0%->30%; 26/9/16: Compl:30%->50%; 20/12/16: Compl ; 21/3/17: Compl:8...
- 632: 1/7/16: Compl:0%->25%1/26/9/16: Compl:25%->40%; 20/12/16: Compl:40%->70% ; 21/3/17: Compl:70%->100%
- 633: ; 1/7/16: Compl:0%->15%; 26/9/16: Compl:15%->30%; 20/12/16: Compl:30%->80%21/3/17: Compl:80%->100%
- 634: 11/03/15: WID changed from FS_DCCII to FS_DCCHII as per SA5 chair request; June2015: Compl:0%->7; 07/09/15: 7%->15; 7/12/15: 15%->60, FCD: 09/15->03/16; 7/3/16: 60%->100. 22/3/16: Rel-13->Rel-14
- 635: TR number added. Mar. 15: 0->5%; June2015: Compl:5%->10; Aug2015: 10%->15; 07/09/15: 15%->30, FCD: 12/15->03/16; 7/3/16: 30%->40. 15/4/16: moved from Rel-13. FCD: 11/3/16->23/9/16; 11/6/16: 40%->50; 19/9/16: 50%->70, FCD:09/16->12/16; 1/12/16: 70%->80;; 6/3/17: 80%->100
- 636: 28/7/16: 26.880 added; 19/9/16: 0%->30, FCD: 12/16->03/17; 1/12/16: 30%->60; 6/3/17: 60%->100
- 637: 28/7/16: 26.981 added; 19/9/16: 0%->30; 1/12/16: 30%->50; 1/12/16: FCD:12/16->03/17; 6/3/17: 50%->100
- 638: 16/9/16: 0%->15.
- 639: 26/9/16: Compl:0%->30%; 6/10/16: 36.745 added; 20/12/16: Compl:30%->100%
- 640: continuation of GERAN SI UID 590034, DOMIMO under RAN626/9/16: Compl:0%->100%
- 641: 11/3: WID: SP-150050->150142; June2015: Compl:0%->20; 07/09/15: 20%->60. 07/12/15: Created by MCC as BB to dissociate SA1 versus SA2 aspects

| ID | WBS | Task | Type | Duration | Start | Finish | Complete | Remaining | Baseline start | Baseline finish | Baseline duration | Total slack | Constraint | Resources | Work | Actual work | Acronym | PCG approved | Impacted TSs and TRs | WI rapporteur name | WI rapporteur e-mail | Release | TSG approved | MCC resp | Special Focus Doc | Acronym_3GU_Export | Status Report | TSG stopped |
| --- | --- | --- | --- | --- | --- | --- | --- | --- | --- | --- | --- | --- | --- | --- | --- | --- | --- | --- | --- | --- | --- | --- | --- | --- | --- | --- | --- | --- |
| 642 | 253 | **Study on Stage 1 for New Services and Markets Technology Enablers** |  | 355d? | 2015-02-02 A | 2016-06-10 | 98% | 8.39d? |  |  |  | 660d |  | S1 | 10120h | 8334.03h | FS_SMARTER | PCG-34 | New TR 22.891 | Adrian Neal (Vodafone) | adrian.neal@vodafone.com | Rel-14 | SP-67 |  |  |  |  |  |
| 643 | 253.1 | General aspects of FS_SMARTER SA1 |  | 270d? | 2015-02-02 A | 2016-02-12 | 95% | 13.5d? |  |  |  | 745d | finish no earlier than 2016-02-12 | S1 | 2160h | 2052h | FS_SMARTER | PCG-34 | New TR 22.891 | Adrian Neal (Vodafone) | adrian.neal@vodafone.com | Rel-14 | SP-67 |  |  |  |  |  |
| 644 | 253.2 | FS_SMARTER – massive Internet of Things |  | 160d? | 2015-11-02 A | 2016-06-10 A | 100% |  |  |  |  |  | finish no earlier than 2016-06-10 | S1 | 1280h | 1280h | FS_SMARTER-mIoT | PCG-36 | New TR 22.861 | Adrian Neal (Vodafone) | adrian.neal@vodafone.com | Rel-14 | SP-70 |  |  |  |  |  |
| 645 | 253.3 | FS_SMARTER – Critical Communications |  | 160d? | 2015-11-02 A | 2016-06-10 | 95% | 8d? |  |  |  | 660d | finish no earlier than 2016-06-10 | S1 | 1280h | 1216h | FS_SMARTER-CRIC | PCG-36 | New TR 22.862 | Kanerva, Mikko | mikko.kanerva@nokia.com | Rel-14 | SP-70 |  |  |  |  |  |
| 646 | 253.4 | FS_SMARTER – enhanced Mobile Broadband |  | 160d? | 2015-11-02 A | 2016-06-10 A | 100% |  |  |  |  |  | finish no earlier than 2016-06-10 | S1 | 1280h | 1280h | FS_SMARTER-eMBB | PCG-36 | New TR 22.863 | Laurence Meriau | laurence.meriau@huawei.com | Rel-14 | SP-70 |  |  |  |  |  |
| 647 | 253.5 | FS_SMARTER – Network Operation |  | 160d? | 2015-11-02 A | 2016-06-10 A | 100% |  |  |  |  |  | finish no earlier than 2016-06-10 | S1 | 1280h | 1280h | FS_SMARTER-NEO | PCG-36 | New TR 22.864 | Lu Lu | lulu@chinamobile.com | Rel-14 | SP-70 |  |  |  |  |  |
| 648 | 254 | SA2 aspects on Study on Architecture and Security for next Generation System |  | 270d? | 2015-12-07 A | 2016-12-15 A | 100% |  |  |  |  |  | finish no earlier than 2016-12-15 | S2 | 2160h | 2160h | FS_NextGen | PCG-36 | TR 23.799 | suntao@chinamobile.com, devaki.chandramouli@nokia.com | suntao@chinamobile.com, devaki.chandramouli@nokia.com | Rel-14 | SP-70 |  |  |  |  |  |
| 649 | 255 | SA3 aspects on Study on Architecture and Security for Next Generation System |  | 273d? | 2016-03-01 A | 2017-03-15 | 60% | 109.2d? |  |  |  | 461d | finish no earlier than 2017-03-15 | S3 | 2184h | 1310.4h | FS_NSA | PCG-36 | TR 33.899 | Vesa Torvinen, Ericsson | vesa.torvinen@ericsson.com | Rel-14 | SP-71 |  |  |  |  |  |
| 650 | 256 | Study on New Radio (NR) Access Technology |  | 263d? | 2016-03-15 A | 2017-03-15 A | 100% |  |  |  |  |  | finish no earlier than 2017-03-15 | R1 | 2104h | 2104h | FS_NR_newRAT | PCG-36 | TR 38.801, TR 38.912; 38.802; 38.901; 38.805 | NTT DOCOMO |  | Rel-14 | TSG#71 |  |  |  |  |  |
| 651 | 257 | Release 13 Features |  | 253.25d? | 2013-12-11 A | 2014-11-25 A | 100% |  | 2015-04-14 | 2015-12-25 | 183.25d? |  |  | SP; RP; CP; GP | 8104h | 8104h |  |  |  |  |  | Rel-13 |  |  |  |  |  |  |
| 652 | 258 | **Mission Critical Push To Talk over LTE (MCPTT)** |  | 1053d? | 2013-12-11 A | 2017-12-15 | 90% | 100.67d? | 2013-12-11 | 2015-06-17 | 397d? | 264d |  | S1; S2; S3; S6; S4 | 68846.8h | 47781.7h | MCPTT | PCG-32 | Stage 1/2; | NIST | david.cypher@nist.gov | Rel-13 | SP-62 | Alain | Public Safety (A-A) | MCPTT |  |  |
| 653 | 258.1 | Study on Application Architecture to support MCPTT |  | 326d? | 2014-06-23 A | 2015-09-16 A | 100% |  | 2014-06-18 | 2014-12-10 | 126d? |  | finish no earlier than 2015-09-16 | S6 | 2608h | 2608h | MCPTT | PCG-33 | New TR 23.779 | Yannick Lair | yannick.lair@lge.com | Rel-13 | SP-64 |  | Public Safety (A-A) |  |  |  |
| 654 | 258.2 | SA2 Study on Architecture Enhancements at the EPS and IMS Level to Support MCPTT |  | 69d? | 2015-03-13 A | 2015-06-17 A | 100% |  |  |  |  |  | finish no earlier than 2015-06-17 | S2 | 552h | 552h | MCPTT | PCG-34 |  | Randy Bloomfield (randy@its.bldrdoc.gov) | Randy Bloomfield (randy@its.bldrdoc.gov) | Rel-13 | SP-67 |  |  |  |  |  |
| 655 | 258.3 | Study on Security Enhancements for MCPTT |  | 261d? | 2015-03-13 A | 2016-03-11 A | 100% |  |  |  |  |  | finish no earlier than 2016-03-11 | S3 | 2088h | 2088h | MCPTT | PCG-34 | 33.879; 33.280; 39.880 | Peter Haigh (peter.haigh at cesg.gsi.gov.uk) | Peter Haigh (peter.haigh at cesg.gsi.gov.uk) | Rel-13 | SP-67 |  |  |  |  |  |
| 656 | 258.4 | Study on media, codecs and MBMS enhancements for MCPTT |  | 326d? | 2014-12-12 A | 2016-03-11 | 85% | 48.9d? |  |  |  | 725d | finish no earlier than 2016-03-11 | S4 | 2608h | 2216.8h | MCPTT | PCG-34 | New TR 26.879 | Zhiming Li (lizhiming@huawei.com) | Zhiming Li (lizhiming@huawei.com) | Rel-13 | SP-67 |  |  |  |  |  |
| 657 | 258.5 | Stage 1 for MCPTT |  | 263d? | 2013-12-11 A | 2014-12-12 A | 100% |  | 2013-12-11 | 2014-12-10 | 261d? |  | finish no earlier than 2014-12-12 | S1 | 2104h | 2104h | MCPTT | PCG-32 | New TS 22.179 | NIST | david.cypher@nist.gov | Rel-13 | SP-62 | Alain | Public Safety (A-A) |  | SP-140502 |  |
| 658 | 258.6 | Functional architecture and information flows to support MCPTT |  | 127d? | 2015-06-18 A | 2015-12-11 A | 100% |  | 2014-06-18 | 2014-12-10 | 126d? |  | finish no earlier than 2015-12-11 | S6 | 1016h | 1016h | MCPTT | PCG-33 | New TS 23.179 | Yannick Lair | yannick.lair@lge.com | Rel-13 | SP-64 |  | Public Safety (A-A) |  |  |  |
| 659 | 258.7 | Security of MCPTT |  | 326d? | 2014-12-12 A | 2016-03-11 A | 100% |  |  |  |  |  | finish no earlier than 2016-03-11 | S3 | 2608h | 2608h | MCPTT | PCG-34 | TS 33.179 | Peter Haigh (peter.haigh at cesg.gsi.gov.uk) | Peter Haigh (peter.haigh at cesg.gsi.gov.uk) | Rel-13 | SP-66 |  |  |  |  |  |
| 660 | 258.8 | MCPTT Codecs and media handling |  | 267d? | 2015-03-05 A | 2016-03-11 | 85% | 40.05d? |  |  |  | 725d | finish no earlier than 2016-03-11 | S4 | 2136h | 1815.6h | MCPTT | PCG-34 | 26.346, new TS 26.179 | Zhiming Li (lizhiming@huawei.com) | Zhiming Li (lizhiming@huawei.com) | Rel-13 | SP-67 |  |  |  |  |  |
| 661 | 258.9 | **MCPTT protocol aspects** |  | 215d? | 2015-09-07 A | 2016-06-30 | 96% | 9.64d? |  |  |  | 645d |  | ct | 16584h | 14539h | MCPTT-CT | PCG-35 |  | Keith Drage, Alcatel-Lucent |  | Rel-13 | CP-69 |  |  |  |  |  |
| 662 | 258.9.1 | **CT1 aspects for MCPTT protocol aspects** |  | 135d? | 2015-09-07 A | 2016-03-11 A | 100% |  |  |  |  |  |  | C1 | 10800h | 10800h | MCPTT-CT | PCG-35 | 24.379, 24.380 24.38, 24.382, 24.383, 24.384, 24.229 | Samsung, Ricky Kaura | ricky.kaura@samsung.com | Rel-13 | CP-69 |  |  |  |  |  |
| 663 | 258.9.1.1 | Call Control – On Network |  | 135d? | 2015-09-07 A | 2016-03-11 A | 100% |  |  |  |  |  | finish no earlier than 2016-03-11 | C1 | 1080h | 1080h | MCPTT-CT | PCG-35 | 24.379 | Samsung, Ricky Kaura | ricky.kaura@samsung.com | Rel-13 | CP-69 |  |  |  |  |  |
| 664 | 258.9.1.2 | Call Control – Off Network |  | 135d? | 2015-09-07 A | 2016-03-11 A | 100% |  |  |  |  |  | finish no earlier than 2016-03-11 | C1 | 1080h | 1080h | MCPTT-CT | PCG-35 | 24.379 | Samsung, Ricky Kaura | ricky.kaura@samsung.com | Rel-13 | CP-69 |  |  |  |  |  |
| 665 | 258.9.1.3 | Floor Control – On Network |  | 135d? | 2015-09-07 A | 2016-03-11 A | 100% |  |  |  |  |  | finish no earlier than 2016-03-11 | C1 | 1080h | 1080h | MCPTT-CT | PCG-35 | 24.380 | Samsung, Ricky Kaura | ricky.kaura@samsung.com | Rel-13 | CP-69 |  |  |  |  |  |
| 666 | 258.9.1.4 | Floor Control – Off Network |  | 135d? | 2015-09-07 A | 2016-03-11 A | 100% |  |  |  |  |  | finish no earlier than 2016-03-11 | C1 | 1080h | 1080h | MCPTT-CT | PCG-35 | 24.380 | Samsung, Ricky Kaura | ricky.kaura@samsung.com | Rel-13 | CP-69 |  |  |  |  |  |
| 667 | 258.9.1.5 | Broadcast – Call Control and Floor Control |  | 135d? | 2015-09-07 A | 2016-03-11 A | 100% |  |  |  |  |  | finish no earlier than 2016-03-11 | C1 | 1080h | 1080h | MCPTT-CT | PCG-35 | 24.379, 24.380 | Samsung, Ricky Kaura | ricky.kaura@samsung.com | Rel-13 | CP-69 |  |  |  |  |  |
| 668 | 258.9.1.6 | Group management |  | 135d? | 2015-09-07 A | 2016-03-11 A | 100% |  |  |  |  |  | finish no earlier than 2016-03-11 | C1 | 1080h | 1080h | MCPTT-CT | PCG-35 | 24.381 | Samsung, Ricky Kaura | ricky.kaura@samsung.com | Rel-13 | CP-69 |  |  |  |  |  |
| 669 | 258.9.1.7 | Identity management |  | 135d? | 2015-09-07 A | 2016-03-11 A | 100% |  |  |  |  |  | finish no earlier than 2016-03-11 | C1 | 1080h | 1080h | MCPTT-CT | PCG-35 | 24.382 | Samsung, Ricky Kaura | ricky.kaura@samsung.com | Rel-13 | CP-69 |  |  |  |  |  |
| 670 | 258.9.1.8 | Management Object |  | 135d? | 2015-09-07 A | 2016-03-11 A | 100% |  |  |  |  |  | finish no earlier than 2016-03-11 | C1 | 1080h | 1080h | MCPTT-CT | PCG-35 | 24.383 | Samsung, Ricky Kaura | ricky.kaura@samsung.com | Rel-13 | CP-69 |  |  |  |  |  |
| 671 | 258.9.1.9 | Configuration management |  | 135d? | 2015-09-07 A | 2016-03-11 A | 100% |  |  |  |  |  | start no earlier than 2015-09-07 | C1 | 1080h | 1080h | MCPTT-CT | PCG-36 | 24.384 | Samsung, Ricky Kaura | ricky.kaura@samsung.com | Rel-13 | TSG#71 |  |  |  |  |  |
| 672 | 258.9.2 | CT3 aspects for MCPTT protocol aspects |  | 135d? | 2015-09-07 A | 2016-03-11 A | 100% |  |  |  |  |  | finish no earlier than 2016-03-11 | C3 | 1080h | 1080h | MCPTT-CT | PCG-35 | 29.165 | Alcatel-Lucent, Keith Drage | keith.drage@alcatel-lucent.com | Rel-13 | CP-69 |  |  |  |  |  |
| 673 | 258.9.3 | CT4 aspects for MCPTT protocol aspects |  | 135d? | 2015-09-07 A | 2016-03-11 A | 100% |  |  |  |  |  | finish no earlier than 2016-03-11 | C4 | 1080h | 1080h | MCPTT-CT | PCG-35 | 23.003, 23.008, 29.283 | Alcatel-Lucent, Keith Drage | keith.drage@alcatel-lucent.com | Rel-13 | CP-69 |  |  |  |  |  |
| 674 | 258.9.4 | CT6 aspects for MCPTT protocol aspects |  | 135d? | 2015-09-07 A | 2016-03-11 A | 100% |  |  |  |  |  | finish no earlier than 2016-03-11 | C6 | 1080h | 1080h | MCPTT-CT | PCG-36 | 31.102, 31.103 | Alcatel-Lucent, Keith Drage | keith.drage@alcatel-lucent.com | Rel-13 | CP-70 |  |  |  |  |  |
| 675 | 258.9.5 | (IETF) IANA Registration of New SIP Resource- Priority Namespace for MCPTT |  | 103d? | 2016-02-10 A | 2016-06-30 | 25% | 77.25d? |  |  |  | 645d | start no earlier than 2016-02-10 | C1-IETF | 824h | 206h | MCPTT-CT | PCG-36 | draft-holmberg-dispatch-mcptt-rp-namespace | Ericsson | christer.holmberg@ericsson.com | Rel-13 | TSG#71 |  |  |  |  |  |
| 676 | 258.10 | IMS Profile to support MCPTT |  | 130d? | 2015-09-14 A | 2016-03-11 A | 100% |  |  |  |  |  | finish no earlier than 2016-03-11 | C1 | 1040h | 1040h | MCPTT-Prof | PCG-35 | 24.980 | Huawei, PATEL Milan | Milan.Patel@huawei.com | Rel-13 | CP-69 |  |  |  |  |  |
| 677 | 258.11 | UE Conformance Test Aspects - Support for Mission Critical Push To Talk over LTE (MCPTT) |  | 262d? | 2016-12-15 A | 2017-12-15 | 5% | 248.9d? |  |  |  | 264d | finish no earlier than 2017-12-15 | R5 | 2096h | 104.8h | MCPTT-ConTest |  | 36.579-5 | US Department of Commerce |  | Rel-13 |  |  |  |  |  |  |
| 678 | 258.12 | Deleted: SA2 aspects for MCPTT |  | 1d? | 2015-03-13 A | 2015-03-13 A | 100% |  | 2014-06-18 | 2015-06-17 | 261d? |  | finish no earlier than 2015-03-13 | S2 | 8h | 8h | MCPTT | PCG-33 | New TS 23.179 | Randy Bloomfield (randy@its.bldrdoc.gov) | Randy Bloomfield (randy@its.bldrdoc.gov) | Rel-13 | SP-64 |  | Public Safety (A-A) |  |  | SP-69 |
| 679 | 258.13 | Deleted (duplicated): Application Architecture to support MCPTT | milestone | 0d? | 2015-03-13 A | 2015-03-13 A | 100% |  |  |  |  |  | finish no earlier than 2015-03-13 | S6 |  |  | MCPTT | PCG-34 |  | U.S. Department of Commerce | Randy Bloomfield (randy@its.bldrdoc.gov) | Rel-13 | SP-67 |  |  |  |  | SP-69 |
| 680 | 258.14 | Deleted (duplicated): SA6 aspects for MCPTT |  | 261d? | 2014-12-12 A | 2015-12-11 A | 100% |  |  |  |  |  | finish no earlier than 2015-12-11 | S6 | 2088h | 2088h | MCPTT | PCG-34 |  | David Cypher (david.cypher at nist.gov) | David Cypher (david.cypher at nist.gov) | Rel-13 | SP-66 |  |  |  |  | SP-69 |

Notes:
- 643: 7/12/15: 60%->85; 2/3/16: 85%->95
- 644: 2/3/16: 35%->65; 9/6/16: 65%->100
- 645: 2/3/16: 15%->60; 9/6/16: 60%->95
- 646: 2/3/16: 40%->75; 9/6/16: 75%->100
- 647: 2/3/16: 30%->60; 19/9/16: 60%->100
- 648: 28/1/16: 23.799 added; Acronym corrected ("NexGen"->"NextGen"); 7/3/16: 5%->15; 10/3/16: WID:SP-150853->SP-160200. Name changed from "Study on Architecture for next Generation System"; 9/6/16: 15%->35; 19/9/16: 35%->64; 22/9/16: WID:SP-160227->SP-16072
- 649: 19/9/16: 0%->25; 22/9/16: WID:SP-160227->SP-160727; 22/9/16: FCD:12/16->03/17; 1/12/16: 25%->45; 6/3/17: 45%->60
- 650: includes RAN TR 38.801; 1/7/16: Compl:0%->10%; 1/7/16: CD:Thu 15/06/17->Wed 15/03/17; 1/7/16: WID: RP-160671->RP-161214; 1/7/16: Release: Rel-15->Rel-14; 28/7/16: 38.802 added; 26/9/16: Compl:10%->20%; 26/9/16: WID: RP-161214->RP-161596. 2/12/16: Moved...; 21/3/17: 38.805 added;
- 651: -
- 652: SP#65 updated WID SP-140276=>SP-140435. Mar 15: WID: SP-140879->SP-150164. 4/15: S4 added. 6/15: WID updated
- 653: SP#65 completion 12/14=>06/15. Updated WID SP-140276=>SP-140435. Dec.14: 2->20%. Mar 15: WID: SP-140879->SP-150095. Mar15: 30%. Transferred to SA6. June 15: FCD shifted to Sept,WID updated; June2015: Compl:24%->50; June2015: Compl:50%->70. 3/8/15: Rapp
- 654: Mar 2015: WID: SP-140879->SP-150164.; June2015: Compl:0%->30, WID updated; 07/09/15: 30%->100, "To be confirmed" deleted, since SA2 has completed it.
- 655: Mar 2015: WID: SP-140879->SP-150164. Name clarified.6/15: WID updated; 7/12/15: 0%->75; 10/12/15: FCD->March, ES in SP-150729; 7/3/16: 75%->80; 28/7/16: 33.280 added; 28/7/16: 39.880 added; 1/12/16: 80%->100
- 656: Mar 2015: WID: SP-140879->SP-150164. Name clarified. 5/5/15: TR number added; June2015: Compl:0%->5, WID updated; Aug2015: 5%->15; 07/09/15: 15%->40; 7/12/15: 40%->80, FCD: 12/15->03/16; 7/3/16: 80%->85
- 657: SP#65 completion 09/14=>12/14. Exception in SP-140502. TS 22.179v100 for Information. Completed. Mar 15: WID: SP-140879->SP-150164. 6/15: WID updated
- 658: June2015: added as per SP-150356; June2015: Compl:0%->15. 31 July: Rapporteur corrected. 3/8/15: name aligned to the WID; 07/09/15: 15%->50; 07/09/15: 50%->85. 15/09/15: FCD: 09/15->12/15; 7/3/16: 85%->100
- 659: Mar 2015: WID: SP-140879->SP-150164. Name clarified. FCD: 03/2016->12/2015; June2015: Compl:5%->15, WID updated. 7/9/15: TS number added; 7/12/15: 15%->60. FCD -> 03/16, ES in SP-150729; 7/3/16: 60%->85; 1/12/16: 85%->98; 6/3/17: 98%->100
- 660: Mar 2015: WID: SP-140879->SP-150164. Name clarified. FCD: 03/2016->12/2015; June2015: Compl:0%->5, WID updated; Aug2015: 5%->15; 07/09/15: 15%->40. ES in SP-150663; 7/3/16: 40%->85
- 661: 7/12/15: WID:CP-150587->CP-150793; 28/1/16: 24.384 added;
- 662: 7/12/15: WID:CP-150587->CP-150793; 7/3/16: WID:CP-150863->CP-160160; 5/12/16: WID:CP-160160->CP-160817
- 663: Proposed by Atle after some talks with several interested parties; 7/12/15: 0%->50; 7/12/15: WID:CP-150587->CP-150863. FCD->03/16, ES in CP-150721; 7/3/16: 50%->100; 7/3/16: WID:CP-150863->CP-160160; 5/12/16: WID:CP-160160->CP-160817
- 664: Proposed by Atle after some talks with several interested parties; 7/12/15: 0%->75; 7/12/15: WID:CP-150587->CP-150863. FCD->03/16, ES in CP-150721; 7/3/16: 75%->100; 7/3/16: WID:CP-150863->CP-160160; 5/12/16: WID:CP-160160->CP-160817
- 665: Proposed by Atle after some talks with several interested parties; 7/12/15: 0%->80; 7/12/15: WID:CP-150587->CP-150863. FCD->03/16, ES in CP-150721; 7/3/16: 80%->100; 7/3/16: WID:CP-150863->CP-160160; 5/12/16: WID:CP-160160->CP-160817
- 666: Proposed by Atle after some talks with several interested parties; 7/12/15: 0%->85; 7/12/15: WID:CP-150587->CP-150863. FCD->03/16, ES in CP-150721; 7/3/16: 85%->100; 7/3/16: WID:CP-150863->CP-160160; 5/12/16: WID:CP-160160->CP-160817
- 667: Proposed by Atle after some talks with several interested parties; 7/12/15: 0%->50; 7/12/15: WID:CP-150587->CP-150863. FCD->03/16, ES in CP-150721; 7/3/16: 50%->100; 7/3/16: WID:CP-150863->CP-160160; 5/12/16: WID:CP-160160->CP-160817
- 668: Proposed by Atle after some talks with several interested parties; 7/12/15: 0%->75; 7/12/15: WID:CP-150587->CP-150863. FCD->03/16, ES in CP-150721; 7/3/16: 75%->100; 7/3/16: WID:CP-150863->CP-160160; 5/12/16: WID:CP-160160->CP-160817
- 669: Proposed by Atle after some talks with several interested parties; 7/12/15: WID:CP-150587->CP-150863. FCD->03/16, ES in CP-150721; 7/3/16: 0%->100; 7/3/16: WID:CP-150863->CP-160160; 5/12/16: WID:CP-160160->CP-160817
- 670: Proposed by Atle after some talks with several interested parties; 7/12/15: 0%->10; 7/12/15: WID:CP-150587->CP-150863. FCD->03/16, ES in CP-150721; 7/3/16: 10%->100. Name changed from "Configuration management"; 7/3/16: WID:CP-150863->CP-160160; 5/12/1
- 671: Introduced from CT1 WP update in 03/16; 7/3/16: WID:CP-150863->CP-160160; 5/12/16: WID:CP-160160->CP-160817
- 672: 7/12/15: 0%->70; 7/12/15: WID:CP-150587->CP-150863. FCD -> 03/16, ES in CP-150643; 7/3/16: 70%->100; 7/3/16: WID:CP-150863->CP-160160; 5/12/16: WID:CP-160160->CP-160817
- 673: 7/12/15: WID:CP-150587->CP-150863. FCD -> 03/16, ES in CP-150864; 7/3/16: 0%->100; 7/3/16: WID:CP-150863->CP-160160; 5/12/16: WID:CP-160160->CP-160817
- 674: 7/12/15: WID:CP-150587->CP-150863. FCD -> 03/16, ES in CP-150866; 7/3/16: 0%->100; 7/3/16: WID:CP-150863->CP-160160; 5/12/16: WID:CP-160160->CP-160817
- 675: 5/12/16: WID:CP-160160->CP-160817
- 676: 12/15: TR # added; 7/12/15: 0%->60; 7/12/15: WID:CP-150500->CP-150794. FCD -> 03/16, ES in CP-150722; 7/3/16: 60%->100
- 677: 6/1/17: acronym changed from "MCPTT-UEConTest" ; 21/3/17: Compl:0%->5%; 21/3/17: 36.579-5 added;
- 678: Mar 2015: transferred to SA6. Was 06/14 to 06/15. 6/15: WID updated
- 679: Mar 2015: WID: SP-140879->SP-150164. Name clarified.6/15: WID updated. 7/15: removed since duplicates 640143 and 660054 (only 640143 is kept)
- 680: Mar 2015: WID: SP-140879->SP-150164. Name clarified. 6/15: WID updated. 31 July: deleted since duplicates 640143 and 670031 (only 640143 is kept)

| ID | WBS | Task | Duration | Start | Finish | Complete | Baseline start | Baseline finish | Baseline duration | Constraint | Resources | Work | Actual work | Acronym | PCG approved | Impacted TSs and TRs | WI rapporteur name | WI rapporteur e-mail | Release | TSG approved | MCC resp | Status Report | Special Focus Doc | Acronym_3GU_Export |
| --- | --- | --- | --- | --- | --- | --- | --- | --- | --- | --- | --- | --- | --- | --- | --- | --- | --- | --- | --- | --- | --- | --- | --- | --- |
| 681 | 259 | **MBMS Extensions and Profiling** | 202d? | 2015-03-05 A | 2015-12-11 A | 100% |  |  |  |  | S4 | 4848h | 4848h | MEPRO | PCG-34 | 26.346, new TR 26.852 | Imed Bouazizi, Samsung and Thorsten Lohmar, Ericsson | i.bouazizi@samsung.com, thorsten.lohmar@ericsson.com | Rel-13 | SP-67 |  |  |  |  |
| 682 | 259.1 | TR on Profiling and Extensions of MBMS | 202d? | 2015-03-05 A | 2015-12-11 A | 100% |  |  |  | finish no earlier than 2015-12-11 | S4 | 1616h | 1616h | MEPRO | PCG-34 | new TR 26.852 | Imed Bouazizi, Samsung and Thorsten Lohmar, Ericsson | i.bouazizi@samsung.com, thorsten.lohmar@ericsson.com | Rel-13 | SP-67 |  |  |  |  |
| 683 | 259.2 | Specification of MBMS Extensions and Profiling | 202d? | 2015-03-05 A | 2015-12-11 A | 100% |  |  |  | start no earlier than 2015-03-05 | S4 | 1616h | 1616h | MEPRO | PCG-34 | 26.346 | Imed Bouazizi, Samsung and Thorsten Lohmar, Ericsson | i.bouazizi@samsung.com, thorsten.lohmar@ericsson.com | Rel-13 | SP-67 |  |  |  |  |
| 684 | 260 | **Isolated E-UTRAN Operation for Public Safety** | 529d? | 2014-03-07 A | 2016-03-11 A | 100% | 2014-03-07 | 2014-09-17 | 139d? |  | S1 | 8600h | 8600h | IOPS | PCG-32 | New TS 22.346 | General Dynamics | paul.piggin@gd-broadband.com | Rel-13 | SP-63 | Alain | S1-143304 | Public Safety (A-A) | IOPS |
| 685 | 260.1 | Stage 1 fo Isolated E-UTRAN Operation for Public Safety | 140d? | 2014-03-07 A | 2014-09-17 A | 100% | 2014-03-07 | 2014-09-17 | 139d? | finish no earlier than 2014-09-17 | S1 | 1120h | 1120h | IOPS | PCG-32 | New TS 22.346 | General Dynamics | paul.piggin@gd-broadband.com | Rel-13 | SP-63 | Alain | S1-143304 | Public Safety (A-A) | IOPS |
| 686 | 260.2 | Stage 2 for Isolated E-UTRAN Operation for Public Safety | 140d? | 2015-06-18 A | 2015-12-30 A | 100% | 2014-03-07 | 2014-09-17 | 139d? | start no earlier than 2015-06-18 | S2 | 1120h | 1120h | IOPS | PCG-32 | 23.401 | Phil Young | phil.young@gd-broadband.com | Rel-13 | SP-63 | Alain |  | Public Safety (A-A) | IOPS |
| 687 | 260.3 | Security aspects for Isolated E-UTRAN Operation for Public Safety | 76d? | 2015-09-16 A | 2015-12-30 A | 100% | 2014-03-07 | 2014-09-17 | 139d? | start no earlier than 2015-09-16 | S3 | 608h | 608h | IOPS | PCG-32 | TS 33.401 | General Dynamics | paul.piggin@gd-ms.uk | Rel-13 | SP-63 | Alain |  | Public Safety (A-A) | IOPS |
| 688 | 260.4 | **CT aspects for IOPS** | 95d? | 2015-11-02 A | 2016-03-11 A | 100% |  |  |  |  | C6 | 1520h | 1520h | IOPS-CT | PCG-36 |  | Heiko Kruse, Morpho Cards GmbH | heiko.kruse@mrpho.com | Rel-13 | CP-70 |  |  |  |  |
| 689 | 260.4.1 | CT6 aspects for IOPS | 95d? | 2015-11-02 A | 2016-03-11 A | 100% |  |  |  | finish no earlier than 2016-03-11 | C6 | 760h | 760h | IOPS-CT | PCG-36 | 31.102 | Heiko Kruse, Morpho Cards GmbH | heiko.kruse@mrpho.com | Rel-13 | CP-70 |  |  |  |  |
| 690 | 261 | Service Requirements Maintenance for Group Communication System Enablers for LTE | 67d? | 2014-06-18 A | 2014-09-17 A | 100% | 2014-06-18 | 2014-09-17 | 66d? | finish no earlier than 2014-09-17 | S1 | 536h | 536h | SRM_GCSE_LTE | PCG-33 | 22.468 | Nokia Networks | Juergen.Merkel@nsn.com | Rel-13 | SP-64 |  | S1-143307 | Public Safety (A-A) | SRM_GCSE_LTE |
| 691 | 262 | Enhanced Calling Information Presentation | 330d? | 2014-09-15 A | 2015-12-16 A | 100% | 2013-12-11 | 2014-09-17 | 201d? | finish no earlier than 2015-12-16 | S1 | 2640h | 2640h | ECIP | PCG-32 | 22.182 (CAT), 22.183 (CRS) | China Mobile | LI Xiaofan (lixiaofan@chinamobile.com | Rel-13 | SP-62 | Alain | S1-143311 |  | ECIP |
| 692 | 263 | **Flexible Mobile Service Steering** | 392d? | 2014-09-15 A | 2016-03-11 A | 100% | 2013-12-11 | 2014-09-17 | 202d? |  | S1; S2 | 7943.76h | 6367.76h | FMSS | PCG-33 | 22.101 | China Mobile | Lu Lu (lulu@chinamobile.com) | Rel-13 | SP-65 | Alain | S1-143310 |  | FMSS |
| 693 | 263.1 | Stage 1 for Flexible Mobile Service Steering | 3d? | 2014-09-15 A | 2014-09-17 A | 100% | 2013-12-11 | 2014-09-17 | 202d? | start no earlier than 2014-09-15 | S1 | 23.85h | 23.85h | FMSS-ST1 | PCG-33 | 22.101 | China Mobile | Lu Lu (lulu@chinamobile.com) | Rel-13 | SP-65 | Alain | S1-143310 |  | FMSS |
| 694 | 263.2 | Flexible Mobile Service Steering TR Phase | 134d? | 2014-12-12 A | 2015-06-17 A | 100% |  |  |  | finish no earlier than 2015-06-17 | S2 | 1072h | 1072h | FMSS-SA2TR | PCG-34 | 23.718 | Lu Lu, China Mobile | lulu@chinamobile.com | Rel-13 | SP-66 |  |  |  |  |
| 695 | 263.3 | Flexible Mobile Service Steering - Stage 2 | 134d? | 2014-12-12 A | 2015-06-17 A | 100% |  |  |  | start no earlier than 2014-12-12 | S2 | 1072h | 1072h | FMSS-SA2 | PCG-34 |  | Lu Lu, China Mobile | lulu@chinamobile.com | Rel-13 | SP-66 |  |  |  |  |
| 696 | 263.4 | CT3 Aspect of Flexible Mobile Service Steering | 133d? | 2015-09-09 A | 2016-03-11 A | 100% |  |  |  | finish no earlier than 2016-03-11 | C3 | 1064h | 1064h | FMSS-CT | PCG-35 | 29.abc, 29.212, 29.213 | ZTE,Zhou Xiaoyun | zhou.xiaoyun@zte.com.cn | Rel-13 | CP-69 |  |  |  |  |
| 697 | 264 | GERAN UTRAN Sharing Enhancements | 63d? | 2014-09-19 A | 2014-12-12 A | 100% |  |  |  | finish no earlier than 2014-12-12 | S1 | 504h | 504h | GUSH | PCG-33 | 22.101 | Telefónica | chris.friel@telefonica.com | Rel-13 | SP-65 |  | SP-140515 |  | GUSH |
| 698 | 265 | **Application specific Congestion control for Data Communication** | 456d? | 2014-06-18 A | 2016-03-11 A | 100% | 2014-06-18 | 2014-09-17 | 66d? |  | S1; C1 | 17920h | 14808h | ACDC | PCG-33 | 22.011 | NTT DOCOMO | Atsushi Minokuchi (minokuchi@nttdocomo.co.jp) | Rel-13 | SP-64 |  | S1-143305 |  | ACDC |
| 699 | 265.1 | Stage 1 for Application specific Congestion control for Data Communication | 67d? | 2014-06-18 A | 2014-09-17 A | 100% | 2014-06-18 | 2014-09-17 | 66d? | finish no earlier than 2014-09-17 | S1 | 536h | 536h | ACDC-ST1 | PCG-33 | 22.011 | NTT DOCOMO | Atsushi Minokuchi (minokuchi@nttdocomo.co.jp) | Rel-13 | SP-64 |  | S1-143305 |  | ACDC |
| 700 | 265.2 | **Stage 3 for Application specific Congestion control for Data Communication** | 332d? | 2014-12-04 A | 2016-03-11 A | 100% |  |  |  |  | C1 | 7472h | 7472h | ACDC-CT | PCG-34 | TS 24.105, 24.301, 24.008, 27.007, 31.102 | Kim, Jaehyun, LGE | jaehyun7.kim@lge.com | Rel-13 | CT-66 |  |  |  |  |
| 701 | 265.2.1 | CT1 part of Stage 3 for Application specific Congestion control for Data Communication | 270d? | 2014-12-04 A | 2015-12-16 A | 100% |  |  |  | finish no earlier than 2015-12-16 | C1 | 2160h | 2160h | ACDC-CT | PCG-34 | 24.105, 24.301, 24.008, 27.007, 23.122 | Kim, Jaehyun, LGE | jaehyun7.kim@lge.com | Rel-13 | CT-66 |  |  |  |  |
| 702 | 265.2.2 | CT6 part of Stage 3 for Application specific Congestion control for Data Communication | 332d? | 2014-12-04 A | 2016-03-11 A | 100% |  |  |  | finish no earlier than 2016-03-11 | C6 | 2656h | 2656h | ACDC-CT | PCG-34 | 31.102 | Kim, Jaehyun, LGE | jaehyun7.kim@lge.com | Rel-13 | CT-66 |  |  |  |  |
| 703 | 265.3 | **RAN aspects of Application specific Congestion control for Data Communication** | 197d? | 2015-03-16 A | 2015-12-15 A | 100% |  |  |  |  | R2 | 3152h | 3152h | ACDC-RAN | PCG-34 |  | LG Electronics |  | Rel-13 | RP-67 |  |  |  |  |
| 704 | 265.3.1 | Core part: RAN aspects of Application specific Congestion control for Data Communication | 197d? | 2015-03-16 A | 2015-12-15 A | 100% |  |  |  | finish no earlier than 2015-12-15 | R2 | 1576h | 1576h | ACDC-RAN-Core | PCG-34 |  | LG Electronics |  | Rel-13 | RP-67 |  | RP-151275 |  |  |

Notes:
- 681: 1/4/15: TS number added; 14/09/15: WID:SP-150099->SP-150439
- 682: 8/4/15: line added; June2015: Compl:0%->10; Aug2015: 10%->15; 07/09/15: 15%->40; 14/09/15: WID:SP-150099->SP-150439; 7/12/15: 40%->100
- 683: 8/4/15: line added; June2015: Compl:0%->10; Aug2015: 10%->15; 07/09/15: 15%->40; 14/09/15: WID:SP-150099->SP-150439; 7/12/15: 40%->100
- 684: SP#65 completed. TS 22.346v100 for 1-step Approval. Triggered by Rel-13 TR 22.897 (FS_IOPS); 14/09/15: WID:SP 150358->SP-150463
- 685: SP#65 completed. TS 22.346v100 for 1-step Approval. Triggered by Rel-13 TR 22.897 (FS_IOPS); 14/09/15: WID:SP 150358->SP-150463
- 686: 07/09/15: 0%->100; 14/09/15: WID:SP 150358->SP-150463
- 687: 07/09/15: 0%->100; 11/12/15: 0%->100
- 689: ES in CP-150837; 7/3/16: 0%->100
- 690: SP#65 completed. Some Rel-12 service reqs have no Stage 2/3 implementation
- 691: SP#65 approved WID & completed. Triggered by Rel-13 TR 22.810. Linked to Multimedia Telephony Service for IMS (UID_7038), Customized Alerting Tone (CAT) UID_370028, Customized Ringing Signal (CRS) UID_380067. 31/07/15: 100%
- 692: SP#65 WID approved & completed. Triggered by Rel-13 TR 22.808 (FS_FMSS)
- 693: SP#65 WID approved & completed. Triggered by Rel-13 TR 22.808 (FS_FMSS). Dec.14: moved from Feature to S1 BB
- 694: 3/3: TR number added.Mar15: 15->20%; June2015: Compl:20%->85; 07/09/15: 85%->100
- 695: 07/09/15: 0%->90; 07/09/15: 90%->100
- 696: 07/09/15: 0%->20; 14/09/15: WID:CP-150488->CP-150577; 7/12/15: 20%->90; 7/12/15: WID:CP-150577->CP-150799. FCD -> 03/16. ES in CP-150646; 7/3/16: 90%->100
- 697: SP#65 exception in SP-140515. Triggered by TR 22.852 (FS_RSE and FS_GUSH). Completed.
- 698: SP#65 completed. Triggered by Rel-13 Study TR 22.806
- 699: Results from MCC Split of the SA1 feature into F+BB for stage 1
- 700: Presented at CT#66. June 2015: FCD: June->Dec 2015, WID: CP-140999-> CP-150282
- 701: Presented at CT#66; June2015: Compl:0%->10. June 2015: FCD: June->Dec 2015, WID: CP-140999-> CP-150282; 07/09/15: 5%->70; 7/12/15: 70%->100
- 702: Presented at CT#66. June 2015: FCD: June->Dec 2015, WID: CP-140999-> CP-150282. 12/15: FCD -> 03/16, ES in CP-150838; 7/3/16: 0%->100
- 704: 03/07/15: Compl:0%->25% 03/07/15: WID: RP-150512->RP-150662 03/07/15: Stat Rep: ->RP-150661 29/09/15: Compl:25%->70% 29/09/15: Stat Rep: RP-150661->RP-151275; 1/1/16: Compl:70%->100%

| ID | WBS | Task | Duration | Start | Finish | Complete | Remaining | Baseline start | Baseline finish | Baseline duration | Total slack | Constraint | Resources | Work | Actual work | Acronym | PCG approved | WI rapporteur name | WI rapporteur e-mail | Release | TSG approved | MCC resp | Acronym_3GU_Export | PCG stopped | TSG stopped | Status Report |
| --- | --- | --- | --- | --- | --- | --- | --- | --- | --- | --- | --- | --- | --- | --- | --- | --- | --- | --- | --- | --- | --- | --- | --- | --- | --- | --- |
| 705 | 266 | **User Plane Congestion management** | 667d? | 2012-09-12 A | 2015-03-18 A | 100% |  | 2012-02-02 | 2015-06-17 | 890d? |  |  | S1; S2; C3; C4 | 39368h | 39368h | UPCON | PCG-29 | KDDI | Eriko Yoshida (er-yoshida@kddi.com) | Rel-13 | SP-57 | Alain | UPCON |  |  |  |
| 706 | 266.1 | Stage 1 for User Plane Congestion management | 129d? | 2012-09-12 A | 2013-03-06 A | 100% |  | 2012-02-02 | 2013-03-06 | 289d? |  | start no earlier than 2012-09-12 | S1 | 1032h | 1032h | UPCON-ST1 | PCG-29 | KDDI | Eriko Yoshida (er-yoshida@kddi.com) | Rel-13 | SP-57 | Alain |  |  |  |  |
| 707 | 266.2 | TR on Stage 2 for User Plane Congestion management | 595d? | 2012-12-12 A | 2015-03-18 A | 100% |  | 2012-12-12 | 2014-12-10 | 525d? |  | finish no earlier than 2015-03-18 | S2 | 4760h | 4760h | UPCON-SA2TR | PCG-30 | Allot | Alla Goldner (agoldner@allot.com) | Rel-13 | SP-58 | Maurice |  |  |  |  |
| 708 | 266.3 | Deleted - Stage 2 for User Plane Congestion management | 261d? | 2012-12-19 A | 2013-12-11 A | 100% |  | 2012-12-19 | 2013-12-11 | 261d? |  | finish no earlier than 2013-12-11 | S2 | 2088h | 2088h | UPCON-SA2Del | PCG-30 | NEC | andreas.maeder@neclab.eu | Rel-13 | SP-58 | Maurice |  | PCG-32 | SP-62 |  |
| 709 | 266.4 | **BB1: RAN Downlink Traffic Differentiation, Congestion Detection and Reporting** | 269d? | 2014-03-07 A | 2015-03-13 A | 100% |  | 2014-03-07 | 2015-06-17 | 334d? |  |  | S2 | 10048h | 10048h | UPCON-DOTCON | PCG-32 | Allot | Alla Goldner (agoldner@allot.com) | Rel-13 | SP-63 | Maurice | UPCON-DOTCON |  |  |  |
| 710 | 266.4.1 | Stage 2 for RAN Downlink Traffic Differentiation, Congestion Detection and Reporting | 201d? | 2014-03-07 A | 2014-12-12 A | 100% |  | 2014-03-07 | 2015-06-17 | 334d? |  | finish no earlier than 2014-12-12 | S2 | 1608h | 1608h | UPCON-DOTCON-SA2 | PCG-32 | Allot | Alla Goldner (agoldner@allot.com) | Rel-13 | SP-63 | Maurice |  |  |  |  |
| 711 | 266.4.2 | **CT aspects of User Plane Congestion Management for BB1** | 262d? | 2014-03-18 A | 2015-03-13 A | 100% |  |  |  |  |  |  | C3 | 6288h | 6288h | UPCON-DOTCON-CT | PCG-33 | Huawei | Xia Haitao (xiahaitao@huawei.com) | Rel-13 | CP-65 |  | UPCON-DOTCON-CT |  |  |  |
| 712 | 266.4.2.1 | CT3 part of CT aspects of User Plane Congestion Management for BB1 | 262d? | 2014-03-18 A | 2015-03-13 A | 100% |  |  |  |  |  | finish no earlier than 2015-03-13 | C3 | 2096h | 2096h | UPCON-DOTCON-CT | PCG-33 | Huawei | Xia Haitao (xiahaitao@huawei.com) | Rel-13 | CP-65 |  |  |  |  |  |
| 713 | 266.4.2.2 | CT4 part of CT aspects of User Plane Congestion Management for BB1 | 262d? | 2014-03-18 A | 2015-03-13 A | 100% |  |  |  |  |  | finish no earlier than 2015-03-13 | C4 | 2096h | 2096h | UPCON-DOTCON-CT | PCG-33 | Huawei | Xia Haitao (xiahaitao@huawei.com) | Rel-13 | CP-65 |  |  |  |  |  |
| 714 | 266.5 | Deleted - BB2: Application and Content Prioritization | 140d? | 2014-03-07 A | 2014-09-17 A | 100% |  | 2014-03-07 | 2015-06-17 | 334d? |  | finish no earlier than 2014-09-17 | S2 | 1120h | 1120h | UPCON-CONDEL | PCG-32 | Allot | Alla Goldner (agoldner@allot.com) | Rel-13 | SP-63 | Maurice | UPCON-CON | PCG-33 | SP-65 |  |
| 715 | 266.6 | Deleted - BB3: Uplink traffic and attended/unattended traffic | 140d? | 2014-03-07 A | 2014-09-17 A | 100% |  | 2014-03-07 | 2015-06-17 | 334d? |  | finish no earlier than 2014-09-17 | S2 | 1120h | 1120h | UPCON-TRAFDEL | PCG-32 | Allot | Alla Goldner (agoldner@allot.com) | Rel-13 | SP-63 | Maurice | UPCON-TRAF | PCG-33 | SP-65 |  |
| 716 | 267 | **Media Handling Aspects of IMS-based Telepresence** | 660d? | 2014-09-09 A | 2017-03-15 | 79% | 141.71d? |  |  |  | 461d |  | S4 | 20696h | 14760.4h | IMS_TELEP_S4 | PCG-33 | Intel | ozgur.oyman@intel.com | Rel-13 | SP-65 |  | IMS_TELEP_S4 |  |  |  |
| 717 | 267.1 | TR on Media Handling Aspects of IMS-based Telepresence | 269d? | 2014-09-09 A | 2015-09-16 A | 100% |  |  |  |  |  | finish no earlier than 2015-09-16 | S4 | 2152h | 2152h | IMS_TELEP_S4 | PCG-33 | Intel | ozgur.oyman@intel.com | Rel-13 | SP-65 |  |  |  |  |  |
| 718 | 267.2 | Specification on Media Handling Aspects of IMS-based Telepresence | 334d? | 2014-09-09 A | 2015-12-16 A | 100% |  |  |  |  |  | finish no earlier than 2015-12-16 | S4 | 2672h | 2672h | IMS_TELEP_S4 | PCG-33 | Intel | ozgur.oyman@intel.com | Rel-13 | SP-65 |  |  |  |  |  |
| 719 | 267.3 | (IETF) CLUE Protocol (draft-ietf-clue-protocol) | 331d? | 2015-12-10 A | 2017-03-15 | 60% | 132.4d? |  |  |  | 461d | finish no earlier than 2017-03-15 | S4-IETF | 2648h | 1588.8h | IMS_TELEP_S4 | PCG-36 | Intel | ozgur.oyman@intel.com | Rel-13 | TSG#71 |  |  |  |  |  |
| 720 | 267.4 | (IETF) Mapping RTP streams to CLUE media captures (draft-ietf-clue-rtp-mapping) | 331d? | 2015-12-10 A | 2017-03-15 | 60% | 132.4d? |  |  |  | 461d | finish no earlier than 2017-03-15 | S4-IETF | 2648h | 1588.8h | IMS_TELEP_S4 | PCG-36 | Intel | ozgur.oyman@intel.com | Rel-13 | TSG#71 |  |  |  |  |  |
| 721 | 267.5 | (IETF) DTLS Encapsulation of SCTP Packets (draft-ietf-tsvwg-sctp-dtls-encaps) | 331d? | 2015-12-10 A | 2017-03-15 | 95% | 16.55d? |  |  |  | 461d | finish no earlier than 2017-03-15 | S4-IETF | 2648h | 2515.6h | IMS_TELEP_S4 | PCG-36 | Intel | ozgur.oyman@intel.com | Rel-13 | TSG#71 |  |  |  |  |  |
| 722 | 267.6 | (IETF) Using Simulcast in SDP and RTP Sessions (draft-ietf-mmusic-sdp-simulcast) | 331d? | 2015-12-10 A | 2017-03-15 | 60% | 132.4d? |  |  |  | 461d | finish no earlier than 2017-03-15 | S4-IETF | 2648h | 1588.8h | IMS_TELEP_S4 | PCG-36 | Ericsson | tomas.frankkila@ericsson.com | Rel-13 | TSG#71 |  |  |  |  |  |
| 723 | 268 | **RAN Sharing Enhancements** | 657d? | 2013-06-19 A | 2015-12-15 A | 100% |  | 2013-06-19 | 2013-12-11 | 129d? |  |  | S1; R3 | 16824h | 16824h | RSE | PCG-31 | NEC | joerg.swetina@neclab.eu | Rel-13 | SP-60 | Alain | RSE |  |  |  |
| 724 | 268.1 | Stage 1 for RAN Sharing Enhancements | 129d? | 2013-06-19 A | 2013-12-11 A | 100% |  | 2013-06-19 | 2013-12-11 | 129d? |  |  | S1 | 1032h | 1032h | RSE-SA1 | PCG-31 | NEC | joerg.swetina@neclab.eu | Rel-13 | SP-60 | Alain |  |  |  |  |
| 725 | 268.2 | **RAN aspects of RAN Sharing Enhancements for LTE** | 330d? | 2014-09-12 A | 2015-12-15 A | 100% |  | 2014-06-13 | 2015-06-12 | 261d? |  |  | R3 | 5280h | 5280h | RSE-RAN_LTE | PCG-33 | NEC | Siva.Vakeesar@emea.nec.com | Rel-13 | RP-65 |  | RSE-RAN_LTE |  |  |  |
| 726 | 268.2.1 | Core part: RAN aspects of RAN Sharing Enhancements for LTE | 330d? | 2014-09-12 A | 2015-12-15 A | 100% |  | 2014-06-13 | 2015-06-12 | 261d? |  | finish no earlier than 2015-12-15 | R3 | 2640h | 2640h | RSE-RAN_LTE-Core | PCG-33 | NEC | Siva.Vakeesar@emea.nec.com | Rel-13 | RP-65 |  | RSE-RAN_LTE-Core |  |  | RP-151295 |
| 727 | 269 | **Enhancements to WEBRTC interoperability** | 529d? | 2014-03-07 A | 2016-03-11 | 95% | 24.12d? | 2014-03-07 | 2015-06-17 | 334d? | 725d |  | S1; S2; S3 | 27336h | 16630.6h | eWebRTCi | PCG-32 | Alcatel-Lucent | betsy.covell@alcatel-lucent.com | Rel-13 | SP-63 | Alain | eWebRTCi |  |  |  |
| 728 | 269.1 | Stage 1 for Enhancements to WEBRTC interoperability | 139d? | 2014-03-07 A | 2014-09-17 A | 100% |  | 2014-03-07 | 2014-09-17 | 139d? |  | finish no earlier than 2014-09-17 | S1 | 1112h | 1112h | eWebRTCi | PCG-32 | Alcatel-Lucent | betsy.covell@alcatel-lucent.com | Rel-13 | SP-63 | Alain |  |  |  | S1-143303 |
| 729 | 269.2 | TR on Stage 2 for Enhancements to WEBRTC interoperability | 196d? | 2014-06-19 A | 2015-03-18 A | 100% |  | 2014-06-18 | 2015-03-18 | 196d? |  | finish no earlier than 2015-03-18 | S2 | 1568h | 1568h | eWebRTCi | PCG-33 | China Mobile | Yu Qing (yuqing@chinamobile.com) | Rel-13 | SP-64 |  |  |  |  |  |
| 730 | 269.3 | Stage 2 for Enhancements to WEBRTC interoperability | 261d? | 2014-06-23 A | 2015-06-17 A | 100% |  | 2014-06-18 | 2015-06-17 | 261d? |  | finish no earlier than 2015-06-17 | S2 | 2088h | 2088h | eWebRTCi | PCG-33 | China Mobile | Yu Qing (yuqing@chinamobile.com) | Rel-13 | SP-64 |  |  |  |  |  |
| 731 | 269.4 | TR on Security for Enhancements to WEBRTC interoperability | 273d? | 2014-09-17 A | 2015-09-30 A | 100% |  |  |  |  |  | start no earlier than 2014-09-17 | S3 | 2184h | 2184h | eWebRTCi | PCG-33 | Ericsson | vesa.lehtovirta@ericsson.com | Rel-13 | SP-65 |  |  |  |  |  |
| 732 | 269.5 | Security for Enhancements to WEBRTC interoperability | 273d? | 2014-09-17 A | 2015-09-30 A | 100% |  |  |  |  |  | start no earlier than 2014-09-17 | S3 | 2184h | 2184h | eWebRTCi | PCG-33 | Ericsson | vesa.lehtovirta@ericsson.com | Rel-13 | SP-65 |  |  |  |  |  |
| 733 | 269.6 | (IETF) Session Traversal Utilities for NAT (STUN) Extension for Third Party Authorization (draft-ietf-tram-turn-third-party-authz) | 198d? | 2014-09-17 A | 2015-08-12 A | 100% |  |  |  |  |  | start no earlier than 2014-09-17 | S3-IET | 1584h | 1584h | eWebRTCi | PCG-35 | Alcatel-Lucent |  | Rel-13 | CP-69 |  |  |  |  |  |

Notes:
- 705: SP#65 updated WID SP-140153=>SP-140631 (BBII & BBIII stopped). Triggered by Rel-12 TR 22.805 Study on User Plane Congestion management (FS_UPCON) / Impacted TSs and TRs: Stage 1/2/3
- 706: SP#63 moved to Rel-13 updated WID SP-120890=>SP-140153. SP#59 completed. Convert TR 22.805 clause 6 consolidated requirements to normative requirements in 22.101. 3/3/15: start date corrected (was Mar 12) / Impacted TSs and TRs: 22.101
- 707: SP#65 updated WID SP-140153=>SP-140631. TR 23.705v100 for Information. Dec.14: 87->98%. Mar15: 100% / Impacted TSs and TRs: new TR 23.705
- 708: SP#62 stopped at 0% completion / Impacted TSs and TRs: TBD
- 709: SP#65 updated WID SP-140153=>SP-140631. IncludES in CP-150RAN Congestion Detection: , RAN Traffic Differentiation, RAN Congestion Reporting, CN Congestion Mitigation mechanisms, Dynamic Policy Control
- 710: SP#65 updated WID SP-140153=>S2-142850 (added impacted specs). Dec.14: 70->100% only if RAN agrees to standardize the FPI / Impacted TSs and TRs: 23.060, 23.203, 23.401
- 711: Stage 3; WID: CP-140734->CP-140929. June 2015: WID: CP-140929-> CP-150365. / Impacted TSs and TRs: Stage 3
- 712: Dec.14: 0->60; WID: CP-140734->CP-140929. Mar.15: 60->95%; June2015: Compl:95%->100. WID: CP-140929-> CP-150365. / Impacted TSs and TRs: 29.201, 29.212, 29.213, 29.214, 29.215, 29.219, New TS 29.217 (PCC over Np)
- 713: Dec.14: 0->20; WID: CP-140734->CP-140929. Mar. 15: 50%; June2015: Compl:50%->90. WID: CP-140929-> CP-150365.; 07/09/15: 90%->100 / Impacted TSs and TRs: 23.003, 29.303, New TS 29.405 (UPCON over Nq)
- 714: SP#65 updated WID SP-140153=>SP-140631 (BBII & BBIII stopped). IncludES in CP-150Content specific UP prioritization (Video), Application specific UP prioritization / Impacted TSs and TRs: TBD
- 715: SP#65 updated WID SP-140153=>SP-140631 (BBII & BBIII stopped). IncludES in CP-150Uplink Congestion Management, Un/Attended UE Information / Impacted TSs and TRs: TBD
- 716: Can be seen as an "enhancement" of Rel-12 IMS-based Telepresence (IMS_TELEP) UID_530042. Mar. 15: 20%
- 717: Dec.14: 0->10%. 8/4/15: 20%; June2015: Compl:20%->30; Aug2015: 30%->35; 07/09/15: 35%->60; 7/12/15: 60%->100 / Impacted TSs and TRs: New TR 26.9xy
- 718: Dec.14: 0->10%. 8/4/15: 20%; June2015: Compl:20%->30; 07/09/15: 30%->60; 7/12/15: 60%->100 / Impacted TSs and TRs: New TS 26.1xy
- 719: Impacted TSs and TRs: 26.22
- 720: Impacted TSs and TRs: 26.22
- 721: Impacted TSs and TRs: 26.22
- 722: Impacted TSs and TRs: 26.114, 26.223
- 723: Triggered by Rel-12 TR 22.852 Study on RAN Sharing Enhancements (FS_RSE)
- 724: SP#62 completed / Impacted TSs and TRs: 22.101
- 725: Triggered by TR 36.856 Study on RAN aspects of RAN Sharing Enhancements for LTE (FS_RSE-RAN_LTE) & SA1 22.101 Stage 1 / Impacted TSs and TRs: LTE
- 726: ; CD:Mon 15/06/15->Tue 15/09/15; Stat Rep: -->RP-141891 1st Apr 15: Compl:15%->20% 1st Apr 15: Stat Rep: RP-141891->RP-150289 03/07/15: Compl:20%->75% 03/07/15: Stat Rep: RP-150289->RP-150875 29/09/15: Compl:75%->80% 29/09/15: CD:Tue 15/09/15->Tue 15/1 / Impacted TSs and TRs: 36.300, 36.413, 36.423
- 727: SP#65 updated WID SP-14028=>SP-140630 (added SA3 part, SA1 change). Add enhanced interoperability support for WebRTC to Rel-12 Web Real Time Communication (WebRTC) Access to IMS. / Impacted TSs and TRs: Stage 1/2
- 728: SP#65 completed. Updated WID SP-140286=>SP-140630 / Impacted TSs and TRs: 22.228
- 729: SP#65 updated WID SP-14028=>SP-140630 (added SA3 part). Dec.14: 9->55%; June2015: Compl:55%->85; 07/09/15: 85%->100 / Impacted TSs and TRs: New TR 23.706
- 730: SP#65 updated WID SP-14028=>SP-140630 (added SA3 part); June2015: Compl:0%->85; 07/09/15: 85%->100 / Impacted TSs and TRs: 23.228
- 731: SP#65 updated WID SP-14028=>SP-140630 (added SA3 part). Dec.14: 0->20%, TR number added. 3/3/15: 30%.; June2015: Compl:30%->75; 11/12/15: 54%->100; 11/12/15: 100%->100 / Impacted TSs and TRs: New TR 33.872
- 732: SP#65 updated WID SP-14028=>SP-140630 (added SA3 part). Dec.14: 0->20%; 11/12/15: 15%->100 / Impacted TSs and TRs: 33.203, 33.328
- 733: TS 33.203 CR0235draft-ietf-tram-turn-third-party-authz; 7/3/16: 10%->100 / Impacted TSs and TRs: 33.203, RRC 7635 (was draft-ietf-tram-turn-third-party-authz)

| ID | WBS | Task | Type | Duration | Start | Finish | Complete | Remaining | Baseline start | Baseline finish | Baseline duration | Total slack | Constraint | Resources | Work | Actual work | Acronym | PCG approved | WI rapporteur name | WI rapporteur e-mail | Release | TSG approved | Impacted TSs and TRs | MCC resp | Acronym_3GU_Export | Special Focus Doc |
| --- | --- | --- | --- | --- | --- | --- | --- | --- | --- | --- | --- | --- | --- | --- | --- | --- | --- | --- | --- | --- | --- | --- | --- | --- | --- | --- |
| 734 | 269.7 | **Stage 3 for Enhancements to WebRTC interoperability** |  | 135d? | 2015-09-07 A | 2016-03-11 | 84% | 21.09d? |  |  |  | 725d |  | ct | 6048h | 4340h | eWebRTCi-CT | PCG-35 | China Mobile, Song Yue | songyue@chinamobile.com | Rel-13 | CP-69 |  |  |  |  |
| 735 | 269.7.1 | CT1 aspects 3 for Enhancements to WebRTC interoperability |  | 75d? | 2015-09-07 A | 2015-12-18 A | 100% |  |  |  |  |  | finish no earlier than 2015-12-18 | C1 | 600h | 600h | eWebRTCi-CT | PCG-35 | China Mobile, Song Yue | songyue@chinamobile.com | Rel-13 | CP-69 | 24.371, 24.229 |  |  |  |
| 736 | 269.7.2 | CT3 aspects for Enhancements to WebRTC interoperability |  | 135d? | 2015-09-07 A | 2016-03-11 A | 100% |  |  |  |  |  | finish no earlier than 2016-03-11 | C3 | 1080h | 1080h | eWebRTCi-CT | PCG-35 | China Mobile, Song Yue | songyue@chinamobile.com | Rel-13 | CP-69 | 29.214 |  |  |  |
| 737 | 269.7.3 | CT4 aspects for Enhancements to WebRTC interoperability |  | 135d? | 2015-09-07 A | 2016-03-11 A | 100% |  |  |  |  |  | finish no earlier than 2016-03-11 | C4 | 1080h | 1080h | eWebRTCi-CT | PCG-35 | China Mobile, Song Yue | songyue@chinamobile.com | Rel-13 | CP-69 | 29.228, 23.334, 29.334, 23.008 |  |  |  |
| 738 | 269.7.4 | (IETF) SDP-based Data Channel Negotiation (draft-ietf-mmusic-data-channel-sdpneg) |  | 69d? | 2015-12-08 A | 2016-03-11 | 75% | 17.25d? |  |  |  | 725d | finish no earlier than 2016-03-11 | C1-IETF; SA4-IETF | 1104h | 828h | eWebRTCi-CT | PCG-36 | Ericsson | christer.holmberg@ericsson.com | Rel-13 | TSG#71 | 24.371, 24.229 |  |  |  |
| 739 | 269.7.5 | (IETF) MSRP over Data Channels (draft-ietf-mmusic-msrp-usage-data-channel) |  | 69d? | 2015-12-08 A | 2016-03-11 | 75% | 17.25d? |  |  |  | 725d | start no earlier than 2015-12-08 | C1-IETF | 552h | 414h | eWebRTCi-CT | PCG-36 | Ericsson | christer.holmberg@ericsson.com | Rel-13 | TSG#71 | 24.371, 24.229, 26.223 |  |  |  |
| 740 | 269.7.6 | (IETF) A Language for Rules Describing JSON Content (draft-newton-json-content-rules) |  | 69d? | 2015-12-08 A | 2016-03-11 | 25% | 51.75d? |  |  |  | 725d | start no earlier than 2015-12-08 | C3-IETF | 552h | 138h | eWebRTCi-CT | PCG-36 | Ericsson | christer.holmberg@ericsson.com | Rel-13 | TSG#71 | 24.371, 24.229, 26.223 |  |  |  |
| 741 | 270 | **Improvements to CS/PS coordination in UTRAN/GERAN Shared Networks** |  | 573d? | 2014-03-07 A | 2016-05-12 A | 100% |  | 2014-03-07 | 2014-12-10 | 199d? |  |  | S2 | 9768h | 9768h | CSPS_Coord | PCG-32 | Ericsson | roland.gustafsson@ericsson.com | Rel-13 | SP-63 | Stage 2 | Maurice | CSPS_Coord |  |
| 742 | 270.1 | TR on Stage 2 for Improvements to CS/PS coordination in UTRAN/GERAN Shared Networks |  | 140d? | 2014-03-07 A | 2014-09-17 A | 100% |  | 2014-03-07 | 2014-12-10 | 199d? |  | finish no earlier than 2014-09-17 | S2 | 1120h | 1120h | CSPS_Coord-SA2TR | PCG-32 | Ericsson | roland.gustafsson@ericsson.com | Rel-13 | TSG-63 | New TR 23.704 | Maurice |  |  |
| 743 | 270.2 | Stage 2 for Improvements to CS/PS coordination in UTRAN/GERAN Shared Networks |  | 201d? | 2014-03-12 A | 2014-12-12 A | 100% |  | 2014-03-07 | 2014-12-10 | 199d? |  | finish no earlier than 2014-12-12 | S2 | 1608h | 1608h | CSPS_Coord-SA2 | PCG-32 | Ericsson | roland.gustafsson@ericsson.com | Rel-13 | TSG-63 | 23.216, 23.251, 23.272 | Maurice |  |  |
| 744 | 270.3 | RAN aspects for improvements to CS/PS coordination in GERAN Shared Networks |  | 307d? | 2015-03-11 A | 2016-05-12 A | 100% |  |  |  |  |  | finish no earlier than 2016-05-12 | G2 | 2456h | 2456h | CSPS_Coord_GERAN |  | Nicklas Johansson, Ericsson LM | Nicklas.Johansson@Ericsson.com | Rel-13 | GP-65 | 48.008, 48.018 |  |  |  |
| 745 | 271 | **Enhancements to Proximity-based Services** |  | 788d? | 2013-03-18 A | 2016-03-11 A | 100% |  | 2014-06-18 | 2015-06-12 | 258d? |  |  | S1; S2; S3 | 30792h | 27152h | eProSe | PCG-33 | Qualcomm | Eddy Hall (edhall@qti.qualcomm.com) | Rel-13 | SP-64 | Stage 1/2 |  | eProSe | Public Safety (A-A) |
| 746 | 271.1 | Stage 1 for Enhancements to Proximity-based Services |  | 66d? | 2014-06-19 A | 2014-09-17 A | 100% |  | 2014-06-18 | 2014-09-17 | 66d? |  | finish no earlier than 2014-09-17 | S1 | 528h | 528h | eProSe-SA1 | PCG-33 | Qualcomm | Eddy Hall (edhall@qti.qualcomm.com) | Rel-13 | SP-64 | 22.115, 22.278 |  |  | Public Safety (A-A) |
| 747 | 271.2 | Stage 2 for Enhancements to Proximity-based Services - Extensions |  | 326d? | 2014-06-23 A | 2015-09-16 A | 100% |  | 2014-06-18 | 2015-06-12 | 258d? |  | finish no earlier than 2015-09-16 | S2 | 2608h | 2608h | eProSe-Ext-SA2 | PCG-33 | Qualcomm | Haris Zisimopoulos (harisz@qti.qualcomm.com) | Rel-13 | SP-64 | 23.303, TBD |  | eProSe-Ext | Public Safety (A-A) |
| 748 | 271.3 | TR on Stage 2 for Enhancements to Proximity-based Services - Extensions |  | 193d? | 2014-06-18 A | 2015-03-13 A | 100% |  | 2014-06-18 | 2015-03-13 | 193d? |  | finish no earlier than 2015-03-13 | S2 | 1544h | 1544h | eProSe-Ext-SA2TR | PCG-33 | Qualcomm | Haris Zisimopoulos (harisz@qti.qualcomm.com) | Rel-13 | SP-64 | New TR 23.713 |  |  | Public Safety (A-A) |
| 749 | 271.4 | Security for Enhancements to Proximity-based Services - Extensions |  | 388d? | 2014-09-19 A | 2016-03-11 A | 100% |  |  |  |  |  | finish no earlier than 2016-03-11 | S3 | 3104h | 3104h | eProSe-Ext-SA3 | PCG-33 | Qualcomm | Adrian Escott (aescott@qti.qualcomm.com) | Rel-13 | SP-65 | 33.303 |  |  | Public Safety (A-A) |
| 750 | 271.5 | **CT aspects of enhancements to Proximity-based** |  | 195d? | 2015-06-15 A | 2016-03-11 A | 100% |  |  |  |  |  |  | C1 | 7304h | 7304h | eProSe-Ext-CT | PCG-35 | Lena Chaponniere | lguellec@qti.qualcomm.com | Rel-13 | CP-68 | 23.122, 24.301, 24.333, 24.334 |  |  |  |
| 751 | 271.5.1 | CT1 aspects of enhancements to Proximity-based |  | 195d? | 2015-06-15 A | 2016-03-11 A | 100% |  |  |  |  |  | finish no earlier than 2016-03-11 | C1 | 1560h | 1560h | eProSe-Ext-CT | PCG-35 | Lena Chaponniere | lguellec@qti.qualcomm.com | Rel-13 | CP-68 | 29.343 |  |  |  |
| 752 | 271.5.2 | CT3 aspects of enhancements to Proximity-based |  | 133d? | 2015-06-15 A | 2015-12-16 A | 100% |  |  |  |  |  | start no earlier than 2015-06-15 | C3 | 1064h | 1064h | eProSe-Ext-CT | PCG-35 | Lena Chaponniere | lguellec@qti.qualcomm.com | Rel-13 | CP-68 | 23.003, 23.008, 29.272, 29.344, 29.345 |  |  |  |
| 753 | 271.5.3 | CT4 aspects of enhancements to Proximity-based |  | 195d? | 2015-06-15 A | 2016-03-11 A | 100% |  |  |  |  |  | finish no earlier than 2016-03-11 | C4 | 1560h | 1560h | eProSe-Ext-CT | PCG-35 | Lena Chaponniere | lguellec@qti.qualcomm.com | Rel-13 | CP-68 | 31.102, 31.111 |  |  |  |
| 754 | 271.5.4 | CT6 aspects of enhancements to Proximity-based |  | 195d? | 2015-06-15 A | 2016-03-11 A | 100% |  |  |  |  |  | finish no earlier than 2016-03-11 | C6 | 1560h | 1560h | eProSe-Ext-CT | PCG-35 | Lena Chaponniere | lguellec@qti.qualcomm.com | Rel-13 | CP-68 | 31.102, 31.111 |  |  |  |
| 755 | 271.6 | Study on Security for Proximity-based Services |  | 596d? | 2013-03-18 A | 2015-06-17 A | 100% |  | 2013-03-07 | 2014-09-17 | 401d? |  | finish no earlier than 2015-06-17 | S3 | 4768h | 4768h | FS_ProSe_Sec | PCG-30 | Qualcomm | Adrian Escott (aescott@qti.qualcomm.com) | Rel-13 | SP-59 | 33.833 | Mirko | FS_ProSe_Sec | Public Safety (A-A) |
| 756 | 271.7 | Note: Charging Aspects done in Rel-14 under CH14-Prose (UID 720049) | milestone | 0d? | 2015-06-17 A | 2015-06-17 A | 100% |  |  |  |  |  | start no earlier than 2015-06-17 | S5 |  |  | eProSe |  |  |  | Rel-13 |  |  |  |  |  |
| 757 | 272 | **voice over E-UTRAN Paging Policy Differentiation** |  | 133d? | 2014-06-16 A | 2014-12-12 A | 100% |  | 2014-06-16 | 2014-12-10 | 128d? |  |  | S1; S2; C4; C1; C3 | 9244.75h | 9244.75h | voE_UTRAN_PPD | PCG-33 | Alcatel-Lucent | (betsy.covell@alcatel-lucent.com) | Rel-13 | SP-64 | Stage 1/2 |  | voE_UTRAN_PPD |  |
| 758 | 272.1 | Stage 1 for voice over E-UTRAN Paging Policy Differentiation |  | 3d? | 2014-06-16 A | 2014-06-18 A | 100% |  | 2014-06-16 | 2014-06-18 | 3d? |  | finish no earlier than 2014-06-18 | S1 | 24h | 24h | voE_UTRA-N_PPD-SA1 | PCG-33 | Alcatel-Lucent | betsy.covell@alcatel-lucent.com | Rel-13 | SP-64 | 22.228, 22.278 |  |  |  |
| 759 | 272.2 | Stage 2 for voice over E-UTRAN Paging Policy Differentiation |  | 128d? | 2014-06-18 A | 2014-12-12 A | 100% |  | 2014-06-18 | 2014-12-10 | 126d? |  | finish no earlier than 2014-12-12 | S2 | 1024h | 1024h | voE_UTRAN_PPD-SA2 | PCG-33 | Alcatel-Lucent | laurent.thiebaut@alcatel-lucent.com | Rel-13 | SP-64 | 23.228, 23.401 |  |  |  |

Notes:
- 734: 7/12/15: WID:CP-150498->CP-150790->CP-150767
- 735: 7/12/15: 0%->100; 7/12/15: WID:CP-150498->CP-150790->CP-150767
- 736: 7/12/15: WID:CP-150498->CP-150790->CP-150767. ES in CP-150644; 7/3/16: 0%->100
- 737: 7/12/15: WID:CP-150498->CP-150790->CP-150767. ES in CP-150623; 7/3/16: 0%->100
- 738: 7/3/16: Introduced by IETF updates
- 739: 7/3/16: Introduced by IETF updates
- 740: 7/3/16: Introduced by IETF updates
- 741: Provide improvements to the solutions for CS/PS coordination in TS 23.251 to ensure that CS/PS coordination can be achieved for all mobility scenarios
- 742: SP#65 completed. TR 23.704v200 for Approval
- 743: Dec.14: 0->100%
- 744: June2015: Compl:0%->35; 07/09/15: 35%->50, FCD:08/15->11/15; 7/12/15: 50%->95, FCD: 12/15->02/16. 02/03/16: FCD: 02/16->05/16; 13/6/16: 95%->100
- 745: -
- 746: SP#65 completed. Some Rel-12 ProSe service requirements have not been implemented at Stage 2/3 level. These are taken up in Rel-13 Stage 2/3 and need Stage 1 appropriate service requirements. No new service requirements are introduced.
- 747: SP#65 updated WID SP-140385=>SP-140573 (added SA3 part). Mar15: WID: SP-140573 ->SP-150028; June2015: Compl:0%->30. FCD: June->Sept. 07/09/15: 24->70%; 07/09/15: 70%->90; 7/12/15: 90%->100
- 748: SP#65 updated WID SP-140385=>SP-140573 (added SA3 part). Acronym corrected: eProSe-Ex-SA2TRt->eProSe-Ext-SA2TR. Mar15: 60% Mar15: WID: SP-140573 ->SP-150028; June2015: Compl:60%->90; 07/09/15: 90%->95; 07/09/15: 95%->100
- 749: SP#65 updated WID SP-140385=>SP-140573 (added SA3 part). Acronym corrected: eProSe-Ex-SA3t->eProSe-Ext-SA3. Mar15: WID: SP-140573 ->SP-150028; 7/12/15: 0%->75; 10/12/15: FCD ->03/16, ES in SP-150714; 7/3/16: 75%->100
- 751: 07/09/15: 0%->40; 7/12/15: 40%->90. FCD -> 03/16, ES in CP-150724; 7/3/16: 90%->100
- 752: 07/09/15: 0%->60; 8/3/16: 60%->100
- 753: 07/09/15: 0%->10; 7/12/15: 10%->80. FCD->03/16. ES in CP-150616; 7/3/16: 80%->100
- 754: 7/12/15: FCD -> 03/16, ES in CP-150839. FCD->03/16. ES in CP-150616; 7/3/16: 0%->95; 8/3/16: 95%->100
- 755: SP#65 updated WID SP-140300=>SP-140629 (Moved the TR phase to Rel-13 as a stand-alone Study). Completion 09/14=>06/15. SP#64 TR 33.833 v100 for Information. 4/3/15: 95%->70% (more topics to be included); June2015: Compl:70%->75; 7/12/15: 75%->95; 7/3/1
- 757: -
- 758: SP#64 approved WID & completed
- 759: Architectural enhancements allowing a differentiated paging policy for IMS voice calls over E-UTRAN. Dec.14: 25->100%

| ID | WBS | Task | Duration | Start | Finish | Complete | Baseline start | Baseline finish | Baseline duration | Constraint | Resources | Work | Actual work | Acronym | PCG approved | WI rapporteur name | Release | TSG approved | Acronym_3GU_Export |
| --- | --- | --- | --- | --- | --- | --- | --- | --- | --- | --- | --- | --- | --- | --- | --- | --- | --- | --- | --- |
| 760 | 272.3 | **CT aspects of voice over E-UTRAN Paging Policy Differentiation** | 63d? | 2014-09-16 A | 2014-12-09 A | 100% |  |  |  |  | C4; C1; C3 | 3024h | 3024h | voE_UTRAN_PPD-CT | PCG-33 | Alcatel-Lucent | Rel-13 | CP-65 |  |
| 761 | 272.3.1 | CT4 part of CT aspects of voice over E-UTRAN Paging Policy Differentiation | 63d? | 2014-09-16 A | 2014-12-09 A | 100% |  |  |  | finish no earlier than 2014-12-09 | C4 | 504h | 504h | voE_UTRAN_PPD-CT | PCG-33 | Alcatel-Lucent | Rel-13 | CP-65 |  |
| 762 | 272.3.2 | CT1 part of CT aspects of voice over E-UTRAN Paging Policy Differentiation | 63d? | 2014-09-16 A | 2014-12-09 A | 100% |  |  |  | finish no earlier than 2014-12-09 | C1 | 504h | 504h | voE_UTRAN_PPD-CT | PCG-33 | Alcatel-Lucent | Rel-13 | CP-65 |  |
| 763 | 272.3.3 | CT3 part of CT aspects of voice over E-UTRAN Paging Policy Differentiation | 63d? | 2014-09-16 A | 2014-12-09 A | 100% |  |  |  | finish no earlier than 2014-12-09 | C3 | 504h | 504h | voE_UTRAN_PPD-CT | PCG-33 | Alcatel-Lucent | Rel-13 | CP-65 |  |
| 764 | 273 | **IP Flow Mobility support for S2a and S2b Interfaces** | 524d? | 2014-06-18 A | 2016-06-15 A | 100% | 2014-06-18 | 2015-06-17 | 261d? |  | S2 | 15656h | 15656h | NBIFOM | PCG-33 | Tricci So, ZTE | Rel-13 | SP-64 | NBIFOM |
| 765 | 273.1 | TR for IP Flow Mobility support for S2a and S2b Interfaces | 193d? | 2014-06-18 A | 2015-03-13 A | 100% | 2014-06-18 | 2015-03-13 | 193d? | finish no earlier than 2015-03-13 | S2 | 1544h | 1544h | NBIFOM-SA2TR | PCG-33 | Tricci So, ZTE | Rel-13 | SP-64 |  |
| 766 | 273.2 | Stage 2 for IP Flow Mobility support for S2a and S2b Interfaces | 326d? | 2014-06-23 A | 2015-09-16 A | 100% | 2014-06-18 | 2015-06-17 | 261d? | finish no earlier than 2015-09-16 | S2 | 2608h | 2608h | NBIFOM-SA2 |  | Tricci So, ZTE | Rel-13 | TSG-64 |  |
| 767 | 273.3 | Charging Aspects of IP Flow Mobility support for S2a and S2b Interfaces (NBIFOM) | 196d? | 2015-09-16 A | 2016-06-15 A | 100% | 2014-06-18 | 2015-06-17 | 261d? | finish no earlier than 2016-06-15 | S5 | 1568h | 1568h | NBIFOM-CH | PCG-35 | GUO Wenjie, ZTE | Rel-13 | CP-69 |  |
| 768 | 273.4 | **CT aspects of IP Flow Mobility support for S2a and S2b Interfaces** | 195d? | 2015-06-15 A | 2016-03-11 A | 100% |  |  |  |  | C1 | 5744h | 5744h | NBIFOM-CT | PCG-35 | Xingyue(Joy) Zhou, ZTECorporation | Rel-13 | CP-68 |  |
| 769 | 273.4.1 | CT1 aspects of IP Flow Mobility support for S2a and S2b Interfaces | 195d? | 2015-06-15 A | 2016-03-11 A | 100% |  |  |  | finish no earlier than 2016-03-11 | C1 | 1560h | 1560h | NBIFOM-CT | PCG-35 | Xingyue(Joy) Zhou, ZTECorporation. ES in 641 | Rel-13 | CP-68 |  |
| 770 | 273.4.2 | CT3 aspects of IP Flow Mobility support for S2a and S2b Interfaces | 195d? | 2015-06-15 A | 2016-03-11 A | 100% |  |  |  | finish no earlier than 2016-03-11 | C3 | 1560h | 1560h | NBIFOM-CT | PCG-35 | 680001Xingyue(Joy) Zhou, ZTECorporation. ES in 641 | Rel-13 | CP-68 |  |
| 771 | 273.4.3 | CT4 aspects of IP Flow Mobility support for S2a and S2b Interfaces | 133d? | 2015-06-15 A | 2015-12-16 A | 100% |  |  |  | start no earlier than 2015-06-15 | C4 | 1064h | 1064h | NBIFOM-CT | PCG-35 | Xingyue(Joy) Zhou, ZTECorporation | Rel-13 | CP-68 |  |
| 772 | 274 | **Double Resource Reuse for Multiple Media Sessions** | 264d? | 2014-03-14 A | 2015-03-13 A | 100% | 2014-03-14 | 2015-03-13 | 261d? |  | S2 | 5952h | 5952h | DRuMS | PCG-33 | Ericsson | Rel-13 | SP-64 | DRuMS |
| 773 | 274.1 | Stage 2 for Double Resource Reuse for Multiple Media Sessions | 264d? | 2014-03-14 A | 2015-03-13 A | 100% | 2014-03-14 | 2015-03-13 | 261d? | finish no earlier than 2015-03-13 | S2 | 2088h | 2088h | DRuMS-SA2 | PCG-33 | Ericsson | Rel-13 | SP-64 |  |
| 774 | 274.2 | **CT aspects of Double Resource Reuse for Multiple Media Sessions** | 73d? | 2014-12-03 A | 2015-03-13 A | 100% |  |  |  |  | C3 | 1752h | 1752h | DRuMS-CT | PCG-34 | Ericsson | Rel-13 | CT-66 |  |
| 775 | 274.2.1 | CT1 aspects of Double Resource Reuse for Multiple Media Sessions | 73d? | 2014-12-03 A | 2015-03-13 A | 100% |  |  |  | start no earlier than 2014-12-03 | C1 | 584h | 584h | DRuMS-CT | PCG-34 | Ericsson | Rel-13 | CT-66 |  |
| 776 | 274.2.2 | CT3 aspects of Double Resource Reuse for Multiple Media Sessions | 73d? | 2014-12-03 A | 2015-03-13 A | 100% |  |  |  | start no earlier than 2014-12-03 | C3 | 584h | 584h | DRuMS-CT | PCG-34 | Ericsson | Rel-13 | CT-66 |  |
| 777 | 275 | Lawful Interception in the 3GPP Rel-13 | 656d? | 2014-06-18 A | 2016-12-15 A | 100% | 2014-06-18 | 2015-12-09 | 386d? | finish no earlier than 2016-12-15 | S3 | 5248h | 5248h | LI13 | PCG-33 | PIDS, Alcatel-Lucent | Rel-13 | SP-64 | LI13 |
| 778 | 276 | STOPPED - Study on Lawful Interception Service Evolution | 386d? | 2014-06-23 A | 2015-12-09 A | 100% | 2014-06-18 | 2015-12-09 | 386d? | finish no earlier than 2015-12-09 | S3 | 3088h | 3088h | FS_LISE | PCG-33 | Alcatel-Lucent | Rel-13 | SP-64 | FS_LISE |
| 779 | 277 | **Video enhancements by Region-Of-Interest information signalling** | 394d? | 2014-06-18 A | 2015-12-16 A | 100% | 2014-06-18 | 2015-06-17 | 261d? |  | S4 | 10016h | 10016h | ROI | PCG-33 | Intel | Rel-13 | SP-64 | ROI |
| 780 | 277.1 | SA4 aspects of Video enhancements by Region-Of-Interest information signalling | 329d? | 2014-06-18 A | 2015-09-16 A | 100% |  |  |  | finish no earlier than 2015-09-16 | S4 | 2632h | 2632h | ROI | PCG-33 | Intel | Rel-13 | SP-64 |  |
| 781 | 277.2 | **CT Aspects of Video Enhancements by Region-Of-Interest information signalling** | 133d? | 2015-06-15 A | 2015-12-16 A | 100% |  |  |  |  | C4 | 4256h | 4256h | ROI-CT | PCG-35 | Vivek Gupta, Intel | Rel-13 | CP-68 |  |
| 782 | 277.2.1 | CT1 Aspects of Video Enhancements by Region-Of-Interest information signalling | 133d? | 2015-06-15 A | 2015-12-16 A | 100% |  |  |  | start no earlier than 2015-06-15 | C1 | 1064h | 1064h | ROI-CT | PCG-35 | Vivek Gupta, Intel | Rel-13 | CP-68 |  |
| 783 | 277.2.2 | CT3 Aspects of Video Enhancements by Region-Of-Interest information signalling | 133d? | 2015-06-15 A | 2015-12-16 A | 100% |  |  |  | start no earlier than 2015-06-15 | C3 | 1064h | 1064h | ROI-CT | PCG-35 | Vivek Gupta, Intel | Rel-13 | CP-68 |  |
| 784 | 277.2.3 | CT4 Aspects of Video Enhancements by Region-Of-Interest information signalling | 133d? | 2015-06-15 A | 2015-12-16 A | 100% |  |  |  | start no earlier than 2015-06-15 | C4 | 1064h | 1064h | ROI-CT | PCG-35 | Vivek Gupta, Intel | Rel-13 | CP-68 |  |

Notes:
- 760: Stage 3 / Impacted TSs and TRs: Stage 3 / WI rapporteur e-mail: bruno.landais@alcatel-lucent.com
- 761: Mar.15: 0->100% / Impacted TSs and TRs: 29.274, 29.281 / WI rapporteur e-mail: bruno.landais@alcatel-lucent.com
- 762: Dec.14: 0->50%; 07/09/15: 50%->50; 7/12/15: 50%->100 / Impacted TSs and TRs: 24.229 / WI rapporteur e-mail: bruno.landais@alcatel-lucent.com
- 763: Mar.15: 0->100% / Impacted TSs and TRs: 29.061 / WI rapporteur e-mail: bruno.landais@alcatel-lucent.com
- 764: 06/15: WID: SP-140279->SP-150250 / Impacted TSs and TRs: Stage 2 / WI rapporteur e-mail: tso@zte.com.cn
- 765: Revived the Rel-12 DRAFT TR 23.861 stopped at SP#59 (at 40% completion). Dec.14: 20->60%; June2015: Compl:60%->90, WID: SP-140279->SP-150250 / Impacted TSs and TRs: New TR 23.861 / WI rapporteur e-mail: tso@zte.com.cn
- 766: June2015: Compl:0%->65, WID: SP-140279->SP-150250; 07/09/15: 52%->100 / Impacted TSs and TRs: 23.402, New TS 23.203 / WI rapporteur e-mail: tso@zte.com.cn
- 767: 7/12/15: 0%->50. ES in SP-150710 (wrong UID mentioned in the ES); 7/3/16: 50%->85%, FCD:03/16->06/16; 13/6/16: 85%->100 / Impacted TSs and TRs: 32.251, 32.298, 32.299 / WI rapporteur e-mail: guo.wenjie1@zte.com.cn
- 768: 14/09/15: WID:CP-150285->CP-150497; 7/12/15: WID:CP-150497->CP-150791->874 / Impacted TSs and TRs: 24.161 / WI rapporteur e-mail: zhou.xingyue@zte.com.cn
- 769: 07/09/15: 0%->25; 14/09/15: WID:CP-150285->CP-150497; 7/12/15: 25%->75; 7/12/15: WID:CP-150497->CP-150791->874. FCD -> 03/16. ES in CP-150725; 7/3/16: 75%->100 / Impacted TSs and TRs: 24.301, 24.302, 24.244, 24.008 / WI rapporteur e-mail: zhou.xingyue@zte.com.cn
- 770: 07/09/15: 0%->40; 14/09/15: WID:CP-150285->CP-150497; 7/12/15: 40%->95; 7/12/15: WID:CP-150497->CP-150791->874. FCD -> 03/16. ES in CP-150725; 7/3/16: 95%->100 / Impacted TSs and TRs: 29.212, 29.213, 29.214, 29.215 / WI rapporteur e-mail: zhou.xingyue@zte.com.cn
- 771: 07/09/15: 0%->20; 14/09/15: WID:CP-150285->CP-150497; 7/12/15: 20%->100; 7/12/15: WID:CP-150497->CP-150791->874 / Impacted TSs and TRs: 29.274, 23.008 / WI rapporteur e-mail: zhou.xingyue@zte.com.cn
- 772: - / Impacted TSs and TRs: Stage 2 / WI rapporteur e-mail: George.Foti@ericsson.com
- 773: Dec.14: 49->95%. Mar15: 100% / Impacted TSs and TRs: 23.203, 23.228 / WI rapporteur e-mail: George.Foti@ericsson.com
- 774: Impacted TSs and TRs: 24.229, 24.615, 24.610, 24.605, 29.212, 29.213, 29.214, 29.215
- 775: 5/5/15: C3 corrected in C1; June2015: Compl:65%->90; 07/09/15: 90%->100 / Impacted TSs and TRs: 24.229, 24.615, 24.610, 24.605
- 776: Mar.15: 65->95%; June2015: Compl:95%->100 / Impacted TSs and TRs: 29.212, 29.213, 29.214, 29.215 / WI rapporteur e-mail: Jan Holm
- 777: SP#65 updated WID SP-140400=>SP-140578. 2/4/15: WID SP-140815->SP-150111; June2015: Compl:0%->10. WID: SP-150111->SP-150290; 14/09/15: WID:SP-150290->SP-150460; 7/12/15: 10%->15; 7/3/16: 13%->20; 7/3/16: WID:SP-150460->SP-160043; 19/9/16: 20%->60. FCD / Impacted TSs and TRs: 33.106, 33.107, 33.108 / WI rapporteur e-mail: Koen Jaspers (k.b.jaspers@minjus.nl), terry.jacobson@alcatel-lucent.com
- 778: Linked to LI13 which defines existing LI service requirements in TS 33.106 as well as existing HI1, HI2 & HI3 reference points. 3/3/15: 0->5%; 7/12/15: 5%->10. Stoppped at 10% in March 2017.; 6/3/17: 10%->100 / Impacted TSs and TRs: 33.826 / WI rapporteur e-mail: terry.jacobson@alcatel-lucent.com
- 779: Dec.14: 5->20%. Mar.15: 40%; 07/09/15: 43%->100 / Impacted TSs and TRs: 26.114 / WI rapporteur e-mail: ozgur.oyman@intel.com
- 780: Created by MCC as the structure of the Feature get expanded to include CT aspects; June2015: Compl:40%->90, FCD: 06/15->09/15; Aug2015: Compl:90%->95 / Impacted TSs and TRs: 26.114 / WI rapporteur e-mail: ozgur.oyman@intel.com
- 781: 14/09/15: WID:CP-150241->CP-150425 / WI rapporteur e-mail: vivek.g.gupta@intel.com
- 782: 07/09/15: 100%->50; 14/09/15: WID:CP-150241->CP-150425; 7/12/15: 50%->100 / Impacted TSs and TRs: 24.229 / WI rapporteur e-mail: vivek.g.gupta@intel.com
- 783: 07/09/15: 100%->10; 14/09/15: WID:CP-150241->CP-150425; 7/12/15: 10%->100 / Impacted TSs and TRs: 29.162 / WI rapporteur e-mail: vivek.g.gupta@intel.com
- 784: 07/09/15: 100%->5; 14/09/15: WID:CP-150241->CP-150425; 7/12/15: 5%->100 / Impacted TSs and TRs: 23.334, 29.334, 29.238 / WI rapporteur e-mail: vivek.g.gupta@intel.com

| ID | WBS | Task | Duration | Start | Finish | Complete | Remaining | Baseline start | Baseline finish | Baseline duration | Total slack | Constraint | Resources | Work | Actual work | Acronym | PCG approved | WI rapporteur name | Release | TSG approved | Acronym_3GU_Export | Status Report | MCC resp |
| --- | --- | --- | --- | --- | --- | --- | --- | --- | --- | --- | --- | --- | --- | --- | --- | --- | --- | --- | --- | --- | --- | --- | --- |
| 785 | 278 | **TV video profile** | 396d? | 2014-09-09 A | 2016-03-11 A | 100% |  |  |  |  |  |  | S4 | 9504h | 9504h | TVProf | PCG-33 | Orange | Rel-13 | SP-65 | TVProf |  |  |
| 786 | 278.1 | TR on TV video profile | 396d? | 2014-09-09 A | 2016-03-11 A | 100% |  |  |  |  |  | finish no earlier than 2016-03-11 | S4 | 3168h | 3168h | TVProf-SA4TR | PCG-33 | Orange | Rel-13 | SP-65 |  |  |  |
| 787 | 278.2 | Specification on TV video profile | 396d? | 2014-09-09 A | 2016-03-11 A | 100% |  |  |  |  |  | finish no earlier than 2016-03-11 | S4 | 3168h | 3168h | TVProf-SA4 | PCG-33 | Orange | Rel-13 | SP-65 |  |  |  |
| 788 | 279 | Enhanced LTE UE Delay test methods and requirements | 464d? | 2014-09-09 A | 2016-06-15 A | 100% |  |  |  |  |  | finish no earlier than 2016-06-15 | S4 | 3712h | 3712h | E_LTE_UED | PCG-33 | Orange | Rel-13 | SP-65 | E_LTE_UED |  |  |
| 789 | 280 | HTML5 Presentation Layer | 334d? | 2014-09-09 A | 2015-12-16 A | 100% |  |  |  |  |  | finish no earlier than 2015-12-16 | S4 | 2672h | 2672h | HTML5 | PCG-33 | Samsung | Rel-13 | SP-65 | HTML5 |  |  |
| 790 | 281 | **Support of EVS in 3G Circuit-Switched networks** | 396d? | 2014-09-09 A | 2016-03-11 A | 100% |  |  |  |  |  |  | S4; C4; C1; C3; R1; R2; R3 | 42757.6h | 24952h | EVSoCS | PCG-33 | Qualcomm | Rel-13 | SP-65 | EVSoCS |  |  |
| 791 | 281.1 | SA4 aspects of EVS in 3G Circuit-Switched networks | 396d? | 2014-09-09 A | 2016-03-11 A | 100% |  |  |  |  |  | finish no earlier than 2016-03-11 | S4 | 3168h | 3168h | EVSoCS-S4 | PCG-33 | Qualcomm | Rel-13 | SP-65 | EVSoCS |  |  |
| 792 | 281.2 | **CT aspects of EVS in 3G Circuit-Switched Networks** | 268d? | 2015-03-04 A | 2016-03-11 A | 100% |  |  |  |  |  |  | C4; C1; C3 | 12344h | 12344h | EVSoCS-CT | PCG-34 | Qualcomm, Lena Chaponniere | Rel-13 | CP-67 |  |  |  |
| 793 | 281.2.1 | CT1 aspects of EVS in 3G Circuit-Switched Networks | 203d? | 2015-03-04 A | 2015-12-11 A | 100% |  |  |  |  |  | finish no earlier than 2015-12-11 | C1 | 1624h | 1624h | EVSoCS-CT | PCG-34 | Qualcomm, Lena Chaponniere | Rel-13 | CP-67 |  |  |  |
| 794 | 281.2.2 | CT3 aspects of EVS in 3G Circuit-Switched Networks | 268d? | 2015-03-04 A | 2016-03-11 A | 100% |  |  |  |  |  | finish no earlier than 2016-03-11 | C3 | 2144h | 2144h | EVSoCS-CT | PCG-34 | Qualcomm, Lena Chaponniere | Rel-13 | CP-67 |  |  |  |
| 795 | 281.2.3 | CT4 aspects of EVS in 3G Circuit-Switched Networks | 268d? | 2015-03-04 A | 2016-03-11 A | 100% |  |  |  |  |  | finish no earlier than 2016-03-11 | C4 | 2144h | 2144h | EVSoCS-CT | PCG-34 | Qualcomm, Lena Chaponniere | Rel-13 | CP-67 |  |  |  |
| 796 | 281.3 | **Support of EVS over UTRAN CS** | 130.67d? | 2015-06-16 A | 2015-12-15 A | 100% |  |  |  |  |  |  | R2; R1; R3 | 6272h | 6272h | EVSoCS_UTRAN | PCG-34 | Qualcomm | Rel-13 | RP-66 |  |  |  |
| 797 | 281.3.1 | Core part: Support of EVS over UTRAN CS | 130.67d? | 2015-06-16 A | 2015-12-15 A | 100% |  |  |  |  |  | finish no earlier than 2015-12-15 | R2; R1; R3 | 3136h | 3136h | EVSoCS_UTRAN-Core | PCG-34 | Francesco Pica - Qualcomm Incorporated | Rel-13 | RP-66 |  | RP-151282 |  |
| 798 | 282 | Enhanced DASH (Dynamic Adaptive Streaming over HTTP in 3GPP) | 334d? | 2014-09-09 A | 2015-12-16 A | 100% |  |  |  |  |  | finish no earlier than 2015-12-16 | S4 | 2672h | 2672h | eDASH | PCG-33 | Qualcomm, Huawei | Rel-13 | SP-65 | eDASH |  |  |
| 799 | 283 | **QoS End-to-end Multimedia Telephony Service for IMS (MTSI) extensions (Stage 3)** | 796d? | 2013-03-06 A | 2016-03-11 A | 100% |  | 2013-03-06 | 2015-03-13 | 533d? |  |  | S4; C3; C1; C4 | 53457.8h | 53457.8h | QOSE2EMTSI | PCG-30 | Ericsson | Rel-13 | SP-59 | QOSE2EMTSI |  | Paolo |
| 800 | 283.1 | TR on improved end-to-end QoS handling for MTSI | 589d? | 2013-12-11 A | 2016-03-11 A | 100% |  | 2013-12-11 | 2015-03-13 | 329d? |  | finish no earlier than 2016-03-11 | S4 | 4705.83h | 4705.83h | QOSE2EMTSI | PCG-32 | Ericsson | Rel-13 | SP-62 |  |  | Paolo |
| 801 | 283.2 | SA4 part of QoS End-to-end Multimedia Telephony Service for IMS (MTSI) extensions (Stage 3) | 792d? | 2013-03-06 A | 2016-03-11 A | 100% |  | 2013-03-06 | 2015-03-13 | 532d? |  | finish no earlier than 2016-03-11 | S4 | 6336h | 6336h | QOSE2EMTSI | PCG-30 | Ericsson | Rel-13 | SP-59 |  |  | Paolo |
| 802 | 283.3 | **CT Aspects of QoS End-to-End MTSI Extensions** | 353d? | 2014-11-05 A | 2016-03-11 A | 100% |  |  |  |  |  |  | C3; C1; C4 | 16944h | 16944h | QOSE2EMTSI-CT | PCG-34 | Ericsson | Rel-13 | CP-66 |  |  |  |
| 803 | 283.3.1 | CT3 Aspects of QoS End-to-End MTSI Extensions | 353d? | 2014-11-05 A | 2016-03-11 A | 100% |  |  |  |  |  | finish no earlier than 2016-03-11 | C3 | 2824h | 2824h | QOSE2EMTSI-CT | PCG-34 | Ericsson | Rel-13 | CP-66 |  |  |  |
| 804 | 283.3.2 | CT1 Aspects of QoS End-to-End MTSI Extensions | 353d? | 2014-11-05 A | 2016-03-11 A | 100% |  |  |  |  |  | finish no earlier than 2016-03-11 | C1 | 2824h | 2824h | QOSE2EMTSI-CT | PCG-34 | Ericsson | Rel-13 | CP-66 |  |  |  |
| 805 | 283.3.3 | CT4 Aspects of QoS End-to-End MTSI Extensions | 353d? | 2014-11-05 A | 2016-03-11 A | 100% |  |  |  |  |  | finish no earlier than 2016-03-11 | C4 | 2824h | 2824h | QOSE2EMTSI-CT | PCG-34 | Ericsson | Rel-13 | CP-66 |  |  |  |
| 806 | 284 | **MTSI Extension on Multi-stream Multiparty** | 322d? | 2014-12-12 A | 2016-03-07 | 83% | 53.53d? |  |  |  | 729d |  | S4 | 5752h | 5216.24h | MMCMH | PCG-34 | Tomas Frankkila, Ericsson LM | Rel-13 | SP-66 |  |  |  |
| 807 | 284.1 | Codec aspects for MMCMH | 265d? | 2014-12-12 A | 2015-12-17 A | 100% |  |  |  |  |  | finish no earlier than 2015-12-17 | S4 | 2120h | 2120h | MMCMH | PCG-34 | Tomas Frankkila, Ericsson LM | Rel-13 | SP-66 |  |  |  |
| 808 | 284.2 | (IETF) RTP Stream Pause and Resume (RFC 7728) | 66d? | 2015-12-07 A | 2016-03-07 A | 100% |  |  |  |  |  | finish no earlier than 2016-03-07 | S4-IETF | 528h | 528h | MMCMH | PCG-36 | Ericsson | Rel-13 | TSG#71 |  |  |  |
| 809 | 284.3 | (IETF) draft-ietf-mmusic-sdp-simulcast | 66d? | 2015-12-07 | 2016-03-07 |  |  |  |  |  | 729d | start no earlier than 2015-12-07 | S4-IETF | 528h |  | MMCMH | PCG-37 |  | Rel-13 | TSG#72 |  |  |  |

Notes:
- 785: Mar. 15: 5->15% / WI rapporteur e-mail: gilles.teniou@orange.com
- 786: Dec.14: 0->5%; June2015: Compl:15%->30; Aug2015: 30%->45; 07/09/15: 45%->70; 7/12/15: 70%->85, FCD: 12/15->03/16; 7/3/16: 85%->100 / Impacted TSs and TRs: New TR 26.9xy. ES in SP-150650 / WI rapporteur e-mail: gilles.teniou@orange.com
- 787: Dec.14: 0->5%; June2015: Compl:15%->30; Aug2015: 30%->45; 07/09/15: 45%->70; 7/12/15: 70%->85, FCD: 12/15->03/16. ES in SP-150650; 7/3/16: 85%->100 / Impacted TSs and TRs: 26.234, 26.244, 26.346, 26.247, New TS 26.xyz. ES in SP-150650 / WI rapporteur e-mail: gilles.teniou@orange.com
- 788: Mar. 15: 0->5%; June2015: Compl:5%->10; Aug2015: 10%->15; 07/09/15: 15%->50; 7/12/15: 50%->80, FCD: 12/15->03/16. ES in SP-150652; 7/3/16: FCD: 03/16->06/16; 11/6/16: 80%->100 / Impacted TSs and TRs: 26.131, 26.132 / WI rapporteur e-mail: stephane.ragot@orange.com
- 789: Triggered by Rel-12 TR 26.907 (Study of HTML5 and 3GPP User Services). Dec.14: 0->5%. Mar. 15: 10%; June2015: Compl:10%->20; Aug2015: 20%->40; 07/09/15: 40%->70; 7/12/15: 70%->100 / Impacted TSs and TRs: 26.140, 26.234, 26.247, 26.346, New TS 26.xyz / WI rapporteur e-mail: Imed Bouazizi (i.bouazizi@samsung.com)
- 790: Provide CS support of EVS to enhance voice quality in CS services over UTRAN (3G WCDMA). Dec.14: 0->5%; 28/1/16: 26.454 added; 28/1/16: 26.453 added; / Impacted TSs and TRs: 26.103, 28.062, New TS 26.454; New TS 26.453 / WI rapporteur e-mail: Imre Varga (ivarga@qti.qualcomm.com)
- 791: Created by MCC (duplicated from previously single-line Feature) due to the introduction of the CT BB. Mar. 15: 10%; Aug2015: 10%->20; 07/09/15: 20%->40; 7/12/15: 40%->60, FCD:12/15->03/16. ES in SP-150655; 28/1/16: 26.454 added; 28/1/16: 26.453 added; / Impacted TSs and TRs: 26.103, 28.062, New TS 26.454; New TS 26.453 / WI rapporteur e-mail: Imre Varga (ivarga@qti.qualcomm.com)
- 792: WI rapporteur e-mail: lguellec@qti.qualcomm.com
- 793: 07/09/15: 0%->90; 7/12/15: 90%->100 / Impacted TSs and TRs: 24.008 / WI rapporteur e-mail: lguellec@qti.qualcomm.com
- 794: June2015: Compl:0%->10; 07/09/15: 10%->15; 7/12/15: 15%->90. FCD -> 03/16, ES in CP-150638; 7/3/16: 90%->100 / Impacted TSs and TRs: 29.163, 29.414, 29.415 / WI rapporteur e-mail: lguellec@qti.qualcomm.com
- 795: June2015: Compl:0%->95. FCD -> 03/16, ES in CP-150618; 7/3/16: 95%->100 / Impacted TSs and TRs: 23.153, 23.334, 29.002, 29.231, 29.232, 29.332, 29.334 / WI rapporteur e-mail: lguellec@qti.qualcomm.com
- 796: WI rapporteur e-mail: Qualcomm
- 797: Rapporteur details and involved WGs updated 1st Apr 15: Compl:0%->10% 1st Apr 15: Stat Rep: ->RP-150128. 5/5/15: 0->10% 03/07/15: Compl:10%->25% 03/07/15: Stat Rep: RP-150128->RP-150759 29/09/15: Compl:25%->50% 29/09/15: CD:Tue 15/09/15->Tue 15/12/15 2 / WI rapporteur e-mail: fpica@qti.qualcomm.com
- 798: Triggered by Rel-12 Dec.14: 0->10%. Mar. 15: 15%; June2015: Compl:15%->25. WID updated; Aug2015: 25%->30; 07/09/15: 30%->60; 14/09/15: WID:SP-150211->SP-150448; 7/12/15: 60%->100 / Impacted TSs and TRs: 26.233, 26.234, 26.244, 26.247, 26.938, TS 26.346, TR 26.946 / WI rapporteur e-mail: Thomas Stockhammer (tsto@qti.qualcomm.com), Li Zhiming (lizhiming@huawei.com)
- 799: SP#65 updated WID SP-130670=>SP-140601 (moved work from Rel-12 incl. new TR to Rel-13). Co-ordinate with SA2, CT1/3/4, IETF MMUSIC. Linked to SA4 Rel-7 Media handling and interaction in MTSI (MTSI-MHI) UID_7040 / WI rapporteur e-mail: tomas.frankkila@ericsson.com
- 800: SP#65 updated WID SP-130670=>SP-140601 (moved work from Rel12 incl. new TR to Rel-13). Completion 03/15=>06/15. Mar15: 26.924 for info. 8/4/15: 50%; Aug2015: 50%->60; 7/12/15: 75%->90, FCD: 06/15->03/16; 7/3/16: 90%->100 / Impacted TSs and TRs: new TR 26.924 / WI rapporteur e-mail: tomas.frankkila@ericsson.com
- 801: SP#65: WID SP-130670=>SP-140601 (moved from Rel12 incl. new TR to Rel-13). FCD 03/15=>06/15. St1 in TS 22.173. 12/14: 70->40%, CD: 06/15->09/15. 03/15: 50%. June 15: FCD: 09/15->12/15; 08/15: 60%; 09/15: 75%; 7/12. ES in SP-150658; 7/3/16: 90%->100 / Impacted TSs and TRs: 26.114 / WI rapporteur e-mail: tomas.frankkila@ericsson.com
- 803: 7/12/15: 0%->70. FCD -> 03/16, ES in CP-150636; 7/3/16: 70%->100 / Impacted TSs and TRs: 29.162, 29.163, 29.213, 29.214
- 804: FCD -> 03/16, ES in CP-150726; 7/3/16: 0%->100 / Impacted TSs and TRs: 24.229
- 805: FCD -> 03/16, ES in CP-150620; 7/3/16: 0%->100 / Impacted TSs and TRs: 23.333, 23.334, 29.238, 29.332, 29.333, 29.334
- 806: Mar. 15: 0->10%. WID: SP-140738->SP-150097; June2015: Compl:10%->30; Aug2015: 30%->50, FCD: sep->Dec 2015; 07/09/15: 50%->60; 7/12/15: 60%->100; 10/12/15: WID:SP-150097->SP-150660. Might be moved to Rel-14 (see note in UID710002) / Impacted TSs and TRs: 26.114, New TR 26.980 / WI rapporteur e-mail: tomas.frankkila@ericsson.com
- 807: Introduced by MCC to dissociate S4 from IeTF aspects / Impacted TSs and TRs: 26.114, New TR 26.980 / WI rapporteur e-mail: tomas.frankkila@ericsson.com
- 808: 02/2016: published as RFC 7728 / Impacted TSs and TRs: (IETF) RTP Stream Pause and Resume (RFC 7728) / WI rapporteur e-mail: tomas.frankkila@ericsson.com

| ID | WBS | Task | Duration | Start | Finish | Complete | Remaining | Baseline start | Baseline finish | Baseline duration | Total slack | Constraint | Resources | Work | Actual work | Acronym | PCG approved | Release | TSG approved | MCC resp | Special Focus Doc | Acronym_3GU_Export |
| --- | --- | --- | --- | --- | --- | --- | --- | --- | --- | --- | --- | --- | --- | --- | --- | --- | --- | --- | --- | --- | --- | --- |
| 810 | 285 | **Video Telephony Robustness Improvements Extensions** | 196d? | 2014-12-12 A | 2015-09-11 | 70% | 58.8d? |  |  |  | 855d |  | S4 | 6272h | 4390.4h | VTRI_EXT | PCG-34 | Rel-13 | SP-66 |  |  |  |
| 811 | 285.1 | TR on Video Telephony Robustness Improvements | 196d? | 2014-12-12 A | 2015-09-11 A | 100% |  |  |  |  |  | finish no earlier than 2015-09-11 | S4 | 1568h | 1568h | VTRI_EXT | PCG-34 | Rel-13 | SP-66 |  |  |  |
| 812 | 285.2 | Specification on Video Telephony Robustness Improvements | 196d? | 2014-12-12 A | 2015-09-11 A | 100% |  |  |  |  |  | finish no earlier than 2015-09-11 | S4 | 1568h | 1568h | VTRI_EXT | PCG-34 | Rel-13 | SP-66 |  |  |  |
| 813 | 285.3 | (IETF) RTP Payload Format for Non-Interleaved and Interleaved Parity Forward Error Correction (FEC) (draft-ietf-payload-flexible-fec-scheme) | 196d? | 2014-12-12 A | 2015-09-11 | 10% | 176.4d? |  |  |  | 855d | finish no earlier than 2015-09-11 | S4-IETF | 1568h | 156.8h | VTRI_EXT | PCG-35 | Rel-13 | CP-69 |  |  |  |
| 814 | 286 | Acoustic Test methods and Performance Objectives for Speakerphone Performance in Noisy Environments | 326d? | 2014-12-12 A | 2016-03-11 A | 100% |  |  |  |  |  | finish no earlier than 2016-03-11 | S4 | 2608h | 2608h | ATeMPO_SPINE | PCG-34 | Rel-13 | SP-66 |  |  |  |
| 815 | 287 | **Rel-13 Operations, Administration, Maintenance and Provisioning (OAM&P)** | 985d? | 2012-06-20 A | 2016-03-11 A | 100% |  | 2014-09-17 | 2015-12-11 | 323d? |  |  | S5 | 57504h | 57504h | OAM13 | PCG-32 | Rel-13 | SP-63 | Mirko | SON | OAM13 |
| 816 | 287.1 | Enhanced Network Management (NM) centralized Coverage and Capacity Optimization | 319d? | 2014-09-19 A | 2015-12-11 A | 100% |  | 2014-09-17 | 2015-12-11 | 319d? |  | finish no earlier than 2015-12-11 | S5 | 2552h | 2552h | SON-NM-CCO | PCG-29 | Rel-13 | SP-56 | Mirko | SON | SON-NM-CCO |
| 817 | 287.2 | **Compliance of 3GPP SA5 specifications to the NGMN Top Operational Efficiency (OPE) Recommendations** | 728d? | 2012-06-20 A | 2015-03-18 A | 100% |  | 2012-06-20 | 2014-09-17 | 595d? |  |  | S5 | 17368h | 17368h | OAM-NGMN_OPE | PCG-29 | Rel-13 | SP-56 | Mirko |  | OAM-NGMN_OPE |
| 818 | 287.2.1 | TR on Compliance of 3GPP SA5 specifications to the NGMN Top Operational Efficiency (OPE) Recommendations | 723d? | 2012-06-20 A | 2015-03-18 A | 100% |  | 2012-06-20 | 2014-09-17 | 593d? |  | finish no earlier than 2015-03-18 | S5 | 5784h | 5784h | OAM-NGMN_OPE | PCG-29 | Rel-13 | SP-56 | Mirko |  |  |
| 819 | 287.2.2 | TS work on Compliance of 3GPP SA5 specifications to the NGMN Top Operational Efficiency (OPE) Recommendations | 720d? | 2012-06-25 A | 2015-03-18 A | 100% |  | 2012-06-25 | 2014-09-17 | 590d? |  | finish no earlier than 2015-03-18 | S5 | 5760h | 5760h | OAM-NGMN_OPE | PCG-29 | Rel-13 | SP-56 | Mirko |  |  |
| 820 | 287.3 | Converged management Performance Management Interface Definitions | 910d? | 2012-06-20 A | 2015-12-11 A | 100% |  | 2012-06-20 | 2014-09-17 | 588d? |  | finish no earlier than 2015-12-11 | S5 | 7280h | 7280h | OAM-PMID | PCG-29 | Rel-13 | SP-56 | Mirko |  | OAM-PMID |
| 821 | 287.4 | **WLAN Management** | 788d? | 2012-06-27 A | 2015-06-17 A | 100% |  | 2012-06-20 | 2014-09-17 | 595d? |  |  | S5 | 18848h | 18848h | WLAN-OAM | PCG-29 | Rel-13 | SP-56 | Mirko | WLAN | WLAN-OAM |
| 822 | 287.4.1 | WLAN Network Resource Model for Type-2 interface | 784d? | 2012-06-27 A | 2015-06-17 A | 100% |  | 2012-06-27 | 2014-09-17 | 589d? |  | finish no earlier than 2015-06-17 | S5 | 6272h | 6272h | WLAN-OAM-SA5 | PCG-29 | Rel-13 | SP-56 | Mirko | WLAN |  |
| 823 | 287.4.2 | WLAN measurements defined in IEEE and IETF WLAN performance measurements for use on Type-2 interface | 784d? | 2012-06-27 A | 2015-06-17 A | 100% |  | 2012-06-27 | 2014-09-17 | 589d? |  | finish no earlier than 2015-06-17 | S5 | 6272h | 6272h | WLAN-OAM-SA5ietf | PCG-29 | Rel-13 | SP-56 | Mirko | WLAN |  |
| 824 | 287.5 | Energy Efficiency related Performance Measurements | 713d? | 2013-06-21 A | 2016-03-11 A | 100% |  | 2013-06-21 | 2014-09-17 | 326d? |  | finish no earlier than 2016-03-11 | S5 | 5704h | 5704h | OAM-PM_EE | PCG-31 | Rel-13 | SP-60 | Mirko |  | OAM-PM_EE |
| 825 | 287.6 | Multi-Broadcast Single Frequency Network (MBSFN) Minimization of Drive Tests (MDT) enhancement | 1d? | 2014-12-12 A | 2014-12-12 A | 100% |  |  |  |  |  | start no earlier than 2014-12-12 | S5 | 8h | 8h | MBSFN_MDT | PCG-34 | Rel-13 | SP-66 |  |  |  |
| 826 | 288 | **Rel-13 Charging** | 393d? | 2014-06-19 A | 2015-12-16 A | 100% |  | 2014-06-18 | 2015-12-09 | 386d? |  |  | S5 | 16236h | 16236h | CH13 | PCG-33 | Rel-13 | SP-64 |  |  | CH13 |
| 827 | 288.1 | **Inter-PLMN PS domain online charging** | 393d? | 2014-06-19 A | 2015-12-16 A | 100% |  | 2014-06-18 | 2015-12-09 | 386d? |  |  | S5 | 8360h | 8360h | iPLMN-PS-OCH | PCG-33 | Rel-13 | SP-64 |  |  | iPLMN-PS-OCH |
| 828 | 288.1.1 | TR on Inter-PLMN PS domain online charging | 261d? | 2014-06-19 A | 2015-06-17 A | 100% |  | 2014-06-18 | 2015-06-17 | 261d? |  | finish no earlier than 2015-06-17 | S5 | 2088h | 2088h | iPLMN-PS-OCH | PCG-33 | Rel-13 | SP-64 |  |  |  |
| 829 | 288.1.2 | Specification of Inter-PLMN PS domain online charging | 391d? | 2014-06-23 A | 2015-12-16 A | 100% |  | 2014-06-18 | 2015-12-09 | 386d? |  | finish no earlier than 2015-12-16 | S5 | 3128h | 3128h | iPLMN-PS-OCH | PCG-33 | Rel-13 | SP-64 |  |  |  |
| 830 | 288.2 | ULI and release causes for charging enhancement for VoLTE | 257d? | 2014-12-12 A | 2015-12-07 A | 100% |  |  |  |  |  | finish no earlier than 2015-12-07 | S5 | 2056h | 2056h | ULRELC-CH | PCG-34 | Rel-13 | SP-66 |  |  |  |
| 831 | 288.3 | Charging on enhancements for IMS Service Continuity | 135d? | 2015-03-05 A | 2015-09-09 A | 100% |  |  |  |  |  | finish no earlier than 2015-12-11 | S5 | 1080h | 1080h | CHeISC | PCG-34 | Rel-13 | SP-67 |  |  |  |
| 832 | 288.4 | Announcements for IMS Online Charging | 131d? | 2015-06-15 A | 2015-12-14 A | 100% |  |  |  |  |  | start no earlier than 2015-06-14 | S5 | 1048h | 1048h | ANIMO | PCG-35 | Rel-13 | SP-68 |  |  |  |
| 833 | 288.5 | Enhanced S2a Mobility Over Trusted WLAN access to EPC - Charging | 68.5d? | 2015-06-15 A | 2015-09-17 A | 100% |  |  |  |  |  | start no earlier than 2015-06-15 | S5 | 548h | 548h | eSaMOG-CH | PCG-35 | Rel-13 | SP-68 |  |  |  |

Notes:
- 810: New TR added. 3/3/15: "extensions" added in the title. Mar. 15: 0->10% / Impacted TSs and TRs: 26.922 (new), 26.114 / WI rapporteur name: Muhammed Coban, Qualcomm Incorporated / WI rapporteur e-mail: mcoban@qti.qualcomm.com
- 811: 3/3/15: created to distinguish TR and TS tasks; June2015: Compl:10%->40; Aug2015: 40%->95; 07/09/15: 95%->100 / Impacted TSs and TRs: 26.922 (new), 26.114 / WI rapporteur name: Muhammed Coban, Qualcomm Incorporated / WI rapporteur e-mail: mcoban@qti.qualcomm.com
- 812: 3/3/15: created to distinguish TR and TS tasks; June2015: Compl:10%->40; Aug2015: 40%->95; 07/09/15: 95%->100 / Impacted TSs and TRs: 26.922 (new), 26.114 / WI rapporteur name: Muhammed Coban, Qualcomm Incorporated / WI rapporteur e-mail: mcoban@qti.qualcomm.com
- 813: 26.114, draft-ietf-payload-flexible-fec-scheme. 7/10/15: rapporteur added / Impacted TSs and TRs: 26.114, draft-ietf-payload-flexible-fec-scheme / WI rapporteur name: Muhammed Coban, Qualcomm Incorporated / WI rapporteur e-mail: mcoban@qti.qualcomm.com
- 814: June2015: Compl:0%->10. Aug: FCD: Jun->Sep15; 07/09/15: 10%->30, FCD:09/15->12/15; 7/12/15: 40%->80, FCD: 12/15->03/16. ES in SP-150642; 7/3/16: 80%->100 / Impacted TSs and TRs: 26.131, 26.132 / WI rapporteur name: Andre Schevciw, Qualcomm Incorporated; Scott Isabelle, Audience Inc. / WI rapporteur e-mail: aschevci@qti.qualcomm.com; sisabelle@audience.com
- 815: OAM13 is an umbrella Feature for changes that are not part of any other dedicated feature/WI; June2015: WID:-->SP-150305; 5/10/15: 28.683 added; / Impacted TSs and TRs: 28.683
- 816: SP#64 work not started. Dec.14: 0->20, cd: 06/15->12/15. Mar 15: 20->30%; June2015: Compl:30%->50; 07/09/15: 50%->60; 7/12/15: 60%->100 / Impacted TSs and TRs: 28.627, 28.628, 32.103, 32.422, 32.425, 32.442 / WI rapporteur name: Ericsson / WI rapporteur e-mail: robert.petersen@ericsson.com
- 817: SP#65 updated WID SP-120349=>SP-140538. Completion 12/14=>03/15. Moved to Rel-13. Source of external requirements: NGMN Top OPE Recommendations 1.0 / WI rapporteur name: Huawei / WI rapporteur e-mail: christian.toche@huawei.com
- 818: SP#65 updated WID SP-120349=>SP-140538. Completion 12/14=>03/15. Moved to Rel-13.. Dec.14: 72->78. Mar 15: 80%; June2015: Compl:80%->85; 07/09/15: 85%->90; 7/12/15: 90%->100 / Impacted TSs and TRs: New TR 32.838 / WI rapporteur name: Huawei / WI rapporteur e-mail: christian.toche@huawei.com
- 819: SP#65 updated WID SP-120349=>SP-140538. Completion 12/14=>03/15. Moved to Rel-13; 7/12/15: 50%->100 / Impacted TSs and TRs: 32.101/2/3,32.111-1,32.111-2,32.111-6,32.15x,32.401,32.411,32.412,32.421,32.422,32.423,32.431,32.432,32.436,32.441,32.442,32.446,32.500,32.501,32.502,32.506,32.521,32.522,32.526,32.531,32.532,32.536,32.551,32.691,32.692,32.696,32.762 / WI rapporteur name: Huawei / WI rapporteur e-mail: christian.toche@huawei.com
- 820: SP#65 updated WID SP-130641=>SP-140613. Completion 09/14=>12/15. Moved to Rel-13. Completion 09/14=>12/15. Dec.14: 20->30; June2015: Compl:30%->60; 07/09/15: 60%->80; 7/12/15: 80%->100; 7/12/15: WID:SP-140613->SP-150678 / Impacted TSs and TRs: new TSs 32.863 / WI rapporteur name: Huawei / WI rapporteur e-mail: christian.toche@huawei.com
- 821: SP#65 moved to Rel-13. Updated WID SP-130042=>SP-140535 (split into Rel-12 Study & Rel-13 normative WI). TR 32.841 was completed as a Rel-12 Study and has triggered this normative work / WI rapporteur name: Intel / WI rapporteur e-mail: joey.chou@intel.com
- 822: SP#65 updated WID SP-130042=>SP-140535. Completion 09/14=>06/15. Moved to Rel-13. Dec.14: 10->20; June2015: Compl:20%->70; 07/09/15: 70%->80; 7/12/15: 80%->100 / Impacted TSs and TRs: new TS (28.680, 28.682), 28.681 / WI rapporteur name: Intel / WI rapporteur e-mail: joey.chou@intel.com
- 823: SP#65 updated WID SP-130042=>SP-140535. Completion 09/14=>06/15. Moved to Rel-13. 22/01:Acronym modified; June2015: Compl:5%->20; 07/09/15: 20%->60; 7/12/15: 60%->100 / Impacted TSs and TRs: new TS 28.403 / WI rapporteur name: Intel / WI rapporteur e-mail: joey.chou@intel.com
- 824: SP#65 updated WID SP-130263=>SP-140612. Completion 09/14=>06/15. Moved to Rel-13; June2015: Compl:25%->40; 07/09/15: 40%->50. ES in SP-150708; 7/3/16: 50%->100 / Impacted TSs and TRs: 32.425 / WI rapporteur name: Nokia Networks / WI rapporteur e-mail: Yizhi.yao@nsn.com
- 825: Mar 15: 0->15%; June2015: Compl:15%->100 / Impacted TSs and TRs: 32.421, 32.422, 32.423, 32.441, 32.442, 32.446 / WI rapporteur name: Padma Sudarsan (Alcatel-Lucent) / WI rapporteur e-mail: padma.sudarsan<AT>alcatel-lucent<DOT>com
- 826: CH13 is an umbrella Feature for changes that are not part of any other dedicated feature/WI; June2015: WID:-->SP-150307
- 827: Study and specify Gy Reference Point service data flows based online charging for inter-PLMN situations / Impacted TSs and TRs: Stage 2/3 / WI rapporteur name: Alcatel-Lucent / WI rapporteur e-mail: maryse.gardella@alcatel-lucent.com
- 828: Dec.14: 10->25%. Mar15: 20->60%. 06/15: 100%; 7/12/15: 100%->100 / Impacted TSs and TRs: New TR 32.843 / WI rapporteur name: Alcatel-Lucent / WI rapporteur e-mail: maryse.gardella@alcatel-lucent.com
- 829: 07/09/15: 0%->80; 7/12/15: 80%->100 / Impacted TSs and TRs: 32.251, 32.299 / WI rapporteur name: Alcatel-Lucent / WI rapporteur e-mail: maryse.gardella@alcatel-lucent.com
- 830: Acronym changed to ULRELC-CH. Mar15: 0->5%. CD: 12/14->09/15. 06/15: 20%; 07/09/15: 20%->40; 7/12/15: 40%->100, FCD: 09/15->12/15 / Impacted TSs and TRs: 32.251, 32.260, 32.299, 32.298, / WI rapporteur name: Alcatel-Lucent, Maryse Gardella / WI rapporteur e-mail: Alcatel-Lucent, Maryse <dot> Gardella <at> Alcatel-Lucent <dot> com
- 831: 06/15: 0->50%; 07/09/15: 50%->100. FCD: 12/15->09/15 / Impacted TSs and TRs: 32.260, 32.299, 32.298 / WI rapporteur name: Gerald Goermer / WI rapporteur e-mail: Gerald <dot> Goermer <at> nsn <dot> com
- 832: 07/09/15: 0%->30; 7/12/15: 30%->100; 7/12/15: WID:SP-150307->SP-150675 / Impacted TSs and TRs: 32.260, 32.275, 32.299, 32.240, 32.281 / WI rapporteur name: Amdocs, Naceur <dot> Lagha <at> Amdocs <dot> com
- 833: 07/09/15: 0%->30; 7/12/15: 30%->100 / Impacted TSs and TRs: 32.240, 32.251, 32.299, 32.298 / WI rapporteur name: Alcatel-Lucent, Maryse <dot> Gardella <at> Alcatel-Lucent <dot> com

| ID | WBS | Task | Duration | Start | Finish | Complete | Remaining | Baseline start | Baseline finish | Baseline duration | Total slack | Constraint | Resources | Work | Actual work | Acronym | PCG approved | WI rapporteur name | WI rapporteur e-mail | Release | TSG approved | MCC resp | Acronym_3GU_Export | Status Report |
| --- | --- | --- | --- | --- | --- | --- | --- | --- | --- | --- | --- | --- | --- | --- | --- | --- | --- | --- | --- | --- | --- | --- | --- | --- |
| 834 | 289 | **Support of Real-time Transport Protocol (RTP) / Real-time Transport Control Protocol (RTCP) multiplexing (signalling) in IMS** | 595d? | 2013-09-09 A | 2015-12-11 A | 100% |  | 2013-09-09 | 2014-09-12 | 267d? |  |  | C4; C1; C3 | 28464h | 28464h | RTCP_MUX | PCG-31 | Alcatel-Lucent | Albrecht.Schwarz@alcatel-lucent.com | Rel-13 | CP-61 | Kimmo | RTCP_MUX |  |
| 835 | 289.1 | CT4 part of Support of RTP / RTCP multiplexing (signalling) in IMS | 591d? | 2013-09-09 A | 2015-12-11 A | 100% |  | 2013-09-09 | 2014-09-12 | 266d? |  | finish no earlier than 2015-12-11 | C4 | 4728h | 4728h | RTCP_MUX | PCG-31 | Alcatel-Lucent | Albrecht.Schwarz@alcatel-lucent.com | Rel-13 | CP-61 | Kimmo |  |  |
| 836 | 289.2 | CT1 part of Support of RTP / RTCP multiplexing (signalling) in IMS | 591d? | 2013-09-13 A | 2015-12-11 A | 100% |  | 2013-09-10 | 2014-09-12 | 266d? |  | finish no earlier than 2015-12-11 | C1 | 4728h | 4728h | RTCP_MUX | PCG-31 | Alcatel-Lucent | Albrecht.Schwarz@alcatel-lucent.com | Rel-13 | CP-61 | Frederic |  |  |
| 837 | 289.3 | CT3 part of Support of RTP / RTCP multiplexing (signalling) in IMS | 591d? | 2013-09-13 A | 2015-12-11 A | 100% |  | 2013-09-10 | 2014-06-13 | 201d? |  | finish no earlier than 2015-12-11 | C3 | 4728h | 4728h | RTCP_MUX | PCG-31 | Alcatel-Lucent | Albrecht.Schwarz@alcatel-lucent.com | Rel-13 | CP-61 | Adrian |  |  |
| 838 | 290 | **LTE in the 1670-1675 MHz Band for US (on hold till 12/2014)** | 868d? | 2012-03-05 A | 2015-06-12 | 8% | 801.54d? | 2012-03-05 | 2015-06-12 | 865d? | 920d |  | R4; R2; R3 | 35264h | 2347.6h | LTE_FDD_1670_US | PCG-28 | LightSquared | masoud.olfat@lightsquared.com | Rel-13 | RP-55 | Issam | LTE_FDD_1670_US |  |
| 839 | 290.1 | Core part: LTE in the 1670-1675 MHz Band for US (on hold till 12/2014) | 313d? | 2013-08-06 A | 2015-03-13 | 15% | 266.05d? | 2013-08-06 | 2015-03-13 | 313d? | 985d | finish no earlier than 2015-03-13 | R4; R2; R3 | 7512h | 1126.8h | LTE_FDD_1670_US-Core | PCG-28 | LightSquared | masoud.olfat@lightsquared.com | Rel-13 | RP-55 | Issam | LTE_FDD_1670_US-Core | RP-141452 |
| 840 | 290.2 | Perf. Part: LTE in the 1670-1675 MHz Band for US (on hold till 12/2014) | 865d? | 2012-03-05 A | 2015-06-12 | 5% | 821.75d? | 2012-03-05 | 2015-06-12 | 865d? | 920d | finish no earlier than 2015-06-12 | R4 | 6920h | 346h | LTE_FDD_1670_US-Perf | PCG-28 | LightSquared | masoud.olfat@lightsquared.com | Rel-13 | RP-55 | Issam | LTE_FDD_1670_US-Perf | RP-141452 |
| 841 | 291 | **Enhanced Signalling for Inter-eNB Coordinated Multi-Point (CoMP) for LTE** | 328d? | 2014-06-18 A | 2015-09-15 A | 100% |  | 2014-06-13 | 2014-12-05 | 126d? |  |  | R3 | 5248h | 5248h | COMP_LTE_IeNB_sig | PCG-33 | Samsung | sunghwan.won@samsung.com | Rel-13 | RP-64 |  | COMP_LTE_IeNB_sig |  |
| 842 | 291.1 | Core part: Enhanced Signalling for Inter-eNB Coordinated Multi-Point (CoMP) for LTE | 328d? | 2014-06-18 A | 2015-09-15 A | 100% |  | 2014-06-13 | 2014-12-05 | 126d? |  | finish no earlier than 2015-09-15 | R3 | 2624h | 2624h | COMP_LTE_IeNB_sig-Core | PCG-33 | Samsung | sunghwan.won@samsung.com | Rel-13 | RP-64 |  | COMP_LTE_IeNB_sig-Core | RP-151213 |
| 843 | 292 | **2GHz FDD LTE in Region 1 (1980-2010MHz and 2170-2200MHz Bands)** | 592d? | 2014-06-17 A | 2016-09-15 A | 100% |  | 2014-06-13 | 2015-06-12 | 261d? |  |  | R4 | 12096h | 12096h | LTE_1980_2170_REG1 | PCG-33 | DISH Network | johny.kim@dish.com, mariam.sorond@dish.com | Rel-13 | RP-64 |  | LTE_1980_2170_REG1 |  |
| 844 | 292.1 | Core part: 2GHz FDD LTE in Region 1 (1980-2010MHz and 2170-2200MHz Bands) | 393d? | 2014-06-17 A | 2015-12-15 A | 100% |  | 2014-06-13 | 2015-06-12 | 261d? |  | finish no earlier than 2015-12-15 | R4 | 3144h | 3144h | LTE_1980_2170_REG1-Core | PCG-33 | DISH Network | johny.kim@dish.com, mariam.sorond@dish.com | Rel-13 | RP-64 |  | LTE_1980_2170_REG1-Core | RP-151299 |
| 845 | 292.2 | Perf. Part: 2GHz FDD LTE in Region 1 (1980-2010MHz and 2170-2200MHz Bands) | 393d? | 2014-06-18 A | 2015-12-15 A | 100% |  | 2014-06-13 | 2015-06-12 | 261d? |  | finish no earlier than 2015-12-15 | R4 | 3144h | 3144h | LTE_1980_2170_REG1-Perf | PCG-33 | DISH Network | johny.kim@dish.com, mariam.sorond@dish.com | Rel-13 | RP-64 |  | LTE_1980_2170_REG1-Perf | RP-151299 |
| 846 | 292.3 | UE Conformance Test Aspects - FDD LTE band 1980-2010 MHz and 2170-2200MHz (band 65) in Region1 and Region 3 | 134d? | 2016-03-15 A | 2016-09-15 A | 100% |  |  |  |  |  | finish no earlier than 2016-09-15 | R5 | 1072h | 1072h | LTE_1980_2170_REG1_REG3-UEConTest | PCG-36 | Dish Network |  | Rel-13 | TSG#71 |  |  |  |
| 847 | 293 | **Self Organizing Networks (SON) for Active Antenna System (AAS) based deployments** | 199d? | 2014-09-12 A | 2015-06-15 A | 100% |  | 2014-06-13 | 2015-06-12 | 261d? |  |  | R3; G2 | 4776h | 4776h | UTRA_LTE_SON_AAS | PCG-33 | Nokia Networks | krzysztof.kordybach@nsn.com | Rel-13 | RP-65 |  | UTRA_LTE_SON_AAS |  |
| 848 | 293.1 | Core part: Self Organizing Networks (SON) for Active Antenna System (AAS) based deployments | 199d? | 2014-09-12 A | 2015-06-15 A | 100% |  | 2014-06-13 | 2015-06-12 | 261d? |  | finish no earlier than 2015-06-15 | R3 | 1592h | 1592h | UTRA_LTE_SON_AAS-Core | PCG-33 | Nokia Networks | krzysztof.kordybach@nsn.com | Rel-13 | RP-65 |  | UTRA_LTE_SON_AAS-Core | RP-150727 |
| 849 | 294 | **Usage Monitoring Control PCC Extension** | 140d? | 2014-12-03 A | 2015-06-16 A | 100% |  |  |  |  |  |  | S2 | 2824h | 2824h | eUMONC | PCG-34 | CTBRI |  | Rel-13 | SP-66 |  |  |  |
| 850 | 294.1 | Stage 2 of Usage Monitoring Control PCC Extension | 140d? | 2014-12-03 A | 2015-06-16 A | 100% |  |  |  |  |  | finish no earlier than 2015-06-16 | S2 | 1120h | 1120h | eUMONC-SA2 | PCG-34 | China Telecom, Jinyan Li | lijy@ctbri.com.cn | Rel-13 | SP-66 |  |  |  |
| 851 | 294.2 | CT3 Aspect of Usage Monitoring Control extension | 73d? | 2014-12-03 A | 2015-03-13 A | 100% |  |  |  |  |  | finish no earlier than 2015-03-13 | C3 | 584h | 584h | eUMONC-CT3 | PCG-34 | ZTE |  | Rel-13 | CT-66 |  |  |  |
| 852 | 295 | **Enhanced P-CSCF discovery using signalling for access to EPC via WLAN** | 115d? | 2014-10-06 A | 2015-03-13 A | 100% |  |  |  |  |  |  | C1 | 2424h | 2424h | ePCSCF_WLAN | PCG-34 | Ericsson |  | Rel-13 | CT-66 |  |  |  |
| 853 | 295.1 | CT1 aspects of Enhanced P-CSCF discovery using signalling for access to EPC via WLAN | 73d? | 2014-12-03 A | 2015-03-13 A | 100% |  |  |  |  |  | finish no earlier than 2015-03-13 | C1 | 584h | 584h | ePCSCF_WLAN | PCG-34 | Ericsson |  | Rel-13 | CT-66 |  |  |  |
| 854 | 295.2 | CT4 aspects of Enhanced P-CSCF discovery using signalling for access to EPC via WLAN | 115d? | 2014-10-06 A | 2015-03-13 A | 100% |  |  |  |  |  | finish no earlier than 2015-03-13 | C4 | 920h | 920h | ePCSCF_WLAN | PCG-34 | Ericsson |  | Rel-13 | CT-66 |  |  |  |
| 855 | 296 | **P-CSCF Restoration Enhancements with WLAN** | 268.05d? | 2014-12-03 A | 2015-12-14 A | 100% |  |  |  |  |  |  | C4 | 6432.4h | 6432.4h | PCSCF_RES_WLAN | PCG-34 | Jean-Jacques Trottin, Alcatel-Lucent | jean-jacques.trottin@alcatel-lucent.com | Rel-13 | CT-66 |  |  |  |
| 856 | 296.1 | CT1 aspects of P-CSCF Restoration Enhancements with WLAN | 268d? | 2014-12-03 A | 2015-12-14 A | 100% |  |  |  |  |  | finish no earlier than 2015-12-11 | C1 | 2144h | 2144h | PCSCF_RES_WLAN | PCG-34 | Jean-Jacques Trottin, Alcatel-Lucent | jean-jacques.trottin@alcatel-lucent.com | Rel-13 | CT-66 |  |  |  |
| 857 | 296.2 | CT4 aspects of P-CSCF Restoration Enhancements with WLAN | 268d? | 2014-12-03 A | 2015-12-11 A | 100% |  |  |  |  |  | finish no earlier than 2015-12-11 | C4 | 2144h | 2144h | PCSCF_RES_WLAN | PCG-34 | Jean-Jacques Trottin, Alcatel-Lucent | jean-jacques.trottin@alcatel-lucent.com | Rel-13 | CT-66 |  |  |  |

Notes:
- 834: CP#65 moved to Rel-13. Stage 2/3 / Impacted TSs and TRs: Stage 2/3
- 835: CP#65 moved to Rel-13. Completion 09/14=>12/15. Dec.14: 10->100 / Impacted TSs and TRs: 23.334, 29.334
- 836: CP#65 moved to Rel-13. Completion 09/14=>12/15; 7/12/15: 0%->100 / Impacted TSs and TRs: 24.229
- 837: CP#65 moved to Rel-13. Completion 09/14=>12/15; 8/12/15: 0%->100 / Impacted TSs and TRs: 29.213, 29.214
- 838: RP#65 FS_LTE_FDD_1670_US is extended to 12/14 and this WI (LTE_FDD_1670_US) is on hold till 12/14 / Impacted TSs and TRs: LTE
- 839: RP#65 completion 03/15=>06/15. On hold till 12/2014 / Impacted TSs and TRs: 25.101, 25.104, 25.113, 25.133, 25.306, 25.307, 25.331, 25.461, 25.466, 34.124, 36.101, 36.104, 36.113, 36.124, 36.133, 36.307, new TR 36.832
- 840: RP#65 completion 06/15=>09/15. . On hold till 12/2014 / Impacted TSs and TRs: 25.133, 25.306, 25.307, 25.331, 25.461, 25.466, 34.124, 36.113, 36.124, 36.133, 36.141, 36.307
- 841: Triggered by TR 36.874 Study on Coordinated Multi-Point (CoMP) operation for LTE with Non-Ideal Backhaul (UID_600015) / Impacted TSs and TRs: LTE
- 842: CD:Thu 11/12/14->Mon 15/06/15; Compl:0%->15%; Stat Rep: -->RP-141805 1st Apr 15: Compl:15%->30% 1st Apr 15: Stat Rep: RP-141805->RP-150162 03/07/15: Compl:30%->90% 03/07/15: CD:Mon 15/06/15->Tue 15/09/15 03/07/15: Stat Rep: RP-150162->RP-150846 29/09/1 / Impacted TSs and TRs: 36.300, 36.423
- 843: Triggered by TR 37.846 Study on 2GHz FDD for UTRA and LTE in Region 1 (1980-2010MHz and 2170-2200MHz Bands) FS_UTRA_LTE_1980_2170_REG1 / Impacted TSs and TRs: LTE
- 844: CD:Fri 12/06/15->Mon 15/06/15; Compl:5%->15%; Stat Rep: RP-141627->RP-141795 1st Apr 15: Compl:15%->35% 1st Apr 15: WID: RP-141710->RP-150424 1st Apr 15: Stat Rep: RP-141795->RP-150106 03/07/15: Compl:35%->70% 03/07/15: CD:Mon 15/06/15->Tue 15/12/15 03 / Impacted TSs and TRs: 36.101, 36.104, 36.133, 36.141, 36.307, generic TR 36.853 (3 Band CA with 1UL), New TR 36.862 (Technical Report for 2 GHz Band in Region 1)
- 845: CD:Fri 12/06/15->Mon 15/06/15; Compl:0%->0%; Stat Rep: RP-141627->RP-141795 1st Apr 15: WID: RP-141710->RP-150424 1st Apr 15: Stat Rep: RP-141795->RP-150106 03/07/15: CD:Mon 15/06/15->Tue 15/12/15 03/07/15: Stat Rep: RP-150106->RP-150705 29/09/15: Stat / Impacted TSs and TRs: 36.101, 36.104, 36.133, 36.141, 36.307, 36.862
- 846: testing REL-13 LTE_1980_2170_REG1-Core and LTE_1980_2170_REG3-Core;
- 847: Triggered by TR 37.822 Study on Next-Generation SON for UTRA and LTE (FS_UTRA_LTE_NG_SON) / Impacted TSs and TRs: LTE
- 848: CD:Tue 16/06/15->Mon 15/06/15; Compl:0%->15%; Stat Rep: -->RP-141854 1st Apr 15: Compl:15%->25% 1st Apr 15: Stat Rep: RP-141854->RP-150110 03/07/15: Compl:25%->100% 03/07/15: Stat Rep: RP-150110->RP-150727 / Impacted TSs and TRs: 36.300, 36.423, 36.413, 25.413
- 850: June2015: Compl:6%->100. Verbal indication from SA2 chair / Impacted TSs and TRs: 23.203
- 851: Mar.15: 10->100% / Impacted TSs and TRs: 29.212, 29.215
- 853: . 12/12:0->100%. 5/5/15: acronym changed from ePCSCF_WLAN-CT1 to ePCSCF_WLAN / Impacted TSs and TRs: 24.229, 24.302
- 854: Mar.15: 0->100%. 5/5/15: acronym changed from ePCSCF_WLAN-CT1 to ePCSCF_WLAN / Impacted TSs and TRs: 29.274, 29.275
- 855: WID added, acronym. June 2015: WID: CP-140995-> CP-150275
- 856: CT4->CT1. 2/4/15: acronym changed to PCSCF_RES_WLAN; June2015: Compl:0%->10. June 2015: WID: CP-140995-> CP-150275; 07/09/15: 10%->70; 7/12/15: 70%->100 / Impacted TSs and TRs: 24.302, 24.229, 24.244, 24.008
- 857: Dec.14: 0->5%. Mar.15: 5->100%. 2/4/15: acronym changed to PCSCF_RES_WLAN; June2015: Compl:100%->75. June 2015: WID: CP-140995-> CP-150275; 07/09/15: 75%->85; 7/12/15: 85%->100 / Impacted TSs and TRs: New 29.8xy, 23.380, 29.273, 29.274, 29.275, 23.008

| ID | WBS | Task | Duration | Start | Finish | Complete | Remaining | Total slack | Constraint | Resources | Work | Actual work | Acronym | PCG approved | WI rapporteur name | WI rapporteur e-mail | Release | TSG approved |
| --- | --- | --- | --- | --- | --- | --- | --- | --- | --- | --- | --- | --- | --- | --- | --- | --- | --- | --- |
| 858 | 297 | **Mobile Equipment Identity signalling over WLAN** | 69d? | 2015-06-15 A | 2015-09-17 A | 100% |  |  |  | C4 | 1656h | 1656h | MEI_WLAN | PCG-35 | Bruno Landais, Alcatel-Lucent | bruno.landais@alcatel-lucent.com | Rel-13 | CP-68 |
| 859 | 297.1 | CT1 aspects of Mobile Equipment Identity signalling over WLAN | 69d? | 2015-06-15 A | 2015-09-17 A | 100% |  |  | start no earlier than 2015-06-15 | C1 | 552h | 552h | MEI_WLAN | PCG-35 | Bruno Landais, Alcatel-Lucent | bruno.landais@alcatel-lucent.com | Rel-13 | CP-68 |
| 860 | 297.2 | CT4 aspects of Mobile Equipment Identity signalling over WLAN | 69d? | 2015-06-15 A | 2015-09-17 A | 100% |  |  | start no earlier than 2015-06-15 | C4 | 552h | 552h | MEI_WLAN | PCG-35 | Bruno Landais, Alcatel-Lucent | bruno.landais@alcatel-lucent.com | Rel-13 | CP-68 |
| 861 | 298 | Authentication Signalling Improvements for WLAN | 195d? | 2015-06-15 A | 2016-03-11 A | 100% |  |  | finish no earlier than 2016-03-11 | C1 | 1560h | 1560h | ASI_WLAN | PCG-35 | Youyang Yu | yuyouyang@huawei.com | Rel-13 | CP-68 |
| 862 | 299 | **Stage-3 SAE Protocol Development - Phase 4** | 268d? | 2014-12-03 A | 2015-12-11 A | 100% |  |  |  | C1 | 8576h | 8576h | SAES4 | PCG-34 | interdigital |  | Rel-13 | CT-66 |
| 863 | 299.1 | SAE Protocol Development (Stage 3) - Phase 4 | 268d? | 2014-12-03 A | 2015-12-11 A | 100% |  |  | start no earlier than 2014-12-03 | C1 | 2144h | 2144h | SAES4 | PCG-34 | interdigital |  | Rel-13 | CT-66 |
| 864 | 299.2 | CS Fallback in EPS - Phase 4 | 268d? | 2014-12-03 A | 2015-12-11 A | 100% |  |  | start no earlier than 2014-12-03 | C1 | 2144h | 2144h | SAES4-CSFB | PCG-34 | interdigital |  | Rel-13 | CT-66 |
| 865 | 299.3 | SAE for support for non-3GPP accesses - Phase 4 | 268d? | 2014-12-03 A | 2015-12-11 A | 100% |  |  | start no earlier than 2014-12-03 | C1 | 2144h | 2144h | SAES4-non3GPP | PCG-34 | interdigital |  | Rel-13 | CT-66 |
| 866 | 300 | **Interworking solution for Called IN number and original called IN number ISUP parameters** | 73d? | 2014-12-03 A | 2015-03-13 | 74% | 19.1d? | 985d |  | C1; C3 | 2354.5h | 1738.34h | INNB_IW | PCG-34 | Orange |  | Rel-13 | CT-66 |
| 867 | 300.1 | Interworking solution for Called IN number and original called IN number ISUP parameters | 73d? | 2014-12-03 A | 2015-03-13 A | 100% |  |  | start no earlier than 2014-12-03 | C1 | 584h | 584h | INNB_IW | PCG-34 | Orange |  | Rel-13 | CT-66 |
| 868 | 300.2 | (IETF) CT1 part of Interworking solution for Called IN number and original called IN number ISUP parameters | 51.75d? | 2014-12-03 | 2015-03-10 |  |  | 988d | finish no earlier than 2015-03-10 | C1-IETF | 414h |  | INNB_IW | PCG-34 | Orange |  | Rel-13 | CT-66 |
| 869 | 300.3 | CT3 aspects of Interworking solution for Called IN number and original called IN number ISUP parameters | 73d? | 2014-12-03 A | 2015-03-13 A | 100% |  |  | finish no earlier than 2015-03-13 | C3 | 584h | 584h | INNB_IW | PCG-34 | Orange |  | Rel-13 | CT-66 |
| 870 | 301 | **Warning Status Report in EPS** | 204d? | 2014-12-03 A | 2015-09-14 A | 100% |  |  |  | C4 | 4896h | 4896h | WSR_EPS | PCG-34 | one2many |  | Rel-13 | CT-66 |
| 871 | 301.1 | CT1 aspects of Warning Status Report in EPS | 204d? | 2014-12-03 A | 2015-09-14 A | 100% |  |  | start no earlier than 2014-12-03 | C1 | 1632h | 1632h | WSR_EPS | PCG-34 | one2many |  | Rel-13 | CT-66 |
| 872 | 301.2 | CT4 aspects of Warning Status Report in EPS | 204d? | 2014-12-03 A | 2015-09-14 A | 100% |  |  | finish no earlier than 2015-09-14 | C4 | 1632h | 1632h | WSR_EPS | PCG-34 | one2many |  | Rel-13 | CT-66 |
| 873 | 302 | Shared Data Update for Multiple Subscriber | 1d? | 2014-12-03 A | 2014-12-03 A | 100% |  |  | start no earlier than 2014-12-03 | C4 | 8h | 8h | SHARED_SubData_UPD | PCG-34 | Huawei, Susan Shi | susan.shishufeng@huawei.com | Rel-13 | CT-66 |
| 874 | 303 | **IMS Stage-3 IETF Protocol Alignment** | 666d? | 2014-12-03 A | 2017-06-20 | 70% | 199.79d? | 392d |  | C1 | 11760h | 6003.22h | IMSProtoc7 | PCG-34 | Alcatel-Lucent | Keith Drage | Rel-13 | CT-66 |
| 875 | 303.1 | CT1 aspects of IMS Stage-3 IETF Protocol Alignment | 268d? | 2014-12-03 A | 2015-12-11 A | 100% |  |  | finish no earlier than 2015-12-11 | C1 | 2144h | 2144h | IMSProtoc7 | PCG-34 | Alcatel-Lucent | Keith Drage | Rel-13 | CT-66 |
| 876 | 303.2 | (IETF) CT1 aspects of IMS Stage-3 IETF Protocol Alignment | 268d? | 2016-06-13 A | 2017-06-20 | 10% | 241.2d? | 392d | finish no earlier than 2015-12-11 | C1 | 2144h | 214.4h | IMSProtoc7 | PCG-34 | Alcatel-Lucent | Keith Drage | Rel-13 | CT-66 |
| 877 | 303.3 | CT3 aspects of IMS Stage-3 IETF Protocol Alignment | 268d? | 2014-12-03 A | 2015-12-11 A | 100% |  |  | start no earlier than 2014-12-03 | C3 | 2144h | 2144h | IMSProtoc7 | PCG-34 | Alcatel-Lucent | Keith Drage | Rel-13 | CT-67 |
| 878 | 304 | Retry restriction for Improving System Efficiency | 205d? | 2015-03-04 A | 2015-12-15 A | 100% |  |  | finish no earlier than 2015-12-15 | C1 | 1640h | 1640h | RISE | PCG-34 | Huawei, Lin Shu | shulin@huawei.com | Rel-13 | CP-67 |
| 879 | 305 | **H.248 Aspects of WebRTC Data Channel on IMS Access Gateway** | 268d? | 2015-03-04 A | 2016-03-11 A | 100% |  |  |  | C4 | 4288h | 4288h | WebRTCH248DC | PCG-34 | China Mobile, Xiaoning Du | duxiaoning@chinamobile.com | Rel-13 | CP-67 |
| 880 | 305.1 | CT4 Aspect of H.248 Aspects of WebRTC Data Channel on IMS Access Gateway | 268d? | 2015-03-04 A | 2016-03-11 A | 100% |  |  | finish no earlier than 2016-03-11 | C4 | 2144h | 2144h | WebRTCH248DC | PCG-34 | China Mobile, Xiaoning Du. ES in 639 | duxiaoning@chinamobile.com | Rel-13 | CT-67 |
| 881 | 306 | Continuation of the Overload Control for PCC based Diameter applications | 203d? | 2015-03-04 A | 2015-12-11 A | 100% |  |  | finish no earlier than 2015-12-11 | C3 | 1624h | 1624h | cDOCME_PCC | PCG-34 | ZTE, Zhou Xiaoyun | zhou.xiaoyun@zte.com.cn | Rel-13 | CP-67 |
| 882 | 307 | Review of dedicated 3GPP UICC features | 200d? | 2015-03-09 A | 2015-12-11 A | 100% |  |  | finish no earlier than 2015-12-11 | C6 | 1600h | 1600h | Red_UCe | PCG-34 | Blackberry, Adrian Buckley | abuckley@blackberry.com | Rel-13 | CP-67 |

Notes:
- 858: Impacted TSs and TRs: 24.244, 24.302, 29.273, 29.274, 29.275, 23.008
- 859: 07/09/15: 0%->80; 7/12/15: 80%->100 / Impacted TSs and TRs: 24.244, 24.302
- 860: 07/09/15: 0%->90; 7/12/15: 90%->100 / Impacted TSs and TRs: 29.273, 29.274, 29.275, 23.008
- 861: 07/09/15: 0%->40; 7/12/15: 40%->95. FCD -> 03/16, ES in CP-150727; 7/3/16: 95%->100 / Impacted TSs and TRs: 24.302, 24.244
- 862: WP Structure created 24/03/15 to avoid confusion in Acronyms / Impacted TSs and TRs: 23.12, 24.008, 24.167, 24.229, 24.301, 24.302, 24.303, 24.304, 24.305, 24.312, 29.018, 29.118
- 863: WP Structure created 24/03/15 to avoid confusion in Acronyms. 5/5/15: acronym changed from "SAES4-CT1"; June2015: Compl:0%->30; 07/09/15: 30%->70; 7/12/15: 70%->100
- 864: WP Structure created 24/03/15 to avoid confusion in Acronyms; June2015: Compl:0%->30; 07/09/15: 30%->70; 7/12/15: 70%->100
- 865: WP Structure created 24/03/15 to avoid confusion in Acronyms; June2015: Compl:0%->30; 07/09/15: 30%->50; 7/12/15: 50%->100
- 867: 5/5/15: created; June2015: Compl:0%->70; 07/09/15: 70%->100 / Impacted TSs and TRs: 24.229
- 868: Mar15: resp WG:C1->C1-IETF. WID changed from INNB_IW-CT1 / Impacted TSs and TRs: draft-mohali-dispatch-cause-for-service-number
- 869: Mar.15: 80->90%. WID changed from INNB_IW-CT3; June2015: Compl:0%->98; 07/09/15: 98%->99; 7/12/15: 99%->100
- 870: 5/5/15: acronym changed from "WSR_EP"; 7/12/15: WID:CP-140998->CP-150792
- 871: 2/4/15: acronym changed to WSR_EP. 5/5/15: acronym changed from "WSR_EP"; 07/09/15: 0%->25; 7/12/15: 25%->100; 7/12/15: WID:CP-140998->CP-150792 / Impacted TSs and TRs: New TR 23.712
- 872: 2/4/15: acronym changed to WSR_EP. 5/5/15: acronym changed from "WSR_EP"; 7/12/15: 0%->100; 7/12/15: WID:CP-140998->CP-150792
- 873: Mar.15: 0->50%, WID: CP-140804->CP-150013; June2015: Compl:50%->95; 07/09/15: 95%->100 / Impacted TSs and TRs: 29.328, 29.364
- 874: Mar.15: 0->10% / Impacted TSs and TRs: 23.218, 24.998, 24.930
- 875: Mar.15: 0->10%; June2015: Compl:10%->30; 07/09/15: 30%->70; 7/12/15: 70%->100
- 876: Impacted TSs and TRs: draft-ietf-mmusic-dtls-sdp, draft-ietf-mmusic-4572-update
- 877: 2/4/15: added, following CT3 chair's info that the WID also has a CT3 part; June2015: Compl:0%->20; 07/09/15: 20%->40; 7/12/15: 40%->100
- 878: Continuation of Rel-12 SINE UID 620006. 5/5/15: acronym changed from "RISE"; June2015: Compl:0%->10; 07/09/15: 10%->70; 14/09/15: WID:CP-150092->CP-150495; 7/12/15: 70%->100
- 879: Impacted TSs and TRs: 23.334
- 880: June2015: Compl:0%->10; 07/09/15: 10%->20; 7/12/15: 20%->90; 7/3/16: 90%->100 / Impacted TSs and TRs: 23.334
- 881: Relates to UID 580026 (Study on Diameter overload control mechanism); June2015: Compl:0%->100 / Impacted TSs and TRs: 29.212, 29.215, 29.219, 29.217
- 882: Results from the homonymous Study; June2015: Compl:0%->60; 07/09/15: 60%->75; 7/3/16: 75%->100 / Impacted TSs and TRs: 31.102, 31.111, 31.121, 31.124

| ID | WBS | Task | Type | Duration | Start | Finish | Complete | Baseline start | Baseline finish | Baseline duration | Constraint | Resources | Work | Actual work | Acronym | PCG approved | WI rapporteur name | WI rapporteur e-mail | Release | TSG approved | Status Report | Acronym_3GU_Export | TSG stopped | MCC resp |
| --- | --- | --- | --- | --- | --- | --- | --- | --- | --- | --- | --- | --- | --- | --- | --- | --- | --- | --- | --- | --- | --- | --- | --- | --- |
| 883 | 308 | **Controlling IMS Media Plane with SDP Capability** |  | 195d? | 2015-06-15 A | 2016-03-11 A | 100% |  |  |  |  | C4 | 4680h | 4680h | SDPCN_IMS | PCG-35 | Weiwei(Tommy) Yang, Huawei. ES in 640 | tommy@huawei.com | Rel-13 | CP-68 |  |  |  |  |
| 884 | 308.1 | CT3 aspects of Controlling IMS Media Plane with SDP Capability |  | 195d? | 2015-06-15 A | 2016-03-11 A | 100% |  |  |  | finish no earlier than 2016-03-11 | C3 | 1560h | 1560h | SDPCN_IMS | PCG-35 | Weiwei(Tommy) Yang, Huawei. ES in 640 | tommy@huawei.com | Rel-13 | CP-68 |  |  |  |  |
| 885 | 308.2 | CT4 aspects of Controlling IMS Media Plane with SDP Capability |  | 195d? | 2015-06-15 A | 2016-03-11 A | 100% |  |  |  | finish no earlier than 2016-03-11 | C4 | 1560h | 1560h | SDPCN_IMS | PCG-35 | Weiwei(Tommy) Yang, Huawei. ES in 640 | tommy@huawei.com | Rel-13 | CP-68 |  |  |  |  |
| 886 | 309 | **(SA66: on hold) Co-ordinated packet data network gateway (P-GW) change for SIPTO** |  | 66d? | 2014-06-18 A | 2014-09-16 A | 100% | 2014-06-18 | 2014-09-17 | 66d? |  | S1 | 1056h | 1056h | CSIPTO | PCG-33 | Intel | Eric.siow@intel.com | Rel-13 | SP-64 | S1-143306 | CSIPTO |  |  |
| 887 | 309.1 | Stage 1 for Co-ordinated packet data network gateway (P-GW) change for SIPTO |  | 66d? | 2014-06-18 A | 2014-09-16 A | 100% | 2014-06-18 | 2014-09-17 | 66d? | finish no earlier than 2014-09-17 | S1 | 528h | 528h | CSIPTO-ST1 | PCG-33 | Intel | Eric.siow@intel.com | Rel-13 | SP-64 | S1-143306 | CSIPTO |  |  |
| 888 | 310 | **Enhanced CS Fallback (CSFB)** |  | 196d? | 2014-06-18 A | 2015-03-13 A | 100% | 2014-06-18 | 2015-03-18 | 196d? |  | S2; S3 | 4168h | 2600h | eCSFB | PCG-33 | China Unicom | Yang Xu (xuyang49@chinaunicom.cn) | Rel-13 | SP-64 |  | eCSFB |  |  |
| 889 | 310.1 | TR for Enhanced CS Fallback (CSFB) |  | 128d? | 2014-06-18 A | 2014-12-12 A | 100% | 2014-06-18 | 2014-12-10 | 126d? | finish no earlier than 2014-12-12 | S2 | 1024h | 1024h | eCSFB | PCG-33 | China Unicom | Yang Xu (xuyang49@chinaunicom.cn) | Rel-13 | SP-64 |  |  |  |  |
| 890 | 310.2 | Deleted - Stage 2 for Enhanced CS Fallback (CSFB) | milestone | 0d? | 2015-03-13 A | 2015-03-13 A | 100% | 2014-06-18 | 2015-03-18 | 196d? | start no earlier than 2015-03-13 | S2 |  |  | eCSFB | PCG-33 | China Unicom | Yang Xu (xuyang49@chinaunicom.cn) | Rel-13 | SP-64 |  |  | SP-69 |  |
| 891 | 310.3 | Deleted - Security for Enhanced CS Fallback (CSFB) |  | 1d? | 2014-09-18 A | 2014-09-18 A | 100% |  |  |  | start no earlier than 2014-09-17 | S3 | 8h | 8h | eCSFB | PCG-33 | China Unicom | Feng Gao (gaofeng149@chinaunicom.cn) | Rel-13 | SP-65 |  |  | SP-69 |  |
| 892 | 311 | **SRVCC Enhancements for Transcoding Avoidance** |  | 196d? | 2014-09-19 A | 2015-06-17 A | 100% |  |  |  |  | S2 | 2592h | 2592h | SETA | PCG-33 | Ericsson | George.Foti@ericsson.com | Rel-13 | SP-65 |  | SETA |  |  |
| 893 | 311.1 | TR for SRVCC Enhancements for Transcoding Avoidance |  | 128d? | 2014-09-19 A | 2015-03-13 A | 100% |  |  |  | finish no earlier than 2015-03-13 | S2 | 1024h | 1024h | SETA-SA2TR | PCG-33 | Ericsson | George.Foti@ericsson.com | Rel-13 | SP-65 |  |  |  |  |
| 894 | 311.2 | Deleted - Stage 2 for SRVCC Enhancements for Transcoding Avoidance | milestone | 0d? | 2015-06-17 A | 2015-06-17 A | 100% |  |  |  | start no earlier than 2015-06-17 | S2 |  |  | SETA-SA2 | PCG-33 | Ericsson | George.Foti@ericsson.com | Rel-13 | SP-65 |  |  | SP-69 |  |
| 895 | 312 | **Base Station (BS) RF requirements for Active Antenna System (AAS)** |  | 933d? | 2013-03-04 A | 2016-09-15 A | 100% | 2013-03-04 | 2014-12-05 | 465d? |  | R4 | 21184h | 21184h | AAS_BS_LTE_UTRA | PCG-30 | Huawei | ronnie.zhang@huawei.com | Rel-13 | RP-59 |  | AAS_BS_LTE_UTRA |  | Issam |
| 896 | 312.1 | Core part: Base Station (BS) RF requirements for Active Antenna System (AAS) |  | 793d? | 2013-03-04 A | 2016-03-15 A | 100% | 2013-03-04 | 2014-09-12 | 401d? | finish no earlier than 2016-03-15 | R4 | 6344h | 6344h | AAS_BS_LTE_UTRA-Core | PCG-30 | Huawei | ronnie.zhang@huawei.com | Rel-13 | RP-59 | RP-151241 | AAS_BS_LTE_UTRA-Core |  | Issam |
| 897 | 312.2 | Perf. part: Base Station (BS) RF requirements for Active Antenna System (AAS) |  | 922d? | 2013-03-15 A | 2016-09-15 A | 100% | 2013-03-07 | 2014-12-05 | 461d? | finish no earlier than 2016-09-15 | R4 | 7376h | 7376h | AAS_BS_LTE_UTRA-Perf | PCG-30 | Huawei | ronnie.zhang@huawei.com | Rel-13 | RP-59 | RP-151241 | AAS_BS_LTE_UTRA-Perf |  | Issam |
| 898 | 313 | **Enhanced LTE Device to Device Proximity Services** |  | 460d? | 2014-12-15 A | 2016-09-15 A | 100% |  |  |  |  | R2 | 11016h | 11016h | LTE_eD2D_Prox | PCG-34 | Qualcomm | Qualcomm | Rel-13 | RP-66 |  |  |  |  |
| 899 | 313.1 | Core part: Enhanced LTE Device to Device Proximity Services |  | 152.33d? | 2015-08-14 A | 2016-03-15 A | 100% |  |  |  | finish no earlier than 2016-03-15 | R2; R1; R3 | 3656h | 3656h | LTE_eD2D_Prox-Core | PCG-34 | Qualcomm Incorporated, Shailesh Patil | patil@qti.qualcomm.com | Rel-13 | RP-66 | RP-151337 |  |  |  |
| 900 | 313.2 | Perf. part: Enhanced LTE Device to Device Proximity Services |  | 460d? | 2014-12-15 A | 2016-09-15 A | 100% |  |  |  | finish no earlier than 2016-09-15 | R4 | 3680h | 3680h | LTE_eD2D_Prox-Perf | PCG-34 | Qualcomm | Qualcomm | Rel-13 | RP-66 | RP-151337 |  |  |  |
| 901 | 314 | **Radiated requirements for the verification of multi-antenna reception performance of UEs** |  | 327d? | 2014-12-15 A | 2016-03-15 A | 100% |  |  |  |  | R4 | 5232h | 5232h | UTRA_LTE_MIMO_OTA | PCG-34 | Intel | Intel | Rel-13 | RP-66 |  |  |  |  |
| 902 | 314.1 | Core part: Radiated requirements for the verification of multi-antenna reception performance of UEs |  | 327d? | 2014-12-15 A | 2016-03-15 A | 100% |  |  |  | finish no earlier than 2016-03-15 | R4 | 2616h | 2616h | UTRA_LTE_MIMO_OTA-Core | PCG-34 | Intel | Intel | Rel-13 | RP-66 | RP-151573 |  |  |  |
| 903 | 315 | **UE core requirements for uplink 64 QAM** |  | 197d? | 2014-12-15 A | 2015-09-15 A | 100% |  |  |  |  | R4 | 3152h | 3152h | LTE_UL64QAM | PCG-34 | Huawei | Huawei | Rel-13 | RP-66 |  |  |  |  |
| 904 | 315.1 | Core part: UE core requirements for uplink 64 QAM |  | 197d? | 2014-12-15 A | 2015-09-15 A | 100% |  |  |  | finish no earlier than 2015-09-15 | R4 | 1576h | 1576h | LTE_UL64QAM-Core | PCG-34 | Huawei | Huawei | Rel-13 | RP-66 | RP-151244 |  |  |  |
| 905 | 316 | UE Conformance Test Aspects - Core Requirements for Uplink 64QAM for E-UTRA |  | 132d? | 2015-06-15 A | 2015-12-15 A | 100% |  |  |  | finish no earlier than 2015-12-15 | R5 | 1056h | 1056h | LTE_UL64QAM-UEConTest | PCG-35 | CMCC |  | Rel-13 | TSG-68 | RP-151174 |  |  |  |
| 906 | 317 | **Performance requirements of MMSE-IRC receiver for LTE BS** |  | 393d? | 2014-12-15 A | 2016-06-15 A | 100% |  |  |  |  | R4 | 6288h | 6288h | LTE_MMSE_IRC_BS | PCG-34 | China Telecom | China Telecom | Rel-13 | RP-66 |  |  |  |  |
| 907 | 317.1 | Perf. part: Performance requirements of MMSE-IRC receiver for LTE BS |  | 393d? | 2014-12-15 A | 2016-06-15 A | 100% |  |  |  | finish no earlier than 2016-06-15 | R4 | 3144h | 3144h | LTE_MMSE_IRC_BS-Perf | PCG-34 | China Telecom | China Telecom | Rel-13 | RP-66 | RP-151215 |  |  |  |

Notes:
- 883: Impacted TSs and TRs: 23.334, 29.334, 29.162, 29.238, 23.333, 29.333, 29.163, 29.332, 29.292, 29.232, 29.235
- 884: 7/12/15: 0%->90. FCD->03/16. ES in CP-150614; 7/3/16: 90%->100 / Impacted TSs and TRs: 29.162, 29.163, 29.292, 29.235
- 885: 07/09/15: 0%->5; 7/12/15: 5%->70. FCD->03/16. ES in CP-150614; 7/3/16: 70%->100 / Impacted TSs and TRs: 23.334, 29.334, 29.238, 23.333, 29.333, 29.332, 29.232
- 886: SP#65 completed. Updated WID SP-140235=>SP-140509. Triggered by Rel-13 Study TR 22.828 (FS_CSIPTO) / Impacted TSs and TRs: 22.101
- 887: SP#65 completed. Updated WID SP-140235=>SP-140509. Triggered by Rel-13 Study TR 22.828 (FS_CSIPTO). Dec.14: former S1-only feature split / Impacted TSs and TRs: 22.101
- 888: SP#65 updated ID SP-140285=>SP-140579 (added SA3 part). Linked to Rel-8 WIs Single Radio Voice Call Continuity for 3GPP (SAES-SRVCC) and CS Fallback in EPS (SAES-CSFB) / Impacted TSs and TRs: Stage 2
- 889: SP#65 updated ID SP-140285=>SP-140579 (added SA3 part). Dec.14: 35->85%; 14/09/15: 85%->100. SA#69: decision not to continue the work on this. No normative work. / Impacted TSs and TRs: New TR 23.772
- 890: SP#65 updated ID SP-140285=>SP-140579 (added SA3 part) / Impacted TSs and TRs: 23.272
- 891: SP#65 updated ID SP-140285=>SP-140579; 14/09/15: 0%->100. SA#69: deleted, since SA2 has stopped the work.
- 892: Enhance chances for end-to-end transcoder free operation (TrFo) where possible/ ensure proper CS radio resources are reserved for optimal RAN codec. Address TrFo of EVS codecs during SRVCC that are not covered by Rel-12 / Impacted TSs and TRs: Stage 2
- 893: Dec.14: 0->70%; 14/09/15: 70%->100. Stopped without conclusion, no intention to continue the study nor to do any mormative work. / Impacted TSs and TRs: New TR 23.7xy
- 894: SA#69: stop the work on this. / Impacted TSs and TRs: 23.216, 23.237
- 895: Triggered by Rel-12 TR 37.840 Study of RF and EMC Requirements for Active Antenna Array System BS (FS_AAS_BS_LTE_UTRA) / Impacted TSs and TRs: UTRA, LTE, GERAN
- 896: ; CD:Thu 11/12/14->Tue 15/12/15; WID: RP-141966->RP-142235; Stat Rep: RP-141249->RP-141908; Release: Rel-12->Rel-13 03/07/15: Stat Rep: RP-141908->RP-150687 29/09/15: Compl:75%->80% 29/09/15: Stat Rep: RP-150687->RP-151241; / Impacted TSs and TRs: New TS 37.142 (AAS BS Tx & Rx), New TR 37.842, 37.114, 37.145-1, 37.145-2
- 897: ; CD:Sat 18/06/16->Wed 15/06/16; WID: RP-141966->RP-142235; Stat Rep: RP-141249->RP-141908; Release: Rel-12->Rel-13 03/07/15: Stat Rep: RP-141908->RP-150687 29/09/15: Stat Rep: RP-150687->RP-151241 22/3/16: Compl:2 26/9/16: Compl:95%->100% / Impacted TSs and TRs: New TS 37.1xy (AAS BS conformance testing)
- 899: Rapporteur details and involved WGs updated 1st Apr 15: WID: RP-142311->RP-150441 1st Apr 15: Stat Rep: ->RP-150095 03/07/15: Compl:0%->32% 03/07/15: Stat Rep: RP-150095->RP-150795 29/09/15: Compl:32%->55% 29/09/15: Stat Rep: RP-150795->RP-151337;
- 900: 1st Apr 15: WID: RP-142311->RP-150441 1st Apr 15: Stat Rep: ->RP-150095 03/07/15: Stat Rep: RP-150095->RP-150795 29/09/15: Stat Rep: RP-150795->RP-151337; 1/1/16: CD; 22/3/16: Compl:0%->10%;26/9/16: Compl:85%->100%
- 902: 1st Apr 15: Compl:0%->5% 1st Apr 15: WID: RP-142221->RP-150261 1st Apr 15: Stat Rep: ->RP-150260 03/07/15: Compl:5%->15% 03/07/15: Stat Rep: RP-150260->RP-150746 29/09/15: Compl:15%->25% 29/09/15: WID: RP-150261->RP-151574 29/09/15: Stat Rep: RP-15074
- 904: 1st Apr 15: Compl:0%->10% 1st Apr 15: Stat Rep: ->RP-150232 03/07/15: Compl:10%->90% 03/07/15: WID: RP-142222->RP-150691 03/07/15: Stat Rep: RP-150232->RP-150688 29/09/15: Compl:90%->100% 29/09/15: Stat Rep: RP-150688->RP-151244
- 905: tested Core part: LTE_UL64QAM-Core which is not yet completed 29/09/15: Compl:0%->5% 29/09/15: Stat Rep: -->RP-151174 1/1/16: Compl:5%->100%
- 907: 1st Apr 15: Compl:0%->10% 1st Apr 15: WID: RP-142223->RP-150206 1st Apr 15: Stat Rep: ->RP-150204 03/07/15: Compl:10%->35% 03/07/15: Stat Rep: RP-150204->RP-150630 29/09/15: Compl:35%->50% 29/09/15: Stat Rep: RP-150630->RP-151215;

| ID | WBS | Task | Duration | Start | Finish | Complete | Remaining | Total slack | Constraint | Resources | Work | Actual work | Acronym | PCG approved | WI rapporteur name | WI rapporteur e-mail | Release | TSG approved | Status Report |
| --- | --- | --- | --- | --- | --- | --- | --- | --- | --- | --- | --- | --- | --- | --- | --- | --- | --- | --- | --- |
| 908 | 318 | **CRS Interference Mitigation for LTE Homogenous Deployments** | 327d? | 2014-12-15 A | 2016-03-15 A | 100% |  |  |  | R4 | 5232h | 5232h | LTE_CRSIM | PCG-34 | Ericsson | Ericsson | Rel-13 | RP-66 |  |
| 909 | 318.1 | Perf. part: CRS Interference Mitigation for LTE Homogenous Deployments | 327d? | 2014-12-15 A | 2016-03-15 A | 100% |  |  | finish no earlier than 2016-03-15 | R4 | 2616h | 2616h | LTE_CRSIM-Perf | PCG-34 | Ericsson | Ericsson | Rel-13 | RP-66 | RP-151171 |
| 910 | 319 | **Dual Connectivity enhancements for LTE** | 328d? | 2015-03-16 A | 2016-06-15 A | 100% |  |  |  | R2 | 6824h | 6824h | LTE_dualC_enh | PCG-34 | NTT DOCOMO |  | Rel-13 | RP-67 |  |
| 911 | 319.1 | Core part: Dual Connectivity enhancements for LTE | 197d? | 2015-03-16 A | 2015-12-15 A | 100% |  |  | finish no earlier than 2015-12-15 | R2 | 1576h | 1576h | LTE_dualC_enh-Core | PCG-34 | NTT DOCOMO |  | Rel-13 | RP-67 | RP-151330 |
| 912 | 319.2 | Perf. part: Dual Connectivity enhancements for LTE | 328d? | 2015-03-16 A | 2016-06-15 A | 100% |  |  | finish no earlier than 2016-06-15 | R4 | 2624h | 2624h | LTE_dualC_enh-Perf | PCG-34 | NTT DOCOMO |  | Rel-13 | RP-67 | RP-151330 |
| 913 | 320 | **Multicarrier Load Distribution of UEs in LTE** | 395d? | 2015-03-16 A | 2016-09-15 A | 100% |  |  |  | R2 | 7896h | 7896h | LTE_MC_load | PCG-34 | ZTE |  | Rel-13 | RP-67 |  |
| 914 | 320.1 | Core part: Multicarrier Load Distribution of UEs in LTE | 197d? | 2015-03-16 A | 2015-12-15 A | 100% |  |  | finish no earlier than 2015-12-15 | R2 | 1576h | 1576h | LTE_MC_load-Core | PCG-34 | ZTE |  | Rel-13 | RP-67 | RP-151190 |
| 915 | 320.2 | Perf. part: Multicarrier Load Distribution of UEs in LTE | 395d? | 2015-03-16 A | 2016-09-15 A | 100% |  |  | finish no earlier than 2016-09-15 | R4 | 3160h | 3160h | LTE_MC_load-Perf | PCG-34 | ZTE |  | Rel-13 | RP-67 | RP-151190 |
| 916 | 321 | **LTE-WLAN Radio Level Integration and Interworking Enhancement** | 656d? | 2015-03-16 A | 2017-09-15 | 69% | 205.82d? | 329d |  | R2 | 12600h | 5636.2h | LTE_WLAN_radio | PCG-34 | Intel |  | Rel-13 | RP-67 |  |
| 917 | 321.1 | Core part: LTE-WLAN Radio Level Integration and Interworking Enhancement | 262d? | 2015-03-16 A | 2016-03-15 A | 100% |  |  | finish no earlier than 2016-03-15 | R2 | 2096h | 2096h | LTE_WLAN_radio-Core | PCG-34 | Intel |  | Rel-13 | RP-67 | RP-151563 |
| 918 | 321.2 | Perf. part: LTE-WLAN Radio Level Integration and Interworking Enhancement | 262d? | 2015-03-16 A | 2016-03-15 A | 100% |  |  | finish no earlier than 2016-03-15 | R4 | 2096h | 2096h | LTE_WLAN_radio-Perf | PCG-34 | Intel |  | Rel-13 | RP-67 | RP-151563 |
| 919 | 321.3 | UE Conformance Test Aspects - WLAN/3GPP Radio Level Integration and Interworking Enhancement Interworking | 395d? | 2016-03-15 A | 2017-09-15 | 27% | 288.35d? | 329d | finish no earlier than 2017-09-15 | R5 | 3160h | 853.2h | LTE_WLAN_radio-UEConTest | PCG-36 | Intel |  | Rel-13 | TSG#71 |  |
| 920 | 322 | **RAN aspects for improvements to CS/PS coordination in UTRAN Shared Network** | 197d? | 2015-03-16 A | 2015-12-15 A | 100% |  |  |  | R3 | 3152h | 3152h | CSPS_Coord-UTRA | PCG-34 | Ericsson |  | Rel-13 | RP-67 |  |
| 921 | 322.1 | Core part: RAN aspects for improvements to CS/PS coordination in UTRAN Shared Network | 197d? | 2015-03-16 A | 2015-12-15 A | 100% |  |  | finish no earlier than 2015-12-15 | R3 | 1576h | 1576h | CSPS_Coord-UTRA-Core | PCG-34 | Ericsson |  | Rel-13 | RP-67 | RP-151289 |
| 922 | 323 | **LTE DL 4 Rx antenna ports** | 4573d? | 2000-01-03 A | 2017-06-15 | 98% | 108.77d? | 395d |  | R4 | 76336h | 45494.1h | LTE_4Rx_AP_DL | PCG-34 | Ericsson |  | Rel-13 | RP-67 |  |
| 923 | 323.1 | Core part: LTE DL 4 Rx antenna ports | 197d? | 2015-03-16 A | 2015-12-15 A | 100% |  |  | finish no earlier than 2015-12-15 | R4 | 1576h | 1576h | LTE_4Rx_AP_DL-Core | PCG-34 | Ericsson |  | Rel-13 | RP-67 | RP-151265 |
| 924 | 323.2 | Perf. part: LTE DL 4 Rx antenna ports | 4378d? | 2000-01-03 A | 2016-09-15 A | 100% |  |  | finish no earlier than 2016-09-15 | R4 | 35024h | 35024h | LTE_4Rx_AP_DL-Perf | PCG-34 | Ericsson |  | Rel-13 | RP-67 | RP-151265 |
| 925 | 323.3 | UE Conformance Test Aspects - LTE DL 4 Rx antenna ports | 394d? | 2015-12-15 A | 2017-06-15 | 70% | 118.2d? | 395d | finish no earlier than 2017-06-15 | R5 | 3152h | 2206.4h | LTE_4Rx_AP_DL-UEConTest | PCG-36 | Ericsson |  | Rel-13 | RP-70 |  |
| 926 | 324 | **AWS-Extension Band for LTE** | 395d? | 2015-03-16 A | 2016-09-15 A | 100% |  |  |  | R4 | 7904h | 7904h | LTE_AWS_EXT | PCG-34 | Ericsson |  | Rel-13 | RP-67 |  |
| 927 | 324.1 | Core part: AWS-Extension Band for LTE | 197d? | 2015-03-16 A | 2015-12-15 A | 100% |  |  | finish no earlier than 2015-12-15 | R4 | 1576h | 1576h | LTE_AWS_EXT-Core | PCG-34 | Ericsson |  | Rel-13 | RP-67 | RP-151343 |
| 928 | 324.2 | Perf. part: AWS-Extension Band for LTE | 197d? | 2015-03-16 A | 2015-12-15 A | 100% |  |  | finish no earlier than 2015-12-15 | R4 | 1576h | 1576h | LTE_AWS_EXT-Perf | PCG-34 | Ericsson |  | Rel-13 | RP-67 | RP-151343 |
| 929 | 324.3 | UE Conformance Test Aspects - AWS-Extension Band for LTE (Band 66) | 199d? | 2015-12-15 A | 2016-09-15 A | 100% |  |  | finish no earlier than 2016-09-15 | R5 | 1592h | 1592h | LTE_AWS_EXT-UEConTest | PCG-36 | Ericsson |  | Rel-13 | RP-70 |  |
| 930 | 325 | **Additional bandwidth combination set for LTE Advanced inter-band Carrier Aggregation of Band 5 and Band 7** | 66d? | 2015-03-16 A | 2015-06-15 A | 100% |  |  |  | R4 | 1584h | 1584h | LTE_CA_B5_B7_BWset | PCG-34 | Nokia Networks |  | Rel-13 | RP-67 |  |
| 931 | 325.1 | Core part: Additional bandwidth combination set for LTE Advanced inter-band Carrier Aggregation of Band 5 and Band 7 | 66d? | 2015-03-16 A | 2015-06-15 A | 100% |  |  | finish no earlier than 2015-06-15 | R4 | 528h | 528h | LTE_CA_B5_B7_BWset-Core | PCG-34 | Nokia Networks |  | Rel-13 | RP-67 | RP-150536 |
| 932 | 325.2 | Perf. part: Additional bandwidth combination set for LTE Advanced inter-band Carrier Aggregation of Band 5 and Band 7 | 66d? | 2015-03-16 A | 2015-06-15 A | 100% |  |  | finish no earlier than 2015-06-15 | R4 | 528h | 528h | LTE_CA_B5_B7_BWset-Perf | PCG-34 | Nokia Networks |  | Rel-13 | RP-67 | RP-150536 |

Notes:
- 909: 1st Apr 15: Compl:0%->10% 1st Apr 15: CD:Mon 15/06/15->Tue 15/03/16 1st Apr 15: Stat Rep: ->RP-150061 03/07/15: Compl:10%->20% 03/07/15: Stat Rep: RP-150061->RP-150584 29/09/15: Compl:20%->30% 29/09/15: Stat Rep: RP-150584->RP-151171
- 911: 03/07/15: Compl:0%->25% 03/07/15: Stat Rep: ->RP-150744 29/09/15: Compl:25%->55% 29/09/15: Stat Rep: RP-150744->RP-151330 1/1/16: Compl:55%->100%
- 912: 03/07/15: Stat Rep: ->RP-150744 29/09/15: Stat Rep: RP-150744->RP-151330 ; 1/1/16: WID: RP-150490->RP-15173922/3/16: Compl:0%->50%;
- 914: 03/07/15: Compl:0%->40% 03/07/15: WID: RP-150491->RP-150611 03/07/15: Stat Rep: ->RP-150610 29/09/15: Compl:40%->55% 29/09/15: WID: RP-150611->RP-151206 29/09/15: Stat Rep: RP-150610->RP-151190
- 915: 03/07/15: WID: RP-150491->RP-150611 03/07/15: Stat Rep: ->RP-150610 29/09/15: WID: RP-150611->RP-151206 29/09/15: Stat Rep: RP-150610->RP-1511901/1/16:22/3/16: Compl:70%->75%; 26/9/16: Compl:90%->100%; 26/9/16: WID: RP-152181
- 917: 03/07/15: Compl:0%->30% 03/07/15: WID: RP-150510->RP-151114 03/07/15: Stat Rep: ->RP-151081, 07/08/15: impacted TSs added 29/09/15: Compl:30%->35% 29/09/15: Stat Rep: RP-151081->RP-151563; / Impacted TSs and TRs: 36.461, 36.462, 36.463, 36.464, 36.465, 36.622, 36.623, 36.624, 36.625, 36.360
- 918: 03/07/15: WID: RP-150510->RP-151114 03/07/15: Stat Rep: ->RP-151081 29/09/15: Stat Rep: RP-151081->RP-1515631/1/16: Compl:0%->10% ; 22/3/16: Compl:10%->100%;
- 919: testing REL-13 LTE_WLAN_radio-Core; 1/7/16: Compl:0%->5%; 20/; ; 21/3/17: Compl:20...
- 921: 03/07/15: Compl:0%->45% 03/07/15: Stat Rep: ->RP-150842 29/09/15: Compl:45%->80% 29/09/15: CD:Tue 15/09/15->Tue 15/12/15 29/09/15: Stat Rep: RP-150842->RP-1512891/1/16: Compl:80%->100%
- 923: 03/07/15: Compl:0%->25% 03/07/15: Stat Rep: ->RP-150803 29/09/15: Compl:25%->50% 29/09/15: Stat Rep: RP-150803->RP-151265; 1/1/16: Compl:50%->100%
- 924: 03/07/15: Compl:0%->15% 03/07/15: CD:Mon 02/10/00->Wed 15/06/16 03/07/15: Stat Rep: ->RP-150803 29/09/15: Compl:15%->35% 29/09/15: Stat Rep: RP-150803->RP-15126522/3/16: Compl:60%-;26/9/16: Compl:90%->100%
- 925: ; 22/3/16: Compl:0%->10%; 1/7/16: Compl:10%->25%; 26/9/16: 21/3/17: Compl:60%->70...
- 927: 03/07/15: Compl:0%->20% 03/07/15: WID: RP-150428->RP-150800 03/07/15: Stat Rep: ->RP-150796 29/09/15: Compl:20%->50% 29/09/15: Stat Rep: RP-150796->RP-151343
- 928: 03/07/15: WID: RP-150428->RP-150800 03/07/15: Stat Rep: ->RP-150796 29/09/15: Stat Rep: RP-150796->RP-151343;
- 929: ; 22/3/16: Compl:0%->10%1/7/16: Compl:10%->65%26/9/16: Comp
- 931: 03/07/15: Compl:0%->100% 03/07/15: WID: RP-150171->RP-150602 03/07/15: Stat Rep: ->RP-150536
- 932: 03/07/15: Compl:0%->100% 03/07/15: WID: RP-150171->RP-150602 03/07/15: Stat Rep: ->RP-150536

| ID | WBS | Task | Duration | Start | Finish | Complete | Constraint | Resources | Work | Actual work | Acronym | PCG approved | WI rapporteur name | Release | TSG approved | Status Report | WI rapporteur e-mail | TSG stopped |
| --- | --- | --- | --- | --- | --- | --- | --- | --- | --- | --- | --- | --- | --- | --- | --- | --- | --- | --- |
| 933 | 326 | **Additional bandwidth combination set for LTE Advanced inter-band Carrier Aggregation of Band 3 and Band 5** | 66d? | 2015-03-16 A | 2015-06-15 A | 100% |  | R4 | 1584h | 1584h | LTE_CA_B3_B5_BWset | PCG-34 | Samsung | Rel-13 | RP-67 |  |  |  |
| 934 | 326.1 | Core part: Additional bandwidth combination set for LTE Advanced inter-band Carrier Aggregation of Band 3 and Band 5 | 66d? | 2015-03-16 A | 2015-06-15 A | 100% | finish no earlier than 2015-06-15 | R4 | 528h | 528h | LTE_CA_B3_B5_BWset-Core | PCG-34 | Samsung | Rel-13 | RP-67 | RP-150536 |  |  |
| 935 | 326.2 | Perf. part: Additional bandwidth combination set for LTE Advanced inter-band Carrier Aggregation of Band 3 and Band 5 | 66d? | 2015-03-16 A | 2015-06-15 A | 100% | finish no earlier than 2015-06-15 | R4 | 528h | 528h | LTE_CA_B3_B5_BWset-Perf | PCG-34 | Samsung | Rel-13 | RP-67 | RP-150536 |  |  |
| 936 | 327 | **Multiflow Enhancements for UTRA** | 132d? | 2015-03-16 A | 2015-09-15 A | 100% |  | R2 | 2112h | 2112h | HSDPA_MFTX_enh | PCG-34 | Nokia | Rel-13 | RP-67 |  | alexander.sayenko@nokia.com |  |
| 937 | 327.1 | Core part: Multiflow Enhancements for UTRA | 132d? | 2015-03-16 A | 2015-09-15 A | 100% | finish no earlier than 2015-09-15 | R2 | 1056h | 1056h | HSDPA_MFTX_enh-Core | PCG-34 | Nokia | Rel-13 | RP-67 | RP-151302 | alexander.sayenko@nokia.com |  |
| 938 | 328 | **Message interworking during PS to CS SRVCC** | 68d? | 2015-06-15 A | 2015-09-16 A | 100% |  | C1 | 1632h | 1632h | mSRVCC | PCG-35 | Ivo Sedlacek, Ericsson | Rel-13 | CP-68 |  | ivo.sedlacek@ericsson.com |  |
| 939 | 328.1 | CT1 aspects of Message interworking during PS to CS SRVCC | 68d? | 2015-06-15 A | 2015-09-16 A | 100% | start no earlier than 2015-06-15 | C1 | 544h | 544h | mSRVCC | PCG-35 | Ivo Sedlacek, Ericsson | Rel-13 | CP-68 |  | ivo.sedlacek@ericsson.com |  |
| 940 | 328.2 | CT3 aspects of Message interworking during PS to CS SRVCC | 68d? | 2015-06-15 A | 2015-09-16 A | 100% | finish no earlier than 2015-09-16 | C3 | 544h | 544h | mSRVCC | PCG-35 | Ivo Sedlacek, Ericsson | Rel-13 | CP-68 |  | ivo.sedlacek@ericsson.com |  |
| 941 | 329 | **Support of Emergency services over WLAN – phase 1** | 192d? | 2015-06-18 A | 2016-03-11 A | 100% |  | S2 | 5896h | 5896h | SEW1 | PCG-35 | Laurent thiebaut | Rel-13 | SP-68 |  | Laurent.thiebaut@alcatel-lucent.com |  |
| 942 | 329.1 | Stage 2 of Support of Emergency services over WLAN - phase 1 | 65d? | 2015-06-18 A | 2015-09-16 A | 100% | finish no earlier than 2015-09-16 | S2 | 520h | 520h | SEW1 | PCG-35 | Laurent thiebaut | Rel-13 | SP-68 |  | Laurent.thiebaut@alcatel-lucent.com |  |
| 943 | 329.2 | **CT aspects of Support of Emergency services over WLAN – phase 1** | 135d? | 2015-09-07 A | 2016-03-11 A | 100% |  | ct | 3840h | 3840h | SEW1-CT | PCG-35 | Alcatel-Lucent, Jennifer Liu (CT1) | Rel-13 | CP-69 |  | jennifer.liu@alcatel-lucent.com |  |
| 944 | 329.2.1 | CT1 aspects of Support of Emergency services over WLAN – phase 1 | 135d? | 2015-09-07 A | 2016-03-11 A | 100% | finish no earlier than 2016-03-11 | C1 | 1080h | 1080h | SEW1-CT | PCG-35 | Alcatel-Lucent, Jennifer Liu (CT1) | Rel-13 | CP-69 |  | jennifer.liu@alcatel-lucent.com |  |
| 945 | 329.2.2 | CT3 aspects of Support of Emergency services over WLAN – phase 1 | 70d? | 2015-09-07 A | 2015-12-11 A | 100% | finish no earlier than 2015-12-11 | C3 | 560h | 560h | SEW1-CT | PCG-35 | Alcatel-Lucent, Jennifer Liu (CT1) | Rel-13 | CP-69 |  | jennifer.liu@alcatel-lucent.com |  |
| 946 | 329.2.3 | CT4 aspects of Support of Emergency services over WLAN – phase 1 | 70d? | 2015-09-07 A | 2015-12-11 A | 100% | finish no earlier than 2015-12-11 | C4 | 560h | 560h | SEW1-CT | PCG-35 | Alcatel-Lucent, Jennifer Liu (CT1) | Rel-13 | CP-69 |  | jennifer.liu@alcatel-lucent.com |  |
| 947 | 329.2.4 | CT6 aspects of Support of Emergency services over WLAN – phase 1 | 70d? | 2015-09-07 A | 2015-12-11 A | 100% | finish no earlier than 2015-12-11 | C6 | 560h | 560h | SEW1-CT | PCG-35 | Alcatel-Lucent, Jennifer Liu (CT1) | Rel-13 | CP-69 |  | jennifer.liu@alcatel-lucent.com |  |
| 948 | 330 | **MBMS Enhancements** | 264d? | 2014-12-03 A | 2015-12-07 A | 100% |  | S2 | 4320h | 4320h | MBMS_enh | PCG-34 | Nokia Networks, Curt Wong | Rel-13 | SP-66 |  |  |  |
| 949 | 330.1 | MBMS Enhancements TR Phase | 204d? | 2014-12-03 A | 2015-09-14 A | 100% | finish no earlier than 2015-09-14 | S2 | 1632h | 1632h | FS_MBMS_enh_TR | PCG-34 | Nokia Networks, Curt Wong | Rel-13 | SP-66 |  |  |  |
| 950 | 330.2 | MBMS Enhancements | 28d? | 2015-08-10 A | 2015-09-16 A | 100% | finish no earlier than 2015-09-16 | S2 | 224h | 224h | MBMS_enh_St2 | PCG-35 | Nokia Networks, Curt Wong | Rel-13 | CP-69 |  |  |  |
| 951 | 330.3 | **CT aspects of MBMS Enhancements** | 21d? | 2015-11-09 A | 2015-12-07 A | 100% |  | C3 | 344h | 344h | MBMS_enh-CT | PCG-36 | Nokia Networks, Thomas Belling | Rel-13 | CP-70 |  |  |  |
| 952 | 330.3.1 | CT3 aspects of MBMS enhancements | 21d? | 2015-11-09 A | 2015-12-07 A | 100% | start no earlier than 2015-11-09 | C3 | 168h | 168h | MBMS_enh-CT | PCG-36 | Nokia Networks, Thomas Belling | Rel-13 | CP-70 |  |  |  |
| 953 | 330.3.2 | CT4 aspects of MBMS enhancements | 21d? | 2015-11-09 A | 2015-12-07 A | 100% | finish no earlier than 2015-12-07 | C4 | 168h | 168h | MBMS_enh-CT | PCG-36 | Nokia Networks, Thomas Belling | Rel-13 | CP-70 |  |  |  |
| 954 | 330.4 | Deleted (not approved) - MBMS Enhancements - Stage 2 | 1d? | 2015-03-13 A | 2015-03-13 A | 100% | finish no earlier than 2015-03-13 | S2 | 8h | 8h | MBMS_enh_TS | PCG-34 | Rainer Liebhart | Rel-13 | SP-66 |  |  | SP-69 |
| 955 | 331 | **EPC Signalling Improvements for race scenarios** | 135d? | 2015-09-07 A | 2016-03-11 A | 100% |  | C4 | 2760h | 2760h | EPC_SIG_RACE | PCG-35 | Huawei, Peter Schmitt | Rel-13 | CP-69 |  | Huawei, Peter Schmitt, Peter.Schmitt@HUAWEI.COM |  |
| 956 | 331.1 | CT3 aspects for EPC Signalling Improvements for race scenarios | 135d? | 2015-09-07 A | 2016-03-11 A | 100% | finish no earlier than 2016-03-11 | C3 | 1080h | 1080h | EPC_SIG_RACE | PCG-35 | Huawei, Peter Schmitt | Rel-13 | CP-69 |  | Huawei, Peter Schmitt, Peter.Schmitt@HUAWEI.COM |  |
| 957 | 331.2 | CT4 aspects for EPC Signalling Improvements for race scenarios | 75d? | 2015-09-07 A | 2015-12-18 A | 100% | finish no earlier than 2015-12-18 | C4 | 600h | 600h | EPC_SIG_RACE | PCG-35 | Huawei, Peter Schmitt | Rel-13 | CP-69 |  | Huawei, Peter Schmitt, Peter.Schmitt@HUAWEI.COM |  |

Notes:
- 934: 03/07/15: Compl:0%->100% 03/07/15: Stat Rep: ->RP-150536
- 935: 03/07/15: Compl:0%->100% 03/07/15: Stat Rep: ->RP-150536
- 937: 03/07/15: Compl:0%->80% 03/07/15: WID: RP-150288->RP-151021 03/07/15: Stat Rep: ->RP-150827 29/09/15: Compl:80%->100% 29/09/15: Stat Rep: RP-150827->RP-151302
- 939: 07/09/15: 0%->25; 7/12/15: 25%->100 / Impacted TSs and TRs: 24.237, 24.292
- 940: 07/09/15: 0%->70; 7/12/15: 70%->100 / Impacted TSs and TRs: 29.292
- 941: 07/09/15: 0%->100 / Impacted TSs and TRs: TS 23.402, TS 23.167, TS 23.271, TS 23.203, TS 23.228
- 942: 07/09/15: 0%->100 / Impacted TSs and TRs: TS 23.402, TS 23.167, TS 23.271, TS 23.203, TS 23.228
- 944: 7/12/15: 60%->95. FCD -> 03/16, ES in CP-150729; 7/3/16: 95%->100 / Impacted TSs and TRs: 24.302, 24.229
- 945: 7/12/15: 0%->100 / Impacted TSs and TRs: 29.212, 29.214
- 946: 7/12/15: 0%->100 / Impacted TSs and TRs: 23.003, 23.008, 29.273, 29.274
- 947: 7/3/16: 0%->100 / Impacted TSs and TRs: 31.102
- 948: . 3/3: WID tdoc number updated; 14/09/15: WID:SP-140883->SP-150516
- 949: Acronym changed from "MBMS_enh-SA2TR". Mar15: 0->10%; June2015: Compl:10%->50; 07/09/15: 50%->70. acronym changed from "MBMS_enh" to "MBMS_enh_TR"; 07/09/15: 70%->100; 14/09/15: WID:SP-140883->SP-150516 / Impacted TSs and TRs: TR 23.8xy
- 950: SA#69: no normative work, moved as Study only. 14/10/15: corrected: was mentioned as FS_ / Impacted TSs and TRs: TS 23.246, TS 23.468
- 952: 8/12/15: 0%->100 / Impacted TSs and TRs: 29.061, 29.468
- 953: Impacted TSs and TRs: 29.274, 23.008, 29.230
- 954: Commented during RAN#67 that it should have never beeen here. 07/09/15: "undeleted", acronym changed from "MBMS_enh-del" to "MBMS_enh_TS". 14/10/15: SP-140883 was never approved so this line should have never appeared in the WP. / Impacted TSs and TRs: TS 23.246, TS 23.468
- 956: 7/12/15: FCD -> 03/16, ES in CP-150861; 8/12/15: 0%->100 / Impacted TSs and TRs: 29.212, 29.213
- 957: 7/12/15: 95%->100 / Impacted TSs and TRs: 29.274, 29.274, 29.275, 29.282, 29.273, 29.230, 23.008, 29.273

| ID | WBS | Task | Duration | Start | Finish | Complete | Remaining | Total slack | Constraint | Resources | Work | Actual work | Acronym | PCG approved | WI rapporteur name | WI rapporteur e-mail | Release | TSG approved | Status Report |
| --- | --- | --- | --- | --- | --- | --- | --- | --- | --- | --- | --- | --- | --- | --- | --- | --- | --- | --- | --- |
| 958 | 332 | **Diameter Message Priority** | 164d? | 2015-11-02 A | 2016-06-16 A | 100% |  |  |  | C4 | 3736h | 3736h | DiaPri | PCG-36 | Alcatel-Lucent, Jean-Jacques Trottin | jean-jacques.trottin@alcatel-lucent.com | Rel-13 | CP-70 |  |
| 959 | 332.1 | CT3 aspects of DiaPri | 95d? | 2015-11-02 A | 2016-03-11 A | 100% |  |  | finish no earlier than 2016-03-11 | C3 | 760h | 760h | DiaPri | PCG-36 | Intel, Vivek Gupta |  | Rel-13 | CP-70 |  |
| 960 | 332.2 | CT4 aspects of DiaPri | 95d? | 2015-11-02 A | 2016-03-11 A | 100% |  |  | finish no earlier than 2016-03-11 | C4 | 760h | 760h | DiaPri | PCG-36 | Alcatel-Lucent, Jean-Jacques Trottin | jean-jacques.trottin@alcatel-lucent.com | Rel-13 | CP-70 |  |
| 961 | 332.3 | (IETF) Diameter Routing Message Priority (draft-ietf-dime- | 138d? | 2015-12-08 A | 2016-06-16 A | 100% |  |  | finish no earlier than 2016-06-16 | C4-IETF | 1104h | 1104h | DiaPri | PCG-36 | Alcatel-Lucent, Jean-Jacques Trottin | jean-jacques.trottin@alcatel-lucent.com | Rel-13 | TSG#71 |  |
| 962 | 333 | **Downlink TPC Enhancements for UMTS** | 197d? | 2015-06-15 A | 2016-03-15 A | 100% |  |  |  | R1 | 4208h | 4208h | UTRA_EDL_TPC | PCG-35 | Huawei |  | Rel-13 | TSG-68 |  |
| 963 | 333.1 | Core part: Downlink TPC Enhancements for UMTS | 44d? | 2015-10-15 A | 2015-12-15 A | 100% |  |  | finish no earlier than 2015-12-15 | R1; R2; R3 | 1056h | 1056h | UTRA_EDL_TPC-Core | PCG-35 | Huawei |  | Rel-13 | TSG-68 | RP-151564 |
| 964 | 333.2 | Perf. part: Downlink TPC Enhancements for UMTS | 197d? | 2015-06-15 A | 2016-03-15 A | 100% |  |  | finish no earlier than 2016-03-15 | R4 | 1576h | 1576h | UTRA_EDL_TPC-Perf | PCG-35 | Huawei |  | Rel-13 | TSG-68 | RP-151564 |
| 965 | 334 | **Licensed-Assisted Access using LTE** | 525d? | 2015-06-15 A | 2017-06-15 | 76% | 123.52d? | 395d |  | R1 | 11568h | 6337.51h | LTE_LAA | PCG-35 | Ericsson |  | Rel-13 | TSG-68 |  |
| 966 | 334.1 | Core part: Licensed-Assisted Access using LTE | 132d? | 2015-06-15 A | 2015-12-15 A | 100% |  |  | finish no earlier than 2015-12-15 | R1 | 1056h | 1056h | LTE_LAA-Core | PCG-35 | Ericsson |  | Rel-13 | TSG-68 | RP-151390 |
| 967 | 334.2 | Perf. part: Licensed-Assisted Access using LTE | 395d? | 2015-06-15 A | 2016-12-15 A | 100% |  |  | finish no earlier than 2016-12-15 | R4 | 3160h | 3160h | LTE_LAA-Perf | PCG-35 | Ericsson |  | Rel-13 | TSG-68 |  |
| 968 | 334.3 | UE Conformance Test Aspects - Licensed-Assisted Access using LTE | 394d? | 2015-12-15 A | 2017-06-15 | 45% | 216.7d? | 395d | finish no earlier than 2017-06-15 | R5 | 3152h | 1418.4h | LTE_LAA-UEConTest | PCG-36 | Motorola Mobility |  | Rel-13 | RP-70 |  |
| 969 | 335 | **Elevation Beamforming/Full-Dimension (FD) MIMO for LTE** | 330d? | 2015-06-15 A | 2016-09-15 A | 100% |  |  |  | R1 | 6336h | 6336h | LTE_EBF_FDMIMO | PCG-35 | Samsung |  | Rel-13 | TSG-68 |  |
| 970 | 335.1 | Core part: Elevation Beamforming/Full-Dimension (FD) MIMO for LTE | 132d? | 2015-06-15 A | 2015-12-15 A | 100% |  |  | finish no earlier than 2015-12-15 | R1 | 1056h | 1056h | LTE_EBF_FDMIMO-Core | PCG-35 | Samsung |  | Rel-13 | TSG-68 | RP-151565 |
| 971 | 335.2 | Perf. part: Elevation Beamforming/Full-Dimension (FD) MIMO for LTE | 330d? | 2015-06-15 A | 2016-09-15 A | 100% |  |  | finish no earlier than 2016-09-15 | R4 | 2640h | 2640h | LTE_EBF_FDMIMO-Perf | PCG-35 | Samsung |  | Rel-13 | TSG-68 | RP-151565 |
| 972 | 336 | **L2/L3 Downlink enhancements for UMTS** | 132d? | 2015-06-15 A | 2015-12-15 A | 100% |  |  |  | R2 | 2112h | 2112h | UTRA_EDL_L23 | PCG-35 | Huawei |  | Rel-13 | TSG-68 |  |
| 973 | 336.1 | Core part: L2/L3 Downlink enhancements for UMTS | 132d? | 2015-06-15 A | 2015-12-15 A | 100% |  |  | finish no earlier than 2015-12-15 | R2 | 1056h | 1056h | UTRA_EDL_L23-Core | PCG-35 | Huawei |  | Rel-13 | TSG-68 | RP-151238 |
| 974 | 337 | **Support of single-cell point-to-multipoint transmission in LTE** | 330d? | 2015-06-15 A | 2016-09-15 A | 100% |  |  |  | R2 | 5824h | 5824h | LTE_SC_PTM | PCG-35 | Huawei |  | Rel-13 | TSG-68 |  |
| 975 | 337.1 | Core part: Support of single-cell point-to-multipoint transmission in LTE | 132d? | 2015-06-15 A | 2015-12-15 A | 100% |  |  | finish no earlier than 2015-12-15 | R2 | 1056h | 1056h | LTE_SC_PTM-Core | PCG-35 | Huawei |  | Rel-13 | TSG-68 | RP-151237 |
| 976 | 337.2 | Perf. part: Support of single-cell point-to-multipoint transmission in LTE | 132d? | 2015-06-15 A | 2015-12-15 A | 100% |  |  | finish no earlier than 2016-06-15 | R4 | 1056h | 1056h | LTE_SC_PTM-Perf | PCG-35 | Huawei |  | Rel-13 | TSG-68 | RP-151237 |
| 977 | 337.3 | UE Conformance Test Aspects - Support of single-cell point-to-multipoint transmission in LTE | 134d? | 2016-03-15 A | 2016-09-15 A | 100% |  |  | finish no earlier than 2016-12-15 | R5 | 1072h | 1072h | LTE_SC_PTM-UEConTest | PCG-36 | Huawei |  | Rel-13 | TSG#71 |  |
| 978 | 338 | **Extension of Dual Connectivity in E-UTRAN** | 132d? | 2015-06-15 A | 2015-12-15 A | 100% |  |  |  | R3 | 2112h | 2112h | LTE_dualC_ext | PCG-35 | Samsung |  | Rel-13 | TSG-68 |  |
| 979 | 338.1 | Core part: Extension of Dual Connectivity in E-UTRAN | 132d? | 2015-06-15 A | 2015-12-15 A | 100% |  |  | finish no earlier than 2015-12-15 | R3 | 1056h | 1056h | LTE_dualC_ext-Core | PCG-35 | Samsung |  | Rel-13 | TSG-68 | RP-151214 |
| 980 | 339 | **RAN sharing enhancements for UMTS** | 132d? | 2015-06-15 A | 2015-12-15 A | 100% |  |  |  | R3 | 2112h | 2112h | RSE_UTRA_GUSH | PCG-35 | Huawei |  | Rel-13 | TSG-68 |  |
| 981 | 339.1 | Core part: RAN sharing enhancements for UMTS | 132d? | 2015-06-15 A | 2015-12-15 A | 100% |  |  | finish no earlier than 2015-12-15 | R3 | 1056h | 1056h | RSE_UTRA_GUSH-Core | PCG-35 | Huawei |  | Rel-13 | TSG-68 | RP-151239 |

Notes:
- 959: ES in CP-150645; 7/3/16: 65%->100 / Impacted TSs and TRs: 29.153, 29.154, 29.201, 29.212, 29.213, 29.214, 29.215, 29.217, 29.219
- 960: ES in CP-150622; 7/3/16: 70%->100 / Impacted TSs and TRs: 29.228, 29.229, 29.272, 29.273, 29.328, 29.329, 29.336, 29.337, 29.338, 29.344, 29.345
- 961: 02/2016: publication requested; 2/12/16: 85%->100 / Impacted TSs and TRs: 29.227, 29.272, 29.273, 29.229
- 962: follow-up WI of REL-13 SI FS_UTRA_EDL; TPC = Transmit Power Control
- 963: follow-up WI of REL-13 SI FS_UTRA_EDL; TPC = Transmit Power Control 29/09/15: Compl:0%->35% 29/09/15: Stat Rep: -->RP-1515641/1/16: Compl:35%->100%1/1/16: WID:
- 964: follow-up WI of REL-13 SI FS_UTRA_EDL; TPC = Transmit Power Control 29/09/15: Stat Rep: -->RP-151564; 1/1/16: Compl:0%->80%; 1/1/16: WID: RP-151044->RP-151880
- 965: follow-up WI of REL-13 SI FS_LTE_LAA
- 966: follow-up WI of REL-13 SI FS_LTE_LAA 29/09/15: Compl:0%->25% 29/09/15: Stat Rep: -->RP-1513901/1/16: Compl:25%->100%
- 967: follow-up WI of REL-13 SI FS_LTE_LAA 29/09/15: Stat Rep: -->RP-15139022/3/16: Compl:0%->33%; 1/7/16: Compl:3; 26/9/16: Compl:50%->90%; 20/12/16: Compl:90%->100%; 20/12/16: Stat Rep: RP-151390->
- 968: ; 22/3/16: Compl:0%->5%1/7/16: Compl:5%->8%26/9/16: Compl:8%->15%; 20/21/3/17: Com...
- 969: follow-up WI of REL-13 SI FS_LTE_EBF_FDMIMO
- 970: follow-up WI of REL-13 SI FS_LTE_EBF_FDMIMO 29/09/15: Compl:0%->25% 29/09/15: Stat Rep: -->RP-151565 1/1/16: Compl:25%->100%
- 971: follow-up WI of REL-13 SI FS_LTE_EBF_FDMIMO 29/09/15: Stat Rep: -->RP-151565 ; 1/1/16: Compl:0%->5%; 22/3/16: Compl:5%->35%;26/9/16: Compl:70%->100%
- 972: no Perf. part; follow-up of Rel-13 SI FS_UTRA_EDL
- 973: no Perf. part; follow-up of Rel-13 SI FS_UTRA_EDL 29/09/15: Compl:0%->35% 29/09/15: WID: RP-151043->RP-151249 29/09/15: Stat Rep: -->RP-1512381/1/16: Compl:35%->100% ;
- 974: follow-up WI of REL-13 SI FS_LTE_SC_PTM
- 975: follow-up WI of REL-13 SI FS_LTE_SC_PTM 29/09/15: Compl:0%->30% 29/09/15: Stat Rep: -->RP-151237 1/1/16: Compl:30%->100%
- 976: follow-up WI of REL-13 SI FS_LTE_SC_PTM 29/09/15: Stat Rep: -->RP-1512371/1/16: Compl:0%->100%
- 977: testing REL-13 LTE_SC_PTM-Core1/7/16: Compl:0%->40%26/9/16
- 978: no Perf. part; follow-up WI of REL-13 SI FS_LTE_dualC_ext;
- 979: no Perf. part; follow-up WI of REL-13 SI FS_LTE_dualC_ext; 29/09/15: Compl:0%->30% 29/09/15: Stat Rep: -->RP-151214; 1/1/16: Compl:3
- 980: no Perf. part; follow-up WI for Rel-13 SI FS_RSE_UTRA_GUSH; note: GUSH was a REL-13 SA1 WI; there is an ongoing REL-13 WI for LTE: RSE-RAN_LTE;
- 981: no Perf. part; follow-up WI for Rel-13 SI FS_RSE_UTRA_GUSH; note: GUSH was a REL-13 SA1 WI; there is an ongoing REL-13 WI for LTE: RSE-RAN_LTE; 29/09/15: Compl:0%->30% 29/09/15: WID: RP-151086->RP-151251 29/09/15: Stat Rep: -->RP-151239 ;

| ID | WBS | Task | Duration | Start | Finish | Complete | Remaining | Total slack | Constraint | Resources | Work | Actual work | Acronym | PCG approved | WI rapporteur name | Release | TSG approved | Status Report | Impacted TSs and TRs | WI rapporteur e-mail |
| --- | --- | --- | --- | --- | --- | --- | --- | --- | --- | --- | --- | --- | --- | --- | --- | --- | --- | --- | --- | --- |
| 982 | 340 | **Interference mitigation for downlink control channels of LTE** | 720d? | 2015-06-15 A | 2018-03-15 | 50% | 359.31d? | 200d |  | R4 | 9960h | 4208h | LTE_IM_DLCCH | PCG-35 | Intel | Rel-13 | TSG-68 |  |  |  |
| 983 | 340.1 | Perf. part: Interference mitigation for downlink control channels of LTE | 263d? | 2015-06-15 A | 2016-06-15 A | 100% |  |  | finish no earlier than 2016-06-15 | R4 | 2104h | 2104h | LTE_IM_DLCCH-Perf | PCG-35 | Intel | Rel-13 | TSG-68 | RP-151301 |  |  |
| 984 | 340.2 | UE Conformance Test Aspects - Interference Mitigation for Downlink Control Channels of LTE | 262d? | 2017-03-15 | 2018-03-15 |  |  | 200d | finish no earlier than 2018-03-15 | R5 | 2096h |  | LTE_IM_DLCCH-UEConTest |  | Intel | Rel-13 |  |  |  |  |
| 985 | 341 | **Network-Assisted Interference Cancellation and Suppression for UMTS** | 66d? | 2015-09-15 A | 2015-12-15 A | 100% |  |  |  | R1 | 1056h | 1056h | UTRA_NAICS | PCG-35 | Huawei | Rel-13 | RP-69 |  |  |  |
| 986 | 341.1 | Core part: Network-Assisted Interference Cancellation and Suppression for UMTS | 66d? | 2015-09-15 A | 2015-12-15 A | 100% |  |  | finish no earlier than 2015-12-15 | R1 | 528h | 528h | UTRA_NAICS-Core | PCG-35 | Huawei | Rel-13 | RP-69 |  |  |  |
| 987 | 342 | **Dual Carrier HSUPA Enhancements for UTRAN CS** | 66d? | 2015-09-15 A | 2015-12-15 A | 100% |  |  |  | R2 | 1056h | 1056h | DC_HSUPA_CS | PCG-35 | Nokia Networks | Rel-13 | RP-69 |  |  |  |
| 988 | 342.1 | Core part: Dual Carrier HSUPA Enhancements for UTRAN CS | 66d? | 2015-09-15 A | 2015-12-15 A | 100% |  |  | finish no earlier than 2015-12-15 | R2 | 528h | 528h | DC_HSUPA_CS-Core | PCG-35 | Nokia Networks | Rel-13 | RP-69 |  |  |  |
| 989 | 343 | **Further Enhancements of Minimization of Drive Tests for E-UTRAN** | 524d? | 2015-03-16 A | 2017-03-15 | 99% | 0d? | 0d |  | R2 | 6304h | 3688h | LTE_eMDT2 | PCG-35 | CMCC | Rel-13 | RP-69 |  |  |  |
| 990 | 343.1 | Study on further Enhancements of Minimization of Drive Tests for E-UTRAN | 132d? | 2015-03-16 A | 2015-09-15 A | 100% |  |  | finish no earlier than 2015-09-15 | R2 | 1056h | 1056h | FS_LTE_eMDT2 | PCG-34 | CMCC | Rel-13 | RP-67 | RP-151181 | 36.880 |  |
| 991 | 343.2 | Core part: Further Enhancements of Minimization of Drive Tests for E-UTRAN | 66d? | 2015-09-15 A | 2015-12-15 A | 100% |  |  | finish no earlier than 2015-12-15 | R2 | 528h | 528h | LTE_eMDT2-Core | PCG-35 | CMCC | Rel-13 | RP-69 |  |  |  |
| 992 | 343.3 | UE Conformance Test Aspects – Further Enhancements of Minimization of Drive Tests for E-UTRAN | 197d? | 2016-06-15 A | 2017-03-15 A | 100% |  |  | finish no earlier than 2017-03-15 | R5 | 1576h | 1576h | LTE_eMDT2-UEConTest | PCG-37 | Intel | Rel-13 | TSG#72 |  |  |  |
| 993 | 344 | **LTE-WLAN RAN Level Integration supporting legacy WLAN** | 131d? | 2015-09-15 A | 2016-03-15 A | 100% |  |  |  | R2 | 2096h | 2096h | LTE_WLAN_radio_legacy | PCG-35 | Alcatel-Lucent | Rel-13 | RP-69 |  |  |  |
| 994 | 344.1 | Core part: LTE-WLAN RAN Level Integration supporting legacy WLAN | 131d? | 2015-09-15 A | 2016-03-15 A | 100% |  |  | finish no earlier than 2016-03-15 | R2 | 1048h | 1048h | LTE_WLAN_radio_legacy-Core | PCG-35 | Alcatel-Lucent | Rel-13 | RP-69 |  | 36.361 |  |
| 995 | 345 | **Indoor Positioning enhancements for UTRA and LTE** | 393d? | 2015-09-15 A | 2017-03-15 | 99% | 0d? | 0d |  | R2 | 7152h | 5584h | UTRA_LTE_iPos_enh | PCG-35 | NextNav | Rel-13 | RP-69 |  |  |  |
| 996 | 345.1 | Core part: Indoor Positioning enhancements for UTRA and LTE | 66d? | 2015-09-15 A | 2015-12-15 A | 100% |  |  | finish no earlier than 2015-12-15 | R2 | 528h | 528h | UTRA_LTE_iPos_enh-Core | PCG-35 | NextNav | Rel-13 | RP-69 |  |  |  |
| 997 | 345.2 | Perf. part: Indoor Positioning enhancements for UTRA and LTE | 197d? | 2015-09-15 A | 2016-06-15 A | 100% |  |  | finish no earlier than 2016-06-15 | R4 | 1576h | 1576h | UTRA_LTE_iPos_enh-Perf | PCG-35 | NextNav | Rel-13 | RP-69 |  | 37.171; 37.958 |  |
| 998 | 345.3 | **CT aspects of Indoor Positionning** | 41d? | 2015-10-12 A | 2015-12-07 A | 100% |  |  |  | C4 | 328h | 328h | UTRA_LTE_iPos_enh-CT | PCG-36 | Ericsson, Jesús de Gregorio | Rel-13 | SP-70 |  | 29.171, 29.172, 29.230, 29.002 | jesus.de.gregorio@ericsson.com |
| 999 | 345.3.1 | CT4 aspects of Indoor Positionning | 41d? | 2015-10-12 A | 2015-12-07 A | 100% |  |  | finish no earlier than 2015-12-07 | C4 | 328h | 328h | UTRA_LTE_iPos_enh-CT | PCG-36 | Ericsson, Jesús de Gregorio | Rel-13 | CP-70 |  | 29.171, 29.172, 29.230, 29.002 | jesus.de.gregorio@ericsson.com |
| 1000 | 345.4 | UE Conformance Test Aspects – Indoor Positioning Enhancement Support for LTE and UMTS | 197d? | 2016-06-15 A | 2017-03-15 A | 100% |  |  | finish no earlier than 2017-06-15 | R5 | 1576h | 1576h | UTRA_LTE_iPos_enh-UEConTest | PCG-37 | NextNav | Rel-13 | TSG#72 |  |  |  |
| 1001 | 346 | **Power saving enhancements for UMTS** | 197d? | 2015-06-15 A | 2016-03-15 A | 100% |  |  |  | R2 | 3160h | 3160h | UTRA_SDATA_POWSAV | PCG-35 | Ericsson | Rel-13 | TSG-68 |  |  |  |
| 1002 | 346.1 | Core part: Power saving enhancements for UMTS | 132d? | 2015-06-15 A | 2015-12-15 A | 100% |  |  | finish no earlier than 2015-12-15 | R2 | 1056h | 1056h | UTRA_SDATA_POWSAV-Core | PCG-35 | Ericsson | Rel-13 | TSG-68 | RP-151291 |  |  |
| 1003 | 346.2 | Perf. Part: Power saving enhancements for UMTS | 66d? | 2015-12-15 A | 2016-03-15 A | 100% |  |  | finish no earlier than 2016-03-15 | R4 | 528h | 528h | UTRA_SDATA_POWSAV-Perf | PCG-36 | Ericsson | Rel-13 | RP-70 |  |  |  |
| 1004 | 347 | **700MHz E-UTRA FDD Band for Arab Region** | 197d? | 2015-06-15 A | 2016-03-15 A | 100% |  |  |  | R4 | 4728h | 4728h | LTE_FDD_700_ARAB | PCG-35 | Etisalat | Rel-13 | TSG-68 |  |  |  |
| 1005 | 347.1 | Core part: 700MHz E-UTRA FDD Band for Arab Region | 197d? | 2015-06-15 A | 2016-03-15 A | 100% |  |  | finish no earlier than 2016-03-15 | R4 | 1576h | 1576h | LTE_FDD_700_ARAB-Core | PCG-35 | Etisalat | Rel-13 | TSG-68 | RP-151207 | 36.893 |  |
| 1006 | 347.2 | Perf. part: 700MHz E-UTRA FDD Band for Arab Region | 197d? | 2015-06-15 A | 2016-03-15 A | 100% |  |  | finish no earlier than 2016-03-15 | R4 | 1576h | 1576h | LTE_FDD_700_ARAB-Perf | PCG-35 | Etisalat | Rel-13 | TSG-68 | RP-151207 |  |  |

Notes:
- 982: only Perf. part, no Core part;
- 983: only Perf. part, no Core part; 29/09/15: CD:Tue 15/03/16->Wed 15/06/16 29/09/15: Stat Rep: -->RP-1513011/1/16: Compl:0%->40%22/3/16: Compl:40%->70%
- 984: tested: REL-13 LTE_IM_DLCCH-Perf (note: WI had no Core part);
- 985: no Perf. part; follow-up WI REL-13 RAN1 SI FS_UTRA_NAICS
- 986: no Perf. part; follow-up WI REL-13 RAN1 SI FS_UTRA_NAICS ; 1/1/16: Compl:0%->100% ; 1/1/16: WID: RP-151577->RP-151879
- 987: no Perf. part; compare REL-13 WI HSUPA_DB_MC
- 988: no Perf. part; compare REL-13 WI HSUPA_DB_MC 1/1/16: Compl:0%->100% 1/1/16: WID: RP-151607->RP-151780
- 989: no Perf. part; follow-up WI of REL-13 SI FS_LTE_eMDT2
- 990: 03/07/15: Compl:0%->70% 03/07/15: Stat Rep: -->RP-150806 29/09/15: Compl:70%->100% 29/09/15: Stat Rep: RP-150806->RP-151181
- 991: no Perf. part; follow-up WI of REL-13 SI FS_LTE_eMDT2; 1/1/16: Compl:0%->100%
- 992: tested REL-13 WI: LTE_eMDT2-Core26/9/16: Com;21/3/17: Compl:5%->100%
- 993: no Perf. part; compare REL-13 WI LTE_WLAN_radio
- 994: no Perf. part; compare REL-13 WI LTE_WLAN_radio1/1/16: Compl:0%->95% 22/3/16: Compl:95%->100%; 28/7/16: 36.361 added;
- 995: follow-up WI of REL-13 SI FS_UTRA_LTE_iPos_enh
- 996: follow-up WI of REL-13 SI FS_UTRA_LTE_iPos_enh1/1/16: Compl:0%->100%1/1/16: WID: RP-151624->RP-15225122/3/16: WID: RP-152251->RP-160332
- 997: follow-up WI of REL-13 SI FS_UTRA_LTE_iPos_enh 1/1/16: Compl:0%->10% 1/1/16: WID: RP-151624->RP-152251; 22/3/16: Compl:10%->20%; 22/3/16: WID: RP-152251->RP-160332 28/7/16: 37.171 added; 28/7/16: 37.958 added;
- 999: 8/12/15: 0%->100
- 1000: tested REL-13 WI: UTRA_LTE_iPos_enh-Core; 26/9/1; 20/12/16:; ; 21/3/17: Compl:...
- 1001: no Perf. part; follow-up WI of SI FS_UTRA_SDATA
- 1002: no Perf. part; follow-up WI of SI FS_UTRA_SDATA 29/09/15: Compl:0%->25% 29/09/15: CD:Tue 15/03/16->Tue 15/12/15 29/09/15: WID: RP-151092->RP-151292 29/09/15: Stat Rep: -->RP-151291 29/09/15: Release: Rel-14->Rel-13
- 1003: ; 22/3/16: Compl:0%->100%
- 1004: REL-independent from REL-9
- 1005: REL-independent from REL-9. Aug 15: TR numb added 29/09/15: Compl:0%->15% 29/09/15: CD:Tue 15/03/16->Tue 15/12/15 29/09/15: Stat Rep: -->RP-151207 29/09/15: Release: Rel-14->Rel-13;
- 1006: REL-independent from REL-9 29/09/15: CD:Tue 15/03/16->Tue 15/12/15 29/09/15: Stat Rep: -->RP-151207 29/09/15: Release: Rel-14->Rel-13

| ID | WBS | Task | Duration | Start | Finish | Complete | Remaining | Baseline start | Baseline finish | Baseline duration | Total slack | Constraint | Resources | Work | Actual work | Acronym | PCG approved | WI rapporteur name | Release | TSG approved | Status Report | WI rapporteur e-mail | MCC resp | Special Focus Doc | Acronym_3GU_Export |
| --- | --- | --- | --- | --- | --- | --- | --- | --- | --- | --- | --- | --- | --- | --- | --- | --- | --- | --- | --- | --- | --- | --- | --- | --- | --- |
| 1007 | 348 | **European 700 Supplemental Downlink band (738-758 MHz) in E-UTRA and LTE Carrier Aggregation (2DL/1UL) with Band 20** | 132d? | 2015-06-15 A | 2015-12-15 A | 100% |  |  |  |  |  |  | R4 | 3168h | 3168h | LTE_CA_700EU_B20 | PCG-35 | TeliaSonera | Rel-13 | TSG-68 |  |  |  |  |  |
| 1008 | 348.1 | Core part: European 700 Supplemental Downlink band (738-758 MHz) in E-UTRA and LTE Carrier Aggregation (2DL/1UL) with Band 20 | 132d? | 2015-06-15 A | 2015-12-15 A | 100% |  |  |  |  |  | finish no earlier than 2015-12-15 | R4 | 1056h | 1056h | LTE_CA_700EU_B20-Core | PCG-35 | TeliaSonera | Rel-13 | TSG-68 | RP-151232 |  |  |  |  |
| 1009 | 348.2 | Perf. part: European 700 Supplemental Downlink band (738-758 MHz) in E-UTRA and LTE Carrier Aggregation (2DL/1UL) with Band 20 | 132d? | 2015-06-15 A | 2015-12-15 A | 100% |  |  |  |  |  | finish no earlier than 2016-03-15 | R4 | 1056h | 1056h | LTE_CA_700EU_B20-Perf | PCG-35 | TeliaSonera | Rel-13 | TSG-68 | RP-151232 |  |  |  |  |
| 1010 | 349 | Release 13 Features on Internet of Things (IoT) | 438.25d? | 2013-09-12 A | 2015-05-12 A | 100% |  | 2015-04-14 | 2015-12-25 | 183.25d? |  |  | SP; RP; CP; GP | 14024h | 14024h |  |  |  | Rel-13 |  |  |  |  |  |  |
| 1011 | 350 | Service Requirements Maintenance for Machine-Type Communications (MTC) | 194d? | 2015-09-15 A | 2016-06-10 A | 100% |  | 2013-12-12 | 2014-12-10 | 261d? |  |  | S1 | 1552h | 1552h | SRMMTC | PCG-32 | KPN | Rel-13 | SP-62 |  | toon.norp@tno.nl | Alain | MTC, M2M | SRMMTC |
| 1012 | 351 | **Cellular (Narrowband) Internet of Things** | 459d? | 2015-09-15 A | 2017-06-15 | 97% | 15.28d? |  |  |  | 395d |  |  | 15600h | 12683.6h | CIoT | PCG-36 |  | Rel-13 | CP-70 |  |  |  |  |  |
| 1013 | 351.1 | Stage 2 of CIoT | 1d? | 2015-10-05 A | 2015-10-05 | 95% | 0.05d? |  |  |  | 839d | start no earlier than 2015-10-05 | S2 | 8h | 7.6h | CIoT | PCG-36 | Intel, Puneet Jain | Rel-13 | SP-70 |  | puneet.jain@intel.com |  |  |  |
| 1014 | 351.2 | Security Aspects of CIoT (aka NB-IoT) | 160d? | 2015-11-02 A | 2016-06-10 A | 100% |  |  |  |  |  | finish no earlier than 2016-06-10 | S3 | 1280h | 1280h | CIoT | PCG-36 | Tim Evans, Vodafone | Rel-13 | SP-70 |  |  |  |  |  |
| 1015 | 351.3 | **CT aspects of CIoT** | 138d? | 2015-12-07 A | 2016-06-15 A | 100% |  |  |  |  |  |  | C1 | 4976h | 4976h | CIoT-CT | PCG-36 | Intel, Vivek Gupta | Rel-13 | CP-70 |  | vivek.g.gupta@intel.com |  |  |  |
| 1016 | 351.3.1 | CT1 aspects of CIoT | 70d? | 2015-12-07 A | 2016-03-11 A | 100% |  |  |  |  |  | finish no earlier than 2016-03-11 | C1 | 560h | 560h | CIoT-CT | PCG-36 | Intel, Vivek Gupta | Rel-13 | CP-70 |  | vivek.g.gupta@intel.com |  |  |  |
| 1017 | 351.3.2 | CT3 aspects of CIoT | 138d? | 2015-12-07 A | 2016-06-15 A | 100% |  |  |  |  |  | finish no earlier than 2016-06-15 | C3 | 1104h | 1104h | CIoT-CT | PCG-36 | Intel, Vivek Gupta | Rel-13 | CP-70 |  | vivek.g.gupta@intel.com |  |  |  |
| 1018 | 351.3.3 | CT4 aspects of CIoT | 138d? | 2015-12-07 A | 2016-06-15 A | 100% |  |  |  |  |  | finish no earlier than 2016-06-15 | C4 | 1104h | 1104h | CIoT-CT | PCG-36 | Intel, Vivek Gupta | Rel-13 | CP-70 |  | vivek.g.gupta@intel.com |  |  |  |
| 1019 | 351.3.4 | CT6 aspects of CIoT | 138d? | 2015-12-07 A | 2016-06-15 A | 100% |  |  |  |  |  | finish no earlier than 2016-06-15 | C6 | 1104h | 1104h | CIoT-CT | PCG-36 | Intel, Vivek Gupta | Rel-13 | CP-70 |  | vivek.g.gupta@intel.com |  |  |  |
| 1020 | 351.4 | Charging Aspects of CIoT | 23d? | 2016-05-12 A | 2016-06-13 A | 100% |  |  |  |  |  | finish no earlier than 2016-06-13 | S5 | 184h | 184h | CIoT-CH | PCG-37 | Gardella, Maryse (Nokia) | Rel-13 | TSG#72 |  | Gardella, Maryse (Nokia) |  |  |  |
| 1021 | 351.5 | **RAN aspects of CIoT aka Narrowband Internet of Things (IOT)** | 329d? | 2015-09-15 A | 2016-12-15 | 99% | 0d? |  |  |  | 0d |  | R1 | 6320h | 3798.78h | NB_IOT | PCG-35 | Vodafone | Rel-13 | RP-69 |  |  |  |  |  |
| 1022 | 351.5.1 | Core part: Narrowband Internet of Things (IOT) | 197d? | 2015-09-15 A | 2016-06-15 A | 100% |  |  |  |  |  | finish no earlier than 2016-06-15 | R1 | 1576h | 1576h | NB_IOT-Core | PCG-35 | Vodafone | Rel-13 | RP-69 |  |  |  |  |  |
| 1023 | 351.5.2 | Perf. part: Narrowband Internet of Things (IOT) | 264d? | 2015-12-15 A | 2016-12-15 A | 100% |  |  |  |  |  | finish no earlier than 2016-12-15 | R4 | 2112h | 2112h | NB_IOT-Perf | PCG-36 | Vodafone | Rel-13 | RP-70 |  |  |  |  |  |
| 1024 | 351.6 | Management for NB-IoT | 25d? | 2016-05-12 A | 2016-06-15 A | 100% |  |  |  |  |  | finish no earlier than 2016-06-15 | S5 | 200h | 200h | NB_IOT-OAM | PCG-37 | Huawei, Kai ZHANG | Rel-13 | TSG#72 |  | kai.zhangkai@huawei.com |  |  |  |
| 1025 | 351.7 | UE Conformance Test Aspects - Narrowband Internet of Things (NB-IOT) | 329d? | 2016-03-15 A | 2017-06-15 | 85% | 49.35d? |  |  |  | 395d | finish no earlier than 2017-06-15 | R5 | 2632h | 2237.2h | NB_IOT-UEConTest | PCG-36 | CMCC | Rel-13 | TSG#71 |  |  |  |  |  |
| 1026 | 352 | **Extended Coverage GSM (EC-GSM) for support of Cellular Internet of Things** | 255.5d? | 2015-09-25 A | 2016-09-15 | 69% | 77.98d? |  |  |  | 590d |  | G1; G2 | 8864h | 4044.7h | CIoT_EC_GSM | PCG-35 | Marteen Sunberg, Ericsson | Rel-13 | RP-69 |  | Marteen.Sunberg@Ericsson.com |  |  |  |
| 1027 | 352.1 | Extended Coverage GSM (EC-GSM) for support of Cellular Internet of Things Core part | 164.5d? | 2015-09-25 A | 2016-05-12 A | 100% |  |  |  |  |  | finish no earlier than 2016-05-12 | G1; G2 | 2632h | 2632h | CIoT_EC_GSM-Core | PCG-36 | Marteen Sunberg, Ericsson | Rel-13 | SP-70 |  | Marteen.Sunberg@Ericsson.com |  |  |  |
| 1028 | 352.2 | Test for CIoT_EC_GSM | 132d? | 2015-11-11 | 2016-05-12 |  |  |  |  |  | 681d | start no earlier than 2015-11-11 | G3 | 1056h |  | CIoT_EC_GSM_GERAN3new | PCG-36 | Sierra Wireless S.A | Rel-13 | SP-70 |  | Marteen.Sunberg@Ericsson.com |  |  |  |
| 1029 | 352.3 | Perf. Part: Extended Coverage GSM (EC-GSM) for support of Cellular Internet of Things | 68d? | 2016-06-15 A | 2016-09-15 A | 100% |  |  |  |  |  | finish no earlier than 2016-09-15 | R6 | 544h | 544h | CIoT_EC_GSM-Perf | PCG-37 | Ericsson | Rel-13 | TSG#72 |  |  |  |  |  |
| 1030 | 352.4 | MS Conformance Test Aspects - Extended Coverage GSM (EC-GSM) for support of Cellular Internet of Things | 68d? | 2016-06-15 A | 2016-09-15 A | 100% |  |  |  |  |  | finish no earlier than 2016-09-15 | R5 | 544h | 544h | CIoT_EC_GSM-MSConTest | PCG-37 | Ericsson | Rel-13 | TSG#72 |  |  |  |  |  |

Notes:
- 1007: introduction of new DL only band and 2DL/1UL CA with it
- 1008: introduction of new DL only band and 2DL/1UL CA with it. Aug 15: TR numb added 29/09/15: Compl:0%->80% 29/09/15: CD:Tue 15/03/16->Tue 15/12/15 29/09/15: WID: RP-150861->RP-151228 29/09/15: Stat Rep: -->RP-151232 29/09/15: Release: Rel-14->Rel-13 / Impacted TSs and TRs: 36.895
- 1009: introduction of new DL only band and 2DL/1UL CA with it 29/09/15: WID: RP-150861->RP-151228 29/09/15: Stat Rep: -->RP-151232 29/09/15: Release: Rel-14->Rel-13
- 1010: -
- 1011: SP#65 completed. Linked to Rel-13 SEES, Rel-12 Support for Interworking with M2M Service Enablement (MTCe-SIMSE), Service Requirement Maintenance (MTCe-SRM). Decide which MTC reqs with no Stage 2 should be removed/maintained in Rel-13. / Impacted TSs and TRs: 22.368
- 1013: 7/3/16: 0%->95 / Impacted TSs and TRs: 23.401, 23.682, 23.251
- 1014: 7/3/16: 0%->39; 19/9/16: 39%->100 / Impacted TSs and TRs: 33.401
- 1015: 11/6/16: WID:CP-150795->CP-160292
- 1016: 7/3/16: 0%->35; 11/6/16: 35%->100; 11/6/16: WID:CP-150795->CP-160292 / Impacted TSs and TRs: 24.301, 24.008, 23.122
- 1017: 7/3/16: 0%->90; 11/6/16: WID:CP-150795->CP-160292; 13/6/16: 90%->100 / Impacted TSs and TRs: 29.061, 29.212
- 1018: 7/3/16: 0%->65; 11/6/16: WID:CP-150795->CP-160292; 13/6/16: 65%->100 / Impacted TSs and TRs: 29.272, 29.274, 23.008, 23.007, 29.128, 29.275, 29.230, 29.336, 29.281, 29.002, 29.303
- 1019: 11/6/16: WID:CP-150795->CP-160292; 13/6/16: 0%->100 / Impacted TSs and TRs: 31.102
- 1020: 32.25x; 13/6/16: 0%->100 / Impacted TSs and TRs: 32.25x, 32.240, 32.251, 32.274, 32.299, 32.298, 32.297
- 1021: no Perf. part; note: WI only stays in REL-13 because of PCG decision
- 1022: no Perf. part; note: WI only stays in REL-13 because of PCG decision1/1/16: Compl:0%->25% 22/3/16: Compl:25%->75%;1/7/16: Com / Impacted TSs and TRs: 36.802
- 1023: 22/3/16: WID: RP-152284->RP-160656; 1/7/16: WID: RP-160656->RP-16093326/9/16: Compl:0%->60%26/9/16: CD:Thu 15/09/16->Thu 15/12/16; 20/12/16: Compl:60%->100%; 20/12/16: WID: RP-160933->RP-162134
- 1024: 13/6/16: 0%->100 / Impacted TSs and TRs: 28.657, 28.658, 28.659, 32.425
- 1025: testing REL-13 NB_IOT-Core1/7/16: Compl:0%->5%; 26/9; 20/12/1; 21/3/17: Compl:...
- 1026: 7/12/15: 0%->60
- 1027: 7/12/15:created by MCC to distinguish core versus test parts. 2/3/16: FCD: 11/15->05/16, 40->90%; 13/6/16: 90%->100
- 1028: 7/12/15: created GERAN. 2/3/16: G1,G2->G3, Acronym: CIoT_EC_GSM-Test->CIoT_EC_GSM_GERAN3new
- 1029: related to GERAN REL-13 WI CIoT_EC_GSM-Core26/9/16: Compl:0%->100%
- 1030: tested REL-13 WI: CIoT_EC_GSM-Core26/9/16: Compl

| ID | WBS | Task | Duration | Start | Finish | Complete | Remaining | Baseline start | Baseline finish | Baseline duration | Total slack | Constraint | Resources | Work | Actual work | Acronym | PCG approved | WI rapporteur name | WI rapporteur e-mail | Release | TSG approved | Status Report | Acronym_3GU_Export |
| --- | --- | --- | --- | --- | --- | --- | --- | --- | --- | --- | --- | --- | --- | --- | --- | --- | --- | --- | --- | --- | --- | --- | --- |
| 1031 | 353 | **Extended DRX cycle for Power Consumption** | 468d? | 2014-12-03 A | 2016-09-15 | 93% | 31.69d? |  |  |  | 590d |  | S2; R2; G2 | 27696h | 16780.9h | eDRX | PCG-35 | Miguel Griot | mgriot@qti.qualcomm.com | Rel-13 | SP-68 |  |  |
| 1032 | 353.1 | Study on Extended DRX cycle for Power Consumption Optimization | 268d? | 2014-12-03 A | 2015-12-11 A | 100% |  |  |  |  |  | finish no earlier than 2015-12-11 | S2 | 2144h | 2144h | FS_eDRX | PCG-34 | Miguel Griot, Qualcomm | mgriot@qti.qualcomm.com | Rel-13 | SP-66 |  |  |
| 1033 | 353.2 | Stage 2 for Extended DRX cycle for Power Consumption | 133d? | 2015-06-15 A | 2015-12-16 | 99% | 1.33d? |  |  |  | 787d | finish no earlier than 2015-12-16 | S2 | 1064h | 1053.36h | eDRX | PCG-35 | Miguel Griot | mgriot@qti.qualcomm.com | Rel-13 | SP-68 |  |  |
| 1034 | 353.3 | **CT aspects of extended DRX cycle** | 135d? | 2015-09-07 A | 2016-03-11 A | 100% |  |  |  |  |  |  | ct | 4912h | 4912h | eDRX-CT | PCG-35 | Catovic, Amer, Qualcomm | Catovic, Amer, Qualcomm | Rel-13 | CP-69 |  |  |
| 1035 | 353.3.1 | CT1 aspects of extended DRX cycle | 135d? | 2015-09-07 A | 2016-03-11 A | 100% |  |  |  |  |  | finish no earlier than 2016-03-11 | C1 | 1080h | 1080h | eDRX-CT | PCG-35 | Catovic, Amer, Qualcomm | Catovic, Amer, Qualcomm | Rel-13 | CP-69 |  |  |
| 1036 | 353.3.2 | CT3 aspects of extended DRX cycle | 135d? | 2015-09-07 A | 2016-03-11 A | 100% |  |  |  |  |  | finish no earlier than 2016-03-11 | C3 | 1080h | 1080h | eDRX-CT | PCG-35 | Catovic, Amer, Qualcomm | Catovic, Amer, Qualcomm | Rel-13 | CP-69 |  |  |
| 1037 | 353.3.3 | CT4 aspects of extended DRX cycle | 74d? | 2015-09-07 A | 2015-12-17 A | 100% |  |  |  |  |  | finish no earlier than 2015-12-17 | C4 | 592h | 592h | eDRX-CT | PCG-35 | Catovic, Amer, Qualcomm | Catovic, Amer, Qualcomm | Rel-13 | CP-69 |  |  |
| 1038 | 353.3.4 | CT6 aspects of extended DRX cycle | 135d? | 2015-09-07 A | 2016-03-11 A | 100% |  |  |  |  |  | finish no earlier than 2016-03-11 | C6 | 1080h | 1080h | eDRX-CT | PCG-36 | Catovic, Amer, Qualcomm | Catovic, Amer, Qualcomm | Rel-13 | CP-70 |  |  |
| 1039 | 353.4 | **RAN enhancements for extended DRX in LTE** | 262d? | 2015-03-16 A | 2016-03-15 A | 100% |  |  |  |  |  |  | R2 | 4192h | 4192h | LTE_extDRX | PCG-34 | Qualcomm |  | Rel-13 | RP-67 |  |  |
| 1040 | 353.4.1 | Core part: RAN enhancements for extended DRX in LTE | 262d? | 2015-03-16 A | 2016-03-15 A | 100% |  |  |  |  |  | finish no earlier than 2016-03-15 | R2 | 2096h | 2096h | LTE_extDRX-Core | PCG-34 | Qualcomm |  | Rel-13 | RP-67 | RP-151338 |  |
| 1041 | 353.5 | UE Conformance Test Aspects - RAN enhancements for extended DRX in LTE | 134d? | 2016-03-15 A | 2016-09-15 A | 100% |  |  |  |  |  | finish no earlier than 2016-12-15 | R5 | 1072h | 1072h | LTE_extDRX-UEConTest | PCG-36 | Qualcomm |  | Rel-13 | TSG#71 |  |  |
| 1042 | 353.6 | **Extended DRX (eDRX) for GSM** | 184.5d? | 2015-08-28 A | 2016-05-12 | 44% | 102.46d? |  |  |  | 681d |  | G2; G1 | 4832h | 2072.8h | eDRX_GSM | PCG-35 | John Diachina, Ericsson LM | John.Diachina@Ericsson.com | Rel-13 | RP-69 |  |  |
| 1043 | 353.6.1 | Core Part: Extended DRX (eDRX) for GSM | 60.5d? | 2015-08-28 A | 2015-11-20 A | 100% |  |  |  |  |  | finish no earlier than 2015-11-20 | G2; G1 | 968h | 968h | eDRX_GSM-Core | PCG-36 | John Diachina, Ericsson LM | John.Diachina@Ericsson.com | Rel-13 | SP-70 |  |  |
| 1044 | 353.6.2 | MS test: Extended DRX (eDRX) for GSM | 114d? | 2015-12-07 A | 2016-05-12 | 15% | 96.9d? |  |  |  | 681d | start no earlier than 2015-12-07 | G3 | 912h | 136.8h | eDRX_GSM_GERAN3new | PCG-36 | Sierra Wireless S.A | John.Diachina@Ericsson.com | Rel-13 | SP-70 |  |  |
| 1045 | 354 | **Optimizations to Support High Latency Communications** | 326d? | 2014-09-19 A | 2015-12-16 A | 100% |  |  |  |  |  |  | S2 | 5824h | 5824h | HLcom | PCG-34 | Ericsson, Hans Rönneke | hans.ronneke(at)ericsson.com | Rel-13 | SP-67 |  |  |
| 1046 | 354.1 | Study on Optimizations to support High Latency communications | 196d? | 2014-09-19 A | 2015-06-17 A | 100% |  |  |  |  |  | finish no earlier than 2015-06-17 | S2 | 1568h | 1568h | FS_HLcom | PCG-33 | Ericsson | hans.ronneke@ericsson.com | Rel-13 | SP-65 |  | FS_HLcom |
| 1047 | 354.2 | Optimizations to Support High Latency Communications | 73d? | 2015-03-05 A | 2015-06-15 A | 100% |  |  |  |  |  | finish no earlier than 2015-06-15 | S2 | 584h | 584h | HLcom | PCG-34 | Ericsson, Hans Rönneke | hans.ronneke(at)ericsson.com | Rel-13 | SP-67 |  |  |
| 1048 | 354.3 | CT aspects of Optimizations to Support High Latency | 133d? | 2015-06-15 A | 2015-12-16 A | 100% |  |  |  |  |  | finish no earlier than 2015-12-16 | C4 | 1064h | 1064h | HLcom-CT | PCG-35 | Yong Yang, Ericsson | frank.yong.yang@ericsson.com | Rel-13 | CP-68 |  |  |
| 1049 | 355 | **Further LTE Physical Layer Enhancements for MTC** | 723d? | 2014-09-12 A | 2017-06-15 | 96% | 27.08d? | 2014-06-13 | 2015-06-12 | 261d? | 395d |  | R1; R4; R2 | 34208h | 23056.3h | LTE_MTCe2_L1 | PCG-33 | Ericsson | johan.bergman@ericsson.com | Rel-13 | RP-65 |  | LTE_MTCe2_L1 |
| 1050 | 355.1 | Core part: Further LTE Physical Layer Enhancements for MTC | 395d? | 2014-09-12 A | 2016-03-15 A | 100% |  | 2014-06-13 | 2015-06-12 | 261d? |  | finish no earlier than 2016-03-15 | R1; R2; R4 | 9480h | 9480h | LTE_MTCe2_L1-Core | PCG-33 | Ericsson | johan.bergman@ericsson.com | Rel-13 | RP-65 | RP-151186 | LTE_MTCe2_L1-Core |
| 1051 | 355.2 | Perf. Part: Further LTE Physical Layer Enhancements for MTC | 593d? | 2014-09-12 A | 2016-12-15 A | 100% |  | 2014-06-13 | 2015-06-12 | 261d? |  | finish no earlier than 2016-12-15 | R4 | 4744h | 4744h | LTE_MTCe2_L1-Perf | PCG-33 | Ericsson | johan.bergman@ericsson.com | Rel-13 | RP-65 |  | LTE_MTCe2_L1-Perf |
| 1052 | 355.3 | UE Conformance Test Aspects - Further LTE Physical Layer Enhancements for MTC | 329d? | 2016-03-15 A | 2017-06-15 | 85% | 49.35d? |  |  |  | 395d | finish no earlier than 2017-06-15 | R5 | 2632h | 2237.2h | LTE_MTCe2_L1-UEConTest | PCG-36 | Ericsson |  | Rel-13 | TSG#71 |  |  |
| 1053 | 356 | EGPRS Access Security Enhancements in relation to Cellular IoT | 128d? | 2015-09-16 A | 2016-03-11 A | 100% |  |  |  |  |  | finish no earlier than 2016-03-11 | S3 | 1024h | 1024h | EASE_EC_GSM | PCG-35 | Vesa Torvinen, Ericsson |  | Rel-13 | SP-69 |  |  |
| 1054 | 357 | **Group based Enhancements** | 394d? | 2014-06-18 A | 2015-12-16 A | 100% |  | 2014-06-18 | 2015-09-16 | 326d? |  |  | S2; S3 | 18676.8h | 18676.8h | GROUPE | PCG-33 | Huawei | ZhangWanqiang@huawei.com | Rel-13 | SP-64 |  | GROUPE |
| 1055 | 357.1 | TR for Group based Enhancements | 196d? | 2014-06-18 A | 2015-03-18 A | 100% |  | 2014-06-18 | 2015-03-18 | 196d? |  | finish no earlier than 2015-03-18 | S2 | 1568h | 1568h | GROUPE | PCG-33 | Huawei, Wanqiang Zhang | ZhangWanqiang@huawei.com | Rel-13 | SP-64 |  |  |
| 1056 | 357.2 | Stage 2 for Group based Enhancements | 261d? | 2014-06-23 A | 2015-06-17 A | 100% |  | 2014-06-18 | 2015-06-17 | 261d? |  | finish no earlier than 2015-06-17 | S2 | 2088h | 2088h | GROUPE | PCG-33 | Huawei | ZhangWanqiang@huawei.com | Rel-13 | SP-64 |  |  |
| 1057 | 357.3 | TR on Security for Group based Enhancements | 231.6d? | 2014-06-18 A | 2015-06-12 A | 100% |  | 2014-06-18 | 2015-06-17 | 231.6d? |  | start no earlier than 2014-06-18 | S3 | 1852.8h | 1852.8h | GROUPE | PCG-33 | Samsung | Rajavelsamy R (rajvel@samsung.com) | Rel-13 | SP-64 |  |  |
| 1058 | 357.4 | Security for Group based Enhancements | 326d? | 2014-06-23 A | 2015-09-16 A | 100% |  | 2014-06-18 | 2015-09-16 | 326d? |  | finish no earlier than 2015-09-16 | S3 | 2608h | 2608h | GROUPE | PCG-33 | Samsung | Rajavelsamy R (rajvel@samsung.com) | Rel-13 | SP-64 |  |  |

Notes:
- 1031: June2015: WID:SP-150254->SP-150369 / Impacted TSs and TRs: 23.401, 23.060, 23.682, 23.271, 23.272
- 1032: No Ran aspects yet. GERAN in FS_uPoD.29/1: TS number added Mar15: 0->30%; June2015: Compl:30%->95, Exc S granted in SP-150352; 07/09/15: 95%->100 / Impacted TSs and TRs: 23.770
- 1033: June2015: WID:SP-150254->SP-150369; 07/09/15: 0%->95; 7/12/15: 95%->99 / Impacted TSs and TRs: 23.401, 23.060, 23.682, 23.271, 23.272
- 1034: 14/09/15: WID:CP-150499->CP-150541
- 1035: 14/09/15: WID:CP-150499->CP-150541; 7/12/15: 25%->80. FCD ->03/16. ES in CP-150723; 7/3/16: 80%->100 / Impacted TSs and TRs: 24.301, 24.008, 29.118
- 1036: 14/09/15: WID:CP-150499->CP-150541. FCD ->03/16. ES in CP-150723; 8/12/15: 0%->100 / Impacted TSs and TRs: 29.338, 23.007, 29.274, 29.060, 29.172
- 1037: 14/09/15: WID:CP-150499->CP-150541; 7/12/15: 40%->100; 8/12/15: 100%->95; 8/3/16: 95%->100 / Impacted TSs and TRs: 29.212
- 1038: 7/12/15: Added. FCD ->03/16. ES in CP-150723; 8/3/16: 0%->100
- 1040: 03/07/15: Compl:0%->15% 03/07/15: Stat Rep: ->RP-150798 29/09/15: Compl:15%->35% 29/09/15: WID: RP-150493->RP-151339 29/09/15: Stat Rep: RP-150798->RP-151338 ; 22/3/16: Compl:95%->100%
- 1041: testing REL-13 LTE_extDRX-Core and CT1 feature eDRX-CT;
- 1042: 07/09/15: 0%->40; 7/12/15: 40%->100 / Impacted TSs and TRs: 43.064, 44.018, 44.060, 45.008, 48.018, 43.022
- 1043: 7/12/15: created by MCC to distinguish Core versus test parts / Impacted TSs and TRs: 43.064, 44.018, 44.060, 45.008, 48.018, 43.022
- 1044: 7/12/15: created by GERAN. 2/3/16: G1,G2->G3. Acronym: eDRX_GSM-Test -> eDRX_GSM_GERAN3new (to conform to WID); 0->15%
- 1045: Impacted TSs and TRs: 23.401, 23.060, 23.682
- 1046: Dec.14: 0->30%. Mar15: 70%; June2015: Compl:70%->100 / Impacted TSs and TRs: New TR 23.709
- 1047: June 2015: created by MCC as a result of the split of the one-line Feature into a several-lines Feature (now Stage 2 and Stage 3 aspects); June2015: Compl:0%->100. WID: SP-150030->SP-150252 / Impacted TSs and TRs: 23.401, 23.060, 23.682
- 1048: 07/09/15: 0%->80; 7/12/15: 80%->100 / Impacted TSs and TRs: 29.274, 29.060, 29.281, 23.008, 29.272, 29.230, 29.002, 29.336, 29.xyz
- 1049: Triggered by Rel-12 TR 36.888 Study on Provision of low-cost MTC UEs based on LTE (FS_LC_MTC_LTE) and Low cost & enhanced coverage MTC UE for LTE (LC_MTC_UE) / Impacted TSs and TRs: LTE
- 1050: 3/3/15: WID: RP-141865; Stat Rep: -->RP-141785 1st Apr 15: Compl:10%->25% 1st Apr 15: WID: RP-141865->RP-150492 1st Apr 15: Stat Rep: RP-141785->RP-150495 03/07/15: Compl:25%->45% 03/07/15: Stat Rep: RP-150495->RP-150583 29/09/15: Compl:45%->65% 29/09 / Impacted TSs and TRs: 36.101, 36.104, 36.133, 36.201, 36.211, 36.212, 36.213, 36.214, 36.300, 36.302, 36.306, 36.321, 36.331
- 1051: ; WID: RP-142043->RP-141865; Stat Rep: -->RP-141785 1st Apr 15: WID: RP-141865->RP-150492 1st Apr 15: Stat Rep: RP-141785->RP-150495 03/07/15: Stat Rep: RP-150495->RP-150583 29/09/15: Stat Rep: RP-150583->RP-151186 ;26/9/16: Compl:70%-; / Impacted TSs and TRs: 36.101, 36.104, 36.133
- 1052: testing REL-13 LTE_MTCe2_L1-Core; 1/7/16: Compl:0%->6%; 26/; 2; 21/3/17: Compl:70%...
- 1053: 7/12/15: 0%->5; 28/1/16: 33.420 added; 7/3/16: 5%->80; 11/6/16: 80%->98; 19/9/16: 98%->99; 21/3/17: 99%->100 / Impacted TSs and TRs: New 33.420
- 1054: - / Impacted TSs and TRs: Stage 2
- 1055: Dec.14: 20->70%. Mar15: 90%; June2015: Compl:90%->100 / Impacted TSs and TRs: New TR 23.769
- 1056: Mar15: 0->20%; June2015: Compl:20%->100 / Impacted TSs and TRs: 23.682, TBD
- 1057: TR 33.8xy will capture requirements, solution alternatives, evaluations and conclusions for the AESE, MONTE and GROUPE WIDs. 3/3/15: 5->10%.; June2015: Compl:10%->60; 11/12/15: 60%->100 / Impacted TSs and TRs: New TR 33.889
- 1058: -; 11/12/15: 0%->100 / Impacted TSs and TRs: 33.187

| ID | WBS | Task | Duration | Start | Finish | Complete | Baseline start | Baseline finish | Baseline duration | Constraint | Resources | Work | Actual work | Acronym | PCG approved | WI rapporteur name | WI rapporteur e-mail | Release | TSG approved | Acronym_3GU_Export | Status Report | MCC resp | Special Focus Doc |
| --- | --- | --- | --- | --- | --- | --- | --- | --- | --- | --- | --- | --- | --- | --- | --- | --- | --- | --- | --- | --- | --- | --- | --- |
| 1059 | 357.5 | **CT aspects of Group based Enhancements** | 133d? | 2015-06-15 A | 2015-12-16 A | 100% |  |  |  |  | C4 | 4256h | 4256h | GROUPE-CT | PCG-35 | Peter Schmitt, Huawei | Peter.Schmitt@huawei.com | Rel-13 | CP-68 |  |  |  |  |
| 1060 | 357.5.1 | CT1 aspects of Group based Enhancements | 133d? | 2015-06-15 A | 2015-12-16 A | 100% |  |  |  | start no earlier than 2015-06-15 | C1 | 1064h | 1064h | GROUPE-CT | PCG-35 | Peter Schmitt, Huawei | Peter.Schmitt@huawei.com | Rel-13 | CP-68 |  |  |  |  |
| 1061 | 357.5.2 | DELETED: CT3 aspects of Group based Enhancements | 133d? | 2015-06-15 A | 2015-12-16 A | 100% |  |  |  | start no earlier than 2015-06-15 | C3 | 1064h | 1064h | GROUPE-CT | PCG-35 | Peter Schmitt, Huawei | Peter.Schmitt@huawei.com | Rel-13 | CP-68 |  |  |  |  |
| 1062 | 357.5.3 | CT4 aspects of Group based Enhancements | 133d? | 2015-06-15 A | 2015-12-16 A | 100% |  |  |  | start no earlier than 2015-06-15 | C4 | 1064h | 1064h | GROUPE-CT | PCG-35 | Peter Schmitt, Huawei | Peter.Schmitt@huawei.com | Rel-13 | CP-68 |  |  |  |  |
| 1063 | 358 | **Monitoring Enhancements** | 456d? | 2014-06-18 A | 2016-03-11 A | 100% | 2014-06-18 | 2015-09-16 | 326d? |  | S2; S3 | 21684.8h | 21684.8h | MONTE | PCG-33 | Intel | puneet.jain@intel.com | Rel-13 | SP-64 | MONTE |  |  |  |
| 1064 | 358.1 | TR for Monitoring Enhancements | 196d? | 2014-09-17 A | 2015-06-17 A | 100% | 2014-09-17 | 2015-06-17 | 196d? | finish no earlier than 2015-06-17 | S2 | 1568h | 1568h | MONTE | PCG-33 | Intel, Puneet Jain | puneet.jain@intel.com | Rel-13 | SP-64 |  |  |  |  |
| 1065 | 358.2 | Stage 2 for Monitoring Enhancements | 261d? | 2014-06-23 A | 2015-06-17 A | 100% | 2014-06-18 | 2015-06-17 | 261d? | finish no earlier than 2015-06-17 | S2 | 2088h | 2088h | MONTE | PCG-33 | Intel, Puneet Jain | puneet.jain@intel.com | Rel-13 | SP-64 |  |  |  |  |
| 1066 | 358.3 | TR on Security for Monitoring Enhancements | 231.6d? | 2014-06-18 A | 2015-06-12 A | 100% | 2014-06-18 | 2015-06-17 | 231.6d? | start no earlier than 2014-06-18 | S3 | 1852.8h | 1852.8h | MONTE | PCG-33 | Samsung | Rajavelsamy R (rajvel@samsung.com) | Rel-13 | SP-64 |  |  |  |  |
| 1067 | 358.4 | Security for Monitoring Enhancements | 326d? | 2014-06-23 A | 2015-09-16 A | 100% | 2014-06-18 | 2015-09-16 | 326d? | finish no earlier than 2015-09-16 | S3 | 2608h | 2608h | MONTE | PCG-33 | Samsung | Rajavelsamy R (rajvel@samsung.com) | Rel-13 | SP-64 |  |  |  |  |
| 1068 | 358.5 | Charging aspects of MONTE | 128d? | 2015-09-16 A | 2016-03-11 A | 100% | 2014-06-18 | 2015-09-16 | 326d? | finish no earlier than 2016-03-11 | S5 | 1024h | 1024h | MONTE-CH | PCG-35 | Huawei(Li Li, jasmine.li@huawei.com) | jasmine.li@huawei.com | Rel-13 | CP-69 |  |  |  |  |
| 1069 | 358.6 | **Monitoring Enhancements CT aspects** | 195d? | 2015-06-15 A | 2016-03-11 A | 100% |  |  |  |  | C4 | 5248h | 5248h | MONTE-CT | PCG-35 | Peter Schmitt, Huawei | peter.schmitt@huawei.com | Rel-13 | CP-68 |  |  |  |  |
| 1070 | 358.6.1 | CT1 aspects of Monitoring Enhancements | 133d? | 2015-06-15 A | 2015-12-16 A | 100% |  |  |  | start no earlier than 2015-06-15 | C1 | 1064h | 1064h | MONTE-CT | PCG-35 | Peter Schmitt, Huawei | peter.schmitt@huawei.com | Rel-13 | CP-68 |  |  |  |  |
| 1071 | 358.6.2 | CT3 aspects of Monitoring Enhancements | 133d? | 2015-06-15 A | 2015-12-16 A | 100% |  |  |  | start no earlier than 2015-06-15 | C3 | 1064h | 1064h | MONTE-CT | PCG-35 | Peter Schmitt, Huawei | peter.schmitt@huawei.com | Rel-13 | CP-68 |  |  |  |  |
| 1072 | 358.6.3 | CT4 aspects of Monitoring Enhancements | 195d? | 2015-06-15 A | 2016-03-11 A | 100% |  |  |  | finish no earlier than 2016-03-11 | C4 | 1560h | 1560h | MONTE-CT | PCG-35 | Peter Schmitt, Huawei | peter.schmitt@huawei.com | Rel-13 | CP-68 |  |  |  |  |
| 1073 | 359 | **Dedicated Core Networks** | 456d? | 2014-06-18 A | 2016-03-11 A | 100% | 2014-06-18 | 2015-03-18 | 196d? |  | S2 | 11518.4h | 11518.4h | DECOR | PCG-33 | NTT DOCOMO | Daisuke Fujishima (fujishimad@nttdocomo.co.jp) | Rel-13 | SP-64 | DECOR |  |  |  |
| 1074 | 359.1 | TR for Dedicated Core Networks | 128d? | 2014-06-18 A | 2014-12-12 A | 100% | 2014-06-18 | 2014-12-10 | 126d? | finish no earlier than 2014-12-12 | S2 | 1024h | 1024h | DECOR | PCG-33 | NTT DOCOMO | Daisuke Fujishima (fujishimad@nttdocomo.co.jp) | Rel-13 | SP-64 |  |  |  |  |
| 1075 | 359.2 | Stage 2 for Dedicated Core Networks | 196d? | 2014-06-23 A | 2015-03-18 A | 100% | 2014-06-18 | 2015-03-18 | 196d? | finish no earlier than 2015-03-18 | S2 | 1568h | 1568h | DECOR | PCG-33 | NTT DOCOMO | Daisuke Fujishima (fujishimad@nttdocomo.co.jp) | Rel-13 | SP-64 |  |  |  |  |
| 1076 | 359.3 | **CT aspects of Dedicated Core Networks** | 186.8d? | 2015-06-25 A | 2016-03-11 A | 100% |  |  |  |  | ct | 3166.4h | 3166.4h | DECOR-CT | PCG-35 | Huawei, Xiaoyan SHI (Sean.shixiaoyan@huawei.com) | Huawei, Xiaoyan SHI (Sean.shixiaoyan@huawei.com) | Rel-13 | CP-69 |  |  |  |  |
| 1077 | 359.3.1 | CT1 aspects for Dedicated Core Networks CT aspects | 74d? | 2015-09-07 A | 2015-12-17 A | 100% |  |  |  | finish no earlier than 2015-12-17 | C1 | 592h | 592h | DECOR-CT | PCG-35 | Huawei |  | Rel-13 | CP-69 |  |  |  |  |
| 1078 | 359.3.2 | CT4 aspects for Dedicated Core Networks CT aspects | 135d? | 2015-06-25 A | 2016-03-11 A | 100% |  |  |  | finish no earlier than 2016-03-11 | C4 | 1080h | 1080h | DECOR-CT | PCG-35 |  |  | Rel-13 | CP-69 |  |  |  |  |
| 1079 | 359.4 | **Dedicated Core Networks RAN Aspects** | 132d? | 2015-06-15 A | 2015-12-15 A | 100% |  |  |  |  | R3 | 2112h | 2112h | DECOR-UTRA_LTE | PCG-35 | Ericsson |  | Rel-13 | TSG-68 |  |  |  |  |
| 1080 | 359.4.1 | Core part: Dedicated Core Networks | 132d? | 2015-06-15 A | 2015-12-15 A | 100% |  |  |  | finish no earlier than 2015-12-15 | R3 | 1056h | 1056h | DECOR-UTRA_LTE-Core | PCG-35 | Ericsson |  | Rel-13 | TSG-68 |  | RP-151290 |  |  |
| 1081 | 360 | **Service Exposure and Enablement Support** | 268d? | 2013-09-12 A | 2014-09-17 A | 100% | 2013-09-12 | 2014-09-17 | 267d? |  | S1 | 5880h | 5880h | SEES | PCG-31 | KPN | toon.norp@tno.nl | Rel-13 | SP-61 | SEES | S1-143301 | Alain | MTC, M2M |
| 1082 | 360.1 | TR on Stage 1 for Service Exposure and Enablement Support | 202d? | 2013-09-12 A | 2014-06-18 A | 100% | 2013-09-12 | 2014-06-18 | 202d? | finish no earlier than 2014-06-18 | S1 | 1608h | 1608h | SEES | PCG-31 | KPN | toon.norp@tno.nl | Rel-13 | SP-61 |  | S1-143301 | Alain | MTC, M2M |
| 1083 | 360.2 | Stage 1 for Service Exposure and Enablement Support | 266d? | 2013-09-12 A | 2014-09-17 A | 100% | 2013-09-12 | 2014-09-17 | 266d? | finish no earlier than 2014-09-17 | S1 | 2128h | 2128h | SEES | PCG-31 | KPN | toon.norp@tno.nl | Rel-13 | SP-61 |  | S1-143301 | Alain | MTC, M2M |

Notes:
- 1059: 7/12/15: WID:CP-150240->CP-150816 / Impacted TSs and TRs: 24.008, 24.301, 29.468, 29.272, 23.008, 29.336, 29.303, 29.002, 29.230, 29.305, 23.003
- 1060: 07/09/15: 0%->15; 7/12/15: 15%->100; 7/12/15: WID:CP-150240->CP-150816 / Impacted TSs and TRs: 24.008, 24.301
- 1061: 7/12/15: WID:CP-150240->CP-150816. CT3 task removed / Impacted TSs and TRs: 29.468
- 1062: 07/09/15: 0%->80; 7/12/15: 80%->100; 7/12/15: WID:CP-150240->CP-150816 / Impacted TSs and TRs: 29.272, 23.008, 29.336, 29.303, 29.002, 29.230, 29.305, 23.003
- 1063: Linked to Rel-13 Feature Architecture Enhancements for Service Exposure (AESE). Although service requirements (TS 22.368 clause 7.2.8) are motivated by MTC, the solution may apply to normal UEs; 5/10/15: 32.278 added; / Impacted TSs and TRs: 32.278
- 1064: Dec.14: 25->85%. Mar15: 100% / Impacted TSs and TRs: New TR 23.789
- 1065: -; June2015: Compl:0%->100 / Impacted TSs and TRs: 23.682, TBD
- 1066: TR 33.8xy will capture requirements, solution alternatives, evaluations and conclusions for the AESE, MONTE and GROUPE WIDs.3/3/15: 5->10%.; June2015: Compl:10%->15; 11/12/15: 15%->100 / Impacted TSs and TRs: New TR 33.889
- 1067: -; 11/12/15: 0%->100 / Impacted TSs and TRs: 33.187
- 1068: 7/10/15: acronym changed from "MONTE" to "MONTE-CH"; 7/12/15: 0%->50. ES in SP-150709 (wrong UID in the ES); 7/3/16: 25%->100 / Impacted TSs and TRs: 32.27x, 32.240, 32.299, 32.298
- 1069: 14/09/15: WID:CP-150396->CP-150422
- 1070: 07/09/15: 0%->95; 14/09/15: WID:CP-150396->CP-150422; 7/12/15: 95%->100 / Impacted TSs and TRs: 24.301, 24.008
- 1071: 07/09/15: 0%->100; 14/09/15: WID:CP-150396->CP-150422 / Impacted TSs and TRs: 29.214, 29.213, 29.201
- 1072: 61907/09/15: 0%->50; 14/09/15: WID:CP-150396->CP-150422; 7/12/15: 50%->85. FCD -> 03/16, ES in CP-150619; 7/3/16: 85%->100 / Impacted TSs and TRs: New TS 29.128, 29.272, 29.002, 29.336, 29.230, 23.008
- 1073: 06/15: WID: SP-140707-> SP-150249 / Impacted TSs and TRs: Stage 2
- 1074: Dec.14: 30->100%. 06/15: WID: SP-140707-> SP-150249 / Impacted TSs and TRs: New TR 23.707
- 1075: Mar15: 0->70%; June2015: Compl:70%->100, WID: SP-140707-> SP-150249 / Impacted TSs and TRs: 23.060, 23.401, 23.236
- 1077: 7/12/15: 0%->100 / Impacted TSs and TRs: 24.301, 24.008
- 1078: 7/12/15: 70%->90. FCD -> 03/16, ES CP-150617; 7/3/16: 90%->100 / Impacted TSs and TRs: 29.274, 29.060, 23.003, 29.272, 29.002, 29.305, 23.008, 29.230, 29.303, 23.007
- 1079: no Perf. part; note: DECOR is a REL-13 SA2 WI;
- 1080: no Perf. part; note: DECOR is a REL-13 SA2 WI; 29/09/15: Compl:0%->30% 29/09/15: Stat Rep: -->RP-1512901/1/16: Compl:30%->100%
- 1081: SP#62 completion 06/14=>09/14. Linked to Rel-12 Study TR 22.888 (FS_MTCe) and to Features Rel-11 SIMTC & Rel-12 MTCe and MOSAP / Impacted TSs and TRs: Stage 1
- 1082: SP#64 completed. TR 22.853v200 for Approval. External requirements from oneM2M TR0001(oneM2M Use Case collection), TS0002 (M2M Requirements) / Impacted TSs and TRs: New TR 22.853
- 1083: SP#65 completed / Impacted TSs and TRs: 22.101, 22.115, 22.368, TBD

| ID | WBS | Task | Duration | Start | Finish | Complete | Remaining | Baseline start | Baseline finish | Baseline duration | Total slack | Constraint | Resources | Work | Actual work | Acronym | PCG approved | WI rapporteur name | WI rapporteur e-mail | Release | TSG approved | Acronym_3GU_Export | MCC resp | Special Focus Doc | Status Report |
| --- | --- | --- | --- | --- | --- | --- | --- | --- | --- | --- | --- | --- | --- | --- | --- | --- | --- | --- | --- | --- | --- | --- | --- | --- | --- |
| 1084 | 361 | **Architecture Enhancements for Service capability Exposure** | 456d? | 2014-06-18 A | 2016-03-11 A | 100% |  | 2014-06-18 | 2015-09-16 | 326d? |  |  | S2; S3 | 19675.2h | 16027.2h | AESE | PCG-33 | Intel | puneet.jain@intel.com | Rel-13 | SP-64 | AESE |  |  |  |
| 1085 | 361.1 | TR for Architecture Enhancements for Service capability Exposure | 196d? | 2014-06-18 A | 2015-03-18 A | 100% |  | 2014-06-18 | 2015-03-18 | 196d? |  | finish no earlier than 2015-03-18 | S2 | 1568h | 1568h | AESE | PCG-33 | Intel, Puneet Jain | puneet.jain@intel.com | Rel-13 | SP-64 |  |  |  |  |
| 1086 | 361.2 | Stage 2 for Architecture Enhancements for Service capability Exposure | 261d? | 2014-06-23 A | 2015-06-17 A | 100% |  | 2014-06-18 | 2015-06-17 | 261d? |  | finish no earlier than 2015-06-17 | S2 | 2088h | 2088h | AESE | PCG-33 | Intel, Puneet Jain | puneet.jain@intel.com | Rel-13 | SP-64 |  |  |  |  |
| 1087 | 361.3 | TR on Security for Architecture Enhancements for Service capability Exposure | 241.4d? | 2014-06-23 A | 2015-06-17 A | 100% |  | 2014-06-18 | 2015-06-17 | 241.4d? |  | finish no earlier than 2015-06-17 | S3 | 1931.2h | 1931.2h | AESE | PCG-33 | Samsung | Rajavelsamy R (rajvel@samsung.com) | Rel-13 | SP-64 |  |  |  |  |
| 1088 | 361.4 | Security for Architecture Enhancements for Service capability Exposure | 326d? | 2014-06-23 A | 2015-09-16 A | 100% |  | 2014-06-18 | 2015-09-16 | 326d? |  | finish no earlier than 2015-09-16 | S3 | 2608h | 2608h | AESE | PCG-33 | Samsung | Rajavelsamy R (rajvel@samsung.com) | Rel-13 | SP-64 |  |  |  |  |
| 1089 | 361.5 | **CT aspects of Architecture Enhancements for Service capability Exposure** | 195d? | 2015-06-15 A | 2016-03-11 A | 100% |  |  |  |  |  |  | C3 | 4184h | 4184h | AESE-CT | PCG-35 | Yizhuang Wu, Huawei | wuyizhuang@huawei.com | Rel-13 | CP-68 |  |  |  |  |
| 1090 | 361.5.1 | CT3 aspects of Architecture Enhancements for Service capability Exposure | 195d? | 2015-06-15 A | 2016-03-11 A | 100% |  |  |  |  |  | finish no earlier than 2016-03-11 | C3 | 1560h | 1560h | AESE-CT | PCG-35 | Yizhuang Wu, Huawei. FCD+3, ES in 642 | wuyizhuang@huawei.com | Rel-13 | CP-68 |  |  |  |  |
| 1091 | 361.5.2 | CT4 aspects of Architecture Enhancements for Service capability Exposure | 133d? | 2015-06-15 A | 2015-12-16 A | 100% |  |  |  |  |  | start no earlier than 2015-06-15 | C4 | 1064h | 1064h | AESE-CT | PCG-35 | Yizhuang Wu, Huawei | wuyizhuang@huawei.com | Rel-13 | CP-68 |  |  |  |  |
| 1092 | 362 | **Rel-13 LTE Carrier Aggregation** | 1055d? | 2013-12-09 A | 2017-12-15 | 94% | 65.64d? | 2014-03-06 | 2015-06-12 | 332d? | 264d |  | R4 | 550376h | 506648h | LTE_CA_Rel13 | PCG-30 |  |  | Rel-13 | RP-58 | LTE_CA_Rel-13 | Issam | CA |  |
| 1093 | 362.1 | **LTE Advanced 4 Band Carrier Aggregation (4DL/1UL) of Band 4, Band 4, Band 5 and Band 12** | 66d? | 2015-09-15 A | 2015-12-15 A | 100% |  |  |  |  |  |  | R4 | 1584h | 1584h | LTE_CA_B4_B4_B5_B12 | PCG-35 | US Cellular |  | Rel-13 | RP-69 |  |  |  |  |
| 1094 | 362.1.1 | Core part: LTE Advanced 4 Band Carrier Aggregation (4DL/1UL) of Band 4, Band 4, Band 5 and Band 12 | 66d? | 2015-09-15 A | 2015-12-15 A | 100% |  |  |  |  |  | finish no earlier than 2016-03-15 | R4 | 528h | 528h | LTE_CA_B4_B4_B5_B12-Core | PCG-35 | US Cellular |  | Rel-13 | RP-69 |  |  |  |  |
| 1095 | 362.1.2 | Perf. part: LTE Advanced 4 Band Carrier Aggregation (4DL/1UL) of Band 4, Band 4, Band 5 and Band 12 | 66d? | 2015-09-15 A | 2015-12-15 A | 100% |  |  |  |  |  | finish no earlier than 2016-03-15 | R4 | 528h | 528h | LTE_CA_B4_B4_B5_B12-Perf | PCG-35 | US Cellular |  | Rel-13 | RP-69 |  |  |  |  |
| 1096 | 362.2 | **LTE Advanced 4 Band Carrier Aggregation (4DL/1UL) of Band 2, Band 4, Band 4 and Band 5** | 66d? | 2015-09-15 A | 2015-12-15 A | 100% |  |  |  |  |  |  | R4 | 1584h | 1584h | LTE_CA_B2_B4_B4_B5 | PCG-35 | US Cellular |  | Rel-13 | RP-69 |  |  |  |  |
| 1097 | 362.2.1 | Core part: LTE Advanced 4 Band Carrier Aggregation (4DL/1UL) of Band 2, Band 4, Band 4 and Band 5 | 66d? | 2015-09-15 A | 2015-12-15 A | 100% |  |  |  |  |  | finish no earlier than 2016-03-15 | R4 | 528h | 528h | LTE_CA_B2_B4_B4_B5-Core | PCG-35 | US Cellular |  | Rel-13 | RP-69 |  |  |  |  |
| 1098 | 362.2.2 | Perf. part: LTE Advanced 4 Band Carrier Aggregation (4DL/1UL) of Band 2, Band 4, Band 4 and Band 5 | 66d? | 2015-09-15 A | 2015-12-15 A | 100% |  |  |  |  |  | finish no earlier than 2016-03-15 | R4 | 528h | 528h | LTE_CA_B2_B4_B4_B5-Perf | PCG-35 | US Cellular |  | Rel-13 | RP-69 |  |  |  |  |
| 1099 | 362.3 | **LTE Advanced inter-band Carrier Aggregation of Band 8 and Band 27** | 531d? | 2013-12-09 A | 2015-12-15 | 30% | 371.7d? | 2013-12-09 | 2014-12-11 | 265d? | 788d |  | R4 | 12696h | 2643.08h | LTE_CA_B8_B27 | PCG-32 | KT | ilwhan.kim@kt.com | Rel-13 | RP-62 | LTE_CA_B8_B27 | Issam | CA |  |
| 1100 | 362.3.1 | Core part: LTE Advanced inter-band Carrier Aggregation of Band 8 and Band 27 | 528d? | 2013-12-09 A | 2015-12-15 | 30% | 369.6d? | 2013-12-09 | 2014-12-11 | 265d? | 788d | finish no earlier than 2015-12-15 | R4 | 4224h | 1267.2h | LTE_CA_B8_B27-Core | PCG-32 | KT | ilwhan.kim@kt.com | Rel-13 | RP-62 | LTE_CA_B8_B27-Core | Issam | CA | RP-151131 |
| 1101 | 362.3.2 | Perf. part: LTE Advanced inter-band Carrier Aggregation of Band 8 and Band 27 | 528d? | 2013-12-09 A | 2015-12-15 | 30% | 369.6d? | 2013-12-09 | 2014-12-11 | 265d? | 788d | finish no earlier than 2015-12-15 | R4 | 4224h | 1267.2h | LTE_CA_B8_B27-Perf | PCG-32 | KT | ilwhan.kim@kt.com | Rel-13 | RP-62 | LTE_CA_B8_B27-Perf | Issam | CA | RP-151131 |
| 1102 | 362.4 | **LTE Advanced 3 band Carrier Aggregation (3DL/1UL) for Band 3, Band 8 and Band 27** | 531d? | 2013-12-09 A | 2015-12-15 | 25% | 398.25d? | 2013-12-09 | 2014-12-05 | 261d? | 788d |  | R4 | 12696h | 2384h | LTE_CA_B3_B8_B27 | PCG-32 | KT | Chungwoo HWANG (cwhwang@kt.com) | Rel-13 | RP-62 | LTE_CA_B3_B8_B27 | Issam | CA |  |
| 1103 | 362.4.1 | Core part: LTE Advanced 3 band Carrier Aggregation (3DL/1UL) for Band 3, Band 8 and Band 27 | 528d? | 2013-12-09 A | 2015-12-15 | 25% | 396d? | 2013-12-09 | 2014-12-05 | 261d? | 788d | finish no earlier than 2015-12-15 | R4 | 4224h | 1056h | LTE_CA_B3_B8_B27-Core | PCG-32 | KT | Chungwoo HWANG (cwhwang@kt.com) | Rel-13 | RP-62 | LTE_CA_B3_B8_B27-Core | Issam | CA | RP-151131 |
| 1104 | 362.4.2 | Perf. part: LTE Advanced 3 band Carrier Aggregation (3DL/1UL) for Band 3, Band 8 and Band 27 | 528d? | 2013-12-09 A | 2015-12-15 | 25% | 396d? | 2013-12-09 | 2014-12-05 | 261d? | 788d | finish no earlier than 2015-12-15 | R4 | 4224h | 1056h | LTE_CA_B3_B8_B27-Perf | PCG-32 | KT | Chungwoo HWANG (cwhwang@kt.com) | Rel-13 | RP-62 | LTE_CA_B3_B8_B27-Perf | Issam | CA | RP-151131 |
| 1105 | 362.5 | **LTE Advanced inter-band Carrier Aggregation of Band 7 and Band 22** | 336d? | 2014-03-06 A | 2015-06-15 A | 100% |  | 2014-03-06 | 2014-12-05 | 197d? |  |  | R4 | 8016h | 8016h | LTE_CA_B7_B22 | PCG-32 | Orange, Ericsson | erika.tejedor@ericsson.com | Rel-13 | RP-63 | LTE_CA_B7_B22 | Issam | CA |  |
| 1106 | 362.5.1 | Core part: LTE Advanced inter-band Carrier Aggregation of Band 7 and Band 22 | 333d? | 2014-03-06 A | 2015-06-15 A | 100% |  | 2014-03-06 | 2014-12-05 | 197d? |  | finish no earlier than 2015-06-15 | R4 | 2664h | 2664h | LTE_CA_B7_B22-Core | PCG-32 | Orange, Ericsson | erika.tejedor@ericsson.com | Rel-13 | RP-63 | LTE_CA_B7_B22-Core | Issam | CA | RP-150536 |
| 1107 | 362.5.2 | Perf. part: LTE Advanced inter-band Carrier Aggregation of Band 7 and Band 22 | 333d? | 2014-03-11 A | 2015-06-15 A | 100% |  | 2014-03-06 | 2014-12-05 | 197d? |  | finish no earlier than 2015-06-15 | R4 | 2664h | 2664h | LTE_CA_B7_B22-Perf | PCG-32 | Orange, Ericsson | erika.tejedor@ericsson.com | Rel-13 | RP-63 | LTE_CA_B7_B22-Perf | Issam | CA | RP-150536 |

Notes:
- 1084: - / Impacted TSs and TRs: Stage 2
- 1085: Dec.14: 30->65%. Mar15: 75%; June2015: Compl:75%->100 / Impacted TSs and TRs: New TR 23.708
- 1086: -; June2015: Compl:0%->100 / Impacted TSs and TRs: TS 23.682, TS 33.187
- 1087: TR 33.8xy will capture requirements, solution alternatives, evaluations and conclusions for the AESE, MONTE and GROUPE WIDs. Dec.14: 0->40%. 3/3/15: 45%.; June2015: Compl:45%->60; 11/12/15: 60%->100 / Impacted TSs and TRs: New TR 33.889
- 1088: -; 11/12/15: 0%->100 / Impacted TSs and TRs: 33.187
- 1089: 14/09/15: WID:CP-150402->CP-150487->CP-150576
- 1090: 07/09/15: 0%->35; 14/09/15: WID:CP-150402->CP-150487->CP-150576; 7/12/15: 35%->90; 7/3/16: 90%->100 / Impacted TSs and TRs: 29.154
- 1091: 07/09/15: 0%->40; 14/09/15: WID:CP-150402->CP-150487->CP-150576; 7/12/15: 40%->100 / Impacted TSs and TRs: 29.201, 29.336, 29.230, 29.272, 23.008
- 1092: Acronym changed from "LTE_CA_Rel-13" to "LTE_CA_Rel13"
- 1093: 13/6/16: moved from Rel-14 to Rel-13 (was a mistake)
- 1094: 13/6/16: moved from Rel-14 to Rel-13 (was a mistake)
- 1095: 13/6/16: moved from Rel-14 to Rel-13 (was a mistake)
- 1096: 13/6/16: moved from Rel-14 to Rel-13 (was a mistake)
- 1097: 13/6/16: moved from Rel-14 to Rel-13 (was a mistake)
- 1098: 13/6/16: moved from Rel-14 to Rel-13 (was a mistake)
- 1099: Inter-band CA 2DL/1UL / Impacted TSs and TRs: LTE
- 1100: CD:Thu 18/06/15->Mon 15/06/15; Compl:10%->10%; Stat Rep: RP-141084->RP-141732 1st Apr 15: Compl:10%->15% 1st Apr 15: Stat Rep: RP-141732->RP-150013 03/07/15: Compl:15%->30% 03/07/15: CD:Mon 15/06/15->Tue 15/12/15 03/07/15: Stat Rep: RP-150013->RP-15053 / Impacted TSs and TRs: 36.101, 36.104, 36.133, generic TR 36.851
- 1101: CD:Thu 18/06/15->Mon 15/06/15; Compl:10%->10%; Stat Rep: RP-141084->RP-141732 1st Apr 15: Compl:10%->15% 1st Apr 15: Stat Rep: RP-141732->RP-150013 03/07/15: Compl:15%->30% 03/07/15: CD:Mon 15/06/15->Tue 15/12/15 03/07/15: Stat Rep: RP-150013->RP-15053 / Impacted TSs and TRs: 36.141, 36.307
- 1102: Inter-band CA 3DL / Impacted TSs and TRs: LTE
- 1103: CD:Thu 18/06/15->Mon 15/06/15; Compl:25%->25%; Stat Rep: RP-141084->RP-141732 1st Apr 15: Compl:25%->30% 1st Apr 15: Stat Rep: RP-141732->RP-150013 03/07/15: Compl:30%->25% 03/07/15: CD:Mon 15/06/15->Tue 15/12/15 03/07/15: Stat Rep: RP-150013->RP-15053 / Impacted TSs and TRs: 36.101, 36.104, 36.133, 36.141, 36.307, new generic TR 36.853 (3 Band CA with 1UL)
- 1104: CD:Thu 18/06/15->Mon 15/06/15; Compl:25%->25%; Stat Rep: RP-141084->RP-141732 1st Apr 15: Compl:25%->30% 1st Apr 15: Stat Rep: RP-141732->RP-150013 03/07/15: Compl:30%->25% 03/07/15: CD:Mon 15/06/15->Tue 15/12/15 03/07/15: Stat Rep: RP-150013->RP-15053 / Impacted TSs and TRs: 36.101, 36.104, 36.133, 36.141, 36.307
- 1105: Inter-band CA 2DL / Impacted TSs and TRs: LTE
- 1106: CD:Thu 11/12/14->Mon 15/06/15; Compl:10%->10%; Stat Rep: RP-141084->RP-141732 03/07/15: Compl:10%->100% 03/07/15: Stat Rep: RP-141732->RP-150536 / Impacted TSs and TRs: 36.101, 36.104, 36.133, generic TR 36.851 (2 Band CA with 1UL),
- 1107: CD:Thu 11/12/14->Mon 15/06/15; Compl:0%->0%; Stat Rep: RP-141084->RP-141732 03/07/15: Compl:0%->100% 03/07/15: Stat Rep: RP-141732->RP-150536 / Impacted TSs and TRs: 36.141, 36.307

| ID | WBS | Task | Duration | Start | Finish | Complete | Baseline start | Baseline finish | Baseline duration | Constraint | Resources | Work | Actual work | Acronym | PCG approved | WI rapporteur name | WI rapporteur e-mail | Release | TSG approved | Special Focus Doc | Acronym_3GU_Export | Status Report |
| --- | --- | --- | --- | --- | --- | --- | --- | --- | --- | --- | --- | --- | --- | --- | --- | --- | --- | --- | --- | --- | --- | --- |
| 1108 | 362.6 | **LTE Advanced 3 Band Carrier Aggregation (3DL/1UL) for Band 2, Band 2 and Band 12** | 262d? | 2014-06-18 A | 2015-06-15 A | 100% | 2014-06-13 | 2015-03-13 | 196d? |  | R4 | 6288h | 6288h | LTE_CA_B2_B2_B12 | PCG-33 | U.S. Cellular | sebastian.thalanany@uscellular.com | Rel-13 | RP-64 | CA | LTE_CA_B2_B2_B12 |  |
| 1109 | 362.6.1 | Core part: LTE Advanced 3 Band Carrier Aggregation (3DL/1UL) for Band 2, Band 2 and Band 12 | 262d? | 2014-06-18 A | 2015-06-15 A | 100% | 2014-06-13 | 2014-12-05 | 126d? | finish no earlier than 2015-06-15 | R4 | 2096h | 2096h | LTE_CA_B2_B2_B12-Core | PCG-33 | U.S. Cellular | sebastian.thalanany@uscellular.com | Rel-13 | RP-64 | CA | LTE_CA_B2_B2_B12-Core | RP-150536 |
| 1110 | 362.6.2 | Perf. Part: LTE Advanced 3 Band Carrier Aggregation (3DL/1UL) for Band 2, Band 2 and Band 12 | 262d? | 2014-06-18 A | 2015-06-15 A | 100% | 2014-06-13 | 2015-03-13 | 196d? | finish no earlier than 2015-06-15 | R4 | 2096h | 2096h | LTE_CA_B2_B2_B12-Perf | PCG-33 | U.S. Cellular | sebastian.thalanany@uscellular.com | Rel-13 | RP-64 | CA | LTE_CA_B2_B2_B12-Perf | RP-150536 |
| 1111 | 362.7 | **LTE Advanced 3 Band Carrier Aggregation (3DL/1UL) of Band 3, Band 3 and Band 8** | 264d? | 2014-06-16 A | 2015-06-15 A | 100% | 2014-06-13 | 2015-06-12 | 261d? |  | R4 | 6304h | 6304h | LTE_CA_B3_B3_B8 | PCG-33 | CHTTL | Po-Han Hsieh (pohanhsieh@cht.com.tw) | Rel-13 | RP-64 | CA | LTE_CA_B3_B3_B8 |  |
| 1112 | 362.7.1 | Core part: LTE Advanced 3 Band Carrier Aggregation (3DL/1UL) of Band 3, Band 3 and Band 8 | 262d? | 2014-06-16 A | 2015-06-15 A | 100% | 2014-06-13 | 2015-06-12 | 261d? | finish no earlier than 2015-06-15 | R4 | 2096h | 2096h | LTE_CA_B3_B3_B8-Core | PCG-33 | CHTTL | Po-Han Hsieh (pohanhsieh@cht.com.tw) | Rel-13 | RP-64 | CA | LTE_CA_B3_B3_B8-Core | RP-150536 |
| 1113 | 362.7.2 | Perf. Part: LTE Advanced 3 Band Carrier Aggregation (3DL/1UL) of Band 3, Band 3 and Band 8 | 262d? | 2014-06-18 A | 2015-06-15 A | 100% | 2014-06-13 | 2015-06-12 | 261d? | finish no earlier than 2015-06-15 | R4 | 2096h | 2096h | LTE_CA_B3_B3_B8-Perf | PCG-33 | CHTTL | Po-Han Hsieh (pohanhsieh@cht.com.tw) | Rel-13 | RP-64 | CA | LTE_CA_B3_B3_B8-Perf | RP-150536 |
| 1114 | 362.8 | **LTE Advanced 3 Band Carrier Aggregation (3DL/1UL) of Band 41, Band 42 and Band 42** | 264d? | 2014-06-16 A | 2015-06-15 A | 100% | 2014-06-13 | 2014-12-05 | 126d? |  | R4 | 6304h | 6304h | LTE_CA_B41_B42_B42 | PCG-33 | Huawei | leo.liuye@huawei.com | Rel-13 | RP-64 | CA | LTE_CA_B41_B42_B42 |  |
| 1115 | 362.8.1 | Core part: LTE Advanced 3 Band Carrier Aggregation (3DL/1UL) of Band 41, Band 42 and Band 42 | 262d? | 2014-06-16 A | 2015-06-15 A | 100% | 2014-06-13 | 2014-12-05 | 126d? | finish no earlier than 2015-06-15 | R4 | 2096h | 2096h | LTE_CA_B41_B42_B42-Core | PCG-33 | Huawei | leo.liuye@huawei.com | Rel-13 | RP-64 | CA | LTE_CA_B41_B42_B42-Core | RP-150536 |
| 1116 | 362.8.2 | Perf. Part: LTE Advanced 3 Band Carrier Aggregation (3DL/1UL) of Band 41, Band 42 and Band 42 | 262d? | 2014-06-18 A | 2015-06-15 A | 100% | 2014-06-13 | 2014-12-05 | 126d? | finish no earlier than 2015-06-15 | R4 | 2096h | 2096h | LTE_CA_B41_B42_B42-Perf | PCG-33 | Huawei | leo.liuye@huawei.com | Rel-13 | RP-64 | CA | LTE_CA_B41_B42_B42-Perf | RP-150536 |
| 1117 | 362.9 | **LTE Advanced inter-band Carrier Aggregation of Band 3 and Band 38** | 198d? | 2014-09-15 A | 2015-06-15 A | 100% | 2014-06-13 | 2015-03-13 | 196d? |  | R4 | 4752h | 4752h | LTE_CA_B3_B38 | PCG-33 | Nokia Networks | iwajlo.angelow@nsn.com | Rel-13 | RP-65 | CA | LTE_CA_B3_B38 |  |
| 1118 | 362.9.1 | Core part: LTE Advanced inter-band Carrier Aggregation of Band 3 and Band 38 | 198d? | 2014-09-15 A | 2015-06-15 A | 100% | 2014-06-13 | 2015-03-13 | 196d? | finish no earlier than 2015-06-15 | R4 | 1584h | 1584h | LTE_CA_B3_B38-Core | PCG-33 | Nokia Networks | iwajlo.angelow@nsn.com | Rel-13 | RP-65 | CA | LTE_CA_B3_B38-Core | RP-150536 |
| 1119 | 362.9.2 | Perf. Part: LTE Advanced inter-band Carrier Aggregation of Band 3 and Band 38 | 198d? | 2014-09-15 A | 2015-06-15 A | 100% | 2014-06-13 | 2015-03-13 | 196d? | finish no earlier than 2015-06-15 | R4 | 1584h | 1584h | LTE_CA_B3_B38-Perf | PCG-33 | Nokia Networks | iwajlo.angelow@nsn.com | Rel-13 | RP-65 | CA | LTE_CA_B3_B38-Perf | RP-150536 |
| 1120 | 362.10 | **LTE Advanced inter-band Carrier Aggregation of Band 2 and Band 28** | 198d? | 2014-09-15 A | 2015-06-15 A | 100% | 2014-06-13 | 2015-03-13 | 196d? |  | R4 | 4752h | 4752h | LTE_CA_B2_B28 | PCG-33 | Huawei | alf.ahlstrom@huawei.com | Rel-13 | RP-65 | CA | LTE_CA_B2_B28 |  |
| 1121 | 362.10.1 | Core part: LTE Advanced inter-band Carrier Aggregation of Band 2 and Band 28 | 198d? | 2014-09-15 A | 2015-06-15 A | 100% | 2014-06-13 | 2015-03-13 | 196d? | finish no earlier than 2015-06-15 | R4 | 1584h | 1584h | LTE_CA_B2_B28-Core | PCG-33 | Huawei | alf.ahlstrom@huawei.com | Rel-13 | RP-65 | CA | LTE_CA_B2_B28-Core | RP-150536 |
| 1122 | 362.10.2 | Perf. Part: LTE Advanced inter-band Carrier Aggregation of Band 2 and Band 28 | 198d? | 2014-09-15 A | 2015-06-15 A | 100% | 2014-06-13 | 2015-03-13 | 196d? | finish no earlier than 2015-06-15 | R4 | 1584h | 1584h | LTE_CA_B2_B28-Perf | PCG-33 | Huawei | alf.ahlstrom@huawei.com | Rel-13 | RP-65 | CA | LTE_CA_B2_B28-Perf | RP-150536 |
| 1123 | 362.11 | **LTE Advanced inter-band Carrier Aggregation of Band 4 and Band 28** | 198d? | 2014-09-15 A | 2015-06-15 A | 100% | 2014-06-13 | 2015-03-13 | 196d? |  | R4 | 4752h | 4752h | LTE_CA_B4_B28 | PCG-33 | Huawei | alf.ahlstrom@huawei.com | Rel-13 | RP-65 | CA | LTE_CA_B4_B28 |  |
| 1124 | 362.11.1 | Core part: LTE Advanced inter-band Carrier Aggregation of Band 4 and Band 28 | 198d? | 2014-09-15 A | 2015-06-15 A | 100% | 2014-06-13 | 2015-03-13 | 196d? | finish no earlier than 2015-06-15 | R4 | 1584h | 1584h | LTE_CA_B4_B28-Core | PCG-33 | Huawei | alf.ahlstrom@huawei.com | Rel-13 | RP-65 | CA | LTE_CA_B4_B28-Core | RP-150536 |
| 1125 | 362.11.2 | Perf. Part: LTE Advanced inter-band Carrier Aggregation of Band 4 and Band 28 | 198d? | 2014-09-15 A | 2015-06-15 A | 100% | 2014-06-13 | 2015-03-13 | 196d? | finish no earlier than 2015-06-15 | R4 | 1584h | 1584h | LTE_CA_B4_B28-Perf | PCG-33 | Huawei | alf.ahlstrom@huawei.com | Rel-13 | RP-65 | CA | LTE_CA_B4_B28-Perf | RP-150536 |
| 1126 | 362.12 | **LTE Advanced inter-band Carrier Aggregation of Band 20 and Band 40** | 330d? | 2014-09-12 A | 2015-12-15 A | 100% | 2014-06-13 | 2015-03-13 | 196d? |  | R4 | 7912h | 7912h | LTE_CA_B20_B40 | PCG-33 | Ericsson | imadur.rahman@ericsson.com | Rel-13 | RP-65 | CA | LTE_CA_B20_B40 |  |
| 1127 | 362.12.1 | Core part: LTE Advanced inter-band Carrier Aggregation of Band 20 and Band 40 | 330d? | 2014-09-12 A | 2015-12-15 A | 100% | 2014-06-13 | 2015-03-13 | 196d? | finish no earlier than 2015-12-15 | R4 | 2640h | 2640h | LTE_CA_B20_B40-Core | PCG-33 | Ericsson | imadur.rahman@ericsson.com | Rel-13 | RP-65 | CA | LTE_CA_B20_B40-Core | RP-151131 |
| 1128 | 362.12.2 | Perf. Part: LTE Advanced inter-band Carrier Aggregation of Band 20 and Band 40 | 329d? | 2014-09-15 A | 2015-12-15 A | 100% | 2014-06-13 | 2015-03-13 | 196d? | finish no earlier than 2015-12-15 | R4 | 2632h | 2632h | LTE_CA_B20_B40-Perf | PCG-33 | Ericsson | imadur.rahman@ericsson.com | Rel-13 | RP-65 | CA | LTE_CA_B20_B40-Perf | RP-151131 |
| 1129 | 362.13 | **LTE Advanced inter-band Carrier Aggregation of Band 1 and Band 40** | 329d? | 2014-09-15 A | 2015-12-15 A | 100% | 2014-06-13 | 2015-03-13 | 196d? |  | R4 | 7896h | 7896h | LTE_CA_B1_B40 | PCG-33 | KT | ilwhan.kim@kt.com | Rel-13 | RP-65 | CA | LTE_CA_B1_B40 |  |
| 1130 | 362.13.1 | Core part: LTE Advanced inter-band Carrier Aggregation of Band 1 and Band 40 | 329d? | 2014-09-15 A | 2015-12-15 A | 100% | 2014-06-13 | 2015-03-13 | 196d? | finish no earlier than 2015-12-15 | R4 | 2632h | 2632h | LTE_CA_B1_B40-Core | PCG-33 | KT | ilwhan.kim@kt.com | Rel-13 | RP-65 | CA | LTE_CA_B1_B40-Core | RP-151131 |
| 1131 | 362.13.2 | Perf. Part: LTE Advanced inter-band Carrier Aggregation of Band 1 and Band 40 | 329d? | 2014-09-15 A | 2015-12-15 A | 100% | 2014-06-13 | 2015-03-13 | 196d? | finish no earlier than 2015-12-15 | R4 | 2632h | 2632h | LTE_CA_B1_B40-Perf | PCG-33 | KT | ilwhan.kim@kt.com | Rel-13 | RP-65 | CA | LTE_CA_B1_B40-Perf | RP-151131 |

Notes:
- 1108: Inter-band CA 3DL/1UL / Impacted TSs and TRs: LTE
- 1109: CD:Thu 12/03/15->Sun 15/03/15; Compl:0%->40%; Stat Rep: RP-141084->RP-141732 1st Apr 15: Compl:40%->99% 1st Apr 15: CD:Sun 15/03/15->Mon 15/06/15 1st Apr 15: Stat Rep: RP-141732->RP-150013 03/07/15: Compl:99%->100% 03/07/15: Stat Rep: RP-150013->RP-150536 / Impacted TSs and TRs: 36.101, 36.104, 36.133, 36.141, 36.307, generic new Rel-13 TR36.8xy [similar to Rel-12 TR 36.853 (3 Band CA with 1UL)]
- 1110: CD:Thu 18/06/15->Mon 15/06/15; Compl:0%->10%; Stat Rep: RP-141084->RP-141732 1st Apr 15: Compl:10%->99% 1st Apr 15: Stat Rep: RP-141732->RP-150013 03/07/15: Compl:99%->100% 03/07/15: Stat Rep: RP-150013->RP-150536 / Impacted TSs and TRs: 36.101, 36.104, 36.133, 36.141, 36.307
- 1111: Inter-band CA 3DL/1UL / Impacted TSs and TRs: LTE
- 1112: ; WID: RP-142043->RP-141832; Stat Rep: RP-141084->RP-141732 1st Apr 15: Compl:60%->99% 1st Apr 15: Stat Rep: RP-141732->RP-150013 03/07/15: Compl:99%->100% 03/07/15: WID: RP-141832->RP-150874 03/07/15: Stat Rep: RP-150013->RP-150536 / Impacted TSs and TRs: 36.101, 36.133, generic TR 36.853 (3 Band CA with 1UL)
- 1113: ; WID: RP-142043->RP-141832; Stat Rep: RP-141084->RP-141732 1st Apr 15: Compl:0%->99% 1st Apr 15: Stat Rep: RP-141732->RP-150013 03/07/15: Compl:99%->100% 03/07/15: WID: RP-141832->RP-150874 03/07/15: Stat Rep: RP-150013->RP-150536 / Impacted TSs and TRs: 36.307
- 1114: Inter-band CA 3DL/1UL / Impacted TSs and TRs: LTE
- 1115: CD:Thu 11/12/14->Sun 15/03/15; Compl:30%->50%; Stat Rep: RP-141084->RP-141732 1st Apr 15: Compl:50%->60% 1st Apr 15: CD:Sun 15/03/15->Mon 15/06/15 1st Apr 15: Stat Rep: RP-141732->RP-150013 03/07/15: Compl:60%->100% 03/07/15: Stat Rep: RP-150013->RP-15 / Impacted TSs and TRs: 36.101, 36.104, 36.133, generic TR 36.853 (3 Band CA with 1UL)
- 1116: CD:Thu 11/12/14->Sun 15/03/15; Compl:0%->0%; Stat Rep: RP-141084->RP-141732 1st Apr 15: Compl:0%->60% 1st Apr 15: CD:Sun 15/03/15->Mon 15/06/15 1st Apr 15: Stat Rep: RP-141732->RP-150013 03/07/15: Compl:60%->100% 03/07/15: Stat Rep: RP-150013->RP-150536 / Impacted TSs and TRs: 36.141, 36.307
- 1117: Inter-band CA 2DL/1UL / Impacted TSs and TRs: LTE
- 1118: CD:Thu 11/12/14->Sun 15/03/15; Compl:0%->90%; Stat Rep: -->RP-141732 1st Apr 15: CD:Sun 15/03/15->Mon 15/06/15 1st Apr 15: Stat Rep: RP-141732->RP-150013 03/07/15: Compl:90%->100% 03/07/15: WID: RP-141129->RP-150717 03/07/15: Stat Rep: RP-150013->RP-15 / Impacted TSs and TRs: 36.101, 36.104, New TR 36.8xx
- 1119: CD:Thu 11/12/14->Sun 15/03/15; Compl:0%->90%; Stat Rep: -->RP-141732 1st Apr 15: CD:Sun 15/03/15->Mon 15/06/15 1st Apr 15: Stat Rep: RP-141732->RP-150013 03/07/15: Compl:90%->100% 03/07/15: WID: RP-141129->RP-150717 03/07/15: Stat Rep: RP-150013->RP-15 / Impacted TSs and TRs: 36.141, 36.307
- 1120: Inter-band CA 2DL/1UL / Impacted TSs and TRs: LTE
- 1121: CD:Fri 11/12/15->Sun 15/03/15; Compl:0%->50%; Stat Rep: -->RP-141732 1st Apr 15: Compl:50%->99% 1st Apr 15: CD:Sun 15/03/15->Mon 15/06/15 1st Apr 15: Stat Rep: RP-141732->RP-150013 03/07/15: Compl:99%->100% 03/07/15: Stat Rep: RP-150013->RP-150536 / Impacted TSs and TRs: 36.101, 36.104, New TR 36.8xx
- 1122: CD:Thu 12/03/15->Sun 15/03/15; Compl:0%->0%; Stat Rep: -->RP-141732 1st Apr 15: Compl:0%->99% 1st Apr 15: CD:Sun 15/03/15->Mon 15/06/15 1st Apr 15: Stat Rep: RP-141732->RP-150013 03/07/15: Compl:99%->100% 03/07/15: Stat Rep: RP-150013->RP-150536 / Impacted TSs and TRs: 36.141, 36.307
- 1123: Inter-band CA 2DL/1UL / Impacted TSs and TRs: LTE
- 1124: CD:Fri 11/12/15->Sun 15/03/15; Compl:0%->35%; Stat Rep: -->RP-141732 1st Apr 15: Compl:35%->99% 1st Apr 15: CD:Sun 15/03/15->Mon 15/06/15 1st Apr 15: Stat Rep: RP-141732->RP-150013 03/07/15: Compl:99%->100% 03/07/15: Stat Rep: RP-150013->RP-150536 / Impacted TSs and TRs: 36.101, 36.104, New TR 36.8xx
- 1125: CD:Thu 12/03/15->Sun 15/03/15; Compl:0%->0%; Stat Rep: -->RP-141732 1st Apr 15: Compl:0%->99% 1st Apr 15: CD:Sun 15/03/15->Mon 15/06/15 1st Apr 15: Stat Rep: RP-141732->RP-150013 03/07/15: Compl:99%->100% 03/07/15: Stat Rep: RP-150013->RP-150536 / Impacted TSs and TRs: 36.141, 36.307
- 1126: Inter-band CA 2DL/1UL / Impacted TSs and TRs: LTE
- 1127: CD:Wed 11/03/15->Sun 15/03/15; Compl:0%->30%; Stat Rep: -->RP-141732 1st Apr 15: Compl:30%->70% 1st Apr 15: CD:Sun 15/03/15->Mon 15/06/15 1st Apr 15: Stat Rep: RP-141732->RP-150013 03/07/15: CD:Mon 15/06/15->Tue 15/09/15 03/07/15: Stat Rep: RP-150013-> / Impacted TSs and TRs: 36.101, 36.104, 36.133, New TR 36.8xx
- 1128: CD:Thu 12/03/15->Sun 15/03/15; Compl:0%->0%; Stat Rep: -->RP-141732 1st Apr 15: CD:Sun 15/03/15->Mon 15/06/15 1st Apr 15: Stat Rep: RP-141732->RP-150013 03/07/15: Compl:0%->70% 03/07/15: CD:Mon 15/06/15->Tue 15/09/15 03/07/15: Stat Rep: RP-150013->RP-1 / Impacted TSs and TRs: 36.141, 36.307
- 1129: Inter-band CA 2DL/1UL / Impacted TSs and TRs: LTE
- 1130: CD:Fri 12/06/15->Mon 15/06/15; Compl:0%->70%; Stat Rep: -->RP-141732 1st Apr 15: Compl:70%->80% 1st Apr 15: Stat Rep: RP-141732->RP-150013 03/07/15: Compl:80%->70% 03/07/15: CD:Mon 15/06/15->Tue 15/12/15 03/07/15: Stat Rep: RP-150013->RP-150536 29/09/1 / Impacted TSs and TRs: 36.101, 36.104, 36.133, New TR 36.8xx
- 1131: CD:Fri 11/12/15->Mon 15/06/15; Compl:0%->70%; Stat Rep: -->RP-141732 1st Apr 15: Compl:70%->80% 1st Apr 15: Stat Rep: RP-141732->RP-150013 03/07/15: Compl:80%->70% 03/07/15: CD:Mon 15/06/15->Tue 15/12/15 03/07/15: Stat Rep: RP-150013->RP-150536 29/09/1 / Impacted TSs and TRs: 36.141, 36.307

| ID | WBS | Task | Duration | Start | Finish | Complete | Baseline start | Baseline finish | Baseline duration | Constraint | Resources | Work | Actual work | Acronym | PCG approved | WI rapporteur name | WI rapporteur e-mail | Release | TSG approved | Special Focus Doc | Acronym_3GU_Export | Status Report |
| --- | --- | --- | --- | --- | --- | --- | --- | --- | --- | --- | --- | --- | --- | --- | --- | --- | --- | --- | --- | --- | --- | --- |
| 1132 | 362.14 | **LTE Advanced inter-band Carrier Aggregation of Band 3 and Band 40** | 198d? | 2014-09-15 A | 2015-06-15 A | 100% | 2014-06-13 | 2015-03-13 | 196d? |  | R4 | 4752h | 4752h | LTE_CA_B3_B40 | PCG-33 | KT | Chungwoo HWANG (cwhwang@kt.com) | Rel-13 | RP-65 | CA | LTE_CA_B3_B40 |  |
| 1133 | 362.14.1 | Core part: LTE Advanced inter-band Carrier Aggregation of Band 3 and Band 40 | 198d? | 2014-09-15 A | 2015-06-15 A | 100% | 2014-06-13 | 2015-03-13 | 196d? | finish no earlier than 2015-06-15 | R4 | 1584h | 1584h | LTE_CA_B3_B40-Core | PCG-33 | KT | Chungwoo HWANG (cwhwang@kt.com) | Rel-13 | RP-65 | CA | LTE_CA_B3_B40-Core | RP-150536 |
| 1134 | 362.14.2 | Perf. Part: LTE Advanced inter-band Carrier Aggregation of Band 3 and Band 40 | 198d? | 2014-09-15 A | 2015-06-15 A | 100% | 2014-06-13 | 2015-03-13 | 196d? | finish no earlier than 2015-06-15 | R4 | 1584h | 1584h | LTE_CA_B3_B40-Perf | PCG-33 | KT | Chungwoo HWANG (cwhwang@kt.com) | Rel-13 | RP-65 | CA | LTE_CA_B3_B40-Perf | RP-150536 |
| 1135 | 362.15 | **LTE Advanced inter-band Carrier Aggregation of Band 20 and Band 31** | 198d? | 2014-09-15 A | 2015-06-15 A | 100% | 2014-06-13 | 2015-03-13 | 196d? |  | R4 | 4752h | 4752h | LTE_CA_B20_B31 | PCG-33 | Huawei | Liu Liehai (liuliehai@huawei.com) | Rel-13 | RP-65 | CA | LTE_CA_B20_B31 |  |
| 1136 | 362.15.1 | Core part: LTE Advanced inter-band Carrier Aggregation of Band 20 and Band 31 | 198d? | 2014-09-15 A | 2015-06-15 A | 100% | 2014-06-13 | 2015-03-13 | 196d? | finish no earlier than 2015-06-15 | R4 | 1584h | 1584h | LTE_CA_B20_B31-Core | PCG-33 | Huawei | Liu Liehai (liuliehai@huawei.com) | Rel-13 | RP-65 | CA | LTE_CA_B20_B31-Core | RP-150536 |
| 1137 | 362.15.2 | Perf. Part: LTE Advanced inter-band Carrier Aggregation of Band 20 and Band 31 | 198d? | 2014-09-15 A | 2015-06-15 A | 100% | 2014-06-13 | 2015-03-13 | 196d? | finish no earlier than 2015-06-15 | R4 | 1584h | 1584h | LTE_CA_B20_B31-Perf | PCG-33 | Huawei | Liu Liehai (liuliehai@huawei.com) | Rel-13 | RP-65 | CA | LTE_CA_B20_B31-Perf | RP-150536 |
| 1138 | 362.16 | **LTE Advanced inter-band Carrier Aggregation of Band 3 and Band 31** | 198d? | 2014-09-15 A | 2015-06-15 A | 100% | 2014-06-13 | 2015-03-13 | 196d? |  | R4 | 4752h | 4752h | LTE_CA_B3_B31 | PCG-33 | Huawei | Liu Liehai (liuliehai@huawei.com) | Rel-13 | RP-65 | CA | LTE_CA_B3_B31 |  |
| 1139 | 362.16.1 | Core part: LTE Advanced inter-band Carrier Aggregation of Band 3 and Band 31 | 198d? | 2014-09-15 A | 2015-06-15 A | 100% | 2014-06-13 | 2015-03-13 | 196d? | finish no earlier than 2015-06-15 | R4 | 1584h | 1584h | LTE_CA_B3_B31-Core | PCG-33 | Huawei | Liu Liehai (liuliehai@huawei.com) | Rel-13 | RP-65 | CA | LTE_CA_B3_B31-Core | RP-150536 |
| 1140 | 362.16.2 | Perf. Part: LTE Advanced inter-band Carrier Aggregation of Band 3 and Band 31 | 198d? | 2014-09-15 A | 2015-06-15 A | 100% | 2014-06-13 | 2015-03-13 | 196d? | finish no earlier than 2015-06-15 | R4 | 1584h | 1584h | LTE_CA_B3_B31-Perf | PCG-33 | Huawei | Liu Liehai (liuliehai@huawei.com) | Rel-13 | RP-65 | CA | LTE_CA_B3_B31-Perf | RP-150536 |
| 1141 | 362.17 | **LTE Advanced inter-band Carrier Aggregation of Band 5 and Band 40** | 199d? | 2014-09-12 A | 2015-06-15 A | 100% | 2014-06-13 | 2015-03-13 | 196d? |  | R4 | 4768h | 4768h | LTE_CA_B5_B40 | PCG-33 | SK Telecom | haesung.park@sk.com | Rel-13 | RP-65 | CA | LTE_CA_B5_B40 |  |
| 1142 | 362.17.1 | Core part: LTE Advanced inter-band Carrier Aggregation of Band 5 and Band 40 | 199d? | 2014-09-12 A | 2015-06-15 A | 100% | 2014-06-13 | 2015-03-13 | 196d? | finish no earlier than 2015-06-15 | R4 | 1592h | 1592h | LTE_CA_B5_B40-Core | PCG-33 | SK Telecom | haesung.park@sk.com | Rel-13 | RP-65 | CA | LTE_CA_B5_B40-Core | RP-150536 |
| 1143 | 362.17.2 | Perf. Part: LTE Advanced inter-band Carrier Aggregation of Band 5 and Band 40 | 198d? | 2014-09-15 A | 2015-06-15 A | 100% | 2014-06-13 | 2015-03-13 | 196d? | finish no earlier than 2015-06-15 | R4 | 1584h | 1584h | LTE_CA_B5_B40-Perf | PCG-33 | SK Telecom | haesung.park@sk.com | Rel-13 | RP-65 | CA | LTE_CA_B5_B40-Perf | RP-150536 |
| 1144 | 362.18 | **LTE Advanced intra-band contiguous Carrier Aggregation in Band 42 for 3DL** | 198d? | 2014-09-15 A | 2015-06-15 A | 100% | 2014-06-13 | 2015-03-13 | 196d? |  | R4 | 4752h | 4752h | LTE_CA_C_B42_3DL | PCG-33 | CATT | Yuexia Song (songyuexia@catt.cn) | Rel-13 | RP-65 | CA | LTE_CA_C_B42_3DL |  |
| 1145 | 362.18.1 | Core part: LTE Advanced intra-band contiguous Carrier Aggregation in Band 42 for 3DL | 198d? | 2014-09-15 A | 2015-06-15 A | 100% | 2014-06-13 | 2015-03-13 | 196d? | finish no earlier than 2015-06-15 | R4 | 1584h | 1584h | LTE_CA_C_B42_3DL-Core | PCG-33 | CATT | Yuexia Song (songyuexia@catt.cn) | Rel-13 | RP-65 | CA | LTE_CA_C_B42_3DL-Core | RP-150536 |
| 1146 | 362.18.2 | Perf. Part: LTE Advanced intra-band contiguous Carrier Aggregation in Band 42 for 3DL | 198d? | 2014-09-15 A | 2015-06-15 A | 100% | 2014-06-13 | 2015-03-13 | 196d? | finish no earlier than 2015-06-15 | R4 | 1584h | 1584h | LTE_CA_C_B42_3DL-Perf | PCG-33 | CATT | Yuexia Song (songyuexia@catt.cn) | Rel-13 | RP-65 | CA | LTE_CA_C_B42_3DL-Perf | RP-150536 |
| 1147 | 362.19 | **LTE Advanced 3 Band Carrier Aggregation (3DL/1UL) of Band 8, Band 41 and Band 41** | 199d? | 2014-09-12 A | 2015-06-15 A | 100% | 2014-06-13 | 2015-03-13 | 196d? |  | R4 | 4768h | 4768h | LTE_CA_B8_B41_B41 | PCG-33 | China Mobile | PAN, Qun (panqun@chinamobile.com) | Rel-13 | RP-65 | CA | LTE_CA_B8_B41_B41 |  |
| 1148 | 362.19.1 | Core part: LTE Advanced 3 Band Carrier Aggregation (3DL/1UL) of Band 8, Band 41 and Band 41 | 198d? | 2014-09-15 A | 2015-06-15 A | 100% | 2014-06-13 | 2015-03-13 | 196d? | finish no earlier than 2015-06-15 | R4 | 1584h | 1584h | LTE_CA_B8_B41_B41-Core | PCG-33 | China Mobile | PAN, Qun (panqun@chinamobile.com) | Rel-13 | RP-65 | CA | LTE_CA_B8_B41_B41-Core | RP-150536 |
| 1149 | 362.19.2 | Perf. Part: LTE Advanced 3 Band Carrier Aggregation (3DL/1UL) of Band 8, Band 41 and Band 41 | 199d? | 2014-09-12 A | 2015-06-15 A | 100% | 2014-06-13 | 2015-03-13 | 196d? | finish no earlier than 2015-06-15 | R4 | 1592h | 1592h | LTE_CA_B8_B41_B41-Perf | PCG-33 | China Mobile | PAN, Qun (panqun@chinamobile.com) | Rel-13 | RP-65 | CA | LTE_CA_B8_B41_B41-Perf | RP-150536 |
| 1150 | 362.20 | **LTE Advanced 3 Band Carrier Aggregation (3DL/1UL) of Band 38, Band 40 and Band 40** | 198d? | 2014-09-15 A | 2015-06-15 A | 100% | 2014-06-13 | 2015-03-13 | 196d? |  | R4 | 4752h | 4752h | LTE_CA_B38_B40_B40 | PCG-33 | Samsung | xutao.zhou@samsung.com | Rel-13 | RP-65 | CA | LTE_CA_B38_B40_B40 |  |
| 1151 | 362.20.1 | Core part: LTE Advanced 3 Band Carrier Aggregation (3DL/1UL) of Band 38, Band 40 and Band 40 | 198d? | 2014-09-15 A | 2015-06-15 A | 100% | 2014-06-13 | 2015-03-13 | 196d? | finish no earlier than 2015-06-15 | R4 | 1584h | 1584h | LTE_CA_B38_B40_B40-Core | PCG-33 | Samsung | xutao.zhou@samsung.com | Rel-13 | RP-65 | CA | LTE_CA_B38_B40_B40-Core | RP-150536 |
| 1152 | 362.20.2 | Perf. Part: LTE Advanced 3 Band Carrier Aggregation (3DL/1UL) of Band 38, Band 40 and Band 40 | 198d? | 2014-09-15 A | 2015-06-15 A | 100% | 2014-06-13 | 2015-03-13 | 196d? | finish no earlier than 2015-06-15 | R4 | 1584h | 1584h | LTE_CA_B38_B40_B40-Perf | PCG-33 | Samsung | xutao.zhou@samsung.com | Rel-13 | RP-65 | CA | LTE_CA_B38_B40_B40-Perf | RP-150536 |
| 1153 | 362.21 | **LTE Advanced 3 Band Carrier Aggregation (3DL/1UL) of Band 2, Band 5 and Band 29** | 198d? | 2014-09-15 A | 2015-06-15 A | 100% | 2014-06-13 | 2015-03-13 | 196d? |  | R4 | 4752h | 4752h | LTE_CA_B2_B5_B29 | PCG-33 | Huawei | SHAN Huiping (shanhuiping@huawei.com) | Rel-13 | RP-65 | CA | LTE_CA_B2_B5_B29 |  |
| 1154 | 362.21.1 | Core part: LTE Advanced 3 Band Carrier Aggregation (3DL/1UL) of Band 2, Band 5 and Band 29 | 198d? | 2014-09-15 A | 2015-06-15 A | 100% | 2014-06-13 | 2015-03-13 | 196d? | finish no earlier than 2015-06-15 | R4 | 1584h | 1584h | LTE_CA_B2_B5_B29-Core | PCG-33 | Huawei | SHAN Huiping (shanhuiping@huawei.com) | Rel-13 | RP-65 | CA | LTE_CA_B2_B5_B29-Core | RP-150536 |
| 1155 | 362.21.2 | Perf. Part: LTE Advanced 3 Band Carrier Aggregation (3DL/1UL) of Band 2, Band 5 and Band 29 | 198d? | 2014-09-15 A | 2015-06-15 A | 100% | 2014-06-13 | 2015-03-13 | 196d? | finish no earlier than 2015-06-15 | R4 | 1584h | 1584h | LTE_CA_B2_B5_B29-Perf | PCG-33 | Huawei | SHAN Huiping (shanhuiping@huawei.com) | Rel-13 | RP-65 | CA | LTE_CA_B2_B5_B29-Perf | RP-150536 |

Notes:
- 1132: Inter-band CA 2DL/1UL / Impacted TSs and TRs: LTE
- 1133: CD:Fri 11/12/15->Mon 15/06/15; Compl:0%->70%; Stat Rep: -->RP-141732 1st Apr 15: Compl:70%->80% 1st Apr 15: Stat Rep: RP-141732->RP-150013 03/07/15: Compl:80%->100% 03/07/15: WID: RP-141674->RP-150832 03/07/15: Stat Rep: RP-150013->RP-150536 / Impacted TSs and TRs: 36.101, 36.104, 36.133, New TR 36.8xx
- 1134: CD:Fri 12/06/15->Mon 15/06/15; Compl:0%->70%; Stat Rep: -->RP-141732 1st Apr 15: Compl:70%->80% 1st Apr 15: Stat Rep: RP-141732->RP-150013 03/07/15: Compl:80%->100% 03/07/15: WID: RP-141674->RP-150832 03/07/15: Stat Rep: RP-150013->RP-150536 / Impacted TSs and TRs: 36.141, 36.307
- 1135: Inter-band CA 2DL/1UL / Impacted TSs and TRs: LTE
- 1136: ; WID: RP-142043->RP-142007; Stat Rep: -->RP-141732 1st Apr 15: Compl:75%->99% 1st Apr 15: CD:Sun 15/03/15->Mon 15/06/15 1st Apr 15: Stat Rep: RP-141732->RP-150013 03/07/15: Compl:99%->100% 03/07/15: Stat Rep: RP-150013->RP-150536 / Impacted TSs and TRs: 36.101, 36.104, New TR 36.8xx
- 1137: ; WID: RP-142043->RP-142007; Stat Rep: -->RP-141732 1st Apr 15: Compl:0%->99% 1st Apr 15: CD:Sun 15/03/15->Mon 15/06/15 1st Apr 15: Stat Rep: RP-141732->RP-150013 03/07/15: Compl:99%->100% 03/07/15: Stat Rep: RP-150013->RP-150536 / Impacted TSs and TRs: 36.141, 36.307
- 1138: Inter-band CA 2DL/1UL / Impacted TSs and TRs: LTE
- 1139: CD:Fri 11/12/15->Sun 15/03/15; Compl:0%->50%; Stat Rep: -->RP-141732 1st Apr 15: Compl:50%->75% 1st Apr 15: CD:Sun 15/03/15->Mon 15/06/15 1st Apr 15: WID: RP-141337->RP-150318 1st Apr 15: Stat Rep: RP-141732->RP-150013 03/07/15: Compl:75%->100% 03/07/1 / Impacted TSs and TRs: 36.101, 36.104, New TR 36.8xx
- 1140: CD:Thu 12/03/15->Sun 15/03/15; Compl:0%->0%; Stat Rep: -->RP-141732 1st Apr 15: CD:Sun 15/03/15->Mon 15/06/15 1st Apr 15: WID: RP-141337->RP-150318 1st Apr 15: Stat Rep: RP-141732->RP-150013 03/07/15: Compl:0%->100% 03/07/15: Stat Rep: RP-150013->RP-15 / Impacted TSs and TRs: 36.141, 36.307
- 1141: Inter-band CA 2DL/1UL / Impacted TSs and TRs: LTE
- 1142: ; WID: RP-142043->RP-141888; Stat Rep: -->RP-141732 1st Apr 15: Compl:0%->80% 1st Apr 15: WID: RP-141888->RP-150285 1st Apr 15: Stat Rep: RP-141732->RP-150013 03/07/15: Compl:80%->100% 03/07/15: Stat Rep: RP-150013->RP-150536 / Impacted TSs and TRs: 36.101, 36.104, New TR 36.8xx
- 1143: ; WID: RP-142043->RP-141888; Stat Rep: -->RP-141732 1st Apr 15: Compl:0%->80% 1st Apr 15: WID: RP-141888->RP-150285 1st Apr 15: Stat Rep: RP-141732->RP-150013 03/07/15: Compl:80%->100% 03/07/15: Stat Rep: RP-150013->RP-150536 / Impacted TSs and TRs: 36.141, 36.307
- 1144: Intra-band contig. CA 3DL / Impacted TSs and TRs: LTE
- 1145: CD:Fri 12/06/15->Mon 15/06/15; Compl:0%->70%; Stat Rep: -->RP-141732 1st Apr 15: Compl:70%->99% 1st Apr 15: WID: RP-141677->RP-150319 1st Apr 15: Stat Rep: RP-141732->RP-150013 03/07/15: Compl:99%->100% 03/07/15: WID: RP-150319->RP-151027 03/07/15: Sta / Impacted TSs and TRs: 36.101, 36.104, 36.133, New TR 36.833-5-42
- 1146: CD:Fri 12/06/15->Mon 15/06/15; Compl:0%->0%; Stat Rep: -->RP-141732 1st Apr 15: Compl:0%->99% 1st Apr 15: WID: RP-141677->RP-150319 1st Apr 15: Stat Rep: RP-141732->RP-150013 03/07/15: Compl:99%->100% 03/07/15: WID: RP-150319->RP-151027 03/07/15: Stat / Impacted TSs and TRs: 36.141, 36.307
- 1147: Inter-band CA 3DL/1UL / Impacted TSs and TRs: LTE
- 1148: ; WID: RP-142043->RP-141845; Stat Rep: -->RP-141732 1st Apr 15: Compl:80%->99% 1st Apr 15: CD:Sun 15/03/15->Mon 15/06/15 1st Apr 15: Stat Rep: RP-141732->RP-150013 03/07/15: Compl:99%->100% 03/07/15: Stat Rep: RP-150013->RP-150536 / Impacted TSs and TRs: 36.101, 36.104, 36.133, New TR 36.8xx
- 1149: ; WID: RP-142043->RP-141845; Stat Rep: -->RP-141732 1st Apr 15: Compl:0%->99% 1st Apr 15: CD:Sun 15/03/15->Mon 15/06/15 1st Apr 15: Stat Rep: RP-141732->RP-150013 03/07/15: Compl:99%->100% 03/07/15: Stat Rep: RP-150013->RP-150536 / Impacted TSs and TRs: 36.141, 36.307
- 1150: Inter-band CA 3DL/1UL / Impacted TSs and TRs: LTE
- 1151: CD:Fri 12/06/15->Mon 15/06/15; Compl:0%->0%; Stat Rep: -->RP-141732 1st Apr 15: Compl:0%->70% 1st Apr 15: Stat Rep: RP-141732->RP-150013 03/07/15: Compl:70%->100% 03/07/15: Stat Rep: RP-150013->RP-150536 / Impacted TSs and TRs: 36.101, 36.104, 36.133, New TR 36.8xx
- 1152: CD:Fri 12/06/15->Mon 15/06/15; Compl:0%->0%; Stat Rep: -->RP-141732 1st Apr 15: Compl:0%->70% 1st Apr 15: Stat Rep: RP-141732->RP-150013 03/07/15: Compl:70%->100% 03/07/15: Stat Rep: RP-150013->RP-150536 / Impacted TSs and TRs: 36.141, 36.307
- 1153: Inter-band CA 3DL/1UL / Impacted TSs and TRs: LTE
- 1154: CD:Fri 11/12/15->Mon 15/06/15; Compl:0%->50%; Stat Rep: -->RP-141732 1st Apr 15: Compl:50%->99% 1st Apr 15: Stat Rep: RP-141732->RP-150013 03/07/15: Compl:99%->100% 03/07/15: Stat Rep: RP-150013->RP-150536 / Impacted TSs and TRs: 36.101, 36.104, 36.133, New TR 36.8xy (inter-band CA 2DL/1UL (introduce CA_B5-B29), New TR 36.8xz (inter-band CA 3DL/1UL)
- 1155: CD:Fri 12/06/15->Mon 15/06/15; Compl:0%->0%; Stat Rep: -->RP-141732 1st Apr 15: Compl:0%->99% 1st Apr 15: Stat Rep: RP-141732->RP-150013 03/07/15: Compl:99%->100% 03/07/15: Stat Rep: RP-150013->RP-150536 / Impacted TSs and TRs: 36.141, 36.307

| ID | WBS | Task | Duration | Start | Finish | Complete | Remaining | Total slack | Constraint | Resources | Work | Actual work | Acronym | PCG approved | WI rapporteur name | WI rapporteur e-mail | Release | TSG approved | Status Report |
| --- | --- | --- | --- | --- | --- | --- | --- | --- | --- | --- | --- | --- | --- | --- | --- | --- | --- | --- | --- |
| 1156 | 362.22 | **LTE Carrier Aggregation Enhancement Beyond 5 Carriers** | 721d? | 2014-12-15 A | 2017-09-15 | 73% | 195.7d? | 329d |  |  | 7336h | 5344.8h | LTE_CA_enh_b5C | PCG-34 | Nokia Networks | Nokia | Rel-13 | RP-66 |  |
| 1157 | 362.22.1 | Core part: LTE Carrier Aggregation Enhancement Beyond 5 Carriers | 262d? | 2014-12-15 A | 2015-12-15 A | 100% |  |  | finish no earlier than 2015-12-15 | R1 | 2096h | 2096h | LTE_CA_enh_b5C-Core | PCG-34 | Nokia Networks | Nokia | Rel-13 | RP-66 | RP-151285 |
| 1158 | 362.22.2 | Perf. part: LTE Carrier Aggregation Enhancement Beyond 5 Carriers | 393d? | 2014-12-15 A | 2016-06-15 A | 100% |  |  | finish no earlier than 2016-06-15 | R4 | 3144h | 3144h | LTE_CA_enh_b5C-Perf | PCG-34 | Nokia Networks | Nokia | Rel-13 | RP-66 | RP-151285 |
| 1159 | 362.22.3 | UE Conformance Test Aspects - LTE Carrier Aggregation Enhancement Beyond 5 Carriers: PUCCH on Scell | 262d? | 2016-09-15 A | 2017-09-15 | 5% | 248.9d? | 329d | finish no earlier than 2017-09-15 | R5 | 2096h | 104.8h | LTE_CA_enh_b5C_PUCCH-UEConTest |  | Huawei |  | Rel-13 | TSG-66 |  |
| 1160 | 362.23 | **HSPA Dual-Band UL carrier aggregation** | 327d? | 2014-12-15 A | 2016-03-15 A | 100% |  |  |  | R4 | 7328h | 7328h | HSUPA_DB_MC | PCG-34 | Qualcomm | Qualcomm | Rel-13 | RP-66 |  |
| 1161 | 362.23.1 | Core part: HSPA Dual-Band UL carrier aggregation | 262d? | 2014-12-15 A | 2015-12-15 A | 100% |  |  | finish no earlier than 2015-12-15 | R4 | 2096h | 2096h | HSUPA_DB_MC-Core | PCG-34 | Qualcomm | Qualcomm | Rel-13 | RP-66 | RP-151281 |
| 1162 | 362.23.2 | Perf. part: HSPA Dual-Band UL carrier aggregation | 327d? | 2014-12-15 A | 2016-03-15 A | 100% |  |  | finish no earlier than 2016-03-15 | R4 | 2616h | 2616h | HSUPA_DB_MC-Perf | PCG-34 | Qualcomm | Qualcomm | Rel-13 | RP-66 | RP-151281 |
| 1163 | 362.24 | **LTE Advanced inter-band Carrier Aggregation of Band 25 and Band 26** | 131d? | 2014-12-15 A | 2015-06-15 A | 100% |  |  |  | R4 | 3144h | 3144h | LTE_CA_B25_B26 | PCG-34 | Sprint | Sprint | Rel-13 | RP-66 |  |
| 1164 | 362.24.1 | Core part: LTE Advanced inter-band Carrier Aggregation of Band 25 and Band 26 | 131d? | 2014-12-15 A | 2015-06-15 A | 100% |  |  | finish no earlier than 2015-06-15 | R4 | 1048h | 1048h | LTE_CA_B25_B26-Core | PCG-34 | Sprint | Sprint | Rel-13 | RP-66 | RP-150536 |
| 1165 | 362.24.2 | Perf. part: LTE Advanced inter-band Carrier Aggregation of Band 25 and Band 26 | 131d? | 2014-12-15 A | 2015-06-15 A | 100% |  |  | finish no earlier than 2015-06-15 | R4 | 1048h | 1048h | LTE_CA_B25_B26-Perf | PCG-34 | Sprint | Sprint | Rel-13 | RP-66 | RP-150536 |
| 1166 | 362.25 | **LTE Advanced inter-band Carrier Aggregation of Band 3 and Band 41** | 262d? | 2014-12-15 A | 2015-12-15 A | 100% |  |  |  | R4 | 6288h | 6288h | LTE_CA_B3_B41 | PCG-34 | China Telecom | China Telecom | Rel-13 | RP-66 |  |
| 1167 | 362.25.1 | Core part: LTE Advanced inter-band Carrier Aggregation of Band 3 and Band 41 | 262d? | 2014-12-15 A | 2015-12-15 A | 100% |  |  | finish no earlier than 2015-12-15 | R4 | 2096h | 2096h | LTE_CA_B3_B41-Core | PCG-34 | China Telecom | China Telecom | Rel-13 | RP-66 | RP-151131 |
| 1168 | 362.25.2 | Perf. part: LTE Advanced inter-band Carrier Aggregation of Band 3 and Band 41 | 262d? | 2014-12-15 A | 2015-12-15 A | 100% |  |  | finish no earlier than 2015-12-15 | R4 | 2096h | 2096h | LTE_CA_B3_B41-Perf | PCG-34 | China Telecom | China Telecom | Rel-13 | RP-66 | RP-151131 |
| 1169 | 362.26 | **LTE Advanced 3 band Carrier Aggregation (3DL/1UL) of Band 1, Band 3 and Band 3** | 197d? | 2014-12-15 A | 2015-09-15 A | 100% |  |  |  | R4 | 4728h | 4728h | LTE_CA_B1_B3_B3 | PCG-34 | China Unicom | China Unicom | Rel-13 | RP-66 |  |
| 1170 | 362.26.1 | Core part: LTE Advanced 3 band Carrier Aggregation (3DL/1UL) of Band 1, Band 3 and Band 3 | 197d? | 2014-12-15 A | 2015-09-15 A | 100% |  |  | finish no earlier than 2015-09-15 | R4 | 1576h | 1576h | LTE_CA_B1_B3_B3-Core | PCG-34 | China Unicom | China Unicom | Rel-13 | RP-66 | RP-151131 |
| 1171 | 362.26.2 | Perf. part: LTE Advanced 3 band Carrier Aggregation (3DL/1UL) of Band 1, Band 3 and Band 3 | 197d? | 2014-12-15 A | 2015-09-15 A | 100% |  |  | finish no earlier than 2015-09-15 | R4 | 1576h | 1576h | LTE_CA_B1_B3_B3-Perf | PCG-34 | China Unicom | China Unicom | Rel-13 | RP-66 | RP-151131 |
| 1172 | 362.27 | **LTE Advanced 3 Band Carrier Aggregation (3DL/1UL) of Band 1, Band 19 and Band 28** | 197d? | 2014-12-15 A | 2015-09-15 A | 100% |  |  |  | R4 | 4728h | 4728h | LTE_CA_B1_B19_B28 | PCG-34 | NTT DOCOMO | NTT DOCOMO | Rel-13 | RP-66 |  |
| 1173 | 362.27.1 | Core part: LTE Advanced 3 Band Carrier Aggregation (3DL/1UL) of Band 1, Band 19 and Band 28 | 197d? | 2014-12-15 A | 2015-09-15 A | 100% |  |  | finish no earlier than 2015-09-15 | R4 | 1576h | 1576h | LTE_CA_B1_B19_B28-Core | PCG-34 | NTT DOCOMO | NTT DOCOMO | Rel-13 | RP-66 | RP-151131 |
| 1174 | 362.27.2 | Perf. part: LTE Advanced 3 Band Carrier Aggregation (3DL/1UL) of Band 1, Band 19 and Band 28 | 197d? | 2014-12-15 A | 2015-09-15 A | 100% |  |  | finish no earlier than 2015-09-15 | R4 | 1576h | 1576h | LTE_CA_B1_B19_B28-Perf | PCG-34 | NTT DOCOMO | NTT DOCOMO | Rel-13 | RP-66 | RP-151131 |
| 1175 | 362.28 | **LTE Advanced 3 Band Carrier Aggregation (3DL/1UL) of Band 21, Band 42 and Band 42** | 131d? | 2014-12-15 A | 2015-06-15 A | 100% |  |  |  | R4 | 3144h | 3144h | LTE_CA_B21_B42_B42 | PCG-34 | NTT DOCOMO | NTT DOCOMO | Rel-13 | RP-66 |  |
| 1176 | 362.28.1 | Core part: LTE Advanced 3 Band Carrier Aggregation (3DL/1UL) of Band 21, Band 42 and Band 42 | 131d? | 2014-12-15 A | 2015-06-15 A | 100% |  |  | finish no earlier than 2015-06-15 | R4 | 1048h | 1048h | LTE_CA_B21_B42_B42-Core | PCG-34 | NTT DOCOMO | NTT DOCOMO | Rel-13 | RP-66 | RP-150536 |
| 1177 | 362.28.2 | Perf. part: LTE Advanced 3 Band Carrier Aggregation (3DL/1UL) of Band 21, Band 42 and Band 42 | 131d? | 2014-12-15 A | 2015-06-15 A | 100% |  |  | finish no earlier than 2015-06-15 | R4 | 1048h | 1048h | LTE_CA_B21_B42_B42-Perf | PCG-34 | NTT DOCOMO | NTT DOCOMO | Rel-13 | RP-66 | RP-150536 |
| 1178 | 362.29 | **LTE Advanced 3 Band Carrier Aggregation (3DL/1UL) of Band 7, Band 40 and Band 40** | 197d? | 2014-12-15 A | 2015-09-15 A | 100% |  |  |  | R4 | 4728h | 4728h | LTE_CA_B7_B40_B40 | PCG-34 | ZTE | ZTE | Rel-13 | RP-66 |  |
| 1179 | 362.29.1 | Core part: LTE Advanced 3 Band Carrier Aggregation (3DL/1UL) of Band 7, Band 40 and Band 40 | 197d? | 2014-12-15 A | 2015-09-15 A | 100% |  |  | finish no earlier than 2015-09-15 | R4 | 1576h | 1576h | LTE_CA_B7_B40_B40-Core | PCG-34 | ZTE | ZTE | Rel-13 | RP-66 | RP-151131 |
| 1180 | 362.29.2 | Perf. part: LTE Advanced 3 Band Carrier Aggregation (3DL/1UL) of Band 7, Band 40 and Band 40 | 197d? | 2014-12-15 A | 2015-09-15 A | 100% |  |  | finish no earlier than 2015-09-15 | R4 | 1576h | 1576h | LTE_CA_B7_B40_B40-Perf | PCG-34 | ZTE | ZTE | Rel-13 | RP-66 | RP-151131 |

Notes:
- 1156: FCD: 06/16->12/15, Rel-14?->Rel-13
- 1157: FCD: 06/16->12/15, Rel-14?->Rel-13 1st Apr 15: Compl:0%->10% 1st Apr 15: WID: RP-142286->RP-150277 1st Apr 15: Stat Rep: ->RP-150272 03/07/15: Compl:10%->40% 03/07/15: WID: RP-150277->RP-150771 03/07/15: Stat Rep: RP-150272->RP-150769 29/09/15: Compl:4
- 1158: 1st Apr 15: WID: RP-142286->RP-150277 1st Apr 15: Stat Rep: ->RP-150272 03/07/15: WID: RP-150277->RP-150771 03/07/15: Stat Rep: RP-150272->RP-150769 29/09/15: Stat Rep: RP-150769->RP-151285; 22/3/16: ;
- 1159: ; 20/12/16: Compl:0%->5%
- 1161: 1st Apr 15: Compl:0%->10% 1st Apr 15: WID: RP-142237->RP-150129 1st Apr 15: Stat Rep: ->RP-150127 03/07/15: Compl:10%->40% 03/07/15: Stat Rep: RP-150127->RP-150761 29/09/15: Compl:40%->50% 29/09/15: Stat Rep: RP-150761->RP-151281;
- 1162: 1st Apr 15: WID: RP-142237->RP-150129 1st Apr 15: Stat Rep: ->RP-150127 03/07/15: Stat Rep: RP-150127->RP-150761 29/09/15: Stat Rep: RP-150761->RP-1512811/1/16: Compl:0%->90% ;
- 1164: 1st Apr 15: Compl:0%->95% 1st Apr 15: CD:Tue 15/12/15->Mon 15/06/15 1st Apr 15: WID: RP-142020->RP-150115 1st Apr 15: Stat Rep: ->RP-150013 03/07/15: Compl:95%->100% 03/07/15: Stat Rep: RP-150013->RP-150536
- 1165: 1st Apr 15: Compl:0%->95% 1st Apr 15: CD:Tue 15/12/15->Mon 15/06/15 1st Apr 15: WID: RP-142020->RP-150115 1st Apr 15: Stat Rep: ->RP-150013 03/07/15: Compl:95%->100% 03/07/15: Stat Rep: RP-150013->RP-150536
- 1167: 1st Apr 15: Compl:0%->20% 1st Apr 15: Stat Rep: ->RP-150013 03/07/15: Compl:20%->65% 03/07/15: Stat Rep: RP-150013->RP-150536 29/09/15: CD:Tue 15/09/15->Tue 15/12/15 29/09/15: WID: RP-142239->RP-151446 29/09/15: Stat Rep: RP-150536->RP-151131; 29/09/1
- 1168: 1st Apr 15: Compl:0%->20% 1st Apr 15: Stat Rep: ->RP-150013 03/07/15: Compl:20%->65% 03/07/15: Stat Rep: RP-150013->RP-150536 29/09/15: CD:Tue 15/09/15->Tue 15/12/15 29/09/15: WID: RP-142239->RP-151446 29/09/15: Stat Rep: RP-150536->RP-151131; 29/09/1
- 1170: 1st Apr 15: Compl:0%->50% 1st Apr 15: Stat Rep: ->RP-150013 03/07/15: Compl:50%->90% 03/07/15: CD:Mon 15/06/15->Tue 15/09/15 03/07/15: Stat Rep: RP-150013->RP-150536 29/09/15: Compl:90%->100% 29/09/15: Stat Rep: RP-150536->RP-151131
- 1171: 03/07/15: Compl:0%->90% 03/07/15: CD:Mon 15/06/15->Tue 15/09/15 03/07/15: Stat Rep: ->RP-150536 29/09/15: Compl:90%->100% 29/09/15: Stat Rep: RP-150536->RP-151131
- 1173: 1st Apr 15: Compl:0%->50% 1st Apr 15: Stat Rep: ->RP-150013 03/07/15: Compl:50%->90% 03/07/15: CD:Mon 15/06/15->Tue 15/09/15 03/07/15: WID: RP-141791->RP-150639 03/07/15: Stat Rep: RP-150013->RP-150536 29/09/15: Compl:90%->100% 29/09/15: Stat Rep: RP-
- 1174: 03/07/15: CD:Mon 15/06/15->Tue 15/09/15 03/07/15: WID: RP-141791->RP-150639 03/07/15: Stat Rep: ->RP-150536 29/09/15: Compl:0%->100% 29/09/15: Stat Rep: RP-150536->RP-151131
- 1176: 1st Apr 15: Compl:0%->90% 1st Apr 15: Stat Rep: ->RP-150013 03/07/15: Compl:90%->100% 03/07/15: WID: RP-141792->RP-150640 03/07/15: Stat Rep: RP-150013->RP-150536
- 1177: 03/07/15: Compl:0%->100% 03/07/15: WID: RP-141792->RP-150640 03/07/15: Stat Rep: ->RP-150536
- 1179: 1st Apr 15: Compl:0%->40% 1st Apr 15: Stat Rep: ->RP-150013 03/07/15: Compl:40%->75% 03/07/15: CD:Mon 15/06/15->Tue 15/09/15 03/07/15: WID: RP-141802->RP-150614 03/07/15: Stat Rep: RP-150013->RP-150536 29/09/15: Compl:75%->100% 29/09/15: Stat Rep: RP-
- 1180: 1st Apr 15: Compl:0%->40% 1st Apr 15: Stat Rep: ->RP-150013 03/07/15: Compl:40%->75% 03/07/15: CD:Mon 15/06/15->Tue 15/09/15 03/07/15: WID: RP-141802->RP-150614 03/07/15: Stat Rep: RP-150013->RP-150536 29/09/15: Compl:75%->100% 29/09/15: Stat Rep: RP-

| ID | WBS | Task | Duration | Start | Finish | Complete | Remaining | Total slack | Constraint | Resources | Work | Actual work | Acronym | PCG approved | WI rapporteur name | WI rapporteur e-mail | Release | TSG approved | Status Report |
| --- | --- | --- | --- | --- | --- | --- | --- | --- | --- | --- | --- | --- | --- | --- | --- | --- | --- | --- | --- |
| 1181 | 362.30 | **LTE Advanced 3 band Carrier Aggregation (3DL/1UL) of Band 1, Band 8 and Band 28** | 327d? | 2014-12-15 A | 2016-03-15 | 40% | 196.2d? | 723d |  | R4 | 7848h | 2723.2h | LTE_CA_B1_B8_B28 | PCG-34 | Softbank Mobile | Softbank Mobile | Rel-13 | RP-66 |  |
| 1182 | 362.30.1 | Core part: LTE Advanced 3 band Carrier Aggregation (3DL/1UL) of Band 1, Band 8 and Band 28 | 327d? | 2014-12-15 A | 2016-03-15 | 40% | 196.2d? | 723d | finish no earlier than 2016-03-15 | R4 | 2616h | 1046.4h | LTE_CA_B1_B8_B28-Core | PCG-34 | Softbank Mobile | Softbank Mobile | Rel-13 | RP-66 | RP-151131 |
| 1183 | 362.30.2 | Perf. part: LTE Advanced 3 band Carrier Aggregation (3DL/1UL) of Band 1, Band 8 and Band 28 | 327d? | 2014-12-15 A | 2016-03-15 | 40% | 196.2d? | 723d | finish no earlier than 2016-03-15 | R4 | 2616h | 1046.4h | LTE_CA_B1_B8_B28-Perf | PCG-34 | Softbank Mobile | Softbank Mobile | Rel-13 | RP-66 | RP-151131 |
| 1184 | 362.31 | **LTE Advanced 3 Band Carrier Aggregation (3DL/1UL) of Band 3, Band 7 and Band 7** | 131d? | 2014-12-15 A | 2015-06-15 A | 100% |  |  |  | R4 | 3144h | 3144h | LTE_CA_B3_B7_B7_Bwset | PCG-34 | Ericsson | Ericsson | Rel-13 | RP-66 |  |
| 1185 | 362.31.1 | Core part: Additional bandwidth combination set for LTE Advanced 3 Band Carrier Aggregation (3DL/1UL) of Band 3, Band 7 and Band 7 | 131d? | 2014-12-15 A | 2015-06-15 A | 100% |  |  | finish no earlier than 2015-06-15 | R4 | 1048h | 1048h | LTE_CA_B3_B7_B7_Bwset-Core | PCG-34 | Ericsson | Ericsson | Rel-13 | RP-66 | RP-150536 |
| 1186 | 362.31.2 | Perf. Part: Additional bandwidth combination set for LTE Advanced 3 Band Carrier Aggregation (3DL/1UL) of Band 3, Band 7 and Band 7 | 131d? | 2014-12-15 A | 2015-06-15 A | 100% |  |  | finish no earlier than 2015-06-15 | R4 | 1048h | 1048h | LTE_CA_B3_B7_B7_BWset-Perf | PCG-34 | Ericsson | Ericsson | Rel-13 | RP-66 | RP-150536 |
| 1187 | 362.32 | **LTE Advanced 3 Band Carrier Aggregation (3DL/1UL) of Band 7, Band 7 and Band 28** | 131d? | 2014-12-15 A | 2015-06-15 A | 100% |  |  |  | R4 | 3144h | 3144h | LTE_CA_B7_B7_B28 | PCG-34 | Ericsson | Ericsson | Rel-13 | RP-66 |  |
| 1188 | 362.32.1 | Core part: LTE Advanced 3 Band Carrier Aggregation (3DL/1UL) of Band 7, Band 7 and Band 28 | 131d? | 2014-12-15 A | 2015-06-15 A | 100% |  |  | finish no earlier than 2015-06-15 | R4 | 1048h | 1048h | LTE_CA_B7_B7_B28-Core | PCG-34 | Ericsson | Ericsson | Rel-13 | RP-66 | RP-150536 |
| 1189 | 362.32.2 | Perf. part: LTE Advanced 3 Band Carrier Aggregation (3DL/1UL) of Band 7, Band 7 and Band 28 | 131d? | 2014-12-15 A | 2015-06-15 A | 100% |  |  | finish no earlier than 2015-06-15 | R4 | 1048h | 1048h | LTE_CA_B7_B7_B28-Perf | PCG-34 | Ericsson | Ericsson | Rel-13 | RP-66 | RP-150536 |
| 1190 | 362.33 | **LTE Advanced 3 band Carrier Aggregation (3DL/1UL) of Band 1, Band 3 and Band 40** | 262d? | 2014-12-15 A | 2015-12-15 A | 100% |  |  |  | R4 | 6288h | 6288h | LTE_CA_B1_B3_B40 | PCG-34 | KT | KT | Rel-13 | RP-66 |  |
| 1191 | 362.33.1 | Core part: LTE Advanced 3 band Carrier Aggregation (3DL/1UL) of Band 1, Band 3 and Band 40 | 262d? | 2014-12-15 A | 2015-12-15 A | 100% |  |  | finish no earlier than 2015-12-15 | R4 | 2096h | 2096h | LTE_CA_B1_B3_B40-Core | PCG-34 | KT | KT | Rel-13 | RP-66 | RP-151131 |
| 1192 | 362.33.2 | Perf. part: LTE Advanced 3 band Carrier Aggregation (3DL/1UL) of Band 1, Band 3 and Band 40 | 262d? | 2014-12-15 A | 2015-12-15 A | 100% |  |  | finish no earlier than 2015-12-15 | R4 | 2096h | 2096h | LTE_CA_B1_B3_B40-Perf | PCG-34 | KT | KT | Rel-13 | RP-66 | RP-151131 |
| 1193 | 362.34 | **LTE Advanced 3 band Carrier Aggregation (3DL/1UL) of Band 1, Band 8 and Band 40** | 262d? | 2014-12-15 A | 2015-12-15 A | 100% |  |  |  | R4 | 6288h | 6288h | LTE_CA_B1_B8_B40 | PCG-34 | KT | KT | Rel-13 | RP-66 |  |
| 1194 | 362.34.1 | Core part: LTE Advanced 3 band Carrier Aggregation (3DL/1UL) of Band 1, Band 8 and Band 40 | 262d? | 2014-12-15 A | 2015-12-15 A | 100% |  |  | finish no earlier than 2015-12-15 | R4 | 2096h | 2096h | LTE_CA_B1_B8_B40-Core | PCG-34 | KT | KT | Rel-13 | RP-66 | RP-151131 |
| 1195 | 362.34.2 | Perf. part: LTE Advanced 3 band Carrier Aggregation (3DL/1UL) of Band 1, Band 8 and Band 40 | 262d? | 2014-12-15 A | 2015-12-15 A | 100% |  |  | finish no earlier than 2015-12-15 | R4 | 2096h | 2096h | LTE_CA_B1_B8_B40-Perf | PCG-34 | KT | KT | Rel-13 | RP-66 | RP-151131 |
| 1196 | 362.35 | **LTE Advanced 3 band Carrier Aggregation (3DL/1UL) of Band 3, Band 8 and Band 40** | 262d? | 2014-12-15 A | 2015-12-15 A | 100% |  |  |  | R4 | 6288h | 6288h | LTE_CA_B3_B8_B40 | PCG-34 | KT | KT | Rel-13 | RP-66 |  |
| 1197 | 362.35.1 | Core part: LTE Advanced 3 band Carrier Aggregation (3DL/1UL) of Band 3, Band 8 and Band 40 | 262d? | 2014-12-15 A | 2015-12-15 A | 100% |  |  | finish no earlier than 2015-12-15 | R4 | 2096h | 2096h | LTE_CA_B3_B8_B40-Core | PCG-34 | KT | KT | Rel-13 | RP-66 | RP-151131 |
| 1198 | 362.35.2 | Perf. part: LTE Advanced 3 band Carrier Aggregation (3DL/1UL) of Band 3, Band 8 and Band 40 | 262d? | 2014-12-15 A | 2015-12-15 A | 100% |  |  | finish no earlier than 2015-12-15 | R4 | 2096h | 2096h | LTE_CA_B3_B8_B40-Perf | PCG-34 | KT | KT | Rel-13 | RP-66 | RP-151131 |
| 1199 | 362.36 | **LTE Advanced 3 Band Carrier Aggregation (3DL) of Band 3, Band 7 and Band 8** | 131d? | 2014-12-15 A | 2015-06-15 A | 100% |  |  |  | R4 | 3144h | 3144h | LTE_CA_B3_B7_B8 | PCG-34 | Ericsson | Ericsson | Rel-13 | RP-66 |  |
| 1200 | 362.36.1 | Core part: LTE Advanced 3 Band Carrier Aggregation (3DL) of Band 3, Band 7 and Band 8 | 131d? | 2014-12-15 A | 2015-06-15 A | 100% |  |  | finish no earlier than 2015-06-15 | R4 | 1048h | 1048h | LTE_CA_B3_B7_B8-Core | PCG-34 | Ericsson | Ericsson | Rel-13 | RP-66 | RP-150536 |
| 1201 | 362.36.2 | Perf. part: LTE Advanced 3 Band Carrier Aggregation (3DL) of Band 3, Band 7 and Band 8 | 131d? | 2014-12-15 A | 2015-06-15 A | 100% |  |  | finish no earlier than 2015-06-15 | R4 | 1048h | 1048h | LTE_CA_B3_B7_B8-Perf | PCG-34 | Ericsson | Ericsson | Rel-13 | RP-66 | RP-150536 |
| 1202 | 362.37 | **LTE Advanced 3 Band Carrier Aggregation (3DL/1UL) of Band 1, Band 3 and Band 28** | 131d? | 2014-12-15 A | 2015-06-15 A | 100% |  |  |  | R4 | 3144h | 3144h | LTE_CA_B1_B3_B28 | PCG-34 | Nokia Networks | Nokia Networks | Rel-13 | RP-66 |  |
| 1203 | 362.37.1 | Core part: LTE Advanced 3 Band Carrier Aggregation (3DL/1UL) of Band 1, Band 3 and Band 28 | 131d? | 2014-12-15 A | 2015-06-15 A | 100% |  |  | finish no earlier than 2015-06-15 | R4 | 1048h | 1048h | LTE_CA_B1_B3_B28-Core | PCG-34 | Nokia Networks | Nokia Networks | Rel-13 | RP-66 | RP-150536 |
| 1204 | 362.37.2 | Perf. part: LTE Advanced 3 Band Carrier Aggregation (3DL/1UL) of Band 1, Band 3 and Band 28 | 131d? | 2014-12-15 A | 2015-06-15 A | 100% |  |  | finish no earlier than 2015-06-15 | R4 | 1048h | 1048h | LTE_CA_B1_B3_B28-Perf | PCG-34 | Nokia Networks | Nokia Networks | Rel-13 | RP-66 | RP-150536 |

Notes:
- 1182: 1st Apr 15: Compl:0%->20% 1st Apr 15: WID: RP-141826->RP-150447 1st Apr 15: Stat Rep: ->RP-150013 03/07/15: Compl:20%->40% 03/07/15: Stat Rep: RP-150013->RP-150536 29/09/15: CD:Tue 15/09/15->Tue 15/12/15 29/09/15: Stat Rep: RP-150536->RP-151131
- 1183: 1st Apr 15: Compl:0%->20% 1st Apr 15: WID: RP-141826->RP-150447 1st Apr 15: Stat Rep: ->RP-150013 03/07/15: Compl:20%->40% 03/07/15: Stat Rep: RP-150013->RP-150536 29/09/15: CD:Tue 15/09/15->Tue 15/12/15 29/09/15: Stat Rep: RP-150536->RP-151131
- 1184: Acronym changed from LTE_CA_B3_B7_B7
- 1185: Acronym changed from LTE_CA_B3_B7_B7-Core 1st Apr 15: Compl:0%->99% 1st Apr 15: CD:Sun 15/03/15->Mon 15/06/15 1st Apr 15: Stat Rep: ->RP-150013 03/07/15: Compl:99%->100% 03/07/15: Stat Rep: RP-150013->RP-150536
- 1186: Acronym changed from LTE_CA_B3_B7_B7-Perf 1st Apr 15: Compl:0%->99% 1st Apr 15: CD:Sun 15/03/15->Mon 15/06/15 1st Apr 15: Stat Rep: ->RP-150013 03/07/15: Compl:99%->100% 03/07/15: Stat Rep: RP-150013->RP-150536
- 1188: 1st Apr 15: Compl:0%->99% 1st Apr 15: CD:Sun 15/03/15->Mon 15/06/15 1st Apr 15: Stat Rep: ->RP-150013 03/07/15: Compl:99%->100% 03/07/15: Stat Rep: RP-150013->RP-150536
- 1189: 1st Apr 15: Compl:0%->99% 1st Apr 15: CD:Sun 15/03/15->Mon 15/06/15 1st Apr 15: Stat Rep: ->RP-150013 03/07/15: Compl:99%->100% 03/07/15: Stat Rep: RP-150013->RP-150536
- 1191: 1st Apr 15: Compl:0%->10% 1st Apr 15: Stat Rep: ->RP-150013 03/07/15: Compl:10%->60% 03/07/15: CD:Tue 15/09/15->Tue 15/12/15 03/07/15: Stat Rep: RP-150013->RP-150536 29/09/15: Compl:60%->80% 29/09/15: WID: RP-141946->RP-151258 29/09/15: Stat Rep: RP-1
- 1192: 1st Apr 15: Compl:0%->10% 1st Apr 15: Stat Rep: ->RP-150013 03/07/15: Compl:10%->60% 03/07/15: CD:Tue 15/09/15->Tue 15/12/15 03/07/15: Stat Rep: RP-150013->RP-150536 29/09/15: Compl:60%->80% 29/09/15: WID: RP-141946->RP-151258 29/09/15: Stat Rep: RP-1
- 1194: 1st Apr 15: Compl:0%->10% 1st Apr 15: Stat Rep: ->RP-150013 03/07/15: Compl:10%->60% 03/07/15: CD:Tue 15/09/15->Tue 15/12/15 03/07/15: Stat Rep: RP-150013->RP-150536 29/09/15: Compl:60%->80% 29/09/15: WID: RP-141947->RP-151259 29/09/15: Stat Rep: RP-1
- 1195: 1st Apr 15: Compl:0%->10% 1st Apr 15: Stat Rep: ->RP-150013 03/07/15: Compl:10%->60% 03/07/15: CD:Tue 15/09/15->Tue 15/12/15 03/07/15: Stat Rep: RP-150013->RP-150536 29/09/15: Compl:60%->80% 29/09/15: WID: RP-141947->RP-151259 29/09/15: Stat Rep: RP-1
- 1197: 1st Apr 15: Compl:0%->10% 1st Apr 15: Stat Rep: ->RP-150013 03/07/15: Compl:10%->60% 03/07/15: CD:Tue 15/09/15->Tue 15/12/15 03/07/15: Stat Rep: RP-150013->RP-150536 29/09/15: Compl:60%->95% 29/09/15: WID: RP-141949->RP-151261 29/09/15: Stat Rep: RP-1
- 1198: 1st Apr 15: Compl:0%->10% 1st Apr 15: Stat Rep: ->RP-150013 03/07/15: Compl:10%->60% 03/07/15: CD:Tue 15/09/15->Tue 15/12/15 03/07/15: Stat Rep: RP-150013->RP-150536 29/09/15: Compl:60%->90% 29/09/15: WID: RP-141949->RP-151261 29/09/15: Stat Rep: RP-1
- 1200: 1st Apr 15: Compl:0%->95% 1st Apr 15: Stat Rep: ->RP-150013 03/07/15: Compl:95%->100% 03/07/15: Stat Rep: RP-150013->RP-150536
- 1201: 1st Apr 15: Compl:0%->99% 1st Apr 15: Stat Rep: ->RP-150013 03/07/15: Compl:99%->100% 03/07/15: Stat Rep: RP-150013->RP-150536
- 1203: 1st Apr 15: Compl:0%->99% 1st Apr 15: CD:Sun 15/03/15->Mon 15/06/15 1st Apr 15: Stat Rep: ->RP-150013 03/07/15: Compl:99%->100% 03/07/15: WID: RP-142038->RP-150719 03/07/15: Stat Rep: RP-150013->RP-150536
- 1204: 1st Apr 15: Compl:0%->99% 1st Apr 15: CD:Sun 15/03/15->Mon 15/06/15 1st Apr 15: Stat Rep: ->RP-150013 03/07/15: Compl:99%->100% 03/07/15: WID: RP-142038->RP-150719 03/07/15: Stat Rep: RP-150013->RP-150536

| ID | WBS | Task | Duration | Start | Finish | Complete | Remaining | Total slack | Constraint | Resources | Work | Actual work | Acronym | PCG approved | WI rapporteur name | WI rapporteur e-mail | Release | TSG approved | Status Report |
| --- | --- | --- | --- | --- | --- | --- | --- | --- | --- | --- | --- | --- | --- | --- | --- | --- | --- | --- | --- |
| 1205 | 362.38 | **LTE Advanced 3 band Carrier Aggregation (3DL/1UL) of Band 3, Band 8 and Band 28** | 327d? | 2014-12-15 A | 2016-03-15 | 40% | 196.2d? | 723d |  | R4 | 7848h | 2332.07h | LTE_CA_B3_B8_B28 | PCG-34 | Softbank Mobile | Softbank Mobile | Rel-13 | RP-66 |  |
| 1206 | 362.38.1 | Core part: LTE Advanced 3 band Carrier Aggregation (3DL/1UL) of Band 3, Band 8 and Band 28 | 327d? | 2014-12-15 A | 2016-03-15 | 40% | 196.2d? | 723d | finish no earlier than 2016-03-15 | R4 | 2616h | 1046.4h | LTE_CA_B3_B8_B28-Core | PCG-34 | Softbank Mobile | Softbank Mobile | Rel-13 | RP-66 | RP-151131 |
| 1207 | 362.38.2 | Perf. part: LTE Advanced 3 band Carrier Aggregation (3DL/1UL) of Band 3, Band 8 and Band 28 | 327d? | 2014-12-15 A | 2016-03-15 | 40% | 196.2d? | 723d | finish no earlier than 2016-03-15 | R4 | 2616h | 1046.4h | LTE_CA_B3_B8_B28-Perf | PCG-34 | Softbank Mobile | Softbank Mobile | Rel-13 | RP-66 | RP-151131 |
| 1208 | 362.39 | **LTE Advanced 3 Band Carrier Aggregation (3DL/1UL) of Band 8, Band 42 and Band 42** | 327d? | 2014-12-15 A | 2016-03-15 A | 100% |  |  |  | R4 | 7848h | 7848h | LTE_CA_B8_B42_B42 | PCG-34 | Softbank Mobile | Softbank Mobile | Rel-13 | RP-66 |  |
| 1209 | 362.39.1 | Core part: LTE Advanced 3 Band Carrier Aggregation (3DL/1UL) of Band 8, Band 42 and Band 42 | 327d? | 2014-12-15 A | 2016-03-15 A | 100% |  |  | finish no earlier than 2016-03-15 | R4 | 2616h | 2616h | LTE_CA_B8_B42_B42-Core | PCG-34 | Softbank Mobile | Softbank Mobile | Rel-13 | RP-66 | RP-151131 |
| 1210 | 362.39.2 | Perf. part: LTE Advanced 3 Band Carrier Aggregation (3DL/1UL) of Band 8, Band 42 and Band 42 | 327d? | 2014-12-15 A | 2016-03-15 A | 100% |  |  | finish no earlier than 2016-03-15 | R4 | 2616h | 2616h | LTE_CA_B8_B42_B42-Perf | PCG-34 | Softbank Mobile | Softbank Mobile | Rel-13 | RP-66 | RP-151131 |
| 1211 | 362.40 | **LTE Advanced 3 Band Carrier Aggregation (3DL/1UL) of Band 28, Band 40 and Band 40** | 262d? | 2014-12-15 A | 2015-12-15 A | 100% |  |  |  | R4 | 6288h | 6288h | LTE_CA_B28_B40_B40 | PCG-34 | Huawei | Huawei | Rel-13 | RP-66 |  |
| 1212 | 362.40.1 | Core part: LTE Advanced 3 Band Carrier Aggregation (3DL/1UL) of Band 28, Band 40 and Band 40 | 262d? | 2014-12-15 A | 2015-12-15 A | 100% |  |  | finish no earlier than 2015-12-15 | R4 | 2096h | 2096h | LTE_CA_B28_B40_B40-Core | PCG-34 | Huawei | Huawei | Rel-13 | RP-66 | RP-151131 |
| 1213 | 362.40.2 | Perf. part: LTE Advanced 3 Band Carrier Aggregation (3DL/1UL) of Band 28, Band 40 and Band 40 | 262d? | 2014-12-15 A | 2015-12-15 A | 100% |  |  | finish no earlier than 2015-12-15 | R4 | 2096h | 2096h | LTE_CA_B28_B40_B40-Perf | PCG-34 | Huawei | Huawei | Rel-13 | RP-66 | RP-151131 |
| 1214 | 362.41 | **LTE Advanced 3 Band Carrier Aggregation (3DL/1UL) of Band 3, Band 40 and Band 40** | 131d? | 2014-12-15 A | 2015-06-15 A | 100% |  |  |  | R4 | 3144h | 3144h | LTE_CA_B3_B40_B40 | PCG-34 | Huawei | Huawei | Rel-13 | RP-66 |  |
| 1215 | 362.41.1 | Core part: LTE Advanced 3 Band Carrier Aggregation (3DL/1UL) of Band 3, Band 40 and Band 40 | 131d? | 2014-12-15 A | 2015-06-15 A | 100% |  |  | finish no earlier than 2015-06-15 | R4 | 1048h | 1048h | LTE_CA_B3_B40_B40-Core | PCG-34 | Huawei | Huawei | Rel-13 | RP-66 | RP-150536 |
| 1216 | 362.41.2 | Perf. part: LTE Advanced 3 Band Carrier Aggregation (3DL/1UL) of Band 3, Band 40 and Band 40 | 131d? | 2014-12-15 A | 2015-06-15 A | 100% |  |  | finish no earlier than 2015-06-15 | R4 | 1048h | 1048h | LTE_CA_B3_B40_B40-Perf | PCG-34 | Huawei | Huawei | Rel-13 | RP-66 | RP-150536 |
| 1217 | 362.42 | **LTE Advanced 3 Band Carrier Aggregation (3DL/1UL) of Band 1, Band 7 and Band 28** | 131d? | 2014-12-15 A | 2015-06-15 A | 100% |  |  |  | R4 | 3144h | 3144h | LTE_CA_B1_B7_B28 | PCG-34 | Huawei | Huawei | Rel-13 | RP-66 |  |
| 1218 | 362.42.1 | Core part: LTE Advanced 3 Band Carrier Aggregation (3DL/1UL) of Band 1, Band 7 and Band 28 | 131d? | 2014-12-15 A | 2015-06-15 A | 100% |  |  | finish no earlier than 2015-06-15 | R4 | 1048h | 1048h | LTE_CA_B1_B7_B28-Core | PCG-34 | Huawei | Huawei | Rel-13 | RP-66 | RP-150536 |
| 1219 | 362.42.2 | Perf. part: LTE Advanced 3 Band Carrier Aggregation (3DL/1UL) of Band 1, Band 7 and Band 28 | 131d? | 2014-12-15 A | 2015-06-15 A | 100% |  |  | finish no earlier than 2015-06-15 | R4 | 1048h | 1048h | LTE_CA_B1_B7_B28-Perf | PCG-34 | Huawei | Huawei | Rel-13 | RP-66 | RP-150536 |
| 1220 | 362.43 | **LTE Advanced 3 Band Carrier Aggregation (3DL/1UL) of Band 1, Band 3 and Band 7** | 262d? | 2014-12-15 A | 2015-12-15 A | 100% |  |  |  | R4 | 6288h | 6288h | LTE_CA_B1_B3_B7 | PCG-34 | Huawei | Huawei | Rel-13 | RP-66 |  |
| 1221 | 362.43.1 | Core part: LTE Advanced 3 Band Carrier Aggregation (3DL/1UL) of Band 1, Band 3 and Band 7 | 262d? | 2014-12-15 A | 2015-12-15 A | 100% |  |  | finish no earlier than 2015-12-15 | R4 | 2096h | 2096h | LTE_CA_B1_B3_B7-Core | PCG-34 | Huawei | Huawei | Rel-13 | RP-66 | RP-151131 |
| 1222 | 362.43.2 | Perf. part: LTE Advanced 3 Band Carrier Aggregation (3DL/1UL) of Band 1, Band 3 and Band 7 | 262d? | 2014-12-15 A | 2015-12-15 A | 100% |  |  | finish no earlier than 2015-12-15 | R4 | 2096h | 2096h | LTE_CA_B1_B3_B7-Perf | PCG-34 | Huawei | Huawei | Rel-13 | RP-66 | RP-151131 |
| 1223 | 362.44 | **LTE Advanced 3 Band Carrier Aggregation (3DL/1UL) of Band 3, Band 3 and Band 5** | 131d? | 2014-12-15 A | 2015-06-15 A | 100% |  |  |  | R4 | 3144h | 3144h | LTE_CA_B3_B3_B5 | PCG-34 | Intel | Intel | Rel-13 | RP-66 |  |
| 1224 | 362.44.1 | Core part: LTE Advanced 3 Band Carrier Aggregation (3DL/1UL) of Band 3, Band 3 and Band 5 | 131d? | 2014-12-15 A | 2015-06-15 A | 100% |  |  | finish no earlier than 2015-09-15 | R4 | 1048h | 1048h | LTE_CA_B3_B3_B5-Core | PCG-34 | Intel | Intel | Rel-13 | RP-66 | RP-150536 |
| 1225 | 362.44.2 | Perf. part: LTE Advanced 3 Band Carrier Aggregation (3DL/1UL) of Band 3, Band 3 and Band 5 | 131d? | 2014-12-15 A | 2015-06-15 A | 100% |  |  | finish no earlier than 2015-09-15 | R4 | 1048h | 1048h | LTE_CA_B3_B3_B5-Perf | PCG-34 | Intel | Intel | Rel-13 | RP-66 | RP-150536 |
| 1226 | 362.45 | **LTE Advanced 3 Band Carrier Aggregation (3DL/1UL) of Band 3, Band 7 and Band 28** | 131d? | 2014-12-15 A | 2015-06-15 A | 100% |  |  |  | R4 | 3144h | 3144h | LTE_CA_B3_B7_B28 | PCG-34 | Ericsson | Ericsson | Rel-13 | RP-66 |  |
| 1227 | 362.45.1 | Core part: LTE Advanced 3 Band Carrier Aggregation (3DL/1UL) of Band 3, Band 7 and Band 28 | 131d? | 2014-12-15 A | 2015-06-15 A | 100% |  |  | finish no earlier than 2015-06-15 | R4 | 1048h | 1048h | LTE_CA_B3_B7_B28-Core | PCG-34 | Ericsson | Ericsson | Rel-13 | RP-66 | RP-150536 |
| 1228 | 362.45.2 | Perf. part: LTE Advanced 3 Band Carrier Aggregation (3DL/1UL) of Band 3, Band 7 and Band 28 | 131d? | 2014-12-15 A | 2015-06-15 A | 100% |  |  | finish no earlier than 2015-06-15 | R4 | 1048h | 1048h | LTE_CA_B3_B7_B28-Perf | PCG-34 | Ericsson | Ericsson | Rel-13 | RP-66 | RP-150536 |

Notes:
- 1206: 1st Apr 15: Compl:0%->20% 1st Apr 15: CD:Tue 15/12/15->Tue 15/09/15 1st Apr 15: Stat Rep: ->RP-150013 03/07/15: Compl:20%->40% 03/07/15: Stat Rep: RP-150013->RP-150536 29/09/15: CD:Tue 15/09/15->Tue 15/12/15 29/09/15: Stat Rep: RP-150536->RP-151131;
- 1207: 1st Apr 15: Compl:0%->20% 1st Apr 15: Stat Rep: ->RP-150013 03/07/15: Compl:20%->40% 03/07/15: Stat Rep: RP-150013->RP-150536 29/09/15: CD:Tue 15/09/15->Tue 15/12/15 29/09/15: Stat Rep: RP-150536->RP-151131
- 1209: 1st Apr 15: Compl:0%->20% 1st Apr 15: CD:Tue 15/12/15->Mon 15/06/15 1st Apr 15: Stat Rep: ->RP-150013 03/07/15: Compl:20%->40% 03/07/15: CD:Mon 15/06/15->Tue 15/09/15 03/07/15: Stat Rep: RP-150013->RP-150536 29/09/15: CD:Tue 15/09/15->Tue 15/12/15 29
- 1210: 1st Apr 15: Compl:0%->20% 1st Apr 15: Stat Rep: ->RP-150013 03/07/15: Compl:20%->40% 03/07/15: CD:Mon 15/06/15->Tue 15/09/15 03/07/15: Stat Rep: RP-150013->RP-150536 29/09/15: CD:Tue 15/09/15->Tue 15/12/15 29/09/15: Stat Rep: RP-150536->RP-151131;
- 1212: 1st Apr 15: Compl:0%->30% 1st Apr 15: CD:Tue 15/12/15->Mon 15/06/15 1st Apr 15: WID: RP-142206->RP-150233 1st Apr 15: Stat Rep: ->RP-150013 03/07/15: Compl:30%->60% 03/07/15: CD:Mon 15/06/15->Tue 15/12/15 03/07/15: WID: RP-150233->RP-150676 03/07/15:
- 1213: 1st Apr 15: WID: RP-142206->RP-150233 1st Apr 15: Stat Rep: ->RP-150013 03/07/15: CD:Mon 15/06/15->Tue 15/12/15 03/07/15: WID: RP-150233->RP-150676 03/07/15: Stat Rep: RP-150013->RP-150536 29/09/15: Stat Rep: RP-150536->RP-151131;
- 1215: 1st Apr 15: Compl:0%->50% 1st Apr 15: CD:Tue 15/12/15->Mon 15/06/15 1st Apr 15: Stat Rep: ->RP-150013 03/07/15: Compl:50%->100% 03/07/15: WID: RP-142207->RP-151071 03/07/15: Stat Rep: RP-150013->RP-150536
- 1216: 03/07/15: Compl:0%->100% 03/07/15: WID: RP-142207->RP-151071 03/07/15: Stat Rep: ->RP-150536
- 1218: 1st Apr 15: Compl:0%->50% 1st Apr 15: CD:Tue 15/12/15->Mon 15/06/15 1st Apr 15: WID: RP-142208->RP-150234 1st Apr 15: Stat Rep: ->RP-150013 03/07/15: Compl:50%->100% 03/07/15: Stat Rep: RP-150013->RP-150536
- 1219: 1st Apr 15: WID: RP-142208->RP-150234 1st Apr 15: Stat Rep: ->RP-150013 03/07/15: Compl:0%->100% 03/07/15: Stat Rep: RP-150013->RP-150536
- 1221: 1st Apr 15: Compl:0%->30% 1st Apr 15: CD:Tue 15/12/15->Mon 15/06/15 1st Apr 15: Stat Rep: ->RP-150013 03/07/15: Compl:30%->40% 03/07/15: CD:Mon 15/06/15->Tue 15/09/15 03/07/15: Stat Rep: RP-150013->RP-150536 29/09/15: Compl:40%->50% 29/09/15: CD:Tue 1
- 1222: 03/07/15: CD:Mon 15/06/15->Tue 15/09/15 03/07/15: Stat Rep: ->RP-150536 29/09/15: CD:Tue 15/09/15->Tue 15/12/15 29/09/15: Stat Rep: RP-150536->RP-151131
- 1224: 1st Apr 15: Compl:0%->10% 1st Apr 15: Stat Rep: ->RP-150013 03/07/15: Compl:10%->100% 03/07/15: CD:Tue 15/09/15->Mon 15/06/15 03/07/15: Stat Rep: RP-150013->RP-150536
- 1225: 03/07/15: Compl:0%->100% 03/07/15: CD:Tue 15/09/15->Mon 15/06/15 03/07/15: Stat Rep: ->RP-150536
- 1227: 1st Apr 15: Compl:0%->99% 1st Apr 15: CD:Sun 15/03/15->Mon 15/06/15 1st Apr 15: Stat Rep: ->RP-150013 03/07/15: Compl:99%->100% 03/07/15: Stat Rep: RP-150013->RP-150536
- 1228: 1st Apr 15: Compl:0%->99% 1st Apr 15: CD:Sun 15/03/15->Mon 15/06/15 1st Apr 15: Stat Rep: ->RP-150013 03/07/15: Compl:99%->100% 03/07/15: Stat Rep: RP-150013->RP-150536

| ID | WBS | Task | Duration | Start | Finish | Complete | Constraint | Resources | Work | Actual work | Acronym | PCG approved | WI rapporteur name | WI rapporteur e-mail | Release | TSG approved | Status Report |
| --- | --- | --- | --- | --- | --- | --- | --- | --- | --- | --- | --- | --- | --- | --- | --- | --- | --- |
| 1229 | 362.46 | **LTE Advanced 4 Band Carrier Aggregation (4DL/1UL) of Band 2, Band 2, Band 12 and Band 30** | 262d? | 2014-12-15 A | 2015-12-15 A | 100% |  | R4 | 6288h | 6288h | LTE_CA_B2_B2_B12_B30 | PCG-34 | AT&T | AT&T | Rel-13 | RP-66 |  |
| 1230 | 362.46.1 | Core part: LTE Advanced 4 Band Carrier Aggregation (4DL/1UL) of Band 2, Band 2, Band 12 and Band 30 | 262d? | 2014-12-15 A | 2015-12-15 A | 100% | finish no earlier than 2015-12-15 | R4 | 2096h | 2096h | LTE_CA_B2_B2_B12_B30-Core | PCG-34 | AT&T | AT&T | Rel-13 | RP-66 | RP-151131 |
| 1231 | 362.46.2 | Perf. part: LTE Advanced 4 Band Carrier Aggregation (4DL/1UL) of Band 2, Band 2, Band 12 and Band 30 | 262d? | 2014-12-15 A | 2015-12-15 A | 100% | finish no earlier than 2015-12-15 | R4 | 2096h | 2096h | LTE_CA_B2_B2_B12_B30-Perf | PCG-34 | AT&T | AT&T | Rel-13 | RP-66 | RP-151131 |
| 1232 | 362.47 | **LTE Advanced 4 Band Carrier Aggregation (4DL/1UL) of Band 2, Band 2, Band 5 and Band 30** | 262d? | 2014-12-15 A | 2015-12-15 A | 100% |  | R4 | 6288h | 6288h | LTE_CA_B2_B2_B5_B30 | PCG-34 | AT&T | AT&T | Rel-13 | RP-66 |  |
| 1233 | 362.47.1 | Core part: LTE Advanced 4 Band Carrier Aggregation (4DL/1UL) of Band 2, Band 2, Band 5 and Band 30 | 262d? | 2014-12-15 A | 2015-12-15 A | 100% | finish no earlier than 2015-12-15 | R4 | 2096h | 2096h | LTE_CA_B2_B2_B5_B30-Core | PCG-34 | AT&T | AT&T | Rel-13 | RP-66 | RP-151131 |
| 1234 | 362.47.2 | Perf. part: LTE Advanced 4 Band Carrier Aggregation (4DL/1UL) of Band 2, Band 2, Band 5 and Band 30 | 262d? | 2014-12-15 A | 2015-12-15 A | 100% | finish no earlier than 2015-12-15 | R4 | 2096h | 2096h | LTE_CA_B2_B2_B5_B30-Perf | PCG-34 | AT&T | AT&T | Rel-13 | RP-66 | RP-151131 |
| 1235 | 362.48 | **LTE Advanced 4 Band Carrier Aggregation (4DL/1UL) of Band 2, Band 2 Band 29 and Band 30** | 262d? | 2014-12-15 A | 2015-12-15 A | 100% |  | R4 | 6288h | 6288h | LTE_CA_B2_B2_B29_B30 | PCG-34 | AT&T | AT&T | Rel-13 | RP-66 |  |
| 1236 | 362.48.1 | Core part: LTE Advanced 4 Band Carrier Aggregation (4DL/1UL) of Band 2, Band 2 Band 29 and Band 30 | 262d? | 2014-12-15 A | 2015-12-15 A | 100% | finish no earlier than 2015-12-15 | R4 | 2096h | 2096h | LTE_CA_B2_B2_B29_B30-Core | PCG-34 | AT&T | AT&T | Rel-13 | RP-66 | RP-151131 |
| 1237 | 362.48.2 | Perf. part: LTE Advanced 4 Band Carrier Aggregation (4DL/1UL) of Band 2, Band 2 Band 29 and Band 30 | 262d? | 2014-12-15 A | 2015-12-15 A | 100% | finish no earlier than 2015-12-15 | R4 | 2096h | 2096h | LTE_CA_B2_B2_B29_B30-Perf | PCG-34 | AT&T | AT&T | Rel-13 | RP-66 | RP-151131 |
| 1238 | 362.49 | **LTE Advanced 4 Band Carrier Aggregation (4DL/1UL) of Band 2, Band 4, Band 12 and Band 30** | 262d? | 2014-12-15 A | 2015-12-15 A | 100% |  | R4 | 6288h | 6288h | LTE_CA_B2_B4_B12_B30 | PCG-34 | AT&T | AT&T | Rel-13 | RP-66 |  |
| 1239 | 362.49.1 | Core part: LTE Advanced 4 Band Carrier Aggregation (4DL/1UL) of Band 2, Band 4, Band 12 and Band 30 | 262d? | 2014-12-15 A | 2015-12-15 A | 100% | finish no earlier than 2015-12-15 | R4 | 2096h | 2096h | LTE_CA_B2_B4_B12_B30-Core | PCG-34 | AT&T | AT&T | Rel-13 | RP-66 | RP-151131 |
| 1240 | 362.49.2 | Perf. part: LTE Advanced 4 Band Carrier Aggregation (4DL/1UL) of Band 2, Band 4, Band 12 and Band 30 | 262d? | 2014-12-15 A | 2015-12-15 A | 100% | finish no earlier than 2015-12-15 | R4 | 2096h | 2096h | LTE_CA_B2_B4_B12_B30-Perf | PCG-34 | AT&T | AT&T | Rel-13 | RP-66 | RP-151131 |
| 1241 | 362.50 | **LTE Advanced 4 Band Carrier Aggregation (4DL/1UL) of Band 2, Band 4, Band 5 and Band 30** | 262d? | 2014-12-15 A | 2015-12-15 A | 100% |  | R4 | 6288h | 6288h | LTE_CA_B2_B4_B5_B30 | PCG-34 | AT&T | AT&T | Rel-13 | RP-66 |  |
| 1242 | 362.50.1 | Core part: LTE Advanced 4 Band Carrier Aggregation (4DL/1UL) of Band 2, Band 4, Band 5 and Band 30 | 262d? | 2014-12-15 A | 2015-12-15 A | 100% | finish no earlier than 2015-12-15 | R4 | 2096h | 2096h | LTE_CA_B2_B4_B5_B30-Core | PCG-34 | AT&T | AT&T | Rel-13 | RP-66 | RP-151131 |
| 1243 | 362.50.2 | Perf. part: LTE Advanced 4 Band Carrier Aggregation (4DL/1UL) of Band 2, Band 4, Band 5 and Band 30 | 262d? | 2014-12-15 A | 2015-12-15 A | 100% | finish no earlier than 2015-12-15 | R4 | 2096h | 2096h | LTE_CA_B2_B4_B5_B30-Perf | PCG-34 | AT&T | AT&T | Rel-13 | RP-66 | RP-151131 |
| 1244 | 362.51 | **LTE Advanced 4 Band Carrier Aggregation (4DL/1UL) of Band 2, Band 4, Band 29 and Band 30** | 262d? | 2014-12-15 A | 2015-12-15 A | 100% |  | R4 | 6288h | 6288h | LTE_CA_B2_B4_B29_B30 | PCG-34 | AT&T | AT&T | Rel-13 | RP-66 |  |
| 1245 | 362.51.1 | Core part: LTE Advanced 4 Band Carrier Aggregation (4DL/1UL) of Band 2, Band 4, Band 29 and Band 30 | 262d? | 2014-12-15 A | 2015-12-15 A | 100% | finish no earlier than 2015-12-15 | R4 | 2096h | 2096h | LTE_CA_B2_B4_B29_B30-Core | PCG-34 | AT&T | AT&T | Rel-13 | RP-66 | RP-151131 |
| 1246 | 362.51.2 | Perf. part: LTE Advanced 4 Band Carrier Aggregation (4DL/1UL) of Band 2, Band 4, Band 29 and Band 30 | 262d? | 2014-12-15 A | 2015-12-15 A | 100% | finish no earlier than 2015-12-15 | R4 | 2096h | 2096h | LTE_CA_B2_B4_B29_B30-Perf | PCG-34 | AT&T | AT&T | Rel-13 | RP-66 | RP-151131 |
| 1247 | 362.52 | **LTE Advanced 4 Band Carrier Aggregation (4DL/1UL) of Band 25, Band 41, Band 41 and Band 41** | 262d? | 2014-12-15 A | 2015-12-15 A | 100% |  | R4 | 6288h | 6288h | LTE_CA_B25_B41_B41_B41 | PCG-34 | Alcatel-Lucent | Alcatel-Lucent | Rel-13 | RP-66 |  |
| 1248 | 362.52.1 | Core part: LTE Advanced 4 Band Carrier Aggregation (4DL/1UL) of Band 25, Band 41, Band 41 and Band 41 | 262d? | 2014-12-15 A | 2015-12-15 A | 100% | finish no earlier than 2015-12-15 | R4 | 2096h | 2096h | LTE_CA_B25_B41_B41_B41-Core | PCG-34 | Alcatel-Lucent | Alcatel-Lucent | Rel-13 | RP-66 | RP-151131 |
| 1249 | 362.52.2 | Perf. part: LTE Advanced 4 Band Carrier Aggregation (4DL/1UL) of Band 25, Band 41, Band 41 and Band 41 | 262d? | 2014-12-15 A | 2015-12-15 A | 100% | finish no earlier than 2015-12-15 | R4 | 2096h | 2096h | LTE_CA_B25_B41_B41_B41-Perf | PCG-34 | Alcatel-Lucent | Alcatel-Lucent | Rel-13 | RP-66 | RP-151131 |
| 1250 | 362.53 | **LTE Advanced dual uplink inter-band Carrier Aggregation Class A1 in REL-13** | 262d? | 2014-12-15 A | 2015-12-15 A | 100% |  | R4 | 6288h | 6288h | LTE_CA_2UL_R13-A1 | PCG-34 | Huawei | Huawei | Rel-13 | RP-66 |  |
| 1251 | 362.53.1 | Core part: LTE Advanced dual uplink inter-band Carrier Aggregation Class A1 in REL-13 | 262d? | 2014-12-15 A | 2015-12-15 A | 100% | finish no earlier than 2015-12-15 | R4 | 2096h | 2096h | LTE_CA_2UL_R13-A1-Core | PCG-34 | Huawei | Huawei | Rel-13 | RP-66 | RP-151131 |
| 1252 | 362.53.2 | Perf. part: LTE Advanced dual uplink inter-band Carrier Aggregation Class A1 in REL-13 | 262d? | 2014-12-15 A | 2015-12-15 A | 100% | finish no earlier than 2015-12-15 | R4 | 2096h | 2096h | LTE_CA_2UL_R13-A1-Perf | PCG-34 | Huawei | Huawei | Rel-13 | RP-66 | RP-151131 |

Notes:
- 1230: 1st Apr 15: Compl:0%->50% 1st Apr 15: WID: RP-142198->RP-150449 1st Apr 15: Stat Rep: ->RP-150013 03/07/15: Compl:50%->95% 03/07/15: Stat Rep: RP-150013->RP-150536 29/09/15: Stat Rep: RP-150536->RP-151131
- 1231: 1st Apr 15: Compl:0%->50% 1st Apr 15: WID: RP-142198->RP-150449 1st Apr 15: Stat Rep: ->RP-150013 03/07/15: Compl:50%->95% 03/07/15: Stat Rep: RP-150013->RP-150536 29/09/15: Stat Rep: RP-150536->RP-151131
- 1233: 1st Apr 15: Compl:0%->50% 1st Apr 15: CD:Tue 15/12/15->Tue 15/09/15 1st Apr 15: WID: RP-142199->RP-150448 1st Apr 15: Stat Rep: ->RP-150013 03/07/15: Compl:50%->95% 03/07/15: CD:Tue 15/09/15->Tue 15/12/15 03/07/15: Stat Rep: RP-150013->RP-150536 29/09
- 1234: 1st Apr 15: Compl:0%->50% 1st Apr 15: WID: RP-142199->RP-150448 1st Apr 15: Stat Rep: ->RP-150013 03/07/15: Compl:50%->95% 03/07/15: Stat Rep: RP-150013->RP-150536 29/09/15: Stat Rep: RP-150536->RP-151131
- 1236: 1st Apr 15: Compl:0%->50% 1st Apr 15: WID: RP-142200->RP-150450 1st Apr 15: Stat Rep: ->RP-150013 03/07/15: Compl:50%->95% 03/07/15: Stat Rep: RP-150013->RP-150536 29/09/15: Stat Rep: RP-150536->RP-151131
- 1237: 1st Apr 15: Compl:0%->50% 1st Apr 15: WID: RP-142200->RP-150450 1st Apr 15: Stat Rep: ->RP-150013 03/07/15: Compl:50%->95% 03/07/15: Stat Rep: RP-150013->RP-150536 29/09/15: Stat Rep: RP-150536->RP-151131
- 1239: 1st Apr 15: Compl:0%->50% 1st Apr 15: WID: RP-142201->RP-150452 1st Apr 15: Stat Rep: ->RP-150013 03/07/15: Compl:50%->95% 03/07/15: Stat Rep: RP-150013->RP-150536 29/09/15: Stat Rep: RP-150536->RP-151131
- 1240: 1st Apr 15: Compl:0%->50% 1st Apr 15: WID: RP-142201->RP-150452 1st Apr 15: Stat Rep: ->RP-150013 03/07/15: Compl:50%->95% 03/07/15: Stat Rep: RP-150013->RP-150536 29/09/15: Stat Rep: RP-150536->RP-151131
- 1242: 1st Apr 15: Compl:0%->50% 1st Apr 15: WID: RP-142202->RP-150451 1st Apr 15: Stat Rep: ->RP-150013 03/07/15: Compl:50%->95% 03/07/15: Stat Rep: RP-150013->RP-150536 29/09/15: Stat Rep: RP-150536->RP-151131
- 1243: 1st Apr 15: Compl:0%->50% 1st Apr 15: WID: RP-142202->RP-150451 1st Apr 15: Stat Rep: ->RP-150013 03/07/15: Compl:50%->95% 03/07/15: Stat Rep: RP-150013->RP-150536 29/09/15: Stat Rep: RP-150536->RP-151131
- 1245: 1st Apr 15: Compl:0%->50% 1st Apr 15: WID: RP-142203->RP-150453 1st Apr 15: Stat Rep: ->RP-150013 03/07/15: Compl:50%->95% 03/07/15: Stat Rep: RP-150013->RP-150536 29/09/15: Stat Rep: RP-150536->RP-151131
- 1246: 1st Apr 15: Compl:0%->50% 1st Apr 15: WID: RP-142203->RP-150453 1st Apr 15: Stat Rep: ->RP-150013 03/07/15: Compl:50%->95% 03/07/15: Stat Rep: RP-150013->RP-150536 29/09/15: Stat Rep: RP-150536->RP-151131
- 1248: 1st Apr 15: Compl:0%->50% 1st Apr 15: Stat Rep: ->RP-150013 03/07/15: Compl:50%->90% 03/07/15: Stat Rep: RP-150013->RP-150536 29/09/15: Compl:90%->95% 29/09/15: CD:Tue 15/09/15->Tue 15/12/15 29/09/15: Stat Rep: RP-150536->RP-151131
- 1249: 1st Apr 15: Compl:0%->25% 1st Apr 15: Stat Rep: ->RP-150013 03/07/15: Compl:25%->75% 03/07/15: Stat Rep: RP-150013->RP-150536 29/09/15: Compl:75%->80% 29/09/15: Stat Rep: RP-150536->RP-151131
- 1251: 1st Apr 15: Compl:0%->40% 1st Apr 15: WID: RP-141935->RP-150411 1st Apr 15: Stat Rep: ->RP-150013 03/07/15: Compl:40%->60% 03/07/15: WID: RP-150411->RP-150678 03/07/15: Stat Rep: RP-150013->RP-150536 29/09/15: Compl:60%->80% 29/09/15: Stat Rep: RP-150
- 1252: 1st Apr 15: Compl:0%->40% 1st Apr 15: WID: RP-141935->RP-150411 1st Apr 15: Stat Rep: ->RP-150013 03/07/15: Compl:40%->60% 03/07/15: WID: RP-150411->RP-150678 03/07/15: Stat Rep: RP-150013->RP-150536 29/09/15: Compl:60%->80% 29/09/15: Stat Rep: RP-150

| ID | WBS | Task | Duration | Start | Finish | Complete | Baseline start | Baseline finish | Baseline duration | Constraint | Resources | Work | Actual work | Acronym | PCG approved | WI rapporteur name | WI rapporteur e-mail | Release | TSG approved | Status Report | Acronym_3GU_Export |
| --- | --- | --- | --- | --- | --- | --- | --- | --- | --- | --- | --- | --- | --- | --- | --- | --- | --- | --- | --- | --- | --- |
| 1253 | 362.54 | **LTE Advanced dual uplink inter-band Carrier Aggregation Class A2 in REL-13** | 262d? | 2014-12-15 A | 2015-12-15 A | 100% |  |  |  |  | R4 | 6288h | 6288h | LTE_CA_2UL_R13-A2 | PCG-34 | Qualcomm | Qualcomm | Rel-13 | RP-66 |  |  |
| 1254 | 362.54.1 | Core part: LTE Advanced dual uplink inter-band Carrier Aggregation Class A2 in REL-13 | 262d? | 2014-12-15 A | 2015-12-15 A | 100% |  |  |  | finish no earlier than 2015-12-15 | R4 | 2096h | 2096h | LTE_CA_2UL_R13-A2-Core | PCG-34 | Qualcomm | Qualcomm | Rel-13 | RP-66 | RP-151131 |  |
| 1255 | 362.54.2 | Perf. part: LTE Advanced dual uplink inter-band Carrier Aggregation Class A2 in REL-13 | 262d? | 2014-12-15 A | 2015-12-15 A | 100% |  |  |  | finish no earlier than 2015-12-15 | R4 | 2096h | 2096h | LTE_CA_2UL_R13-A2-Perf | PCG-34 | Qualcomm | Qualcomm | Rel-13 | RP-66 | RP-151131 |  |
| 1256 | 362.55 | **LTE Advanced dual uplink inter-band Carrier Aggregation Class A3 in REL-13** | 262d? | 2014-12-15 A | 2015-12-15 A | 100% |  |  |  |  | R4 | 6288h | 6288h | LTE_CA_2UL_R13-A3 | PCG-34 | Ericsson | Ericsson | Rel-13 | RP-66 |  |  |
| 1257 | 362.55.1 | Core part: LTE Advanced dual uplink inter-band Carrier Aggregation Class A3 in REL-13 | 262d? | 2014-12-15 A | 2015-12-15 A | 100% |  |  |  | finish no earlier than 2015-12-15 | R4 | 2096h | 2096h | LTE_CA_2UL_R13-A3-Core | PCG-34 | Ericsson | Ericsson | Rel-13 | RP-66 | RP-151131 |  |
| 1258 | 362.55.2 | Perf. part: LTE Advanced dual uplink inter-band Carrier Aggregation Class A3 in REL-13 | 262d? | 2014-12-15 A | 2015-12-15 A | 100% |  |  |  | finish no earlier than 2015-12-15 | R4 | 2096h | 2096h | LTE_CA_2UL_R13-A3-Perf | PCG-34 | Ericsson | Ericsson | Rel-13 | RP-66 | RP-151131 |  |
| 1259 | 362.56 | **LTE Advanced intra-band non-contiguous Carrier Aggregation in Band 41 for 4 DL** | 262d? | 2014-12-15 A | 2015-12-15 A | 100% |  |  |  |  | R4 | 6288h | 6288h | LTE_CA_NC_B41_4DL | PCG-34 | Alcatel-Lucent | Alcatel-Lucent | Rel-13 | RP-66 |  |  |
| 1260 | 362.56.1 | Core part: LTE Advanced intra-band non-contiguous Carrier Aggregation in Band 41 for 4 DL | 262d? | 2014-12-15 A | 2015-12-15 A | 100% |  |  |  | finish no earlier than 2015-12-15 | R4 | 2096h | 2096h | LTE_CA_NC_B41_4DL-Core | PCG-34 | Alcatel-Lucent | Alcatel-Lucent | Rel-13 | RP-66 | RP-151131 |  |
| 1261 | 362.56.2 | Perf. part: LTE Advanced intra-band non-contiguous Carrier Aggregation in Band 41 for 4 DL | 262d? | 2014-12-15 A | 2015-12-15 A | 100% | 2013-09-18 | 2015-12-24 | 593d? | finish no earlier than 2015-12-15 | R4 | 2096h | 2096h | LTE_CA_NC_B41_4DL-Perf | PCG-31 | Alcatel-Lucent | Alcatel-Lucent | Rel-13 | RP-66 | RP-151131 | TEI13 |
| 1262 | 362.57 | **LTE Advanced 3 Band Carrier Aggregation (3DL/1UL) of Band 1, Band 3 and Band 42** | 66d? | 2015-03-16 A | 2015-06-15 A | 100% |  |  |  |  | R4 | 1584h | 1584h | LTE_CA_B1_B3_B42 | PCG-34 | NTT DOCOMO, INC. |  | Rel-13 | RP-67 |  |  |
| 1263 | 362.57.1 | Core part: LTE Advanced 3 Band Carrier Aggregation (3DL/1UL) of Band 1, Band 3 and Band 42 | 66d? | 2015-03-16 A | 2015-06-15 A | 100% |  |  |  | finish no earlier than 2015-09-15 | R4 | 528h | 528h | LTE_CA_B1_B3_B42-Core | PCG-34 | NTT DOCOMO, INC. |  | Rel-13 | RP-67 | RP-150536 |  |
| 1264 | 362.57.2 | Perf. part: LTE Advanced 3 Band Carrier Aggregation (3DL/1UL) of Band 1, Band 3 and Band 42 | 66d? | 2015-03-16 A | 2015-06-15 A | 100% |  |  |  | finish no earlier than 2015-09-15 | R4 | 528h | 528h | LTE_CA_B1_B3_B42-Perf | PCG-34 | NTT DOCOMO, INC. |  | Rel-13 | RP-67 | RP-150536 |  |
| 1265 | 362.58 | **LTE Advanced 3 Band Carrier Aggregation (3DL/1UL) of Band 1, Band 19 and Band 42** | 66d? | 2015-03-16 A | 2015-06-15 A | 100% |  |  |  |  | R4 | 1584h | 1584h | LTE_CA_B1_B19_B42 | PCG-34 | NTT DOCOMO, INC. |  | Rel-13 | RP-67 |  |  |
| 1266 | 362.58.1 | Core part: LTE Advanced 3 Band Carrier Aggregation (3DL/1UL) of Band 1, Band 19 and Band 42 | 66d? | 2015-03-16 A | 2015-06-15 A | 100% |  |  |  | finish no earlier than 2015-09-15 | R4 | 528h | 528h | LTE_CA_B1_B19_B42-Core | PCG-34 | NTT DOCOMO, INC. |  | Rel-13 | RP-67 | RP-150536 |  |
| 1267 | 362.58.2 | Perf. part: LTE Advanced 3 Band Carrier Aggregation (3DL/1UL) of Band 1, Band 19 and Band 42 | 66d? | 2015-03-16 A | 2015-06-15 A | 100% |  |  |  | finish no earlier than 2015-09-15 | R4 | 528h | 528h | LTE_CA_B1_B19_B42-Perf | PCG-34 | NTT DOCOMO, INC. |  | Rel-13 | RP-67 | RP-150536 |  |
| 1268 | 362.59 | **LTE Advanced 3 Band Carrier Aggregation (3DL/1UL) of Band 1, Band 21 and Band 42** | 66d? | 2015-03-16 A | 2015-06-15 A | 100% |  |  |  |  | R4 | 1584h | 1584h | LTE_CA_B1_B21_B42 | PCG-34 | NTT DOCOMO, INC. |  | Rel-13 | RP-67 |  |  |
| 1269 | 362.59.1 | Core part: LTE Advanced 3 Band Carrier Aggregation (3DL/1UL) of Band 1, Band 21 and Band 42 | 66d? | 2015-03-16 A | 2015-06-15 A | 100% |  |  |  | finish no earlier than 2015-09-15 | R4 | 528h | 528h | LTE_CA_B1_B21_B42-Core | PCG-34 | NTT DOCOMO, INC. |  | Rel-13 | RP-67 | RP-150536 |  |
| 1270 | 362.59.2 | Perf. part: LTE Advanced 3 Band Carrier Aggregation (3DL/1UL) of Band 1, Band 21 and Band 42 | 66d? | 2015-03-16 A | 2015-06-15 A | 100% |  |  |  | finish no earlier than 2015-09-15 | R4 | 528h | 528h | LTE_CA_B1_B21_B42-Perf | PCG-34 | NTT DOCOMO, INC. |  | Rel-13 | RP-67 | RP-150536 |  |
| 1271 | 362.60 | **LTE Advanced 3 Band Carrier Aggregation (3DL/1UL) of Band 3, Band 19 and Band 42** | 66d? | 2015-03-16 A | 2015-06-15 A | 100% |  |  |  |  | R4 | 1584h | 1584h | LTE_CA_B3_B19_B42 | PCG-34 | NTT DOCOMO, INC. |  | Rel-13 | RP-67 |  |  |
| 1272 | 362.60.1 | Core part: LTE Advanced 3 Band Carrier Aggregation (3DL/1UL) of Band 3, Band 19 and Band 42 | 66d? | 2015-03-16 A | 2015-06-15 A | 100% |  |  |  | finish no earlier than 2015-09-15 | R4 | 528h | 528h | LTE_CA_B3_B19_B42-Core | PCG-34 | NTT DOCOMO, INC. |  | Rel-13 | RP-67 | RP-150536 |  |
| 1273 | 362.60.2 | Perf. part: LTE Advanced 3 Band Carrier Aggregation (3DL/1UL) of Band 3, Band 19 and Band 42 | 66d? | 2015-03-16 A | 2015-06-15 A | 100% |  |  |  | finish no earlier than 2015-09-15 | R4 | 528h | 528h | LTE_CA_B3_B19_B42-Perf | PCG-34 | NTT DOCOMO, INC. |  | Rel-13 | RP-67 | RP-150536 |  |
| 1274 | 362.61 | **LTE Advanced 3 Band Carrier Aggregation (3DL/1UL) of Band 19, Band 21 and Band 42** | 66d? | 2015-03-16 A | 2015-06-15 A | 100% |  |  |  |  | R4 | 1584h | 1584h | LTE_CA_B19_B21_B42 | PCG-34 | NTT DOCOMO, INC. |  | Rel-13 | RP-67 |  |  |
| 1275 | 362.61.1 | Core part: LTE Advanced 3 Band Carrier Aggregation (3DL/1UL) of Band 19, Band 21 and Band 42 | 66d? | 2015-03-16 A | 2015-06-15 A | 100% |  |  |  | finish no earlier than 2015-09-15 | R4 | 528h | 528h | LTE_CA_B19_B21_B42-Core | PCG-34 | NTT DOCOMO, INC. |  | Rel-13 | RP-67 | RP-150536 |  |
| 1276 | 362.61.2 | Perf. part: LTE Advanced 3 Band Carrier Aggregation (3DL/1UL) of Band 19, Band 21 and Band 42 | 66d? | 2015-03-16 A | 2015-06-15 A | 100% |  |  |  | finish no earlier than 2015-09-15 | R4 | 528h | 528h | LTE_CA_B19_B21_B42-Perf | PCG-34 | NTT DOCOMO, INC. |  | Rel-13 | RP-67 | RP-150536 |  |

Notes:
- 1254: 1st Apr 15: Compl:0%->50% 1st Apr 15: WID: RP-141975->RP-150408 1st Apr 15: Stat Rep: ->RP-150013 03/07/15: Stat Rep: RP-150013->RP-150536 29/09/15: Stat Rep: RP-150536->RP-151131
- 1255: 1st Apr 15: Compl:0%->50% 1st Apr 15: WID: RP-141975->RP-150408 1st Apr 15: Stat Rep: ->RP-150013 03/07/15: Stat Rep: RP-150013->RP-150536 29/09/15: Stat Rep: RP-150536->RP-151131
- 1257: 1st Apr 15: Compl:0%->25% 1st Apr 15: WID: RP-142010->RP-150409 1st Apr 15: Stat Rep: ->RP-150013 03/07/15: Compl:25%->50% 03/07/15: Stat Rep: RP-150013->RP-150536 29/09/15: Compl:50%->75% 29/09/15: Stat Rep: RP-150536->RP-151131;
- 1258: 1st Apr 15: Compl:0%->25% 1st Apr 15: WID: RP-142010->RP-150409 1st Apr 15: Stat Rep: ->RP-150013 03/07/15: Compl:25%->50% 03/07/15: Stat Rep: RP-150013->RP-150536 29/09/15: Compl:50%->75% 29/09/15: Stat Rep: RP-150536->RP-151131;
- 1260: 1st Apr 15: Compl:0%->10% 1st Apr 15: CD:Tue 15/03/16->Tue 15/12/15 1st Apr 15: Stat Rep: ->RP-150013 03/07/15: Compl:10%->50% 03/07/15: Stat Rep: RP-150013->RP-150536 29/09/15: Compl:50%->80% 29/09/15: Stat Rep: RP-150536->RP-151131
- 1261: 1st Apr 15: Compl:0%->10% 1st Apr 15: CD:Tue 18/12/18->Tue 15/12/15 1st Apr 15: Stat Rep: -->RP-150013 03/07/15: Compl:10%->25% 03/07/15: Stat Rep: RP-150013->RP-150536 29/09/15: Compl:25%->50% 29/09/15: Stat Rep: RP-150536->RP-151131 ;
- 1263: 03/07/15: Compl:0%->100% 03/07/15: CD:Tue 15/09/15->Mon 15/06/15 03/07/15: WID: RP-150121->RP-150641 03/07/15: Stat Rep: ->RP-150536
- 1264: 03/07/15: Compl:0%->100% 03/07/15: CD:Tue 15/09/15->Mon 15/06/15 03/07/15: WID: RP-150121->RP-150641 03/07/15: Stat Rep: ->RP-150536
- 1266: 03/07/15: Compl:0%->100% 03/07/15: CD:Tue 15/09/15->Mon 15/06/15 03/07/15: WID: RP-150122->RP-150642 03/07/15: Stat Rep: ->RP-150536
- 1267: 03/07/15: Compl:0%->100% 03/07/15: CD:Tue 15/09/15->Mon 15/06/15 03/07/15: WID: RP-150122->RP-150642 03/07/15: Stat Rep: ->RP-150536
- 1269: 03/07/15: Compl:0%->100% 03/07/15: CD:Tue 15/09/15->Mon 15/06/15 03/07/15: WID: RP-150123->RP-150643 03/07/15: Stat Rep: ->RP-150536
- 1270: 03/07/15: Compl:0%->100% 03/07/15: CD:Tue 15/09/15->Mon 15/06/15 03/07/15: WID: RP-150123->RP-150643 03/07/15: Stat Rep: ->RP-150536
- 1272: 03/07/15: Compl:0%->100% 03/07/15: CD:Tue 15/09/15->Mon 15/06/15 03/07/15: WID: RP-150124->RP-150644 03/07/15: Stat Rep: ->RP-150536
- 1273: 03/07/15: Compl:0%->100% 03/07/15: CD:Tue 15/09/15->Mon 15/06/15 03/07/15: WID: RP-150124->RP-150644 03/07/15: Stat Rep: ->RP-150536
- 1275: 03/07/15: Compl:0%->100% 03/07/15: CD:Tue 15/09/15->Mon 15/06/15 03/07/15: WID: RP-150125->RP-150645 03/07/15: Stat Rep: ->RP-150536
- 1276: 03/07/15: Compl:0%->100% 03/07/15: CD:Tue 15/09/15->Mon 15/06/15 03/07/15: WID: RP-150125->RP-150645 03/07/15: Stat Rep: ->RP-150536

| ID | WBS | Task | Duration | Start | Finish | Complete | Constraint | Resources | Work | Actual work | Acronym | PCG approved | WI rapporteur name | Release | TSG approved | Status Report |
| --- | --- | --- | --- | --- | --- | --- | --- | --- | --- | --- | --- | --- | --- | --- | --- | --- |
| 1277 | 362.62 | **Additional bandwidth combination set for LTE Advanced 3 Band Carrier Aggregation (3DL/1UL) of Band 4, Band 4 and Band 7** | 197d? | 2015-03-16 A | 2015-12-15 A | 100% |  | R4 | 4728h | 4728h | LTE_CA_B4_B4_B7_BWset | PCG-34 | Rogers Communications | Rel-13 | RP-67 |  |
| 1278 | 362.62.1 | Core part: Additional bandwidth combination set for LTE Advanced 3 Band Carrier Aggregation (3DL/1UL) of Band 4, Band 4 and Band 7 | 197d? | 2015-03-16 A | 2015-12-15 A | 100% | finish no earlier than 2015-12-15 | R4 | 1576h | 1576h | LTE_CA_B4_B4_B7_BWset-Core | PCG-34 | Rogers Communications | Rel-13 | RP-67 | RP-151131 |
| 1279 | 362.62.2 | Perf. part: Additional bandwidth combination set for LTE Advanced 3 Band Carrier Aggregation (3DL/1UL) of Band 4, Band 4 and Band 7 | 197d? | 2015-03-16 A | 2015-12-15 A | 100% | finish no earlier than 2015-12-15 | R4 | 1576h | 1576h | LTE_CA_B4_B4_B7_BWset-Perf | PCG-34 | Rogers Communications | Rel-13 | RP-67 | RP-151131 |
| 1280 | 362.63 | **Additional bandwidth combination set for LTE Advanced 3 Band Carrier Aggregation (3DL/1UL) of Band 4, Band 7 and Band 12** | 197d? | 2015-03-16 A | 2015-12-15 A | 100% |  | R4 | 4728h | 4728h | LTE_CA_B4_B7_B12_BWset | PCG-34 | Rogers Communications | Rel-13 | RP-67 |  |
| 1281 | 362.63.1 | Core part: Additional bandwidth combination set for LTE Advanced 3 Band Carrier Aggregation (3DL/1UL) of Band 4, Band 7 and Band 12 | 197d? | 2015-03-16 A | 2015-12-15 A | 100% | finish no earlier than 2015-12-15 | R4 | 1576h | 1576h | LTE_CA_B4_B7_B12_BWset-Core | PCG-34 | Rogers Communications | Rel-13 | RP-67 | RP-151131 |
| 1282 | 362.63.2 | Perf. part: Additional bandwidth combination set for LTE Advanced 3 Band Carrier Aggregation (3DL/1UL) of Band 4, Band 7 and Band 12 | 197d? | 2015-03-16 A | 2015-12-15 A | 100% | finish no earlier than 2015-12-15 | R4 | 1576h | 1576h | LTE_CA_B4_B7_B12_BWset-Perf | PCG-34 | Rogers Communications | Rel-13 | RP-67 | RP-151131 |
| 1283 | 362.64 | **LTE Advanced 3 Band Carrier Aggregation (3DL/1UL) of Band 2, Band 7 and Band 12** | 262d? | 2015-03-16 A | 2016-03-15 A | 100% |  | R4 | 6288h | 6288h | LTE_CA_B2_B7_B12 | PCG-34 | Rogers Communications | Rel-13 | RP-67 |  |
| 1284 | 362.64.1 | Core part: LTE Advanced 3 Band Carrier Aggregation (3DL/1UL) of Band 2, Band 7 and Band 12 | 262d? | 2015-03-16 A | 2016-03-15 A | 100% | finish no earlier than 2016-03-15 | R4 | 2096h | 2096h | LTE_CA_B2_B7_B12-Core | PCG-34 | Rogers Communications | Rel-13 | RP-67 | RP-151131 |
| 1285 | 362.64.2 | Perf. part: LTE Advanced 3 Band Carrier Aggregation (3DL/1UL) of Band 2, Band 7 and Band 12 | 262d? | 2015-03-16 A | 2016-03-15 A | 100% | finish no earlier than 2016-03-15 | R4 | 2096h | 2096h | LTE_CA_B2_B7_B12-Perf | PCG-34 | Rogers Communications | Rel-13 | RP-67 | RP-151131 |
| 1286 | 362.65 | **LTE Advanced 3 Band Carrier Aggregation (3DL/1UL) of Band 2, Band 4 and Band 7** | 262d? | 2015-03-16 A | 2016-03-15 A | 100% |  | R4 | 6288h | 6288h | LTE_CA_B2_B4_B7 | PCG-34 | Rogers Communications | Rel-13 | RP-67 |  |
| 1287 | 362.65.1 | Core part: LTE Advanced 3 Band Carrier Aggregation (3DL/1UL) of Band 2, Band 4 and Band 7 | 262d? | 2015-03-16 A | 2016-03-15 A | 100% | finish no earlier than 2016-03-15 | R4 | 2096h | 2096h | LTE_CA_B2_B4_B7-Core | PCG-34 | Rogers Communications | Rel-13 | RP-67 | RP-151131 |
| 1288 | 362.65.2 | Perf. part: LTE Advanced 3 Band Carrier Aggregation (3DL/1UL) of Band 2, Band 4 and Band 7 | 262d? | 2015-03-16 A | 2016-03-15 A | 100% | finish no earlier than 2016-03-15 | R4 | 2096h | 2096h | LTE_CA_B2_B4_B7-Perf | PCG-34 | Rogers Communications | Rel-13 | RP-67 | RP-151131 |
| 1289 | 362.66 | **LTE Advanced 3 Band Carrier Aggregation (3DL/1UL) of Band 7, Band 20 and Band 38** | 197d? | 2015-03-16 A | 2015-12-15 A | 100% |  | R4 | 4728h | 4728h | LTE_CA_B7_B20_B38 | PCG-34 | Nokia Networks | Rel-13 | RP-67 |  |
| 1290 | 362.66.1 | Core part: LTE Advanced 3 Band Carrier Aggregation (3DL/1UL) of Band 7, Band 20 and Band 38 | 197d? | 2015-03-16 A | 2015-12-15 A | 100% | finish no earlier than 2015-12-15 | R4 | 1576h | 1576h | LTE_CA_B7_B20_B38-Core | PCG-34 | Nokia Networks | Rel-13 | RP-67 | RP-151131 |
| 1291 | 362.66.2 | Perf. part: LTE Advanced 3 Band Carrier Aggregation (3DL/1UL) of Band 7, Band 20 and Band 38 | 197d? | 2015-03-16 A | 2015-12-15 A | 100% | finish no earlier than 2015-12-15 | R4 | 1576h | 1576h | LTE_CA_B7_B20_B38-Perf | PCG-34 | Nokia Networks | Rel-13 | RP-67 | RP-151131 |
| 1292 | 362.67 | **LTE Advanced 4 Band Carrier Aggregation (4DL/1UL) of Band 2, Band 4, Band 4 and Band 12** | 197d? | 2015-03-16 A | 2015-12-15 A | 100% |  | R4 | 4728h | 4728h | LTE_CA_B2_B4_B4_B12 | PCG-34 | Nokia Networks | Rel-13 | RP-67 |  |
| 1293 | 362.67.1 | Core part: LTE Advanced 4 Band Carrier Aggregation (4DL/1UL) of Band 2, Band 4, Band 4 and Band 12 | 197d? | 2015-03-16 A | 2015-12-15 A | 100% | finish no earlier than 2015-12-15 | R4 | 1576h | 1576h | LTE_CA_B2_B4_B4_B12-Core | PCG-34 | Nokia Networks | Rel-13 | RP-67 | RP-151131 |
| 1294 | 362.67.2 | Perf. part: LTE Advanced 4 Band Carrier Aggregation (4DL/1UL) of Band 2, Band 4, Band 4 and Band 12 | 197d? | 2015-03-16 A | 2015-12-15 A | 100% | finish no earlier than 2015-12-15 | R4 | 1576h | 1576h | LTE_CA_B2_B4_B4_B12-Perf | PCG-34 | Nokia Networks | Rel-13 | RP-67 | RP-151131 |
| 1295 | 362.68 | **LTE Advanced 4 Band Carrier Aggregation (4DL/1UL) of Band 2, Band 2, Band 4 and Band 12** | 197d? | 2015-03-16 A | 2015-12-15 A | 100% |  | R4 | 4728h | 4728h | LTE_CA_B2_B2_B4_B12 | PCG-34 | Nokia Networks | Rel-13 | RP-67 |  |
| 1296 | 362.68.1 | Core part: LTE Advanced 4 Band Carrier Aggregation (4DL/1UL) of Band 2, Band 2, Band 4 and Band 12 | 197d? | 2015-03-16 A | 2015-12-15 A | 100% | finish no earlier than 2015-12-15 | R4 | 1576h | 1576h | LTE_CA_B2_B2_B4_B12-Core | PCG-34 | Nokia Networks | Rel-13 | RP-67 | RP-151131 |
| 1297 | 362.68.2 | Perf. part: LTE Advanced 4 Band Carrier Aggregation (4DL/1UL) of Band 2, Band 2, Band 4 and Band 12 | 197d? | 2015-03-16 A | 2015-12-15 A | 100% | finish no earlier than 2015-12-15 | R4 | 1576h | 1576h | LTE_CA_B2_B2_B4_B12-Perf | PCG-34 | Nokia Networks | Rel-13 | RP-67 | RP-151131 |
| 1298 | 362.69 | **LTE Advanced 4 Band Carrier Aggregation (4DL/1UL) of Band 2, Band 2, Band 4 and Band 4** | 197d? | 2015-03-16 A | 2015-12-15 A | 100% |  | R4 | 4728h | 4728h | LTE_CA_B2_B2_B4_B4 | PCG-34 | Nokia Networks | Rel-13 | RP-67 |  |
| 1299 | 362.69.1 | Core part: LTE Advanced 4 Band Carrier Aggregation (4DL/1UL) of Band 2, Band 2, Band 4 and Band 4 | 197d? | 2015-03-16 A | 2015-12-15 A | 100% | finish no earlier than 2015-12-15 | R4 | 1576h | 1576h | LTE_CA_B2_B2_B4_B4-Core | PCG-34 | Nokia Networks | Rel-13 | RP-67 | RP-151131 |
| 1300 | 362.69.2 | Perf. part: LTE Advanced 4 Band Carrier Aggregation (4DL/1UL) of Band 2, Band 2, Band 4 and Band 4 | 197d? | 2015-03-16 A | 2015-12-15 A | 100% | finish no earlier than 2015-12-15 | R4 | 1576h | 1576h | LTE_CA_B2_B2_B4_B4-Perf | PCG-34 | Nokia Networks | Rel-13 | RP-67 | RP-151131 |

Notes:
- 1278: 03/07/15: CD:Tue 15/09/15->Tue 15/12/15 03/07/15: Stat Rep: ->RP-150536 29/09/15: Stat Rep: RP-150536->RP-151131
- 1279: 03/07/15: CD:Tue 15/09/15->Tue 15/12/15 03/07/15: Stat Rep: ->RP-150536 29/09/15: Stat Rep: RP-150536->RP-151131
- 1281: 03/07/15: CD:Tue 15/09/15->Tue 15/12/15 03/07/15: Stat Rep: ->RP-150536 29/09/15: Stat Rep: RP-150536->RP-151131
- 1282: 03/07/15: CD:Tue 15/09/15->Tue 15/12/15 03/07/15: Stat Rep: ->RP-150536 29/09/15: Stat Rep: RP-150536->RP-151131
- 1284: 03/07/15: Stat Rep: ->RP-150536 29/09/15: Stat Rep: RP-150536->RP-151131 ; 1/122/3/16: Compl:0%->100%
- 1285: 03/07/15: Stat Rep: ->RP-150536 29/09/15: Stat Rep: RP-150536->RP-151131 122/3/16: Compl:0%->100%
- 1287: 03/07/15: Stat Rep: ->RP-150536 29/09/15: Stat Rep: RP-150536->RP-1511311/1/16:22/3/16: Compl:0%->100%
- 1288: 03/07/15: Stat Rep: ->RP-150536 29/09/15: Stat Rep: RP-150536->RP-151131 1/1/1; 22/3/16: Compl:0%->100%
- 1290: 03/07/15: Compl:0%->30% 03/07/15: Stat Rep: ->RP-150536 29/09/15: Compl:30%->60% 29/09/15: Stat Rep: RP-150536->RP-151131
- 1291: 03/07/15: Compl:0%->30% 03/07/15: Stat Rep: ->RP-150536 29/09/15: Compl:30%->60% 29/09/15: Stat Rep: RP-150536->RP-151131
- 1293: 03/07/15: Compl:0%->95% 03/07/15: WID: RP-150073->RP-150660 03/07/15: Stat Rep: ->RP-150536 29/09/15: Stat Rep: RP-150536->RP-151131
- 1294: 03/07/15: Compl:0%->95% 03/07/15: WID: RP-150073->RP-150660 03/07/15: Stat Rep: ->RP-150536 29/09/15: Stat Rep: RP-150536->RP-151131
- 1296: 03/07/15: Compl:0%->95% 03/07/15: WID: RP-150074->RP-150659 03/07/15: Stat Rep: ->RP-150536 29/09/15: Stat Rep: RP-150536->RP-151131
- 1297: 03/07/15: Compl:0%->95% 03/07/15: WID: RP-150074->RP-150659 03/07/15: Stat Rep: ->RP-150536 29/09/15: Stat Rep: RP-150536->RP-151131
- 1299: 03/07/15: Compl:0%->95% 03/07/15: WID: RP-150075->RP-150658 03/07/15: Stat Rep: ->RP-150536 29/09/15: Stat Rep: RP-150536->RP-151131
- 1300: 03/07/15: Compl:0%->95% 03/07/15: WID: RP-150075->RP-150658 03/07/15: Stat Rep: ->RP-150536 29/09/15: Stat Rep: RP-150536->RP-151131

| ID | WBS | Task | Duration | Start | Finish | Complete | Constraint | Resources | Work | Actual work | Acronym | PCG approved | WI rapporteur name | Release | TSG approved | Status Report |
| --- | --- | --- | --- | --- | --- | --- | --- | --- | --- | --- | --- | --- | --- | --- | --- | --- |
| 1301 | 362.70 | **LTE Advanced 4 Band Carrier Aggregation (4DL/1UL) of Band 1, Band 3, Band 5 and Band 40** | 197d? | 2015-03-16 A | 2015-12-15 A | 100% |  | R4 | 4728h | 4728h | LTE_CA_B1_B3_B5_B40 | PCG-34 | SK Telecom | Rel-13 | RP-67 |  |
| 1302 | 362.70.1 | Core part: LTE Advanced 4 Band Carrier Aggregation (4DL/1UL) of Band 1, Band 3, Band 5 and Band 40 | 197d? | 2015-03-16 A | 2015-12-15 A | 100% | finish no earlier than 2015-12-15 | R4 | 1576h | 1576h | LTE_CA_B1_B3_B5_B40-Core | PCG-34 | SK Telecom | Rel-13 | RP-67 | RP-151131 |
| 1303 | 362.70.2 | Perf. part: LTE Advanced 4 Band Carrier Aggregation (4DL/1UL) of Band 1, Band 3, Band 5 and Band 40 | 197d? | 2015-03-16 A | 2015-12-15 A | 100% | finish no earlier than 2015-12-15 | R4 | 1576h | 1576h | LTE_CA_B1_B3_B5_B40-Perf | PCG-34 | SK Telecom | Rel-13 | RP-67 | RP-151131 |
| 1304 | 362.71 | **LTE Advanced 4 Band Carrier Aggregation (4DL/1UL) of Band 1, Band 3, Band 7 and Band 8** | 197d? | 2015-03-16 A | 2015-12-15 A | 100% |  | R4 | 4728h | 4728h | LTE_CA_B1_B3_B7_B8 | PCG-34 | Nokia Networks | Rel-13 | RP-67 |  |
| 1305 | 362.71.1 | Core part: LTE Advanced 4 Band Carrier Aggregation (4DL/1UL) of Band 1, Band 3, Band 7 and Band 8 | 197d? | 2015-03-16 A | 2015-12-15 A | 100% | finish no earlier than 2015-12-15 | R4 | 1576h | 1576h | LTE_CA_B1_B3_B7_B8-Core | PCG-34 | Nokia Networks | Rel-13 | RP-67 | RP-151131 |
| 1306 | 362.71.2 | Perf. part: LTE Advanced 4 Band Carrier Aggregation (4DL/1UL) of Band 1, Band 3, Band 7 and Band 8 | 197d? | 2015-03-16 A | 2015-12-15 A | 100% | finish no earlier than 2015-12-15 | R4 | 1576h | 1576h | LTE_CA_B1_B3_B7_B8-Perf | PCG-34 | Nokia Networks | Rel-13 | RP-67 | RP-151131 |
| 1307 | 362.72 | **LTE Advanced 4 Band Carrier Aggregation (4DL/1UL) of Band 2, Band 4, Band 5 and Band 29** | 197d? | 2015-03-16 A | 2015-12-15 A | 100% |  | R4 | 4728h | 4728h | LTE_CA_B2_B4_B5_B29 | PCG-34 | Huawei | Rel-13 | RP-67 |  |
| 1308 | 362.72.1 | Core part: LTE Advanced 4 Band Carrier Aggregation (4DL/1UL) of Band 2, Band 4, Band 5 and Band 29 | 197d? | 2015-03-16 A | 2015-12-15 A | 100% | finish no earlier than 2015-12-15 | R4 | 1576h | 1576h | LTE_CA_B2_B4_B5_B29-Core | PCG-34 | Huawei | Rel-13 | RP-67 | RP-151131 |
| 1309 | 362.72.2 | Perf. part: LTE Advanced 4 Band Carrier Aggregation (4DL/1UL) of Band 2, Band 4, Band 5 and Band 29 | 197d? | 2015-03-16 A | 2015-12-15 A | 100% | finish no earlier than 2015-12-15 | R4 | 1576h | 1576h | LTE_CA_B2_B4_B5_B29-Perf | PCG-34 | Huawei | Rel-13 | RP-67 | RP-151131 |
| 1310 | 362.73 | **LTE Advanced dual uplink inter-band Carrier Aggregation FDD-TDD** | 197d? | 2015-03-16 A | 2015-12-15 A | 100% |  | R4 | 4728h | 4728h | LTE_CA_2UL_FDD_TDD | PCG-34 | KDDI | Rel-13 | RP-67 |  |
| 1311 | 362.73.1 | Core part: LTE Advanced dual uplink inter-band Carrier Aggregation FDD-TDD | 197d? | 2015-03-16 A | 2015-12-15 A | 100% | finish no earlier than 2015-12-15 | R4 | 1576h | 1576h | LTE_CA_2UL_FDD_TDD-Core | PCG-34 | KDDI | Rel-13 | RP-67 | RP-151131 |
| 1312 | 362.73.2 | Perf. part: LTE Advanced dual uplink inter-band Carrier Aggregation FDD-TDD | 197d? | 2015-03-16 A | 2015-12-15 A | 100% | finish no earlier than 2015-12-15 | R4 | 1576h | 1576h | LTE_CA_2UL_FDD_TDD-Perf | PCG-34 | KDDI | Rel-13 | RP-67 | RP-151131 |
| 1313 | 362.74 | **LTE Advanced dual uplink inter-band Carrier Aggregation Class A4** | 197d? | 2015-03-16 A | 2015-12-15 A | 100% |  | R4 | 4728h | 4728h | LTE_CA_2UL_R13-A4 | PCG-34 | Nokia Networks | Rel-13 | RP-67 |  |
| 1314 | 362.74.1 | Core part: LTE Advanced dual uplink inter-band Carrier Aggregation Class A4 in REL-13 | 197d? | 2015-03-16 A | 2015-12-15 A | 100% | finish no earlier than 2015-12-15 | R4 | 1576h | 1576h | LTE_CA_2UL_R13-A4-Core | PCG-34 | Nokia Networks | Rel-13 | RP-67 | RP-151131 |
| 1315 | 362.74.2 | Perf. Part: LTE Advanced dual uplink inter-band Carrier Aggregation Class A4 in REL-13 | 197d? | 2015-03-16 A | 2015-12-15 A | 100% | finish no earlier than 2015-12-15 | R4 | 1576h | 1576h | LTE_CA_2UL_R13-A4-Perf | PCG-34 | Nokia Networks | Rel-13 | RP-67 | RP-151131 |
| 1316 | 362.75 | **LTE Advanced 3DL/2UL inter-band Carrier Aggregation** | 197d? | 2015-03-16 A | 2015-12-15 A | 100% |  | R4 | 4728h | 4728h | LTE_CA_3DL_2UL | PCG-34 | Nokia Corporation | Rel-13 | RP-67 |  |
| 1317 | 362.75.1 | Core part: LTE Advanced 3DL/2UL inter-band Carrier Aggregation | 197d? | 2015-03-16 A | 2015-12-15 A | 100% | finish no earlier than 2015-12-15 | R4 | 1576h | 1576h | LTE_CA_3DL_2UL-Core | PCG-34 | Nokia Corporation | Rel-13 | RP-67 | RP-151131 |
| 1318 | 362.75.2 | Perf. part: LTE Advanced 3DL/2UL inter-band Carrier Aggregation | 197d? | 2015-03-16 A | 2015-12-15 A | 100% | finish no earlier than 2015-12-15 | R4 | 1576h | 1576h | LTE_CA_3DL_2UL-Perf | PCG-34 | Nokia Corporation | Rel-13 | RP-67 | RP-151131 |
| 1319 | 362.76 | **LTE Advanced intra-band non-contiguous Carrier Aggregation in Band 42 for 3DL** | 66d? | 2015-03-16 A | 2015-06-15 A | 100% |  | R4 | 1584h | 1584h | LTE_CA_NC_B42_3DL | PCG-34 | Huawei | Rel-13 | RP-67 |  |
| 1320 | 362.76.1 | Core part: LTE Advanced intra-band non-contiguous Carrier Aggregation in Band 42 for 3DL | 66d? | 2015-03-16 A | 2015-06-15 A | 100% | finish no earlier than 2015-09-15 | R4 | 528h | 528h | LTE_CA_NC_B42_3DL-Core | PCG-34 | Huawei | Rel-13 | RP-67 | RP-150536 |
| 1321 | 362.76.2 | Perf. part: LTE Advanced intra-band non-contiguous Carrier Aggregation in Band 42 for 3DL | 66d? | 2015-03-16 A | 2015-06-15 A | 100% | finish no earlier than 2015-09-15 | R4 | 528h | 528h | LTE_CA_NC_B42_3DL-Perf | PCG-34 | Huawei | Rel-13 | RP-67 | RP-150536 |
| 1322 | 362.77 | **LTE Advanced intra-band contiguous Carrier Aggregation in Band 8** | 197d? | 2015-03-16 A | 2015-12-15 A | 100% |  | R4 | 4728h | 4728h | LTE_CA_C_B8 | PCG-34 | CMCC | Rel-13 | RP-67 |  |
| 1323 | 362.77.1 | Core part: LTE Advanced intra-band contiguous Carrier Aggregation in Band 8 | 197d? | 2015-03-16 A | 2015-12-15 A | 100% | finish no earlier than 2015-12-15 | R4 | 1576h | 1576h | LTE_CA_C_B8-Core | PCG-34 | CMCC | Rel-13 | RP-67 | RP-151131 |
| 1324 | 362.77.2 | Perf. part: LTE Advanced intra-band contiguous Carrier Aggregation in Band 8 | 197d? | 2015-03-16 A | 2015-12-15 A | 100% | finish no earlier than 2015-12-15 | R4 | 1576h | 1576h | LTE_CA_C_B8-Perf | PCG-34 | CMCC | Rel-13 | RP-67 | RP-151131 |

Notes:
- 1302: 03/07/15: Compl:0%->30% 03/07/15: WID: RP-150434->RP-150617 03/07/15: Stat Rep: ->RP-150536 29/09/15: Compl:30%->60% 29/09/15: CD:Tue 15/09/15->Tue 15/12/15 29/09/15: WID: RP-150617->RP-151216 29/09/15: Stat Rep: RP-150536->RP-151131
- 1303: 03/07/15: WID: RP-150434->RP-150617 03/07/15: Stat Rep: ->RP-150536 29/09/15: CD:Tue 15/09/15->Tue 15/12/15 29/09/15: WID: RP-150617->RP-151216 29/09/15: Stat Rep: RP-150536->RP-151131
- 1305: 03/07/15: Compl:0%->40% 03/07/15: Stat Rep: ->RP-150536 29/09/15: Compl:40%->45% 29/09/15: Stat Rep: RP-150536->RP-151131
- 1306: 03/07/15: Stat Rep: ->RP-150536 29/09/15: Stat Rep: RP-150536->RP-151131
- 1308: 03/07/15: Compl:0%->50% 03/07/15: Stat Rep: ->RP-150536 29/09/15: Compl:50%->95% 29/09/15: Stat Rep: RP-150536->RP-151131
- 1309: 03/07/15: Stat Rep: ->RP-150536 29/09/15: Compl:0%->95% 29/09/15: Stat Rep: RP-150536->RP-151131
- 1311: 03/07/15: Compl:0%->70% 03/07/15: Stat Rep: ->RP-150536 29/09/15: Compl:70%->90% 29/09/15: Stat Rep: RP-150536->RP-151131
- 1312: 03/07/15: CD:Tue 15/09/15->Tue 15/12/15 03/07/15: Stat Rep: ->RP-150536 29/09/15: Compl:0%->90% 29/09/15: Stat Rep: RP-150536->RP-151131
- 1314: 03/07/15: Compl:0%->25% 03/07/15: WID: RP-150410->RP-150616 03/07/15: Stat Rep: ->RP-150536 29/09/15: Compl:25%->75% 29/09/15: Stat Rep: RP-150536->RP-151131
- 1315: 03/07/15: Compl:0%->25% 03/07/15: WID: RP-150410->RP-150616 03/07/15: Stat Rep: ->RP-150536 29/09/15: Compl:25%->75% 29/09/15: Stat Rep: RP-150536->RP-151131
- 1317: 03/07/15: Compl:0%->25% 03/07/15: CD:Tue 15/03/16->Tue 15/12/15 03/07/15: Stat Rep: ->RP-150536 29/09/15: Compl:25%->75% 29/09/15: WID: RP-150479->RP-151230 29/09/15: Stat Rep: RP-150536->RP-151131
- 1318: 03/07/15: Compl:0%->25% 03/07/15: Stat Rep: ->RP-150536 29/09/15: Compl:25%->75% 29/09/15: CD:Tue 15/03/16->Tue 15/12/15 29/09/15: WID: RP-150479->RP-151230 29/09/15: Stat Rep: RP-150536->RP-151131
- 1320: 03/07/15: Compl:0%->100% 03/07/15: CD:Tue 15/09/15->Mon 15/06/15 03/07/15: Stat Rep: ->RP-150536
- 1321: 03/07/15: Compl:0%->100% 03/07/15: CD:Tue 15/09/15->Mon 15/06/15 03/07/15: Stat Rep: ->RP-150536
- 1323: 03/07/15: Compl:0%->60% 03/07/15: WID: RP-150437->RP-150809 03/07/15: Stat Rep: ->RP-150536 29/09/15: Compl:60%->90% 29/09/15: CD:Tue 15/09/15->Tue 15/12/15 29/09/15: WID: RP-150809->RP-151177 29/09/15: Stat Rep: RP-150536->RP-151131
- 1324: 03/07/15: WID: RP-150437->RP-150809 03/07/15: Stat Rep: ->RP-150536 29/09/15: Compl:0%->50% 29/09/15: CD:Tue 15/09/15->Tue 15/12/15 29/09/15: WID: RP-150809->RP-151177 29/09/15: Stat Rep: RP-150536->RP-151131;

| ID | WBS | Task | Duration | Start | Finish | Complete | Remaining | Total slack | Constraint | Resources | Work | Actual work | Acronym | PCG approved | WI rapporteur name | Release | TSG approved | Status Report |
| --- | --- | --- | --- | --- | --- | --- | --- | --- | --- | --- | --- | --- | --- | --- | --- | --- | --- | --- |
| 1325 | 362.78 | **LTE Advanced intra-band contiguous Carrier Aggregation in Band 42 for 4DL** | 197d? | 2015-03-16 A | 2015-12-15 A | 100% |  |  |  | R4 | 4728h | 4728h | LTE_CA_C_B42_4DL | PCG-34 | CATT | Rel-13 | RP-67 |  |
| 1326 | 362.78.1 | Core part: LTE Advanced intra-band contiguous Carrier Aggregation in Band 42 for 4DL | 197d? | 2015-03-16 A | 2015-12-15 A | 100% |  |  | finish no earlier than 2015-12-15 | R4 | 1576h | 1576h | LTE_CA_C_B42_4DL-Core | PCG-34 | CATT | Rel-13 | RP-67 | RP-151131 |
| 1327 | 362.78.2 | Perf. part: LTE Advanced intra-band contiguous Carrier Aggregation in Band 42 for 4DL | 197d? | 2015-03-16 A | 2015-12-15 A | 100% |  |  | finish no earlier than 2015-12-15 | R4 | 1576h | 1576h | LTE_CA_C_B42_4DL-Perf | PCG-34 | CATT | Rel-13 | RP-67 | RP-151131 |
| 1328 | 362.79 | **LTE Advanced 3 Band Carrier Aggregation (3DL/1UL) of Band 1, Band 8 and Band 11** | 67d? | 2015-06-15 A | 2015-09-15 A | 100% |  |  |  | R4 | 1608h | 1608h | LTE_CA_B1_B8_B11 | PCG-35 | Softbank Mobile | Rel-13 | TSG-68 |  |
| 1329 | 362.79.1 | Core part: LTE Advanced 3 Band Carrier Aggregation (3DL/1UL) of Band 1, Band 8 and Band 11 | 67d? | 2015-06-15 A | 2015-09-15 A | 100% |  |  | finish no earlier than 2015-09-15 | R4 | 536h | 536h | LTE_CA_B1_B8_B11-Core | PCG-35 | Softbank Mobile | Rel-13 | TSG-68 | RP-151131 |
| 1330 | 362.79.2 | Perf. part: LTE Advanced 3 Band Carrier Aggregation (3DL/1UL) of Band 1, Band 8 and Band 11 | 67d? | 2015-06-15 A | 2015-09-15 A | 100% |  |  | finish no earlier than 2015-09-15 | R4 | 536h | 536h | LTE_CA_B1_B8_B11-Perf | PCG-35 | Softbank Mobile | Rel-13 | TSG-68 | RP-151131 |
| 1331 | 362.80 | **LTE Advanced 3 Band Carrier Aggregation (3DL/1UL) of Band 3, Band 20 and Band 32** | 197d? | 2015-06-15 A | 2016-03-15 | 90% | 19.69d? | 723d |  | R4 | 4728h | 3364.8h | LTE_CA_B3_B20_B32 | PCG-35 | Ericsson | Rel-13 | TSG-68 |  |
| 1332 | 362.80.1 | Core part: LTE Advanced 3 Band Carrier Aggregation (3DL/1UL) of Band 3, Band 20 and Band 32 | 197d? | 2015-06-15 A | 2016-03-15 | 90% | 19.7d? | 723d | finish no earlier than 2016-03-15 | R4 | 1576h | 1418.4h | LTE_CA_B3_B20_B32-Core | PCG-35 | Ericsson | Rel-14 | TSG-68 | RP-151131 |
| 1333 | 362.80.2 | Perf. part: LTE Advanced 3 Band Carrier Aggregation (3DL/1UL) of Band 3, Band 20 and Band 32 | 197d? | 2015-06-15 A | 2016-03-15 | 90% | 19.7d? | 723d | finish no earlier than 2016-03-15 | R4 | 1576h | 1418.4h | LTE_CA_B3_B20_B32-Perf | PCG-35 | Ericsson | Rel-14 | TSG-68 | RP-151131 |
| 1334 | 362.81 | **LTE Advanced 3 Band Carrier Aggregation (3DL/1UL) for Band 7, Band 42 and Band 42** | 132d? | 2015-06-15 A | 2015-12-15 A | 100% |  |  |  | R4 | 3168h | 3168h | LTE_CA_B7_B42_B42 | PCG-35 | Huawei | Rel-13 | TSG-68 |  |
| 1335 | 362.81.1 | Core part: LTE Advanced 3 Band Carrier Aggregation (3DL/1UL) for Band 7, Band 42 and Band 42 | 132d? | 2015-06-15 A | 2015-12-15 A | 100% |  |  | finish no earlier than 2015-12-15 | R4 | 1056h | 1056h | LTE_CA_B7_B42_B42-Core | PCG-35 | Huawei | Rel-13 | TSG-68 | RP-151131 |
| 1336 | 362.81.2 | Perf. part: LTE Advanced 3 Band Carrier Aggregation (3DL/1UL) for Band 7, Band 42 and Band 42 | 132d? | 2015-06-15 A | 2015-12-15 A | 100% |  |  | finish no earlier than 2015-12-15 | R4 | 1056h | 1056h | LTE_CA_B7_B42_B42-Perf | PCG-35 | Huawei | Rel-13 | TSG-68 | RP-151131 |
| 1337 | 362.82 | **LTE Advanced 3 Band Carrier Aggregation (3DL/1UL) for Band 20, Band 42 and Band 42** | 67d? | 2015-06-15 A | 2015-09-15 A | 100% |  |  |  | R4 | 1608h | 1608h | LTE_CA_B20_B42_B42 | PCG-35 | Huawei | Rel-13 | TSG-68 |  |
| 1338 | 362.82.1 | Core part: LTE Advanced 3 Band Carrier Aggregation (3DL/1UL) for Band 20, Band 42 and Band 42 | 67d? | 2015-06-15 A | 2015-09-15 A | 100% |  |  | finish no earlier than 2015-12-15 | R4 | 536h | 536h | LTE_CA_B20_B42_B42-Core | PCG-35 | Huawei | Rel-13 | TSG-68 | RP-151131 |
| 1339 | 362.82.2 | Perf. part: LTE Advanced 3 Band Carrier Aggregation (3DL/1UL) for Band 20, Band 42 and Band 42 | 67d? | 2015-06-15 A | 2015-09-15 A | 100% |  |  | finish no earlier than 2015-12-15 | R4 | 536h | 536h | LTE_CA_B20_B42_B42-Perf | PCG-35 | Huawei | Rel-13 | TSG-68 | RP-151131 |
| 1340 | 362.83 | **LTE Advanced 3 Band Carrier Aggregation (3DL/1UL) for Band 3, Band 7 and Band 38** | 132d? | 2015-06-15 A | 2015-12-15 A | 100% |  |  |  | R4 | 3168h | 3168h | LTE_CA_B3_B7_B38 | PCG-35 | Nokia Networks | Rel-13 | TSG-68 |  |
| 1341 | 362.83.1 | Core part: LTE Advanced 3 Band Carrier Aggregation (3DL/1UL) for Band 3, Band 7 and Band 38 | 132d? | 2015-06-15 A | 2015-12-15 A | 100% |  |  | finish no earlier than 2015-12-15 | R4 | 1056h | 1056h | LTE_CA_B3_B7_B38-Core | PCG-35 | Nokia Networks | Rel-13 | TSG-68 | RP-151131 |
| 1342 | 362.83.2 | Perf. part: LTE Advanced 3 Band Carrier Aggregation (3DL/1UL) for Band 3, Band 7 and Band 38 | 132d? | 2015-06-15 A | 2015-12-15 A | 100% |  |  | finish no earlier than 2015-12-15 | R4 | 1056h | 1056h | LTE_CA_B3_B7_B38-Perf | PCG-35 | Nokia Networks | Rel-13 | TSG-68 | RP-151131 |
| 1343 | 362.84 | **LTE Advanced 3 Band Carrier Aggregation (3DL/1UL) of Band 28, Band 41 and Band 41** | 132d? | 2015-06-15 A | 2015-12-15 A | 100% |  |  |  | R4 | 3168h | 3168h | LTE_CA_B28_B41_B41 | PCG-35 | KDDI | Rel-13 | TSG-68 |  |
| 1344 | 362.84.1 | Core part: LTE Advanced 3 Band Carrier Aggregation (3DL/1UL) of Band 28, Band 41 and Band 41 | 132d? | 2015-06-15 A | 2015-12-15 A | 100% |  |  | finish no earlier than 2015-12-15 | R4 | 1056h | 1056h | LTE_CA_B28_B41_B41-Core | PCG-35 | KDDI | Rel-13 | TSG-68 | RP-151131 |
| 1345 | 362.84.2 | Perf. part: LTE Advanced 3 Band Carrier Aggregation (3DL/1UL) of Band 28, Band 41 and Band 41 | 132d? | 2015-06-15 A | 2015-12-15 A | 100% |  |  | finish no earlier than 2015-12-15 | R4 | 1056h | 1056h | LTE_CA_B28_B41_B41-Perf | PCG-35 | KDDI | Rel-13 | TSG-68 | RP-151131 |
| 1346 | 362.85 | **LTE Advanced 3 Band Carrier Aggregation (3DL/1UL) of Band 28, Band 42 and Band 42** | 132d? | 2015-06-15 A | 2015-12-15 A | 100% |  |  |  | R4 | 3168h | 3168h | LTE_CA_B28_B42_B42 | PCG-35 | KDDI | Rel-13 | TSG-68 |  |
| 1347 | 362.85.1 | Core part: LTE Advanced 3 Band Carrier Aggregation (3DL/1UL) of Band 28, Band 42 and Band 42 | 132d? | 2015-06-15 A | 2015-12-15 A | 100% |  |  | finish no earlier than 2015-12-15 | R4 | 1056h | 1056h | LTE_CA_B28_B42_B42-Core | PCG-35 | KDDI | Rel-13 | TSG-68 | RP-151131 |
| 1348 | 362.85.2 | Perf. part: LTE Advanced 3 Band Carrier Aggregation (3DL/1UL) of Band 28, Band 42 and Band 42 | 132d? | 2015-06-15 A | 2015-12-15 A | 100% |  |  | finish no earlier than 2015-12-15 | R4 | 1056h | 1056h | LTE_CA_B28_B42_B42-Perf | PCG-35 | KDDI | Rel-13 | TSG-68 | RP-151131 |

Notes:
- 1326: 03/07/15: Compl:0%->50% 03/07/15: Stat Rep: ->RP-150536 29/09/15: Compl:50%->80% 29/09/15: Stat Rep: RP-150536->RP-151131
- 1327: 03/07/15: Compl:0%->50% 03/07/15: Stat Rep: ->RP-150536 29/09/15: Compl:50%->80% 29/09/15: Stat Rep: RP-150536->RP-151131
- 1329: 29/09/15: Compl:0%->100% 29/09/15: Stat Rep: -->RP-151131
- 1330: 29/09/15: Compl:0%->100% 29/09/15: Stat Rep: -->RP-151131
- 1332: 29/09/15: Compl:0%->50% 29/09/15: Stat Rep: -->RP-1511311/22/3/16: Compl:50%->90%
- 1333: 29/09/15: Compl:0%->50% 29/09/15: Stat Rep: -->RP-151131 ; 22/3/16: Compl:50%->90%
- 1335: 29/09/15: Compl:0%->70% 29/09/15: Stat Rep: -->RP-151131
- 1336: 29/09/15: Compl:0%->70% 29/09/15: Stat Rep: -->RP-151131
- 1338: 29/09/15: Compl:0%->100% 29/09/15: CD:Tue 15/12/15->Tue 15/09/15 29/09/15: Stat Rep: -->RP-151131
- 1339: 29/09/15: Compl:0%->100% 29/09/15: CD:Tue 15/12/15->Tue 15/09/15 29/09/15: Stat Rep: -->RP-151131
- 1341: 29/09/15: Compl:0%->60% 29/09/15: Stat Rep: -->RP-1511311/1/16: Compl:
- 1342: 29/09/15: Compl:0%->60% 29/09/15: Stat Rep: -->RP-151131; 1/1/16: Comp
- 1344: 29/09/15: Compl:0%->50% 29/09/15: Stat Rep: -->RP-151131
- 1345: 29/09/15: Stat Rep: -->RP-151131
- 1347: 29/09/15: Compl:0%->40% 29/09/15: WID: RP-151112->RP-151158 29/09/15: Stat Rep: -->RP-151131
- 1348: 29/09/15: WID: RP-151112->RP-151158 29/09/15: Stat Rep: -->RP-151131;

| ID | WBS | Task | Duration | Start | Finish | Complete | Constraint | Resources | Work | Actual work | Acronym | PCG approved | WI rapporteur name | Release | TSG approved | Status Report |
| --- | --- | --- | --- | --- | --- | --- | --- | --- | --- | --- | --- | --- | --- | --- | --- | --- |
| 1349 | 362.86 | **LTE Advanced 4 Band Carrier Aggregation (4DL/1UL) of Band 2, Band 4, Band 7 and Band 12** | 197d? | 2015-06-15 A | 2016-03-15 A | 100% |  | R4 | 4728h | 4728h | LTE_CA_B2_B4_B7_B12 | PCG-35 | Rogers Communications | Rel-13 | TSG-68 |  |
| 1350 | 362.86.1 | Core part: LTE Advanced 4 Band Carrier Aggregation (4DL/1UL) of Band 2, Band 4, Band 7 and Band 12 | 197d? | 2015-06-15 A | 2016-03-15 A | 100% | finish no earlier than 2016-03-15 | R4 | 1576h | 1576h | LTE_CA_B2_B4_B7_B12-Core | PCG-35 | Rogers Communications | Rel-13 | TSG-68 | RP-151131 |
| 1351 | 362.86.2 | Perf. part: LTE Advanced 4 Band Carrier Aggregation (4DL/1UL) of Band 2, Band 4, Band 7 and Band 12 | 197d? | 2015-06-15 A | 2016-03-15 A | 100% | finish no earlier than 2016-03-15 | R4 | 1576h | 1576h | LTE_CA_B2_B4_B7_B12-Perf | PCG-35 | Rogers Communications | Rel-13 | TSG-68 | RP-151131 |
| 1352 | 362.87 | **LTE Advanced 4 Band Carrier Aggregation (4DL/1UL) of Band 1, Band 3, Band 19 and Band 42** | 132d? | 2015-06-15 A | 2015-12-15 A | 100% |  | R4 | 3168h | 3168h | LTE_CA_B1_B3_B19_B42 | PCG-35 | NTT DOCOMO, INC. | Rel-13 | TSG-68 |  |
| 1353 | 362.87.1 | Core part: LTE Advanced 4 Band Carrier Aggregation (4DL/1UL) of Band 1, Band 3, Band 19 and Band 42 | 132d? | 2015-06-15 A | 2015-12-15 A | 100% | finish no earlier than 2015-12-15 | R4 | 1056h | 1056h | LTE_CA_B1_B3_B19_B42-Core | PCG-35 | NTT DOCOMO, INC. | Rel-13 | TSG-68 | RP-151131 |
| 1354 | 362.87.2 | Perf. part: LTE Advanced 4 Band Carrier Aggregation (4DL/1UL) of Band 1, Band 3, Band 19 and Band 42 | 132d? | 2015-06-15 A | 2015-12-15 A | 100% | finish no earlier than 2015-12-15 | R4 | 1056h | 1056h | LTE_CA_B1_B3_B19_B42-Perf | PCG-35 | NTT DOCOMO, INC. | Rel-13 | TSG-68 | RP-151131 |
| 1355 | 362.88 | **LTE Advanced 4 Band Carrier Aggregation (4DL/1UL) of Band 1, Band 3, Band 42 and Band 42** | 132d? | 2015-06-15 A | 2015-12-15 A | 100% |  | R4 | 3168h | 3168h | LTE_CA_B1_B3_B42_B42 | PCG-35 | NTT DOCOMO, INC. | Rel-13 | TSG-68 |  |
| 1356 | 362.88.1 | Core part: LTE Advanced 4 Band Carrier Aggregation (4DL/1UL) of Band 1, Band 3, Band 42 and Band 42 | 132d? | 2015-06-15 A | 2015-12-15 A | 100% | finish no earlier than 2015-12-15 | R4 | 1056h | 1056h | LTE_CA_B1_B3_B42_B42-Core | PCG-35 | NTT DOCOMO, INC. | Rel-13 | TSG-68 | RP-151131 |
| 1357 | 362.88.2 | Perf. part: LTE Advanced 4 Band Carrier Aggregation (4DL/1UL) of Band 1, Band 3, Band 42 and Band 42 | 132d? | 2015-06-15 A | 2015-12-15 A | 100% | finish no earlier than 2015-12-15 | R4 | 1056h | 1056h | LTE_CA_B1_B3_B42_B42-Perf | PCG-35 | NTT DOCOMO, INC. | Rel-13 | TSG-68 | RP-151131 |
| 1358 | 362.89 | **LTE Advanced 4 Band Carrier Aggregation (4DL/1UL) of Band 1, Band 19, Band 42 and Band 42** | 132d? | 2015-06-15 A | 2015-12-15 A | 100% |  | R4 | 3168h | 3168h | LTE_CA_B1_B19_B42_B42 | PCG-35 | NTT DOCOMO, INC. | Rel-13 | TSG-68 |  |
| 1359 | 362.89.1 | Core part: LTE Advanced 4 Band Carrier Aggregation (4DL/1UL) of Band 1, Band 19, Band 42 and Band 42 | 132d? | 2015-06-15 A | 2015-12-15 A | 100% | finish no earlier than 2015-12-15 | R4 | 1056h | 1056h | LTE_CA_B1_B19_B42_B42-Core | PCG-35 | NTT DOCOMO, INC. | Rel-13 | TSG-68 | RP-151131 |
| 1360 | 362.89.2 | Perf. part: LTE Advanced 4 Band Carrier Aggregation (4DL/1UL) of Band 1, Band 19, Band 42 and Band 42 | 132d? | 2015-06-15 A | 2015-12-15 A | 100% | finish no earlier than 2015-12-15 | R4 | 1056h | 1056h | LTE_CA_B1_B19_B42_B42-Perf | PCG-35 | NTT DOCOMO, INC. | Rel-13 | TSG-68 | RP-151131 |
| 1361 | 362.90 | **LTE Advanced 4 Band Carrier Aggregation (4DL/1UL) of Band 3, Band 19, Band 42 and Band 42** | 132d? | 2015-06-15 A | 2015-12-15 A | 100% |  | R4 | 3168h | 3168h | LTE_CA_B3_B19_B42_B42 | PCG-35 | NTT DOCOMO, INC. | Rel-13 | TSG-68 |  |
| 1362 | 362.90.1 | Core part: LTE Advanced 4 Band Carrier Aggregation (4DL/1UL) of Band 3, Band 19, Band 42 and Band 42 | 132d? | 2015-06-15 A | 2015-12-15 A | 100% | finish no earlier than 2015-12-15 | R4 | 1056h | 1056h | LTE_CA_B3_B19_B42_B42-Core | PCG-35 | NTT DOCOMO, INC. | Rel-13 | TSG-68 | RP-151131 |
| 1363 | 362.90.2 | Perf. part: LTE Advanced 4 Band Carrier Aggregation (4DL/1UL) of Band 3, Band 19, Band 42 and Band 42 | 132d? | 2015-06-15 A | 2015-12-15 A | 100% | finish no earlier than 2015-12-15 | R4 | 1056h | 1056h | LTE_CA_B3_B19_B42_B42-Perf | PCG-35 | NTT DOCOMO, INC. | Rel-13 | TSG-68 | RP-151131 |
| 1364 | 362.91 | **LTE Advanced 4 Band Carrier Aggregation (4DL/1UL) of Band 1, Band 19, Band 21 and Band 42** | 132d? | 2015-06-15 A | 2015-12-15 A | 100% |  | R4 | 3168h | 3168h | LTE_CA_B1_B19_B21_B42 | PCG-35 | NTT DOCOMO, INC. | Rel-13 | TSG-68 |  |
| 1365 | 362.91.1 | Core part: LTE Advanced 4 Band Carrier Aggregation (4DL/1UL) of Band 1, Band 19, Band 21 and Band 42 | 132d? | 2015-06-15 A | 2015-12-15 A | 100% | finish no earlier than 2015-12-15 | R4 | 1056h | 1056h | LTE_CA_B1_B19_B21_B42-Core | PCG-35 | NTT DOCOMO, INC. | Rel-13 | TSG-68 | RP-151131 |
| 1366 | 362.91.2 | Perf. part: LTE Advanced 4 Band Carrier Aggregation (4DL/1UL) of Band 1, Band 19, Band 21 and Band 42 | 132d? | 2015-06-15 A | 2015-12-15 A | 100% | finish no earlier than 2015-12-15 | R4 | 1056h | 1056h | LTE_CA_B1_B19_B21_B42-Perf | PCG-35 | NTT DOCOMO, INC. | Rel-13 | TSG-68 | RP-151131 |
| 1367 | 362.92 | **LTE Advanced 4 Band Carrier Aggregation (4DL/1UL) of Band 1, Band 21, Band 42 and Band 42** | 132d? | 2015-06-15 A | 2015-12-15 A | 100% |  | R4 | 3168h | 3168h | LTE_CA_B1_B21_B42_B42 | PCG-35 | NTT DOCOMO, INC. | Rel-13 | TSG-68 |  |
| 1368 | 362.92.1 | Core part: LTE Advanced 4 Band Carrier Aggregation (4DL/1UL) of Band 1, Band 21, Band 42 and Band 42 | 132d? | 2015-06-15 A | 2015-12-15 A | 100% | finish no earlier than 2015-12-15 | R4 | 1056h | 1056h | LTE_CA_B1_B21_B42_B42-Core | PCG-35 | NTT DOCOMO, INC. | Rel-13 | TSG-68 | RP-151131 |
| 1369 | 362.92.2 | Perf. part: LTE Advanced 4 Band Carrier Aggregation (4DL/1UL) of Band 1, Band 21, Band 42 and Band 42 | 132d? | 2015-06-15 A | 2015-12-15 A | 100% | finish no earlier than 2015-12-15 | R4 | 1056h | 1056h | LTE_CA_B1_B21_B42_B42-Perf | PCG-35 | NTT DOCOMO, INC. | Rel-13 | TSG-68 | RP-151131 |
| 1370 | 362.93 | **LTE Advanced 4 Band Carrier Aggregation (4DL/1UL) of Band 19, Band 21, Band 42 and Band 42** | 132d? | 2015-06-15 A | 2015-12-15 A | 100% |  | R4 | 3168h | 3168h | LTE_CA_B19_B21_B42_B42 | PCG-35 | NTT DOCOMO, INC. | Rel-13 | TSG-68 |  |
| 1371 | 362.93.1 | Core part: LTE Advanced 4 Band Carrier Aggregation (4DL/1UL) of Band 19, Band 21, Band 42 and Band 42 | 132d? | 2015-06-15 A | 2015-12-15 A | 100% | finish no earlier than 2015-12-15 | R4 | 1056h | 1056h | LTE_CA_B19_B21_B42_B42-Core | PCG-35 | NTT DOCOMO, INC. | Rel-13 | TSG-68 | RP-151131 |
| 1372 | 362.93.2 | Perf. part: LTE Advanced 4 Band Carrier Aggregation (4DL/1UL) of Band 19, Band 21, Band 42 and Band 42 | 132d? | 2015-06-15 A | 2015-12-15 A | 100% | finish no earlier than 2015-12-15 | R4 | 1056h | 1056h | LTE_CA_B19_B21_B42_B42-Perf | PCG-35 | NTT DOCOMO, INC. | Rel-13 | TSG-68 | RP-151131 |

Notes:
- 1350: 29/09/15: Stat Rep: -->RP-151131 22/3/16: Compl:0%->100%
- 1351: 29/09/15: Stat Rep: -->RP-151131 ; 22/3/16: Compl:0%->100%
- 1353: 29/09/15: Compl:0%->95% 29/09/15: CD:Tue 15/09/15->Tue 15/12/15 29/09/15: Stat Rep: -->RP-151131
- 1354: 29/09/15: Compl:0%->95% 29/09/15: CD:Tue 15/09/15->Tue 15/12/15 29/09/15: Stat Rep: -->RP-151131
- 1356: 29/09/15: Compl:0%->95% 29/09/15: CD:Tue 15/09/15->Tue 15/12/15 29/09/15: Stat Rep: -->RP-151131
- 1357: 29/09/15: Compl:0%->95% 29/09/15: CD:Tue 15/09/15->Tue 15/12/15 29/09/15: Stat Rep: -->RP-151131
- 1359: 29/09/15: Compl:0%->95% 29/09/15: CD:Tue 15/09/15->Tue 15/12/15 29/09/15: Stat Rep: -->RP-151131
- 1360: 29/09/15: Compl:0%->95% 29/09/15: CD:Tue 15/09/15->Tue 15/12/15 29/09/15: Stat Rep: -->RP-151131
- 1362: 29/09/15: Compl:0%->95% 29/09/15: CD:Tue 15/09/15->Tue 15/12/15 29/09/15: Stat Rep: -->RP-151131
- 1363: 29/09/15: Compl:0%->95% 29/09/15: CD:Tue 15/09/15->Tue 15/12/15 29/09/15: Stat Rep: -->RP-151131
- 1365: 29/09/15: Compl:0%->95% 29/09/15: CD:Tue 15/09/15->Tue 15/12/15 29/09/15: Stat Rep: -->RP-151131
- 1366: 29/09/15: Compl:0%->95% 29/09/15: CD:Tue 15/09/15->Tue 15/12/15 29/09/15: Stat Rep: -->RP-151131
- 1368: 29/09/15: Compl:0%->95% 29/09/15: CD:Tue 15/09/15->Tue 15/12/15 29/09/15: Stat Rep: -->RP-151131
- 1369: 29/09/15: Compl:0%->95% 29/09/15: CD:Tue 15/09/15->Tue 15/12/15 29/09/15: Stat Rep: -->RP-151131
- 1371: 29/09/15: Compl:0%->95% 29/09/15: CD:Tue 15/09/15->Tue 15/12/15 29/09/15: Stat Rep: -->RP-151131
- 1372: 29/09/15: Compl:0%->95% 29/09/15: CD:Tue 15/09/15->Tue 15/12/15 29/09/15: Stat Rep: -->RP-151131

| ID | WBS | Task | Duration | Start | Finish | Complete | Constraint | Resources | Work | Actual work | Acronym | PCG approved | WI rapporteur name | Release | TSG approved | Status Report |
| --- | --- | --- | --- | --- | --- | --- | --- | --- | --- | --- | --- | --- | --- | --- | --- | --- |
| 1373 | 362.94 | **LTE Advanced 4 Band Carrier Aggregation (4DL/1UL) of Band 2, Band 4, Band 5 and Band 12** | 132d? | 2015-06-15 A | 2015-12-15 A | 100% |  | R4 | 3168h | 3168h | LTE_CA_B2_B4_B5_B12 | PCG-35 | U.S. Cellular | Rel-13 | TSG-68 |  |
| 1374 | 362.94.1 | Core part: LTE Advanced 4 Band Carrier Aggregation (4DL/1UL) of Band 2, Band 4, Band 5 and Band 12 | 132d? | 2015-06-15 A | 2015-12-15 A | 100% | finish no earlier than 2015-12-15 | R4 | 1056h | 1056h | LTE_CA_B2_B4_B5_B12-Core | PCG-35 | U.S. Cellular | Rel-13 | TSG-68 | RP-151131 |
| 1375 | 362.94.2 | Perf. part: LTE Advanced 4 Band Carrier Aggregation (4DL/1UL) of Band 2, Band 4, Band 5 and Band 12 | 132d? | 2015-06-15 A | 2015-12-15 A | 100% | finish no earlier than 2015-12-15 | R4 | 1056h | 1056h | LTE_CA_B2_B4_B5_B12-Perf | PCG-35 | U.S. Cellular | Rel-13 | TSG-68 | RP-151131 |
| 1376 | 362.95 | **LTE Advanced 4 Band Carrier Aggregation (4DL/1UL) of Band 2, Band 2, Band 4 and Band 5** | 132d? | 2015-06-15 A | 2015-12-15 A | 100% |  | R4 | 3168h | 3168h | LTE_CA_B2_B2_B4_B5 | PCG-35 | U.S. Cellular | Rel-13 | TSG-68 |  |
| 1377 | 362.95.1 | Core part: LTE Advanced 4 Band Carrier Aggregation (4DL/1UL) of Band 2, Band 2, Band 4 and Band 5 | 132d? | 2015-06-15 A | 2015-12-15 A | 100% | finish no earlier than 2015-12-15 | R4 | 1056h | 1056h | LTE_CA_B2_B2_B4_B5-Core | PCG-35 | U.S. Cellular | Rel-13 | TSG-68 | RP-151131 |
| 1378 | 362.95.2 | Perf. part: LTE Advanced 4 Band Carrier Aggregation (4DL/1UL) of Band 2, Band 2, Band 4 and Band 5 | 132d? | 2015-06-15 A | 2015-12-15 A | 100% | finish no earlier than 2015-12-15 | R4 | 1056h | 1056h | LTE_CA_B2_B2_B4_B5-Perf | PCG-35 | U.S. Cellular | Rel-13 | TSG-68 | RP-151131 |
| 1379 | 362.96 | **LTE Advanced 4-Band Carrier Aggregation (4DL/1UL) of Band 2, Band 2, Band 12 and Band 12** | 132d? | 2015-06-15 A | 2015-12-15 A | 100% |  | R4 | 3168h | 3168h | LTE_CA_B2_B2_B12_B12 | PCG-35 | U.S. Cellular | Rel-13 | TSG-68 |  |
| 1380 | 362.96.1 | Core part: LTE Advanced 4-Band Carrier Aggregation (4DL/1UL) of Band 2, Band 2, Band 12 and Band 12 | 132d? | 2015-06-15 A | 2015-12-15 A | 100% | finish no earlier than 2015-12-15 | R4 | 1056h | 1056h | LTE_CA_B2_B2_B12_B12-Core | PCG-35 | U.S. Cellular | Rel-13 | TSG-68 | RP-151131 |
| 1381 | 362.96.2 | Perf. part: LTE Advanced 4-Band Carrier Aggregation (4DL/1UL) of Band 2, Band 2, Band 12 and Band 12 | 132d? | 2015-06-15 A | 2015-12-15 A | 100% | finish no earlier than 2015-12-15 | R4 | 1056h | 1056h | LTE_CA_B2_B2_B12_B12-Perf | PCG-35 | U.S. Cellular | Rel-13 | TSG-68 | RP-151131 |
| 1382 | 362.97 | **LTE Advanced 4 Band Carrier Aggregation (4DL/1UL) of Band 4, Band 4, Band 5 and Band 30** | 197d? | 2015-06-15 A | 2016-03-15 A | 100% |  | R4 | 4728h | 4728h | LTE_CA_B4_B4_B5_B30 | PCG-35 | AT&T | Rel-13 | TSG-68 |  |
| 1383 | 362.97.1 | Core part: LTE Advanced 4 Band Carrier Aggregation (4DL/1UL) of Band 4, Band 4, Band 5 and Band 30 | 197d? | 2015-06-15 A | 2016-03-15 A | 100% | finish no earlier than 2016-03-15 | R4 | 1576h | 1576h | LTE_CA_B4_B4_B5_B30-Core | PCG-35 | AT&T | Rel-13 | TSG-68 | RP-151131 |
| 1384 | 362.97.2 | Perf. part: LTE Advanced 4 Band Carrier Aggregation (4DL/1UL) of Band 4, Band 4, Band 5 and Band 30 | 197d? | 2015-06-15 A | 2016-03-15 A | 100% | finish no earlier than 2016-03-15 | R4 | 1576h | 1576h | LTE_CA_B4_B4_B5_B30-Perf | PCG-35 | AT&T | Rel-13 | TSG-68 | RP-151131 |
| 1385 | 362.98 | **LTE Advanced 4 Band Carrier Aggregation (4DL/1UL) of Band 4, Band 4, Band 12 and Band 30** | 197d? | 2015-06-15 A | 2016-03-15 A | 100% |  | R4 | 4728h | 4728h | LTE_CA_B4_B4_B12_B30 | PCG-35 | AT&T | Rel-13 | TSG-68 |  |
| 1386 | 362.98.1 | Core part: LTE Advanced 4 Band Carrier Aggregation (4DL/1UL) of Band 4, Band 4, Band 12 and Band 30 | 197d? | 2015-06-15 A | 2016-03-15 A | 100% | finish no earlier than 2016-03-15 | R4 | 1576h | 1576h | LTE_CA_B4_B4_B12_B30-Core | PCG-35 | AT&T | Rel-13 | TSG-68 | RP-151131 |
| 1387 | 362.98.2 | Perf. part: LTE Advanced 4 Band Carrier Aggregation (4DL/1UL) of Band 4, Band 4, Band 12 and Band 30 | 197d? | 2015-06-15 A | 2016-03-15 A | 100% | finish no earlier than 2016-03-15 | R4 | 1576h | 1576h | LTE_CA_B4_B4_B12_B30-Perf | PCG-35 | AT&T | Rel-13 | TSG-68 | RP-151131 |
| 1388 | 362.99 | **LTE Advanced 4 Band Carrier Aggregation (4DL/1UL) of Band 4, Band 4, Band 29 and Band 30** | 197d? | 2015-06-15 A | 2016-03-15 A | 100% |  | R4 | 4728h | 4728h | LTE_CA_B4_B4_B29_B30 | PCG-35 | AT&T | Rel-13 | TSG-68 |  |
| 1389 | 362.99.1 | Core part: LTE Advanced 4 Band Carrier Aggregation (4DL/1UL) of Band 4, Band 4, Band 29 and Band 30 | 197d? | 2015-06-15 A | 2016-03-15 A | 100% | finish no earlier than 2016-03-15 | R4 | 1576h | 1576h | LTE_CA_B4_B4_B29_B30-Core | PCG-35 | AT&T | Rel-13 | TSG-68 | RP-151131 |
| 1390 | 362.99.2 | Perf. part: LTE Advanced 4 Band Carrier Aggregation (4DL/1UL) of Band 4, Band 4, Band 29 and Band 30 | 197d? | 2015-06-15 A | 2016-03-15 A | 100% | finish no earlier than 2016-03-15 | R4 | 1576h | 1576h | LTE_CA_B4_B4_B29_B30-Perf | PCG-35 | AT&T | Rel-13 | TSG-68 | RP-151131 |
| 1391 | 362.100 | **LTE Advanced 4 Band Carrier Aggregation (4DL/1UL) of Band 2, Band 2, Band 5 and Band 12** | 132d? | 2015-06-15 A | 2015-12-15 A | 100% |  | R4 | 3168h | 3168h | LTE_CA_B2_B2_B5_B12 | PCG-35 | U.S. Cellular | Rel-13 | TSG-68 |  |
| 1392 | 362.100.1 | Core part: LTE Advanced 4 Band Carrier Aggregation (4DL/1UL) of Band 2, Band 2, Band 5 and Band 12 | 132d? | 2015-06-15 A | 2015-12-15 A | 100% | finish no earlier than 2015-12-15 | R4 | 1056h | 1056h | LTE_CA_B2_B2_B5_B12-Core | PCG-35 | U.S. Cellular | Rel-13 | TSG-68 | RP-151131 |
| 1393 | 362.100.2 | Perf. part: LTE Advanced 4 Band Carrier Aggregation (4DL/1UL) of Band 2, Band 2, Band 5 and Band 12 | 132d? | 2015-06-15 A | 2015-12-15 A | 100% | finish no earlier than 2015-12-15 | R4 | 1056h | 1056h | LTE_CA_B2_B2_B5_B12-Perf | PCG-35 | U.S. Cellular | Rel-13 | TSG-68 | RP-151131 |
| 1394 | 362.101 | **LTE Advanced 4 Band Carrier Aggregation (4DL/1UL) of Band 2, Band 5, Band 12 and Band 12** | 132d? | 2015-06-15 A | 2015-12-15 A | 100% |  | R4 | 3168h | 3168h | LTE_CA_B2_B5_B12_B12 | PCG-35 | U.S. Cellular | Rel-13 | TSG-68 |  |
| 1395 | 362.101.1 | Core part: LTE Advanced 4 Band Carrier Aggregation (4DL/1UL) of Band 2, Band 5, Band 12 and Band 12 | 132d? | 2015-06-15 A | 2015-12-15 A | 100% | finish no earlier than 2015-12-15 | R4 | 1056h | 1056h | LTE_CA_B2_B5_B12_B12-Core | PCG-35 | U.S. Cellular | Rel-13 | TSG-68 | RP-151131 |
| 1396 | 362.101.2 | Perf. part: LTE Advanced 4 Band Carrier Aggregation (4DL/1UL) of Band 2, Band 5, Band 12 and Band 12 | 132d? | 2015-06-15 A | 2015-12-15 A | 100% | finish no earlier than 2015-12-15 | R4 | 1056h | 1056h | LTE_CA_B2_B5_B12_B12-Perf | PCG-35 | U.S. Cellular | Rel-13 | TSG-68 | RP-151131 |

Notes:
- 1374: 29/09/15: Compl:0%->40% 29/09/15: Stat Rep: -->RP-151131
- 1375: 29/09/15: Compl:0%->40% 29/09/15: Stat Rep: -->RP-151131
- 1377: 29/09/15: Compl:0%->40% 29/09/15: Stat Rep: -->RP-151131
- 1378: 29/09/15: Compl:0%->40% 29/09/15: Stat Rep: -->RP-151131
- 1380: 29/09/15: Compl:0%->40% 29/09/15: Stat Rep: -->RP-151131
- 1381: 29/09/15: Compl:0%->40% 29/09/15: Stat Rep: -->RP-151131
- 1383: 29/09/15: Stat Rep: -->RP-151131 22/3/16: Compl:50%->100%
- 1384: 29/09/15: Stat Rep: -->RP-151131 ; 22/3/16: Compl:50%->100%
- 1386: 29/09/15: Stat Rep: -->RP-151131 22/3/16: Compl:50%->100%
- 1387: 29/09/15: Stat Rep: -->RP-151131 22/3/16: Compl:50%->100%
- 1389: 29/09/15: Stat Rep: -->RP-151131 ; 22/3/16: Compl:50%->100%
- 1390: 29/09/15: Stat Rep: -->RP-151131 22/3/16: Compl:50%->100%
- 1392: 29/09/15: Compl:0%->40% 29/09/15: Stat Rep: -->RP-151131
- 1393: 29/09/15: Compl:0%->40% 29/09/15: Stat Rep: -->RP-151131
- 1395: 29/09/15: Compl:0%->40% 29/09/15: Stat Rep: -->RP-151131
- 1396: 29/09/15: Compl:0%->40% 29/09/15: Stat Rep: -->RP-151131

| ID | WBS | Task | Duration | Start | Finish | Complete | Constraint | Resources | Work | Actual work | Acronym | PCG approved | WI rapporteur name | Release | TSG approved | Status Report | Impacted TSs and TRs |
| --- | --- | --- | --- | --- | --- | --- | --- | --- | --- | --- | --- | --- | --- | --- | --- | --- | --- |
| 1397 | 362.102 | **LTE Advanced 3DL/2UL mixed intra- and inter-band Carrier Aggregation** | 132d? | 2015-06-15 A | 2015-12-15 A | 100% |  | R4 | 3168h | 3168h | LTE_CA_3DL_2UL_inter_intra | PCG-35 | Nokia Networks | Rel-14 | TSG-68 |  |  |
| 1398 | 362.102.1 | Core part: LTE Advanced 3DL/2UL mixed intra- and inter-band Carrier Aggregation | 132d? | 2015-06-15 A | 2015-12-15 A | 100% | finish no earlier than 2015-12-15 | R4 | 1056h | 1056h | LTE_CA_3DL_2UL_inter_intra-Core | PCG-35 | Nokia Networks | Rel-13 | TSG-68 | RP-151131 |  |
| 1399 | 362.102.2 | Perf. part: LTE Advanced 3DL/2UL mixed intra- and inter-band Carrier Aggregation | 132d? | 2015-06-15 A | 2015-12-15 A | 100% | finish no earlier than 2015-12-15 | R4 | 1056h | 1056h | LTE_CA_3DL_2UL_inter_intra-Perf | PCG-35 | Nokia Networks | Rel-13 | TSG-68 | RP-151131 |  |
| 1400 | 362.103 | **LTE Advanced intra-band contiguous Carrier Aggregation in Band 5** | 132d? | 2015-06-15 A | 2015-12-15 A | 100% |  | R4 | 3168h | 3168h | LTE_CA_C_B5 | PCG-35 | Intel | Rel-13 | TSG-68 |  |  |
| 1401 | 362.103.1 | Core part: LTE Advanced intra-band contiguous Carrier Aggregation in Band 5 | 132d? | 2015-06-15 A | 2015-12-15 A | 100% | finish no earlier than 2015-12-15 | R4 | 1056h | 1056h | LTE_CA_C_B5-Core | PCG-35 | Intel | Rel-13 | TSG-68 | RP-151131 |  |
| 1402 | 362.103.2 | Perf. part: LTE Advanced intra-band contiguous Carrier Aggregation in Band 5 | 132d? | 2015-06-15 A | 2015-12-15 A | 100% | finish no earlier than 2015-12-15 | R4 | 1056h | 1056h | LTE_CA_C_B5-Perf | PCG-35 | Intel | Rel-13 | TSG-68 | RP-151131 |  |
| 1403 | 362.104 | **Additional bandwidth combination set for LTE Advanced intra-band non-contiguous Carrier Aggregation in Band 4** | 67d? | 2015-06-15 A | 2015-09-15 A | 100% |  | R4 | 1608h | 1608h | LTE_CA_NC_B4_BWset | PCG-35 | Nokia Networks | Rel-13 | TSG-68 |  |  |
| 1404 | 362.104.1 | Core part: Additional bandwidth combination set for LTE Advanced intra-band non-contiguous Carrier Aggregation in Band 4 | 67d? | 2015-06-15 A | 2015-09-15 A | 100% | finish no earlier than 2015-09-15 | R4 | 536h | 536h | LTE_CA_NC_B4_BWset-Core | PCG-35 | Nokia Networks | Rel-13 | TSG-68 | RP-151131 |  |
| 1405 | 362.104.2 | Perf. part: Additional bandwidth combination set for LTE Advanced intra-band non-contiguous Carrier Aggregation in Band 4 | 67d? | 2015-06-15 A | 2015-09-15 A | 100% | finish no earlier than 2015-09-15 | R4 | 536h | 536h | LTE_CA_NC_B4_BWset-Perf | PCG-35 | Nokia Networks | Rel-13 | TSG-68 | RP-151131 |  |
| 1406 | 362.105 | **LTE Advanced intra-band non-contiguous Carrier Aggregation in Band 5** | 132d? | 2015-06-15 A | 2015-12-15 A | 100% |  | R4 | 3168h | 3168h | LTE_CA_NC_B5 | PCG-35 | Intel | Rel-13 | TSG-68 |  |  |
| 1407 | 362.105.1 | Core part: LTE Advanced intra-band non-contiguous Carrier Aggregation in Band 5 | 132d? | 2015-06-15 A | 2015-12-15 A | 100% | finish no earlier than 2015-12-15 | R4 | 1056h | 1056h | LTE_CA_NC_B5-Core | PCG-35 | Intel | Rel-13 | TSG-68 | RP-151131 |  |
| 1408 | 362.105.2 | Perf. part: LTE Advanced intra-band non-contiguous Carrier Aggregation in Band 5 | 132d? | 2015-06-15 A | 2015-12-15 A | 100% | finish no earlier than 2015-12-15 | R4 | 1056h | 1056h | LTE_CA_NC_B5-Perf | PCG-35 | Intel | Rel-13 | TSG-68 | RP-151131 |  |
| 1409 | 362.106 | **LTE Advanced intra-band non-contiguous Carrier Aggregation in Band 42 for 4DL** | 132d? | 2015-06-15 A | 2015-12-15 A | 100% |  | R4 | 3168h | 3168h | LTE_CA_NC_B42_4DL | PCG-35 | Huawei | Rel-13 | TSG-68 |  |  |
| 1410 | 362.106.1 | Core part: LTE Advanced intra-band non-contiguous Carrier Aggregation in Band 42 for 4DL | 132d? | 2015-06-15 A | 2015-12-15 A | 100% | finish no earlier than 2015-12-15 | R4 | 1056h | 1056h | LTE_CA_NC_B42_4DL-Core | PCG-35 | Huawei | Rel-13 | TSG-68 | RP-151131 |  |
| 1411 | 362.106.2 | Perf. part: LTE Advanced intra-band non-contiguous Carrier Aggregation in Band 42 for 4DL | 132d? | 2015-06-15 A | 2015-12-15 A | 100% | finish no earlier than 2015-12-15 | R4 | 1056h | 1056h | LTE_CA_NC_B42_4DL-Perf | PCG-35 | Huawei | Rel-13 | TSG-68 | RP-151131 |  |
| 1412 | 362.107 | **Additional bandwidth combination set for LTE Advanced inter-band Carrier Aggregation of Band 2 and Band 12** | 67d? | 2015-06-15 A | 2015-09-15 A | 100% |  | R4 | 1608h | 1608h | LTE_CA_B2_B12_BWset | PCG-35 | Nokia Networks | Rel-13 | TSG-68 |  |  |
| 1413 | 362.107.1 | Core part: Additional bandwidth combination set for LTE Advanced inter-band Carrier Aggregation of Band 2 and Band 12 | 67d? | 2015-06-15 A | 2015-09-15 A | 100% | finish no earlier than 2015-09-15 | R4 | 536h | 536h | LTE_CA_B2_B12_BWset-Core | PCG-35 | Nokia Networks | Rel-13 | TSG-68 | RP-151131 |  |
| 1414 | 362.107.2 | Perf. part: Additional bandwidth combination set for LTE Advanced inter-band Carrier Aggregation of Band 2 and Band 12 | 67d? | 2015-06-15 A | 2015-09-15 A | 100% | finish no earlier than 2015-09-15 | R4 | 536h | 536h | LTE_CA_B2_B12_BWset-Perf | PCG-35 | Nokia Networks | Rel-13 | TSG-68 | RP-151131 |  |
| 1415 | 362.108 | **Additional bandwidth combination set 2 for LTE Advanced inter-band Carrier Aggregation of Band 4 and Band 12** | 67d? | 2015-06-15 A | 2015-09-15 A | 100% |  | R4 | 1608h | 1608h | LTE_CA_B4_B12_BWset2 | PCG-35 | Nokia Networks | Rel-13 | TSG-68 |  |  |
| 1416 | 362.108.1 | Core part: Additional bandwidth combination set 2 for LTE Advanced inter-band Carrier Aggregation of Band 4 and Band 12 | 67d? | 2015-06-15 A | 2015-09-15 A | 100% | finish no earlier than 2015-09-15 | R4 | 536h | 536h | LTE_CA_B4_B12_BWset2-Core | PCG-35 | Nokia Networks | Rel-13 | TSG-68 | RP-151131 |  |
| 1417 | 362.108.2 | Perf. part: Additional bandwidth combination set 2 for LTE Advanced inter-band Carrier Aggregation of Band 4 and Band 12 | 67d? | 2015-06-15 A | 2015-09-15 A | 100% | finish no earlier than 2015-09-15 | R4 | 536h | 536h | LTE_CA_B4_B12_BWset2-Perf | PCG-35 | Nokia Networks | Rel-13 | TSG-68 | RP-151131 |  |
| 1418 | 362.109 | **Introduction of 1447-1467MHz Band for TD-LTE in China** | 330d? | 2015-06-15 A | 2016-09-15 A | 100% |  | R4 | 5824h | 5824h | LTE_TDD_1447MHz_China | PCG-35 | Huawei | Rel-13 | TSG-68 |  |  |
| 1419 | 362.109.1 | Core part: Introduction of 1447-1467MHz Band for TD-LTE in China | 132d? | 2015-06-15 A | 2015-12-15 A | 100% | finish no earlier than 2015-12-15 | R4 | 1056h | 1056h | LTE_TDD_1447MHz_China-Core | PCG-35 | Huawei | Rel-13 | TSG-68 | RP-151242 | 36.892 |
| 1420 | 362.109.2 | Perf. part: Introduction of 1447-1467MHz Band for TD-LTE in China | 132d? | 2015-06-15 A | 2015-12-15 A | 100% | finish no earlier than 2016-03-15 | R4 | 1056h | 1056h | LTE_TDD_1447MHz_China-Perf | PCG-35 | Huawei | Rel-13 | TSG-68 | RP-151242 |  |
| 1421 | 362.109.3 | UE Conformance Test Aspects - Introduction of 1447-1467MHz Band for TD-LTE in China | 134d? | 2016-03-15 A | 2016-09-15 A | 100% | finish no earlier than 2016-09-15 | R5 | 1072h | 1072h | LTE_TDD_1447MHz_China-UEConTest | PCG-36 | Huawei | Rel-13 | TSG#71 |  |  |

Notes:
- 1397: covers combinations of contiguous intra-band CA and inter-band CA or combinations of non-contiguous intra-band CA and inter-band CA for LTE; pure intra-band CA combinations are also covered by this WI; note: There is already a REL-13 WI LTE_CA_3DL_2UL whi
- 1398: covers combinations of contiguous intra-band CA and inter-band CA or combinations of non-contiguous intra-band CA and inter-band CA for LTE; pure intra-band CA combinations are also covered by this WI; note: There is already a REL-13 WI LTE_CA_3DL_2UL
- 1399: covers combinations of contiguous intra-band CA and inter-band CA or combinations of non-contiguous intra-band CA and inter-band CA for LTE; pure intra-band CA combinations are also covered by this WI; note: There is already a REL-13 WI LTE_CA_3DL_2UL
- 1401: 29/09/15: Compl:0%->20% 29/09/15: Stat Rep: -->RP-151131
- 1402: 29/09/15: Compl:0%->20% 29/09/15: Stat Rep: -->RP-151131
- 1403: LTE_CA_NC_B4 was completed in REL-12
- 1404: LTE_CA_NC_B4 was completed in REL-12 29/09/15: Compl:0%->100% 29/09/15: Stat Rep: -->RP-151131
- 1405: LTE_CA_NC_B4 was completed in REL-12 29/09/15: Compl:0%->100% 29/09/15: Stat Rep: -->RP-151131
- 1407: 29/09/15: Compl:0%->20% 29/09/15: Stat Rep: -->RP-151131
- 1408: 29/09/15: Compl:0%->20% 29/09/15: Stat Rep: -->RP-151131
- 1410: 29/09/15: Compl:0%->50% 29/09/15: Stat Rep: -->RP-151131
- 1411: 29/09/15: Stat Rep: -->RP-151131
- 1412: LTE_CA_B2_B12 was completed as REL-12 WI
- 1413: LTE_CA_B2_B12 was completed as REL-12 WI 29/09/15: Compl:0%->100% 29/09/15: Stat Rep: -->RP-151131
- 1414: LTE_CA_B2_B12 was completed as REL-12 WI 29/09/15: Compl:0%->100% 29/09/15: Stat Rep: -->RP-151131
- 1415: LTE_CA_B4_B12 was completed in REL-11 and LTE_CA_B4_B12_BWset was completed in REL-12
- 1416: LTE_CA_B4_B12 was completed in REL-11 and LTE_CA_B4_B12_BWset was completed in REL-12 29/09/15: Compl:0%->100% 29/09/15: Stat Rep: -->RP-151131
- 1417: LTE_CA_B4_B12 was completed in REL-11 and LTE_CA_B4_B12_BWset was completed in REL-12 29/09/15: Compl:0%->100% 29/09/15: Stat Rep: -->RP-151131
- 1418: Aug 15: TR numb added
- 1419: Aug 15: TR numb added 29/09/15: Compl:0%->20% 29/09/15: Stat Rep: -->RP-151242
- 1420: 29/09/15: Stat Rep: -->RP-151242
- 1421: testing REL-13 LTE_TDD_1447MHz_China-Core; 1/7/16: C;

| ID | WBS | Task | Duration | Start | Finish | Complete | Constraint | Resources | Work | Actual work | Acronym | PCG approved | WI rapporteur name | Release | TSG approved | Status Report |
| --- | --- | --- | --- | --- | --- | --- | --- | --- | --- | --- | --- | --- | --- | --- | --- | --- |
| 1422 | 362.110 | **LTE Advanced 4 Band Carrier Aggregation (4DL/1UL) of Band 41, Band 41, Band 42 and Band 42** | 132d? | 2015-06-15 A | 2015-12-15 A | 100% |  | R4 | 3168h | 3168h | LTE_CA_B41_B41_B42_B42 | PCG-35 | ZTE | Rel-13 | TSG-68 |  |
| 1423 | 362.110.1 | Core part: LTE Advanced 4 Band Carrier Aggregation (4DL/1UL) of Band 41, Band 41, Band 42 and Band 42 | 132d? | 2015-06-15 A | 2015-12-15 A | 100% | finish no earlier than 2015-12-15 | R4 | 1056h | 1056h | LTE_CA_B41_B41_B42_B42-Core | PCG-35 | ZTE | Rel-13 | TSG-68 | RP-151131 |
| 1424 | 362.110.2 | Perf. part: LTE Advanced 4 Band Carrier Aggregation (4DL/1UL) of Band 41, Band 41, Band 42 and Band 42 | 132d? | 2015-06-15 A | 2015-12-15 A | 100% | finish no earlier than 2015-12-15 | R4 | 1056h | 1056h | LTE_CA_B41_B41_B42_B42-Perf | PCG-35 | ZTE | Rel-13 | TSG-68 | RP-151131 |
| 1425 | 362.111 | **LTE Advanced inter-band Carrier Aggregation for Band 5 and Band 38** | 66d? | 2015-09-15 A | 2015-12-15 A | 100% |  | R4 | 1584h | 1584h | LTE_CA_B5_B38 | PCG-35 | Huawei | Rel-13 | RP-69 |  |
| 1426 | 362.111.1 | Core part: LTE Advanced inter-band Carrier Aggregation for Band 5 and Band 38 | 66d? | 2015-09-15 A | 2015-12-15 A | 100% | finish no earlier than 2015-12-15 | R4 | 528h | 528h | LTE_CA_B5_B38-Core | PCG-35 | Huawei | Rel-13 | RP-69 |  |
| 1427 | 362.111.2 | Perf. part: LTE Advanced inter-band Carrier Aggregation for Band 5 and Band 38 | 66d? | 2015-09-15 A | 2015-12-15 A | 100% | finish no earlier than 2015-12-15 | R4 | 528h | 528h | LTE_CA_B5_B38-Perf | PCG-35 | Huawei | Rel-13 | RP-69 |  |
| 1428 | 362.112 | **LTE Advanced 3 Band Carrier Aggregation (3DL/1UL) of Band 1, Band 11 and Band 18** | 66d? | 2015-09-15 A | 2015-12-15 A | 100% |  | R4 | 1584h | 1584h | LTE_CA_B1_B11_B18 | PCG-35 | KDDI | Rel-13 | RP-69 |  |
| 1429 | 362.112.1 | Core part: LTE Advanced 3 Band Carrier Aggregation (3DL/1UL) of Band 1, Band 11 and Band 18 | 66d? | 2015-09-15 A | 2015-12-15 A | 100% | finish no earlier than 2015-12-15 | R4 | 528h | 528h | LTE_CA_B1_B11_B18-Core | PCG-35 | KDDI | Rel-13 | RP-69 |  |
| 1430 | 362.112.2 | Perf. part: LTE Advanced 3 Band Carrier Aggregation (3DL/1UL) of Band 1, Band 11 and Band 18 | 66d? | 2015-09-15 A | 2015-12-15 A | 100% | finish no earlier than 2015-12-15 | R4 | 528h | 528h | LTE_CA_B1_B11_B18-Perf | PCG-35 | KDDI | Rel-13 | RP-69 |  |
| 1431 | 362.113 | **LTE Advanced 3 Band Carrier Aggregation (3DL/1UL) of Band 5, Band 40, and Band 40** | 66d? | 2015-09-15 A | 2015-12-15 A | 100% |  | R4 | 1584h | 1584h | LTE_CA_B5_B40_B40 | PCG-35 | ZTE | Rel-13 | RP-69 |  |
| 1432 | 362.113.1 | Core part: LTE Advanced 3 Band Carrier Aggregation (3DL/1UL) of Band 5, Band 40, and Band 40 | 66d? | 2015-09-15 A | 2015-12-15 A | 100% | finish no earlier than 2015-12-15 | R4 | 528h | 528h | LTE_CA_B5_B40_B40-Core | PCG-35 | ZTE | Rel-13 | RP-69 |  |
| 1433 | 362.113.2 | Perf. part: LTE Advanced 3 Band Carrier Aggregation (3DL/1UL) of Band 5, Band 40, and Band 40 | 66d? | 2015-09-15 A | 2015-12-15 A | 100% | finish no earlier than 2015-12-15 | R4 | 528h | 528h | LTE_CA_B5_B40_B40-Perf | PCG-35 | ZTE | Rel-13 | RP-69 |  |
| 1434 | 362.114 | **LTE Advanced 3 Band Carrier Aggregation (3DL/1UL) for Band 3, Band 41 and Band 42** | 66d? | 2015-09-15 A | 2015-12-15 A | 100% |  | R4 | 1584h | 1584h | LTE_CA_B3_B41_B42 | PCG-35 | Huawei | Rel-13 | RP-69 |  |
| 1435 | 362.114.1 | Core part: LTE Advanced 3 Band Carrier Aggregation (3DL/1UL) for Band 3, Band 41 and Band 42 | 66d? | 2015-09-15 A | 2015-12-15 A | 100% | finish no earlier than 2015-12-15 | R4 | 528h | 528h | LTE_CA_B3_B41_B42-Core | PCG-35 | Huawei | Rel-13 | RP-69 |  |
| 1436 | 362.114.2 | Perf. part: LTE Advanced 3 Band Carrier Aggregation (3DL/1UL) for Band 3, Band 41 and Band 42 | 66d? | 2015-09-15 A | 2015-12-15 A | 100% | finish no earlier than 2015-12-15 | R4 | 528h | 528h | LTE_CA_B3_B41_B42-Perf | PCG-35 | Huawei | Rel-13 | RP-69 |  |
| 1437 | 362.115 | **LTE Advanced 3 Band Carrier Aggregation (3DL/1UL) of Band 3, Band 41, and Band 41** | 66d? | 2015-09-15 A | 2015-12-15 A | 100% |  | R4 | 1584h | 1584h | LTE_CA_B3_B41_B41 | PCG-35 | ZTE | Rel-13 | RP-69 |  |
| 1438 | 362.115.1 | Core part: LTE Advanced 3 Band Carrier Aggregation (3DL/1UL) of Band 3, Band 41, and Band 41 | 66d? | 2015-09-15 A | 2015-12-15 A | 100% | finish no earlier than 2015-12-15 | R4 | 528h | 528h | LTE_CA_B3_B41_B41-Core | PCG-35 | ZTE | Rel-13 | RP-69 |  |
| 1439 | 362.115.2 | Perf. part: LTE Advanced 3 Band Carrier Aggregation (3DL/1UL) of Band 3, Band 41, and Band 41 | 66d? | 2015-09-15 A | 2015-12-15 A | 100% | finish no earlier than 2015-12-15 | R4 | 528h | 528h | LTE_CA_B3_B41_B41-Perf | PCG-35 | ZTE | Rel-13 | RP-69 |  |
| 1440 | 362.116 | **LTE Advanced 4 Band Carrier Aggregation (4DL1UL) of Band 39, Band 41, Band 41 and Band 41** | 66d? | 2015-09-15 A | 2015-12-15 A | 100% |  | R4 | 1584h | 1584h | LTE_CA_B39_B41_B41_B41 | PCG-35 | CMCC | Rel-13 | RP-69 |  |
| 1441 | 362.116.1 | Core part: LTE Advanced 4 Band Carrier Aggregation (4DL1UL) of Band 39, Band 41, Band 41 and Band 41 | 66d? | 2015-09-15 A | 2015-12-15 A | 100% | finish no earlier than 2015-12-15 | R4 | 528h | 528h | LTE_CA_B39_B41_B41_B41-Core | PCG-35 | CMCC | Rel-13 | RP-69 |  |
| 1442 | 362.116.2 | Perf. part: LTE Advanced 4 Band Carrier Aggregation (4DL1UL) of Band 39, Band 41, Band 41 and Band 41 | 66d? | 2015-09-15 A | 2015-12-15 A | 100% | finish no earlier than 2015-12-15 | R4 | 528h | 528h | LTE_CA_B39_B41_B41_B41-Perf | PCG-35 | CMCC | Rel-13 | RP-69 |  |
| 1443 | 362.117 | **LTE Advanced 4 Band Carrier Aggregation (4DL1UL) of Band 39, Band 39, Band 41 and Band 41** | 66d? | 2015-09-15 A | 2015-12-15 A | 100% |  | R4 | 1584h | 1584h | LTE_CA_B39_B39_B41_B41 | PCG-35 | CMCC | Rel-13 | RP-69 |  |
| 1444 | 362.117.1 | Core part: LTE Advanced 4 Band Carrier Aggregation (4DL1UL) of Band 39, Band 39, Band 41 and Band 41 | 66d? | 2015-09-15 A | 2015-12-15 A | 100% | finish no earlier than 2015-12-15 | R4 | 528h | 528h | LTE_CA_B39_B39_B41_B41-Core | PCG-35 | CMCC | Rel-13 | RP-69 |  |
| 1445 | 362.117.2 | Perf. part: LTE Advanced 4 Band Carrier Aggregation (4DL1UL) of Band 39, Band 39, Band 41 and Band 41 | 66d? | 2015-09-15 A | 2015-12-15 A | 100% | finish no earlier than 2015-12-15 | R4 | 528h | 528h | LTE_CA_B39_B39_B41_B41-Perf | PCG-35 | CMCC | Rel-13 | RP-69 |  |

Notes:
- 1423: 29/09/15: Compl:0%->40% 29/09/15: WID: RP-150627->RP-151562 29/09/15: Stat Rep: ->RP-151131
- 1424: 29/09/15: Compl:0%->40% 29/09/15: WID: RP-150627->RP-151562 29/09/15: Stat Rep: ->RP-151131
- 1426: 1/1/16: Compl:0%->100%
- 1427: ; 1/1/16: Compl:0%->100%
- 1429: ; 1/1/16: Compl:0%->100%
- 1430: 1/1/16: Compl:0%->100%
- 1432: 1/1/16: Compl:0%->100%
- 1433: 1/1/16: Compl:0%->100%
- 1435: 1/1/16: Compl:0%->100%
- 1436: ; 1/1/16: Compl:0%->100%
- 1438: ; 1/1/16: Compl:0%->100%
- 1439: 1/1/16: Compl:0%->100%

| ID | WBS | Task | Duration | Start | Finish | Complete | Constraint | Resources | Work | Actual work | Acronym | PCG approved | WI rapporteur name | Release | TSG approved | Impacted TSs and TRs |
| --- | --- | --- | --- | --- | --- | --- | --- | --- | --- | --- | --- | --- | --- | --- | --- | --- |
| 1446 | 362.118 | **LTE Advanced 4 Band Carrier Aggregation (4DL/1UL) of Band 1, Band 3, Band 8 and Band 40** | 66d? | 2015-09-15 A | 2015-12-15 A | 100% |  | R4 | 1584h | 1584h | LTE_CA_B1_B3_B8_B40 | PCG-35 | KT | Rel-13 | RP-69 |  |
| 1447 | 362.118.1 | Core part: LTE Advanced 4 Band Carrier Aggregation (4DL/1UL) of Band 1, Band 3, Band 8 and Band 40 | 66d? | 2015-09-15 A | 2015-12-15 A | 100% | finish no earlier than 2015-12-15 | R4 | 528h | 528h | LTE_CA_B1_B3_B8_B40-Core | PCG-35 | KT | Rel-13 | RP-69 |  |
| 1448 | 362.118.2 | Perf. part: LTE Advanced 4 Band Carrier Aggregation (4DL/1UL) of Band 1, Band 3, Band 8 and Band 40 | 66d? | 2015-09-15 A | 2015-12-15 A | 100% | finish no earlier than 2015-12-15 | R4 | 528h | 528h | LTE_CA_B1_B3_B8_B40-Perf | PCG-35 | KT | Rel-13 | RP-69 |  |
| 1449 | 362.119 | **LTE Advanced 4 Band Carrier Aggregation (4DL/1UL) for Band 3, Band 28, Band 40 and Band 40** | 66d? | 2015-09-15 A | 2015-12-15 A | 100% |  | R4 | 1584h | 1584h | LTE_CA_B3_B28_B40_B40 | PCG-35 | Huawei | Rel-13 | RP-69 |  |
| 1450 | 362.119.1 | Core part: LTE Advanced 4 Band Carrier Aggregation (4DL/1UL) for Band 3, Band 28, Band 40 and Band 40 | 66d? | 2015-09-15 A | 2015-12-15 A | 100% | finish no earlier than 2015-12-15 | R4 | 528h | 528h | LTE_CA_B3_B28_B40_B40-Core | PCG-35 | Huawei | Rel-13 | RP-69 |  |
| 1451 | 362.119.2 | Perf. part: LTE Advanced 4 Band Carrier Aggregation (4DL/1UL) for Band 3, Band 28, Band 40 and Band 40 | 66d? | 2015-09-15 A | 2015-12-15 A | 100% | finish no earlier than 2015-12-15 | R4 | 528h | 528h | LTE_CA_B3_B28_B40_B40-Perf | PCG-35 | Huawei | Rel-13 | RP-69 |  |
| 1452 | 362.120 | **LTE Advanced 4 Band Carrier Aggregation (4DL/1UL) for Band 28, Band 40, Band 40 and Band 40** | 66d? | 2015-09-15 A | 2015-12-15 A | 100% |  | R4 | 1584h | 1584h | LTE_CA_B28_B40_B40_B40 | PCG-35 | Huawei | Rel-13 | RP-69 |  |
| 1453 | 362.120.1 | Core part: LTE Advanced 4 Band Carrier Aggregation (4DL/1UL) for Band 28, Band 40, Band 40 and Band 40 | 66d? | 2015-09-15 A | 2015-12-15 A | 100% | finish no earlier than 2015-12-15 | R4 | 528h | 528h | LTE_CA_B28_B40_B40_B40-Core | PCG-35 | Huawei | Rel-13 | RP-69 |  |
| 1454 | 362.120.2 | Perf. part: LTE Advanced 4 Band Carrier Aggregation (4DL/1UL) for Band 28, Band 40, Band 40 and Band 40 | 66d? | 2015-09-15 A | 2015-12-15 A | 100% | finish no earlier than 2015-12-15 | R4 | 528h | 528h | LTE_CA_B28_B40_B40_B40-Perf | PCG-35 | Huawei | Rel-13 | RP-69 |  |
| 1455 | 362.121 | **LTE Advanced 4 Band Carrier Aggregation (4DL/1UL) of Band 3, Band 7, Band 7 and Band 28** | 66d? | 2015-09-15 A | 2015-12-15 A | 100% |  | R4 | 1584h | 1584h | LTE_CA_B3_B7_B7_B28 | PCG-35 | Telstra | Rel-13 | RP-69 |  |
| 1456 | 362.121.1 | Core part: LTE Advanced 4 Band Carrier Aggregation (4DL/1UL) of Band 3, Band 7, Band 7 and Band 28 | 66d? | 2015-09-15 A | 2015-12-15 A | 100% | finish no earlier than 2015-12-15 | R4 | 528h | 528h | LTE_CA_B3_B7_B7_B28-Core | PCG-35 | Telstra | Rel-13 | RP-69 |  |
| 1457 | 362.121.2 | Perf. part: LTE Advanced 4 Band Carrier Aggregation (4DL/1UL) of Band 3, Band 7, Band 7 and Band 28 | 66d? | 2015-09-15 A | 2015-12-15 A | 100% | finish no earlier than 2015-12-15 | R4 | 528h | 528h | LTE_CA_B3_B7_B7_B28-Perf | PCG-35 | Telstra | Rel-13 | RP-69 |  |
| 1458 | 362.122 | **LTE Advanced 5 Band Carrier Aggregation (5DL/1UL) of Band 1, Band 3, Band 19, Band 42 and Band 42** | 66d? | 2015-09-15 A | 2015-12-15 A | 100% |  | R4 | 1584h | 1584h | LTE_CA_B1_B3_B19_B42_B42 | PCG-35 | NTT DOCOMO | Rel-13 | RP-69 | 36.857-13 |
| 1459 | 362.122.1 | Core part: LTE Advanced 5 Band Carrier Aggregation (5DL/1UL) of Band 1, Band 3, Band 19, Band 42 and Band 42 | 66d? | 2015-09-15 A | 2015-12-15 A | 100% | finish no earlier than 2015-12-15 | R4 | 528h | 528h | LTE_CA_B1_B3_B19_B42_B42-Core | PCG-35 | NTT DOCOMO | Rel-13 | RP-69 | 36.857-13 |
| 1460 | 362.122.2 | Perf. part: LTE Advanced 5 Band Carrier Aggregation (5DL/1UL) of Band 1, Band 3, Band 19, Band 42 and Band 42 | 66d? | 2015-09-15 A | 2015-12-15 A | 100% | finish no earlier than 2015-12-15 | R4 | 528h | 528h | LTE_CA_B1_B3_B19_B42_B42-Perf | PCG-35 | NTT DOCOMO | Rel-13 | RP-69 | 36.857-13 |
| 1461 | 362.123 | **LTE Advanced 5 Band Carrier Aggregation (5DL/1UL) of Band 1, Band 19, Band 21, Band 42 and Band 42** | 66d? | 2015-09-15 A | 2015-12-15 A | 100% |  | R4 | 1584h | 1584h | LTE_CA_B1_B19_B21_B42_B42 | PCG-35 | NTT DOCOMO | Rel-13 | RP-69 |  |
| 1462 | 362.123.1 | Core part: LTE Advanced 5 Band Carrier Aggregation (5DL/1UL) of Band 1, Band 19, Band 21, Band 42 and Band 42 | 66d? | 2015-09-15 A | 2015-12-15 A | 100% | finish no earlier than 2015-12-15 | R4 | 528h | 528h | LTE_CA_B1_B19_B21_B42_B42-Core | PCG-35 | NTT DOCOMO | Rel-13 | RP-69 |  |
| 1463 | 362.123.2 | Perf. part: LTE Advanced 5 Band Carrier Aggregation (5DL/1UL) of Band 1, Band 19, Band 21, Band 42 and Band 42 | 66d? | 2015-09-15 A | 2015-12-15 A | 100% | finish no earlier than 2015-12-15 | R4 | 528h | 528h | LTE_CA_B1_B19_B21_B42_B42-Perf | PCG-35 | NTT DOCOMO | Rel-13 | RP-69 |  |
| 1464 | 362.124 | **LTE Advanced 5 Band Carrier Aggregation (5DL/1UL) of Band 1, Band 3, Band 7, Band 7 and Band 28** | 131d? | 2015-09-15 A | 2016-03-15 A | 100% |  | R4 | 3144h | 3144h | LTE_CA_B1_B3_B7_B7_B28 | PCG-35 | Telstra | Rel-13 | RP-69 |  |
| 1465 | 362.124.1 | Core part: LTE Advanced 5 Band Carrier Aggregation (5DL/1UL) of Band 1, Band 3, Band 7, Band 7 and Band 28 | 131d? | 2015-09-15 A | 2016-03-15 A | 100% | finish no earlier than 2016-03-15 | R4 | 1048h | 1048h | LTE_CA_B1_B3_B7_B7_B28-Core | PCG-35 | Telstra | Rel-13 | RP-69 |  |
| 1466 | 362.124.2 | Perf. part: LTE Advanced 5 Band Carrier Aggregation (5DL/1UL) of Band 1, Band 3, Band 7, Band 7 and Band 28 | 131d? | 2015-09-15 A | 2016-03-15 A | 100% | finish no earlier than 2016-03-15 | R4 | 1048h | 1048h | LTE_CA_B1_B3_B7_B7_B28-Perf | PCG-35 | Telstra | Rel-13 | RP-69 |  |
| 1467 | 362.125 | **LTE Advanced 5 Band Carrier Aggregation (5DL/1UL) of Band 3, Band 3, Band 7, Band 7 and Band 28** | 131d? | 2015-09-15 A | 2016-03-15 A | 100% |  | R4 | 3144h | 3144h | LTE_CA_B3_B3_B7_B7_B28 | PCG-35 | Telstra | Rel-13 | RP-69 |  |
| 1468 | 362.125.1 | Core part: LTE Advanced 5 Band Carrier Aggregation (5DL/1UL) of Band 3, Band 3, Band 7, Band 7 and Band 28 | 131d? | 2015-09-15 A | 2016-03-15 A | 100% | finish no earlier than 2016-03-15 | R4 | 1048h | 1048h | LTE_CA_B3_B3_B7_B7_B28-Core | PCG-35 | Telstra | Rel-13 | RP-69 |  |
| 1469 | 362.125.2 | Perf. part: LTE Advanced 5 Band Carrier Aggregation (5DL/1UL) of Band 3, Band 3, Band 7, Band 7 and Band 28 | 131d? | 2015-09-15 A | 2016-03-15 A | 100% | finish no earlier than 2016-03-15 | R4 | 1048h | 1048h | LTE_CA_B3_B3_B7_B7_B28-Perf | PCG-35 | Telstra | Rel-13 | RP-69 |  |

Notes:
- 1447: ; 1/1
- 1448: 1
- 1465: ; 22/3/16: Compl:95%->100%;
- 1466: 22/3/16: Compl:95%->100%;
- 1468: 22/3/16: Compl:95%->100%
- 1469: ; 22/3/16: Compl:95%->100%

| ID | WBS | Task | Duration | Start | Finish | Complete | Remaining | Baseline start | Baseline finish | Baseline duration | Total slack | Constraint | Resources | Work | Actual work | Acronym | PCG approved | WI rapporteur name | Release | TSG approved | Impacted TSs and TRs | Status Report | WI rapporteur e-mail | Acronym_3GU_Export | Special Focus Doc | MCC resp |
| --- | --- | --- | --- | --- | --- | --- | --- | --- | --- | --- | --- | --- | --- | --- | --- | --- | --- | --- | --- | --- | --- | --- | --- | --- | --- | --- |
| 1470 | 362.126 | **LTE Advanced 3 Band Carrier Aggregation (3DL/3UL) of Band 39, Band 41 and Band 41** | 66d? | 2015-09-15 A | 2015-12-15 A | 100% |  |  |  |  |  |  | R4 | 1584h | 1584h | LTE_CA_3DL3UL_B39_B41_B41 | PCG-35 | CATT | Rel-13 | RP-69 |  |  |  |  |  |  |
| 1471 | 362.126.1 | Core part: LTE Advanced 3 Band Carrier Aggregation (3DL/3UL) of Band 39, Band 41 and Band 41 | 66d? | 2015-09-15 A | 2015-12-15 A | 100% |  |  |  |  |  | finish no earlier than 2015-12-15 | R4 | 528h | 528h | LTE_CA_3DL3UL_B39_B41_B41-Core | PCG-35 | CATT | Rel-13 | RP-69 |  |  |  |  |  |  |
| 1472 | 362.126.2 | Perf. part: LTE Advanced 3 Band Carrier Aggregation (3DL/3UL) of Band 39, Band 41 and Band 41 | 66d? | 2015-09-15 A | 2015-12-15 A | 100% |  |  |  |  |  | finish no earlier than 2015-12-15 | R4 | 528h | 528h | LTE_CA_3DL3UL_B39_B41_B41-Perf | PCG-35 | CATT | Rel-13 | RP-69 |  |  |  |  |  |  |
| 1473 | 362.127 | **LTE Advanced 3 Band Carrier Aggregation (3DL/3UL) of Band 39, Band 39 and Band 41** | 66d? | 2015-09-15 A | 2015-12-15 A | 100% |  |  |  |  |  |  | R4 | 1584h | 1584h | LTE_CA_3DL3UL_B39_B39_B41 | PCG-35 | CATT | Rel-13 | RP-69 | 36.899-13 |  |  |  |  |  |
| 1474 | 362.127.1 | Core part: LTE Advanced 3 Band Carrier Aggregation (3DL/3UL) of Band 39, Band 39 and Band 41 | 66d? | 2015-09-15 A | 2015-12-15 A | 100% |  |  |  |  |  | finish no earlier than 2015-12-15 | R4 | 528h | 528h | LTE_CA_3DL3UL_B39_B39_B41-Core | PCG-35 | CATT | Rel-13 | RP-69 |  |  |  |  |  |  |
| 1475 | 362.127.2 | Perf. part: LTE Advanced 3 Band Carrier Aggregation (3DL/3UL) of Band 39, Band 39 and Band 41 | 66d? | 2015-09-15 A | 2015-12-15 A | 100% |  |  |  |  |  | finish no earlier than 2015-12-15 | R4 | 528h | 528h | LTE_CA_3DL3UL_B39_B39_B41-Perf | PCG-35 | CATT | Rel-13 | RP-69 |  |  |  |  |  |  |
| 1476 | 362.128 | **Additional bandwidth combination set for LTE Advanced intra-band non-contiguous Carrier Aggregation in Band 7** | 66d? | 2015-09-15 A | 2015-12-15 A | 100% |  |  |  |  |  |  | R4 | 1584h | 1584h | LTE_CA_NC_B7_BWset | PCG-35 | Huawei | Rel-13 | RP-69 |  |  |  |  |  |  |
| 1477 | 362.128.1 | Core part: Additional bandwidth combination set for LTE Advanced intra-band non-contiguous Carrier Aggregation in Band 7 | 66d? | 2015-09-15 A | 2015-12-15 A | 100% |  |  |  |  |  | finish no earlier than 2015-12-15 | R4 | 528h | 528h | LTE_CA_NC_B7_BWset-Core | PCG-35 | Huawei | Rel-13 | RP-69 |  |  |  |  |  |  |
| 1478 | 362.128.2 | Perf. part: Additional bandwidth combination set for LTE Advanced intra-band non-contiguous Carrier Aggregation in Band 7 | 66d? | 2015-09-15 A | 2015-12-15 A | 100% |  |  |  |  |  | finish no earlier than 2015-12-15 | R4 | 528h | 528h | LTE_CA_NC_B7_BWset-Perf | PCG-35 | Huawei | Rel-13 | RP-69 |  |  |  |  |  |  |
| 1479 | 362.129 | UE Conformance Test Aspects - Rel-13 LTE CA configurations | 525d? | 2015-12-15 A | 2017-12-15 | 56% | 231d? |  |  |  | 264d | finish no earlier than 2017-12-15 | R5 | 4200h | 2352h | LTE_CA_Rel13-UEConTest | PCG-36 | Ericsson | Rel-13 | RP-70 |  |  |  |  |  |  |
| 1480 | 363 | (Small) Technical Enhancements and Improvements for Rel-13 | 593d? | 2013-09-18 A | 2015-12-21 A | 100% |  |  |  |  |  | finish no earlier than 2015-12-21 | SP; CP; RP; GP | 18976h | 18976h | TEI13 | PCG-31 |  | Rel-13 | SP-61 |  | PCG-31 |  |  |  |  |
| 1481 | 364 | (Small) Test Technical Enhancements and Improvements for Rel-13 | 593d? | 2013-09-18 A | 2015-12-21 A | 100% |  |  |  |  |  | finish no earlier than 2015-12-21 | SP; CP; RP; GP | 18976h | 18976h | TEI13_Test | PCG-31 |  | Rel-13 | SP-61 |  | PCG-31 |  |  |  |  |
| 1482 | 365 | Awaiting formal work item | 593d? | 2013-09-18 A | 2015-12-21 A | 100% |  |  |  |  |  | start no earlier than 2013-09-18 | SP; CP; RP; GP | 18976h | 18976h | DUMMY | PCG-35 |  | Rel-13 | SP-69 |  |  |  |  |  |  |
| 1483 | 366 | (Small) Security Enhancements and Improvements for Rel-13 | 2372d? | 2006-12-12 A | 2015-12-21 A | 100% |  |  |  |  |  | finish no earlier than 2015-12-21 | S3 | 18976h | 18976h | SEC13 | PCG-31 |  | Rel-13 | SP-61 |  | PCG-31 |  |  |  |  |
| 1484 | 367 | Release 13 IoT related Studies | 602d? | 2013-09-12 A | 2015-12-25 A | 100% |  | 2014-07-31 | 2015-12-25 | 366.5d? |  | start no earlier than 2013-09-12 | SP; R2 | 9632h | 9632h |  |  |  | Rel-13 |  |  |  |  |  |  |  |
| 1485 | 368 | Study on Power saving for Machine-Type Communications (MTC) devices | 266.6d? | 2014-08-12 A | 2015-08-14 A | 100% |  | 2014-06-18 | 2015-02-20 | 160.5d? |  | finish no earlier than 2015-08-14 | G2; G1 | 4000.8h | 4000.8h | FS_uPoD | PCG-32 | China Mobile | Rel-13 | GP-60 | 43.869 |  | Jing Han (hanjing@chinamobile.com) | FS_uPoD |  |  |
| 1486 | 369 | Study on Cellular system support for ultra Low Complexity and low throughput Internet of Things | 329d? | 2014-05-30 A | 2015-08-28 A | 100% |  | 2015-01-14 | 2015-08-28 | 163d? |  | finish no earlier than 2015-08-28 | G1; G2 | 5264h | 5264h | FS_IoT_LC | PCG-33 | Vodafone | Rel-13 | GP-66 | 45.8xy |  | chris.pudney@vodafone.com | FS_IoT_LC | MTC, M2M |  |
| 1487 | 370 | Study on architecture enhancements of cellular systems for ultra low complexity and low throughput Internet of Things | 196d? | 2015-03-13 A | 2015-12-11 A | 100% |  |  |  |  |  | finish no earlier than 2015-12-11 | S2 | 1568h | 1568h | FS_AE_CIoT | PCG-34 | puneet.jain@intel.com | Rel-13 | SP-67 | New TR 23.8xx |  | puneet.jain@intel.com |  |  |  |
| 1488 | 371 | Study on Battery Efficient Security for very low Throughput Machine Type Communication Devices | 196d? | 2015-03-13 A | 2015-12-11 A | 100% |  |  |  |  |  | finish no earlier than 2015-12-11 | S3 | 1568h | 1568h | FS_BEST_MTC_Sec | PCG-34 | Barry, Aguibou, VODAFONE Group Plc | Rel-13 | SP-67 | 32.863; 33.163 |  | Barry, Aguibou, VODAFONE Group Plc |  |  |  |
| 1489 | 372 | Study on Small data transmission enhancements for UMTS | 197d? | 2014-09-16 A | 2015-06-15 A | 100% |  |  |  |  |  | finish no earlier than 2015-06-15 | R1; R3 | 3152h | 3152h | FS_UTRA_SDATA | PCG-33 | Ericsson | Rel-13 | RP-65 | 25.705 | RP-150843 | gerardo.agni.medina.acosta@ericsson.com | FS_UTRA_SDATA |  |  |
| 1490 | 373 | Study on Application specific Congestion control for Data Communication | 531.29d? | 2012-09-17 A | 2014-09-17 A | 100% |  | 2012-09-13 | 2014-09-17 | 532d? |  | finish no earlier than 2014-09-17 | S1 | 4250.28h | 4250.28h | FS_ACDC | PCG-29 | NTT DOCOMO | Rel-13 | SP-57 | 22.806 | S1-143305 | Atsushi Minokuchi (minokuchi@nttdocomo.co.jp) | FS_ACDC |  | Alain |
| 1491 | 374 | Study on enhancements for Infrastructure based data Communication Between Devices | 266d? | 2013-09-14 A | 2014-09-17 A | 100% |  | 2013-09-12 | 2014-09-17 | 266d? |  | finish no earlier than 2014-09-17 | S1 | 2128h | 2128h | FS_eICBD | PCG-31 | KPN | Rel-13 | SP-61 | 22.807 | S1-143309 | toon.norp@tno.nl | FS_eICBD | MTC, M2M | Alain |
| 1492 | 375 | Release 13 other Studies | 602d? | 2013-09-12 A | 2015-12-25 A | 100% |  | 2014-07-31 | 2015-12-25 | 366.5d? |  | start no earlier than 2013-09-12 | SP; R2 | 9632h | 9632h |  |  |  | Rel-13 |  |  |  |  |  |  |  |
| 1493 | 376 | Study on Isolated E-UTRAN Operation for Public Safety | 261d? | 2013-06-25 A | 2014-06-18 A | 100% |  | 2013-06-21 | 2014-06-18 | 262d? |  | finish no earlier than 2014-06-18 | S1 | 2088h | 2088h | FS_IOPS | PCG-31 | General Dynamics | Rel-13 | SP-60 | 22.897 |  | paul.piggin@gd-broadband.com | FS_IOPS | Public Safety (A-A) | Alain |
| 1494 | 377 | Study on architecture enhancements for Public Safety | 131d? | 2014-12-12 A | 2015-06-12 A | 100% |  |  |  |  |  | finish no earlier than 2015-06-12 | S2 | 1048h | 1048h | FS_IOPS_St2 | PCG-34 |  | Rel-13 | SP-66 |  |  | phil.young@gd-broadband.com |  |  |  |
| 1495 | 378 | Study on Security Aspects of Isolated E-UTRAN Operation for Public Safety | 137d? | 2015-03-12 A | 2015-09-18 A | 100% |  |  |  |  |  | finish no earlier than 2015-09-18 | S3 | 1096h | 1096h | FS_IOPS_Sec | PCG-34 | Paul Piggin, General Dynamics UK | Rel-13 | SP-67 | New TR 33.897 |  | paul.piggin@gd-broadband.com |  |  |  |
| 1496 | 379 | (SA66: on hold) Study on Co-ordinated packet data network gateway (P-GW) change for SIPTO | 201d? | 2013-09-13 A | 2014-06-18 A | 100% |  | 2013-09-12 | 2014-06-18 | 202d? |  | finish no earlier than 2014-06-18 | S1 | 1608h | 1608h | FS_CSIPTO | PCG-31 | Intel | Rel-13 | SP-61 | 22.828 |  | Eric.siow@intel.com | FS_CSIPTO |  | Alain |
| 1497 | 380 | Study on Flexible Mobile Service Steering | 201d? | 2013-12-13 A | 2014-09-17 A | 100% |  | 2013-12-11 | 2014-09-17 | 202d? |  | finish no earlier than 2014-09-17 | S1 | 1608h | 1608h | FS_FMSS | PCG-32 | China Mobile | Rel-13 | SP-62 | 22.808 | S1-143310 | Lu Lu (lulu@chinamobile.com) | FS_FMSS |  | Alain |
| 1498 | 381 | Study on Enhanced Calling Information Presentation | 201d? | 2013-12-13 A | 2014-09-17 A | 100% |  | 2013-12-11 | 2014-09-17 | 201d? |  | finish no earlier than 2014-09-17 | S1 | 1608h | 1608h | FS_ECIP | PCG-32 | China Mobile | Rel-13 | SP-62 | 22.810 | S1-143311 | LI Xiaofan (lixiaofan@chinamobile.com | FS_ECIP |  | Alain |
| 1499 | 382 | Study on RAN Sharing Enhancements on GERAN and UTRAN | 140d? | 2014-03-07 A | 2014-09-17 A | 100% |  | 2014-03-07 | 2014-09-17 | 139d? |  | finish no earlier than 2014-09-17 | S1 | 1120h | 1120h | FS_GUSH | PCG-32 | Telefónica | Rel-13 | SP-63 | 22.852 updates |  | chris.friel@telefonica.com | FS_GUSH |  | Alain |

Notes:
- 1470: TDD case
- 1471: TDD case
- 1472: TDD case
- 1473: TDD case; 5/10/15: 36.899-13 added;
- 1474: TDD case
- 1475: TDD case
- 1476: LTE_CA_NC_B7 was completed in REL-12
- 1477: LTE_CA_NC_B7 was completed in REL-12 ;
- 1478: LTE_CA_NC_B7 was completed in REL-12 ;
- 1479: ; 22/3/16: Compl:0%->5%;1/7/16: Compl:5%->22%26/9/16: Compl:22%->; 2 21/3/17: Compl:39%...
- 1480: -
- 1481: Created upon demand of RAN5
- 1483: -
- 1484: -
- 1485: GP#65 completion 02/15=>05/15. GP#60 approved WID. Linked to Rel-12 Feature MTCe, Stage 2 BB3: UE Power Consumptions Optimizations (UEPCOP). Dec.14: 30->40%; June2015: Compl:40%->75; 07/09/15: 75%->100
- 1486: GP#62 approved WID. Dec.14: 15->40%; June2015: Compl:40%->75; 07/09/15: 75%->100; 14/09/15: WID:GP-140421->GP-150354
- 1487: 07/09/15: 0%->20; 07/09/15: 20%->65; 7/12/15: 65%->95; 7/3/16: 95%->100
- 1488: TR number added; June2015: Compl:0%->10; 7/12/15: 10%->50; 11/12/15: 50%->75; 7/3/16: 75%->95; 19/9/16: 95%->100; 6/10/16: 33.163 added;
- 1489: 3/3/15: WID: RP-141861; Stat Rep: -->RP-141859. Impacted TR number added. 1st Apr 15: Compl:30%->55% 1st Apr 15: Stat Rep: RP-141859->RP-150196 03/07/15: Compl:55%->100% 03/07/15: Stat Rep: RP-150196->RP-150843
- 1490: SP#65 completed. SP#64 TR 22.806v200 for Approval. ACDC is applicable to UTRAN and E-UTRAN. Possible overlap with RAN2 TR 36.848 Study on smart congestion mitigation in E-UTRAN (prioritising MMTEL voice over other traffic during congestion)
- 1491: SP#65 completed. TR 22.807v200 for Approval
- 1492: -
- 1493: SP#64 completed. TR 22.897v200 for Approval. Linked to Rel-12 TR 22.803 (FS_ProSe) and FeaturES in CP-150ProSe, GCSE_LTE
- 1494: June2015: Compl:0%->100
- 1495: TR added; June2015: Compl:0%->30; 7/12/15: 30%->100
- 1496: SP#64 completed. TR 22.828v200 for Approval. Linked to FeaturES in CP-150Rel-10 LIPA_SIPTO & Rel-12 LIMONET
- 1497: SP#65 completed. TR 22.808v200 for Approval. Study supporting traffic classification and service chain selection capabilities per operators policy in order to realize efficient and flexible mobile service steering in the Gi-LAN network
- 1498: SP#65 completed. TR 22.810v200 for Approval. Linked to Multimedia Telephony Service for IMS (UID_7038), Customized Alerting Tone (CAT) UID_370028, Customized Ringing Signal (CRS) UID_380067
- 1499: SP#65 completed. Update on GERAN and UTRAN of Rel-12 TR 22.852 Study on RAN Sharing Enhancements (FS_RSE)

| ID | WBS | Task | Duration | Start | Finish | Complete | Remaining | Baseline start | Baseline finish | Baseline duration | Total slack | Constraint | Resources | Work | Actual work | Acronym | PCG approved | WI rapporteur name | Release | TSG approved | MCC resp | Acronym_3GU_Export | PCG stopped | TSG stopped | Special Focus Doc | Status Report |
| --- | --- | --- | --- | --- | --- | --- | --- | --- | --- | --- | --- | --- | --- | --- | --- | --- | --- | --- | --- | --- | --- | --- | --- | --- | --- | --- |
| 1500 | 383 | **Study on Usage Monitoring Enhancements for Service, Application and Subscriber Group** | 934d? | 2011-06-08 A | 2014-12-12 A | 100% |  | 2011-06-08 | 2014-12-10 | 929d? |  |  | S2 | 13978.1h | 13978.1h | FS_UMONC_sas | PCG-27 | China Telecom | Rel-13 | SP-52 | Maurice | FS_UMONC_sas |  |  |  |  |
| 1501 | 383.1 | Deleted - SA1 part of Study on Usage Monitoring Control PCC Enhancement | 275d? | 2011-06-08 A | 2012-06-20 A | 100% |  | 2011-06-08 | 2012-06-20 | 275d? |  | finish no earlier than 2012-06-20 | S1 | 2200h | 2200h |  | PCG-27 | ZTE |  | SP-52 | Maurice | FS_UMONC | PCG-31 | SP-58 |  |  |
| 1502 | 383.2 | SA2 part of Study on Usage Monitoring Control PCC Enhancement | 397.26d? | 2013-06-14 A | 2014-12-12 A | 100% |  | 2013-06-02 | 2014-12-10 | 403d? |  | finish no earlier than 2014-12-12 | S2 | 3178.08h | 3178.08h | FS_UMONC_sas | PCG-27 | China Telecom | Rel-13 | SP-52 | Maurice |  |  |  |  |  |
| 1503 | 383.3 | Deleted - SA5 part of Study on Usage Monitoring Control enhancement | 141d? | 2012-03-02 A | 2012-09-12 A | 100% |  | 2012-03-02 | 2012-09-12 | 141d? |  | finish no earlier than 2012-09-12 | S5 | 1128h | 1128h |  | PCG-27 | Huawei |  | SP-52 | Mirko |  | PCG-29 | SP-57 |  |  |
| 1504 | 384 | Study on Security aspects of Integration of Single Sign-On (SSO) frameworks with 3GPP networks | 1180d? | 2010-12-28 A | 2015-06-12 A | 100% |  | 2010-12-16 | 2014-09-17 | 988d? |  | finish no earlier than 2015-06-12 | S3 | 9440h | 9440h | FS_SSO_Int_Sec | PCG-26 | Ericsson | Rel-13 | SP-50 | Mirko | FS_SSO_Int_Sec |  |  |  |  |
| 1505 | 385 | Study on Subscriber Privacy Impact in 3GPP | 591d? | 2013-09-17 A | 2015-12-16 A | 100% |  | 2013-09-12 | 2014-09-17 | 266d? |  | finish no earlier than 2015-12-16 | S3 | 4728h | 4728h | FS_SPI | PCG-31 | China Unicom | Rel-13 | SP-61 | Mirko | FS_SPI |  |  |  |  |
| 1506 | 386 | Study on Enhancements of OAM aspects of Distributed Mobility Load Balancing (MLB) SON function | 458d? | 2014-09-15 A | 2016-06-13 A | 100% |  | 2013-09-12 | 2014-12-10 | 326d? |  | finish no earlier than 2016-06-13 | S5 | 3664h | 3664h | FS_D_MLB_SON_OAM | PCG-31 | Cisco | Rel-13 | SP-61 | Mirko | FS_D_MLB_SON_OAM |  |  | SON |  |
| 1507 | 387 | Study on Application and Partitioning of Itf-N | 458d? | 2013-12-17 A | 2015-09-11 A | 100% |  | 2013-12-11 | 2014-12-10 | 261d? |  | finish no earlier than 2015-09-11 | S5 | 3664h | 3664h | FS_OAM_AP_Itf-N | PCG-32 | China Mobile | Rel-13 | SP-62 | Mirko | FS_OAM_AP_Itf-N |  |  |  |  |
| 1508 | 388 | Study on Charging aspects on Roaming End-to-end scenarios with VoLTE IMS and interconnecting networks | 393d? | 2013-12-17 A | 2015-06-12 A | 100% |  | 2013-12-11 | 2014-12-10 | 261d? |  | finish no earlier than 2015-06-12 | S5 | 3144h | 3144h | FS_REVOLTE_IMS_CH | PCG-32 | Deutsche Telekom | Rel-13 | SP-62 | Mirko | FS_REVOLTE_IMS_CH |  |  |  |  |
| 1509 | 389 | Study on Network Management of Virtualized Networks | 269d? | 2014-06-11 A | 2015-06-17 A | 100% |  | 2014-06-06 | 2015-06-17 | 269d? |  | finish no earlier than 2015-06-17 | S5 | 2152h | 2152h | FS_OAM_VIRNET | PCG-33 | China Mobile, Huawei | Rel-13 | SP-64 |  | FS_OAM_VIRNET |  |  |  |  |
| 1510 | 390 | Study on Review of dedicated 3GPP UICC features | 729d? | 2013-03-13 A | 2015-12-16 A | 100% |  | 2013-03-04 | 2014-09-12 | 401d? |  | finish no earlier than 2015-12-16 | C6 | 5832h | 5832h | FS_Red_UCe | PCG-30 | BlackBerry | Rel-13 | CP-59 | Xavier | FS_Red_UCe |  |  |  |  |
| 1511 | 391 | Study on Solutions for GSM/EDGE BTS Energy Saving | 458.8d? | 2011-08-30 A | 2015-11-20 A | 100% |  | 2009-03-10 | 2014-08-29 | 557d? |  | finish no earlier than 2015-11-20 | G1; G2 | 3670.4h | 3670.4h | FS_Energy_BTS | PCG-25 | Nokia Networks | Rel-13 | GP-47 | Paolo | FS_Energy_BTS |  |  |  |  |
| 1512 | 392 | Study on Downlink MIMO | 459d? | 2014-08-14 A | 2016-05-12 | 75% | 114.75d? | 2013-08-20 | 2015-02-20 | 396d? | 681d | finish no earlier than 2016-05-12 | G1; G2 | 4004.8h | 3086.8h | FS_DOMIMO | PCG-30 | Nokia Networks | Rel-13 | GP-57 | Paolo | FS_DOMIMO |  |  |  |  |
| 1513 | 393 | Study on MIMO OTA antenna test function for LTE | 462d? | 2013-03-18 A | 2014-12-15 A | 100% |  | 2013-03-15 | 2014-12-05 | 456d? |  | finish no earlier than 2014-12-15 | R4 | 3696h | 3696h | FS_LTE_MIMO_OTA_ATF | PCG-33 | Keysight | Rel-13 | RP-64 |  | FS_LTE_MIMO_OTA_ATF |  |  |  | RP-142045 |
| 1514 | 394 | Stopped at 20% - Study on UpLink MultiUser Multiple-Input Multiple-Output (UL MU-MIMO) | 481.6d? | 2014-04-17 A | 2016-02-19 A | 100% |  | 2014-04-17 | 2015-02-20 | 195.5d? |  | finish no earlier than 2016-02-19 | G1; G2 | 5688h | 5688h | FS_UL_MU_MIMO | PCG-32 | Huawei | Rel-13 | GP-60 |  | FS_UL_MU_MIMO |  | SP#71 |  |  |
| 1515 | 395 | Study on LTE FDD in the bands 1980-2010 MHz and 2170-2200 MHz | 854d? | 2012-09-11 A | 2015-12-15 A | 100% |  | 2012-09-11 | 2014-09-12 | 527d? |  | finish no earlier than 2015-12-15 | R4 | 6832h | 6832h | FS_LTE_1980_2170_Korea | PCG-29 | KT | Rel-13 | RP-57 | Issam | FS_LTE_1980_2170_Korea |  |  |  | RP-151274 |
| 1516 | 396 | Study on Positioning enhancements for E-UTRA | 524d? | 2012-05-01 A | 2014-12-15 A | 100% |  | 2013-04-25 | 2014-12-05 | 256d? |  | finish no earlier than 2014-12-15 | R4 | 4192h | 4192h | FS_LCSenh_LTE | PCG-31 | Huawei | Rel-13 | RP-60 | Issam | FS_LCSenh_LTE |  |  |  | RP-142224 |
| 1517 | 397 | Study on Multi-RAT joint coordination | 397d? | 2013-12-06 A | 2015-06-15 A | 100% |  | 2013-12-06 | 2014-12-05 | 261d? |  | finish no earlier than 2015-06-15 | R4 | 3176h | 3176h | FS_MultiRAT_JC | PCG-32 | China Mobile | Rel-13 | RP-62 | Juha | FS_MultiRAT_JC |  |  | WLAN | RP-150807 |
| 1518 | 398 | Study on Advanced Wireless Services (AWS) - Extension band for LTE | 265d? | 2013-12-16 A | 2014-12-15 A | 100% |  | 2013-12-09 | 2014-12-05 | 261d? |  | finish no earlier than 2014-12-15 | R4 | 2120h | 2120h | FS_LTE_AWS_EXT | PCG-33 | Qualcomm | Rel-13 | RP-64 |  | FS_LTE_AWS_EXT |  |  |  | RP-141968 |
| 1519 | 399 | Study on Indoor Positioning Enhancements for UTRA and LTE | 328d? | 2014-06-18 A | 2015-09-15 A | 100% |  | 2014-06-13 | 2015-09-17 | 330d? |  | finish no earlier than 2015-09-15 | R1; R4 | 5248h | 5248h | FS_UTRA_LTE_iPos_enh | PCG-33 | NextNav | Rel-13 | RP-64 |  | FS_UTRA_LTE_iPos_enh |  |  |  | RP-151178 |
| 1520 | 400 | Study on Downlink enhancements for UMTS | 199d? | 2014-09-12 A | 2015-06-15 A | 100% |  |  |  |  |  | finish no earlier than 2015-06-15 | R2; R1 | 3184h | 3184h | FS_UTRA_EDL | PCG-33 | Huawei | Rel-13 | RP-65 |  | FS_UTRA_EDL |  |  |  | RP-150681 |
| 1521 | 401 | Study on Elevation Beamforming/Full-Dimension (FD) MIMO for LTE | 199d? | 2014-09-12 A | 2015-06-15 A | 100% |  |  |  |  |  | finish no earlier than 2015-06-15 | R1 | 1592h | 1592h | FS_LTE_EBF_FDMIMO | PCG-33 | Nokia Networks (DL), Samsung (UL) | Rel-13 | RP-65 |  | FS_LTE_EBF_FDMIMO |  |  |  | RP-150734 |
| 1522 | 402 | Study on Licensed-Assisted Access using LTE | 197d? | 2014-09-16 A | 2015-06-15 A | 100% |  |  |  |  |  | finish no earlier than 2015-06-15 | R1; R2; R4 | 4728h | 4728h | FS_LTE_LAA | PCG-33 | Ericsson, Huawei | Rel-13 | RP-65 |  | FS_LTE_LAA |  |  |  | RP-150624 |
| 1523 | 403 | Study on EPC Signalling Improvement for Race Scenarios | 203d? | 2014-12-03 A | 2015-09-11 A | 100% |  |  |  |  |  | finish no earlier than 2015-09-11 | C4 | 1624h | 1624h | FS_EPC_SIG_RACE | PCG-34 | Huawei | Rel-13 | CT-66 |  |  |  |  |  |  |
| 1524 | 404 | Study on Video Enhancements in 3GPP Multimedia Services | 261d? | 2014-12-12 A | 2015-12-11 A | 100% |  |  |  |  |  | finish no earlier than 2015-12-11 | S4 | 2088h | 2088h | FS_VE_3MS | PCG-34 | Ye-Kui Wang, Qualcomm Incorporated | Rel-13 | SP-66 |  |  |  |  |  |  |
| 1525 | 405 | Study on possible additional configuration for LTE TDD | 197d? | 2014-12-15 A | 2015-09-15 A | 100% |  |  |  |  |  | finish no earlier than 2015-09-15 | R4 | 1576h | 1576h | FS_LTE_TDD_add_config | PCG-34 | NTT DOCOMO, Hideaki Takahashi | Rel-13 | RP-66 |  |  |  |  |  | RP-151283 |
| 1526 | 406 | Study on Network-Assisted Interference Cancellation and Suppression for UMTS | 197d? | 2014-12-15 A | 2015-09-15 A | 100% |  |  |  |  |  | finish no earlier than 2015-09-15 | R1 | 1576h | 1576h | FS_UTRA_NAICS | PCG-34 | Huawei | Rel-13 | RP-66 |  |  |  |  |  | RP-151235 |
| 1527 | 407 | Study on Enhanced Multiuser Transmissions and Network Assisted Interference Cancellation for LTE | 65d? | 2014-12-15 | 2015-03-15 |  |  |  |  |  | 985d | finish no earlier than 2015-03-15 | R1 | 520h |  | FS_LTE_MUTX_NAIC | PCG-34 | MediaTek | Rel-13 | RP-66 |  |  |  |  |  | RP-150213 |
| 1528 | 408 | Study on Support of single-cell point-to-multipoint transmission in LTE | 131d? | 2014-12-15 A | 2015-06-15 A | 100% |  |  |  |  |  | finish no earlier than 2015-06-15 | R4 | 1048h | 1048h | FS_LTE_SC_PTM | PCG-34 | Jeff GAO | Rel-13 | RP-66 |  |  |  |  |  | RP-150695 |
| 1529 | 409 | Study on Extension of Dual Connectivity in E-UTRAN | 131d? | 2014-12-15 A | 2015-06-15 A | 100% |  |  |  |  |  | finish no earlier than 2015-06-15 | R3 | 1048h | 1048h | FS_LTE_dualC_ext | PCG-34 | Samsung | Rel-13 | RP-66 |  |  |  |  |  | RP-150849 |
| 1530 | 410 | Study on further enhancements of small cell higher layer aspects for LTE | 197d? | 2014-12-15 A | 2015-09-15 A | 100% |  |  |  |  |  | finish no earlier than 2015-09-15 | R3 | 1576h | 1576h | FS_LTE_SC_enh2_hilayer | PCG-34 | Huawei | Rel-13 | RP-66 |  |  |  |  |  | RP-151243 |
| 1531 | 411 | Study on RAN sharing enhancements for UMTS | 131d? | 2014-12-15 A | 2015-06-15 A | 100% |  |  |  |  |  | finish no earlier than 2015-06-15 | R3 | 1048h | 1048h | FS_RSE_UTRA_GUSH | PCG-34 | Huawei | Rel-13 | RP-66 |  |  |  |  |  | RP-150684 |
| 1532 | 412 | Study on LTE DL 4 Rx antenna ports | 65d? | 2014-12-15 A | 2015-03-15 A | 100% |  |  |  |  |  | finish no earlier than 2015-03-15 | R4 | 520h | 520h | FS_LTE_4Rx_AP_DL | PCG-34 | Ericsson | Rel-13 | RP-66 |  |  |  |  |  | RP-150138 |
| 1533 | 413 | Study on performance enhancements for high speed scenario in LTE | 262d? | 2014-12-15 A | 2015-12-15 A | 100% |  |  |  |  |  | finish no earlier than 2015-12-15 | R4 | 2096h | 2096h | FS_LTE_high_speed | PCG-34 | NTTDoCoMo | Rel-13 | RP-66 |  |  |  |  |  | RP-151313 |
| 1534 | 414 | Study on Enhanced Multiuser Transmissions and Network | 261d? | 2014-12-12 | 2015-12-11 |  |  |  |  |  | 790d | finish no earlier than 2015-12-11 | R1 | 2088h |  | FS_MUIC_LTE | PCG-34 | Pei-Kai Liao | Rel-13 | SP-67 |  |  |  |  |  |  |
| 1535 | 415 | Study on regulatory aspects for flexible duplex for E-UTRAN | 133d? | 2016-06-15 A | 2016-12-15 | 99% | 1d? |  |  |  | 525d |  | RP | 1064h | 1056h | FS_LTE_flex_duplex_reg | PCG-34 | LG Electronics Inc. | Rel-13 | RP-67 |  |  |  |  |  | RP-151307 |
| 1536 | 416 | Study on Downlink Multiuser Superposition Transmission for LTE | 197d? | 2015-03-16 A | 2015-12-15 A | 100% |  |  |  |  |  | finish no earlier than 2015-12-15 | R1 | 1576h | 1576h | FS_LTE_MUST | PCG-34 | Mediatek | Rel-13 | RP-67 |  |  |  |  |  | RP-151345 |
| 1537 | 417 | Study on Measurement gap enhancement for LTE | 197d? | 2015-03-16 A | 2015-12-15 A | 100% |  |  |  |  |  | finish no earlier than 2015-12-15 | R4 | 1576h | 1576h | FS_LTE_meas_gap |  |  | Rel-13 | TSG-67 |  |  |  |  |  | RP-151317 |
| 1538 | 418 | Study on Phase 1 of the Support of Emergency services over WLAN | 71d? | 2015-03-12 A | 2015-06-18 A | 100% |  |  |  |  |  | finish no earlier than 2015-06-18 | S2 | 568h | 568h | FS_SEW | PCG-34 | Laurent Thiebaut, Alcatel Lucent | Rel-13 | SP-67 |  |  |  |  |  |  |
| 1539 | 419 | Study on EGPRS Access Security Enhancements with relation to cellular IoT | 197d? | 2015-03-12 A | 2015-12-11 A | 100% |  |  |  |  |  | finish no earlier than 2015-12-11 | S3 | 1576h | 1576h | FS_EASE_IoT | PCG-34 | Vesa Torvinen, Ericsson | Rel-13 | SP-67 |  |  |  |  |  |  |
| 1540 | 420 | Study on SCC AS Restoration | 1d? | 2015-06-15 A | 2015-06-15 A | 100% |  |  |  |  |  | start no earlier than 2015-06-15 | C4 | 8h | 8h | FS_SCCAS_RES | PCG-35 | Hao Zhang,, China Mobile | Rel-13 | CP-68 |  |  |  |  |  |  |
| 1541 | 421 | Study on S6a/S6d Shared Data Update | 130d? | 2015-06-15 A | 2015-12-11 A | 100% |  |  |  |  |  | finish no earlier than 2015-12-11 | C4 | 1040h | 1040h | FS_eSDU | PCG-35 | Ulrich Wiehe, Nokia Networks | Rel-13 | CP-68 |  |  |  |  |  |  |
| 1542 | 422 | Study on Network Assistance for Network Synchronization in LTE | 395d? | 2015-06-15 A | 2016-12-15 A | 100% |  |  |  |  |  | finish no earlier than 2016-12-15 | R3 | 3160h | 3160h | FS_LTE_NW_SYNC | PCG-35 | Huawei | Rel-14 | TSG-68 |  |  |  |  |  |  |
| 1543 | 423 | Study on LTE Advanced inter-band Carrier Aggregation of Band 20 and Band 28 | 132d? | 2015-06-15 A | 2015-12-15 A | 100% |  |  |  |  |  | finish no earlier than 2015-12-15 | R4 | 1056h | 1056h | FS_LTE_CA_B20_B28 | PCG-35 | TeliaSonera | Rel-13 | TSG-68 |  |  |  |  |  | RP-151231 |
| 1544 | 424 | Study on Impacts of the Diameter Base Protocol Specification Update | 75d? | 2015-09-07 A | 2015-12-18 A | 100% |  |  |  |  |  | finish no earlier than 2015-12-18 | C4 | 600h | 600h | FS_DBPU | PCG-35 | Huawei, Peter Schmitt | Rel-13 | SP-69 |  |  |  |  |  |  |
| 1545 | 425 | Study on new AWS-3/4 Band for LTE | 66d? | 2015-09-15 A | 2015-12-15 A | 100% |  |  |  |  |  | finish no earlier than 2015-12-15 | R4 | 528h | 528h | FS_LTE_AWS_3_4 | PCG-35 | Dish Network | Rel-13 | RP-69 |  |  |  |  |  |  |
| 1546 | 426 | Study on multi-node testing for LAA | 263d? | 2016-06-15 A | 2017-06-15 | 30% | 184.1d? |  |  |  | 395d | finish no earlier than 2017-06-15 | R4 | 2104h | 631.2h | FS_LTE_LAA_multinode_test | PCG-37 | Huawei | Rel-13 | TSG#72 |  |  |  |  |  |  |
| 1547 | 427 | Release 12 Features | 306d? | 2013-10-14 A | 2014-12-12 A | 100% |  | 2013-10-14 | 2014-12-10 | 304d? |  | finish no earlier than 2014-12-12 | SP; CP; RP; GP | 9792h | 9792h |  |  |  | Rel-12 |  |  |  |  |  |  |  |
| 1548 | 428 | Stage 1 - ONLY Features | 647d? | 2011-09-27 A | 2014-03-05 A | 100% |  | 2011-09-27 | 2014-03-05 | 647d? |  | start no earlier than 2011-09-27 | SP; CP | 10352h | 10352h |  | PCG-30 |  | Rel-12 | SP-58 |  |  |  |  |  |  |

Notes:
- 1500: SP#64 revived. Added to the Title "for Service, Application and Subscriber Group", Changed Acronym: FS_UMONC=>FS_UMONC_sas / Impacted TSs and TRs: 23.858 / WI rapporteur e-mail: Jinyan Li (lijy@ctbri.com.cn)
- 1501: SP#56 completed / Impacted TSs and TRs: 23.858 / WI rapporteur e-mail: Li.Mian@zte.com.cn
- 1502: SP#64 revived. Updated WID SP-120554=>SP-140403. Changed Justification/objectives/Rapporteut ZTE=>China Unciom. SP#58 SA2 stopped (at 70% completion). Dec.14: 80->100%. Mar 15: WID SP-140403->SP-150029 / Impacted TSs and TRs: 23.858 / WI rapporteur e-mail: Jinyan Li (lijy@ctbri.com.cn)
- 1503: SP#57 stopped / Impacted TSs and TRs: 32.858 / WI rapporteur e-mail: Hui Cai (Sarah.Cai@huawei.com)
- 1504: SP#65 moved to Rel-13. Updated WID SP-100734=>SP-140576. Completion 09/14=>06/15. Dec.14: 60->65%; June2015: Compl:65%->100; June2015: WID:SP-140576->SP-150368 / Impacted TSs and TRs: 33.895 / WI rapporteur e-mail: vesa.lehtovirta@ericsson.com
- 1505: SP#65 moved to Rel-13. Completion 09/14=>12/15. Related to SA1 TR 22.949 Rel-6 Study on Privacy Capability (PrivCap) UID_31030 studied generalized privacy capability (protection of personal data and non-disclosure of identity). Dec.14: 80->85; June2015 / Impacted TSs and TRs: 33.849 / WI rapporteur e-mail: Feng Gao (gaofeng149@chinaunicom.cn)
- 1506: SP#64 completion 06/14=>12/14. Dec.14: 20->25%, CD: 12/14->06/15; June2015: Compl:25%->30; 7/12/15: 30%->45; 7/3/16: 45%->50; 13/6/16: 50%->100 / Impacted TSs and TRs: 32.860 / WI rapporteur e-mail: Vladimir Yanover (vyanover@cisco.com)
- 1507: -Dec.14: 15->30%, CD: 12/14->09/15; June2015: Compl:30%->60; 07/09/15: 60%->100 / Impacted TSs and TRs: 32.861 / WI rapporteur e-mail: Li Jian (lijian@chinamobile.com), Hu Yaxi (huyaxi@cmdi.chinamobile.com)
- 1508: SP#64 moved to Rel-13. Completion 06/14=>12/14. Dec.14: 35->55, CD: 12/14->06/15. Mar 15: 55->75%; June2015: Compl:75%->100 / Impacted TSs and TRs: 32.849 / WI rapporteur e-mail: Roland Jesske (r.jesske@telekom.de)
- 1509: Dec.14: 10->25%. Mar 15: 25->60%; June2015: Compl:60%->85; 07/09/15: 85%->100 / Impacted TSs and TRs: 32.842 / WI rapporteur e-mail: Liu Jinglei (liujinglei@chinamobile.com), zoulan@huawei.com
- 1510: CP#65 TR 31.901v100 for Information. Moved to Rel-13. Completion 09/14=>12/15. Waiting for feedback from external organizations (PTCRB/PVG). Dec.14: 65->100% / Impacted TSs and TRs: 31.901 / WI rapporteur e-mail: Adrian Buckley (abuckley@blackberry.com)
- 1511: GP#63 moved to Rel-13. Completion 08/14=>11/14. GP#55 TR 45.926v100 for Information. GP#47 approved WID. Dec.14: 90->95%. 3/3/15: start date corrected (was 03/09). 7/9/15: FCD: 8/15->11/15; 7/12/15: 95%->100 / Impacted TSs and TRs: 45.926 / WI rapporteur e-mail: juergen.hofmann@nokia.com
- 1512: GP#62 completion 08/14=>02/15. Moved to Rel-13. GP#57 approved WID. Dec.14: 50->65%, CD: 02/15->05/15. 7/9/15: FCD: 11/15->02/16; 2/3/16: 65%->75, FCD: 02/16->05/16 / Impacted TSs and TRs: 45.8xy / WI rapporteur e-mail: juergen.hofmann@nokia.com
- 1513: CD:Thu 11/12/14->Mon 15/12/14; Compl:60%->100%; Stat Rep: RP-141124->RP-142045 / Impacted TSs and TRs: 36.509, new TR 37.978 / WI rapporteur e-mail: Moray_Rumney@keysight.com
- 1514: GP#62 completion 11/14=>02/15. GP#60 approved WID. Dec.14: 02/15->05/15. 02/03/16: stopped at 20% / Impacted TSs and TRs: 45.876 / WI rapporteur e-mail: Chao Luo (chluo@huawei.com)
- 1515: CD:Thu 11/12/14->Sun 15/03/15; Compl:85%->90%; Stat Rep: RP-141153->RP-141851 1st Apr 15: CD:Sun 15/03/15->Mon 15/06/15 1st Apr 15: WID: RP-141154->RP-150119 1st Apr 15: Stat Rep: RP-141851->RP-150120 03/07/15: CD:Mon 15/06/15->Tue 15/09/15 03/07/15: S / Impacted TSs and TRs: LTE 36.861 / WI rapporteur e-mail: Chungwoo HWANG (cwhwang@kt.com)
- 1516: WID: RP-140667->RP-130680; Stat Rep: RP-140639->RP-142224. 3/3/15: R1 removed as 2nd responsible WG / Impacted TSs and TRs: LTE 36.855 / WI rapporteur e-mail: Jie Cui (cuijie@huawei.com)
- 1517: ; WID: RP-142043->RP-132086; Stat Rep: RP-141301->RP-141838 1st Apr 15: Compl:55%->85% 1st Apr 15: WID: RP-132086->RP-150417 1st Apr 15: Stat Rep: RP-141838->RP-150187 03/07/15: Compl:85%->100% 03/07/15: Stat Rep: RP-150187->RP-150807 / Impacted TSs and TRs: UTRA, LTE 37.870 / WI rapporteur e-mail: Kimba Dit Adamou, Boubacar (jinba@chinamobile.com)
- 1518: CD:Thu 11/12/14->Mon 15/12/14; Compl:10%->100%; Stat Rep: RP-141429->RP-141968. 5/5/15: 2nd TR number added (to be clarified why two TR for a same topic) / Impacted TSs and TRs: 36.849, 36.869 / WI rapporteur e-mail: Gene Fong (gfong@qti.qualcomm.com)
- 1519: CD:Thu 17/09/15->Tue 15/09/15; Compl:0%->8%; Stat Rep: RP-141101->RP-141818 1st Apr 15: Compl:8%->30% 1st Apr 15: Stat Rep: RP-141818->RP-150080 03/07/15: Compl:30%->75% 03/07/15: Stat Rep: RP-150080->RP-150595 29/09/15: Compl:75%->100% 29/09/15: Stat / Impacted TSs and TRs: UTRA, LTE 37.857 / WI rapporteur e-mail: Vogedes Jerome (jvogedes@NextNav.com)
- 1520: WID: RP-141901; Stat Rep: -->RP-142233 1st Apr 15: Compl:40%->80% 1st Apr 15: WID: RP-141901->RP-150224 1st Apr 15: Stat Rep: RP-142233->RP-150223. 5/5/15: R4 replaced by R1 (correction mistake) 03/07/15: Compl:80%->100% 03/07/15: Stat Rep: RP-150223-> / Impacted TSs and TRs: UTRA TR 25.706 / WI rapporteur e-mail: jun.chen@huawei.com
- 1521: 3/3/15: WID: RP-141831; Stat Rep: -->RP-141822, impacted TR number added. 1st Apr 15: Compl:30%->45% 1st Apr 15: Stat Rep: RP-141822->RP-150346. 5/5/15: "R4" replaced by "R1" (correction mistake) 03/07/15: Compl:45%->100% 03/07/15: WID: RP-141831->RP-1 / Impacted TSs and TRs: 36.897 / WI rapporteur e-mail: bishwarup.mondal@nsn.com, hyoungju.ji@samsung.com
- 1522: 3/3/15: WID: RP-141817; Stat Rep: -->RP-141816. Impacted TR number added. 1st Apr 15: Compl:30%->40% 1st Apr 15: Stat Rep: RP-141816->RP-150414 03/07/15: Compl:40%->100% 03/07/15: Stat Rep: RP-150414->RP-150624 / Impacted TSs and TRs: 36.889 / WI rapporteur e-mail: havish.koorapaty@ericsson.com, david.mazzarese@huawei.com
- 1523: Mar15: 0->20%; June2015: Compl:20%->80; 07/09/15: 80%->95; 7/12/15: 95%->100 / Impacted TSs and TRs: New TR 29.811
- 1524: Mar. 15: 0->20%; June2015: Compl:20%->40; 07/09/15: 40%->80; 7/12/15: 80%->100 / WI rapporteur e-mail: yekuiw@qti.qualcomm.com
- 1525: TR 36.825 rapporteur: CATT. TR number added. 1st Apr 15: Compl:0%->5% 1st Apr 15: Stat Rep: ->RP-150151 03/07/15: Compl:5%->35% 03/07/15: WID: RP-142248->RP-150652 03/07/15: Stat Rep: RP-150151->RP-150805 29/09/15: Compl:35%->100% 29/09/15: Stat Rep: R / Impacted TSs and TRs: 36.825 / WI rapporteur e-mail: NTT DOCOMO
- 1526: TS number added 1st Apr 15: Compl:0%->20% 1st Apr 15: WID: RP-142250->RP-150174 1st Apr 15: Stat Rep: ->RP-150175. 5/5/15: "R4" replaced by "R1" (correction mistake) 03/07/15: Compl:20%->65% 03/07/15: Stat Rep: RP-150175->RP-150679 29/09/15: Compl:65%- / Impacted TSs and TRs: 25.766 / WI rapporteur e-mail: Huawei
- 1527: 1st Apr 15: CD:Tue 15/12/15->Sun 15/03/15 1st Apr 15: Stat Rep: ->RP-150213. 5/5/15: "R4" replaced by "R1" (correction mistake) / WI rapporteur e-mail: MediaTek
- 1528: deleted 660062 (duplicated). 29/1: TR number added 1st Apr 15: Compl:0%->25% 1st Apr 15: WID: RP-142205->RP-150177 1st Apr 15: Stat Rep: ->RP-150176 03/07/15: Compl:25%->100% 03/07/15: Stat Rep: RP-150176->RP-150695 / Impacted TSs and TRs: TR 36.890 / WI rapporteur e-mail: gaoyongqiang@huawei.com
- 1529: 1st Apr 15: WID: RP-142257->RP-150170 1st Apr 15: Stat Rep: ->RP-150163 03/07/15: Compl:85%->100% 03/07/15: Stat Rep: RP-150163->RP-150849. 7/10/15: responsible group corrected (R4->R3) / Impacted TSs and TRs: 36.875 / WI rapporteur e-mail: Samsung
- 1530: 03/07/15: Compl:10%->30% 03/07/15: Stat Rep: RP-150226->RP-150683 29/09/15: Compl:30%->100% 29/09/15: Stat Rep: RP-150683->RP-151243. 7/10/15: responsible group corrected (R4->R3) and TS (37.876->36.876) / Impacted TSs and TRs: 36.876 / WI rapporteur e-mail: Huawei
- 1531: 03/07/15: Compl:10%->100% 03/07/15: WID: RP-142284->RP-150686 03/07/15: Stat Rep: RP-150227->RP-150684. 7/10/15: responsible group corrected (R4->R3) / Impacted TSs and TRs: 25.756 / WI rapporteur e-mail: Huawei
- 1532: 1st Apr 15: Compl:0%->100% 1st Apr 15: WID: RP-142299->RP-150457 1st Apr 15: Stat Rep: ->RP-150138 / WI rapporteur e-mail: Ericsson
- 1533: TR Rapporteur is Huawei 1st Apr 15: Compl:0%->5% 1st Apr 15: WID: RP-142307->RP-150159 1st Apr 15: Stat Rep: ->RP-150517 03/07/15: Compl:5%->40% 03/07/15: Stat Rep: RP-150517->RP-150793 29/09/15: Compl:40%->80% 29/09/15: CD:Tue 15/09/15->Tue 15/12/15 2 / WI rapporteur e-mail: NTTDoCoMo
- 1534: TR added / Impacted TSs and TRs: 36.891 / WI rapporteur e-mail: pk.liao@mediatek.com
- 1535: TR added 03/07/15: Compl:0%->5% 03/07/15: Stat Rep: -->RP-150770 29/09/15: Compl:5%->100% 29/09/15: Stat Rep: RP-150770->RP-151307 / Impacted TSs and TRs: 36.882
- 1536: TR added 03/07/15: Compl:0%->30% 03/07/15: WID: RP-150496->RP-151100 03/07/15: Stat Rep: -->RP-150857 29/09/15: Compl:30%->50% 29/09/15: Stat Rep: RP-150857->RP-151345 / Impacted TSs and TRs: 36.859
- 1537: 03/07/15: Compl:0%->15% 03/07/15: CD:Thu 10/12/15->Tue 15/12/15 03/07/15: Stat Rep: ->RP-150754 03/07/15: Release: REL-13->Rel-13. Aug 15: TR numb added 29/09/15: Compl:15%->65% 29/09/15: Stat Rep: RP-150754->RP-151317 / Impacted TSs and TRs: 36.894
- 1538: June2015: Compl:0%->100, SP-150151->SP-150251 / Impacted TSs and TRs: new 23.771 / WI rapporteur e-mail: Laurent.thiebaut@alcatel-lucent.com
- 1539: TR added; June2015: Compl:0%->25; 7/12/15: 25%->70; 28/1/16: 33.420 added; 7/3/16: 70%->100 / Impacted TSs and TRs: New 33.860; 33.420
- 1540: 07/09/15: 5%->20; 7/12/15: 20%->100 / Impacted TSs and TRs: New 29.812 / WI rapporteur e-mail: zhanghao@chinamobile.com
- 1541: 07/09/15: 0%->20; 7/12/15: 20%->100 / Impacted TSs and TRs: New 29.813 / WI rapporteur e-mail: ulrich.wiehe@nokia.com
- 1542: Aug 15: TR numb added 29/09/15: Compl:0%->15% 29/09/15: WID: RP-151084->RP-151252 29/09/15: Stat Rep: -->RP-151240 22/3/16: Compl:60%->80%; 22/3/16: CD:Tue 15/03/16->Wed 15/06/16; ; / Impacted TSs and TRs: New 36.898
- 1543: 29/09/15: Compl:0%->20% 29/09/15: WID: RP-151101->RP-151515 29/09/15: Stat Rep: -->RP-151231
- 1544: 7/3/16: 0%->79; 13/6/16: 79%->99; 2/12/16: 99%->100 / Impacted TSs and TRs: 29.274, 29.060, 23.003, 29.272, 29.002, 29.305, 23.008, 29.230, 29.303, 23.007, 24.301, 24.008
- 1545: Impacted TSs and TRs: 36.870
- 1546: coexistence testing for REL-13 WI LTE_LAA26/9/16: Compl:0%->10%26/9/16: WID: RP-161197->RP-161672; 20/12/16: Compl:10%->30%; 20/12/16: CD:Thu 15/12/16->Wed 15/03/17; 20/12/16: WID: RP-161672->RP-162144; 21/3/17: CD:Wed 15/03/17->Thu 15/06/17
- 1547: -
- 1548: -

| ID | WBS | Task | Duration | Start | Finish | Complete | Baseline start | Baseline finish | Baseline duration | Constraint | Resources | Work | Actual work | Acronym | PCG approved | Impacted TSs and TRs | WI rapporteur name | WI rapporteur e-mail | Release | TSG approved | MCC resp | Special Focus Doc | Acronym_3GU_Export | PCG stopped | TSG stopped |
| --- | --- | --- | --- | --- | --- | --- | --- | --- | --- | --- | --- | --- | --- | --- | --- | --- | --- | --- | --- | --- | --- | --- | --- | --- | --- |
| 1549 | 429 | **SIPTO Service Continuity of IP Data Session** | 262d? | 2010-09-23 A | 2011-09-21 A | 100% | 2010-09-23 | 2011-09-21 | 262d? |  | S1 | 4176h | 4176h | SIPTO_SC | PCG-25 | Stage 1 | Vodafone | mona.mustapha@vodafone.com | Rel-12 | SP-49 | Alain | HNB | SIPTO_SC |  |  |
| 1550 | 429.1 | Stage 1 for SIPTO Service Continuity of IP Data Session | 262d? | 2010-09-23 A | 2011-09-21 A | 100% | 2010-09-23 | 2011-09-21 | 262d? | finish no earlier than 2011-09-21 | S1 | 2080h | 2080h | SIPTO_SC-SA1 | PCG-25 | 22.101, 22.220 | Vodafone | mona.mustapha@vodafone.com | Rel-12 | SP-49 | Alain | HNB |  |  |  |
| 1551 | 430 | **Interworking between Mobile Operators using the Evolved Packet System and Data Application Providers** | 792d? | 2010-12-16 A | 2013-12-11 A | 100% | 2010-12-16 | 2013-12-11 | 792d? |  | S1; S2 | 22794.7h | 22794.7h | MOSAP | PCG-26 | Stage 1 | Cisco | Vojislav Vucetic (vvucetic@cisco.com) | Rel-12 | SP-50 | Alain |  | MOSAP |  |  |
| 1552 | 430.1 | Stage 1 for MOSAP | 202d? | 2010-12-16 A | 2011-09-21 A | 100% | 2010-12-16 | 2011-09-21 | 202d? | finish no earlier than 2011-09-21 | S1 | 1600h | 1600h | MOSAP-SA1 | PCG-26 | 22.278 | Cisco | Vojislav Vucetic (vvucetic@cisco.com) | Rel-12 | SP-50 | Alain |  |  |  |  |
| 1553 | 430.2 | TR on Stage 2 for MOSAP | 669d? | 2011-06-06 A | 2013-12-11 A | 100% | 2011-06-06 | 2013-12-11 | 669d? | finish no earlier than 2012-12-12 | S2 | 5338.74h | 5338.74h | MOSAP-SA2TR | PCG-27 | new TR 23.862 | Intel | chang.hong.shan@intel.com | Rel-12 | SP-52 | Maurice |  |  |  |  |
| 1554 | 430.3 | Deleted - Stage 2 for MOSAP | 399d? | 2011-06-14 A | 2012-12-12 A | 100% | 2011-06-14 | 2012-12-12 | 399d? | finish no earlier than 2012-12-12 | S2 | 3184h | 3184h | MOSAP-SA2Del | PCG-27 | TBD | Intel | chang.hong.shan@intel.com | Rel-12 | SP-52 | Maurice |  |  | PCG-30 | SP-58 |
| 1555 | 431 | **IMS Network-Independent Public User Identities** | 275d? | 2011-06-08 A | 2012-06-20 A | 100% | 2011-06-08 | 2012-06-20 | 275d? |  | S1 | 4390.4h | 4390.4h | INIPUI | PCG-27 | Stage 1 | Vodafone | mona.mustapha@vodafone.com | Rel-12 | SP-52 | Alain |  | INIPUI |  |  |
| 1556 | 431.1 | Stage 1 for IMS Network-Independent Public User Identities | 275d? | 2011-06-08 A | 2012-06-20 A | 100% | 2011-06-08 | 2012-06-20 | 275d? | finish no earlier than 2012-06-20 | S1 | 2190.4h | 2190.4h | INIPUI-SA1 | PCG-27 | 22.115, 22.228 | Vodafone | mona.mustapha@vodafone.com | Rel-12 | SP-52 | Alain |  |  |  |  |
| 1557 | 432 | **Service and Media Reachability for Users over Restrictive Firewalls** | 198d? | 2011-09-21 A | 2012-06-20 A | 100% | 2011-09-21 | 2012-06-20 | 198d? |  | S1 | 3161.67h | 3161.67h | SMURFs | PCG-27 | Stage 1 | Vodafone | mona.mustapha@vodafone.com | Rel-12 | SP-53 | Alain |  | SMURFs |  |  |
| 1558 | 432.1 | Stage 1 for Service and Media Reachability for Users over Restrictive Firewalls | 198d? | 2011-09-21 A | 2012-06-20 A | 100% | 2011-09-21 | 2012-06-20 | 198d? | finish no earlier than 2012-06-08 | S1 | 1577.67h | 1577.67h | SMURFs-SA1 | PCG-27 | 22.278 | Vodafone | mona.mustapha@vodafone.com | Rel-12 | SP-53 | Alain |  |  |  |  |
| 1559 | 433 | **Advanced IP Interconnection of Services (IPXS) for national interconnect** | 139d? | 2012-03-06 A | 2012-09-12 A | 100% | 2012-03-06 | 2012-09-12 | 139d? |  | S1 | 2208h | 2208h | IPXSNAT | PCG-28 | Stage 1 | KPN | toon.norp@tno.nl | Rel-12 | SP-55 | Alain |  | IPXSNAT |  |  |
| 1560 | 433.1 | Stage 1 for Advanced IP Interconnection of Services (IPXS) for national interconnect | 139d? | 2012-03-06 A | 2012-09-12 A | 100% | 2012-03-06 | 2012-09-12 | 139d? | finish no earlier than 2012-09-12 | S1 | 1096h | 1096h | IPXSNAT-SA1 | PCG-28 | 22.228 CR#0161 | KPN | toon.norp@tno.nl | Rel-12 | SP-55 | Alain |  |  |  |  |
| 1561 | 434 | **Integration of Single Sign-On (SSO) frameworks with 3GPP networks** | 137d? | 2012-03-08 A | 2012-09-12 A | 100% | 2012-03-08 | 2012-09-12 | 137d? |  | S1 | 2184h | 2184h | SSO_Int | PCG-28 | Stage 1 | InterDigital | christopher.wallace@interdigital.com | Rel-12 | SP-55 | Alain |  | SSO_Int |  |  |
| 1562 | 434.1 | Stage 1 for Integration of Single Sign-On (SSO) frameworks with 3GPP networks | 137d? | 2012-03-08 A | 2012-09-12 A | 100% | 2012-03-08 | 2012-09-12 | 137d? | finish no earlier than 2012-09-12 | S1 | 1088h | 1088h | SSO_Int-SA1 | PCG-28 | 22.101 | InterDigital | christopher.wallace@interdigital.com | Rel-12 | SP-55 | Alain |  |  |  |  |
| 1563 | 435 | **Explicit Communication Transfer Blind (ECT Blind) service interactions** | 3d? | 2012-06-18 A | 2012-06-20 A | 100% | 2012-06-18 | 2012-06-20 | 3d? |  | S1 | 48h | 48h | ECTB | PCG-29 | Stage 1 | Orange | philippe.lottin@orange.com | Rel-12 | SP-56 | Alain |  | ECTB |  |  |
| 1564 | 435.1 | Stage 1 for Explicit Communication Transfer Blind (ECT Blind) service interactions | 3d? | 2012-06-18 A | 2012-06-20 A | 100% | 2012-06-18 | 2012-06-20 | 3d? | finish no earlier than 2012-06-20 | S1 | 24h | 24h | ECTB-SA1 | PCG-29 | 22.173 | Orange | philippe.lottin@orange.com | Rel-12 | SP-56 | Alain |  |  |  |  |
| 1565 | 436 | **IMS access via Digital Video Broadcast - Return Channel via Satellite (DVB-RCS2)** | 162d? | 2012-02-02 A | 2012-09-12 A | 100% | 2012-02-02 | 2012-09-12 | 162d? |  | S1 | 2584h | 2584h | IMSSat | PCG-29 | Stage 1 | KPN | toon.norp@tno.nl | Rel-12 | SP-57 | Alain |  | IMSSat |  |  |
| 1566 | 436.1 | Stage 1 for IMS access via DVB-RCS2 | 162d? | 2012-02-02 A | 2012-09-12 A | 100% | 2012-02-02 | 2012-09-12 | 162d? | finish no earlier than 2012-09-12 | S1 | 1288h | 1288h | IMSSat-SA1 | PCG-29 | 22.228 | KPN | toon.norp@tno.nl | Rel-12 | SP-57 | Alain |  |  |  |  |
| 1567 | 437 | **Sequential Flexible Alerting** | 3d? | 2012-12-10 A | 2012-12-12 A | 100% | 2012-12-10 | 2012-12-12 | 3d? |  | S1 | 48h | 48h | SEQ_FA | PCG-30 | Stage 1 | Orange | bruno.tossou@orange-ftgroup.com | Rel-12 | SP-58 | Alain |  | IMSSat |  |  |
| 1568 | 437.1 | Stage 1 for Sequential Flexible Alerting | 3d? | 2012-12-10 A | 2012-12-12 A | 100% | 2012-12-10 | 2012-12-12 | 3d? | finish no earlier than 2012-12-12 | S1 | 24h | 24h | SEQ_FA | PCG-30 | 22.173 | Orange | bruno.tossou@orange-ftgroup.com | Rel-12 | SP-58 | Alain |  |  |  |  |
| 1569 | 438 | **Language and Modality Information for communications** | 63d? | 2012-12-11 A | 2013-03-06 A | 100% | 2012-12-11 | 2013-03-06 | 63d? |  | S1 | 1008h | 1008h | LangInfo | PCG-30 | Stage 1 | Orange | philippe.lottin@orange.com | Rel-12 | SP-58 | Alain |  | LangInfo |  |  |
| 1570 | 438.1 | Stage 1 for Language and Modality Information for communications | 63d? | 2012-12-11 A | 2013-03-06 A | 100% | 2012-12-11 | 2013-03-06 | 63d? | finish no earlier than 2013-03-06 | S1 | 504h | 504h | LangInfo-SA1 | PCG-30 | 22.228 | Orange | philippe.lottin@orange.com | Rel-12 | SP-58 | Alain |  |  |  |  |
| 1571 | 439 | **Emergency Session Identification** | 3d? | 2013-03-04 A | 2013-03-06 A | 100% | 2013-03-04 | 2013-03-06 | 3d? |  | S1 | 48h | 48h | ESID | PCG-30 | Stage 1 | Telecom Italia | carmen.catalano@telecomitalia.it | Rel-12 | SP-59 | Alain |  | ESID |  |  |
| 1572 | 439.1 | Stage 1 for Emergency Session Identification | 3d? | 2013-03-04 A | 2013-03-06 A | 100% | 2013-03-04 | 2013-03-06 | 3d? | finish no earlier than 2013-03-06 | S1 | 24h | 24h | ESID-SA1 | PCG-30 | 22.101 | Telecom Italia | carmen.catalano@telecomitalia.it | Rel-12 | SP-59 | Alain |  |  |  |  |

Notes:
- 1549: SP#57 moved to Rel-12 (Reason: Stage 2 for requirements in TS 22.101 clause 4.3.5 have not been implemented in Rel-11). Linked to Rel-10 Local IP Access and Selected Internet IP Traffic Offload (LIPA_SIPTO)
- 1550: SP#57 moved to Rel-12. SP#53 completed
- 1551: SP#58 Stage 2 stopped (TR only, no normative work done)
- 1552: SP#53 completed
- 1553: SP#62 completed. TR 23.862v200 for Approval. SP#58 frozen as v100.
- 1554: SP#58 stopped (no normative work done)
- 1555: Triggered by Rel-11 TR 22.894 (FS_INIPUI)
- 1556: SP#56 re-completed. Updated WID SP-110381=>SP-120425 (Re-opened & moved to Rel-12 by adding new reqs & removing reqs from Rel-11). SP#53 Rel-11 Stage 1 completed
- 1557: SP#56 Stage 1 completed
- 1558: SP#56 completed
- 1559: SP#57 Stage 1 completed. Linked to Rel-11 Feature Advanced IP Interconnection of Services (IPXS) UID_470051.
- 1560: SP#57 completed
- 1561: SP#57 Stage 1 completed. Triggered by Rel-12 TR 22.895. Linked to SA3 33.8xy (Study on Security aspects of SSO_Int), 33.914 (SSO application security for common IMS based on SIP Digest), 33.924 (i/w GBA and OpenID), 33.980 (i/w GBA and Liberty Alliance)
- 1562: SP#57 completed
- 1563: SP#56 WID approved & Stage 1 completed
- 1564: SP#56 new WID approved & work completed. Clarify the service interactions between ECT Blind and other MMTEL Supplementary Services
- 1565: SP#57 Stage 1 completed. Integrate Satcom access with IMS. Specify DVB-RCS2 as an IP Connectivity Access Network for IMS
- 1566: SP#57 completed. Definition of DVB-RCS2 as a non-3GPP IP Connectivity Access Network for IMS
- 1567: SP#58 approved WID & Stage 1 completed. Currently Flexible Alerting (FA) group members are simultaneously alerted by the incoming call. Add the possibility to alert FA group members sequentially. 22/01: acronym modified
- 1568: SP#58 approved WID & Stage 1 completed
- 1569: SP#59 Stage 1 completed. Triggered by Rel-11 Study on Non Voice Emergency Services (FS_NOVES) TR 22.871 use case 10
- 1570: SP#59 completed. Updated WID SP-120937=>SP-130108
- 1571: SP#59 Stage 1 completed.
- 1572: SP#59 completed (22.101 CR#0445)

| ID | WBS | Task | Duration | Start | Finish | Complete | Baseline start | Baseline finish | Baseline duration | Constraint | Resources | Work | Actual work | Acronym | PCG approved | WI rapporteur name | WI rapporteur e-mail | Release | TSG approved | MCC resp | PCG stopped | TSG stopped | Acronym_3GU_Export | Special Focus Doc | Status Report |
| --- | --- | --- | --- | --- | --- | --- | --- | --- | --- | --- | --- | --- | --- | --- | --- | --- | --- | --- | --- | --- | --- | --- | --- | --- | --- |
| 1573 | 440 | **Deleted - Application and Service Access Control** | 77d? | 2013-03-06 A | 2013-06-19 A | 100% | 2013-03-06 | 2013-06-19 | 77d? |  | S1 | 1224h | 1224h | ASAC | PCG-30 | NTT DOCOMO | Atsushi Minokuchi (minokuchi@nttdocomo.co.jp) | Rel-12 | SP-59 | Alain | PCG-31 | SP-60 | ASAC |  |  |
| 1574 | 440.1 | Deleted - Stage 1 for Application and Service Access Control | 77d? | 2013-03-06 A | 2013-06-19 A | 100% | 2013-03-06 | 2013-06-19 | 77d? | finish no earlier than 2013-06-19 | S1 | 608h | 608h | ASAC-SA1del | PCG-30 | NTT DOCOMO | Atsushi Minokuchi (minokuchi@nttdocomo.co.jp) | Rel-12 | SP-59 | Alain | PCG-31 | SP-60 |  |  |  |
| 1575 | 441 | **Prevention of Mobile-Originating signalling and/or data traffic of UE in Connected mode** | 3d? | 2013-03-04 A | 2013-03-06 A | 100% | 2013-03-04 | 2013-03-06 | 3d? |  | S1 | 48h | 48h | PMOC | PCG-30 | NTT DOCOMO | Atsushi Minokuchi (minokuchi@nttdocomo.co.jp) | Rel-12 | SP-59 | Alain |  |  | PMOC |  |  |
| 1576 | 441.1 | Stage 1 for Prevention of Mobile-Originating signalling and/or data traffic of UE in Connected mode | 3d? | 2013-03-04 A | 2013-03-06 A | 100% | 2013-03-04 | 2013-03-06 | 3d? | finish no earlier than 2013-03-06 | S1 | 24h | 24h | PMOC-SA1 | PCG-30 | NTT DOCOMO | Atsushi Minokuchi (minokuchi@nttdocomo.co.jp) | Rel-12 | SP-59 | Alain |  |  |  |  |  |
| 1577 | 442 | SA1/SA2 Features | 216d? | 2013-05-17 A | 2014-03-07 A | 100% | 2013-05-17 | 2014-03-07 | 216d? | finish no earlier than 2014-03-07 | SP; CP; RP | 5184h | 5184h |  | PCG-30 |  |  | Rel-12 | SP-58 |  |  |  |  |  |  |
| 1578 | 443 | **LIPA Mobility and SIPTO at the Local Network** | 898d? | 2010-10-15 A | 2014-03-06 A | 100% | 2010-10-15 | 2014-03-06 | 898d? |  | S2; C4; C1; R3 | 87994h | 87994h | LIMONET | PCG-26 | Huawei | zhufenqin@huawei.com | Rel-12 | SP-50 | Maurice |  |  | LIMONET | HNB |  |
| 1579 | 443.1 | TR on Stage 2 for LIPA Mobility and SIPTO at the Local Network | 580.85d? | 2010-10-15 A | 2013-03-06 A | 100% | 2010-10-15 | 2013-03-06 | 580.85d? | finish no earlier than 2013-03-06 | S2 | 4646.8h | 4646.8h | LIMONET-SA3 | PCG-26 | Huawei | zhufenqin@huawei.com | Rel-12 | SP-50 | Maurice |  |  |  | HNB |  |
| 1580 | 443.2 | **BB1: SIPTO at the Local Network** | 892d? | 2010-10-22 A | 2014-03-05 A | 100% | 2010-10-22 | 2014-03-05 | 892d? |  | S2 | 31685.6h | 31685.6h | LIMONET-SIPTO | PCG-26 | Huawei | zhufenqin@huawei.com | Rel-12 | SP-50 | Maurice |  |  | LIMONET-SIPTO | HNB |  |
| 1581 | 443.2.1 | Stage 2 for SIPTO at the Local Network | 655.85d? | 2010-10-22 A | 2013-06-19 A | 100% | 2010-10-22 | 2013-06-19 | 655.85d? | finish no earlier than 2013-06-19 | S2 | 5246.8h | 5246.8h | LIMONET-SIPTO-SA2 | PCG-26 | Huawei | zhufenqin@huawei.com | Rel-12 | SP-50 | Maurice |  |  |  | HNB |  |
| 1582 | 443.2.2 | **Stage 3 CN aspects of SIPTO at the Local Network** | 649d? | 2011-09-24 A | 2014-03-05 A | 100% | 2011-09-24 | 2014-03-05 | 649d? |  | C4; C1 | 19680h | 19680h | LIMONET-SIPTO | PCG-27 | Huawei | peter.schmitt@huawei.com | Rel-12 | CP-53 | Kimmo |  |  |  | HNB |  |
| 1583 | 443.2.2.1 | CT4 part of Stage 3 CN aspects of SIPTO at the Local Network | 518d? | 2011-09-24 A | 2013-09-06 A | 100% | 2011-09-24 | 2013-09-06 | 518d? | finish no earlier than 2013-09-06 | C4 | 4136h | 4136h | LIMONET-SIPTO-CT4 | PCG-27 | Huawei | peter.schmitt@huawei.com | Rel-12 | CP-53 | Kimmo |  |  |  | HNB |  |
| 1584 | 443.2.2.2 | CT1 part of Stage 3 CN aspects of SIPTO at the Local Network | 646d? | 2011-09-24 A | 2014-03-05 A | 100% | 2011-09-24 | 2014-03-05 | 646d? | finish no earlier than 2014-01-29 | C1 | 5160h | 5160h | LIMONET-SIPTO-CT1 | PCG-27 | Huawei | peter.schmitt@huawei.com | Rel-12 | CP-53 | Frederic |  |  |  | HNB |  |
| 1585 | 443.3 | **RAN aspects for SIPTO at the Local Network** | 269d? | 2013-03-04 A | 2014-03-06 A | 100% | 2013-03-04 | 2014-03-06 | 269d? |  | R3 | 4272h | 4272h | LIMONET-RAN | PCG-30 | Huawei | zheng.zhou@huawei.com | Rel-12 | RP-59 | Juha |  |  | LIMONET-RAN | HNB |  |
| 1586 | 443.3.1 | Core part: RAN aspects for SIPTO at the Local Network | 266d? | 2013-03-04 A | 2014-03-06 A | 100% | 2013-03-04 | 2014-03-06 | 266d? | finish no earlier than 2014-03-06 | R3 | 2120h | 2120h | LIMONET-RAN-Core | PCG-30 | Huawei | zheng.zhou@huawei.com | Rel-12 | RP-59 | Juha |  |  | LIMONET-RAN-Core | HNB | RP-131512 |
| 1587 | 443.4 | **Deleted - BB2: Stand-alone L-GW and associated Mobility for LIPA and SIPTO at the Local Network** | 566d? | 2010-10-22 A | 2012-12-12 A | 100% | 2010-10-22 | 2012-12-12 | 566d? |  | S2 | 18653.6h | 18653.6h | LIMONET-LIPA | PCG-26 | Huawei | zhufenqin@huawei.com | Rel-12 | SP-50 | Maurice | PCG-30 | SP-58 | LIMONET-LIPA | HNB |  |
| 1588 | 443.4.1 | Deleted - Stage 2 for stand-alone L-GW and associated Mobility for LIPA and SIPTO at the Local Network | 519.85d? | 2010-10-22 A | 2012-12-12 A | 100% | 2010-10-22 | 2012-12-12 | 519.85d? | finish no earlier than 2012-12-12 | S2 | 4158.8h | 4158.8h | LIMONET-LIPA-del1 | PCG-26 | Huawei | zhufenqin@huawei.com | Rel-12 | SP-50 | Maurice | PCG-30 | SP-58 |  | HNB |  |
| 1589 | 443.4.2 | **Deleted - Stage 3 CN aspects of LIPA Mobility** | 323d? | 2011-09-24 A | 2012-12-12 A | 100% | 2011-09-24 | 2012-12-12 | 323d? |  | C1; C4 | 10336h | 10336h | LIMONET-LIPA-del2 | PCG-27 | Huawei | christian.herrero@huawei.com | Rel-12 | CP-53 | Frederic | PCG-30 | SP-58 |  | HNB |  |
| 1590 | 443.4.2.1 | Deleted - CT1 part of CN aspects of LIPA Mobility | 323d? | 2011-09-24 A | 2012-12-12 A | 100% | 2011-09-24 | 2012-12-12 | 323d? | finish no earlier than 2012-12-12 | C1 | 2584h | 2584h | LIMONET-LIPA-del3 | PCG-27 | Huawei | christian.herrero@huawei.com | Rel-12 | CP-53 | Frederic | PCG-30 | SP-58 |  | HNB |  |
| 1591 | 443.4.2.2 | Deleted - CT4 part of CN aspects of LIPA Mobility | 323d? | 2011-09-24 A | 2012-12-12 A | 100% | 2011-09-24 | 2012-12-12 | 323d? | finish no earlier than 2012-12-12 | C4 | 2584h | 2584h | LIMONET-LIPA-del4 | PCG-27 | Huawei | christian.herrero@huawei.com | Rel-12 | CP-53 | Kimmo | PCG-30 | SP-58 |  | HNB |  |
| 1592 | 444 | **Operator Policies for IP Interface Selection** | 720d? | 2011-03-23 A | 2013-12-06 A | 100% | 2011-03-23 | 2013-12-06 | 720d? |  | S2; C1 | 20256h | 20256h | OPIIS | PCG-26 | LG Electronics | taehyeon.kim@lge.com | Rel-12 | SP-51 | Maurice |  |  | OPIIS |  |  |
| 1593 | 444.1 | TR on Stage 2 for Operator Policies for IP Interface Selection | 457d? | 2011-03-23 A | 2012-12-12 A | 100% | 2011-03-23 | 2012-12-12 | 457d? | finish no earlier than 2012-12-12 | S2 | 3640h | 3640h | OPIIS | PCG-26 | LG Electronics | taehyeon.kim@lge.com | Rel-12 | SP-51 | Maurice |  |  |  |  |  |
| 1594 | 444.2 | Stage 2 for Operator Policies for IP Interface Selection | 511d? | 2011-04-04 A | 2013-03-06 A | 100% | 2011-04-04 | 2013-03-06 | 511d? | finish no earlier than 2013-03-06 | S2 | 4088h | 4088h | OPIIS | PCG-26 | LG Electronics | taehyeon.kim@lge.com | Rel-12 | SP-51 | Maurice |  |  |  |  |  |
| 1595 | 444.3 | Stage 3 for Operator Policies for IP Interface Selection | 126d? | 2013-06-14 A | 2013-12-06 A | 100% | 2013-06-14 | 2013-12-06 | 126d? | finish no earlier than 2013-12-06 | C1 | 1008h | 1008h | OPIIS-CT | PCG-31 | LG Electronics | Jaehyun Kim (jaehyun7.kim@lge.com) | Rel-12 | CP-60 | Frederic |  |  | OPIIS-CT |  |  |
| 1596 | 445 | **Short Message Service (SMS) submit and delivery without MSISDN in IMS** | 665d? | 2011-06-08 A | 2013-12-06 A | 100% | 2011-06-08 | 2013-12-06 | 665d? |  | S2; C1; C4 | 28336.3h | 28336.3h | SMSMI | PCG-27 | Nokia Siemens Networks | curt.wong@nsn.com | Rel-12 | SP-52 | Maurice |  |  | SMSMI |  |  |
| 1597 | 445.1 | TR on Stage 2 for SMS submit and delivery without MSISDN in IMS | 402d? | 2011-06-08 A | 2012-12-12 A | 100% | 2011-06-08 | 2012-12-12 | 402d? | finish no earlier than 2012-12-12 | S2 | 3192.32h | 3192.32h | SMSMI-SA2TR | PCG-27 | Nokia Siemens Networks | curt.wong@nsn.com | Rel-12 | SP-52 | Maurice |  |  |  |  |  |
| 1598 | 445.2 | Stage 2 for SMS submit and delivery without MSISDN in IMS | 400d? | 2011-06-13 A | 2012-12-12 A | 100% | 2011-06-13 | 2012-12-12 | 400d? | finish no earlier than 2012-12-12 | S2 | 3192h | 3192h | SMSMI-SA2 | PCG-27 | Nokia Siemens Networks | curt.wong@nsn.com | Rel-12 | SP-52 | Maurice |  |  |  |  |  |

Notes:
- 1573: SP#60 stopped and Rel-13 FS_ACDC continues. Triggered by TR 22.806 Study on Application specific Congestion control for Data Communication (FS_ACDC) UID_570034 / Impacted TSs and TRs: Stage 1
- 1574: SP#60 stopped and Rel-13 FS_ACDC contd. Allow/prohibit for E-UTRAN idle mode UE initiation of particular applications defined by operator and subject to regional regulations. Prevent/mitigate overload of AN/CN defined by operator (congestion or disaster) / Impacted TSs and TRs: 22.011
- 1575: SP#59 Stage 1 completed / Impacted TSs and TRs: Stage 1
- 1576: SP#59 completed / Impacted TSs and TRs: 22.011
- 1577: -
- 1578: CP#63 completed. SP#58 updated WID SP-120256=>SP-120926 (stopped BB2 LIMONET-LIPA on Mobility). Linked to UID_450035 Local IP Access and Selected IP Traffic Offload (LIPA_SIPTO) / Impacted TSs and TRs: Stage 2/3
- 1579: SP#59 completed. TR 23.859 v100 for Information and Approval / Impacted TSs and TRs: new TR 23.859
- 1580: SP#60 completed / Impacted TSs and TRs: 23.060, 23.401
- 1581: SP#60 completed / Impacted TSs and TRs: 23.060, 23.401
- 1582: CP#63 completed / Impacted TSs and TRs: Stage 3
- 1583: CP#61 completed / Impacted TSs and TRs: 23.003, 23.008, 29.002, 29.060, 29.230, 29.272, 29.274, 29.303
- 1584: CP#63 completed / Impacted TSs and TRs: 24.008, 24.301
- 1585: - / Impacted TSs and TRs: UTRA, LTE
- 1586: RP#62 completed / Impacted TSs and TRs: 25.401, 25.413, 25.423, 25.467, 25.469, 36.300, 36.413, 36.423
- 1587: SP#58 updated WID SP-120256=>SP-120926 (stopped BB2 LIMONET-LIPA on Mobility) / Impacted TSs and TRs: 23.060, 23.401
- 1588: SP#58 updated WID SP-120256=>SP-120926 (stopped BB2 LIMONET-LIPA on Mobility) / Impacted TSs and TRs: 23.060, 23.401
- 1589: SP#58 CT Stage 3 part stopped because of SA stopping Stage 2 for BB2 LIMONET-LIPA on Mobility) / Impacted TSs and TRs: Stage 3
- 1590: SP#58 CT Stage 3 part stopped because of SA stopping Stage 2 for BB2 LIMONET-LIPA on Mobility) / Impacted TSs and TRs: 24.008, 24.301
- 1591: SP#58 CT Stage 3 part stopped because of SA stopping Stage 2 for BB2 LIMONET-LIPA on Mobility) / Impacted TSs and TRs: 29.060, 29.274, 29.281, 29.303, 29.002, 29.272, 29.275, 29.282, 29.305
- 1592: Linked to Rel-10 IFOM IP Flow Mobility and seamless WLAN offload (non-seamless WLAN offload aspects) & Rel-11 LIMONET (support traffic offload at local network) / Impacted TSs and TRs: Stage 2/3
- 1593: SP#58 completed / Impacted TSs and TRs: new TR 23.853
- 1594: SP#59 completed (23.402 CR#152: Introduction of Inter-APN Routing Policies) / Impacted TSs and TRs: 23.402
- 1595: CP#62 completed. Specify Inter-APN Routing Policies for selecting an IP interface to route IP flows among a choice of available interfacES in CP-150both 3GPP and non-3GPP accesses / Impacted TSs and TRs: 24.302, 24.312
- 1596: Linked to Rel-7 SMSIP (Support of SMS over generic 3GPP IP access), Rel-11 SIMTC, Rel-12 TR 22.988 SA1 Study on alternatives to E.164 for MTC / Impacted TSs and TRs: Stage 2/3
- 1597: SP#58 completed / Impacted TSs and TRs: new TR 23.863
- 1598: SP#58 completed / Impacted TSs and TRs: 23.204, 23.682

| ID | WBS | Task | Duration | Start | Finish | Complete | Remaining | Baseline start | Baseline finish | Baseline duration | Total slack | Constraint | Resources | Work | Actual work | Acronym | PCG approved | Impacted TSs and TRs | WI rapporteur name | WI rapporteur e-mail | Release | TSG approved | MCC resp | Acronym_3GU_Export | Status Report | Special Focus Doc |
| --- | --- | --- | --- | --- | --- | --- | --- | --- | --- | --- | --- | --- | --- | --- | --- | --- | --- | --- | --- | --- | --- | --- | --- | --- | --- | --- |
| 1599 | 445.3 | **Stage 3 for SMS submit and delivery without MSISDN in IMS** | 205d? | 2013-03-01 A | 2013-12-06 A | 100% |  | 2013-03-01 | 2013-12-06 | 205d? |  |  | C1; C4 | 5992h | 5992h | SMSMI-CT | PCG-30 | Stage 3 | NSN | peter.leis@nsn.com | Rel-12 | CP-59 | Frederic | SMSMI-CT |  |  |
| 1600 | 445.3.1 | CT1 part of Stage 3 for SMS submit and delivery without MSISDN in IMS | 205d? | 2013-03-01 A | 2013-12-06 A | 100% |  | 2013-03-01 | 2013-12-06 | 205d? |  | finish no earlier than 2013-12-06 | C1 | 1608h | 1608h | SMSMI-CT | PCG-30 | 23.040, 24.341 | NSN | peter.leis@nsn.com | Rel-12 | CP-59 | Frederic |  |  |  |
| 1601 | 445.3.2 | CT4 part of Stage 3 for SMS submit and delivery without MSISDN in IMS | 139d? | 2013-03-01 A | 2013-09-06 A | 100% |  | 2013-03-01 | 2013-09-06 | 139d? |  | finish no earlier than 2013-09-06 | C4 | 1104h | 1104h | SMSMI-CT | PCG-30 | 23.008, 29.002, 29.305, 29.328, 29.338 | NSN | peter.leis@nsn.com | Rel-12 | CP-59 | Kimmo |  |  |  |
| 1602 | 446 | **IMS-based Telepresence** | 1247.5d? | 2010-03-22 A | 2014-12-09 | 66% | 430.02d? | 2010-03-19 | 2014-12-05 | 1243.5d? | 1053d |  | S1; C1; C3; C4; IETF | 122882h | 38645.9h | IMS_TELEP | PCG-27 | Stage 1/2/3 | Orange | bruno.tossou@orange-ftgroup.com | Rel-12 | SP-53 | Alain | IMS_TELEP |  |  |
| 1603 | 446.1 | Stage 1 for IMS-based Telepresence | 197d? | 2011-09-22 A | 2012-06-20 A | 100% |  | 2011-09-22 | 2012-06-20 | 197d? |  | finish no earlier than 2012-06-08 | S1 | 1569.86h | 1569.86h | IMS_TELEP | PCG-27 | 22.228 | Orange | bruno.tossou@orange-ftgroup.com | Rel-12 | SP-53 | Alain |  |  |  |
| 1604 | 446.2 | **CT part for IMS Telepresence (Stage 2/3)** | 1247.5d? | 2010-03-22 A | 2014-12-09 | 64% | 444.19d? | 2010-03-19 | 2014-12-05 | 1243.5d? | 1053d |  | C1; C3; C4; IETF | 87712h | 30772h | IMS_TELEP | PCG-30 | Stage 2/3 | Huawei | Weiwei(Tommy) Yang (tommy@huawei.com) | Rel-12 | CP-58 | Frederic |  |  |  |
| 1605 | 446.2.1 | TR on CT part of IMS Telepresence (Stage 2/3) | 399d? | 2012-12-07 A | 2014-06-13 A | 100% |  | 2012-12-07 | 2014-06-13 | 399d? |  | finish no earlier than 2014-06-13 | C1 | 3184h | 3184h | IMS_TELEP | PCG-30 | New TR 24.803 | Huawei | Weiwei(Tommy) Yang (tommy@huawei.com) | Rel-12 | CP-58 | Frederic |  |  |  |
| 1606 | 446.2.2 | CT1 part of IMS Telepresence (Stage 3) | 526d? | 2012-12-07 A | 2014-12-09 A | 100% |  | 2012-12-07 | 2014-09-12 | 464d? |  | finish no earlier than 2014-12-09 | C1 | 4208h | 4208h | IMS_TELEP | PCG-30 | 24.147, 24.166, 24.229, New TS 24.103 | Huawei | Weiwei(Tommy) Yang (tommy@huawei.com) | Rel-12 | CP-58 | Frederic |  | CP-140616 |  |
| 1607 | 446.2.3 | (IETF) CT1 part of IMS Telepresence (mmusic-sctp-sdp) | 851d? | 2010-03-22 A | 2014-12-09 | 50% | 425.5d? | 2010-03-19 | 2014-12-05 | 849d? | 1053d | finish no earlier than 2014-12-09 | C1-IETF | 6808h | 3404h | IMS_TELEP | PCG-33 | draft-ietf-mmusic-sctp-sdp | christer.holmberg@ericsson.com | christer.holmberg@ericsson.com | Rel-12 | CP-64 |  |  |  |  |
| 1608 | 446.2.4 | (IETF) CT1 part of IMS Telepresence (clue-framework ) | 851d? | 2010-03-22 A | 2014-12-09 | 50% | 425.5d? | 2010-03-19 | 2014-12-05 | 849d? | 1053d | finish no earlier than 2014-12-09 | C1-IETF | 6808h | 3404h | IMS_TELEP | PCG-33 | draft-ietf-clue-framework | christer.holmberg@ericsson.com | christer.holmberg@ericsson.com | Rel-12 | CP-64 |  |  |  |  |
| 1609 | 446.2.5 | (IETF) CT1 part of IMS Telepresence (clue-datachannel) | 851d? | 2010-03-22 A | 2014-12-09 | 50% | 425.5d? | 2010-03-19 | 2014-12-05 | 849d? | 1053d | finish no earlier than 2014-12-09 | C1-IETF | 6808h | 3404h | IMS_TELEP | PCG-33 | draft-ietf-clue-datachannel | christer.holmberg@ericsson.com | christer.holmberg@ericsson.com | Rel-12 | CP-64 |  |  |  |  |
| 1610 | 446.2.6 | (IETF) CT1 part of IMS Telepresence (clue-signaling) | 851d? | 2010-03-22 A | 2014-12-09 | 50% | 425.5d? | 2010-03-19 | 2014-12-05 | 849d? | 1053d | finish no earlier than 2014-12-09 | C1-IETF | 6808h | 3404h | IMS_TELEP | PCG-33 | draft-ietf-clue-signaling | christer.holmberg@ericsson.com | christer.holmberg@ericsson.com | Rel-12 | CP-64 |  |  |  |  |
| 1611 | 446.2.7 | (IETF) CT1 part of IMS Telepresence (clue-data-model-schema) | 851d? | 2010-03-22 A | 2014-12-09 | 50% | 425.5d? | 2010-03-19 | 2014-12-05 | 849d? | 1053d | finish no earlier than 2014-12-09 | C1-IETF | 6808h | 3404h | IMS_TELEP | PCG-33 | draft-ietf-clue-data-model-schema | christer.holmberg@ericsson.com | christer.holmberg@ericsson.com | Rel-12 | CP-64 |  |  |  |  |
| 1612 | 446.2.8 | CT3 part of IMS Telepresence (Stage 3) | 467d? | 2012-12-07 A | 2014-09-11 A | 100% |  | 2012-12-07 | 2014-09-12 | 467d? |  | finish no earlier than 2014-09-12 | C3 | 3736h | 3736h | IMS_TELEP | PCG-30 | 29.165 | Huawei | Weiwei(Tommy) Yang (tommy@huawei.com) | Rel-12 | CP-58 | Adrian |  |  |  |
| 1613 | 446.2.9 | CT4 part of IMS Telepresence (Stage 2/3) | 328d? | 2013-09-13 A | 2014-12-09 A | 100% |  | 2013-09-10 | 2014-09-12 | 266d? |  | finish no earlier than 2014-12-09 | C4 | 2624h | 2624h | IMS_TELEP | PCG-31 | 23.333, 29.333 | Huawei | Weiwei(Tommy) Yang (tommy@huawei.com) | Rel-12 | CP-61 | Kimmo |  | CP-140477 |  |
| 1614 | 447 | **Group Communication System Enablers for LTE** | 727d? | 2012-06-18 A | 2015-03-15 A | 100% |  | 2012-06-18 | 2014-09-17 | 597d? |  |  | S1; S2; S3; C3; C4; R3; C1 | 59744h | 58696h | GCSE_LTE | PCG-29 | Stage 1/2/3 | Nokia Networks | Juergen.Merkel@nsn.com | Rel-12 | SP-56 | Alain | GCSE_LTE |  | Public Safety (A-A) |
| 1615 | 447.1 | Stage 1 for Group Communication System Enablers for LTE | 267d? | 2012-06-18 A | 2013-06-19 A | 100% |  | 2012-06-18 | 2013-06-19 | 267d? |  | finish no earlier than 2013-06-19 | S1 | 2128h | 2128h | GCSE_LTE | PCG-29 | New TS 22.468 | Nokia Networks | Juergen.Merkel@nsn.com | Rel-12 | SP-56 | Alain |  |  | Public Safety (A-A) |
| 1616 | 447.2 | TR on Architecture enhancements to support Group Communication System Enablers for LTE | 267d? | 2013-03-07 A | 2014-03-07 A | 100% |  | 2013-03-07 | 2014-03-07 | 267d? |  | finish no earlier than 2014-03-07 | S2 | 2128h | 2128h | GCSE_LTE | PCG-30 | New TR 23.768 | Nokia Networks | rainer.liebhart@nsn.com | Rel-12 | SP-59 | Maurice |  |  | Public Safety (A-A) |
| 1617 | 447.3 | Stage 2 for Group Communication System Enablers for LTE | 402d? | 2013-03-12 A | 2014-09-16 A | 100% |  | 2013-03-12 | 2014-09-17 | 402d? |  | finish no earlier than 2014-09-17 | S2 | 3208h | 3208h | GCSE_LTE | PCG-30 | New TS 23.468 | Nokia Networks | rainer.liebhart@nsn.com | Rel-12 | SP-59 | Maurice |  |  | Public Safety (A-A) |
| 1618 | 447.4 | TR on Security for Group Communication System Enablers for LTE (Stage 2) | 201d? | 2013-09-12 A | 2014-06-18 A | 100% |  | 2013-09-12 | 2014-06-18 | 201d? |  | finish no earlier than 2014-06-18 | S3 | 1608h | 1608h | GCSE_LTE | PCG-31 | New TR 33.888 | Nokia Networks | anja.jerichow@nsn.com | Rel-12 | SP-61 | Mirko |  |  | Public Safety (A-A) |
| 1619 | 447.5 | Security for Group Communication System Enablers for LTE (Stage 2) | 201d? | 2013-09-13 A | 2014-06-18 A | 100% |  | 2013-09-13 | 2014-06-18 | 201d? |  | finish no earlier than 2014-06-18 | S3 | 1608h | 1608h | GCSE_LTE | PCG-31 | 33.246 | Nokia Networks | anja.jerichow@nsn.com | Rel-12 | SP-61 | Mirko |  |  | Public Safety (A-A) |
| 1620 | 447.6 | **CT aspects of Group Communication System Enablers for LTE** | 131d? | 2014-06-13 A | 2014-12-09 A | 100% |  | 2014-06-13 | 2014-09-12 | 66d? |  |  | C3; C4; C1 | 5200h | 4152h | GCSE_LTE-CT | PCG-33 | Stage 3 | Nokia Networks | thomas.belling@nsn.com | Rel-12 | CP-64 |  | GCSE_LTE-CT |  | Public Safety (A-A) |
| 1621 | 447.6.1 | CT3 part of Group Communication System Enablers for LTE | 66d? | 2014-06-13 A | 2014-09-11 A | 100% |  | 2014-06-13 | 2014-09-12 | 66d? |  | finish no earlier than 2014-09-12 | C3 | 528h | 528h | GCSE_LTE-CT | PCG-33 | 29.212, 29.213, 29.214, 29.274, New TS 29.468 | Nokia Networks | thomas.belling@nsn.com | Rel-12 | CP-64 |  |  |  | Public Safety (A-A) |
| 1622 | 447.6.2 | CT4 part of Group Communication System Enablers for LTE | 128d? | 2014-06-13 A | 2014-12-09 A | 100% |  | 2014-06-13 | 2014-09-12 | 66d? |  | finish no earlier than 2014-12-09 | C4 | 1024h | 1024h | GCSE_LTE-CT | PCG-33 | 23.007, 23.008 | Nokia Networks | thomas.belling@nsn.com | Rel-12 | CP-64 |  |  | CP-140725 | Public Safety (A-A) |
| 1623 | 447.6.3 | CT1 part of Group Communication System Enablers for LTE | 63d? | 2014-09-12 A | 2014-12-09 A | 100% |  |  |  |  |  | finish no earlier than 2014-12-09 | C1 | 504h | 504h | GCSE_LTE-CT | PCG-33 | 24.301 | Nokia Networks | thomas.belling@nsn.com | Rel-12 | CP-65 |  |  | CP-140614 | Public Safety (A-A) |

Notes:
- 1599: CP#62 completed. Address scenario IMS client to IMS client SMS (comprises SMS receive and send SMS without requiring an MSISDN associated as part of their subscription record in HSS
- 1600: CP#62 completed
- 1601: CP#61 completed
- 1602: This feature does not introduce any changes to the IMS architecture, and no stage 2 impacts are identified
- 1603: SP#56 completed. 2/4/15: acronym changed to IMS_TELEP
- 1604: CP#65 updated WID CP-140196=>CP-140624. 2/4/15: acronym changed to IMS_TELEP
- 1605: CP#64 completed. 2/4/15: acronym changed to IMS_TELEP
- 1606: CP#65 TS 24.103v100 for Information. Updated WID CP-140196=>CP-140624. Completion 09/14=>12/14. Exception in CP-140616. Dec.14: 90->100%. 2/4/15: acronym changed to IMS_TELEP
- 1607: work in progress. 2/4/15: acronym changed to IMS_TELEP
- 1608: work in progress. 2/4/15: acronym changed to IMS_TELEP
- 1609: work in progress. 2/4/15: acronym changed to IMS_TELEP
- 1610: work in progress. 2/4/15: acronym changed to IMS_TELEP
- 1611: work in progress. 2/4/15: acronym changed to IMS_TELEP
- 1612: CP#65 completed. 2/4/15: acronym changed to IMS_TELEP
- 1613: CP#65 updated WID CP-140196=>CP-140624. Completion 09/14=>12/14. Exception in CP-140477. Mar.15: 0->100%. 2/4/15: acronym changed to IMS_TELEP
- 1614: Linked to Rel-12 FS_ProSe TR 22.803 Study on Proximity-based Services. External requirements: NIST, MESA, APCO Global Alliance, TCCA. Specify 3GPP system enablers to support group communication over LTE for Public Safety
- 1615: SP#60 completed. TS 22.468 v100 for 1-step Approval
- 1616: SP#63 completed. TR 23.768v200 for Approval
- 1617: SP#65 completed. Updated WID SP-140113=>SP-140433. SP#63 TS 23.468v100 for 1-step Approval
- 1618: SP#64 completed. TR 33.888v100 for 1-step Approval
- 1619: SP#64 completed
- 1620: CP#65 updated WID CP-140452=>C3-143199 (added CT1 part)
- 1621: CP#65 completed. TS 29.468v200 for Approval
- 1622: CP#65 completion 09/14=>12/14. Exception in CP-140725. Dec.14: 35->100
- 1623: CP#65 updated WID CP-140452=>CP-140559 (added CT1 part). Exception in CP-140614. Dec.14: 90->100%

| ID | WBS | Task | Duration | Start | Finish | Complete | Remaining | Baseline start | Baseline finish | Baseline duration | Total slack | Constraint | Resources | Work | Actual work | Acronym | PCG approved | Impacted TSs and TRs | WI rapporteur name | WI rapporteur e-mail | Release | TSG approved | Special Focus Doc | Acronym_3GU_Export | Status Report | MCC resp | PCG stopped | TSG stopped |
| --- | --- | --- | --- | --- | --- | --- | --- | --- | --- | --- | --- | --- | --- | --- | --- | --- | --- | --- | --- | --- | --- | --- | --- | --- | --- | --- | --- | --- |
| 1624 | 447.7 | **Group Call eMBMS congestion management for LTE** | 198d? | 2014-06-16 A | 2015-03-15 A | 100% |  | 2014-06-13 | 2014-09-12 | 66d? |  |  | R3 | 3152h | 3152h | GCSE_LTE-MBMS_CM | PCG-33 | LTE | Alcatel-Lucent | hakon.helmers@alcatel-lucent.com | Rel-12 | RP-64 | Public Safety (A-A) | GCSE_LTE-MBMS_CM |  |  |  |  |
| 1625 | 447.7.1 | Core part: Group Call eMBMS congestion management for LTE | 196d? | 2014-06-16 A | 2015-03-15 A | 100% |  | 2014-06-13 | 2014-09-12 | 66d? |  | finish no earlier than 2015-03-15 | R3 | 1568h | 1568h | GCSE_LTE-MBMS_CM-Core | PCG-33 | 36.413 | Alcatel-Lucent | hakon.helmers@alcatel-lucent.com | Rel-12 | RP-64 | Public Safety (A-A) | GCSE_LTE-MBMS_CM-Core | RP-150081 |  |  |  |
| 1626 | 448 | **Machine-Type and other mobile data applications Communications enhancements** | 1692d? | 2009-12-10 A | 2016-05-12 | 98% | 40.3d? | 2009-12-10 | 2014-09-12 | 1255d? | 681d |  | S2; S1; S3; C1; C3; C4; C6; R2; R3; G1 | 223392h | 188568h | MTCe | PCG-29 | Stage 1/2/3 | Intel | puneet.jain@intel.com | Rel-12 | SP-56 | MTC, M2M | MTCe |  | Maurice |  |  |
| 1627 | 448.1 | Stage 1 for Support for Interworking with M2M Service Enablement | 189d? | 2012-06-18 A | 2013-03-06 A | 100% |  | 2012-06-18 | 2013-03-06 | 189d? |  | finish no earlier than 2013-03-06 | S1 | 1504h | 1504h | MTCe-SIMSE | PCG-29 | 22.368 | KPN | toon.norp@tno.nl | Rel-12 | SP-56 | MTC, M2M | MTCe-SIMSE |  | Alain |  |  |
| 1628 | 448.2 | Stage 1 for Machine-Type and other mobile data applications Communications – Service Requirement Maintenance | 127d? | 2012-09-13 A | 2013-03-06 A | 100% |  | 2012-09-13 | 2013-03-06 | 127d? |  | finish no earlier than 2013-03-06 | S1 | 1008h | 1008h | MTCe-SRM | PCG-29 | 22.101, 22.368 | KPN | toon.norp@tno.nl | Rel-12 | SP-57 | MTC, M2M | MTCe-SRM |  | Alain |  |  |
| 1629 | 448.3 | TR on Security aspects of Machine-Type Communications | 1113d? | 2009-12-10 A | 2014-03-07 A | 100% |  | 2009-12-10 | 2014-03-07 | 1113d? |  | finish no earlier than 2014-03-07 | S3 | 8896h | 8896h | MTCe-SA3TR | PCG-29 | New TR 33.868 | Samsung | Rajavelsamy R (rajvel@samsung.com) | Rel-12 | SP-56 | MTC, M2M |  |  | Mirko |  |  |
| 1630 | 448.4 | Security and Privacy aspects for Machine-Type and other mobile data applications Communications enhancements (Stage 2) | 452d? | 2012-06-22 A | 2014-03-07 A | 100% |  | 2012-06-22 | 2014-03-07 | 452d? |  | finish no earlier than 2014-03-07 | S3 | 3608h | 3608h | MTCe-SA3 | PCG-29 | New TS 33.187 | Samsung | Rajavelsamy R (rajvel@samsung.com) | Rel-12 | SP-56 | MTC, M2M |  |  | Mirko |  |  |
| 1631 | 448.5 | **BB1: Small Data and Device Triggering Enhancements (SDDTE)** | 594d? | 2012-06-18 A | 2014-09-11 A | 100% |  | 2012-06-18 | 2014-09-12 | 594d? |  |  | S2; C4; C3 | 24400h | 24400h | MTCe-SDDTE | PCG-29 |  | Intel | puneet.jain@intel.com | Rel-12 | SP-56 | MTC, M2M | MTCe-SDDTE |  | Maurice |  |  |
| 1632 | 448.5.1 | TR on Stage 2 BB1: Small Data and Device Triggering Enhancements | 394d? | 2012-06-18 A | 2013-12-11 A | 100% |  | 2012-06-18 | 2013-12-11 | 394d? |  | finish no earlier than 2013-12-11 | S2 | 3128h | 3128h | MTCe-SDDTE | PCG-29 | New TR 23.887 | Intel | puneet.jain@intel.com | Rel-12 | SP-56 | MTC, M2M |  |  | Maurice |  |  |
| 1633 | 448.5.2 | Stage 2 for BB1: Small Data and Device Triggering Enhancements | 390d? | 2012-06-26 A | 2013-12-11 A | 100% |  | 2012-06-26 | 2013-12-11 | 390d? |  | finish no earlier than 2013-12-11 | S2 | 3120h | 3120h | MTCe-SDDTE | PCG-29 | 23.682 | Intel | puneet.jain@intel.com | Rel-12 | SP-56 | MTC, M2M |  |  | Maurice |  |  |
| 1634 | 448.5.3 | **Stage 3 for BB1: Small Data and Device Triggering Enhancements** | 138d? | 2014-03-05 A | 2014-09-11 A | 100% |  | 2014-03-05 | 2014-09-12 | 138d? |  |  | C4; C3 | 3896h | 3896h | MTCe-SDDTE-CT | PCG-32 | Stage 3 | Huawei | peter.schmitt@huawei.com | Rel-12 | CP-63 | MTC, M2M | MTCe-SDDTE-CT |  | Kimmo |  |  |
| 1635 | 448.5.3.1 | CT4 part of Stage 3 for BB1: Small Data and Device Triggering Enhancement | 138d? | 2014-03-05 A | 2014-09-11 A | 100% |  | 2014-03-05 | 2014-09-12 | 138d? |  | finish no earlier than 2014-09-12 | C4 | 1104h | 1104h | MTCe-SDDTE-CT | PCG-32 | 29.002, 29.336, 23.008, 29.337, 29.338, 29.230 | Huawei | peter.schmitt@huawei.com | Rel-12 | CP-63 | MTC, M2M |  |  | Kimmo |  |  |
| 1636 | 448.5.3.2 | CT3 part of Stage 3 for BB1: Small Data and Device Triggering Enhancement | 73d? | 2014-03-05 A | 2014-06-13 A | 100% |  | 2014-03-05 | 2014-06-13 | 73d? |  | finish no earlier than 2014-06-13 | C3 | 584h | 584h | MTCe-SDDTE-CT | PCG-32 | 29.368 | Huawei | peter.schmitt@huawei.com | Rel-12 | CP-63 | MTC, M2M |  |  | Adrian |  |  |
| 1637 | 448.6 | Deleted - BB2: Monitoring Enhancements (MONTE) | 131d? | 2012-06-18 A | 2012-12-12 A | 100% |  | 2012-06-18 | 2012-12-12 | 131d? |  | finish no earlier than 2012-12-12 | S2 | 1048h | 1048h | MTCe-MONTE | PCG-29 | 23.682 | Intel | puneet.jain@intel.com | Rel-12 | SP-56 | MTC, M2M | MTCe-MONTE |  | Maurice | PCG-30 | SP-58 |
| 1638 | 448.7 | **BB3: UE Power Consumptions Optimizations (UEPCOP)** | 1031d? | 2012-06-18 A | 2016-05-12 | 93% | 71.29d? | 2012-06-18 | 2014-09-12 | 594d? | 681d |  | S2; C1; C4; C6; G1 | 49221.3h | 44157h | MTCe-UEPCOP | PCG-29 |  | Ericsson | peter.hedman@ericsson.com | Rel-12 | SP-56 | MTC, M2M | MTCe-UEPCOP |  | Maurice |  |  |
| 1639 | 448.7.1 | TR on Stage 2 BB3: UE Power Consumptions Optimizations (UEPCOP) | 394d? | 2012-06-18 A | 2013-12-11 A | 100% |  | 2012-06-18 | 2013-12-11 | 394d? |  | finish no earlier than 2013-12-11 | S2 | 3128h | 3128h | MTCe-UEPCOP | PCG-29 | New TR 23.887 | Ericsson | peter.hedman@ericsson.com | Rel-12 | SP-56 | MTC, M2M |  |  | Maurice |  |  |
| 1640 | 448.7.2 | Stage 2 for BB3: UE Power Consumptions Optimizations (UEPCOP) | 390d? | 2012-06-26 A | 2013-12-11 A | 100% |  | 2012-06-26 | 2013-12-11 | 390d? |  | finish no earlier than 2013-12-11 | S2 | 3120h | 3120h | MTCe-UEPCOP | PCG-29 | 23.060, 23.401, 23.682 | Ericsson | peter.hedman@ericsson.com | Rel-12 | SP-56 | MTC, M2M |  |  | Maurice |  |  |
| 1641 | 448.7.3 | **Stage 3 for BB3: UE Power Consumptions Optimizations (UEPCOP)** | 597d? | 2013-12-06 A | 2016-03-15 A | 100% |  | 2013-12-06 | 2014-09-12 | 202d? |  |  | C1; C4; C6 | 20696h | 20696h | MTCe-UEPCOP-CT | PCG-32 | Stage 3 | Ericsson | mikael.wass@ericsson.com | Rel-12 | CP-62 | MTC, M2M | MTCe-UEPCOP-CT |  | Frederic |  |  |
| 1642 | 448.7.3.1 | CT1 part of Stage 3 for BB3: UE Power Consumptions Optimizations (UEPCOP) | 202d? | 2013-12-06 A | 2014-09-11 A | 100% |  | 2013-12-06 | 2014-09-12 | 202d? |  | finish no earlier than 2014-09-12 | C1 | 1608h | 1608h | MTCe-UEPCOP-CT1 | PCG-32 | 24.008, 24.301 | Ericsson | mikael.wass@ericsson.com | Rel-12 | CP-62 | MTC, M2M |  |  | Frederic |  |  |
| 1643 | 448.7.3.2 | Deleted - CT4 part of Stage 3 for BB3: UE Power Consumptions Optimizations (UEPCOP) | 201d? | 2013-12-09 A | 2014-09-11 A | 100% |  | 2013-12-09 | 2014-09-12 | 201d? |  | finish no earlier than 2014-09-12 | C4 | 1608h | 1608h | MTCe-UEPCOP-CT4 | PCG-32 | 29.274, 29.060, 23.008 | Ericsson | mikael.wass@ericsson.com | Rel-12 | CP-62 | MTC, M2M |  |  | Kimmo | PCG-33 | CP-65 |
| 1644 | 448.7.3.3 | CT6 part of Stage 3 for BB3: UE Power Consumptions Optimizations (UEPCOP) | 263d? | 2013-12-09 A | 2014-12-09 A | 100% |  | 2013-12-09 | 2014-09-12 | 201d? |  | finish no earlier than 2014-12-09 | C6 | 2104h | 2104h | MTCe-UEPCOP-CT6 | PCG-32 | 31.101, 31.102, 31.111 | Ericsson | mikael.wass@ericsson.com | Rel-12 | CP-62 | MTC, M2M |  | CP-140697 | Xavier |  |  |
| 1645 | 448.7.3.4 | UE Conformance Test Aspects - UE Power Consumptions Optimizations (UEPCOP) | 131d? | 2015-09-15 A | 2016-03-15 A | 100% |  |  |  |  |  | finish no earlier than 2016-03-15 | R5 | 1048h | 1048h | MTCe-UEPCOP-UEConTest | PCG-35 |  | Ericsson |  | Rel-12 | RP-69 |  |  |  |  |  |  |
| 1646 | 448.7.4 | Support of Power Saving Mode in GERAN | 5d? | 2014-08-25 A | 2014-08-29 A | 100% |  |  |  |  |  | finish no earlier than 2014-08-29 | G1 | 40h | 40h | MTCe-UEPCOP-GERAN | PCG-33 | 43.022 | Ericsson | sajal.kumar.das@ericsson.com | Rel-12 | GP-63 |  | MTCe-UEPCOP-GERAN |  |  |  |  |
| 1647 | 448.7.5 | Testing of Support of Power Saving Mode in GERAN | 132d? | 2015-11-11 A | 2016-05-12 | 10% | 118.8d? |  |  |  | 681d | finish no earlier than 2016-05-12 | G3 | 1056h | 105.6h | MTCe-UEPCOP_GERAN3new | PCG-36 |  | Ericsson | sajal.kumar.das@ericsson.com | Rel-12 | SP-70 |  | MTCe-UEPCOP-GERAN |  |  |  |  |
| 1648 | 448.8 | Deleted - BB4: Group based MTC feature (GROUP) | 129d? | 2012-06-20 A | 2012-12-12 A | 100% |  | 2012-06-20 | 2012-12-12 | 129d? |  | finish no earlier than 2012-12-12 | S2 | 1032h | 1032h | MTCe-GROUP | PCG-29 | 23.682 | KPN | Annemieke Kips | Rel-12 | SP-56 | MTC, M2M | MTCe-GROUP |  | Maurice | PCG-30 | SP-58 |

Notes:
- 1624: -
- 1625: CD:Thu 11/12/14->Sun 15/03/15; Compl:25%->80%; Stat Rep: RP-141327->RP-141863 1st Apr 15: Compl:80%->100% 1st Apr 15: Stat Rep: RP-141863->RP-150081
- 1626: -
- 1627: SP#59 completed. Define requirements for interworking with M2M service enablement layer specified by ETSI TC M2M in TS 102 689 ( specification for Service Enablement layer)
- 1628: SP#59 completed. Updated WID SP-120541=>SP-130105
- 1629: SP#63 completed. TR 33.868v100 for 1-step Approval. Was Rel-10 UID_460023 (Security for NIMTC). Was Rel-11 UID_490028 (TR on Security aspects of MTC). SP#56 activity transferred to Rel-12 Feature MTCe
- 1630: SP#63 completed. TS 33.187v100 for 1-step Approval
- 1631: -
- 1632: SP#62 completed. TR 23.887v200 for Approval
- 1633: SP#62 completed
- 1634: CP#65 updated WID CP-140272=>CP-140489
- 1635: CP#65 completed. Updated WID CP-140272=>CP-140489
- 1636: CP#64 completed
- 1637: SP#58 stopped (at 20% completion)
- 1638: -
- 1639: SP#62 completed. TR 23.887v200 for Approval
- 1640: SP#62 completed
- 1641: -
- 1642: CP#65 completed
- 1643: CP#65 stopped (no inpact on CT4)
- 1644: CP#65 completion 09/14=>12/14. Exception in CP-140697; June2015: Compl:90%->100
- 1645: tested: MTCe-UEPCOP was a REL-12 SA2 WI; NAS over LTE and UTRA;1/1/16: Compl:0%->25%22/3/16: C
- 1646: GP#63 approved WID and completed
- 1647: 7/12/15: created.02/3/16: acronym: MTCe-UEPCOP-GERAN_test->MTCe-UEPCOP_GERAN3new; 2/3/16: 0%->10
- 1648: SP#58 stopped (at 25% completion)

| ID | WBS | Task | Duration | Start | Finish | Complete | Remaining | Baseline start | Baseline finish | Baseline duration | Total slack | Constraint | Resources | Work | Actual work | Acronym | PCG approved | WI rapporteur name | WI rapporteur e-mail | Release | TSG approved | MCC resp | Special Focus Doc | Acronym_3GU_Export | Status Report | PCG stopped | TSG stopped |
| --- | --- | --- | --- | --- | --- | --- | --- | --- | --- | --- | --- | --- | --- | --- | --- | --- | --- | --- | --- | --- | --- | --- | --- | --- | --- | --- | --- |
| 1649 | 448.9 | **RAN enhancements for Machine-Type and other mobile data applications Communications** | 161.2d? | 2014-02-03 A | 2014-09-12 A | 100% |  | 2014-02-03 | 2014-09-12 | 160.2d? |  |  | R2; R3 | 3651h | 3651h | MTCe-RAN | PCG-32 | ZTE | sergio.parolari@zte.com.cn | Rel-12 | RP-62 | Yong-Jun | MTC, M2M | MTCe-RAN |  |  |  |
| 1650 | 448.9.1 | Core part: RAN enhancements for Machine-Type and other mobile data applications Communications | 133d? | 2014-02-03 A | 2014-09-12 A | 100% |  | 2014-02-03 | 2014-09-12 | 133d? |  | finish no earlier than 2014-09-12 | R2; R3 | 2128h | 2128h | MTCe-RAN-Core | PCG-32 | ZTE | sergio.parolari@zte.com.cn | Rel-12 | RP-62 | Yong-Jun | MTC, M2M | MTCe-RAN-Core | RP-141096 |  |  |
| 1651 | 449 | **Low cost & enhanced coverage MTC UE for LTE** | 922d? | 2013-06-15 A | 2016-12-15 | 99% | 0d? | 2013-06-20 | 2015-03-13 | 456d? | 0d |  | R1; R2; R4 | 34104h | 12595.2h | LC_MTC_LTE | PCG-31 | Vodafone | eric.bouton@vodafone.com | Rel-12 | RP-60 | Patrick | MTC, M2M | LC_MTC_LTE |  |  |  |
| 1652 | 449.1 | Core part: Low cost & enhanced coverage MTC UE for LTE | 174.67d? | 2013-06-15 A | 2014-12-15 A | 100% |  | 2013-10-15 | 2014-09-12 | 108.67d? |  | finish no earlier than 2014-12-15 | R1; R2; R4 | 4192h | 4192h | LC_MTC_LTE-Core | PCG-31 | Vodafone | eric.bouton@vodafone.com | Rel-12 | RP-60 | Patrick | MTC, M2M | LC_MTC_LTE-Core | RP-142024 |  |  |
| 1653 | 449.2 | Perf. part: Low cost & enhanced coverage MTC UE for LTE | 522d? | 2013-06-15 A | 2015-06-15 A | 100% |  | 2013-06-20 | 2015-03-13 | 456d? |  | finish no earlier than 2015-06-15 | R4 | 4176h | 4176h | LC_MTC_LTE-Perf | PCG-31 | Vodafone | eric.bouton@vodafone.com | Rel-12 | RP-60 | Issam | MTC, M2M | LC_MTC_LTE-Perf | RP-150915 |  |  |
| 1654 | 449.3 | UE Conformance Test Aspects - Low cost & enhanced coverage MTC UE for LTE | 460d? | 2015-03-16 A | 2016-12-15 A | 100% |  |  |  |  |  | finish no earlier than 2016-12-15 | R5 | 3680h | 3680h | LC_MTC_LTE-UEConTest | PCG-34 | Ericsson |  | Rel-12 | RP-67 |  |  |  |  |  |  |
| 1655 | 450 | **Policy and Charging Control for supporting fixed broadband access networks** | 660d? | 2012-06-20 A | 2014-12-12 A | 100% |  | 2012-06-20 | 2014-09-17 | 595d? |  |  | S2; S1; S5; C3; C1; C4 | 84075.4h | 84075.4h | P4C | PCG-29 | Huawei | marco.spini@huawei.com | Rel-12 | SP-56 | Maurice |  | P4C |  |  |  |
| 1656 | 450.1 | Stage 1 for Policy and Charging Support for Fixed Mobile Convergence | 3d? | 2012-09-10 A | 2012-09-12 A | 100% |  | 2012-09-10 | 2012-09-12 | 3d? |  | finish no earlier than 2012-09-12 | S1 | 24h | 24h | P4C-FMC | PCG-29 | Huawei | amar.deol@huawei.com | Rel-12 | SP-57 | Alain |  | P4C-FMC |  |  |  |
| 1657 | 450.2 | **BB1: Policy and Charging Control for supporting traffic from fixed terminals and NSWO (Non Seamless WLAN Offload) traffic from 3GPP UEs in fixed broadband access networks (P4C-F)** | 660d? | 2012-06-20 A | 2014-12-12 A | 100% |  | 2012-06-20 | 2014-09-17 | 595d? |  |  | S2; S5; C3; C1; C4 | 45657.3h | 45657.3h | P4C-F | PCG-29 | Huawei | marco.spini@huawei.com | Rel-12 | SP-56 | Maurice | WLAN | P4C-F |  |  |  |
| 1658 | 450.2.1 | TR on Stage 2 for BB1: Policy and Charging Control for supporting traffic from fixed terminals and NSWO traffic from 3GPP UEs in fixed broadband access networks (P4C-F) | 539.9d? | 2012-06-20 A | 2014-12-12 A | 100% |  | 2012-06-20 | 2014-09-17 | 476.9d? |  | finish no earlier than 2014-12-12 | S2 | 4290.1h | 4290.1h | P4C-F-SA2TR | PCG-29 | Huawei | marco.spini@huawei.com | Rel-12 | SP-56 | Maurice | WLAN |  |  |  |  |
| 1659 | 450.2.2 | Stage 2 for BB1: Policy and Charging Control for supporting traffic from fixed terminals and NSWO traffic from 3GPP UEs in fixed broadband access networks (P4C-F) | 272.9d? | 2012-06-20 A | 2013-12-11 A | 100% |  | 2012-06-20 | 2013-12-11 | 272.9d? |  | finish no earlier than 2013-12-11 | S2 | 2183.2h | 2183.2h | P4C-F-SA2 | PCG-29 | Huawei | marco.spini@huawei.com | Rel-12 | SP-56 | Maurice | WLAN |  |  |  |  |
| 1660 | 450.2.3 | **Stage 3 for BB1: Policy and Charging Control for supporting traffic from fixed terminals and NSWO traffic from 3GPP UEs in fixed broadband access networks** | 203d? | 2013-09-06 A | 2014-06-13 A | 100% |  | 2013-09-06 | 2014-06-13 | 203d? |  |  | C3; C1; C4 | 8088h | 8088h | P4C-F-CT3 | PCG-31 | Huawei | Xia Haitao (xiahaitao@huawei.com) | Rel-12 | CP-61 | Adrian | WLAN | P4C-F-CT3 |  |  |  |
| 1661 | 450.2.3.1 | CT3 part of Stage 3 for BB1: Policy and Charging Control for supporting traffic from fixed terminals and NSWO traffic from 3GPP UEs in fixed broadband access networks | 203d? | 2013-09-06 A | 2014-06-13 A | 100% |  | 2013-09-06 | 2014-06-13 | 203d? |  | finish no earlier than 2014-06-13 | C3 | 1608h | 1608h | P4C-F-CT3 | PCG-31 | Huawei | Xia Haitao (xiahaitao@huawei.com) | Rel-12 | CP-61 | Adrian | WLAN |  |  |  |  |
| 1662 | 450.2.3.2 | CT1 part of Stage 3 for BB1: Policy and Charging Control for supporting traffic from fixed terminals and NSWO traffic from 3GPP UEs in fixed broadband access networks | 65d? | 2013-12-06 A | 2014-03-05 A | 100% |  | 2013-12-06 | 2014-03-05 | 65d? |  | finish no earlier than 2014-03-05 | C1 | 512h | 512h | P4C-F-CT3 | PCG-32 | Huawei | Xia Haitao (xiahaitao@huawei.com) | Rel-12 | CP-62 | Frederic | WLAN |  |  |  |  |
| 1663 | 450.2.3.3 | CT4 part of Stage 3 for BB1: Policy and Charging Control for supporting traffic from fixed terminals and NSWO traffic from 3GPP UEs in fixed broadband access networks | 137d? | 2013-12-06 A | 2014-06-13 A | 100% |  | 2013-12-06 | 2014-06-13 | 137d? |  | finish no earlier than 2014-06-13 | C4 | 1096h | 1096h | P4C-F-CT3 | PCG-32 | Huawei | Xia Haitao (xiahaitao@huawei.com) | Rel-12 | CP-62 | Kimmo | WLAN |  |  |  |  |
| 1664 | 450.2.4 | Policy and Charging Enforcement Function (PCEF) based Charging for traffic from fixed terminals and NSWO traffic from 3GPP UEs in fixed broadband access networks (Stage 2/3) | 326d? | 2013-06-21 A | 2014-09-17 A | 100% |  | 2013-06-21 | 2014-09-17 | 326d? |  | finish no earlier than 2014-09-17 | S5 | 2608h | 2608h | P4C-F-CH_P | PCG-31 | Alcatel-Lucent | maryse.gardella@alcatel-lucent.com | Rel-12 | SP-60 | Mirko | WLAN | P4C-F-CH_P |  |  |  |
| 1665 | 450.2.5 | Traffic Detection Function (TDF) based Charging for traffic from fixed terminals and NSWO traffic from 3GPP UEs in fixed broadband access networks (Stage 2/3) | 261d? | 2013-06-24 A | 2014-06-18 A | 100% |  | 2013-06-24 | 2014-06-18 | 261d? |  | finish no earlier than 2014-06-18 | S5 | 2088h | 2088h | P4C-F-CH_T | PCG-31 | Openet Telecom | alan.mcnamee@openet.com | Rel-12 | SP-60 | Mirko | WLAN | P4C-F-CH_T |  |  |  |
| 1666 | 450.3 | **BB2: Policy and Charging Control for 3GPP UEs connected to BroadBand Forum access network as Trusted network in Interworking scenario (P4C-TI)** | 266d? | 2012-06-20 A | 2013-06-19 A | 100% |  | 2012-06-20 | 2013-06-19 | 266d? |  |  | S2 | 2610.07h | 2610.07h | P4C-TI | PCG-29 | Alcatel-Lucent | konstantin.livanos@alcatel-lucent.com | Rel-12 | SP-56 | Maurice |  | P4C-TI |  |  |  |
| 1667 | 450.3.1 | TR on Stage 2 for BB2: Policy and Charging Control for 3GPP UEs connected to BroadBand Forum access network as Trusted network in Interworking scenario (P4C-TI) | 109.2d? | 2012-06-20 A | 2013-06-19 A | 100% |  | 2012-06-20 | 2013-06-19 | 109.2d? |  | finish no earlier than 2013-06-06 | S2 | 862.87h | 862.87h | P4C-TI-SA2TR | PCG-29 | Alcatel-Lucent | konstantin.livanos@alcatel-lucent.com | Rel-12 | SP-56 | Maurice |  |  |  |  |  |
| 1668 | 450.3.2 | Stage 2 for BB2: Policy and Charging Control for 3GPP UEs connected to BroadBand Forum access network as Trusted network in Interworking scenario (P4C-TI) | 109.2d? | 2012-06-20 A | 2013-06-19 A | 100% |  | 2012-06-20 | 2013-06-19 | 109.2d? |  | finish no earlier than 2013-06-19 | S2 | 873.6h | 873.6h | P4C-TI-SA2 | PCG-29 | Alcatel-Lucent | konstantin.livanos@alcatel-lucent.com | Rel-12 | SP-56 | Maurice |  |  |  |  |  |
| 1669 | 450.4 | Deleted - BB3: Policy and Charging Control for 3GPP UEs connected to fixed broadband access network via S2b and S2c reference points for EPC routed traffic (P4C-S2bc) | 128d? | 2012-06-21 A | 2012-12-12 A | 100% |  | 2012-06-21 | 2012-12-12 | 128d? |  | finish no earlier than 2012-12-12 | S2 | 1024h | 1024h | P4C-S2bc | PCG-29 | ZTE | Tricci So (tso@zteusa.com) | Rel-12 | SP-56 | Maurice |  | P4C-S2bc |  | PCG-30 | SP-58 |
| 1670 | 450.5 | Deleted - BB4: Policy and Charging Control for EPC routed traffic over fixed broadband access networks of 3GPP UEs connected via H(e)NB in convergent scenarios (P4C-HeNB) | 128d? | 2012-06-21 A | 2012-12-12 A | 100% |  | 2012-06-21 | 2012-12-12 | 128d? |  | finish no earlier than 2012-12-12 | S2 | 1024h | 1024h | P4C-HeNB | PCG-29 | NEC | Stefan.Schmid@neclab.eu | Rel-12 | SP-56 | Maurice |  | P4C-HeNB |  | PCG-30 | SP-58 |
| 1671 | 450.6 | Deleted - BB5: Policy and Charging Control for supporting Layer 2 traffic in fixed broadband access network (P4C-FL2) | 128d? | 2012-06-21 A | 2012-12-12 A | 100% |  | 2012-06-21 | 2012-12-12 | 128d? |  | finish no earlier than 2012-12-12 | S2 | 1024h | 1024h | P4C-FL2 | PCG-29 | Huawei | marco.spini@huawei.com | Rel-12 | SP-56 | Maurice |  | P4C-FL2 |  | PCG-30 | SP-58 |
| 1672 | 450.7 | Deleted - BB6: Policy and Charging Control for 3GPP UEs connected to fixed broadband access networks via S2a reference point for EPC routed traffic in convergence (P4C-TC) | 129d? | 2012-06-20 A | 2012-12-12 A | 100% |  | 2012-06-20 | 2012-12-12 | 129d? |  | finish no earlier than 2012-12-12 | S2 | 1032h | 1032h | P4C-TC | PCG-29 | ZTE | Tricci So (tso@zteusa.com) | Rel-12 | SP-56 | Maurice |  | P4C-TC |  | PCG-30 | SP-58 |

Notes:
- 1649: Triggered by TR 23.887 Machine Type and other mobile data applications Communications Enhancements (MTCe), TR 37.869 Study on Enhancements MTC and other Mobile Data Applications; RAN aspects (FS_MTCe_RAN), Rel-11 TR 23.888 SIMTC / Impacted TSs and TRs: UTRA, LTE
- 1650: RP#65 completed / Impacted TSs and TRs: 25.300, 25.304, 25.413, 36.300, 36.304, 36.413, 36.423
- 1651: Triggered by Rel-11 TR 36.888 (FS_LC_MTC_UE) / Impacted TSs and TRs: LTE
- 1652: ; CD:Thu 18/06/15->Mon 15/06/15; WID: RP-130848->RP-140522; Stat Rep: RP-141221->RP-142024 / Impacted TSs and TRs: 36.101, 36.104, 36.133, 36.201, 36.211, 36.212, 36.213, 36.300, 36.302, 36.306, 36.321, 36.331
- 1653: ; CD:Thu 18/06/15->Mon 15/06/15; WID: RP-130848->RP-140522; Stat Rep: RP-141221->RP-142024 1st Apr 15: Compl:65%->90% 1st Apr 15: CD:Sun 15/03/15->Mon 15/06/15 1st Apr 15: Stat Rep: RP-142024->RP-150149 03/07/15: Compl:90%->100% 03/07/15: WID: RP-14052 / Impacted TSs and TRs: 36.101, 36.104, 36.133
- 1654: 03/07/15: Compl:0%->13% 03/07/15: WID: RP-150135->RP-150838 03/07/15: Stat Rep: ->RP-150833 29/09/15: Compl:13%->25% 29/09/15: Stat Rep: RP-150833->RP-151165 ; 1/1/16: Compl:25%->70% ; 1/1/16: CD:Tue 15/12/15->Tue 15/03/16
- 1655: Linked to BBF, IETF work. SP#58 stopped BB3 to BB6. Split BB1 and BB2 into TR and Stage 2 work / Impacted TSs and TRs: Stage 1/2/3
- 1656: SP#57 completed / Impacted TSs and TRs: 22.278
- 1657: -
- 1658: SP#64 TR 23.896 was never sent for approval due to incomplete P4C BBs. SP#61 TR 23.896v100 for Information. Dec.14: 90->100%. Mar15: 23.896 for approval. / Impacted TSs and TRs: new TR 23.896
- 1659: SP#62 completed / Impacted TSs and TRs: 23.139, 23.203
- 1660: - / Impacted TSs and TRs: Stage 3
- 1661: CP#64 completed / Impacted TSs and TRs: 29.212, 29.213, 29.215, 29.219
- 1662: CP#63 completed / Impacted TSs and TRs: 24.302
- 1663: CP#64 completed / Impacted TSs and TRs: 29.273
- 1664: SP#65 completed. Introduce Charging Characteristics in Convergent scenario, Include missing fixed user location information for NSWO / Impacted TSs and TRs: Stage 2 (32.240, 32.251), Stage 3 (32.298, 32.299)
- 1665: SP#64 completed / Impacted TSs and TRs: Stage 2 (32.240, 32.251), Stage 3 (32.298, 32.299)
- 1666: -
- 1667: SP#60 completed / Impacted TSs and TRs: new TR 23.839
- 1668: SP#60 completed / Impacted TSs and TRs: 23.139, 23.203
- 1669: SP#58 stopped (at 0% completion) / Impacted TSs and TRs: 23.139, 23.203, new TR 23.896
- 1670: SP#58 stopped (at 0% completion) / Impacted TSs and TRs: 23.139, 23.203, new TR 23.896
- 1671: SP#58 stopped (at 0% completion) / Impacted TSs and TRs: 23.139, 23.203, new TR 23.896
- 1672: SP#58 stopped (at 30% completion) / Impacted TSs and TRs: 23.139, 23.203, new TR 23.896

| ID | WBS | Task | Duration | Start | Finish | Complete | Remaining | Baseline start | Baseline finish | Baseline duration | Total slack | Constraint | Resources | Work | Actual work | Acronym | PCG approved | Impacted TSs and TRs | WI rapporteur name | WI rapporteur e-mail | Release | TSG approved | MCC resp | Acronym_3GU_Export | Status Report | Special Focus Doc | PCG stopped | TSG stopped |
| --- | --- | --- | --- | --- | --- | --- | --- | --- | --- | --- | --- | --- | --- | --- | --- | --- | --- | --- | --- | --- | --- | --- | --- | --- | --- | --- | --- | --- |
| 1673 | 451 | **IMS Business Trunking for IP-PBX in Static Mode of Operation** | 847.1d? | 2011-09-28 A | 2014-12-09 A | 100% |  | 2011-09-28 | 2014-09-12 | 782.1d? |  |  | S2; S1; C1; C3 | 43555.2h | 43555.2h | BusTI | PCG-29 | Stage 1/2/3 | Deutsche Telekom | michele.zarri@telekom.com | Rel-12 | SP-56 | Maurice | BusTI |  |  |  |  |
| 1674 | 451.1 | Stage 1 for IMS Business Trunking for IP-PBX in Static Mode of Operation | 64d? | 2011-09-28 A | 2012-09-12 A | 100% |  | 2011-09-28 | 2012-09-12 | 64d? |  | finish no earlier than 2012-08-30 | S1 | 504h | 504h | BusTI-SA1 | PCG-29 | 22.228 | Deutsche Telekom | kurt.bischinger@t-mobile.at | Rel-12 | SP-56 | Alain |  |  |  |  |  |
| 1675 | 451.2 | TR on IMS Business Trunking for IP-PBX in Static Mode of Operation | 268d? | 2012-06-18 A | 2013-06-19 A | 100% |  | 2012-06-18 | 2013-06-19 | 268d? |  | finish no earlier than 2013-06-19 | S2; S1 | 4288h | 4288h | BusTI-SATR | PCG-29 | new TR 23.897 | Deutsche Telekom | michele.zarri@telekom.com | Rel-12 | SP-56 | Maurice |  |  |  |  |  |
| 1676 | 451.3 | Stage 2 for IMS Business Trunking for IP-PBX in Static Mode of Operation | 263d? | 2012-06-25 A | 2013-06-19 A | 100% |  | 2012-06-25 | 2013-06-19 | 263d? |  | finish no earlier than 2013-06-19 | S2 | 2104h | 2104h | BusTI-SA2 | PCG-29 | 23.228 | Deutsche Telekom | michele.zarri@telekom.com | Rel-12 | SP-56 | Maurice |  |  |  |  |  |
| 1677 | 451.4 | **CT aspects of IMS Business Trunking for IP-PBX in Static Mode of Operation (Stage 3)** | 333d? | 2013-09-06 A | 2014-12-09 A | 100% |  | 2013-09-06 | 2014-09-12 | 268d? |  |  | C1; C3 | 9552h | 9552h | BusTI-CT | PCG-31 | Stage 3 | Deutsche Telekom | michael.kreipl@telekom.de | Rel-12 | CP-61 | Frederic | BusTI-CT |  |  |  |  |
| 1678 | 451.4.1 | CT1 part of CT aspects of IMS Business Trunking for IP-PBX in Static Mode of Operation (Stage 3) | 329d? | 2013-09-06 A | 2014-12-09 A | 100% |  | 2013-09-06 | 2014-09-12 | 267d? |  | finish no earlier than 2014-12-09 | C1 | 2632h | 2632h | BusTI-CT | PCG-31 | 23.218, 24.229, 24.525 (transfer of ETSI TS 182 025) | Deutsche Telekom | michael.kreipl@telekom.de | Rel-12 | CP-61 | Frederic |  | CP-140607 |  |  |  |
| 1679 | 451.4.2 | CT3 part of CT aspects of IMS Business Trunking for IP-PBX in Static Mode of Operation (Stage 3) | 201d? | 2013-09-06 A | 2014-06-11 A | 100% |  | 2013-09-06 | 2014-06-13 | 201d? |  | finish no earlier than 2014-06-13 | C3 | 1608h | 1608h | BusTI-CT | PCG-31 | 29.165 | Deutsche Telekom | michael.kreipl@telekom.de | Rel-12 | CP-61 | Adrian |  |  |  |  |  |
| 1680 | 452 | **WLAN Network Selection for 3GPP Terminals** | 659d? | 2012-06-18 A | 2014-12-09 A | 100% |  | 2012-06-18 | 2014-09-12 | 594d? |  |  | S2; S1; S3; C1 | 35272h | 35272h | WLAN_NS | PCG-29 | Stage 1/2/3 | Intel | vivek.g.gupta@intel.com | Rel-12 | SP-56 | Maurice | WLAN_NS |  | WLAN |  |  |
| 1681 | 452.1 | TR on Stage 2 for WLAN Network Selection for 3GPP Terminals | 396d? | 2012-06-18 A | 2013-12-11 A | 100% |  | 2012-06-18 | 2013-12-11 | 396d? |  | finish no earlier than 2013-12-11 | S2; S1 | 6336h | 6336h | WLAN_NS-SATR | PCG-29 | New TR 23.865 | Intel | vivek.g.gupta@intel.com | Rel-12 | SP-56 | Maurice |  |  | WLAN |  |  |
| 1682 | 452.2 | Stage 2 for WLAN Network Selection for 3GPP Terminals | 392d? | 2012-06-22 A | 2013-12-11 A | 100% |  | 2012-06-22 | 2013-12-11 | 392d? |  | finish no earlier than 2013-12-11 | S2 | 3136h | 3136h | WLAN_NS-SA2 | PCG-29 | 23.402, 23.865 | Intel | vivek.g.gupta@intel.com | Rel-12 | SP-56 | Maurice |  |  | WLAN |  |  |
| 1683 | 452.3 | Deleted - TR on Security Aspects of WLAN Network Selection for 3GPP Terminals | 326d? | 2012-12-13 A | 2014-03-07 A | 100% |  | 2012-12-13 | 2014-03-07 | 326d? |  | finish no earlier than 2014-03-07 | S3 | 2608h | 2608h | WLAN_Nsdel | PCG-30 | New TR 33.865 | Huawei | Lydia Xu (xuyixian@huawei.com) | Rel-12 | SP-58 | Mirko |  |  | WLAN | PCG-32 | CP-63 |
| 1684 | 452.4 | CT aspects of WLAN Network Selection for 3GPP Terminals (Stage 3) | 263d? | 2013-12-06 A | 2014-12-09 A | 100% |  | 2013-12-06 | 2014-09-12 | 201d? |  | finish no earlier than 2014-12-09 | C1 | 2104h | 2104h | WLAN_NS-CT | PCG-32 | 24.302, 24.312 | Qualcomm | Amer Catovic, amerc@qualcomm.com | Rel-12 | CP-62 | Frederic | WLAN_NS-CT | CP-140622 | WLAN |  |  |
| 1685 | 453 | **Deleted - IMS Registration Control** | 496d? | 2012-01-31 A | 2013-12-11 A | 100% |  | 2012-01-31 | 2013-12-11 | 496d? |  |  | S1; S2; C1; C4 | 23400h | 23400h | IMS_RegCon | PCG-29 | Stage 1/2/3 | China Mobile | lulu@chinamobile.com | Rel-12 | SP-57 | Alain | IMS_RegCon |  |  | PCG-32 | SP-62 |
| 1686 | 453.1 | Deleted - Stage 1 for IMS Registration Control | 164d? | 2012-01-31 A | 2012-09-12 A | 100% |  | 2012-01-31 | 2012-09-12 | 164d? |  | finish no earlier than 2012-09-12 | S1 | 1304h | 1304h | IMS_RegCon-del1 | PCG-29 | 22.228 | China Mobile | lulu@chinamobile.com | Rel-12 | SP-57 | Alain |  |  |  | PCG-32 | SP-62 |
| 1687 | 453.2 | Deleted - Stage 2 for IMS Registration Control | 262d? | 2012-12-13 A | 2013-12-11 A | 100% |  | 2012-12-13 | 2013-12-11 | 262d? |  | finish no earlier than 2013-12-11 | S2 | 2096h | 2096h | IMS_RegCon-del2 | PCG-30 | 23.228 | China Mobile | Jiang Yi (jiangyi@chinamobile.com) | Rel-12 | SP-58 | Maurice |  |  |  | PCG-32 | SP-62 |
| 1688 | 453.3 | **Deleted - CT aspects of IMS registration control** | 129d? | 2013-06-19 A | 2013-12-11 A | 100% |  | 2013-06-19 | 2013-12-11 | 129d? |  |  | C1; C4 | 4128h | 4128h | IMS_RegCon-CT | PCG-31 | Stage 2/3 | China Mobile | Jiang Yi (jiangyi@chinamobile.com) | Rel-12 | CP-60 | Frederic | IMS_RegCon-CT |  |  | PCG-32 | SP-62 |
| 1689 | 453.3.1 | Deleted - CT1 aspects of CT aspects of IMS registration control (Stage 2/3) | 129d? | 2013-06-19 A | 2013-12-11 A | 100% |  | 2013-06-19 | 2013-12-11 | 129d? |  | finish no earlier than 2013-12-11 | C1 | 1032h | 1032h | IMS_RegCon-CT1 | PCG-31 | 23.218, 24.229 | China Mobile | Jiang Yi (jiangyi@chinamobile.com) | Rel-12 | CP-60 | Frederic |  |  |  | PCG-32 | SP-62 |
| 1690 | 453.3.2 | Deleted - CT4 aspects of CT aspects of IMS registration control (Stage 3) | 129d? | 2013-06-19 A | 2013-12-11 A | 100% |  | 2013-06-19 | 2013-12-11 | 129d? |  | finish no earlier than 2013-12-11 | C4 | 1032h | 1032h | IMS_RegCon-CT4 | PCG-31 | 29.228, 29.229, 23.008 | China Mobile | Jiang Yi (jiangyi@chinamobile.com) | Rel-12 | CP-60 | Kimmo |  |  |  | PCG-32 | SP-62 |
| 1691 | 454 | **Proximity-based Services** | 1186d? | 2012-12-13 A | 2017-06-15 | 99% | 14.62d? | 2012-12-13 | 2015-03-13 | 593d? | 395d |  | S1; S2; S3; C1; C3; C4; C6; R1; R2; R4; S5; IETF | 175105h | 49262.2h | ProSe | PCG-30 | Stage 1/2 | Qualcomm | Rich Hovey (rhovey@qualcomm.com) | Rel-12 | SP-58 | Alain | ProSe |  | Public Safety (A-A) |  |  |
| 1692 | 454.1 | Stage 1 for Proximity-based Services | 137d? | 2012-12-13 A | 2013-06-19 A | 100% |  | 2012-12-13 | 2013-06-19 | 137d? |  | finish no earlier than 2013-06-19 | S1 | 1088h | 1088h | ProSe-SA1 | PCG-30 | 22.115, 22.278 | Qualcomm | Rich Hovey (rhovey@qualcomm.com) | Rel-12 | SP-58 | Alain |  |  | Public Safety (A-A) |  |  |
| 1693 | 454.2 | TR on Stage 2 for Proximity-based Services | 327d? | 2012-12-13 A | 2014-03-07 A | 100% |  | 2012-12-13 | 2014-03-07 | 327d? |  | finish no earlier than 2014-03-07 | S2 | 2608h | 2608h | ProSe-SA2TR | PCG-30 | New TR 23.703 | Qualcomm | Haris Zisimopoulos (harisz@qti.qualcomm.com) | Rel-12 | SP-58 | Maurice |  |  | Public Safety (A-A) |  |  |
| 1694 | 454.3 | Stage 2 for Proximity-based Services | 397d? | 2012-12-19 A | 2014-06-18 A | 100% |  | 2012-12-19 | 2014-06-18 | 397d? |  | finish no earlier than 2014-06-18 | S2 | 3168.8h | 3168.8h | ProSe-SA2 | PCG-30 | New TS 23.303 | Qualcomm | Haris Zisimopoulos (harisz@qti.qualcomm.com) | Rel-12 | SP-58 | Maurice |  |  | Public Safety (A-A) |  |  |
| 1695 | 454.4 | Security for Proximity-based Services | 464d? | 2013-03-13 A | 2014-12-12 A | 100% |  | 2013-03-13 | 2014-06-18 | 336d? |  | finish no earlier than 2014-12-12 | S3 | 3712h | 3712h | ProSe-SA3 | PCG-30 | 33.220, New TS 33.303 | Qualcomm | Adrian Escott (aescott@qti.qualcomm.com) | Rel-12 | SP-59 | Mirko |  | SP-140584 | Public Safety (A-A) |  |  |
| 1696 | 454.5 | (IETF) Security for Proximity-based Services (ietf-avtcore-srtp-aes-gcm) | 63d? | 2014-09-12 A | 2014-12-09 A | 100% |  |  |  |  |  | finish no earlier than 2014-12-09 | S3-IETF | 504h | 504h | ProSe | PCG-33 | RFC 7714 (was ietf-avtcore-srtp-aes-gcm) | Atle Monrad | atle.monrad@ericsson.com | Rel-12 | SP-65 |  |  |  | Public Safety (A-A) |  |  |

Notes:
- 1673: Linked to Rel-11 IPXS Feature UID_470051 Advanced IP Interconnection of Services. This WI defines a generic framework for interconnecting with any type of IMS based network including IP-PBXs.
- 1674: SP#57 completed. 22.228CR#0171
- 1675: SP#60 completed
- 1676: SP#60 completed
- 1677: -
- 1678: CP#65 completion 09/14=>12/14. Exception in CP-140607. Dec.14: 85->100%
- 1679: CP#64 completed
- 1680: Evaluate and if needed enhance existing 3GPP solutions for WLAN network selection taking into account WFA Hotspot 2.0 solutions
- 1681: SP#62 completed
- 1682: SP#62 completed
- 1683: SP#63 stopped (84% complete)
- 1684: CP#65 completion 09/14=>12/14. CP#65 exception CP-140622. Dec.14: 95->100%
- 1685: SP#62 stopped. Specify for fixed line the requirement of controlling user registration to IMS based on network information related to user location (e.g. IP address, DSLAM information)
- 1686: SP#57 completed
- 1687: SP#62 stopped at 50% completion
- 1688: SP#62 no CT/Stage 3 work is needed (stopped at 0% completion)
- 1689: SP#62 no CT/Stage 3 work is needed (stopped at 0% completion)
- 1690: SP#62 no CT/Stage 3 work is needed (stopped at 0% completion)
- 1691: SP#65 SA3 updated the SA-wide WID SP-140300=>SP-140574 (Moved the TR phase to Rel-13 as a stand-alone Study). Triggered by Rel-12 TR 22.803 Study on Proximity-based Services (FS_ProSe) UID_530044
- 1692: SP#60 completed
- 1693: SP#63 completed. TR 23.703v200 for Approval
- 1694: SP#64 completed open issue/alignment to RAN/SA3 decisions. SP#63 TS 23.303v100 for 1-step Approval
- 1695: SP#65 re-opened. Completion 06/14=>12/14. Exception in SP-140584. Updated WID SP-140300=>SP-140574 (Moved the TR phase to Rel-13 as a stand-alone Study). SP#64 completed. TS 33.303 v100 for 1-step Approval; Aug2015: 90%->100
- 1696: Submitted to IESG for publication; 7/3/16: 75%->100

| ID | WBS | Task | Duration | Start | Finish | Complete | Remaining | Baseline start | Baseline finish | Baseline duration | Total slack | Constraint | Resources | Work | Actual work | Acronym | PCG approved | WI rapporteur name | WI rapporteur e-mail | Release | TSG approved | Status Report | Special Focus Doc | Acronym_3GU_Export | MCC resp |
| --- | --- | --- | --- | --- | --- | --- | --- | --- | --- | --- | --- | --- | --- | --- | --- | --- | --- | --- | --- | --- | --- | --- | --- | --- | --- |
| 1697 | 454.6 | **Charging Aspects of Proximity-based Services** | 195d? | 2014-06-19 A | 2015-03-13 A | 100% |  | 2014-06-18 | 2014-09-17 | 66d? |  |  | S5 | 4160h | 4160h | ProSe-CH | PCG-33 | Qualcomm | Cheng Hong (hongc@qti.qualcomm.com) | Rel-12 | SP-64 | SP-140543 | Public Safety (A-A) | ProSe-CH |  |
| 1698 | 454.6.1 | Study on Charging support for ProSe one-to-many Direct Communication for Public Safety use | 130d? | 2014-06-19 A | 2014-12-12 A | 100% |  | 2014-06-18 | 2014-09-17 | 66d? |  | finish no earlier than 2014-12-12 | S5 | 1040h | 1040h | ProSe-CH-SA5TR | PCG-33 | Qualcomm | Cheng Hong (hongc@qti.qualcomm.com) | Rel-12 | SP-64 | SP-140543 | Public Safety (A-A) |  |  |
| 1699 | 454.6.2 | Specification of Charging Aspects of Proximity-based Services | 195d? | 2014-06-19 A | 2015-03-13 A | 100% |  | 2014-06-18 | 2014-09-17 | 66d? |  | finish no earlier than 2015-03-13 | S5 | 1560h | 1560h | ProSe-CH-SA5 | PCG-33 | Qualcomm | Cheng Hong (hongc@qti.qualcomm.com) | Rel-12 | SP-64 | SP-140543 | Public Safety (A-A) |  |  |
| 1700 | 454.7 | **CT aspects of Proximity-based Services (Stage 3)** | 203d? | 2014-03-05 A | 2014-12-09 A | 100% |  | 2014-03-05 | 2014-09-12 | 138d? |  |  | C1; C3; C4; C6 | 12888h | 12888h | ProSe-CT | PCG-32 | Qualcomm | Lena Chaponniere (lguellec@qti.qualcomm.com) | Rel-12 | CP-63 |  | Public Safety (A-A) | ProSe-CT | Frederic |
| 1701 | 454.7.1 | CT1 part of CT aspects of Proximity-based Services | 200d? | 2014-03-05 A | 2014-12-09 A | 100% |  | 2014-03-05 | 2014-09-12 | 138d? |  | finish no earlier than 2014-12-09 | C1 | 1600h | 1600h | ProSe-CT | PCG-32 | Qualcomm | Lena Chaponniere (lguellec@qti.qualcomm.com) | Rel-12 | CP-63 | CP-140615 | Public Safety (A-A) |  | Frederic |
| 1702 | 454.7.2 | CT3 part of CT aspects of Proximity-based Services | 200d? | 2014-03-05 A | 2014-12-09 A | 100% |  | 2014-03-05 | 2014-09-12 | 138d? |  | finish no earlier than 2014-12-09 | C3 | 1600h | 1600h | ProSe-CT | PCG-32 | Qualcomm | Lena Chaponniere (lguellec@qti.qualcomm.com) | Rel-12 | CP-63 | CP-140568 | Public Safety (A-A) |  | Adrian |
| 1703 | 454.7.3 | CT4 part of CT aspects of Proximity-based Services | 200d? | 2014-03-05 A | 2014-12-09 A | 100% |  | 2014-03-05 | 2014-09-12 | 138d? |  | finish no earlier than 2014-12-09 | C4 | 1600h | 1600h | ProSe-CT | PCG-32 | Qualcomm | Lena Chaponniere (lguellec@qti.qualcomm.com) | Rel-12 | CP-63 | CP-140484 | Public Safety (A-A) |  | Kimmo |
| 1704 | 454.7.4 | CT6 part of CT aspects of Proximity-based Services | 199d? | 2014-03-06 A | 2014-12-09 A | 100% |  | 2014-03-06 | 2014-09-12 | 137d? |  | finish no earlier than 2014-12-09 | C6 | 1592h | 1592h | ProSe-CT | PCG-32 | Qualcomm | Lena Chaponniere (lguellec@qti.qualcomm.com) | Rel-12 | CP-63 | CP-140695 | Public Safety (A-A) |  | Xavier |
| 1705 | 454.8 | **LTE Device to Device Proximity Services** | 857d? | 2014-03-11 A | 2017-06-15 | 96% | 30.71d? | 2014-03-06 | 2015-03-13 | 267d? | 395d |  | R1; R2; R4 | 35312h | 15933.4h | LTE_D2D_Prox | PCG-32 | Qualcomm | Shailesh Patil (patil@qti.qualcomm.com) | Rel-12 | RP-63 |  | Public Safety (A-A) | LTE_D2D_Prox | Patrick |
| 1706 | 454.8.1 | Core part: LTE Device to Device Proximity Services | 263d? | 2014-03-15 A | 2015-03-15 A | 100% |  | 2014-07-11 | 2014-09-12 | 45.67d? |  | finish no earlier than 2015-03-15 | R1; R2; R4 | 6312h | 6312h | LTE_D2D_Prox-Core | PCG-32 | Qualcomm | Shailesh Patil (patil@qti.qualcomm.com) | Rel-12 | RP-63 | RP-150094 | Public Safety (A-A) | LTE_D2D_Prox-Core | Patrick |
| 1707 | 454.8.2 | Perf. part: LTE Device to Device Proximity Services | 464d? | 2014-03-11 A | 2015-12-15 A | 100% |  | 2014-03-06 | 2015-03-13 | 267d? |  | finish no earlier than 2015-12-15 | R4 | 3712h | 3712h | LTE_D2D_Prox-Perf | PCG-32 | Qualcomm | Shailesh Patil (patil@qti.qualcomm.com) | Rel-12 | RP-63 | RP-151276 | Public Safety (A-A) | LTE_D2D_Prox-Perf | Issam |
| 1708 | 454.8.3 | UE Conformance Test Aspects – LTE Device-to-Device Proximity Services | 590d? | 2015-03-16 A | 2017-06-15 | 92% | 47.2d? |  |  |  | 395d | finish no earlier than 2017-06-15 | R5 | 4720h | 4342.4h | LTE_D2D_Prox-UEConTest | PCG-34 | Qualcomm | svora@qti.qualcomm.com | Rel-12 | RP-67 |  |  |  |  |
| 1709 | 455 | **Web Real Time Communication access to IMS** | 530d? | 2012-12-14 A | 2014-12-12 | 88% | 63.97d? | 2012-12-14 | 2014-12-10 | 525d? | 1050d |  | S1; S2; S3 | 34985.8h | 22067h | IMS_WebRTC | PCG-30 | China Mobile | lulu@chinamobile.com | Rel-12 | SP-58 |  |  | IMS_WebRTC | Alain |
| 1710 | 455.1 | Stage 1 for Web Real Time Communication access to IMS | 136d? | 2012-12-14 A | 2013-06-19 A | 100% |  | 2012-12-14 | 2013-06-19 | 136d? |  | finish no earlier than 2013-06-19 | S1 | 1088h | 1088h | IMS_WebRTC | PCG-30 | China Mobile | lulu@chinamobile.com | Rel-12 | SP-58 |  |  |  | Alain |
| 1711 | 455.2 | TR on Stage 2 for Web Real Time Communication access to IMS | 126d? | 2013-06-19 A | 2013-12-11 A | 100% |  | 2013-06-19 | 2013-12-11 | 126d? |  | finish no earlier than 2013-12-11 | S2 | 1008h | 1008h | IMS_WebRTC | PCG-31 | China Mobile | Yu Qing (yuqing@chinamobile.com) | Rel-12 | SP-60 |  |  |  | Maurice |
| 1712 | 455.3 | Stage 2 for Web Real Time Communication access to IMS | 192d? | 2013-06-19 A | 2014-03-07 A | 100% |  | 2013-06-19 | 2014-03-07 | 192d? |  | finish no earlier than 2014-03-07 | S2 | 1528h | 1528h | IMS_WebRTC | PCG-31 | China Mobile | Yu Qing (yuqing@chinamobile.com) | Rel-12 | SP-60 |  |  |  | Maurice |
| 1713 | 455.4 | (IETF) Web Real Time Communication access to IMS (rtcweb-overview) | 391d? | 2013-06-25 A | 2014-12-12 | 50% | 195.5d? | 2013-06-19 | 2014-12-10 | 389d? | 1050d | finish no earlier than 2014-12-12 | C1-IETF | 3128h | 1564h | IMS_WebRTC | PCG-32 | Uwe Rauschenbach | Uwe Rauschenbach | Rel-12 | SP-63 |  |  |  |  |
| 1714 | 455.5 | TR on Security for Web Real Time Communication access to IMS | 202d? | 2013-12-11 A | 2014-09-17 A | 100% |  | 2013-12-11 | 2014-09-17 | 202d? |  | finish no earlier than 2014-09-17 | S3 | 1608h | 1608h | IMS_WebRTC | PCG-32 | Ericsson | oscar.ohlsson@ericsson.com | Rel-12 | SP-62 |  |  |  | Mirko |
| 1715 | 455.6 | Security for Web Real Time Communication access to IMS | 202d? | 2013-09-12 A | 2014-06-18 A | 100% |  | 2013-09-12 | 2014-06-18 | 202d? |  | finish no earlier than 2014-06-18 | S3 | 1609.85h | 1609.85h | IMS_WebRTC | PCG-31 | Ericsson | oscar.ohlsson@ericsson.com | Rel-12 | SP-61 |  |  |  | Mirko |
| 1716 | 455.7 | **CT aspects of Web Real Time Communication (WebRTC) Access to IMS** | 203d? | 2014-03-05 A | 2014-12-09 | 93% | 14.71d? | 2014-03-05 | 2014-12-05 | 198d? | 1053d |  | C1; C4; IETF | 12296h | 10397.2h | IMS_WebRTC-CT | PCG-32 | China Mobile | Jiang Yi (jiangyi@chinamobile.com) | Rel-12 | CP-63 |  |  | IMS_WebRTC-CT | Frederic |
| 1717 | 455.7.1 | CT1 part of CT aspects of Web Real Time Communication (WebRTC) Access to IMS | 200d? | 2014-03-05 A | 2014-12-09 A | 100% |  | 2014-03-05 | 2014-09-12 | 138d? |  | finish no earlier than 2014-12-09 | C1 | 1600h | 1600h | IMS_WebRTC-CT1 | PCG-32 | China Mobile | Jiang Yi (jiangyi@chinamobile.com) | Rel-12 | CP-63 | CP-140621 |  |  | Frederic |
| 1718 | 455.7.2 | (IETF) Web Real Time Communication access to IMS (rtcweb-data-channel) | 200d? | 2014-03-06 A | 2014-12-09 | 90% | 20d? | 2014-03-05 | 2014-12-05 | 198d? | 1053d | finish no earlier than 2014-12-09 | C1-IETF | 1600h | 1440h | IMS_WebRTC-data | PCG-33 | christer.holmberg@ericsson.com | christer.holmberg@ericsson.com | Rel-12 | CP-64 |  |  |  |  |
| 1719 | 455.7.3 | (IETF) Web Real Time Communication access to IMS (rtcweb-stun-consent-freshness) | 200d? | 2014-03-06 A | 2014-12-09 A | 100% |  | 2014-03-05 | 2014-12-05 | 198d? |  | finish no earlier than 2014-12-09 | C1-IETF | 1600h | 1600h | IMS_WebRTC-stun | PCG-33 | christer.holmberg@ericsson.com | christer.holmberg@ericsson.com | Rel-12 | CP-64 |  |  |  |  |
| 1720 | 455.7.4 | (IETF) Web Real Time Communication access to IMS (draft-yusef-sipcore-sip-oauth) | 63d? | 2014-09-12 A | 2014-12-09 | 25% | 47.25d? |  |  |  | 1053d | finish no earlier than 2014-12-09 | C1-IETF | 504h | 126h | IMS_WebRTC-yusef | PCG-33 | christer.holmberg@ericsson.com | christer.holmberg@ericsson.com | Rel-12 | CP-65 |  |  |  |  |
| 1721 | 455.7.5 | Deleted - (IETF) Web Real Time Communication access to IMS (draft-holmberg-sipcore-auth-id) | 65d? | 2014-09-12 A | 2014-12-09 A | 100% |  |  |  |  |  | start no earlier than 2014-09-12 | C1-IETF | 520h | 520h | IMS_WebRTC-holmb | PCG-34 | christer.holmberg@ericsson.com |  | Rel-12 | CP-66 |  |  |  |  |
| 1722 | 455.7.6 | CT4 part of CT aspects of Web Real Time Communication (WebRTC) Access to IMS | 200d? | 2014-03-05 A | 2014-12-09 A | 100% |  | 2014-03-05 | 2014-09-19 | 143d? |  | finish no earlier than 2014-12-09 | C4 | 1600h | 1600h | IMS_WebRTC-CT4 | PCG-32 | China Mobile | Jiang Yi (jiangyi@chinamobile.com) | Rel-12 | CP-63 | CP-140732 |  |  | Kimmo |

Notes:
- 1697: SP#65 exception in SP-140543. Mar15: 85->100% / Impacted TSs and TRs: Stage 2/3
- 1698: SP#65 completion 09/14=>12/14. Exception in SP-140543. TR 32.844v100 for Information. Dec.14: CD: 09/14->12/14, 60->100% / Impacted TSs and TRs: New TR 32.844
- 1699: SP#65 completion 09/14=>12/14. Exception in SP-140543. SP#65 TR 32.277v100 for Information. Dec.14: CD: 09/14->03/15, 40->75%. Mar15: 75->100% / Impacted TSs and TRs: 32.240, 32.297, 32.298, 32.299, New TS 32.277
- 1700: CP#64 updated WID CP-140194=>CP-140290 / Impacted TSs and TRs: Stage 3
- 1701: CP#65 completion 09/14=>12/14. Exception in CP-140615. TS 24.333/4v200 for Approval. Dec.14: 90->100% / Impacted TSs and TRs: 24.301, 23.122, New TSs (24.333, 24.334)
- 1702: CP#65 completion 09/14=>12/14. TS 29.343v100 for 1-step Approval. Exception in CP-140568. Dec.14: 90->100 / Impacted TSs and TRs: New TS 29.343
- 1703: CP#65 completion 09/14=>12/14. TS 29.344/5v100 for 1-step Approval. Exception in CP-140484. Dec.14: 90->100 / Impacted TSs and TRs: 29.272, 23.008, 23.003, New TSs (29.344, 29.345)
- 1704: CP#65 completion 09/14=>12/14. Exception in CP-140695. Dec.14: 60->100% / Impacted TSs and TRs: 31.102
- 1705: follow-up of TR 36.843 FS_LTE_D2D_Prox / Impacted TSs and TRs: LTE
- 1706: ; CD:Sat 15/03/14->Sun 15/03/15Compl:0%->95%; CD:Fri 13/03/15->Sun 15/03/15; Stat Rep: RP-141244->RP-141894 1st Apr 15: Compl:95%->100% 1st Apr 15: Stat Rep: RP-141894->RP-150094 / Impacted TSs and TRs: 36.101, 36.133, 36.211, 36.212, 36.213, 36.214, 36.300, 36.304, 36.306, 36.321, 36.322, 36.323, 36.331, 36.413, 36.423, New TR 36.877
- 1707: ; CD:Sat 15/03/14->Sun 15/03/15; Stat Rep: RP-141244->RP-141894 1st Apr 15: Compl:10%->25% 1st Apr 15: Stat Rep: RP-141894->RP-150094 03/07/15: Compl:25%->70% 03/07/15: Stat Rep: RP-150094->RP-150760 29/09/15: Compl:70%->95% 29/09/15: CD:Tue 15/09/15-> / Impacted TSs and TRs: 36.101, 36.133
- 1708: rapporteur e-mail added 03/07/15: Compl:0%->10% 03/07/15: Stat Rep: ->RP-150765 29/09/15: Compl:10%->30% 29/09/15: CD:Tue 15/12/15->Wed 15/06/16 29/09/15: Stat Rep: RP-150765->RP-151280 1/1/16: Compl:30%->45% 1/1/16: WID: RP-1; ...
- 1709: IETF RTCWEB and W3C WEBRTC groups are specifying a browser-based client to support communication services. Interoperability for WebRTC clients to access 3GPP IMS is needed. / Impacted TSs and TRs: Stage 1/2
- 1710: SP#60 completed / Impacted TSs and TRs: 22.101, 22.228
- 1711: SP#62 completed. TR 23.701v100 for Information & Approval / Impacted TSs and TRs: New TR 23.701
- 1712: SP#63 completed / Impacted TSs and TRs: 23.228
- 1713: In WGLC. Mar15: responsible WG changed from S2-IETF / Impacted TSs and TRs: draft-ietf-rtcweb-overview
- 1714: SP#65 completed. TR 33.871v200 for Approval / Impacted TSs and TRs: New TR 33.871
- 1715: SP#64 completed / Impacted TSs and TRs: 33.203, 33.328
- 1716: - / Impacted TSs and TRs: Stage 3
- 1717: CP#65 TS 24.371v100 for Information. Completion 09/14=>12/14. Exception in CP-140621. Dec.14: 70->90%. 3/3/15: 100% cpltd. / Impacted TSs and TRs: 24.229, New TS 24.371
- 1718: Submitted to IESG for publication. Mar15: In RFC-Editors queue / Impacted TSs and TRs: draft-ietf-rtcweb-data-channel
- 1719: Mar15: Publication requested; 7/3/16: 50%->100 / Impacted TSs and TRs: draft-ietf-rtcweb-stun-consent-freshness
- 1720: work in progress / Impacted TSs and TRs: draft-yusef-sipcore-sip-oaut
- 1721: 7/3/16: 25%->100 since deleted (draft no longer needed). / Impacted TSs and TRs: draft-holmberg-sipcore-auth-id
- 1722: CP#65 completion 09/14=>12/14. Exception in CP-140732. Dec.14: 30->80%. Mar. 15: 100% / Impacted TSs and TRs: 23.334, 29.334

| ID | WBS | Task | Duration | Start | Finish | Complete | Baseline start | Baseline finish | Baseline duration | Constraint | Resources | Work | Actual work | Acronym | PCG approved | WI rapporteur name | WI rapporteur e-mail | Release | TSG approved | MCC resp | Acronym_3GU_Export | Special Focus Doc | Status Report |
| --- | --- | --- | --- | --- | --- | --- | --- | --- | --- | --- | --- | --- | --- | --- | --- | --- | --- | --- | --- | --- | --- | --- | --- |
| 1723 | 456 | **Usage Monitoring Control PCC enhancement** | 196d? | 2012-12-13 A | 2013-09-06 A | 100% | 2012-12-13 | 2013-09-06 | 196d? |  | S2; C3 | 4112h | 4112h | UMONC | PCG-30 | ZTE | bi.yifeng@zte.com.cn | Rel-12 | SP-58 | Maurice | UMONC |  |  |
| 1724 | 456.1 | Stage 2 for Usage Monitoring Control PCC enhancement | 61d? | 2012-12-13 A | 2013-03-06 A | 100% | 2012-12-13 | 2013-03-06 | 61d? | finish no earlier than 2013-03-06 | S2 | 488h | 488h | UMONC | PCG-30 | ZTE | bi.yifeng@zte.com.cn | Rel-12 | SP-58 | Maurice |  |  |  |
| 1725 | 456.2 | CT3 aspects of Usage Monitoring Control PCC enhancement (Stage 3) | 63d? | 2013-06-14 A | 2013-09-06 A | 100% | 2013-06-14 | 2013-09-06 | 63d? | finish no earlier than 2013-09-06 | C3 | 488h | 488h | UMONC-CT3 | PCG-31 | ZTE | zhou.xiaoyun@zte.com.cn | Rel-12 | CP-60 | Adrian | UMONC-CT3 |  |  |
| 1726 | 457 | **Application Based Charging** | 340d? | 2013-03-07 A | 2014-06-18 A | 100% | 2013-03-07 | 2014-06-18 | 340d? |  | S2; S5; C3 | 11612h | 11612h | ABC | PCG-30 | Allot | Alla Goldner (agoldner@allot.com) | Rel-12 | SP-59 | Maurice | ABC |  |  |
| 1727 | 457.1 | Stage 2 for Application Based Charging | 76d? | 2013-03-07 A | 2013-06-19 A | 100% | 2013-03-07 | 2013-06-19 | 76d? | finish no earlier than 2013-12-11 | S2 | 608h | 608h | ABC-SA2 | PCG-30 | Allot | Alla Goldner (agoldner@allot.com) | Rel-12 | SP-59 | Maurice |  |  |  |
| 1728 | 457.2 | Charging for Application Based Charging | 232.5d? | 2013-06-19 A | 2014-06-18 A | 100% | 2013-06-19 | 2014-06-18 | 232.5d? | finish no earlier than 2014-06-18 | S5 | 1836h | 1836h | ABC-CT5 | PCG-31 | Openet Telecom | alan.mcnamee@openet.com | Rel-12 | SP-60 | Mirko |  |  |  |
| 1729 | 457.3 | CT3 aspects of Application Based Charging (Stage 3) | 127d? | 2013-06-14 A | 2013-12-06 A | 100% | 2013-06-14 | 2013-12-06 | 127d? | finish no earlier than 2013-12-06 | C3 | 1008h | 1008h | ABC-CT3 | PCG-31 | Allot | Alla Goldner (agoldner@allot.com) | Rel-12 | CP-60 | Adrian | ABC-CT3 |  |  |
| 1730 | 458 | **Enhanced S2a Mobility Over trusted WLAN access to EPC** | 332d? | 2013-09-09 A | 2014-12-09 A | 100% | 2013-09-09 | 2014-09-12 | 267d? |  | S2; C1; C4 | 19024h | 19024h | eSaMOG | PCG-31 | ZTE | Tricci So (tso@zteusa.com) | Rel-12 | SP-61 | Maurice | eSaMOG | WLAN |  |
| 1731 | 458.1 | Stage 2 for Enhanced S2a Mobility Over trusted WLAN access to EPC | 130d? | 2013-09-11 A | 2014-03-07 A | 100% | 2013-09-11 | 2014-03-07 | 130d? | finish no earlier than 2014-03-07 | S2 | 1032h | 1032h | eSaMOG-SA2 | PCG-31 | ZTE | Tricci So (tso@zteusa.com) | Rel-12 | SP-61 | Maurice |  | WLAN |  |
| 1732 | 458.2 | **Stage 3 for Enhanced S2a Mobility Over trusted WLAN access to EPC** | 332d? | 2013-09-09 A | 2014-12-09 A | 100% | 2013-09-09 | 2014-09-12 | 267d? |  | C1; C4 | 10048h | 10048h | eSaMOG-St3 | PCG-31 | ZTE | Joy Zhou (zhou.xingyue@zte.com.cn) | Rel-12 | CP-61 | Frederic | eSaMOG-St3 | WLAN |  |
| 1733 | 458.2.1 | CT1 part of Stage 3 for Enhanced S2a Mobility Over trusted WLAN access to EPC | 329d? | 2013-09-09 A | 2014-12-09 A | 100% | 2013-09-09 | 2014-09-12 | 267d? | finish no earlier than 2014-12-09 | C1 | 2624h | 2624h | eSaMOG-St3 | PCG-31 | ZTE | Joy Zhou (zhou.xingyue@zte.com.cn) | Rel-12 | CP-61 | Frederic |  | WLAN | CP-140608 |
| 1734 | 458.2.2 | CT4 part of Stage 3 for Enhanced S2a Mobility Over trusted WLAN access to EPC | 266d? | 2013-09-09 A | 2014-09-11 A | 100% | 2013-09-09 | 2014-09-12 | 266d? | finish no earlier than 2014-09-12 | C4 | 2128h | 2128h | eSaMOG-St3 | PCG-31 | ZTE | Joy Zhou (zhou.xingyue@zte.com.cn) | Rel-12 | CP-61 | Kimmo |  | WLAN |  |
| 1735 | 459 | **Optimized Offloading to WLAN in 3GPP-RAT Mobility** | 199d? | 2013-09-12 A | 2014-06-13 A | 100% | 2013-09-12 | 2014-06-13 | 199d? |  | S2; C1 | 4800h | 4800h | WORM | PCG-31 | BlackBerry | Steve Barrett (sbarrett@blackberry.com) | Rel-12 | SP-61 | Maurice | WORM | WLAN |  |
| 1736 | 459.1 | Stage 2 for Optimized Offloading to WLAN in 3GPP-RAT Mobility | 66d? | 2013-09-12 A | 2013-12-11 A | 100% | 2013-09-12 | 2013-12-11 | 66d? | finish no earlier than 2013-12-11 | S2 | 528h | 528h | WORM-SA2 | PCG-31 | BlackBerry | Steve Barrett (sbarrett@blackberry.com) | Rel-12 | SP-61 | Maurice |  | WLAN |  |
| 1737 | 459.2 | CT aspects of Optimized Offloading to WLAN in 3GPP-RAT Mobility (Stage 3) | 136d? | 2013-12-06 A | 2014-06-13 A | 100% | 2013-12-06 | 2014-06-13 | 136d? | finish no earlier than 2014-06-13 | C1 | 1088h | 1088h | WORM-CT | PCG-32 | Intel | Chen-ho Chin (chen-hox.chin@intel.com) | Rel-12 | CP-62 | Frederic | WORM-CT | WLAN |  |
| 1738 | 460 | **Network-provided Location information for IMS Trusted WLAN Access Network (TWAN) case** | 264d? | 2013-09-12 A | 2014-09-11 A | 100% | 2013-09-12 | 2014-09-12 | 264d? |  | S2; C3; C1; C4 | 18624h | 18624h | NETLOC_TWAN | PCG-31 | Alcatel-Lucent | Laurent.thiebaut@alcatel-lucent.com | Rel-12 | SP-61 | Maurice | NETLOC_TWAN | WLAN |  |
| 1739 | 460.1 | Stage 2 for Network-provided Location information for IMS Trusted WLAN Access Network (TWAN) case | 129d? | 2013-09-12 A | 2014-03-07 A | 100% | 2013-09-12 | 2014-03-07 | 129d? | finish no earlier than 2014-03-07 | S2 | 1024h | 1024h | NETLOC_TWAN-SA2 | PCG-31 | Alcatel-Lucent | Laurent.thiebaut@alcatel-lucent.com | Rel-12 | SP-61 | Maurice |  |  |  |
| 1740 | 460.2 | **CT aspects of Network-provided Location information for IMS Trusted WLAN Access Network (TWAN) case (Stage 3)** | 202d? | 2013-12-06 A | 2014-09-11 A | 100% | 2013-12-06 | 2014-09-12 | 202d? |  | C3; C1; C4 | 9152h | 9152h | NETLOC_TWAN-CT | PCG-32 | China Telecom | Xia Xu (xiaxu@ctbri.com.cn) | Rel-12 | CP-62 | Adrian | NETLOC_TWAN-CT |  |  |
| 1741 | 460.2.1 | CT3 part of Network-provided Location information for IMS Trusted WLAN Access Network (TWAN) case | 137d? | 2013-12-06 A | 2014-06-13 A | 100% | 2013-12-06 | 2014-06-13 | 137d? | finish no earlier than 2014-06-13 | C3 | 1088h | 1088h | NETLOC_TWAN-CT | PCG-32 | China Telecom | Xia Xu (xiaxu@ctbri.com.cn) | Rel-12 | CP-62 | Adrian |  |  |  |
| 1742 | 460.2.2 | CT1 part of Network-provided Location information for IMS Trusted WLAN Access Network (TWAN) case | 201d? | 2013-12-09 A | 2014-09-11 A | 100% | 2013-12-09 | 2014-09-12 | 201d? | finish no earlier than 2014-09-12 | C1 | 1608h | 1608h | NETLOC_TWAN-CT | PCG-32 | China Telecom | Xia Xu (xiaxu@ctbri.com.cn) | Rel-12 | CP-62 | Frederic |  |  |  |
| 1743 | 460.2.3 | CT4 part of Network-provided Location information for IMS Trusted WLAN Access Network (TWAN) case | 201d? | 2013-12-06 A | 2014-09-11 A | 100% | 2013-12-06 | 2014-09-12 | 201d? | finish no earlier than 2014-09-12 | C4 | 1608h | 1608h | NETLOC_TWAN-CT | PCG-32 | China Telecom | Xia Xu (xiaxu@ctbri.com.cn) | Rel-12 | CP-62 | Kimmo |  |  |  |
| 1744 | 461 | **Core Network Overload - User Location Information reporting improvement** | 203d? | 2013-12-11 A | 2014-09-17 A | 100% | 2013-12-11 | 2014-09-12 | 199d? |  | S2; C3; C4; S5 | 10920h | 10920h | CNO_ULI | PCG-32 | Alcatel-Lucent | nicolas.drevon@alcatel-lucent.com | Rel-12 | SP-62 | Maurice | CNO_ULI |  |  |
| 1745 | 461.1 | Stage 2 for Core Network Overload - User Location Information reporting improvement | 64d? | 2013-12-11 A | 2014-03-07 A | 100% | 2013-12-11 | 2014-03-07 | 64d? | finish no earlier than 2014-03-07 | S2 | 504h | 504h | CNO_ULI-SA2 | PCG-32 | Alcatel-Lucent | nicolas.drevon@alcatel-lucent.com | Rel-12 | SP-62 | Maurice |  |  |  |
| 1746 | 461.2 | Charging aspects of Core Network Overload – User Location Information reporting improvements | 3d? | 2014-09-15 A | 2014-09-17 A | 100% |  |  |  | finish no earlier than 2014-09-17 | S5 | 24h | 24h | CNO_ULI-CH | PCG-33 | Alcatel-Lucent | maryse.gardella@alcatel-lucent.com | Rel-12 | SP-65 |  | CNO_ULI-CH |  |  |

Notes:
- 1723: SP#59 Stage 2 completed. Triggered by Rel-12 TR 23.858 Study on Usage Monitoring Control enhancement (UID_520035) / Impacted TSs and TRs: Stage 2/3
- 1724: SP#59 completed. 23.203 CR#0782 (Time Based Usage Monitoring), CR#0784 (Usage Monitoring via Online Charging System) / Impacted TSs and TRs: 23.203
- 1725: CP#61 completed. 2/4/15: acronym changed to "UMONC-CT3" / Impacted TSs and TRs: 29.212, 29.214, 29.215
- 1726: Triggered by TR 23.800 Study on Application Based Charging (FS_ABC) UID_560038 / Impacted TSs and TRs: Stage 2/3
- 1727: SP#60 completed / Impacted TSs and TRs: 23.203
- 1728: SP#64 completed / Impacted TSs and TRs: 32.240, 32.251, 32.296, 32.298, 32.299
- 1729: CP#62 completed / Impacted TSs and TRs: 29.212, 29.213, 29.214, 29.215, 29.219
- 1730: - / Impacted TSs and TRs: Stage 2/3
- 1731: SP#63 completed / Impacted TSs and TRs: 23.402
- 1732: CP#62 updated WID CP-130580=>CP-130715 / Impacted TSs and TRs: Stage 3
- 1733: CP#65 completion 09/14=>12/14. Exception in CP-140608. TS 24.244 v200 for Approval. Dec.14: 95->100% / Impacted TSs and TRs: 24.302, New TS 24.244 (WLAN control plane protocol for trusted WLAN access to EPC)
- 1734: CP#65 completed / Impacted TSs and TRs: 29.273, 29.274, 29.275
- 1735: Linked to TR 23.890 Study on Optimized Offloading to WLAN in 3GPP-RAT mobility (FS_WORM), SAE for support for non-3GPP accesses, Multi-Access PDN Connectivity (MAPCON), IP Flow Mobility and Seamless WLAN Offload (IFOM), CS Fallback in EPS (SAES-CSFB) / Impacted TSs and TRs: Stage 2/3
- 1736: SP#62 completed / Impacted TSs and TRs: 23.272, 23.401, 23.402
- 1737: CP#64 completed. Stage 3 enabling differentiation/prioritization of 3GPP RATs relative to WLAN for traffic flow routing based on Inter-System Routing Policies / Impacted TSs and TRs: 24.302, 24.312
- 1738: Rel-11 Network Provided Location Information for IMS (NWK-PL2IMS) covers the case where UE is served by a 3GPP RAN. This WI covers the case where the UE is served by a TWAN / Impacted TSs and TRs: Stage 2/3
- 1739: SP#63 completed / Impacted TSs and TRs: 23.203, 23.228, 23.402
- 1740: - / Impacted TSs and TRs: Stage 3
- 1741: CP#64 completed / Impacted TSs and TRs: 29.212, 29.214
- 1742: CP#65 completed / Impacted TSs and TRs: 24.229
- 1743: CP#65 completed / Impacted TSs and TRs: 29.273, 29.274, 29.275, 29.328, 29.329
- 1744: - / Impacted TSs and TRs: Stage 2/3
- 1745: SP#63 completed / Impacted TSs and TRs: 23.060, 23.203, 23.401
- 1746: SP#65 New WID approved & completed. Introduction of Presence Reporting Areas for Charging / Impacted TSs and TRs: 32.251, 32.298, 32.299

| ID | WBS | Task | Duration | Start | Finish | Complete | Baseline start | Baseline finish | Baseline duration | Constraint | Resources | Work | Actual work | Acronym | PCG approved | Impacted TSs and TRs | WI rapporteur name | Release | TSG approved | MCC resp | Acronym_3GU_Export | Special Focus Doc | PCG stopped | TSG stopped | Status Report |
| --- | --- | --- | --- | --- | --- | --- | --- | --- | --- | --- | --- | --- | --- | --- | --- | --- | --- | --- | --- | --- | --- | --- | --- | --- | --- |
| 1747 | 461.3 | **CT aspects of Core Network Overload – User Location Information reporting improvements** | 138d? | 2014-03-05 A | 2014-09-11 A | 100% | 2014-03-05 | 2014-09-12 | 138d? |  | C3; C4 | 3896h | 3896h | CNO_ULI-CT | PCG-32 | Stage 3 | Alcatel-Lucent | Rel-12 | CP-63 | Adrian | CNO_ULI-CT |  |  |  |  |
| 1748 | 461.3.1 | CT3 part of CT aspects of Core Network Overload – User Location Information reporting improvements | 73d? | 2014-03-05 A | 2014-06-13 A | 100% | 2014-03-05 | 2014-06-13 | 73d? | finish no earlier than 2014-06-13 | C3 | 584h | 584h | CNO_ULI-CT | PCG-32 | 29.212, 29.213 | Alcatel-Lucent | Rel-12 | CP-63 | Adrian |  |  |  |  |  |
| 1749 | 461.3.2 | CT4 part of CT aspects of Core Network Overload – User Location Information reporting improvements | 138d? | 2014-03-05 A | 2014-09-11 A | 100% | 2014-03-05 | 2014-09-12 | 138d? | finish no earlier than 2014-09-12 | C4 | 1104h | 1104h | CNO_ULI-CT | PCG-32 | 23.008, 29.060, 29.274 | Alcatel-Lucent | Rel-12 | CP-63 | Kimmo |  |  |  |  |  |
| 1750 | 462 | Rel-12 Security small Enhancements | 923d? | 2011-03-23 A | 2014-09-17 A | 100% | 2011-03-23 | 2014-06-18 | 859d? | finish no earlier than 2014-09-17 | S3 | 7384h | 7384h | SEC12 | PCG-29 | Stage 2/3 |  | Rel-12 | SP-56 | Mirko | SEC12 |  |  |  |  |
| 1751 | 463 | **Security aspects of Public Warning System** | 925d? | 2011-03-23 A | 2014-09-17 A | 100% | 2011-03-23 | 2014-09-17 | 924d? |  | S3; S1 | 36832h | 36832h | PWS_Sec | PCG-26 |  | ST-Ericsson | Rel-12 | SP-51 | Mirko | PWS_Sec | Public Safety (I-A) |  |  |  |
| 1752 | 463.1 | Stage 1 for Protection against false PWS Warning Notifications | 65d? | 2012-06-15 A | 2012-09-12 A | 100% | 2012-06-15 | 2012-09-12 | 65d? | finish no earlier than 2012-09-12 | S1 | 512h | 512h | PWS_Sec-SA1 | PCG-29 | 22.268 | Vodafone | Rel-12 | SP-56 | Alain |  | Public Safety (I-A) |  |  |  |
| 1753 | 463.2 | TR on SA3 part for Security aspects of Public Warning System | 921d? | 2011-03-23 A | 2014-09-17 A | 100% | 2011-03-23 | 2014-09-17 | 921d? | finish no earlier than 2014-09-17 | S3 | 7360h | 7360h | PWS_Sec-SA3TR | PCG-26 | New TR 33.869 changed to 33.969 | ST-Ericsson | Rel-12 | SP-51 | Mirko |  | Public Safety (I-A) |  |  |  |
| 1754 | 463.3 | Deleted - SA3 part for Security aspects of Public Warning System | 852d? | 2011-03-30 A | 2014-06-18 A | 100% | 2011-03-30 | 2014-06-18 | 852d? | finish no earlier than 2014-06-18 | S3 | 6808h | 6808h | PWS_Sec-del1 | PCG-26 | New TS 33.269 | ST-Ericsson | Rel-12 | SP-51 | Mirko |  | Public Safety (I-A) | PCG-33 | SP-64 |  |
| 1755 | 463.4 | Deleted - Stage 1 for Security aspects of Public Warning System | 330d? | 2011-03-23 A | 2012-06-20 A | 100% | 2011-03-23 | 2012-06-20 | 330d? | start no earlier than 2011-03-23 | S1 | 2640h | 2640h | PWS_Sec-del2 | PCG-26 | 22.268 | ST-Ericsson | Rel-12 | SP-51 | Alain |  | Public Safety (I-A) | PCG-29 | SP-56 |  |
| 1756 | 463.5 | Deleted - Stage 2 for Security aspects of Public Warning System | 133d? | 2011-03-23 A | 2011-09-21 A | 100% | 2011-03-23 | 2011-09-21 | 133d? | start no earlier than 2011-03-23 | S2 | 1064h | 1064h | PWS_Sec-del3 | PCG-26 | 23.401 | ST-Ericsson | Rel-12 | SP-51 | Maurice |  | Public Safety (I-A) | PCG-27 | SP-53 |  |
| 1757 | 463.6 | Deleted - CT1 part for Security aspects of Public Warning System | 328d? | 2011-03-25 A | 2012-06-20 A | 100% | 2011-03-25 | 2012-06-20 | 328d? | finish no earlier than 2012-06-20 | C1 | 2624h | 2624h | PWS_Sec-del4 | PCG-26 | 23.041 | ST-Ericsson | Rel-12 | SP-51 | Frederic |  | Public Safety (I-A) | PCG-29 | SP-56 |  |
| 1758 | 463.7 | Deleted - RAN2 part for Security aspects of Public Warning System | 128d? | 2011-03-25 A | 2011-09-16 A | 100% | 2011-03-25 | 2011-09-16 | 128d? | start no earlier than 2011-03-25 | R2 | 1024h | 1024h | PWS_Sec-del5 | PCG-26 | 36.331 | ST-Ericsson | Rel-12 | SP-51 | Yong-Jun |  | Public Safety (I-A) | PCG-27 | RP-53 |  |
| 1759 | 464 | Security enhancements for usage of Generic Bootstrapping Architecture (GBA) from the browser (Stage 2) | 536d? | 2011-06-08 A | 2013-06-20 A | 100% | 2011-06-08 | 2013-06-19 | 536d? | finish no earlier than 2013-06-19 | S3 | 4256h | 4256h | Web_GBA | PCG-27 | 33.220, 33.222, New TR 33.823 | Nokia | Rel-12 | SP-52 | Mirko | Web_GBA |  |  |  |  |
| 1760 | 465 | **Extended IMS media plane security features** | 657d? | 2012-06-20 A | 2014-12-09 A | 100% | 2012-06-20 | 2014-12-10 | 655d? |  | S3; C4; C1; C3; IETF | 73585.2h | 73585.2h | eMEDIASEC | PCG-29 | Stage 2/3 | Vodafone | Rel-12 | SP-56 | Mirko | eMEDIASEC |  |  |  |  |
| 1761 | 465.1 | SA3 part of Extended IMS media plane security features (Stage 2) | 530d? | 2012-06-20 A | 2014-06-18 A | 100% | 2012-06-20 | 2014-06-18 | 530d? | finish no earlier than 2014-06-18 | S3 | 4185.2h | 4185.2h | eMEDIASEC-SA3 | PCG-29 | 33.328 | Vodafone | Rel-12 | SP-56 | Mirko |  |  |  |  |  |
| 1762 | 465.2 | (IETF) SA3 part of Extended IMS media plane security features (RFC 7345) | 591d? | 2012-06-20 A | 2014-09-12 A | 100% | 2012-06-20 | 2014-12-10 | 654d? | finish no earlier than 2014-09-12 | S3-IETF | 4728h | 4728h | eMEDIASECSA3IETF | PCG-31 | RFC 7345 (was draft-ietf-mmusic-udptl-dtls) | christer.holmberg@ericsson.com | Rel-12 | SP-61 |  |  |  |  |  |  |
| 1763 | 465.3 | **CT aspects of Extended IMS media plane security features (Stage 2/3)** | 528d? | 2012-12-13 A | 2014-12-09 A | 100% | 2012-12-13 | 2014-12-05 | 523d? |  | C4; C1; C3; IETF | 38392h | 38392h | eMEDIASEC-CT | PCG-30 | Stage 2/3 | Alcatel-Lucent | Rel-12 | CP-58 | Kimmo | eMEDIASEC-CT |  |  |  |  |
| 1764 | 465.3.1 | TR on Extended IMS media plane security features and TCP related NAT traversal support; IMS H.248 profiles aspects | 461d? | 2012-12-13 A | 2014-09-11 A | 100% | 2012-12-13 | 2014-09-12 | 461d? | finish no earlier than 2014-09-12 | C4 | 3688h | 3688h | eMEDIASEC-CT | PCG-30 | New TR 29.828 | Alcatel-Lucent | Rel-12 | CP-58 | Kimmo |  |  |  |  |  |
| 1765 | 465.3.2 | CT4 part of CT aspects of Extended IMS media plane security features | 520d? | 2012-12-19 A | 2014-12-09 A | 100% | 2012-12-19 | 2014-09-12 | 458d? | finish no earlier than 2014-12-09 | C4 | 4160h | 4160h | eMEDIASEC-CT | PCG-30 | 23.334, 29.334, 29.238, 23.333, 29.333 | Alcatel-Lucent | Rel-12 | CP-58 | Kimmo |  |  |  |  | CP-140479 |
| 1766 | 465.3.3 | (IETF) CT4 part of Extended IMS media plane security features (RFC 7345) | 457d? | 2012-12-18 A | 2014-09-11 A | 100% | 2012-12-18 | 2014-12-05 | 519d? | finish no earlier than 2014-09-11 | C4-IETF | 3656h | 3656h | eMEDIASEC-CT | PCG-32 | RFC 7345 (was draft-ietf-mmusic-udptl-dtls) | christer.holmberg@ericsson.com | Rel-12 | CP-62 |  |  |  |  |  |  |
| 1767 | 465.3.4 | (IETF) CT4 part of Extended IMS media plane security features (draft-schwarz-mmusic-sdp-for-gw) | 129d? | 2014-06-12 A | 2014-12-09 A | 100% | 2014-06-12 | 2014-12-05 | 127d? | finish no earlier than 2014-12-09 | C4-IETF | 1032h | 1032h | eMEDIASEC-CT | PCG-33 | draft-schwarz-mmusic-sdp-for-gw | christer.holmberg@ericsson.com | Rel-12 | CP-64 |  |  |  |  |  |  |
| 1768 | 465.3.5 | CT1 part of CT aspects of Extended IMS media plane security features | 463d? | 2012-12-13 A | 2014-09-11 A | 100% | 2012-12-13 | 2014-09-12 | 463d? | finish no earlier than 2014-09-12 | C1 | 3696h | 3696h | eMEDIASEC-CT | PCG-30 | 23.218, 24.147, 24.229, 24.247 | Alcatel-Lucent | Rel-12 | CP-58 | Frederic |  |  |  |  |  |
| 1769 | 465.3.6 | (IETF) CT1 part of Extended IMS media plane security features (RFC 7345) | 137d? | 2014-03-06 A | 2014-09-11 A | 100% | 2014-03-06 | 2014-12-05 | 197d? | finish no earlier than 2014-09-11 | C1-IETF | 1096h | 1096h | eMEDIASEC-CT | PCG-32 | RFC 7345 (was draft-ietf-mmusic-udptl-dtls) | christer.holmberg@ericsson.com | Rel-12 | CP-62 |  |  |  |  |  |  |
| 1770 | 465.3.7 | CT3 part of CT aspects of Extended IMS media plane security features | 521d? | 2012-12-19 A | 2014-12-09 A | 100% | 2012-12-19 | 2014-06-13 | 394d? | finish no earlier than 2014-12-09 | C3 | 4168h | 4168h | eMEDIASEC-CT | PCG-30 | 29.162 | Alcatel-Lucent | Rel-12 | CP-58 | Adrian |  |  |  |  | CP-140569 |
| 1771 | 466 | Lawful Interception in the 3GPP Rel-12 | 592d? | 2012-09-17 A | 2014-12-12 A | 100% | 2012-09-17 | 2014-09-12 | 526d? | finish no earlier than 2014-12-12 | S3 | 4736h | 4736h | LI12 | PCG-29 | 33.106, 33.107, 33.108 | PIDS, Alcatel-Lucent | Rel-12 | SP-57 | Mirko | LI12 |  |  |  |  |

Notes:
- 1747: Specify Stage 3 procedures to support the ULI signalling optimizations / WI rapporteur e-mail: horst.brinkmann@alcatel-lucent.com
- 1748: CP#64 completed / WI rapporteur e-mail: horst.brinkmann@alcatel-lucent.com
- 1749: CP#65 completed / WI rapporteur e-mail: horst.brinkmann@alcatel-lucent.com
- 1750: SEC12 is an umbrella Feature for Security related TEI12 type of changes that are not part of any other dedicated feature
- 1751: - / WI rapporteur e-mail: john.mattsson@ericsson.com
- 1752: SP#57 completed. Specify reqs to protect against false PWS Warning Notifications (Optional as not all regions/countries require this functionality). WID covers all objectivES in CP-150SA3 PWS_Sec Feature-level WID replacing the original Stage 1 UID_510154 / WI rapporteur e-mail: adrian.neal@vodafone.com
- 1753: SP#65 completed. TR 33.969v100 for 1-step Approval. Former TR 33.869 changed to 33.969. / WI rapporteur e-mail: john.mattsson@ericsson.com
- 1754: SP#64 stopped / WI rapporteur e-mail: john.mattsson@ericsson.com
- 1755: Completed in Rel-9 under PWS. SP#55 stopped, Stage 1 requirements removed from Rel-9 onwards (SP-120172). AP 55/1: SA1 to align Stage 1 PWS security for Rel-12. SA1 new WID PWS Security UID_560029. / WI rapporteur e-mail: john.mattsson@ericsson.com
- 1756: SP#53 work stopped as already done in previous releases / WI rapporteur e-mail: john.mattsson@ericsson.com
- 1757: TSG#56 work stopped. SP#56 updated WID SP-110223=>SP-120334 (removed all but SA3 impacted specs) / WI rapporteur e-mail: mikael.wass@ericsson.com
- 1758: RP#53 work stopped as no WI in RAN / WI rapporteur e-mail: john.mattsson@ericsson.com
- 1759: SP#60 completed / WI rapporteur e-mail: Silke.Holtmanns@nokia.com
- 1760: Triggered by Rel-11 TR 33.829 Study on Extended IMS media plane security features (FS_eMEDIASEC) / WI rapporteur e-mail: Aguibou.Barry@vodafone.com
- 1761: SP#64 completed / WI rapporteur e-mail: Aguibou.Barry@vodafone.com
- 1762: SP#65 completed / WI rapporteur e-mail: christer.holmberg@ericsson.com
- 1763: - / WI rapporteur e-mail: bruno.landais@alcatel-lucent.com
- 1764: CP#65 completed. TR 29.828v200 for Approval. 2/4/15: acronym changed to eMEDIASEC-CT / WI rapporteur e-mail: bruno.landais@alcatel-lucent.com
- 1765: CP#65 completion 09/14=>12/14. Exception in CP-140479. Dec.14: 90->100. 2/4/15: acronym changed to eMEDIASEC-CT / WI rapporteur e-mail: bruno.landais@alcatel-lucent.com
- 1766: CP#65 completed. 2/4/15: acronym changed to eMEDIASEC-CT / WI rapporteur e-mail: christer.holmberg@ericsson.com
- 1767: Work in progress. 2/4/15: acronym changed to eMEDIASEC-CT / WI rapporteur e-mail: christer.holmberg@ericsson.com
- 1768: CP#65 completed. 2/4/15: acronym changed to eMEDIASEC-CT / WI rapporteur e-mail: bruno.landais@alcatel-lucent.com
- 1769: CP#65 completed. 2/4/15: acronym changed to eMEDIASEC-CT / WI rapporteur e-mail: christer.holmberg@ericsson.com
- 1770: CP#65 completion 06/14=>12/14. Level 100%=>80%. Exception in CP-140569. CP#64 completed. Dec.14: 80->100. 2/4/15: acronym changed to eMEDIASEC-CT / WI rapporteur e-mail: bruno.landais@alcatel-lucent.com
- 1771: 3/3/15: 75->100% / WI rapporteur e-mail: Koen Jaspers (k.b.jaspers@minjus.nl), terry.jacobson@alcatel-lucent.com

| ID | WBS | Task | Duration | Start | Finish | Complete | Baseline start | Baseline finish | Baseline duration | Constraint | Resources | Work | Actual work | Acronym | PCG approved | WI rapporteur name | WI rapporteur e-mail | Release | TSG approved | MCC resp | Acronym_3GU_Export | Status Report |
| --- | --- | --- | --- | --- | --- | --- | --- | --- | --- | --- | --- | --- | --- | --- | --- | --- | --- | --- | --- | --- | --- | --- |
| 1772 | 467 | **Tunneling of UE Services over Restrictive Access Networks (Stage 2/3)** | 401d? | 2012-12-13 A | 2014-06-18 A | 100% | 2012-12-13 | 2014-06-18 | 401d? |  | S3; C1 | 11662.5h | 11662.5h | TURAN | PCG-30 | Acme Packet | Prashant Kumar (PKumar@acmepacket.com) | Rel-12 | SP-58 | Mirko | TURAN |  |
| 1773 | 467.1 | SA3 part of Tunneling of UE Services over Restrictive Access Networks (Stage 2/3) | 400d? | 2012-12-13 A | 2014-06-18 A | 100% | 2012-12-13 | 2014-06-18 | 400d? | finish no earlier than 2014-06-18 | S3 | 3168h | 3168h | TURAN-SA3 | PCG-30 | Acme Packet | Prashant Kumar (PKumar@acmepacket.com) | Rel-12 | SP-58 | Mirko |  |  |
| 1774 | 467.2 | CT aspects of Tunneling of UE Services over Restrictive Access Networks (Stage 3) | 264d? | 2013-06-14 A | 2014-06-13 A | 100% | 2013-06-14 | 2014-06-13 | 264d? | finish no earlier than 2014-06-13 | C1 | 2094.45h | 2094.45h | TURAN-CT | PCG-31 | Huawei | Haitao Wei (weihaitao@huawei.com) | Rel-12 | CP-60 | Frederic | TURAN-CT |  |
| 1775 | 468 | Specification of the TUAK Algorithm Set | 139d? | 2013-12-09 A | 2014-06-18 A | 100% | 2013-12-09 | 2014-06-18 | 139d? | finish no earlier than 2014-06-18 | S3 | 1112h | 1112h | STAS | PCG-32 | Vodafone | aguibou.barry@vodafone.com | Rel-12 | SP-62 | Mirko | STAS |  |
| 1776 | 469 | **Codec for Enhanced Voice Services** | 1575d? | 2010-03-25 A | 2016-03-15 A | 100% | 2010-03-25 | 2014-12-12 | 1245d? |  | S4; S1; C4; C1; C3 | 87912h | 87912h | EVS_codec | PCG-24 | Huawei | lei.miao@huawei.com | Rel-12 | SP-47 | Paolo | EVS_codec |  |
| 1777 | 469.1 | Stage 1 for Codec for Enhanced Voice Services | 1d? | 2010-03-25 A | 2010-03-25 A | 100% | 2010-03-25 | 2010-03-25 | 1d? | start no earlier than 2010-03-25 | S1 | 8h | 8h | EVS_codec-SA1 | PCG-24 | Huawei | lei.miao@huawei.com | Rel-12 | SP-47 | Paolo |  |  |
| 1778 | 469.2 | Stage 2/3 for Codec for Enhanced Voice Services | 1240d? | 2010-03-25 A | 2014-12-12 A | 100% | 2010-03-25 | 2014-09-17 | 1178d? | finish no earlier than 2014-12-12 | S4 | 9896h | 9896h | EVS_codec-SA4 | PCG-24 | Huawei | lei.miao@huawei.com | Rel-12 | SP-47 | Paolo |  | SP-140467 |
| 1779 | 469.3 | TR on Performance characterization of Codec for Enhanced Voice Services | 1239d? | 2010-03-25 A | 2014-12-12 A | 100% | 2010-03-25 | 2014-12-12 | 1239d? | finish no earlier than 2014-12-12 | S4 | 9888h | 9888h | EVS_codec-SA4TR | PCG-24 | Huawei | lei.miao@huawei.com | Rel-12 | SP-47 | Paolo |  | SP-140467 |
| 1780 | 469.4 | **CT impacts of codec for Enhanced Voice Services** | 63d? | 2014-09-16 A | 2014-12-09 A | 100% |  |  |  |  | C4; C1; C3 | 3024h | 3024h | EVS_codec-CT | PCG-33 | Nokia Networks | Jan.Kall@nsn.com | Rel-12 | CP-65 |  | EVS_codec-CT |  |
| 1781 | 469.4.1 | CT4 part of CT impacts of codec for Enhanced Voice Services | 63d? | 2014-09-16 A | 2014-12-09 A | 100% |  |  |  | finish no earlier than 2014-12-09 | C4 | 504h | 504h | EVS_codec-CT | PCG-33 | Nokia Networks | Jan.Kall@nsn.com | Rel-12 | CP-65 |  |  | CP-140478 |
| 1782 | 469.4.2 | CT1 part of CT impacts of codec for Enhanced Voice Services | 63d? | 2014-09-16 A | 2014-12-09 A | 100% |  |  |  | finish no earlier than 2014-12-09 | C1 | 504h | 504h | EVS_codec-CT | PCG-33 | Nokia Networks | Jan.Kall@nsn.com | Rel-12 | CP-65 |  |  | CP-140618 |
| 1783 | 469.4.3 | CT3 part of CT impacts of codec for Enhanced Voice Services | 63d? | 2014-09-16 A | 2014-12-09 A | 100% |  |  |  | finish no earlier than 2014-12-09 | C3 | 504h | 504h | EVS_codec-CT | PCG-33 | Nokia Networks | Jan.Kall@nsn.com | Rel-12 | CP-65 |  |  | CP-140560 |
| 1784 | 469.5 | UE Conformance Test Aspects - Codec for Enhanced Voice Services (EVS) | 262d? | 2015-03-16 A | 2016-03-15 A | 100% |  |  |  | finish no earlier than 2016-03-15 | R5 | 2096h | 2096h | EVS_codec-UEConTest | PCG-34 | Ericsson |  | Rel-12 | RP-67 |  |  | RP-151164 |
| 1785 | 470 | **Coordination of Video Orientation** | 400d? | 2012-06-07 A | 2013-12-06 A | 100% | 2012-06-07 | 2013-12-06 | 400d? |  | S4; C4; C1; C3 | 20496.8h | 20496.8h | CVO | PCG-29 | Ericsson | frederic.gabin@ericsson.com | Rel-12 | SP-56 | Paolo | CVO |  |
| 1786 | 470.1 | SA4 part of Coordination of Video Orientation | 196d? | 2012-06-07 A | 2013-03-06 A | 100% | 2012-06-07 | 2013-03-06 | 196d? | finish no earlier than 2013-03-06 | S4 | 1560h | 1560h | CVO-SA4 | PCG-29 | Ericsson | frederic.gabin@ericsson.com | Rel-12 | SP-56 | Paolo |  |  |
| 1787 | 470.2 | **CT aspects of Coordination of Video Orientation** | 129d? | 2013-06-14 A | 2013-12-06 A | 100% | 2013-06-14 | 2013-12-06 | 129d? |  | C4; C1; C3 | 6136.8h | 6136.8h | CVO-CT | PCG-31 | Ericsson | nevenka.biondic@ericsson.com | Rel-12 | CP-60 | Kimmo | CVO-CT |  |
| 1788 | 470.2.1 | CT4 part of CT aspects of Coordination of Video Orientation | 128.05d? | 2013-06-14 A | 2013-12-06 A | 100% | 2013-06-14 | 2013-12-06 | 128.05d? | finish no earlier than 2013-12-06 | C4 | 1008.4h | 1008.4h | CVO-CT | PCG-31 | Ericsson | nevenka.biondic@ericsson.com | Rel-12 | CP-60 | Kimmo |  |  |
| 1789 | 470.2.2 | CT1 part of CT aspects of Coordination of Video Orientation | 129d? | 2013-06-14 A | 2013-12-06 A | 100% | 2013-06-14 | 2013-12-06 | 129d? | finish no earlier than 2013-12-06 | C1 | 1016h | 1016h | CVO-CT | PCG-31 | Ericsson | nevenka.biondic@ericsson.com | Rel-12 | CP-60 | Frederic |  |  |
| 1790 | 470.2.3 | CT3 part of CT aspects of Coordination of Video Orientation | 127.05d? | 2013-06-14 A | 2013-12-06 A | 100% | 2013-06-14 | 2013-12-06 | 127.05d? | finish no earlier than 2013-12-06 | C3 | 1016.4h | 1016.4h | CVO-CT | PCG-31 | Ericsson | nevenka.biondic@ericsson.com | Rel-12 | CP-60 | Adrian |  |  |
| 1791 | 471 | **High Efficiency Video Coding** | 594d? | 2012-09-12 A | 2014-12-05 A | 100% | 2012-09-12 | 2014-12-05 | 591d? |  | S4; IETF | 21576h | 21576h | HEVC | PCG-29 | Qualcomm | Ye-Kui Wang (yekuiw@qti.qualcomm.com) | Rel-12 | SP-57 | Paolo | HEVC |  |
| 1792 | 471.1 | TR on Evaluation of High Efficiency Video Coding for 3GPP Services | 464d? | 2012-09-12 A | 2014-06-19 A | 100% | 2012-09-12 | 2014-06-19 | 464d? | finish no earlier than 2014-06-18 | S4 | 3704h | 3704h | HEVC-SA4TR | PCG-29 | Qualcomm | Ye-Kui Wang (yekuiw@qti.qualcomm.com) | Rel-12 | SP-57 | Paolo |  |  |
| 1793 | 471.2 | High Efficiency Video Coding in 3GPP services PSS, MBMS, DASH, MMS, MTSI, IMS Messaging and Presence | 462d? | 2012-09-17 A | 2014-06-18 A | 100% | 2012-09-17 | 2014-06-18 | 462d? | finish no earlier than 2014-06-18 | S4 | 3688h | 3688h | HEVC-SA4 | PCG-29 | Qualcomm | Ye-Kui Wang (yekuiw@qti.qualcomm.com) | Rel-12 | SP-57 | Paolo |  |  |
| 1794 | 471.3 | (IETF) High Efficiency Video Coding | 587d? | 2012-09-17 A | 2014-12-05 A | 100% | 2012-09-17 | 2014-12-05 | 587d? | finish no earlier than 2014-12-05 | S4-IETF | 4696h | 4696h | HEVC-SA4IETF | PCG-32 | Thomas Stockhammer, Qualcomm Incorporated | tsto@qti.qualcomm.com | Rel-12 | CP-63 |  |  |  |
| 1795 | 472 | Mobile stereoscopic 3D services extensions | 200d? | 2012-12-12 A | 2013-09-11 A | 100% | 2012-12-12 | 2013-09-11 | 200d? | finish no earlier than 2013-09-11 | S4 | 1568h | 1568h | M3DV_Ext | PCG-30 | Huawei | lukasz.kondrad@huawei.com | Rel-12 | SP-58 | Paolo | M3DV_Ext |  |

Notes:
- 1772: Linked to Rel-12 SMURFs. Related to TS 22.278 (EPS) cl.7.1.8 Service Reachability (Firewall traversal for IP based services for non-3GPP access), TS 22.228 (IMS) cl.5 (support Firewall traversal), TR 33.830 (Study on Firewall traversal) / Impacted TSs and TRs: Stage 2/3
- 1773: SP#64 completed / Impacted TSs and TRs: 33.203, 33.402
- 1774: CP#64 completed. Stage 3 for 2 new SA3 solutions for firewall traversal: 1) UE access to PLMN IP-based services via restrictive non-3GPP Ans, 2) UE access to IMS services via restrictive ANs / Impacted TSs and TRs: 24.229, 24.302, New TS 24.322
- 1775: SP#64 completed. Triggered by SP-130602 LS from ETSI SAGE (TUAK as alternative to Milenage). 12/14: new TS added / Impacted TSs and TRs: New TSs: 35.231, 35.232, 35.233, TR 35.9nn, TR 35.9nn, TR 35.9nn
- 1776: Triggered by UID_370045 Study on enhanced voice service requirements for EPS (TR 22.813)
- 1777: SP#47 completed / Impacted TSs and TRs: 22.173
- 1778: SP#65 completion 09/14=>12/14. Exception in SP-140467. TS 26.441v200 for Approval. TSs 26.442/44/45/46/47/48/49/50/51v100 for 1-step Approval. Ongoing TS 26.443 EVS Codec ANSI C code (floating point). Dec.14: 90->95 / Impacted TSs and TRs: 26.114, New TS (26.441, 26.442, 26.443, 26.444, 26.445, 26.446, 26.447, 26.448, 26.449, 26.450, 26.451)
- 1779: SP#65 completion 09/14=>12/14. Ongoing TR 26.952 EVS Codec Performance Characterization. Exception in SP-140467 / Impacted TSs and TRs: New TR 26.952
- 1780: Stage 3; WID: CP-140492-> CP-140800
- 1781: CP#65 exception in CP-140478. Dec.14: 0->100; WID: CP-140492-> CP-140800 / Impacted TSs and TRs: 23.334, 29.232, 29.238, 29.332, 29.333, 29.334
- 1782: CP#65 exception in CP-140618. Dec.14: 0->100%; WID: CP-140492-> CP-140800 / Impacted TSs and TRs: 24.229
- 1783: CP#65 exception in CP-140560. Dec.14: 20->100; WID: CP-140492-> CP-140800 / Impacted TSs and TRs: 29.163, 29.292
- 1784: 03/07/15: Compl:0%->25% 03/07/15: WID: RP-150137->RP-150836 03/07/15: Stat Rep: ->RP-150831 29/09/15: Compl:25%->75% 29/09/15: Stat Rep: RP-150831->RP-1511641/1/16: Compl:75%->95%1/1/16: CD:Tue 15/12/15->Tue 15/03/16;
- 1785: CP#62 completed. Resolve backward compatible video orientation mis-alignment in MTSI real-time video communication via interaction between MTSI video clients at call setup & during mid-call of the video orientation for correct local rendering
- 1786: SP#59 completed. Resolve backward compatible video orientation mis-alignment in MTSI real-time video communication via interaction between MTSI video clients at call setup & during mid-call of the video orientation for correct local rendering / Impacted TSs and TRs: 26.114, 26.141, 26.234, 26.346
- 1787: Complete CVO support (both, basic 2 bit orientation and additional option for extra 6 bit granularity) within CN protocols/procedures for IMS nodes, e.g. IMS ALG/AGW,IBCF/TrGW,MRFC/MRFP & add support of CVO-related SDP attributes to be negotiated by UE / Impacted TSs and TRs: Stage 2/3
- 1788: CP#62 completed / Impacted TSs and TRs: 23.333, 23.334, 29.238, 29.332, 29.333, 29.334
- 1789: CP#62 completed / Impacted TSs and TRs: 24.229
- 1790: CP#62 completed / Impacted TSs and TRs: 29.162, 29.163
- 1791: Specify the support of HEVC in 3GPP services (PSS, DASH, MTSI, MMS, MBMS, IMS Messaging and Presence)
- 1792: SP#64 completed. TR 26.906v200 for Approval / Impacted TSs and TRs: New TR 26.906
- 1793: SP#64 completed / Impacted TSs and TRs: 26.114, 26.140, 26.141, 26.234, 26.244, 26.247, 26.346
- 1794: Submitted to IESG for publication. 7/10/15: Rapporteur added; 7/3/16: 50%->95; 13/6/16: 95%->100 / Impacted TSs and TRs: draft-ietf-payload-rtp-h265
- 1795: SP#61 completed. Related to Rel-11 Study On Mobile 3D Video Coding (FS_M3DVC) TR 26.905 and Rel-11 Mobile 3D Video Coding (M3DVC) / Impacted TSs and TRs: 26.114, 26.245, 26.247, 26.430

| ID | WBS | Task | Duration | Start | Finish | Complete | Baseline start | Baseline finish | Baseline duration | Constraint | Resources | Work | Actual work | Acronym | PCG approved | WI rapporteur name | WI rapporteur e-mail | Release | TSG approved | MCC resp | Acronym_3GU_Export | Impacted TSs and TRs | Status Report | Special Focus Doc |
| --- | --- | --- | --- | --- | --- | --- | --- | --- | --- | --- | --- | --- | --- | --- | --- | --- | --- | --- | --- | --- | --- | --- | --- | --- |
| 1796 | 473 | **IMS-based Streaming and Download Delivery Enhancements** | 329d? | 2012-12-12 A | 2014-03-07 A | 100% | 2012-12-12 | 2014-03-07 | 329d? |  | S4 | 7800h | 7800h | IMS_SDE | PCG-30 | Intel | ozgur.oyman@intel.com | Rel-12 | SP-58 | Paolo | IMS_SDE |  |  |  |
| 1797 | 473.1 | TR on IMS-based Streaming and Download Delivery Enhancements | 326d? | 2012-12-12 A | 2014-03-07 A | 100% | 2012-12-12 | 2014-03-07 | 326d? | finish no earlier than 2014-03-07 | S4 | 2584h | 2584h | IMS_SDE-SA4TR | PCG-30 | Intel | ozgur.oyman@intel.com | Rel-12 | SP-58 | Paolo |  | new TR 26.827 |  |  |
| 1798 | 473.2 | Specification on IMS-based Streaming and Download Delivery Enhancements | 327d? | 2012-12-13 A | 2014-03-07 A | 100% | 2012-12-13 | 2014-03-07 | 327d? | finish no earlier than 2014-03-07 | S4 | 2584h | 2584h | IMS_SDE-SA4 | PCG-30 | Intel | ozgur.oyman@intel.com | Rel-12 | SP-58 | Paolo |  | 26.237 |  |  |
| 1799 | 474 | **Acoustic Requirements and Test methods for IMS-based conversational speech services over LTE** | 532d? | 2012-12-12 A | 2014-12-12 A | 100% | 2012-12-12 | 2014-09-17 | 467d? |  | S4 | 14224h | 14224h | ART_LTE | PCG-30 | Qualcomm | Andre Schevciw (aschevci@qualcomm.com) | Rel-12 | SP-58 | Paolo | ART_LTE | Stage 3 |  |  |
| 1800 | 474.1 | Acoustic Requirements and Test methods for IMS-based conversational speech services over LTE - NarrowBand and WideBand aspects | 265d? | 2012-12-12 A | 2013-12-11 A | 100% | 2012-12-12 | 2013-12-11 | 265d? | finish no earlier than 2013-12-11 | S4 | 2088h | 2088h | ART_LTE-NBWB | PCG-30 | Sony Mobile Communications | peter.isberg@sonymobile.com | Rel-12 | SP-58 | Paolo | ART_LTE-NBWB | 26.131, 26.132 |  |  |
| 1801 | 474.2 | Acoustic Requirements and Test methods for IMS-based conversational speech services over LTE - UE Delay aspects | 462d? | 2012-12-12 A | 2014-09-17 A | 100% | 2012-12-12 | 2014-09-17 | 461d? | finish no earlier than 2014-09-17 | S4 | 3696h | 3696h | ART_LTE-UED | PCG-30 | AT&T, Orange | luisa.marchetto@att.com, stephane.ragot@orange.com | Rel-12 | SP-58 | Paolo | ART_LTE-UED | 26.131, 26.132 |  |  |
| 1802 | 474.3 | Acoustic Requirements and Test methods for IMS-based conversational speech services over LTE - Super wideband and fullband aspects | 523d? | 2012-12-12 A | 2014-12-12 A | 100% | 2012-12-12 | 2014-09-17 | 461d? | finish no earlier than 2014-12-12 | S4 | 4184h | 4184h | ART_LTE-SUPER | PCG-30 | Sony Mobile Communications | peter.isberg@sonymobile.com | Rel-12 | SP-58 | Paolo | ART_LTE-SUPER | 26.131, 26.132 | SP-140470 |  |
| 1803 | 475 | **MBMS Improvements** | 471d? | 2013-03-06 A | 2014-12-12 A | 100% | 2013-03-06 | 2014-09-17 | 406d? |  | S4 | 18584h | 18584h | MI | PCG-30 | Ericsson | eric.turcotte@ericsson.com | Rel-12 | SP-59 | Paolo | MI |  | SP-140471 |  |
| 1804 | 475.1 | TR on Enhanced MBMS Operation | 463d? | 2013-03-06 A | 2014-12-12 A | 100% | 2013-03-06 | 2014-09-17 | 401d? | finish no earlier than 2014-12-12 | S4 | 3704h | 3704h | MI-EMOTR | PCG-30 | Huawei | Zhiming Li (lizhiming@huawei.com) | Rel-12 | SP-59 | Paolo |  | New TR 26.848 | SP-140471 |  |
| 1805 | 475.2 | Enhanced MBMS Operation | 463d? | 2013-03-06 A | 2014-12-12 A | 100% | 2013-03-06 | 2014-09-17 | 401d? | finish no earlier than 2014-12-12 | S4 | 3704h | 3704h | MI-EMO | PCG-30 | Huawei | Zhiming Li (lizhiming@huawei.com) | Rel-12 | SP-59 | Paolo | MI-EMO | 26.247, 26.346 | SP-140471 |  |
| 1806 | 475.3 | TR on MBMS operation on Demand | 463d? | 2013-03-06 A | 2014-12-12 A | 100% | 2013-03-06 | 2014-09-17 | 401d? | finish no earlier than 2014-12-12 | S4 | 3704h | 3704h | MI-MooDTR | PCG-30 | Qualcomm | Charles Lo (clo@qti.qualcomm.com) | Rel-12 | SP-59 | Paolo |  | New TR 26.849 | SP-140471 |  |
| 1807 | 475.4 | MBMS operation on Demand | 463d? | 2013-03-06 A | 2014-12-12 A | 100% | 2013-03-06 | 2014-09-17 | 401d? | finish no earlier than 2014-12-12 | S4 | 3704h | 3704h | MI-MooD | PCG-30 | Qualcomm | Charles Lo (clo@qti.qualcomm.com) | Rel-12 | SP-59 | Paolo | MI-MooD | 26.346 | SP-140471 |  |
| 1808 | 476 | **End-to-End Multimedia Telephony Service for IMS (MTSI) extensions** | 667d? | 2013-03-06 A | 2015-09-14 A | 100% | 2013-03-06 | 2015-03-13 | 533d? |  | S4 | 32648h | 32648h | E2EMTSI | PCG-30 | Ericsson | tomas.frankkila@ericsson.com | Rel-12 | SP-59 | Paolo | E2EMTSI | 26.114 |  |  |
| 1809 | 476.1 | S4 aspects of End-to-End Multimedia Telephony Service for IMS (MTSI) extensions | 406d? | 2013-03-06 A | 2014-09-16 A | 100% | 2013-03-06 | 2015-03-13 | 533d? | finish no earlier than 2014-09-17 | S4 | 3248h | 3248h | E2EMTSI | PCG-30 | Ericsson | tomas.frankkila@ericsson.com | Rel-12 | SP-59 | Paolo | E2EMTSI | 26.114 |  |  |
| 1810 | 476.2 | **CT aspects of End-to-End Multimedia Telephony Service for IMS (MTSI) extensions** | 589d? | 2013-06-21 A | 2015-09-14 A | 100% | 2013-06-20 | 2014-09-12 | 326d? |  | C3; C1; C4 | 24064h | 24064h | E2EMTSI-CT | PCG-31 | Ericsson | susana.fernandez@ericsson.com | Rel-12 | CP-60 | Adrian |  | Stage 2/3 |  |  |
| 1811 | 476.2.1 | CT3 part of CT aspects of End-to-End Multimedia Telephony Service for IMS (MTSI) extensions | 589d? | 2013-06-21 A | 2015-09-14 A | 100% | 2013-06-20 | 2014-09-12 | 326d? | finish no earlier than 2015-09-14 | C3 | 4712h | 4712h | E2EMTSI-CT | PCG-31 | Ericsson | susana.fernandez@ericsson.com | Rel-12 | CP-60 | Adrian |  | 29.162, 29.163, 29.213, 29.214 |  |  |
| 1812 | 476.2.2 | CT1 part of CT aspects of End-to-End Multimedia Telephony Service for IMS (MTSI) extensions | 326d? | 2013-06-21 A | 2014-09-12 A | 100% | 2013-06-20 | 2014-09-12 | 326d? | finish no earlier than 2014-09-12 | C1 | 2608h | 2608h | E2EMTSI-CT | PCG-31 | Ericsson | susana.fernandez@ericsson.com | Rel-12 | CP-60 | Frederic |  | 24.229 |  |  |
| 1813 | 476.2.3 | CT4 part of CT aspects of End-to-End Multimedia Telephony Service for IMS (MTSI) extensions | 326d? | 2013-06-21 A | 2014-09-12 A | 100% | 2013-06-20 | 2014-09-12 | 326d? | finish no earlier than 2014-09-12 | C4 | 2608h | 2608h | E2EMTSI-CT | PCG-31 | Ericsson | susana.fernandez@ericsson.com | Rel-12 | CP-60 | Kimmo |  | 23.333, 23.334, 29.238, 29.332, 29.333, 29.334 |  |  |
| 1814 | 477 | Video Coding Enhancements in IMS Messaging and Presence | 64d? | 2013-12-11 A | 2014-03-07 A | 100% | 2013-12-11 | 2014-03-07 | 64d? | finish no earlier than 2014-03-07 | S4 | 504h | 504h | VCEIMP | PCG-32 | Ericsson | frederic.gabin@ericsson.com | Rel-12 | SP-62 | Paolo | VCEIMP | 26.141 |  |  |
| 1815 | 478 | Video Telephony Robustness Improvements | 66d? | 2014-06-18 A | 2014-09-16 A | 100% | 2014-06-18 | 2014-09-17 | 66d? | finish no earlier than 2014-09-17 | S4 | 528h | 528h | VTRI | PCG-33 | Qualcomm | Muhammed Coban (mcoban@qti.qualcomm.com) | Rel-12 | SP-64 |  | VTRI | 26.114 |  |  |
| 1816 | 479 | **Rel-12 Operations, Administration, Maintenance and Provisioning (OAM&P)** | 857d? | 2011-09-21 A | 2014-12-12 A | 100% | 2011-09-21 | 2014-09-17 | 792d? |  | S5 | 58352.5h | 58352.5h | OAM12 | PCG-29 |  |  | Rel-12 | SP-56 | Mirko | OAM12 |  |  |  |
| 1817 | 479.1 | **Rel-12 Self-Organizing Networks (SON) - OAM aspects** | 591d? | 2011-09-21 A | 2013-12-11 A | 100% | 2011-09-21 | 2013-12-11 | 591d? |  | S5 | 9408h | 9408h | OAM12-SON | PCG-29 |  |  | Rel-12 | SP-56 | Mirko | OAM12-SON |  |  | HNB, SON |
| 1818 | 479.1.1 | Multi-vendor Plug and Play eNB connection to the network | 586d? | 2011-09-21 A | 2013-12-11 A | 100% | 2011-09-21 | 2013-12-11 | 586d? | finish no earlier than 2013-12-11 | S5 | 4680h | 4680h | SON-NM-MUPPET | PCG-29 | NSN | anatoly.andrianov@nsn.com | Rel-12 | SP-56 | Mirko | SON-NM-MUPPET | 32.501, New TSs (32.508, 32.509) |  | HNB, SON |
| 1819 | 479.2 | **Compliance of 3GPP SA5 specifications to the NGMN Next Generation Converged Operations Requirements (NGCOR)** | 596d? | 2012-06-20 A | 2014-09-17 A | 100% | 2012-06-20 | 2014-09-17 | 595d? |  | S5 | 11616.5h | 11616.5h | OAM-NGMN_NGCOR | PCG-29 | Huawei | christian.toche@huawei.com | Rel-12 | SP-56 | Mirko | OAM-NGMN_NGCOR |  |  |  |
| 1820 | 479.2.1 | Converged Management Model Alignment (Phase 2) | 593d? | 2012-06-20 A | 2014-09-17 A | 100% | 2012-06-20 | 2014-09-17 | 593d? | finish no earlier than 2014-09-17 | S5 | 4744h | 4744h | OAM-MODAL | PCG-29 | NSN | olaf.pollakowski@nsn.com | Rel-12 | SP-56 | Mirko | OAM-MODAL | 32.156, new TR 28.820 |  |  |
| 1821 | 479.2.2 | 3GPP Fault Management Solution Profile for NGMN NGCOR | 266d? | 2012-06-20 A | 2013-06-19 A | 100% | 2012-06-20 | 2013-06-19 | 266d? | finish no earlier than 2013-06-19 | S5 | 2104.53h | 2104.53h | OAM-FMSP | PCG-29 | Ericsson | thomas.tovinger@ericsson.com | Rel-12 | SP-56 | Mirko | OAM-FMSP | new TS 28.390 |  |  |

Notes:
- 1796: Provide an extension of IMS based PSS and MBMS user services
- 1797: SP#63 completed. Identify use cases and requirements based on Rel-10/11 PSS and MBMS functionality to be addressed for IMS-based streaming and download enhancements
- 1798: SP#63 completed. Develop procedures towards enabling the IMS-based extensions of the identified use casES in CP-150TS 26.237. Refine existing MBMS download procedures to enable IMS-based MBMS file repair with the use of conventional HTTP web servers.
- 1799: Triggered by Rel-12 Feature Codec for Enhanced Voice Services (EVS_codec) UID_470030. Need for super wideband acoustic requirements and test methods
- 1800: SP#62 completed
- 1801: SP#65 completed
- 1802: SP#65 completion 09/14=>12/14. Exception in SP-140470. Dec.14: 65->100
- 1803: Stage 3 based on existing Stage 2 in TS 23.246 MBMS Architecture and functional description
- 1804: SP#65 completion 09/14=>12/14. Exception in SP-140471. SP#63 TR 26.848v100 for Information. Dec.14: 85->100.
- 1805: SP#65 completion 09/14=>12/14. Exception in SP-140471. Dec.14: 85->100
- 1806: SP#65 completion 09/14=>12/14. Exception in SP-140471. SP#63 TR 26.849v100 for Information. Dec.14: 75->100
- 1807: SP#65 completion 09/14=>12/14. Exception in SP-140471. Dec.14: 75->100
- 1808: SP#65 completed. Updated WID SP-130670=>SP-140594. Reduced Scope & Objectives. Moved work on new TR 26.924, etc. to Rel-13. Co-ordinate with CT1/3/4. Linked to SA4 Rel-7 Media handling and interaction in MTSI (MTSI-MHI) UID_7040
- 1809: SP#65 completed. Updated WID SP-130670=>SP-140594. Reduced Scope & Objectives. Moved work on new TR 26.924, etc. to Rel-13. Co-ordinate with CT1/3/4. Linked to SA4 Rel-7 Media handling and interaction in MTSI (MTSI-MHI) UID_7040
- 1810: Stage 2/3. 5/5/15: corrected to be Rel-12. Nothing to be done in the end (covered by Rel-13 QOSE2EMTSI-CT), so 100%
- 1811: Dec.14: CD: 09/14->09/15. 5/5/15: corrected to be Rel-12. Nothing to be done in the end (covered by Rel-13 QOSE2EMTSI-CT), so 100%
- 1812: CP#64 completion 06/14=>09/14. 5/5/15: corrected to be Rel-12. Nothing to be done in the end (covered by Rel-13 QOSE2EMTSI-CT), so 100%
- 1813: CP#64 completion 06/14=>09/14. 5/5/15: corrected to be Rel-12. Nothing to be done in the end (covered by Rel-13 QOSE2EMTSI-CT), so 100%
- 1814: SP#63 completed. Linked to Rel-6 Media Codecs and Formats for IMS Messaging and Presence (PRESNC-COFIMP) UID_34025. Work item which gave rise to TS 26.141
- 1815: SP#65 completed. Linked to E2EMTSI (End-to-End Multimedia Telephony Service for IMS extensions). Add Reqs&guidelines for video telephony robustness to improve service perf. for PLI, Generic NACK, and FIR messages within overall bitrate limit
- 1816: OAM12 is an umbrella Feature for changes that are not part of any other dedicated feature/WI
- 1817: OAM12-SON is an umbrella BB also for SON related TEI12 type of changes that are not part of any other dedicated feature/WI
- 1818: SP#62 completed. TS 32.508v200 for Approval, TS 32.509v100 for 1-step Approval
- 1819: SP#65 moved to Rel-13 OAM-PMID (Converged management Performance Management Interface Definition) UID_560235
- 1820: SP#65 completed. TR 28.280v100 for 1-step Approval
- 1821: SP#60 completed. TS 28.390v200 for Approval

| ID | WBS | Task | Duration | Start | Finish | Complete | Baseline start | Baseline finish | Baseline duration | Constraint | Resources | Work | Actual work | Acronym | PCG approved | WI rapporteur name | WI rapporteur e-mail | Release | TSG approved | MCC resp | Special Focus Doc | Acronym_3GU_Export | Status Report | TSG stopped |
| --- | --- | --- | --- | --- | --- | --- | --- | --- | --- | --- | --- | --- | --- | --- | --- | --- | --- | --- | --- | --- | --- | --- | --- | --- |
| 1822 | 479.3 | **Network Management for 3GPP Interworking WLAN** | 793d? | 2011-09-21 A | 2014-09-17 A | 100% | 2011-09-21 | 2014-06-18 | 727d? |  | S5 | 17232h | 17232h | OAM-IWLAN | PCG-27 | China Mobile | Chengang@chinamobile.com, lijian@chinamobile.com | Rel-12 | SP-53 | Mirko | WLAN | OAM-IWLAN |  |  |
| 1823 | 479.3.1 | Performance measurements part Network Management for 3GPP Interworking WLAN | 785d? | 2011-09-22 A | 2014-09-17 A | 100% | 2011-09-22 | 2014-06-18 | 720d? | finish no earlier than 2014-09-17 | S5 | 6272h | 6272h | OAM-IWLAN-SA5P | PCG-27 | China Mobile | Chengang@chinamobile.com, lijian@chinamobile.com | Rel-12 | SP-53 | Mirko | WLAN |  |  |  |
| 1824 | 479.3.2 | NIM part Network Management for 3GPP Interworking WLAN | 585d? | 2011-09-21 A | 2013-12-11 A | 100% | 2011-09-21 | 2013-12-11 | 585d? | finish no earlier than 2013-12-11 | S5 | 4672h | 4672h | OAM-IWLAN-SA5NM | PCG-27 | China Mobile | Chengang@chinamobile.com, lijian@chinamobile.com | Rel-12 | SP-53 | Mirko | WLAN |  |  |  |
| 1825 | 479.4 | **Rel-12 Network Infrastructure Management** | 267d? | 2013-12-11 A | 2014-12-12 A | 100% | 2013-12-11 | 2014-09-17 | 202d? |  | S5 | 5848h | 5848h | OAM12-NIM | PCG-30 |  |  | Rel-12 | SP-58 | Mirko |  | OAM12-NIM |  |  |
| 1826 | 479.4.1 | Alarm quality improvements | 263d? | 2013-12-11 A | 2014-12-12 A | 100% | 2013-12-11 | 2014-09-17 | 201d? | finish no earlier than 2014-12-12 | S5 | 2104h | 2104h | OAM-AMI-SA5 | PCG-32 | TeliaSonera | tommy.berggren@teliasonera.com | Rel-12 | SP-62 | Mirko |  | OAM-AMI | SP-140544 |  |
| 1827 | 479.4.2 | Radio Planning Tool (RPT) interface | 201d? | 2014-03-07 A | 2014-12-12 A | 100% | 2014-03-07 | 2014-09-17 | 139d? | finish no earlier than 2014-12-12 | S5 | 1608h | 1608h | OAM-RPTi-SA5 | PCG-32 | Nokia Networks | olaf.pollakowski@nsn.com | Rel-12 | SP-63 | Mirko |  | OAM-RPTi | SP-140546 |  |
| 1828 | 479.5 | Deleted - Rel-12 Performance Management | 328d? | 2013-06-21 A | 2014-09-16 A | 100% | 2013-06-21 | 2014-09-17 | 328d? |  | S5 | 2624h | 2624h | OAM12-PM | PCG-30 |  |  | Rel-12 | SP-58 | Mirko |  | OAM12-PM |  | SP-69 |
| 1829 | 479.6 | **OAM aspects of Network Sharing** | 267d? | 2013-12-11 A | 2014-12-12 A | 100% | 2013-12-11 | 2014-09-17 | 202d? |  | S5 | 6344h | 6344h | OAM-SHARE | PCG-32 | Orange | jeanmichel.cornily@orange.com | Rel-12 | SP-62 | Mirko |  | OAM-SHARE | SP-140545 |  |
| 1830 | 479.6.1 | OAM aspects of Network Sharing - Concepts and high-level requirements | 263d? | 2013-12-11 A | 2014-12-12 A | 100% | 2013-12-11 | 2014-09-17 | 201d? | finish no earlier than 2014-12-12 | S5 | 2104h | 2104h | OAM-SHARE-SA5c | PCG-32 | Orange | jeanmichel.cornily@orange.com | Rel-12 | SP-62 | Mirko |  |  | SP-140545 |  |
| 1831 | 479.6.2 | OAM aspects of Network Sharing - Impacts on existing specifications | 263d? | 2013-12-12 A | 2014-12-12 A | 100% | 2013-12-12 | 2014-09-17 | 201d? | finish no earlier than 2014-12-12 | S5 | 2104h | 2104h | OAM-SHARE-SA5imp | PCG-32 | Orange | jeanmichel.cornily@orange.com | Rel-12 | SP-62 | Mirko |  |  | SP-140545 |  |
| 1832 | 480 | **Rel-12 Charging** | 402d? | 2012-12-12 A | 2014-06-18 A | 100% | 2012-12-12 | 2014-06-18 | 402d? |  | S5 | 10112h | 10112h | CH12 | PCG-29 |  |  | Rel-12 | SP-57 | Mirko |  | CH12 |  |  |
| 1833 | 480.1 | Short Message Service - Service Center (SMS-SC) Offline Charging | 325d? | 2012-12-12 A | 2014-03-10 A | 100% | 2012-12-12 | 2014-03-07 | 325d? | finish no earlier than 2014-03-07 | S5 | 2592h | 2592h | SMS-SC-CH | PCG-30 | Alcatel-Lucent | maryse.gardella@alcatel-lucent.com | Rel-12 | SP-58 | Mirko |  | SMS-SC-CH |  |  |
| 1834 | 480.2 | Charging per IP - Connectivity Access Network (IP-CAN) Session (Stage 2/3) | 201d? | 2013-09-12 A | 2014-06-18 A | 100% | 2013-09-12 | 2014-06-18 | 201d? | finish no earlier than 2014-06-18 | S5 | 1608h | 1608h | CHIPS | PCG-31 | Ericsson | david.shrader@ericsson.com | Rel-12 | SP-61 | Mirko |  | CHIPS |  |  |
| 1835 | 480.3 | Charging using an Alternative Roaming Provider (Stage 2/3) | 202d? | 2013-09-12 A | 2014-06-18 A | 100% | 2013-09-12 | 2014-06-18 | 202d? | finish no earlier than 2014-06-18 | S5 | 1608h | 1608h | CHARP | PCG-31 | Ericsson | david.shrader@ericsson.com | Rel-12 | SP-61 | Mirko |  | CHARP |  |  |
| 1836 | 480.4 | Charging for IMS centralized service (ICS) control (Stage 2/3) | 137d? | 2013-12-11 A | 2014-06-18 A | 100% | 2013-12-11 | 2014-06-18 | 137d? | finish no earlier than 2014-06-18 | S5 | 1088h | 1088h | CHICS | PCG-32 | NSN | Gerald.Goermer@nsn.com | Rel-12 | SP-62 | Mirko |  | CHICS |  |  |
| 1837 | 481 | **IMS Emergency PSAP Callback (Stage 3)** | 724d? | 2011-09-21 A | 2014-06-13 A | 100% | 2011-09-21 | 2014-06-13 | 724d? |  | C1; C3; IETF | 38848h | 38848h | EMC_PC | PCG-27 | Ericsson | christer.holmberg@ericsson.com | Rel-12 | CP-53 | Frederic | Public Safety (I-A) | EMC_PC |  |  |
| 1838 | 481.1 | CT1 part of IMS Emergency PSAP Callback | 721d? | 2011-09-22 A | 2014-06-13 A | 100% | 2011-09-22 | 2014-06-13 | 721d? | finish no earlier than 2014-06-13 | C1 | 5760h | 5760h | EMC_PC | PCG-27 | Ericsson | christer.holmberg@ericsson.com | Rel-12 | CP-53 | Frederic | Public Safety (I-A) |  |  |  |
| 1839 | 481.2 | (IETF) CT1 part of IMS Emergency PSAP Callback (RFC 7090) | 723d? | 2011-09-21 A | 2014-06-13 A | 100% | 2011-09-21 | 2014-06-13 | 723d? | finish no earlier than 2014-06-13 | C1-IETF | 5776h | 5776h | EMC_PC | PCG-27 | christer.holmberg@ericsson.com | christer.holmberg@ericsson.com | Rel-12 | CP-53 | Frederic | Public Safety (I-A) |  |  |  |
| 1840 | 481.3 | CT3 part of IMS Emergency PSAP Callback | 519d? | 2011-09-24 A | 2013-09-06 A | 100% | 2011-09-24 | 2013-09-06 | 519d? | finish no earlier than 2013-09-06 | C3 | 4152h | 4152h | EMC_PC | PCG-27 | Ericsson | christer.holmberg@ericsson.com | Rel-12 | CP-53 | Adrian | Public Safety (I-A) |  |  |  |
| 1841 | 481.4 | (IETF) CT3 part of IMS Emergency PSAP Callback (RFC 7090) | 724d? | 2011-09-21 A | 2014-06-13 A | 100% | 2011-09-21 | 2014-06-13 | 724d? | finish no earlier than 2014-06-13 | C3-IETF | 5784h | 5784h | EMC_PC | PCG-31 | christer.holmberg@ericsson.com | christer.holmberg@ericsson.com | Rel-12 | CP-60 | Adrian | Public Safety (I-A) |  |  |  |
| 1842 | 482 | Interworking between a PLMN with WLAN to access the EPC and a PDN (Stage 3) | 265d? | 2012-09-10 A | 2013-09-06 A | 100% | 2012-09-10 | 2013-09-06 | 265d? | finish no earlier than 2013-08-12 | C3 | 2091.72h | 2091.72h | SAES_WLAN_EPC_intwk | PCG-29 | Huawei | Christian.Herrero@huawei.com | Rel-12 | CP-57 | Adrian | WLAN | SAES_WLAN_EPC_intwk |  |  |
| 1843 | 483 | **Reporting Enhancements in Warning Message Delivery (Stage 2/3)** | 402d? | 2012-12-07 A | 2014-06-13 A | 100% | 2012-12-07 | 2014-06-13 | 402d? |  | C1; C4; R3 | 20832.2h | 20832.2h | REP_WMD | PCG-30 | one2many | peter.sanders@one2many.eu | Rel-12 | CP-58 | Frederic | Public Safety (I-A) | REP_WMD |  |  |
| 1844 | 483.1 | CT1 part of Reporting Enhancements in Warning Message Delivery (Stage 2) | 329d? | 2012-12-07 A | 2014-03-04 A | 100% | 2012-12-07 | 2014-03-04 | 329d? | finish no earlier than 2014-03-06 | C1 | 2592.18h | 2592.18h | REP_WMD-CT1 | PCG-30 | one2many | peter.sanders@one2many.eu | Rel-12 | CP-58 | Frederic | Public Safety (I-A) |  |  |  |
| 1845 | 483.2 | CT4 part of Reporting Enhancements in Warning Message Delivery (Stage 2/3) | 400d? | 2012-12-10 A | 2014-06-13 A | 100% | 2012-12-10 | 2014-06-13 | 400d? | finish no earlier than 2014-06-13 | C4 | 3168h | 3168h | REP_WMD-CT4 | PCG-30 | one2many | peter.sanders@one2many.eu | Rel-12 | CP-58 | Kimmo | Public Safety (I-A) |  |  |  |

Notes:
- 1822: SP#65 updated WID SP-120779=>SP-140542 (removed parts on CN and non-3GPP access). Discontinue I-WLAN spec.
- 1823: SP#65 completed. TS 28.402v100 for 1-step Approval, withdraw New TS 28.401 (CN and non-3GPP access i/w PMs). Moved PMs for EPC and non-3GPP access i/w from 28.401=>28.402 / Impacted TSs and TRs: new TS 28.401, withdrawn new TS 28.402
- 1824: SP#65 discontinue I-WLAN specs: Move parts (e.g. IOCs) applicable for EPC and non-3GPP access interworking NRMs from 28.601/2/6 to 28.611/2/6. Withdraw 28.601/2/6 (CN and non-3GPP access i/w NRMs). SP#62 completed. TSs 28.601/2/6/11/12/16 for Approval / Impacted TSs and TRs: 32.632, 32.636, 32.752, 32.756, new TS (28.611, 28.612, 28.616, withdrawn 28.601, 28.602, 28.606)
- 1825: -
- 1826: SP#65 completion 09/14=>12/14. Exception in SP-140544. Triggered by Rel-12 TR 32.859 Study on Alarm Management (FS_OAM_AM) . Dec.14: 50->100 / Impacted TSs and TRs: 32.111-1, 32.111-2, 32.111-6
- 1827: SP#65 completion 09/14=>12/14. Exception in SP-140546. SP#65 v100 TS 28.667/8 for Information. Dec.14: 60->100 / Impacted TSs and TRs: 32.101, New TSs (28.667, 28.668, 28.669)
- 1828: OAM12-PM is an umbrella BB also for PM related TEI12 type of changes that are not part of any other dedicated feature/WI
- 1829: SP#65 completion 09/14=>12/14. Exception in SP-140545. Triggered by Rel-12 TR 32.851 Study on OAM aspects of Network Sharing (FS_OAM_SHARE), Rel-6 Network Sharing (NTShar) UID_31018 / Impacted TSs and TRs: Stage 1/2/3
- 1830: SP#65 completion 09/14=>12/14. Exception in SP-140545. LM 80->100 / Impacted TSs and TRs: new TS 32.130
- 1831: SP#65 completion 09/14=>12/14. Exception in SP-140545. Dec.14: 60->100 / Impacted TSs and TRs: 28.401,28.621/2/3,28.651/2/3,28.654/5/6,28.657/8/9,28.701/2/3,28.731/2/3,28.734/5/6,32.101/2,32.111-1/2/3/6,32.121/2/6,32.155,32.171/2/6,32.300/1/2/6,32.311/2/6,32.321/2/6,32.331/2/6,32.341/2/6,32.351/352/6,32.361/2/6,32.381/2/6,32.405/6/7/8/9/10/11/12/41
- 1832: CH12 is an umbrella Feature for changes that are not part of any other dedicated feature/WI
- 1833: Stage 2/3. SP#63 completed. Updated WID SP-120775=>SP-140027 / Impacted TSs and TRs: 32.240, 32.274, 32.297, 32.298, 32.299
- 1834: SP#64 completed. 12/15: Acronym reverted back from CHIPCAN to CHIPS / Impacted TSs and TRs: 32.251, 32.298, 32.299
- 1835: SP#64 completed. TS 32.276v200 for Approval, 32.293v100 for 1-step Approval / Impacted TSs and TRs: 32.240, 32.299, New TSs [32.276 (Voice Call Service Charging), 32.293 (Proxy Function)]
- 1836: SP#64 completed. Align SA5 Charging specifications with Rel-8 Feature IMS Centralized Service control (ICSRA) and subsequent enhancements under TEIx (SA2 23.292 ICSRA Stage 2, CT3 29.292, CT1 24.607, 24.611) / Impacted TSs and TRs: 32.250, 32.298
- 1837: Dep. IETF ECRIT on PSAP call back. Fulfill SA1/2 Rel-7 EMC1 reqs UID_32045 PS domain and IMS impacts for supporting IMS Emergency calls (related to BB UID_1653 Emergency Call Enhancements for IP& PS Based Calls / Impacted TSs and TRs: Stage 3
- 1838: CP#64 completed. 2/4/15: acronym changed to EMC_PC / Impacted TSs and TRs: 24.229, tied to completion of IETF dependencies: 24.604, 24.605, 24.610, 24.611, 24.629
- 1839: CP#64 completed. 2/4/15: acronym changed to EMC_PC / Impacted TSs and TRs: RFC 7090 (was draft-ietf-ecrit-psap-callback
- 1840: CP#61 completed. 2/4/15: acronym changed to EMC_PC / Impacted TSs and TRs: 29.163, 29.165
- 1841: CP#64 completed. 2/4/15: acronym changed to EMC_PC / Impacted TSs and TRs: RFC 7090 (was draft-ietf-ecrit-psap-callback)
- 1842: CP#61 completed. Linked to Rel-8 Feature SAES in CP-150System Architecture Evolution specification - Evolved Packet System (non RAN aspects) UID_320005 / Impacted TSs and TRs: 29.061
- 1843: Stage 1 for Cell Broadcast does not exist. This WID enhances the reporting capabilities of Warning Message Delivery. Introduce LTE functionality requested by regulators, equivalent to existing 2G/3G functionality. / Impacted TSs and TRs: Stage 2/3
- 1844: CP#63 completed / Impacted TSs and TRs: 23.041
- 1845: CP#64 completed / Impacted TSs and TRs: 23.007, 29.168

| ID | WBS | Task | Duration | Start | Finish | Complete | Remaining | Baseline start | Baseline finish | Baseline duration | Total slack | Constraint | Resources | Work | Actual work | Acronym | PCG approved | WI rapporteur name | Release | TSG approved | MCC resp | Special Focus Doc | Acronym_3GU_Export | Status Report |
| --- | --- | --- | --- | --- | --- | --- | --- | --- | --- | --- | --- | --- | --- | --- | --- | --- | --- | --- | --- | --- | --- | --- | --- | --- |
| 1846 | 483.3 | **Public Warning System - Reset/Failure/Restart in Warning Message Delivery in LTE** | 340d? | 2013-03-04 A | 2014-06-13 A | 100% |  | 2013-03-04 | 2014-06-13 | 340d? |  |  | R3 | 5424h | 5424h | REP_WMD-RFR_PWS | PCG-30 | one2many, Huawei | Rel-12 | RP-59 | Juha | Public Safety (I-A) | REP_WMD-RFR_PWS |  |
| 1847 | 483.3.1 | Core part: PWS - Reset/Failure/Restart in Warning Message Delivery in LTE | 338d? | 2013-03-04 A | 2014-06-13 A | 100% |  | 2013-03-04 | 2014-06-13 | 338d? |  | finish no earlier than 2014-06-13 | R3 | 2704h | 2704h | REP_WMD-RFR_PWS-Core | PCG-30 | one2many, Huawei | Rel-12 | RP-59 | Juha | Public Safety (I-A) | REP_WMD-RFR_PWS-Core | RP-140637 |
| 1848 | 484 | **Single Radio Voice Call Continuity (SRVCC) before ringing (Stage 3)** | 331d? | 2012-12-07 A | 2014-03-06 A | 100% |  | 2012-12-07 | 2014-03-06 | 331d? |  |  | C1; C3; R5 | 9584h | 9584h | bSRVCC | PCG-30 | NTT DOCOMO | Rel-12 | CP-58 | Frederic |  | bSRVCC |  |
| 1849 | 484.1 | CT1 part of Single Radio Voice Call Continuity (SRVCC) before ringing | 138d? | 2012-12-07 A | 2013-06-14 A | 100% |  | 2012-12-07 | 2013-06-14 | 138d? |  | finish no earlier than 2013-06-14 | C1 | 1096h | 1096h | bSRVCC | PCG-30 | NTT DOCOMO | Rel-12 | CP-58 | Frederic |  |  |  |
| 1850 | 484.2 | CT3 part of Single Radio Voice Call Continuity (SRVCC) before ringing | 3d? | 2013-06-12 A | 2013-06-14 A | 100% |  | 2013-06-12 | 2013-06-14 | 3d? |  | finish no earlier than 2013-06-14 | C3 | 24h | 24h | bSRVCC | PCG-31 | NTT DOCOMO | Rel-12 | CP-60 | Adrian |  |  |  |
| 1851 | 484.3 | Test part: Single Radio Voice Call Continuity (SRVCC) before ringing | 65d? | 2013-12-06 A | 2014-03-06 A | 100% |  | 2013-12-06 | 2014-03-06 | 65d? |  | finish no earlier than 2014-03-06 | R5 | 520h | 520h | bSRVCC-UEConTest | PCG-32 | NTT DOCOMO | Rel-12 | CP-62 | Ingbert |  | bSRVCC-UEConTest | RP-140422 |
| 1852 | 485 | **IMS Stage 3 IETF Protocol Alignment - phase 6** | 532d? | 2012-12-07 A | 2014-12-09 | 97% | 17.95d? | 2012-12-07 | 2014-12-05 | 527d? | 1053d |  | C1; C3; IETF | 20640.6h | 17961.5h | IMSProtoc6 | PCG-30 | Alcatel-Lucent | Rel-12 | CP-58 | Frederic |  | IMSProtoc6 |  |
| 1853 | 485.1 | CT1 part of IMS Stage 3 IETF Protocol Alignment - phase 6 | 464d? | 2012-12-07 A | 2014-09-11 A | 100% |  | 2012-12-07 | 2014-09-12 | 464d? |  | finish no earlier than 2014-09-12 | C1 | 3712h | 3712h | IMSProtoc6 | PCG-30 | Alcatel-Lucent | Rel-12 | CP-58 | Frederic |  |  |  |
| 1854 | 485.2 | (IETF) CT1 part of IMS Stage 3 IETF Protocol Alignment - phase 6 (holmberg-sipcore-received-realm) | 410d? | 2013-05-21 A | 2014-12-09 A | 100% |  | 2013-05-21 | 2014-12-05 | 408d? |  | finish no earlier than 2014-12-09 | C1-IETF | 3256.25h | 3256.25h | IMSProtoc6 | PCG-31 | christer.holmberg@ericsson.com | Rel-12 | CP-60 | Frederic |  |  |  |
| 1855 | 485.3 | (IETF) CT1 part of IMS Stage 3 IETF Protocol Alignment - phase 6 (allen-sipcore-sip-tree-cap-indicators) | 63d? | 2014-09-12 A | 2014-12-09 | 25% | 47.25d? |  |  |  | 1053d | finish no earlier than 2014-12-09 | C1-IETF | 504h | 126h | IMSProtoc6 | PCG-33 | christer.holmberg@ericsson.com | Rel-12 | CP-65 |  |  |  |  |
| 1856 | 485.4 | (IETF) CT1 part of IMS Stage 3 IETF Protocol Alignment - phase 6 (draft-ietf-insipid-session-id) | 65d? | 2014-09-12 A | 2014-12-09 A | 100% |  |  |  |  |  | start no earlier than 2014-09-12 | C1-IETF | 520h | 520h | IMSProtoc6 | PCG-34 | christer.holmberg@ericsson.com | Rel-12 | CP-65 |  |  |  |  |
| 1857 | 485.5 | CT3 part of IMS Stage 3 IETF Protocol Alignment - phase 6 | 71d? | 2014-06-06 A | 2014-09-11 A | 100% |  | 2014-06-06 | 2014-09-12 | 71d? |  | finish no earlier than 2014-09-12 | C3 | 568h | 568h | IMSProtoc6 | PCG-30 | Alcatel-Lucent | Rel-12 | CP-58 | Adrian |  |  |  |
| 1858 | 485.6 | (IETF) CT3 part of IMS Stage 3 IETF Protocol Alignment - phase 6 (holmberg-sipcore-received-realm) | 327d? | 2013-09-06 A | 2014-12-05 A | 100% |  | 2013-09-06 | 2014-12-05 | 327d? |  | finish no earlier than 2014-12-05 | C3-IETF | 2608h | 2608h | IMSProtoc6 | PCG-31 | christer.holmberg@ericsson.com | Rel-12 | CP-61 |  |  |  |  |
| 1859 | 486 | **SAE Protocol Development - Phase 3** | 467d? | 2012-12-07 A | 2014-09-11 A | 100% |  | 2012-12-07 | 2014-09-12 | 467d? |  |  | C1 | 14920h | 14920h | SAES3 | PCG-30 | InterDigital | Rel-12 | CP-58 | Frederic |  | SAES3 |  |
| 1860 | 486.1 | SAE Protocol Development (Stage 3) - Phase 3 | 466d? | 2012-12-07 A | 2014-09-11 A | 100% |  | 2012-12-07 | 2014-09-12 | 466d? |  | finish no earlier than 2014-09-12 | C1 | 3728h | 3728h | SAES3-CT1 | PCG-30 | InterDigital | Rel-12 | CP-58 | Frederic |  |  |  |
| 1861 | 486.2 | CS Fallback in EPS - Phase 3 | 466d? | 2012-12-07 A | 2014-09-11 A | 100% |  | 2012-12-07 | 2014-09-12 | 466d? |  | finish no earlier than 2014-09-12 | C1 | 3728h | 3728h | SAES3-CSFB | PCG-30 | InterDigital | Rel-12 | CP-58 | Frederic |  | SAES3-CSFB |  |
| 1862 | 486.3 | SAE for support for non-3GPP accesses - Phase 3 | 466d? | 2012-12-07 A | 2014-09-11 A | 100% |  | 2012-12-07 | 2014-09-12 | 466d? |  | finish no earlier than 2014-09-12 | C1 | 3728h | 3728h | SAES3-non3GPP | PCG-30 | InterDigital | Rel-12 | CP-58 | Frederic |  | SAES3-non3GPP |  |
| 1863 | 487 | **IM-SSF Application Server Service Data Descriptions (Stage 2/3)** | 138d? | 2012-12-07 A | 2013-06-14 A | 100% |  | 2012-12-07 | 2013-06-14 | 138d? |  |  | C4; C1 | 3780h | 3780h | IMS_SSFDD | PCG-30 | Huawei | Rel-12 | CP-58 | Kimmo |  | IMS_SSFDD |  |
| 1864 | 487.1 | Stage 2 for IM-SSF Application Server Service Data Descriptions | 62d? | 2012-12-07 A | 2013-03-01 A | 100% |  | 2012-12-07 | 2013-03-01 | 62d? |  | finish no earlier than 2013-06-14 | C1 | 488h | 488h | IMS_SSFDD | PCG-30 | Huawei | Rel-12 | CP-58 | Frederic |  |  |  |
| 1865 | 487.2 | Stage 3 for IM-SSF Application Server Service Data Descriptions | 136.5d? | 2012-12-10 A | 2013-06-14 A | 100% |  | 2012-12-10 | 2013-06-14 | 136.5d? |  | finish no earlier than 2013-06-14 | C4 | 1084h | 1084h | IMS_SSFDD | PCG-30 | Huawei | Rel-12 | CP-58 | Kimmo |  |  |  |
| 1866 | 488 | **Diameter based interface between SGSN and SMS central functions (Stage 2/3)** | 265d? | 2012-12-10 A | 2013-12-06 A | 100% |  | 2012-12-10 | 2013-12-06 | 265d? |  |  | C4; C1 | 7952h | 7952h | Dia_SGSN_SMS | PCG-30 | Alcatel-Lucent | Rel-12 | CP-58 | Kimmo |  | Dia_SGSN_SMS |  |
| 1867 | 488.1 | Stage 2 for Diameter based interface between SGSN and SMS central functions | 201d? | 2013-03-07 A | 2013-12-06 A | 100% |  | 2013-03-07 | 2013-12-06 | 201d? |  | finish no earlier than 2013-12-06 | C1 | 1608h | 1608h | Dia_SGSN_SMS | PCG-30 | Alcatel-Lucent | Rel-12 | CP-59 | Frederic |  |  |  |
| 1868 | 488.2 | Stage 3 for Diameter based interface between SGSN and SMS central functions | 265d? | 2012-12-10 A | 2013-12-06 A | 100% |  | 2012-12-10 | 2013-12-06 | 265d? |  | finish no earlier than 2013-12-06 | C4 | 2104h | 2104h | Dia_SGSN_SMS | PCG-30 | Alcatel-Lucent | Rel-12 | CP-58 | Kimmo |  |  |  |
| 1869 | 489 | Diameter based interface between SGSN-GMLC (Stage 3) | 265d? | 2012-12-10 A | 2013-12-06 A | 100% |  | 2012-12-10 | 2013-12-06 | 265d? |  | finish no earlier than 2013-12-06 | C4 | 2096h | 2096h | Dia_SGSN_GMLC | PCG-30 | Cisco | Rel-12 | CP-58 | Kimmo |  | Dia_SGSN_GMLC |  |
| 1870 | 490 | IMS impacts on UICC Application Aspects (Stage 3) | 465d? | 2013-03-04 A | 2014-12-09 A | 100% |  | 2013-03-04 | 2014-09-12 | 403d? |  | finish no earlier than 2014-12-09 | C6 | 3720h | 3720h | IMS_UApAs | PCG-30 | Giesecke & Devrient | Rel-12 | CP-59 | Xavier |  | IMS_UApAs | CP-140696 |

Notes:
- 1846: - / Impacted TSs and TRs: LTE / WI rapporteur e-mail: peter.sanders@one2many.eu, Dai Mingzeng (daimingzeng@huawei.com)
- 1847: RP#64 completed / Impacted TSs and TRs: 36.413 / WI rapporteur e-mail: peter.sanders@one2many.eu, Dai Mingzeng (daimingzeng@huawei.com)
- 1848: Linked to Rel-8 Feature IMS Service Continuity (IMS-Cont) UID_390056. TS 23.237 Rel-12 CR#0444 under TEI12 / Impacted TSs and TRs: GERAN, UTRA, LTE / WI rapporteur e-mail: keisuke.sasada.kx@nttdocomo.com
- 1849: CP#60 completed. 2/4/15: acronym changed to bSRVCC / Impacted TSs and TRs: 24.008, 24.237 / WI rapporteur e-mail: keisuke.sasada.kx@nttdocomo.com
- 1850: CP#60 completedbSRVCC / Impacted TSs and TRs: 29.165 / WI rapporteur e-mail: keisuke.sasada.kx@nttdocomo.com
- 1851: RP#63 completed. Testing for CT1 TS 24.237 (IMS service continuity Stage 3) / Impacted TSs and TRs: 34.229-1, 34.229-2, 36.523-1, 36.523-2 / WI rapporteur e-mail: Masahiro.Tamaoki.eu@nttdocomo.com
- 1852: - / Impacted TSs and TRs: Stage 3 / WI rapporteur e-mail: keith.drage@alcatel-lucent.com
- 1853: CP#65 completed. 4/2/15: acronym changed to IMSProtoc6 / Impacted TSs and TRs: 23.218, 24.229, 24.930 / WI rapporteur e-mail: keith.drage@alcatel-lucent.com
- 1854: Not completed internet-draft. 4/2/15: acronym changed to IMSProtoc6; 21/3/17: 50%->100 / Impacted TSs and TRs: draft-holmberg-sipcore-received-realm / WI rapporteur e-mail: christer.holmberg@ericsson.com
- 1855: Not completed internet-draft. 4/2/15: acronym changed to IMSProtoc6 / Impacted TSs and TRs: draft-allen-sipcore-sip-tree-cap-indicators / WI rapporteur e-mail: christer.holmberg@ericsson.com
- 1856: work in progress. 4/2/15: acronym changed to IMSProtoc6; 21/3/17: 25%->100 / Impacted TSs and TRs: draft-ietf-insipid-session-id
- 1857: CP#65 completed. 4/2/15: acronym changed to IMSProtoc6 / Impacted TSs and TRs: 29.163, 29.165 / WI rapporteur e-mail: keith.drage@alcatel-lucent.com
- 1858: Not completed internet-draft. 4/2/15: acronym changed to IMSProtoc6; 21/3/17: 50%->100 / Impacted TSs and TRs: draft-holmberg-sipcore-received-realm / WI rapporteur e-mail: christer.holmberg@ericsson.com
- 1859: Stage 3 continuation of Rel-8 Feature SAES (3GPP System Architecture Evolution Specification - Evolved Packet System) UID_320005 / Impacted TSs and TRs: Stage 2/3 / WI rapporteur e-mail: behrouz.aghili@interdigital.com
- 1860: CP#65 completed / Impacted TSs and TRs: 23.122, 24.008, 24.167, 24.229, 24.301, 24.302, 24.303, 24.304, 24.305, 24.312, 29.018, 29.118 / WI rapporteur e-mail: behrouz.aghili@interdigital.com
- 1861: CP#65 completed / Impacted TSs and TRs: 23.122, 24.008, 24.167, 24.229, 24.301, 24.302, 24.303, 24.304, 24.305, 24.312, 29.018, 29.118 / WI rapporteur e-mail: behrouz.aghili@interdigital.com
- 1862: CP#65 completed / Impacted TSs and TRs: 23.122, 24.008, 24.167, 24.229, 24.301, 24.302, 24.303, 24.304, 24.305, 24.312, 29.018, 29.118 / WI rapporteur e-mail: behrouz.aghili@interdigital.com
- 1863: CP#60 completed / Impacted TSs and TRs: Stage 2/3 / WI rapporteur e-mail: susan.shishufeng@huawei.com
- 1864: CP#59 completed / Impacted TSs and TRs: 23.218 / WI rapporteur e-mail: susan.shishufeng@huawei.com
- 1865: CP#60 completed / Impacted TSs and TRs: 29.328, 29.329, 29.364 / WI rapporteur e-mail: susan.shishufeng@huawei.com
- 1866: CP#62 completed / Impacted TSs and TRs: Stage 2/3 / WI rapporteur e-mail: jean-jacques.trottin@alcatel-lucent.com
- 1867: CP#62 completed / Impacted TSs and TRs: 23.040 / WI rapporteur e-mail: jean-jacques.trottin@alcatel-lucent.com
- 1868: CP#62 completed / Impacted TSs and TRs: 29.002, 29.230, 29.272, 29.305, 29.336, 29.337, 29.338 / WI rapporteur e-mail: jean-jacques.trottin@alcatel-lucent.com
- 1869: CP#62 completed. Updated WID CP-130273=>CP-130598. No Stage 2 impact. Define a Diameter variant for the protocol used over existing reference points between SGSN and GMLC for LCS (replace the use of MAP by Diameter protocol) / Impacted TSs and TRs: 29.002, 29.172, 29.173, 29.230, 29.272 / WI rapporteur e-mail: Nirav Salot (nsalot@cisco.com)
- 1870: CP#65 completion 09/14=>12/14. Exception in CP-140696. Dec.14: 85->100% / Impacted TSs and TRs: 31.102, 31.103, 31.111, 31.130 / WI rapporteur e-mail: sergi.espi@gi-de.com

| ID | WBS | Task | Duration | Start | Finish | Complete | Baseline start | Baseline finish | Baseline duration | Constraint | Resources | Work | Actual work | Acronym | PCG approved | Impacted TSs and TRs | WI rapporteur name | WI rapporteur e-mail | Release | TSG approved | MCC resp | Acronym_3GU_Export | Status Report |
| --- | --- | --- | --- | --- | --- | --- | --- | --- | --- | --- | --- | --- | --- | --- | --- | --- | --- | --- | --- | --- | --- | --- | --- |
| 1871 | 491 | **eMBMS restoration procedures** | 406d? | 2013-03-01 A | 2014-09-11 A | 100% | 2013-03-01 | 2014-06-13 | 341d? |  | C4; C3 | 10272h | 10272h | eMBMS_Rest | PCG-30 | Stage 3 | Alcatel-Lucent | bruno.landais@alcatel-lucent.com | Rel-12 | CP-59 | Kimmo | eMBMS_Rest |  |
| 1872 | 491.1 | CT4 part of eMBMS restoration procedures | 205d? | 2013-03-01 A | 2013-12-06 A | 100% | 2013-03-01 | 2013-12-06 | 205d? | finish no earlier than 2013-12-06 | C4 | 1616h | 1616h | eMBMS_Rest | PCG-30 | 23.007, 23.008, 29.274 | Alcatel-Lucent | bruno.landais@alcatel-lucent.com | Rel-12 | CP-59 | Kimmo |  |  |
| 1873 | 491.2 | CT3 part of eMBMS restoration procedures | 270d? | 2013-09-04 A | 2014-09-11 A | 100% | 2013-09-04 | 2014-06-13 | 205d? | finish no earlier than 2014-09-12 | C3 | 2160h | 2160h | eMBMS_Rest | PCG-31 | 29.061 | Alcatel-Lucent | bruno.landais@alcatel-lucent.com | Rel-12 | CP-61 | Kimmo |  |  |
| 1874 | 492 | **Dual Radio VCC enhancements (Stage 2/3)** | 325d? | 2012-09-19 A | 2013-12-06 A | 100% | 2012-09-19 | 2013-12-06 | 325d? |  | C1; C3.S2 | 10866.2h | 10866.2h | eDRVCC | PCG-30 | Stage 2/3 | Ericsson | Jan.Holm@ericsson.com | Rel-12 | CP-59 | Maurice | eDRVCC |  |
| 1875 | 492.1 | Stage 2 for Dual Radio VCC enhancements | 57.55d? | 2012-09-19 A | 2013-03-01 A | 100% | 2012-09-19 | 2013-03-01 | 57.55d? | finish no earlier than 2013-03-01 | S2 | 460.4h | 460.4h | eDRVCC | PCG-30 | 23.237 | Ericsson | Jan.Holm@ericsson.com | Rel-12 | CP-59 | Maurice |  |  |
| 1876 | 492.2 | **Stage 3 for Dual Radio VCC enhancements** | 205d? | 2013-03-01 A | 2013-12-06 A | 100% | 2013-03-01 | 2013-12-06 | 205d? |  | C1; C3 | 5205.8h | 5205.8h | eDRVCC | PCG-30 | Stage 3 | Ericsson | Jan.Holm@ericsson.com | Rel-12 | CP-59 | Frederic |  |  |
| 1877 | 492.2.1 | CT1 part of Stage 3 for Dual Radio VCC enhancements | 205d? | 2013-03-01 A | 2013-12-06 A | 100% | 2013-03-01 | 2013-12-06 | 205d? | finish no earlier than 2013-12-06 | C1 | 1608h | 1608h | eDRVCC | PCG-30 | 24.237, 24.292 | Ericsson | Jan.Holm@ericsson.com | Rel-12 | CP-59 | Frederic |  |  |
| 1878 | 492.2.2 | CT3 part of Stage 3 for Dual Radio VCC enhancements | 41.7d? | 2013-03-01 A | 2013-09-06 A | 100% | 2013-03-01 | 2013-09-06 | 41.7d? | finish no earlier than 2013-09-06 | C3 | 317.8h | 317.8h | eDRVCC | PCG-30 | 29.165 | Ericsson | Jan.Holm@ericsson.com | Rel-12 | CP-59 | Adrian |  |  |
| 1879 | 493 | **CT aspects of Signalling of Image Size (Stage 2/3)** | 129d? | 2013-06-14 A | 2013-12-06 A | 100% | 2013-06-14 | 2013-12-06 | 129d? |  | C4; C1; C3 | 6136.8h | 6136.8h | SIS_CT | PCG-31 | Stage 2/3 | Ericsson | nevenka.biondic@ericsson.com | Rel-12 | CP-60 | Kimmo | SIS_CT |  |
| 1880 | 493.1 | CT4 part of Signalling of Image Size | 128.05d? | 2013-06-14 A | 2013-12-06 A | 100% | 2013-06-14 | 2013-12-06 | 128.05d? | finish no earlier than 2013-12-06 | C4 | 1008.4h | 1008.4h | SIS_CT | PCG-31 | 23.333, 23.334, 29.238, 29.332, 29.333, 29.334 | Ericsson | nevenka.biondic@ericsson.com | Rel-12 | CP-60 | Kimmo |  |  |
| 1881 | 493.2 | CT1 part of CT Aspects of Signalling of Image Size | 129d? | 2013-06-14 A | 2013-12-06 A | 100% | 2013-06-14 | 2013-12-06 | 129d? | finish no earlier than 2013-12-06 | C1 | 1016h | 1016h | SIS_CT | PCG-31 | 24.229 | Ericsson | nevenka.biondic@ericsson.com | Rel-12 | CP-60 | Frederic |  |  |
| 1882 | 493.3 | CT3 part of CT Aspects of Signalling of Image Size | 128.05d? | 2013-06-14 A | 2013-12-06 A | 100% | 2013-06-14 | 2013-12-06 | 128.05d? | finish no earlier than 2013-12-06 | C3 | 1016.4h | 1016.4h | SIS_CT | PCG-31 | 29.162, 29.163 | Ericsson | nevenka.biondic@ericsson.com | Rel-12 | CP-60 | Adrian |  |  |
| 1883 | 494 | IMS Centralized Services (ICS) InterWorking Enhancement in Mobile Switching Center Server (MSC-S) | 129d? | 2013-06-14 A | 2013-12-06 A | 100% | 2013-06-14 | 2013-12-06 | 129d? | finish no earlier than 2013-12-06 | C3 | 1008h | 1008h | ICS_IWE | PCG-31 | 29.292 | Orange | marianne.mohali@orange.com | Rel-12 | CP-60 | Adrian | ICS_IWE |  |
| 1884 | 495 | GPRS Tunnelling Protocol for the Control plane (GTP-C) Overload Control Mechanisms | 267d? | 2013-09-06 A | 2014-09-11 A | 100% | 2013-09-06 | 2014-09-12 | 267d? | finish no earlier than 2014-09-12 | C4 | 2136h | 2136h | GOCMe | PCG-31 | 23.008, 29.230, 29.273, 29.274, 29.303, New TR 29.807 | Cisco | Nirav Salot (nsalot@cisco.com) | Rel-12 | CP-61 | Kimmo | GOCMe |  |
| 1885 | 496 | **Proxy Call Session Control Function (P-CSCF) restoration enhancements (Stage 2/3)** | 447.1d? | 2013-04-03 A | 2014-12-09 A | 100% | 2013-04-03 | 2014-12-05 | 442.1d? |  | C4; C3; C1 | 54903.2h | 54903.2h | PCSCF_RES | PCG-31 | Stage 2/3 | Ericsson | maria.cruz.bartolome@ericsson.com | Rel-12 | CP-61 | Kimmo | PCSCF_RES |  |
| 1886 | 496.1 | TR on Proxy Call Session Control Function (P-CSCF) restoration enhancements | 266d? | 2013-09-06 A | 2014-09-11 A | 100% | 2013-09-06 | 2014-09-12 | 266d? | finish no earlier than 2014-09-12 | C4 | 2128h | 2128h | PCSCF_RES | PCG-31 | New TR 29.806 | Ericsson | maria.cruz.bartolome@ericsson.com | Rel-12 | CP-61 | Kimmo |  |  |
| 1887 | 496.2 | **Common for HSS & PCRF solutions** | 447.1d? | 2013-04-03 A | 2014-12-09 A | 100% |  |  |  |  | C4; C3; C1 | 18602.4h | 18602.4h | PCSCF_RES | PCG-33 |  | Ericsson | maria.cruz.bartolome@ericsson.com | Rel-12 | CP-64 |  |  |  |
| 1888 | 496.2.1 | CT4 part of Common for HSS & PCRF solutions | 328d? | 2013-09-06 A | 2014-12-09 A | 100% | 2013-09-06 | 2014-12-05 | 326d? | finish no earlier than 2014-12-09 | C4 | 2624h | 2624h | PCSCF_RES | PCG-31 | 23.380, 29.060, 29.274 | Ericsson | maria.cruz.bartolome@ericsson.com | Rel-12 | CP-61 | Kimmo |  | CP-140481 |
| 1889 | 496.2.2 | CT1 part of Common for HSS & PCRF solutions | 328d? | 2013-04-03 A | 2014-12-05 A | 100% | 2013-04-03 | 2014-12-05 | 326d? | finish no earlier than 2014-12-09 | C1 | 2624h | 2624h | PCSCF_RES | PCG-33 | 24.008 | Ericsson | maria.cruz.bartolome@ericsson.com | Rel-12 | CP-64 | Kimmo |  |  |
| 1890 | 496.2.3 | CT3 part of Common for HSS & PCRF solutions | 328d? | 2013-05-03 A | 2014-12-09 A | 100% | 2013-05-03 | 2014-12-05 | 326d? | finish no earlier than 2014-12-09 | C3 | 2624h | 2624h | PCSCF_RES | PCG-33 | 29.061, 29.165 | Huawei | susan.shishufeng@huawei.com | Rel-12 | CP-65 | Kimmo |  | CP-140687 |
| 1891 | 496.3 | **HSS based solution** | 447.1d? | 2013-04-03 A | 2014-12-09 A | 100% |  |  |  |  | C4; C1 | 12401.6h | 12401.6h | PCSCF_RES | PCG-33 |  | Ericsson | maria.cruz.bartolome@ericsson.com | Rel-12 | CP-64 |  |  |  |
| 1892 | 496.3.1 | CT4 part of HSS based solution | 328d? | 2013-09-06 A | 2014-12-09 A | 100% | 2013-09-06 | 2014-12-05 | 326d? | finish no earlier than 2014-12-09 | C4 | 2624h | 2624h | PCSCF_RES | PCG-31 | 29.002, 29.228, 29.229, 29.272, 29.305 | Ericsson | maria.cruz.bartolome@ericsson.com | Rel-12 | CP-61 | Kimmo |  | CP-140481 |
| 1893 | 496.3.2 | CT1 part of HSS based solution | 328d? | 2013-04-03 A | 2014-12-09 A | 100% | 2013-04-03 | 2014-12-05 | 326d? | finish no earlier than 2014-12-09 | C1 | 2624h | 2624h | PCSCF_RES | PCG-33 | 24.229 | Ericsson | maria.cruz.bartolome@ericsson.com | Rel-12 | CP-64 | Kimmo |  | CP-140605 |
| 1894 | 496.4 | **PCRF based solution** | 447.1d? | 2013-04-03 A | 2014-12-09 A | 100% |  |  |  |  | C3; C1 | 12401.6h | 12401.6h | PCSCF_RES | PCG-33 |  | Huawei | susan.shishufeng@huawei.com | Rel-12 | CP-64 |  |  |  |
| 1895 | 496.4.1 | CT3 part of PCRF based solution | 328d? | 2013-05-03 A | 2014-12-09 A | 100% | 2013-05-03 | 2014-12-05 | 326d? | finish no earlier than 2014-12-09 | C3 | 2624h | 2624h | PCSCF_RES | PCG-33 | 29.212, 29.213, 29.214, 29.215 | Huawei | susan.shishufeng@huawei.com | Rel-12 | CP-64 | Kimmo |  | CP-140687 |
| 1896 | 496.4.2 | CT1 part of PCRF based solution | 328d? | 2013-04-03 A | 2014-12-09 A | 100% | 2013-04-03 | 2014-12-05 | 326d? | finish no earlier than 2014-12-09 | C1 | 2624h | 2624h | PCSCF_RES | PCG-33 | 24.229 | Huawei | susan.shishufeng@huawei.com | Rel-12 | CP-64 | Kimmo |  | CP-140605 |

Notes:
- 1871: CP#62 completed. Linked to Rel-9 MBMS support in EPS (MBMS_EPS). Rel-10 CT Features EPC Node Restoration with/out Idle mode Signalling Reduction (ISR) activated (EPC_NR/EPC_NR_ISR)
- 1872: CP#62 completed
- 1873: CP#65 completed
- 1874: CP#62 completed. Stage 2 in Rel-12 TEI12 TS 23.237 CR#0431, CR#0440, CR#0441, CR#0453 (pre-alerting). Stage 3 linked to Rel-8 Feature IMS Service Continuity (IMS-Cont) UID_390056 (Stage 2 in TS 23.237). 2/4/15: acronym changed to eDRVCC
- 1875: Stage 2 in Rel-12 TEI12 TS 23.237 CR#0431, CR#0440, CR#0441, CR#0453 (pre-alerting). 2/4/15: acronym changed to eDRVCC
- 1876: CP#62 completed
- 1877: CP#62 completed. 2/4/15: acronym changed to eDRVCC
- 1878: CP#61 completed. 2/4/15: acronym changed to eDRVCC
- 1879: CP#62 completed. SA4 Rel-8 MTSI Video: Dynamic Rate Adaptation/Signalling of Image Size UID_34041 has included service aspects to support image attribute (a=imageattr) in TS 26.114 as in RFC 6236. But associated CN aspects were not included
- 1880: CP#62 completed
- 1881: CP#62 completed
- 1882: CP#62 completed
- 1883: CP#62 completed. Stage 3 enhancement interworking between IMS and MSC-S for IMS Centralized Services (ICS)
- 1884: CP#65 completed. Updated WID CP-130433=>CP-140488
- 1885: CP#65 updated WID CP-140443=>CP-140490. Based TR 29.806, solutions B and D are selected for standardization. Dec.14: 95->100
- 1886: CP#65 completed. TR 29.806v200 for Approval
- 1887: -
- 1888: CP#65 completion 09/14=>12/14. Exception in CP-140481. Dec.14: 90->100
- 1889: CP#65 completed
- 1890: CP#65 updated WID CP-140443=>CP-140490 (added CT3 part). Exception in CP-140687
- 1891: -
- 1892: CP#65 completion 09/14=>12/14. Exception in CP-140481. Dec.14: 90->100
- 1893: CP#65 completion 09/14=>12/14. Exception in CP-140605. Dec.14: 65->100%
- 1894: -
- 1895: CP#65 updated WID CP-140443=>CP-140490 (added CT3 part). Exception in CP-140687
- 1896: CP#65 completion 09/14=>12/14. Exception in CP-140605. Dec.14: 65->100

| ID | WBS | Task | Duration | Start | Finish | Complete | Baseline start | Baseline finish | Baseline duration | Constraint | Resources | Work | Actual work | Acronym | PCG approved | WI rapporteur name | WI rapporteur e-mail | Release | TSG approved | MCC resp | Acronym_3GU_Export | Status Report |
| --- | --- | --- | --- | --- | --- | --- | --- | --- | --- | --- | --- | --- | --- | --- | --- | --- | --- | --- | --- | --- | --- | --- |
| 1897 | 497 | **Updating IMS to conform to RFC 6665 (Stage 3)** | 400d? | 2013-09-09 A | 2015-03-13 A | 100% | 2013-09-09 | 2014-09-12 | 267d? |  | C1; C3 | 9576h | 9576h | UP6665 | PCG-31 | BlackBerry | Andrew Allen (aallen@blackberry.com) | Rel-12 | CP-61 | Frederic | UP6665 |  |
| 1898 | 497.1 | CT1 part of Updating IMS to conform to RFC 6665 | 329d? | 2013-09-09 A | 2014-12-09 A | 100% | 2013-09-09 | 2014-09-12 | 267d? | finish no earlier than 2014-12-09 | C1 | 2624h | 2624h | UP6665 | PCG-31 | BlackBerry | Andrew Allen (aallen@blackberry.com) | Rel-12 | CP-61 | Frederic |  | CP-140620 |
| 1899 | 497.2 | CT3 part of Updating IMS to conform to RFC 6665 | 66d? | 2013-09-09 A | 2013-12-06 A | 100% | 2013-09-09 | 2013-12-06 | 66d? | finish no earlier than 2013-12-06 | C3 | 528h | 528h | UP6665 | PCG-31 | BlackBerry | Andrew Allen (aallen@blackberry.com) | Rel-12 | CP-61 | Maurice |  |  |
| 1900 | 497.3 | (IETF) CT1 part of Updating IMS to conform to RFC 6665 (draft-ietf-sipcore-refer-clarifications) | 1d? | 2015-03-13 A | 2015-03-13 A | 100% |  |  |  |  | C1-IETF | 8h | 8h | UP6665 | PCG-34 | BlackBerry | Andrew Allen (aallen@blackberry.com) | Rel-12 | CT-67 |  |  |  |
| 1901 | 497.4 | (IETF) CT1 part of Updating IMS to conform to RFC 6665 (draft-ietf-sipcore-refer-explicit-subscription) | 1d? | 2015-03-13 A | 2015-03-13 A | 100% |  |  |  |  | C1-IETF | 8h | 8h | UP6665 | PCG-34 | BlackBerry | Andrew Allen (aallen@blackberry.com) | Rel-12 | CT-67 |  |  |  |
| 1902 | 497.5 | (IETF) CT1 part of Updating IMS to conform to RFC 6665 (draft-roach-sipcore-6665-clarifications) | 1d? | 2015-03-13 A | 2015-03-13 A | 100% |  |  |  |  | C1-IETF | 8h | 8h | UP6665 | PCG-34 | BlackBerry | Andrew Allen (aallen@blackberry.com) | Rel-12 | CT-67 |  |  |  |
| 1903 | 498 | **IMS Operator Determined Call Barring enhancements (Stage 3)** | 202d? | 2013-12-06 A | 2014-09-11 A | 100% | 2013-12-06 | 2014-06-13 | 137d? |  | C1; C3 | 5928h | 5928h | eIODB | PCG-32 | Ericsson | Jorgen.Axell@ericsson.com | Rel-12 | CP-62 | Frederic | eIODB |  |
| 1904 | 498.1 | CT1 part of IMS Operator Determined Call Barring enhancements | 136d? | 2013-12-06 A | 2014-06-13 A | 100% | 2013-12-06 | 2014-06-13 | 136d? | finish no earlier than 2014-06-13 | C1 | 1088h | 1088h | eIODB | PCG-32 | Ericsson | Jorgen.Axell@ericsson.com | Rel-12 | CP-62 | Frederic |  |  |
| 1905 | 498.2 | CT3 part of IMS Operator Determined Call Barring enhancements | 201d? | 2013-12-09 A | 2014-09-11 A | 100% | 2013-12-09 | 2014-06-13 | 136d? | finish no earlier than 2014-09-12 | C3 | 1608h | 1608h | eIODB | PCG-32 | Ericsson | Jorgen.Axell@ericsson.com | Rel-12 | CP-62 | Adrian |  |  |
| 1906 | 499 | Signalling Improvements for Network Efficiency (Stage 3) | 264d? | 2013-12-06 A | 2014-12-09 A | 100% | 2013-12-06 | 2014-09-12 | 202d? | finish no earlier than 2014-12-09 | C1 | 2112h | 2112h | SINE | PCG-32 | Huawei | Lin Shu (shulin@huawei.com) | Rel-12 | CP-62 | Frederic | SINE | CP-140617 |
| 1907 | 500 | **Interactive Connectivity Establishment (ICE, IETF RFC 5245) impacts on IMS H.248 profiles** | 138d? | 2014-03-05 A | 2014-09-11 A | 100% | 2014-03-05 | 2014-09-12 | 138d? |  | C4; C3 | 3896h | 3896h | ICEH248 | PCG-32 | NSN | Jan.Kall@nsn.com | Rel-12 | CP-63 | Kimmo | ICEH248 |  |
| 1908 | 500.1 | CT4 part of ICE impacts on IMS H.248 profiles (Stage 2/3) | 138d? | 2014-03-05 A | 2014-09-11 A | 100% | 2014-03-05 | 2014-09-12 | 138d? | finish no earlier than 2014-09-12 | C4 | 1104h | 1104h | ICEH248 | PCG-32 | NSN | Jan.Kall@nsn.com | Rel-12 | CP-63 | Kimmo |  |  |
| 1909 | 500.2 | CT3 part of ICE impacts on IMS H.248 profiles (Stage 2) | 73d? | 2014-03-05 A | 2014-06-13 A | 100% | 2014-03-05 | 2014-06-13 | 73d? | finish no earlier than 2014-06-13 | C3 | 584h | 584h | ICEH248 | PCG-32 | NSN | Jan.Kall@nsn.com | Rel-12 | CP-63 | Adrian |  |  |
| 1910 | 501 | **Transfer of ETSI business trunking specifications** | 203d? | 2014-03-05 A | 2014-12-09 A | 100% | 2014-03-05 | 2014-09-17 | 141d? |  | C1; S1 | 5976h | 5976h | IMS_Corp2 | PCG-32 | Alcatel-Lucent | keith.drage@alcatel-lucent.com, Youssef Chadli | Rel-12 | CP-63 | Frederic | IMS_Corp2 |  |
| 1911 | 501.1 | SA1 part of Transfer of ETSI business trunking specifications | 141d? | 2014-03-05 A | 2014-09-17 A | 100% | 2014-03-05 | 2014-09-17 | 141d? | finish no earlier than 2014-09-17 | S1 | 1128h | 1128h | IMS_Corp2 | PCG-32 | Alcatel-Lucent | betsy.covell@alcatel-lucent.com | Rel-12 | SP-63 | Alain |  | S1-143300 |
| 1912 | 501.2 | CT1 part of Transfer of ETSI business trunking specifications | 200d? | 2014-03-05 A | 2014-12-09 A | 100% | 2014-03-05 | 2014-09-12 | 138d? | finish no earlier than 2014-12-09 | C1 | 1600h | 1600h | IMS_Corp2 | PCG-32 | Alcatel-Lucent | keith.drage@alcatel-lucent.com, Youssef Chadli | Rel-12 | CP-63 | Frederic |  | CP-140619 |
| 1913 | 502 | **Support of ALT-C attribute** | 200d? | 2014-03-10 A | 2014-12-09 A | 100% | 2014-03-05 | 2014-09-12 | 138d? |  | C4; C1; C3 | 9600h | 9600h | ALTC | PCG-32 | Orange | lionel.morand@orange.com | Rel-12 | CP-63 | Kimmo | ALTC |  |
| 1914 | 502.1 | CT4 part of Support of ALT-C attribute | 200d? | 2014-03-10 A | 2014-12-09 A | 100% | 2014-03-05 | 2014-09-12 | 138d? | finish no earlier than 2014-12-09 | C4 | 1600h | 1600h | ALTC | PCG-32 | Orange | lionel.morand@orange.com | Rel-12 | CP-63 | Kimmo |  | CP-140485 |
| 1915 | 502.2 | CT1 part of Support of ALT-C attribute | 200d? | 2014-03-10 A | 2014-12-09 A | 100% | 2014-03-05 | 2014-09-12 | 138d? | finish no earlier than 2014-12-09 | C1 | 1600h | 1600h | ALTC | PCG-32 | Orange | lionel.morand@orange.com | Rel-12 | CP-63 | Frederic |  | CP-140611 |
| 1916 | 502.3 | CT3 part of Support of ALT-C attribute | 200d? | 2014-03-10 A | 2014-12-09 A | 100% | 2014-03-05 | 2014-06-13 | 73d? | finish no earlier than 2014-12-09 | C3 | 1600h | 1600h | ALTC | PCG-32 | Orange | lionel.morand@orange.com | Rel-12 | CP-63 | Adrian |  | CP-140563 |
| 1917 | 503 | **Diameter Overload Control Mechanisms** | 131d? | 2014-06-13 A | 2014-12-09 A | 100% | 2014-06-13 | 2014-12-05 | 126d? |  | C4; IETF | 4144h | 4144h | DOCME | PCG-33 | Orange | lionel.morand@orange.com | Rel-12 | CP-64 |  | DOCME |  |
| 1918 | 503.1 | CT4 part of Diameter Overload Control Mechanisms | 128d? | 2014-06-13 A | 2014-12-09 A | 100% | 2014-06-13 | 2014-09-12 | 66d? | finish no earlier than 2014-12-09 | C4 | 1024h | 1024h | DOCME | PCG-33 | Orange | lionel.morand@orange.com | Rel-12 | CP-64 |  |  | CP-140486 |
| 1919 | 503.2 | (IETF) Diameter Overload Control Mechanisms | 128d? | 2014-06-13 A | 2014-12-09 A | 100% | 2014-06-13 | 2014-12-05 | 126d? | finish no earlier than 2014-12-09 | C4-IETF | 1024h | 1024h | DOCME | PCG-33 | christer.holmberg@ericsson.com | christer.holmberg@ericsson.com | Rel-12 | CP-64 |  |  |  |
| 1920 | 504 | **Impacts of RFC7044 for introduction of the new History-Info header field** | 131d? | 2014-06-13 A | 2014-12-09 A | 100% | 2014-06-13 | 2014-09-12 | 66d? |  | C1; C3 | 3648h | 3648h | HISTORY_CT | PCG-33 | Deutsche Telekom | Roland Jesske (r.jesske@telekom.de) | Rel-12 | CP-64 |  | HISTORY_CT |  |
| 1921 | 504.1 | CT1 part of Impacts of RFC7044 for introduction of the new History-Info header field | 128d? | 2014-06-13 A | 2014-12-09 A | 100% | 2014-06-13 | 2014-09-12 | 66d? | finish no earlier than 2014-12-09 | C1 | 1024h | 1024h | HISTORY_CT | PCG-33 | Deutsche Telekom | Roland Jesske (r.jesske@telekom.de) | Rel-12 | CP-64 |  |  | CP-140609 |
| 1922 | 504.2 | CT3 part of Impacts of RFC7044 for introduction of the new History-Info header field | 66d? | 2014-06-13 A | 2014-09-11 A | 100% | 2014-06-13 | 2014-09-12 | 66d? | finish no earlier than 2014-09-12 | C3 | 528h | 528h | HISTORY_CT | PCG-33 | Deutsche Telekom | Roland Jesske (r.jesske@telekom.de) | Rel-12 | CP-64 |  |  |  |

Notes:
- 1897: Stage 3. Review the references related to RFC 3265 in the 3GPP IMS specifications and determine the impact of the RFC 6665 changes / Impacted TSs and TRs: Stage 3
- 1898: CP#65 completion 09/14=>12/14. Exception in CP-140620. 3/3/15: 100% cpltd. / Impacted TSs and TRs: 23.218, 24.141, 24.147, 24.229, 24.237, 24.292, 24.337, 24.341, 24.604, 24.606, 24.623, 24.628, 24.629, 24.642
- 1899: CP#62 completed / Impacted TSs and TRs: 29.163, 29.165
- 1900: Added as per CT chair indications on 12th March 2015, no WID, no end date / Impacted TSs and TRs: draft-ietf-sipcore-refer-clarification
- 1901: Added as per CT chair indications on 12th March 2015, no WID, no end date; 14/09/15: 50%->100 / Impacted TSs and TRs: draft-ietf-sipcore-refer-explicit-subscription
- 1902: Added as per CT chair indications on 12th March 2015, no WID, no end date; 14/09/15: 50%->100 / Impacted TSs and TRs: draft-roach-sipcore-6665-clarification
- 1903: Handling of premium rate numbers remained OPEN in Rel-11 (shifted to Rel-12). CP-130384 LS_out sent to SA1 / GSMA informing this TSG CP#60 decision / Impacted TSs and TRs: Stage 3
- 1904: CP#64 completed / Impacted TSs and TRs: 24.229, 24.315
- 1905: CP#65 completed / Impacted TSs and TRs: 29.165
- 1906: CP#65 completion 09/14=>12/14. Exception in CP-140617.Dec.14: 80->85%. 3/3/15: 100% cpltd. / Impacted TSs and TRs: 24.008, 24.301
- 1907: Add optional ICE support as defined in Rel-8 TS (23.228, 24.229) to Iq, Ix, Mn, Mp, Mc interfaces. SA2 Rel-12 TS 23.228 requires support for ICE in eP-CSCF, eIMS-AGW for WebRTC / Impacted TSs and TRs: Stage 2/3
- 1908: CP#65 completed / Impacted TSs and TRs: 23.333, 23.334, 29.232, 29.238, 29.332, 29.333, 29.334
- 1909: CP#64 completed / Impacted TSs and TRs: 29.162, 29.163, 29.292
- 1910: Rel-12 enhancements to business trunking (BusTI). ETSI E2NA(14)000019 asked 3GPP to take responsibility of business communications over IMS: TS 181 019, TS 182 023, TS 182 024, TS 182 025, TR 183 060
- 1911: SP#65 completed. TS 22.519v200 for Approval / Impacted TSs and TRs: New TS 22.519 (ETSI TS 181 019)
- 1912: CP#65 TS 24.525v200 for Approval. TR 24.969v100 for Information. Completion 09/14=>12/14. Exception in CP-140619. Dec.14: 90->100 / Impacted TSs and TRs: New TSs [24.523 (TS 182 023), 24.524 (TS 182 024), 24.525 (TS 182 025)], New TR 24.969 (TR 183 069)
- 1913: SA2 TS 23.228 requires UEs supporting IPv4, IPv6 or both IPv4 and IPv6 IP address formats shall be supported by IMS. Specify procedures to support altc SDP attribute within IMS for terminating communications destined to an enterprise network.
- 1914: CP#65 completion 09/14=>12/14. Exception in CP-140485. Dec.14: 0->100 / Impacted TSs and TRs: 23.334, 29.238, 29.334
- 1915: CP#65 completion 09/14=>12/14. Exception in CP-140611. Dec.14: 0->100 / Impacted TSs and TRs: 24.229
- 1916: CP#65 completion 09/14=>12/14. Exception in CP-140563. Dec.14: 0->100 / Impacted TSs and TRs: 29.162
- 1917: Triggered by TR 29.809 Study on Diameter overload control mechanism (FS_DOCME)
- 1918: CP#65 completion 09/14=>12/14. Exception in CP-140486. Dec.14: 70->100 / Impacted TSs and TRs: 29.228, 29.229, 29.272, 29.273, 29.328, 29.329, 29.336, 29.337, 29.344, 29.345
- 1919: Mar15: In WGLC; 7/3/16: 50%->100 / Impacted TSs and TRs: draft-ietf-dime-ovli
- 1920: IETF updated RFC4244 for History-Info header field to RFC7044. IETF introduced new features which could be useful for 3GPP use cases.
- 1921: CP#65 completion 09/14=>12/14. Exception in CP-140609. Dec.14: 85->100 / Impacted TSs and TRs: 24.229, 24.259, 24.604
- 1922: CP#65 completed / Impacted TSs and TRs: 29.163, 29.165, 29.292

| ID | WBS | Task | Duration | Start | Finish | Complete | Remaining | Baseline start | Baseline finish | Baseline duration | Total slack | Constraint | Resources | Work | Actual work | Acronym | PCG approved | WI rapporteur name | Release | TSG approved | Acronym_3GU_Export | Status Report | MCC resp |
| --- | --- | --- | --- | --- | --- | --- | --- | --- | --- | --- | --- | --- | --- | --- | --- | --- | --- | --- | --- | --- | --- | --- | --- |
| 1923 | 505 | **Indication of NNI Routeing scenarios in SIP requests** | 131d? | 2014-06-13 A | 2014-12-09 A | 100% |  | 2014-06-13 | 2014-12-05 | 126d? |  |  | C1; C3; IETF | 5456h | 4408h | NNI_RS | PCG-33 | Ericsson | Rel-12 | CP-64 | NNI_RS |  |  |
| 1924 | 505.1 | CT1 part of Indication of NNI Routeing scenarios in SIP requests | 128d? | 2014-06-13 A | 2014-12-09 A | 100% |  | 2014-06-13 | 2014-09-12 | 66d? |  | finish no earlier than 2014-12-09 | C1 | 1024h | 1024h | NNI_RS | PCG-33 | Ericsson | Rel-12 | CP-64 |  | CP-140613 |  |
| 1925 | 505.2 | (IETF) CT1 part of Indication of NNI Routeing scenarios in SIP requests (holmberg-dispatch-iotl) | 95d? | 2014-06-13 A | 2014-12-09 A | 100% |  | 2014-06-13 | 2014-12-05 | 93d? |  | finish no earlier than 2014-12-09 | C1-IETF | 760h | 760h | NNI_RS | PCG-33 | christer.holmberg@ericsson.com | Rel-12 | CP-64 |  |  |  |
| 1926 | 505.3 | CT3 part of Indication of NNI Routeing scenarios in SIP requests | 66d? | 2014-06-13 A | 2014-09-11 A | 100% |  | 2014-06-13 | 2014-09-12 | 66d? |  | finish no earlier than 2014-09-12 | C3 | 528h | 528h | NNI_RS | PCG-33 | Ericsson | Rel-12 | CP-64 |  |  |  |
| 1927 | 506 | Unstructured Supplementary Service Data (USSD) method selection (Stage 3) | 3d? | 2014-06-11 A | 2014-06-13 A | 100% |  | 2014-06-11 | 2014-06-13 | 3d? |  | finish no earlier than 2014-06-13 | C1 | 24h | 24h | USSD_MS | PCG-33 | Ericsson | Rel-12 | CP-64 | USSD_MS |  |  |
| 1928 | 507 | Representational State Transfer (REST) reference point between Application Function (AF) and Protocol Converter (PC) | 128d? | 2014-06-13 A | 2014-12-09 A | 100% |  | 2014-06-13 | 2014-09-12 | 66d? |  | finish no earlier than 2014-12-09 | C3 | 1024h | 1024h | REST_AF_PC | PCG-33 | Alcatel-Lucent | Rel-12 | CP-64 | REST_AF_PC | CP-140561 |  |
| 1929 | 508 | **Overload Control for PCC based Diameter applications** | 131d? | 2014-06-13 A | 2014-12-09 A | 100% |  | 2014-06-13 | 2014-12-05 | 126d? |  |  | C3; IETF | 3648h | 3648h | DOCME-PCC | PCG-33 | Huawei | Rel-12 | CP-64 | DOCME-PCC |  |  |
| 1930 | 508.1 | CT3 part of Overload Control for PCC based Diameter applications | 66d? | 2014-06-13 A | 2014-09-11 A | 100% |  | 2014-06-13 | 2014-09-12 | 66d? |  | finish no earlier than 2014-09-12 | C3 | 528h | 528h | DOCME-PCC | PCG-33 | Huawei | Rel-12 | CP-64 |  |  |  |
| 1931 | 508.2 | (IETF) Overload Control for PCC based Diameter applications | 128d? | 2014-06-13 A | 2014-12-09 A | 100% |  | 2014-06-13 | 2014-12-05 | 126d? |  | finish no earlier than 2014-12-09 | C3-IETF | 1024h | 1024h | DOCME-PCC | PCG-33 | christer.holmberg@ericsson.com | Rel-12 | CP-64 |  |  |  |
| 1932 | 509 | Network Initiated USSD Simulation Services in IMS | 63d? | 2014-09-12 A | 2014-12-09 A | 100% |  |  |  |  |  | finish no earlier than 2014-12-09 | C1 | 504h | 504h | USSI-NET | PCG-33 | AT&T | Rel-12 | CP-65 | USSI-NET | CP-140610 |  |
| 1933 | 510 | **Introduction of ER-GSM band for GSM-R** | 651d? | 2011-09-16 A | 2014-02-28 A | 100% |  | 2011-09-16 | 2014-02-28 | 651d? |  |  | G1; C1; G3new | 26496h | 26496h | RT_ERGSM | PCG-27 | Kapsch Carriercom, Sierra Wireless | Rel-12 | GP-51 | RT_ERGSM |  | Paolo |
| 1934 | 510.1 | GERAN1 part of Introduction of ER-GSM band for GSM-R | 647d? | 2011-09-16 A | 2014-02-28 A | 100% |  | 2011-09-16 | 2014-02-28 | 647d? |  | finish no earlier than 2014-02-28 | G1 | 5168h | 5168h | RT_ERGSM | PCG-27 | Kapsch Carriercom, Sierra Wireless | Rel-12 | GP-51 |  |  | Paolo |
| 1935 | 510.2 | Test part: Introduction of ER-GSM band for GSM-R | 131d? | 2013-09-02 A | 2014-02-28 A | 100% |  | 2013-09-02 | 2014-02-28 | 131d? |  | finish no earlier than 2014-02-28 | G3new | 1048h | 1048h | RT_ERGSM | PCG-31 | Kapsch Carriercom, Sierra Wireless | Rel-12 | GP-59 |  |  | Ingbert |
| 1936 | 510.3 | CT1 part of Introduction of ER-GSM band for GSM-R | 582d? | 2011-09-28 A | 2013-12-06 A | 100% |  | 2011-09-28 | 2013-12-06 | 582d? |  | finish no earlier than 2013-12-06 | C1 | 4656h | 4656h | RT_ERGSM | PCG-27 | Kapsch Carriercom, Sierra Wireless | Rel-12 | CP-53 |  |  | Frederic |
| 1937 | 511 | **Downlink Multi Carrier GERAN** | 666d? | 2012-09-10 A | 2015-03-13 | 91% | 61.92d? | 2012-09-10 | 2014-09-12 | 533d? | 985d |  | G2; G1; C1; G3new | 34536h | 12164.8h | DMCG | PCG-29 | Ericsson | Rel-12 | GP-55 | DMCG |  | Gert |
| 1938 | 511.1 | Core part: Downlink Multi Carrier GERAN | 229d? | 2013-07-22 A | 2014-05-30 A | 100% |  | 2013-07-22 | 2014-05-30 | 229d? |  | finish no earlier than 2014-05-30 | G2; G1 | 3664h | 3664h | DMCG | PCG-29 | Ericsson | Rel-12 | GP-55 |  |  | Gert |
| 1939 | 511.2 | CT part: Downlink Multi Carrier GERAN | 533d? | 2012-09-10 A | 2014-09-11 A | 100% |  | 2012-09-10 | 2014-09-12 | 533d? |  | finish no earlier than 2014-09-12 | C1 | 4264h | 4264h | DMCG | PCG-29 | Ericsson | Rel-12 | GP-55 |  |  | Frederic |
| 1940 | 511.3 | Test part: Downlink Multi Carrier GERAN | 662d? | 2012-09-10 A | 2015-03-13 | 80% | 132.4d? | 2012-09-10 | 2014-08-29 | 522d? | 985d | finish no earlier than 2015-03-13 | G3new | 5296h | 4236.8h | DMCG-MStest | PCG-29 | ST-Ericsson | Rel-12 | GP-55 | DMCG-MStest |  | Ingbert |
| 1941 | 512 | **Mobile Station Receive Diversity (MSRD) for Voice Services over Adaptive Multi-user channels on One Slot (VAMOS)** | 459d? | 2013-03-01 A | 2014-11-21 A | 100% |  | 2013-03-01 | 2014-08-29 | 396d? |  |  | G1; G2; C1; G3new | 24064h | 24064h | MSRD_VAMOS | PCG-30 | Nokia Networks, Microsoft | Rel-12 | GP-57 | MSRD_VAMOS | GP-140579 | Paolo |
| 1942 | 512.1 | CT1 introduction of MS capability support for MS supporting MSRD for VAMOS | 205d? | 2013-03-01 A | 2013-12-06 A | 100% |  | 2013-03-01 | 2013-12-06 | 205d? |  | finish no earlier than 2013-12-06 | C1 | 1640h | 1640h | MSRD_VAMOS | PCG-30 | Nokia Networks, Microsoft | Rel-12 | GP-57 |  |  | Frederic |
| 1943 | 512.2 | MSRD for VAMOS - Performance Requirements | 257.5d? | 2013-11-28 A | 2014-11-21 A | 100% |  | 2013-11-28 | 2014-08-29 | 197.5d? |  | finish no earlier than 2014-11-21 | G1; G2 | 4120h | 4120h | MSRD_VAMOS-PerfReq | PCG-30 | Nokia Networks, Microsoft | Rel-12 | GP-57 | MSRD_VAMOS-PerfReq | GP-140579 | Paolo |
| 1944 | 512.3 | MSRD for VAMOS - MS Conformance Test | 453d? | 2013-03-06 A | 2014-11-21 A | 100% |  | 2013-03-06 | 2014-08-29 | 393d? |  | finish no earlier than 2014-11-21 | G3new | 3616h | 3616h | MSRD_VAMOS-Test | PCG-30 | Nokia Networks, Microsoft | Rel-12 | GP-57 | MSRD_VAMOS-Test | GP-140579 | Ingbert |
| 1945 | 513 | **New Training Sequence Codes (TSC) for GERAN** | 277d? | 2013-11-22 A | 2014-12-09 | 93% | 18.18d? | 2013-11-22 | 2014-08-29 | 202d? | 1053d |  | G1; G2; C1 | 11184h | 10449.7h | NewToN | PCG-32 | Ericsson | Rel-12 | GP-60 | NewToN | GP-140542 | Paolo |
| 1946 | 513.1 | GERAN1 part of New Training Sequence Codes (TSC) for GERAN | 261d? | 2013-11-22 A | 2014-11-21 A | 100% |  | 2013-11-22 | 2014-08-29 | 201d? |  | finish no earlier than 2014-11-21 | G1 | 2088h | 2088h | NewToN | PCG-32 | Ericsson | Rel-12 | GP-60 |  | GP-140542 | Paolo |
| 1947 | 513.2 | GERAN2 part of New Training Sequence Codes (TSC) for GERAN | 261d? | 2013-11-22 A | 2014-11-21 | 80% | 52.2d? | 2013-11-22 | 2014-08-29 | 201d? | 1065d | finish no earlier than 2014-11-21 | G2 | 2088h | 1670.4h | NewToN | PCG-32 | Ericsson | Rel-12 | GP-60 |  | GP-140542 | Gert |
| 1948 | 513.3 | CT1 part of New Training Sequence Codes (TSC) for GERAN (Stage 3) | 273d? | 2013-11-22 A | 2014-12-09 A | 100% |  | 2013-11-22 | 2014-08-29 | 201d? |  | finish no earlier than 2014-12-09 | C1 | 2184h | 2184h | NewToN | PCG-32 | Ericsson | Rel-12 | GP-60 |  | CP-140604 | Frederic |

Notes:
- 1923: Triggered by TR 24.802 Study on Indication of Network to Network Interface (NNI) Routeing scenarios in SIP requests UID_580025 / WI rapporteur e-mail: Jan.Holm@ericsson.com
- 1924: CP#65 completion 09/14=>12/14. Exception in CP-140613. Dec.14: 95->100 / Impacted TSs and TRs: 24.229 / WI rapporteur e-mail: Jan.Holm@ericsson.com
- 1925: Publication requested; 7/3/16: 50%->100 / Impacted TSs and TRs: draft-holmberg-dispatch-iotl / WI rapporteur e-mail: christer.holmberg@ericsson.com
- 1926: CP#65 completed / Impacted TSs and TRs: 29.079, 29.165 / WI rapporteur e-mail: Jan.Holm@ericsson.com
- 1927: CP#64 approved WID & completed. Related to R11 USSD simulation service in IMS (delivery of UE originating USSD request using IMS, I.e. introduce 2nd method for delivery of UE originating USSD request to network (additional to USSD using CS domain) / Impacted TSs and TRs: 24.173, 24.390, New TS 24.391 / WI rapporteur e-mail: ivo.sedlacek@ericsson.com
- 1928: CP#65 completion 09/14=>12/14. TS 29.201v200 for Approval. Exception in CP-140561. Dec.14: 80->100 / Impacted TSs and TRs: 29.213, 29.214, new TS 29.201 / WI rapporteur e-mail: horst.brinkmann@alcatel-lucent.com
- 1929: Triggered by TR 29.809 Study on Diameter overload control mechanism (FS_DOCME) / WI rapporteur e-mail: Xia Haitao (xiahaitao@huawei.com)
- 1930: CP#65 completed / Impacted TSs and TRs: 29.212, 29.213, 29.214 / WI rapporteur e-mail: Xia Haitao (xiahaitao@huawei.com)
- 1931: work in progress; 7/3/16: 50%->100 / Impacted TSs and TRs: draft-ietf-dime-ovli / WI rapporteur e-mail: christer.holmberg@ericsson.com
- 1932: CP#65 exception in CP-140610. Dec.14: 75->100 / Impacted TSs and TRs: 24.390 / WI rapporteur e-mail: Martin Dolly (md3135@att.com)
- 1933: Use of band 870-876/915-921 MHz for land mobile service on national possibilities/market demand - as per ECC/DEC/(04)06. Introduction of ERGSM band, Performance requirements and Deployment scenarios. / Impacted TSs and TRs: GERAN / WI rapporteur e-mail: thomas.chatelet@kapsch.net, Rémi Lascoux (rlascoux@sierrawireless.com)
- 1934: GP#61 completed. GP#51 approved WID / Impacted TSs and TRs: 45.001, 45.005, 45.008, 45.050 / WI rapporteur e-mail: thomas.chatelet@kapsch.net, Rémi Lascoux (rlascoux@sierrawireless.com)
- 1935: GP#61 completed / Impacted TSs and TRs: 51.010, 51.021 / WI rapporteur e-mail: thomas.chatelet@kapsch.net, Rémi Lascoux (rlascoux@sierrawireless.com)
- 1936: CP#62 completed. Added ERGSM capability indication (24.008 CR#2469R1) / Impacted TSs and TRs: 24.008 / WI rapporteur e-mail: thomas.chatelet@kapsch.net, Rémi Lascoux (rlascoux@sierrawireless.com)
- 1937: Linked to Rel-7 Downlink Dual Carrier UID_50579 (Previous work on multiple carriers on the downlink was limited to two). Ref: TR 45.912 Feasibility study for evolved GERAN, TS 43.064 GPRS Stage 2 / Impacted TSs and TRs: GERAN / WI rapporteur e-mail: paul.schliwa-bertling@ericsson.com
- 1938: GP#62 completed. GP#55 approved WID / Impacted TSs and TRs: 43.064, 44.004, 44.018, 44.060, 45.002, 45.003, 45.005, 45.008, 48.018 / WI rapporteur e-mail: paul.schliwa-bertling@ericsson.com
- 1939: CP#65 completed / Impacted TSs and TRs: 24.008 / WI rapporteur e-mail: paul.schliwa-bertling@ericsson.com
- 1940: GP#63 completion 08/14=>11/14. Dec.14: 35->80%, CD:11/14->03/15 / Impacted TSs and TRs: 51.010-1, 51.010-2 / WI rapporteur e-mail: hakan.e.grunditz@stericsson.com
- 1941: GP#63 completion 08/14=>11/14. Exception in GP-140579. Linked to Rel-7 Mobile Station Receive Diversity (DARP Phase II) UID_50569, Rel-9 Voice Services over Adaptive Multiuser channels on One Slot (VAMOS) UID_420002 / Impacted TSs and TRs: GERAN / WI rapporteur e-mail: Khairul Hasan (Nokia Networks), Markku Tarkiainen (Nokia=>Microsoft)
- 1942: CP#62 completed / Impacted TSs and TRs: 24.008 / WI rapporteur e-mail: Khairul Hasan (Nokia Networks), Markku Tarkiainen (Nokia=>Microsoft)
- 1943: GP#63 completion 08/14=>11/14. Exception in GP-140579. Dec.14: 95->100 / Impacted TSs and TRs: 44.018, 45.001, 45.002, 45.005, 45.008, 45.009 / WI rapporteur e-mail: Khairul Hasan (Nokia Networks), Markku Tarkiainen (Nokia=>Microsoft)
- 1944: GP#63 completion 08/14=>11/14. Exception in GP-140579. Dec.14: 85->100 / Impacted TSs and TRs: 51.010-1, 51.010-2 / WI rapporteur e-mail: Khairul Hasan (Nokia Networks), Markku Tarkiainen (Nokia=>Microsoft)
- 1945: GP#63 completion 08/14=>11/14. Exception in GP-140542. GP#60 approved WID. Triggered by GP-131041, GP#40 GP-081949 (WID VAMOS). Linked to Rel-9 VAMOS (Previous work where new TSCs were defined for GMSK modulation) UID_420002 / Impacted TSs and TRs: GERAN / WI rapporteur e-mail: Mårten Sundberg
- 1946: GP#63 completion 08/14=>11/14. Exception in GP-140542. Dec.14: 80->100% / Impacted TSs and TRs: 45.001, 45.002, 45.008, 45.009, 45.050 / WI rapporteur e-mail: Mårten Sundberg
- 1947: GP#63 completion 08/14=>11/14. Exception in GP-140542. / Impacted TSs and TRs: 44.018, 44.060 / WI rapporteur e-mail: Mårten Sundberg
- 1948: CP#65 completion 09/14=>12/14. CP#65 exception in CP-140604. 3/3/15: 100% cpltd. / Impacted TSs and TRs: 24.008 / WI rapporteur e-mail: Mårten Sundberg

| ID | WBS | Task | Duration | Start | Finish | Complete | Remaining | Baseline start | Baseline finish | Baseline duration | Total slack | Constraint | Resources | Work | Actual work | Acronym | PCG approved | WI rapporteur name | Release | TSG approved | MCC resp | Acronym_3GU_Export | Status Report | Special Focus Doc | PCG stopped | TSG stopped |
| --- | --- | --- | --- | --- | --- | --- | --- | --- | --- | --- | --- | --- | --- | --- | --- | --- | --- | --- | --- | --- | --- | --- | --- | --- | --- | --- |
| 1949 | 514 | **Verification of radiated multi-antenna reception performance of UEs in LTE/UMTS** | 469d? | 2012-03-05 A | 2013-12-06 A | 100% |  | 2012-03-05 | 2013-12-06 | 469d? |  |  | R4 | 7464h | 7464h | HSPA_LTE_measRP_MIMO | PCG-28 | Vodafone | Rel-12 | RP-55 | Issam | HSPA_LTE_measRP_MIMO |  |  |  |  |
| 1950 | 514.1 | Perf. Part: Verification of radiated multi-antenna reception performance of UEs in LTE/UMTS | 464d? | 2012-03-05 A | 2013-12-06 A | 100% |  | 2012-03-05 | 2013-12-06 | 464d? |  | finish no earlier than 2013-12-06 | R4 | 3712h | 3712h | HSPA_LTE_measRP_MIMO-Perf | PCG-28 | Vodafone | Rel-12 | RP-55 | Issam | HSPA_LTE_measRP_MIMO-Perf | RP-131507 |  |  |  |
| 1951 | 515 | **Further enhancements to H(e)NB mobility - Part 3 (Stage 2/3)** | 330d? | 2012-09-12 A | 2013-12-06 A | 100% |  | 2012-09-12 | 2013-12-06 | 330d? |  |  | R3; R2 | 10560h | 10560h | EHNB_enh3 | PCG-29 | Alcatel-Lucent | Rel-12 | RP-57 | Juha | EHNB_enh3 |  | HNB |  |  |
| 1952 | 515.1 | Core part: Further enhancements to H(e)NB mobility - Part 3 | 330d? | 2012-09-12 A | 2013-12-06 A | 100% |  | 2012-09-12 | 2013-12-06 | 330d? |  | finish no earlier than 2013-12-06 | R3; R2 | 5280h | 5280h | EHNB_enh3-Core | PCG-29 | Alcatel-Lucent | Rel-12 | RP-57 | Juha | EHNB_enh3-Core | RP-131508 | HNB |  |  |
| 1953 | 516 | **Support for BeiDou Navigation Satellite System (BDS) for UTRA and LTE** | 604d? | 2013-03-04 A | 2015-06-15 A | 100% |  | 2013-03-04 | 2015-06-12 | 600d? |  |  | R2; R3; R4; R5 | 31680h | 31680h | LCS_BDS | PCG-30 | CATR | Rel-12 | RP-59 | Yong-Jun | LCS_BDS |  |  |  |  |
| 1954 | 516.1 | Core part: Support for BeiDou Navigation Satellite System (BDS) for UTRA | 204d? | 2013-06-02 A | 2014-03-06 A | 100% |  | 2013-06-02 | 2014-03-06 | 204d? |  | finish no earlier than 2014-03-06 | R2; R3 | 3264h | 3264h | LCS_BDS-UTRA-Core | PCG-30 | ZTE | Rel-12 | RP-59 | Yong-Jun | LCS_BDS-UTRA-Core | RP-131500 |  |  |  |
| 1955 | 516.2 | Perf. part: Support for BeiDou Navigation Satellite System (BDS) for UTRA | 336d? | 2013-03-07 A | 2014-06-13 A | 100% |  | 2013-03-07 | 2014-06-13 | 336d? |  | finish no earlier than 2014-06-13 | R4 | 2688h | 2688h | LCS_BDS-UTRA-Perf | PCG-30 | ZTE | Rel-12 | RP-59 | Issam | LCS_BDS-UTRA-Perf | RP-140714 |  |  |  |
| 1956 | 516.3 | Core part: Support for BeiDou Navigation Satellite System (BDS) for LTE | 202d? | 2013-03-04 A | 2013-12-06 A | 100% |  | 2013-03-04 | 2013-12-06 | 202d? |  | finish no earlier than 2013-12-06 | R2 | 1616h | 1616h | LCS_BDS-LTE-Core | PCG-30 | CATR | Rel-12 | RP-59 | Yong-Jun | LCS_BDS-LTE-Core | RP-131525 |  |  |  |
| 1957 | 516.4 | Perf. part: Support for BeiDou Navigation Satellite System (BDS) for LTE | 336d? | 2013-03-07 A | 2014-06-13 A | 100% |  | 2013-03-07 | 2014-06-13 | 336d? |  | finish no earlier than 2014-06-13 | R4 | 2688h | 2688h | LCS_BDS-LTE-Perf | PCG-30 | ZTE | Rel-12 | RP-59 | Issam | LCS_BDS-LTE-Perf | RP-140713 |  |  |  |
| 1958 | 516.5 | Test part: BeiDou Navigation Satellite System (BDS) Positioning Support for LTE and UMTS | 262d? | 2014-06-15 A | 2015-06-15 A | 100% |  | 2014-06-13 | 2015-06-12 | 261d? |  | finish no earlier than 2015-06-15 | R5 | 2096h | 2096h | LCS_BDS-UEConTest | PCG-33 | CATT | Rel-12 | RP-64 |  | LCS_BDS-UEConTest | RP-150656 |  |  |  |
| 1959 | 517 | **Support for BeiDou Navigation Satellite System (BDS) for LCS in GERAN** | 345d? | 2013-11-22 A | 2015-03-13 | 93% | 25.19d? | 2013-11-22 | 2014-11-21 | 262d? | 985d |  | G2; G1; G3new | 14213.2h | 5848.39h | LCS_BDS_GERAN | PCG-32 | ZTE | Rel-12 | GP-60 | Gert | LCS_BDS_GERAN |  |  |  |  |
| 1960 | 517.1 | GERAN2 part of Support for BeiDou Navigation Satellite System (BDS) for LCS in GERAN | 201d? | 2013-11-22 A | 2014-08-29 A | 100% |  | 2013-11-22 | 2014-08-29 | 201d? |  | finish no earlier than 2014-08-29 | G2 | 1608h | 1608h | LCS_BDS_GERAN | PCG-32 | ZTE | Rel-12 | GP-60 | Gert |  |  |  |  |  |
| 1961 | 517.2 | GERAN1 part of Support for BeiDou Navigation Satellite System (BDS) for LCS in GERAN | 201d? | 2013-11-22 A | 2014-08-29 A | 100% |  | 2013-11-22 | 2014-08-29 | 201d? |  | finish no earlier than 2014-08-29 | G1 | 1608h | 1608h | LCS_BDS_GERAN | PCG-32 | ZTE | Rel-12 | GP-60 | Paolo |  |  |  |  |  |
| 1962 | 517.3 | Support for BeiDou Navigation Satellite System (BDS) for LCS in GERAN3new | 272d? | 2014-03-01 A | 2015-03-13 | 80% | 54.4d? | 2014-02-28 | 2014-11-21 | 192d? | 985d | finish no earlier than 2015-03-13 | G3new | 2176h | 1740.8h | LCS_BDS_GERAN-GERAN3new | PCG-32 | CATR | Rel-12 | GP-61 | Ingbert | LCS_BDS_GERAN-GERAN3new |  |  |  |  |
| 1963 | 517.4 | Deleted - Test part: Support for BeiDou Navigation Satellite System (BDS) for LCS in GERAN | 71d? | 2013-11-22 A | 2014-02-28 A | 100% |  | 2013-11-22 | 2014-02-28 | 71d? |  | finish no earlier than 2014-08-29 | G3new | 565.19h | 565.19h | LCS_BDS_GERAN-MStest | PCG-32 | ZTE | Rel-12 | GP-60 | Ingbert | LCS_BDS_GERAN-MStest |  |  | PCG-32 | GP-61 |
| 1964 | 518 | **Deleted - New Base Station specification structure** | 127d? | 2013-06-18 A | 2013-12-06 A | 100% |  | 2013-06-18 | 2013-12-06 | 127d? |  |  | R4 | 3024h | 3024h | BSspec_struc | PCG-31 | Ericsson | Rel-12 | RP-60 | Issam | BSspec_struc |  |  | PCG-32 | RP-62 |
| 1965 | 518.1 | Deleted - Core part: New Base Station specification structure | 126d? | 2013-06-18 A | 2013-12-06 A | 100% |  | 2013-06-18 | 2013-12-06 | 126d? |  | finish no earlier than 2013-12-06 | R4 | 1008h | 1008h | BSspec_struc-Core | PCG-31 | Ericsson | Rel-12 | RP-60 | Issam | BSspec_struc-Core | RP-131513 |  | PCG-32 | RP-62 |
| 1966 | 518.2 | Deleted - Perf. part: New Base Station specification structure | 125d? | 2013-06-20 A | 2013-12-06 A | 100% |  | 2013-06-20 | 2013-12-06 | 125d? |  | finish no earlier than 2013-12-06 | R4 | 1000h | 1000h | BSspec_struc-Perf | PCG-31 | Ericsson | Rel-12 | RP-60 | Issam | BSspec_struc-Perf | RP-131514 |  | PCG-32 | RP-62 |
| 1967 | 519 | **L-band for Supplemental Downlink in E-UTRA and UTRA** | 659d? | 2013-06-17 A | 2015-12-15 A | 100% |  | 2013-06-17 | 2014-06-13 | 264d? |  |  | R4; R2; R3 | 21600h | 21600h | LTE_UTRA_SDL_BandL | PCG-31 | Orange | Rel-12 | RP-60 | Issam | LTE_UTRA_SDL_BandL |  |  |  |  |
| 1968 | 519.1 | Core part: L-band for Supplemental Downlink in E-UTRA and UTRA | 87.33d? | 2014-02-13 A | 2014-06-13 A | 100% |  | 2014-02-13 | 2014-06-13 | 87.33d? |  | finish no earlier than 2014-06-13 | R4; R2; R3 | 2096h | 2096h | LTE_UTRA_SDL_BandL-Core | PCG-31 | Orange | Rel-12 | RP-60 | Issam | LTE_UTRA_SDL_BandL-Core | RP-140633 |  |  |  |
| 1969 | 519.2 | Perf. part: L-band for Supplemental Downlink in E-UTRA and UTRA | 264d? | 2013-06-17 A | 2014-06-13 A | 100% |  | 2013-06-17 | 2014-06-13 | 264d? |  | finish no earlier than 2014-06-13 | R4 | 2112h | 2112h | LTE_UTRA_SDL_BandL-Perf | PCG-31 | Orange | Rel-12 | RP-60 | Issam | LTE_UTRA_SDL_BandL-Perf | RP-140633 |  |  |  |
| 1970 | 519.3 | UE Conformance Test Aspects - L-band for Supplemental Downlink in E-UTRA and UTRA | 197d? | 2015-03-16 A | 2015-12-15 A | 100% |  |  |  |  |  | finish no earlier than 2015-12-15 | R5 | 1576h | 1576h | LTE_UTRA_SDL_BandL-UEConTest | PCG-34 | Ericsson | Rel-12 | RP-67 |  |  | RP-151163 |  |  |  |
| 1971 | 520 | **LTE-HRPD (High Rate Packet Data in 3GPP2) inter-RAT SON** | 263d? | 2013-06-18 A | 2014-06-13 A | 100% |  | 2013-06-18 | 2014-06-13 | 263d? |  |  | R3; S2; C4; G2 | 11096h | 11096h | LTE_HRPD_SON | PCG-31 | China Telecom | Rel-12 | RP-60 | Juha | LTE_HRPD_SON |  | SON |  |  |
| 1972 | 520.1 | Stage 2 for LTE-HRPD (High Rate Packet Data in 3GPP2) inter-RAT SON | 67d? | 2013-09-11 A | 2013-12-11 A | 100% |  | 2013-09-11 | 2013-12-11 | 67d? |  | finish no earlier than 2013-09-11 | S2 | 528h | 528h | LTE_HRPD_SON | PCG-31 | Huawei | Rel-12 | SP-61 | Maurice |  |  |  |  |  |
| 1973 | 520.2 | Core part: LTE-HRPD (High Rate Packet Data in 3GPP2) inter-RAT SON | 263d? | 2013-06-18 A | 2014-06-13 A | 100% |  | 2013-06-18 | 2014-06-13 | 263d? |  | finish no earlier than 2014-06-13 | R3 | 2088h | 2088h | LTE_HRPD_SON-Core | PCG-31 | China Telecom | Rel-12 | RP-60 | Juha | LTE_HRPD_SON-Core | RP-140745 |  |  |  |
| 1974 | 520.3 | CT aspects for LTE-HRPD (High Rate Packet Data in 3GPP2) inter-RAT SON (Stage 3) | 3d? | 2013-09-04 A | 2013-09-06 A | 100% |  | 2013-09-04 | 2013-09-06 | 3d? |  | finish no earlier than 2013-09-06 | C4 | 24h | 24h | LTE_HRPD_SON-CT | PCG-31 | Huawei | Rel-12 | CP-61 | Kimmo | LTE_HRPD_SON-CT |  |  |  |  |
| 1975 | 520.4 | GERAN aspects for LTE-HRPD inter-RAT SON, RAN Information Management (RIM) - Stage 3 | 5d? | 2013-08-26 A | 2013-08-30 A | 100% |  | 2013-08-26 | 2013-08-30 | 5d? |  | finish no earlier than 2013-09-06 | G2 | 40h | 40h | LTE_HRPD_SON-RIM | PCG-31 | Alcatel-Lucent | Rel-12 | GP-59 | Gert | LTE_HRPD_SON-RIM |  |  |  |  |

Notes:
- 1949: RP#59 moved to Rel-12. Triggered by FS_HSPA_LTE_measRP_MIMO_multi-antenna. Core functionality exists since Rel-6 & Rel-7 (MIMO). Adds a very generic test method to test UEs with 2 or more Rx antennas / Impacted TSs and TRs: UTRA, LTE / WI rapporteur e-mail: Luis Anaya
- 1950: RP#62 completed. Rx diversity (defined as Rel-6 HSDPA RAN4 enhanced type 1 req.) & MIMO (defined as Rel-7 HSDPA MIMO for HSPA). Rx diversity & MIMO (defined as part of Rel-8 basic LTE WI) / Impacted TSs and TRs: new TR 37.977 / WI rapporteur e-mail: luis.anaya@vodafone.com
- 1951: Triggered by FS_EHNB_enh (TR 37.803) / Impacted TSs and TRs: UTRA, LTE / WI rapporteur e-mail: Martin.Warner@alcatel-lucent.com
- 1952: RP#62 completed / Impacted TSs and TRs: 25.304, 25.331, 25.367, 25.467, 25.469, 36.300, 36.331 / WI rapporteur e-mail: Martin.Warner@alcatel-lucent.com
- 1953: BeiDou = Chinese Navigation Satellite System. Location Services (LCS) TS 22.071 Stage 1, TS 23.271 Stage 2 / Impacted TSs and TRs: UTRA, LTE / WI rapporteur e-mail: Ying Du (duying1@catr.cn)
- 1954: RP#62 completed / Impacted TSs and TRs: 25.305, 25.306, 25.331, 25.453, 25.413, 25.423, 25.433 / WI rapporteur e-mail: Huang He (huang.he4@zte.com.cn)
- 1955: RP#64 completed. TS 25.173v100 for 1-step Approval / Impacted TSs and TRs: 25.172 (FDD), new TS 25.173 (TDD) / WI rapporteur e-mail: Ling Soonleh (soonleh.ling@zte.com.cn)
- 1956: RP#62 completed / Impacted TSs and TRs: 36.305, 36.355 / WI rapporteur e-mail: Ying Du (duying1@catr.cn)
- 1957: RP#64 completed / Impacted TSs and TRs: 36.171 / WI rapporteur e-mail: Ling Soonleh (soonleh.ling@zte.com.cn)
- 1958: ; Stat Rep: RP-141350->RP-141950 1st Apr 15: Compl:80%->90% 1st Apr 15: Stat Rep: RP-141950->RP-150357 03/07/15: Compl:90%->100% 03/07/15: Stat Rep: RP-150357->RP-150656 / Impacted TSs and TRs: 34.108, 36.508, 37.571-1, 37.571-2, 37.571-3, 37.571-4, 37.571-5 / WI rapporteur e-mail: Chen Xiaiozhong (chenxiaozhong@catt.cn)
- 1959: GP#60 approved WID. Based on the same framework used in Rel-8 Support for Additional Navigation Satellite Systems (ANSS) for LCS UID_38001 / Impacted TSs and TRs: GERAN / WI rapporteur e-mail: Wang Xinhui (wangxinhui@zte.com.cn)
- 1960: GP#63 completed / Impacted TSs and TRs: 44.031, 49.031, 44.071, 48.031 / WI rapporteur e-mail: Wang Xinhui (wangxinhui@zte.com.cn)
- 1961: GP#63 completed / Impacted TSs and TRs: 43.059, 45.005 / WI rapporteur e-mail: Wang Xinhui (wangxinhui@zte.com.cn)
- 1962: Dec.14: 25->80%, CD: 11/14->03/15 / Impacted TSs and TRs: 51010-1, 51.010-2, 51.010-7 / WI rapporteur e-mail: Zhou DaiWei, China Academy of Telecommunication Research, zhoudaiwei@catr.cn
- 1963: GP#61 stopped / Impacted TSs and TRs: 51.010-1 / WI rapporteur e-mail: Wang Xinhui (wangxinhui@zte.com.cn)
- 1964: Triggered by Rel-12 TR 37.810 Study on Base Station specification structure (FS_BSspec_struc) / Impacted TSs and TRs: UTRA, LTE, MSR / WI rapporteur e-mail: johan.skold@ericsson.com
- 1965: RP#62 stopped (at 20% completion) / Impacted TSs and TRs: 25.104, 25.105, 36.104, 37.104, 37.810, New TR 37.811 (New BS specification structure), New TS 37.xya (New RF core specification) / WI rapporteur e-mail: johan.skold@ericsson.com
- 1966: RP#62 stopped (at 0% completion) / Impacted TSs and TRs: 25.113, 25.141, 25.142, 36.113, 36.141, 37.113, 37.141, 37.810, New TS 37.xyz (New RF test specification, New TS 37.xyw (ew EMC specification) / WI rapporteur e-mail: johan.skold@ericsson.com
- 1967: ECC(12)052 CEPT decision to harmonize 1452-1492 MHz (L-band) for mobile communications Supplemental Downlink (SDL) => standardize L-band and corresponding E-UTRA and UTRA requirements for SDL operation in Region 1 / Impacted TSs and TRs: UTRA, LTE / WI rapporteur e-mail: olfa.benhaddada@orange.com
- 1968: RP#64 completed. RP#65 forgotten TR 37.814 v100 for 1-step Approval / Impacted TSs and TRs: 25.101, 25.104, 25.113, 25.133, 25.307, 25.327, 25.461, 25.466, 34.124, 36.101, 36.104, 36.113, 36.124, 36.133, 36.307, 36.331, 37.104, 37.113, new TR 37.814 / WI rapporteur e-mail: olfa.benhaddada@orange.com
- 1969: RP#64 completed / Impacted TSs and TRs: 25.133, 25.141, 25.307, 25.327, 36.133, 36.141, 36.307, 37.141 / WI rapporteur e-mail: olfa.benhaddada@orange.com
- 1970: 03/07/15: Compl:0%->85% 03/07/15: CD:Mon 15/06/15->Tue 15/09/15 03/07/15: WID: RP-150134->RP-150835 03/07/15: Stat Rep: ->RP-150830 29/09/15: Compl:85%->90% 29/09/15: CD:Tue 15/09/15->Tue 15/12/15 29/09/15: Stat Rep: RP-150830->RP-151163; 1/1/16
- 1971: Triggered by Rel-12 TR 37.813 (FS_LTE_HRPD_SON). SA2 should verify the architecture solution in TR 37.813 for inter-RAT load balancing between LTE-HRPD. CT4 should specify the RIM extension to support the feature. / Impacted TSs and TRs: UTRA, LTE / WI rapporteur e-mail: Jinlian_wu@189.cn
- 1972: SP#62 completed / Impacted TSs and TRs: 23.402 / WI rapporteur e-mail: Huan Li (ivy.lihuan@huawei.com)
- 1973: RP#64 completed / Impacted TSs and TRs: 36.300, 36.413 / WI rapporteur e-mail: Jinlian_wu@189.cn
- 1974: CP#61 WID approved & Completed / Impacted TSs and TRs: 29.274, 29.276, 29.280 / WI rapporteur e-mail: Xiaoyan SHI (sean.shixiaoyan@huawei.com
- 1975: GP#59 WID approved & Completed / Impacted TSs and TRs: 48.018 / WI rapporteur e-mail: marguerite.woch@alcatel-lucent.com

| ID | WBS | Task | Duration | Start | Finish | Complete | Remaining | Baseline start | Baseline finish | Baseline duration | Total slack | Constraint | Resources | Work | Actual work | Acronym | PCG approved | Impacted TSs and TRs | WI rapporteur name | WI rapporteur e-mail | Release | TSG approved | MCC resp | Acronym_3GU_Export | Status Report | Special Focus Doc | PCG stopped | TSG stopped |
| --- | --- | --- | --- | --- | --- | --- | --- | --- | --- | --- | --- | --- | --- | --- | --- | --- | --- | --- | --- | --- | --- | --- | --- | --- | --- | --- | --- | --- |
| 1976 | 521 | **Increasing the minimum number of carriers for UE monitoring in UTRA and E-UTRA** | 919d? | 2013-12-15 A | 2017-06-15 | 64% | 329.16d? | 2013-12-09 | 2015-03-13 | 331d? | 395d |  | R4; R2 | 18668.4h | 8479.6h | LTE_UTRA_IncMon | PCG-32 | UTRA, LTE | Ericsson | christopher.callender@ericsson.com | Rel-12 | RP-62 | Issam | LTE_UTRA_IncMon |  |  |  |  |
| 1977 | 521.1 | Core part: Increasing the minimum number of carriers for UE monitoring in UTRA and E-UTRA | 201d? | 2013-12-15 A | 2014-12-15 A | 100% |  | 2014-01-06 | 2014-09-12 | 133d? |  | finish no earlier than 2014-12-15 | R4; R2 | 1844.4h | 1844.4h | LTE_UTRA_IncMon-Core | PCG-32 | 25.133, 25.331, 36.133 | Ericsson | christopher.callender@ericsson.com | Rel-12 | RP-62 | Issam | LTE_UTRA_IncMon-Core | RP-141787 |  |  |  |
| 1978 | 521.2 | Perf. part: Increasing the minimum number of carriers for UE monitoring in UTRA and E-UTRA | 395d? | 2013-12-15 A | 2015-06-15 A | 100% |  | 2013-12-09 | 2015-03-13 | 331d? |  | finish no earlier than 2015-06-15 | R4 | 3160h | 3160h | LTE_UTRA_IncMon-Perf | PCG-32 | 25.133, 36.133 | Ericsson | christopher.callender@ericsson.com | Rel-12 | RP-62 | Issam | LTE_UTRA_IncMon-Perf | RP-150596 |  |  |  |
| 1979 | 521.3 | UE Conformance Test Aspects - Increasing the minimum number of carriers for UE monitoring in UTRA and E-UTRA | 394d? | 2015-12-15 A | 2017-06-15 | 10% | 354.6d? |  |  |  | 395d | finish no earlier than 2017-06-15 | R5 | 3152h | 315.2h | LTE_UTRA_IncMon-UEConTest | PCG-36 |  | Ericsson |  | Rel-12 | RP-70 |  |  |  |  |  |  |
| 1980 | 522 | **WLAN/3GPP Radio Interworking** | 267d? | 2013-12-06 A | 2014-12-09 A | 100% |  | 2013-12-06 | 2014-09-17 | 205d? |  |  | R2; S2; C1; C4 | 11021h | 11021h | UTRA_LTE_WLAN_interw | PCG-32 | UTRA, LTE | Intel | sasha.sirotkin@intel.com | Rel-12 | RP-62 | Yong-Jun | UTRA_LTE_WLAN_interw |  | WLAN |  |  |
| 1981 | 522.1 | Core part: WLAN/3GPP Radio Interworking | 202d? | 2013-12-06 A | 2014-09-12 A | 100% |  | 2013-12-06 | 2014-09-12 | 202d? |  | finish no earlier than 2014-09-12 | R2 | 1616h | 1616h | UTRA_LTE_WLAN_interw-Core | PCG-32 | 25.304, 25.306, 25.331, 36.304, 36.306, 36.331 | Intel | sasha.sirotkin@intel.com | Rel-12 | RP-62 | Yong-Jun | UTRA_LTE_WLAN_interw-Core | RP-141310 | WLAN |  |  |
| 1982 | 522.2 | SA2 aspects of WLAN/3GPP Radio Interworking | 140d? | 2014-03-07 A | 2014-09-17 A | 100% |  | 2014-03-07 | 2014-09-17 | 139d? |  | finish no earlier than 2014-09-17 | S2 | 1120h | 1120h | UTRA_LTE_WLAN_interw-SA2 | PCG-32 | 23.402, 23.401, 23.060, 23.251 | Alcatel-Lucent | nicolas.drevon@alcatel-lucent.com | Rel-12 | SP-63 | Maurice | UTRA_LTE_WLAN_interw-SA2 |  | WLAN |  |  |
| 1983 | 522.3 | **CT aspects of WLAN/3GPP Radio Interworking (Stage 2/3)** | 68d? | 2014-09-09 A | 2014-12-09 A | 100% |  | 2014-06-13 | 2014-09-12 | 66d? |  |  | C1; C4 | 1665.6h | 1665.6h | UTRA_LTE_WLAN_interw-CT | PCG-33 | Stage 2/3 | Alcatel-Lucent | jennifer.liu@alcatel-lucent.com | Rel-12 | CP-64 |  | UTRA_LTE_WLAN_interw-CT |  | WLAN |  |  |
| 1984 | 522.3.1 | CT1 part of CT aspects of WLAN/3GPP Radio Interworking (Stage 3) | 68d? | 2014-09-09 A | 2014-12-09 A | 100% |  | 2014-06-13 | 2014-09-12 | 66d? |  | finish no earlier than 2014-12-09 | C1 | 528h | 528h | UTRA_LTE_WLAN_interw-CT | PCG-33 | 24.008, 24.301, 24.302, 24.312 | Alcatel-Lucent | jennifer.liu@alcatel-lucent.com | Rel-12 | CP-64 |  |  | CP-140720 | WLAN |  |  |
| 1985 | 522.3.2 | CT4 part of CT aspects of WLAN/3GPP Radio Interworking (Stage 2/3) | 63d? | 2014-09-12 A | 2014-12-09 A | 100% |  |  |  |  |  | finish no earlier than 2014-12-09 | C4 | 504h | 504h | UTRA_LTE_WLAN_interw-CT | PCG-33 | 23.008, 29.002, 29.272, 29.274, 29.305 | Alcatel-Lucent | jennifer.liu@alcatel-lucent.com | Rel-12 | CP-65 |  |  | CP-140482 | WLAN |  |  |
| 1986 | 523 | UE Conformance Test Aspects – WLAN/3GPP Radio Interworking | 327d? | 2014-12-15 A | 2016-03-15 A | 100% |  |  |  |  |  | finish no earlier than 2016-03-15 | R5 | 2616h | 2616h | UTRA_LTE_WLAN_interw-UEConTest | PCG-34 |  | Intel | Intel | Rel-12 | RP-66 |  |  | RP-151264 |  |  |  |
| 1987 | 524 | **Rel-12 LTE Carrier Aggregation** | 1384d? | 2011-09-19 A | 2016-12-15 | 99% | 12.14d? | 2011-09-19 | 2014-12-11 | 855d? | 525d |  | R4 | 567982h | 555282h | LTE_CA_Rel-12 | PCG-30 | LTE |  |  | Rel-12 | RP-58 | Issam | LTE_CA_Rel-12 |  | CA |  |  |
| 1988 | 524.1 | **LTE Advanced inter-band Carrier Aggregation of Band 1 and Band 7** | 792d? | 2011-09-19 A | 2014-09-12 A | 100% |  | 2011-09-19 | 2014-09-12 | 791d? |  |  | R4 | 18896h | 18896h | LTE_CA_B1_B7 | PCG-27 | LTE | Ericsson | christian.bergljung@ericsson.com | Rel-12 | RP-53 | Issam | LTE_CA_B1_B7 |  | CA |  |  |
| 1989 | 524.1.1 | Core part: LTE Advanced inter-band Carrier Aggregation of Band 1 and Band 7 | 790d? | 2011-09-19 A | 2014-09-12 A | 100% |  | 2011-09-19 | 2014-09-12 | 790d? |  | finish no earlier than 2014-09-12 | R4 | 6312h | 6312h | LTE_CA_B1_B7-Core | PCG-27 | 36.101, 36.104, new generic TR 36.851 | Ericsson | christian.bergljung@ericsson.com | Rel-12 | RP-53 | Issam | LTE_CA_B1_B7-Core | RP-141084 | CA |  |  |
| 1990 | 524.1.2 | Perf. part: LTE Advanced inter-band Carrier Aggregation of Band 1 and Band 7 | 781d? | 2011-10-03 A | 2014-09-12 A | 100% |  | 2011-09-30 | 2014-09-12 | 781d? |  | finish no earlier than 2014-09-12 | R4 | 6248h | 6248h | LTE_CA_B1_B7-Perf | PCG-27 | 36.141, 36.307 | Ericsson | christian.bergljung@ericsson.com | Rel-12 | RP-53 | Issam | LTE_CA_B1_B7-Perf | RP-141084 | CA |  |  |
| 1991 | 524.2 | **LTE Advanced intra-band non-contiguous Carrier Aggregation in Band 25** | 462d? | 2011-09-19 A | 2013-06-14 A | 100% |  | 2011-09-19 | 2013-06-14 | 462d? |  |  | R4 | 11056h | 11056h | LTE_CA_NC_B25 | PCG-27 | LTE | Sprint | George.Cummings@sprint.com | Rel-12 | RP-53 | Issam | LTE_CA_NC_B25 |  | CA |  |  |
| 1992 | 524.2.1 | Core part: LTE Advanced intra-band non-contiguous Carrier Aggregation in Band 25 | 459d? | 2011-09-19 A | 2013-06-14 A | 100% |  | 2011-09-19 | 2013-06-14 | 459d? |  | finish no earlier than 2013-06-14 | R4 | 3672h | 3672h | LTE_CA_NC_B25-Core | PCG-27 | 36.101, 36.104, 36.133, new TR 36.833-2-25 | Sprint | George.Cummings@sprint.com | Rel-12 | RP-53 | Issam | LTE_CA_NC_B25-Core | RP-130563 | CA |  |  |
| 1993 | 524.2.2 | Perf. part: LTE Advanced intra-band non-contiguous Carrier Aggregation in Band 25 | 461d? | 2011-09-19 A | 2013-06-14 A | 100% |  | 2011-09-19 | 2013-06-14 | 461d? |  | finish no earlier than 2013-06-14 | R4 | 3688h | 3688h | LTE_CA_NC_B25-Perf | PCG-27 | 36.141, 36.307 | Sprint | George.Cummings@sprint.com | Rel-12 | RP-53 | Issam | LTE_CA_NC_B25-Perf | RP-130759 | CA |  |  |
| 1994 | 524.3 | **Deleted - LTE Advanced inter-band Carrier Aggregation of Band 3 and Band 5 with 2UL** | 265d? | 2012-03-05 A | 2013-03-01 A | 100% |  | 2012-03-05 | 2013-03-01 | 265d? |  |  | R4 | 6296h | 6296h | LTE_CA_B3_B5_2UL | PCG-28 | LTE | SK Telecom | Seungpyo Hong | Rel-12 | RP-55 | Issam | LTE_CA_B3_B5_2UL |  | CA | PCG-30 | RP-59 |
| 1995 | 524.3.1 | Deleted - Core part: LTE Advanced inter-band Carrier Aggregation of Band 3 and Band 5 with 2UL | 262d? | 2012-03-05 A | 2013-03-01 A | 100% |  | 2012-03-05 | 2013-03-01 | 262d? |  | finish no earlier than 2013-03-01 | R4 | 2096h | 2096h | LTE_CA_B3_B5_2UL-Core | PCG-28 | 36.101, 36.104, 36.133, 36.307, new generic TR 36.851 | SK Telecom | Seungpyo Hong | Rel-12 | RP-55 | Issam | LTE_CA_B3_B5_2UL-Core | RP-130098 | CA | PCG-30 | RP-59 |
| 1996 | 524.3.2 | Deleted - Perf. part: LTE Advanced inter-band Carrier Aggregation of Band 3 and Band 5 with 2UL | 260d? | 2012-03-12 A | 2013-03-01 A | 100% |  | 2012-03-12 | 2013-03-01 | 260d? |  | finish no earlier than 2013-03-01 | R4 | 2080h | 2080h | LTE_CA_B3_B5_2UL-Perf | PCG-28 | 36.133, 36.141 | SK Telecom | Seungpyo Hong | Rel-12 | RP-55 | Issam | LTE_CA_B3_B5_2UL-Perf | RP-130099 | CA | PCG-30 | RP-59 |
| 1997 | 524.4 | UE Conformance Test Aspects - Further Rel-12 configurations for LTE Advanced Carrier Aggregation with 2UL | 460d? | 2015-03-16 A | 2016-12-15 A | 100% |  |  |  |  |  | finish no earlier than 2016-12-15 | R5 | 3680h | 3680h | LTE_CA_Rel12_2UL-UEConTest | PCG-34 |  | Ericsson | NA | Rel-12 | RP-67 |  |  |  |  |  |  |
| 1998 | 524.5 | **LTE Advanced intra-band non-contiguous Carrier Aggregation in Band 3** | 469d? | 2012-03-05 A | 2013-12-06 A | 100% |  | 2012-03-05 | 2013-12-06 | 469d? |  |  | R4 | 11136h | 11136h | LTE_CA_NC_B3 | PCG-28 | LTE | SK Telecom | haesung.park@sk.com | Rel-12 | RP-55 | Issam | LTE_CA_NC_B3 |  | CA |  |  |
| 1999 | 524.5.1 | Core part: LTE Advanced intra-band non-contiguous Carrier Aggregation in Band 3 | 462d? | 2012-03-05 A | 2013-12-06 A | 100% |  | 2012-03-05 | 2013-12-06 | 462d? |  | finish no earlier than 2013-12-06 | R4 | 3696h | 3696h | LTE_CA_NC_B3-Core | PCG-28 | 36.101, 36.104, 36.133, new TR 36.833-2-03 | SK Telecom | haesung.park@sk.com | Rel-12 | RP-55 | Issam | LTE_CA_NC_B3-Core | RP-131573 | CA |  |  |
| 2000 | 524.5.2 | Perf. part: LTE Advanced intra-band non-contiguous Carrier Aggregation in Band 3 | 461d? | 2012-03-15 A | 2013-12-06 A | 100% |  | 2012-03-15 | 2013-12-06 | 461d? |  | finish no earlier than 2013-12-06 | R4 | 3688h | 3688h | LTE_CA_NC_B3-Perf | PCG-28 | 36.101, 36.104, 36.133, 36.141, 36.307 | SK Telecom | haesung.park@sk.com | Rel-12 | RP-55 | Issam | LTE_CA_NC_B3-Perf | RP-131574 | CA |  |  |

Notes:
- 1976: -
- 1977: ; CD:Thu 18/12/14->Mon 15/12/14; WID: RP-141966->RP-142235; Stat Rep: RP-141600->RP-141787
- 1978: ; CD:Fri 12/06/15->Mon 15/06/15; WID: RP-141966->RP-142235; Stat Rep: RP-141600->RP-141787 1st Apr 15: Compl:5%->40% 1st Apr 15: Stat Rep: RP-141787->RP-150063 03/07/15: Compl:40%->100% 03/07/15: Stat Rep: RP-150063->RP-150596
- 1979: 22/3/16: Compl:0%->4%1/7/16: CD:Thu 15/09/16->Thu 15/12/16; 26/9/16: Com 21/3/17: Compl...
- 1980: Triggered by Rel-12 TR 37.834 Study on WLAN/3GPP Radio Interworking (FS_UTRA_LTE_WLAN_interw)
- 1981: SP#65 completed
- 1982: SP#65 completed
- 1983: CP#65 revised WID CP-140287=>CP-140623 (added CT4 part)
- 1984: CP#65 completion 09/14=>12/14. Exception in CP-140720. 78%->95%. 12/12: 95->78%. 3/3/15: 100% cpltd.
- 1985: CP#65 revised WID CP-140287=>CP-140623 (added CT4 part). Exception in CP-140482. Dec.14: 50->100
- 1986: Rel13->Rel-12; Moved at appropriate place 1st Apr 15: Compl:0%->5% 1st Apr 15: Stat Rep: ->RP-150098 03/07/15: Compl:5%->20% 03/07/15: Stat Rep: RP-150098->RP-150929 29/09/15: Compl:20%->60% 29/09/15: WID: RP-141879->RP-151270 29/09/15: Stat Rep: RP-15
- 1987: LTE_CA_Rel-12
- 1988: Inter-band CA 2DL
- 1989: RP#65 completed. Updated WID RP-132042=>RP-141487
- 1990: RP#65 completed
- 1991: Intra-band NC
- 1992: RP#60 completed. TR 36.841 for 1-step Approval
- 1993: RP#60 completed
- 1994: Inter-band 2UL
- 1995: RP#59 stopped (covered by new WI LTE_CA_2UL-A4)
- 1996: RP#59 stopped (covered by new WI LTE_CA_2UL-A4)
- 1997: 03/07/15: Compl:0%->29% 03/07/15: Stat Rep: ->RP-150834 29/09/15: Compl:29%->55% 29/09/15: Stat Rep: RP-150834->RP-151166 1/1/16: Compl:55%->70% 1/1/16: CD:Tue 15/12/15->Tue 15/03/16 1/1/16: WID: RP-1;
- 1998: Intra-band NC
- 1999: RP#62 completed
- 2000: RP#62 completed

| ID | WBS | Task | Duration | Start | Finish | Complete | Baseline start | Baseline finish | Baseline duration | Constraint | Resources | Work | Actual work | Acronym | PCG approved | Impacted TSs and TRs | WI rapporteur name | WI rapporteur e-mail | Release | TSG approved | MCC resp | PCG stopped | TSG stopped | Special Focus Doc | Acronym_3GU_Export | Status Report |
| --- | --- | --- | --- | --- | --- | --- | --- | --- | --- | --- | --- | --- | --- | --- | --- | --- | --- | --- | --- | --- | --- | --- | --- | --- | --- | --- |
| 2001 | 524.6 | **Deleted - LTE Advanced intra-band contiguous Carrier Aggregation in Band 1** | 265d? | 2012-06-18 A | 2013-06-14 A | 100% | 2012-06-18 | 2013-06-14 | 265d? |  | R4 | 6328h | 6328h | LTE_CA_C_B1 | PCG-29 | LTE | KDDI | Masaaki Obara (ms-obara@kddi.com) | Rel-12 | RP-56 | Issam | PCG-31 | RP-60 | CA | LTE_CA_C_B1 |  |
| 2002 | 524.6.1 | Deleted - Core part: LTE Advanced intra-band contiguous Carrier Aggregation in Band 1 | 265d? | 2012-06-18 A | 2013-06-14 A | 100% | 2012-06-18 | 2013-06-14 | 265d? | finish no earlier than 2013-06-14 | R4 | 2120h | 2120h | LTE_CA_C_B1-Core | PCG-29 | 36.101, 36.104, 36.133, 36.141, 36.307, new TR 36.835 | KDDI | Masaaki Obara (ms-obara@kddi.com) | Rel-12 | RP-56 | Issam | PCG-31 | RP-60 | CA | LTE_CA_C_B1-Core | RP-130549 |
| 2003 | 524.6.2 | Deleted - Perf. part: LTE Advanced intra-band contiguous Carrier Aggregation in Band 1 | 261d? | 2012-06-22 A | 2013-06-14 A | 100% | 2012-06-22 | 2013-06-14 | 261d? | finish no earlier than 2013-06-14 | R4 | 2088h | 2088h | LTE_CA_C_B1-Perf | PCG-29 | 36.101, 36.104, 36.133, 36.141, 36.307 | KDDI | Masaaki Obara (ms-obara@kddi.com) | Rel-12 | RP-56 | Issam | PCG-31 | RP-60 | CA | LTE_CA_C_B1-Perf | RP-130550 |
| 2004 | 524.7 | **LTE Advanced intra-band non-contiguous Carrier Aggregation in Band 4** | 327d? | 2012-06-18 A | 2013-09-06 A | 100% | 2012-06-18 | 2013-09-06 | 327d? |  | R4 | 7752h | 7752h | LTE_CA_NC_B4 | PCG-29 | LTE | T-Mobile USA | nelson.ueng@t-mobile.com | Rel-12 | RP-56 | Issam |  |  | CA | LTE_CA_NC_B4 |  |
| 2005 | 524.7.1 | Core part: LTE Advanced intra-band non-contiguous Carrier Aggregation in Band 4 | 323d? | 2012-06-18 A | 2013-09-06 A | 100% | 2012-06-18 | 2013-09-06 | 323d? | finish no earlier than 2013-09-06 | R4 | 2568h | 2568h | LTE_CA_NC_B4-Core | PCG-29 | 36.101, 36.104, 36.133, new TR 36.833-2-04 | T-Mobile USA | nelson.ueng@t-mobile.com | Rel-12 | RP-56 | Issam |  |  | CA | LTE_CA_NC_B4-Core | RP-131039 |
| 2006 | 524.7.2 | Perf. part: LTE Advanced intra-band non-contiguous Carrier Aggregation in Band 4 | 323d? | 2012-06-22 A | 2013-09-06 A | 100% | 2012-06-22 | 2013-09-06 | 323d? | finish no earlier than 2013-09-06 | R4 | 2568h | 2568h | LTE_CA_NC_B4-Perf | PCG-29 | 36.101, 36.104, 36.133, 36.141, 36.307 | T-Mobile USA | nelson.ueng@t-mobile.com | Rel-12 | RP-56 | Issam |  |  | CA | LTE_CA_NC_B4-Perf | RP-131040 |
| 2007 | 524.8 | **LTE Advanced inter-band Carrier Aggregation of Band 2 and Band 4** | 327d? | 2012-06-18 A | 2013-09-06 A | 100% | 2012-06-18 | 2013-09-06 | 327d? |  | R4 | 7752h | 7752h | LTE_CA_B2_B4 | PCG-29 | LTE | T-Mobile USA | nelson.ueng@t-mobile.com | Rel-12 | RP-56 | Issam |  |  | CA | LTE_CA_B2_B4 |  |
| 2008 | 524.8.1 | Core part: LTE Advanced inter-band Carrier Aggregation of Band 2 and Band 4 | 321d? | 2012-06-18 A | 2013-09-06 A | 100% | 2012-06-18 | 2013-09-06 | 321d? | finish no earlier than 2013-09-06 | R4 | 2568h | 2568h | LTE_CA_B2_B4-Core | PCG-29 | 36.101, 36.104, 36.133, new generic TR 36.851 | T-Mobile USA | nelson.ueng@t-mobile.com | Rel-12 | RP-56 | Issam |  |  | CA | LTE_CA_B2_B4-Core | RP-131007 |
| 2009 | 524.8.2 | Perf. part: LTE Advanced inter-band Carrier Aggregation of Band 2 and Band 4 | 321d? | 2012-06-22 A | 2013-09-06 A | 100% | 2012-06-22 | 2013-09-06 | 321d? | finish no earlier than 2013-09-06 | R4 | 2568h | 2568h | LTE_CA_B2_B4-Perf | PCG-29 | 36.101, 36.104, 36.133, 36.141, 36.307 | T-Mobile USA | nelson.ueng@t-mobile.com | Rel-12 | RP-56 | Issam |  |  | CA | LTE_CA_B2_B4-Perf | RP-131376 |
| 2010 | 524.9 | **LTE Advanced inter-band Carrier Aggregation of Band 23 and Band 29** | 202d? | 2012-09-12 A | 2013-06-14 A | 100% | 2012-09-12 | 2013-06-14 | 202d? |  | R4 | 4832h | 4832h | LTE_CA_B23_B29 | PCG-29 | LTE | DISH Network | mariam.sorond@dish.com, johny.kim@dish.com | Rel-12 | RP-57 | Issam |  |  | CA | LTE_CA_B23_B29 |  |
| 2011 | 524.9.1 | Core part: LTE Advanced inter-band Carrier Aggregation of Band 23 and Band 29 | 201d? | 2012-09-12 A | 2013-06-14 A | 100% | 2012-09-12 | 2013-06-14 | 201d? | finish no earlier than 2013-06-14 | R4 | 1608h | 1608h | LTE_CA_B23_B29-Core | PCG-29 | 36.101, 36.104, 36.133, new generic TR 36.851 | DISH Network | mariam.sorond@dish.com, johny.kim@dish.com | Rel-12 | RP-57 | Issam |  |  | CA | LTE_CA_B23_B29-Core | RP-130535 |
| 2012 | 524.9.2 | Perf. part: LTE Advanced inter-band Carrier Aggregation of Band 23 and Band 29 | 201d? | 2012-09-12 A | 2013-06-14 A | 100% | 2012-09-12 | 2013-06-14 | 201d? | finish no earlier than 2013-06-14 | R4 | 1608h | 1608h | LTE_CA_B23_B29-Perf | PCG-29 | 36.141, 36.307 | DISH Network | mariam.sorond@dish.com, johny.kim@dish.com | Rel-12 | RP-57 | Issam |  |  | CA | LTE_CA_B23_B29-Perf | RP-130536 |
| 2013 | 524.10 | **LTE Advanced inter-band Carrier Aggregation of Band 3 and Band 26** | 203d? | 2012-09-11 A | 2013-06-14 A | 100% | 2012-09-11 | 2013-06-14 | 203d? |  | R4 | 4840h | 4840h | LTE_CA_B3_B26 | PCG-29 | LTE | KT | Chungwoo HWANG (cwhwang@kt.com) | Rel-12 | RP-57 | Issam |  |  | CA | LTE_CA_B3_B26 |  |
| 2014 | 524.10.1 | Core part: LTE Advanced inter-band Carrier Aggregation of Band 3 and Band 26 | 202d? | 2012-09-11 A | 2013-06-14 A | 100% | 2012-09-11 | 2013-06-14 | 202d? | finish no earlier than 2013-06-14 | R4 | 1608h | 1608h | LTE_CA_B3_B26-Core | PCG-29 | 36.101, 36.104, 36.133, 36.307, new generic TR 36.851 | KT | Chungwoo HWANG (cwhwang@kt.com) | Rel-12 | RP-57 | Issam |  |  | CA | LTE_CA_B3_B26-Core | RP-130527 |
| 2015 | 524.10.2 | Perf. part: LTE Advanced inter-band Carrier Aggregation of Band 3 and Band 26 | 202d? | 2012-09-11 A | 2013-06-14 A | 100% | 2012-09-11 | 2013-06-14 | 202d? | finish no earlier than 2013-06-14 | R4 | 1608h | 1608h | LTE_CA_B3_B26-Perf | PCG-29 | 36.101, 36.104, 36.133, 36.141, 36.307 | KT | Chungwoo HWANG (cwhwang@kt.com) | Rel-12 | RP-57 | Issam |  |  | CA | LTE_CA_B3_B26-Perf | RP-130528 |
| 2016 | 524.11 | **LTE Advanced inter-band Carrier Aggregation of Band 3 and Band 19** | 203d? | 2012-09-11 A | 2013-06-14 A | 100% | 2012-09-11 | 2013-06-14 | 203d? |  | R4 | 4840h | 4840h | LTE_CA_B3_B19 | PCG-29 | LTE | NTT DOCOMO | Kei ANDO | Rel-12 | RP-57 | Issam |  |  | CA | LTE_CA_B3_B19 |  |
| 2017 | 524.11.1 | Core part: LTE Advanced inter-band Carrier Aggregation of Band 3 and Band 19 | 201d? | 2012-09-11 A | 2013-06-14 A | 100% | 2012-09-11 | 2013-06-14 | 201d? | finish no earlier than 2013-06-14 | R4 | 1608h | 1608h | LTE_CA_B3_B19-Core | PCG-29 | 36.101, 36.104, 36.133, new generic TR 36.851 | NTT DOCOMO | Kei ANDO | Rel-12 | RP-57 | Issam |  |  | CA | LTE_CA_B3_B19-Core | RP-130525 |
| 2018 | 524.11.2 | Perf. part: LTE Advanced inter-band Carrier Aggregation of Band 3 and Band 19 | 201d? | 2012-09-13 A | 2013-06-14 A | 100% | 2012-09-13 | 2013-06-14 | 201d? | finish no earlier than 2013-06-14 | R4 | 1608h | 1608h | LTE_CA_B3_B19-Perf | PCG-29 | 36.141, 36.307 | NTT DOCOMO | Kei ANDO | Rel-12 | RP-57 | Issam |  |  | CA | LTE_CA_B3_B19-Perf | RP-130526 |
| 2019 | 524.12 | **Deleted - LTE Advanced inter-band Carrier Aggregation of Band 38 and Band 39** | 66d? | 2012-09-11 A | 2012-12-07 A | 100% | 2012-09-11 | 2012-12-07 | 66d? |  | R4 | 1584h | 1584h | LTE_CA_B38_B39 | PCG-29 | LTE | China Mobile | Pan Qun (panqun@chinamobile.com) | Rel-12 | RP-57 | Issam | PCG-30 | RP-58 | CA | LTE_CA_B38_B39 |  |
| 2020 | 524.12.1 | Deleted - Core part: LTE Advanced inter-band Carrier Aggregation of Band 38 and Band 39 | 66d? | 2012-09-11 A | 2012-12-07 A | 100% | 2012-09-11 | 2012-12-07 | 66d? | finish no earlier than 2012-12-07 | R4 | 528h | 528h | LTE_CA_B38_B39-Core | PCG-29 | 36.101, 36.104, 36.307, new generic TR 36.851 | China Mobile | Pan Qun (panqun@chinamobile.com) | Rel-12 | RP-57 | Issam | PCG-30 | RP-58 | CA | LTE_CA_B38_B39-Core | RP-121624 |
| 2021 | 524.12.2 | Deleted - Perf. part: LTE Advanced inter-band Carrier Aggregation of Band 38 and Band 39 | 66d? | 2012-09-11 A | 2012-12-07 A | 100% | 2012-09-11 | 2012-12-07 | 66d? | finish no earlier than 2012-12-07 | R4 | 528h | 528h | LTE_CA_B38_B39-Perf | PCG-29 | 36.133, 36.141 | China Mobile | Pan Qun (panqun@chinamobile.com) | Rel-12 | RP-57 | Issam | PCG-30 | RP-58 | CA | LTE_CA_B38_B39-Perf | RP-121625 |
| 2022 | 524.13 | **LTE Advanced intra-band contiguous Carrier Aggregation in Band 3** | 265d? | 2012-09-11 A | 2013-09-06 A | 100% | 2012-09-11 | 2013-09-06 | 265d? |  | R4 | 6312h | 6312h | LTE_CA_C_B3 | PCG-29 | LTE | China Unicom | Fei CUI (cuifei1@chinaunicom.cn) | Rel-12 | RP-57 | Issam |  |  | CA | LTE_CA_C_B3 |  |
| 2023 | 524.13.1 | Core part: LTE Advanced intra-band contiguous Carrier Aggregation in Band 3 | 263d? | 2012-09-11 A | 2013-09-06 A | 100% | 2012-09-11 | 2013-09-06 | 263d? | finish no earlier than 2013-09-06 | R4 | 2096h | 2096h | LTE_CA_C_B3-Core | PCG-29 | 36.101, 36.104, 36.133, new TR 36.833-1-03 | China Unicom | Fei CUI (cuifei1@chinaunicom.cn) | Rel-12 | RP-57 | Issam |  |  | CA | LTE_CA_C_B3-Core | RP-131029 |
| 2024 | 524.13.2 | Perf. part: LTE Advanced intra-band contiguous Carrier Aggregation in Band 3 | 263d? | 2012-09-11 A | 2013-09-06 A | 100% | 2012-09-11 | 2013-09-06 | 263d? | finish no earlier than 2013-09-06 | R4 | 2096h | 2096h | LTE_CA_C_B3-Perf | PCG-29 | 36.141, 36.307 | China Unicom | Fei CUI (cuifei1@chinaunicom.cn) | Rel-12 | RP-57 | Issam |  |  | CA | LTE_CA_C_B3-Perf | RP-131030 |

Notes:
- 2001: Intra-band C
- 2002: RP#60 stopped at 10% completion (rationale in RP-130670)
- 2003: RP#60 stopped at 0% completion
- 2004: Intra-band NC
- 2005: RP#61 completed. Updated WID RP-130842=>RP-131135
- 2006: RP#61 completed. Updated WID RP-130842=>RP-131135
- 2007: Inter-band 1 UL
- 2008: RP#61 completed
- 2009: RP#61 completed
- 2010: Inter-band 1 UL
- 2011: RP#60 completed
- 2012: RP#60 completed
- 2013: Inter-band 1 UL
- 2014: RP#60 completed. Updated WID RP-130199=>RP-130658
- 2015: RP#60 completed. Updated WID RP-130199=>RP-130658
- 2016: Inter-band 1 UL
- 2017: RP#60 completed
- 2018: RP#60 completed
- 2019: Inter-band 1 UL
- 2020: RP#58 stopped at 10% completion following regulatory decisions (see instead new WI LTE_CA_B39_B41)
- 2021: RP#58 stopped at 0% completion following regulatory decisions (see instead new WI LTE_CA_B39_B41)
- 2022: Intra-band NC
- 2023: RP#61 completed. Updated WID RP-130294=>RP-131184 (impacted specs)
- 2024: RP#61 completed

| ID | WBS | Task | Duration | Start | Finish | Complete | Baseline start | Baseline finish | Baseline duration | Constraint | Resources | Work | Actual work | Acronym | PCG approved | WI rapporteur name | WI rapporteur e-mail | Release | TSG approved | MCC resp | Special Focus Doc | Acronym_3GU_Export | Status Report |
| --- | --- | --- | --- | --- | --- | --- | --- | --- | --- | --- | --- | --- | --- | --- | --- | --- | --- | --- | --- | --- | --- | --- | --- |
| 2025 | 524.14 | **LTE Advanced inter-band Carrier Aggregation of Band 1 and Band 8** | 362.8d? | 2012-02-02 A | 2013-06-14 A | 100% | 2012-02-02 | 2013-06-14 | 362.8d? |  | R4 | 6118.4h | 6118.4h | LTE_CA_B1_B8 | PCG-29 | Softbank Mobile | Kenichi Kihara | Rel-12 | RP-57 | Issam | CA | LTE_CA_B1_B8 |  |
| 2026 | 524.14.1 | Core part: LTE Advanced inter-band Carrier Aggregation of Band 1 and Band 8 | 201d? | 2012-02-02 A | 2013-06-14 A | 100% | 2012-02-02 | 2013-06-14 | 201d? | finish no earlier than 2013-06-14 | R4 | 1608h | 1608h | LTE_CA_B1_B8-Core | PCG-29 | Softbank Mobile | Kenichi Kihara | Rel-12 | RP-57 | Issam | CA | LTE_CA_B1_B8-Core | RP-130515 |
| 2027 | 524.14.2 | Perf. part: LTE Advanced inter-band Carrier Aggregation of Band 1 and Band 8 | 202d? | 2012-09-11 A | 2013-06-14 A | 100% | 2012-09-11 | 2013-06-14 | 202d? | finish no earlier than 2013-06-14 | R4 | 1608h | 1608h | LTE_CA_B1_B8-Perf | PCG-29 | Softbank Mobile | Kenichi Kihara | Rel-12 | RP-57 | Issam | CA | LTE_CA_B1_B8-Perf | RP-130516 |
| 2028 | 524.15 | **LTE Advanced inter-band Carrier Aggregation of Band 3 and Band 28** | 203d? | 2012-09-11 A | 2013-06-14 A | 100% | 2012-09-11 | 2013-06-14 | 203d? |  | R4 | 4840h | 4840h | LTE_CA_B3_B28 | PCG-29 | eAccess | FukumotoShiro@eaccess.net | Rel-12 | RP-57 | Issam | CA | LTE_CA_B3_B28 |  |
| 2029 | 524.15.1 | Core part: LTE Advanced inter-band Carrier Aggregation of Band 3 and Band 28 | 202d? | 2012-09-11 A | 2013-06-14 A | 100% | 2012-09-11 | 2013-06-14 | 202d? | finish no earlier than 2013-06-14 | R4 | 1608h | 1608h | LTE_CA_B3_B28-Core | PCG-29 | eAccess | FukumotoShiro@eaccess.net | Rel-12 | RP-57 | Issam | CA | LTE_CA_B3_B28-Core | RP-130529 |
| 2030 | 524.15.2 | Perf. part: LTE Advanced inter-band Carrier Aggregation of Band 3 and Band 28 | 201d? | 2012-09-12 A | 2013-06-14 A | 100% | 2012-09-12 | 2013-06-14 | 201d? | finish no earlier than 2013-06-14 | R4 | 1608h | 1608h | LTE_CA_B3_B28-Perf | PCG-29 | eAccess | FukumotoShiro@eaccess.net | Rel-12 | RP-57 | Issam | CA | LTE_CA_B3_B28-Perf | RP-130530 |
| 2031 | 524.16 | **LTE Advanced inter-band Carrier Aggregation of Band 1 and Band 26** | 200d? | 2012-12-07 A | 2013-09-06 A | 100% | 2012-12-07 | 2013-09-06 | 200d? |  | R4 | 4768h | 4768h | LTE_CA_B1_B26 | PCG-30 | KDDI | Masaaki Obara (ms-obara@kddi.com) | Rel-12 | RP-58 | Issam | CA | LTE_CA_B1_B26 |  |
| 2032 | 524.16.1 | Core part: LTE Advanced inter-band Carrier Aggregation of Band 1 and Band 26 | 200d? | 2012-12-07 A | 2013-09-06 A | 100% | 2012-12-07 | 2013-09-06 | 200d? | finish no earlier than 2013-09-06 | R4 | 1576h | 1576h | LTE_CA_B1_B26-Core | PCG-30 | KDDI | Masaaki Obara (ms-obara@kddi.com) | Rel-12 | RP-58 | Issam | CA | LTE_CA_B1_B26-Core | RP-131005 |
| 2033 | 524.16.2 | Perf. part: LTE Advanced inter-band Carrier Aggregation of Band 1 and Band 26 | 200d? | 2012-12-07 A | 2013-09-06 A | 100% | 2012-12-07 | 2013-09-06 | 200d? | finish no earlier than 2013-09-06 | R4 | 1600h | 1600h | LTE_CA_B1_B26-Perf | PCG-30 | KDDI | Masaaki Obara (ms-obara@kddi.com) | Rel-12 | RP-58 | Issam | CA | LTE_CA_B1_B26-Perf | RP-131006 |
| 2034 | 524.17 | **LTE Advanced inter-band Carrier Aggregation of Band 39 and Band 41** | 330d? | 2012-12-10 A | 2014-03-06 A | 100% | 2012-12-10 | 2014-03-06 | 330d? |  | R4 | 7848h | 7848h | LTE_CA_B39_B41 | PCG-30 | China Mobile | Pan Qun (panqun@chinamobile.com) | Rel-12 | RP-58 | Issam | CA | LTE_CA_B39_B41 | RP-140428 |
| 2035 | 524.17.1 | Core part: LTE Advanced inter-band Carrier Aggregation of Band 39 and Band 41 | 326d? | 2012-12-10 A | 2014-03-06 A | 100% | 2012-12-10 | 2014-03-06 | 326d? | finish no earlier than 2014-03-06 | R4 | 2608h | 2608h | LTE_CA_B39_B41-Core | PCG-30 | China Mobile | Pan Qun (panqun@chinamobile.com) | Rel-12 | RP-58 | Issam | CA | LTE_CA_B39_B41-Core | RP-140428 |
| 2036 | 524.17.2 | Perf. part: LTE Advanced inter-band Carrier Aggregation of Band 39 and Band 41 | 325d? | 2012-12-14 A | 2014-03-06 A | 100% | 2012-12-14 | 2014-03-06 | 325d? | finish no earlier than 2014-03-06 | R4 | 2600h | 2600h | LTE_CA_B39_B41-Perf | PCG-30 | China Mobile | Pan Qun (panqun@chinamobile.com) | Rel-12 | RP-58 | Issam | CA | LTE_CA_B39_B41-Perf | RP-140428 |
| 2037 | 524.18 | **LTE Advanced inter-band Carrier Aggregation of Band 2 and Band 12** | 467d? | 2012-12-10 A | 2014-09-12 A | 100% | 2012-12-10 | 2014-09-12 | 466d? |  | R4 | 10040h | 10040h | LTE_CA_B2_B12 | PCG-30 | US Cellular | sebastian.thalanany@uscellular.com | Rel-12 | RP-58 | Issam | CA | LTE_CA_B2_B12 |  |
| 2038 | 524.18.1 | Core part: LTE Advanced inter-band Carrier Aggregation of Band 2 and Band 12 | 464d? | 2012-12-10 A | 2014-09-12 A | 100% | 2012-12-10 | 2014-09-12 | 464d? | finish no earlier than 2014-09-12 | R4 | 3704h | 3704h | LTE_CA_B2_B12-Core | PCG-30 | US Cellular | sebastian.thalanany@uscellular.com | Rel-12 | RP-58 | Issam | CA | LTE_CA_B2_B12-Core | RP-141084 |
| 2039 | 524.18.2 | Perf. part: LTE Advanced inter-band Carrier Aggregation of Band 2 and Band 12 | 325d? | 2012-12-14 A | 2014-03-06 A | 100% | 2012-12-14 | 2014-03-06 | 325d? | finish no earlier than 2014-06-13 | R4 | 2600h | 2600h | LTE_CA_B2_B12-Perf | PCG-30 | US Cellular | sebastian.thalanany@uscellular.com | Rel-12 | RP-58 | Issam | CA | LTE_CA_B2_B12-Perf | RP-140428 |
| 2040 | 524.19 | **LTE Advanced intra-band non-contiguous Carrier Aggregation in Band 7** | 265d? | 2012-12-10 A | 2013-12-06 A | 100% | 2012-12-10 | 2013-12-06 | 265d? |  | R4 | 6296h | 6296h | LTE_CA_NC_B7 | PCG-30 | Ericsson | christian.bergljung@ericsson.com | Rel-12 | RP-58 | Issam | CA | LTE_CA_NC_B7 |  |
| 2041 | 524.19.1 | Core part: LTE Advanced intra-band non-contiguous Carrier Aggregation in Band 7 | 261d? | 2012-12-10 A | 2013-12-06 A | 100% | 2012-12-10 | 2013-12-06 | 261d? | finish no earlier than 2013-12-06 | R4 | 2088h | 2088h | LTE_CA_NC_B7-Core | PCG-30 | Ericsson | christian.bergljung@ericsson.com | Rel-12 | RP-58 | Issam | CA | LTE_CA_NC_B7-Core | RP-131575 |
| 2042 | 524.19.2 | Perf. part: LTE Advanced intra-band non-contiguous Carrier Aggregation in Band 7 | 261d? | 2012-12-14 A | 2013-12-06 A | 100% | 2012-12-14 | 2013-12-06 | 261d? | finish no earlier than 2013-12-06 | R4 | 2088h | 2088h | LTE_CA_NC_B7-Perf | PCG-30 | Ericsson | christian.bergljung@ericsson.com | Rel-12 | RP-58 | Issam | CA | LTE_CA_NC_B7-Perf | RP-131576 |
| 2043 | 524.20 | **LTE Advanced intra-band contiguous Carrier Aggregation in Band 27** | 401d? | 2012-12-10 A | 2014-06-13 A | 100% | 2012-12-10 | 2014-06-13 | 401d? |  | R4 | 8472h | 8472h | LTE_CA_C_B27 | PCG-30 | NII Holdings | bill.shvodian@nii.com | Rel-12 | RP-58 | Issam | CA | LTE_CA_C_B27 |  |
| 2044 | 524.20.1 | Core part: LTE Advanced intra-band contiguous Carrier Aggregation in Band 27 | 261d? | 2012-12-10 A | 2013-12-06 A | 100% | 2012-12-10 | 2013-12-06 | 261d? | finish no earlier than 2013-12-06 | R4 | 2088h | 2088h | LTE_CA_C_B27-Core | PCG-30 | NII Holdings | bill.shvodian@nii.com | Rel-12 | RP-58 | Issam | CA | LTE_CA_C_B27-Core | RP-131567 |
| 2045 | 524.20.2 | Perf part: LTE Advanced intra-band contiguous Carrier Aggregation in Band 27 | 397d? | 2012-12-14 A | 2014-06-13 A | 100% | 2012-12-14 | 2014-06-13 | 397d? | finish no earlier than 2014-06-13 | R4 | 3176h | 3176h | LTE_CA_C_B27-Perf | PCG-30 | NII Holdings | bill.shvodian@nii.com | Rel-12 | RP-58 | Issam | CA | LTE_CA_C_B27-Perf | RP-140569 |
| 2046 | 524.21 | **LTE Advanced inter-band Carrier Aggregation of Band 2 and Band 13** | 76d? | 2013-03-04 A | 2013-06-14 A | 100% | 2013-03-04 | 2013-06-14 | 76d? |  | R4 | 1824h | 1824h | LTE_CA_B2_B13 | PCG-30 | Ericsson | christian.bergljung@ericsson.com | Rel-12 | RP-59 | Issam | CA | LTE_CA_B2_B13 |  |
| 2047 | 524.21.1 | Core part: LTE Advanced inter-band Carrier Aggregation of Band 2 and Band 13 | 76d? | 2013-03-04 A | 2013-06-14 A | 100% | 2013-03-04 | 2013-06-14 | 76d? | finish no earlier than 2013-06-14 | R4 | 608h | 608h | LTE_CA_B2_B13-Core | PCG-30 | Ericsson | christian.bergljung@ericsson.com | Rel-12 | RP-59 | Issam | CA | LTE_CA_B2_B13-Core | RP-130523 |
| 2048 | 524.21.2 | Perf. part: LTE Advanced inter-band Carrier Aggregation of Band 2 and Band 13 | 76d? | 2013-03-04 A | 2013-06-14 A | 100% | 2013-03-04 | 2013-06-14 | 76d? | finish no earlier than 2013-06-14 | R4 | 608h | 608h | LTE_CA_B2_B13-Perf | PCG-30 | Ericsson | christian.bergljung@ericsson.com | Rel-12 | RP-59 | Issam | CA | LTE_CA_B2_B13-Perf | RP-130524 |

Notes:
- 2025: Inter-band 1 UL / Impacted TSs and TRs: LTE
- 2026: RP#60 completed / Impacted TSs and TRs: 36.101, 36.104, new generic TR 36.851
- 2027: RP#60 completed / Impacted TSs and TRs: 36.141, 36.307
- 2028: Inter-band 1 UL / Impacted TSs and TRs: LTE
- 2029: RP#60 completed / Impacted TSs and TRs: 36.101, 36.104, new generic TR 36.851
- 2030: RP#60 completed / Impacted TSs and TRs: 36.141, 36.307
- 2031: Inter-band 1UL/2DL / Impacted TSs and TRs: LTE
- 2032: RP#61 completed / Impacted TSs and TRs: 36.101, 36.104, 36.133, new generic TR 36.851
- 2033: RP#61 completed / Impacted TSs and TRs: 36.141, 36.307
- 2034: Inter-band 2DL / Impacted TSs and TRs: LTE
- 2035: RP#63 completed. Replaces the Stopped WI - LTE Advanced inter-band Carrier Aggregation of Band 38 and Band 39 (LTE_CA_B38_B39) UID_570015 / Impacted TSs and TRs: 36.101, 36.104, 36.307, new generic TR 36.851
- 2036: RP#63 completed / Impacted TSs and TRs: 36.133, 36.141
- 2037: Inter-band CA 2DL / Impacted TSs and TRs: LTE
- 2038: RP#65 completed / Impacted TSs and TRs: 36.101, 36.104, 36.133, 36.141, 36.307, new generic TR 36.851
- 2039: RP#63 completed / Impacted TSs and TRs: 36.101, 36.104, 36.133, 36.141, 36.307
- 2040: Intra-band NC / Impacted TSs and TRs: LTE
- 2041: RP#62 completed / Impacted TSs and TRs: 36.101, 36.104, 36.133, new TR 36.833-2-07
- 2042: RP#62 completed / Impacted TSs and TRs: 36.141, 36.307
- 2043: Intra-band contig. CA 2DL/1UL / Impacted TSs and TRs: LTE
- 2044: RP#62 completed / Impacted TSs and TRs: 36.101, 36.104, new TR 36.833-1-27
- 2045: RP#64 completed. TR 36.833-1-27v200 for Approval / Impacted TSs and TRs: 36.101, 36.133, 36.141, 36.307, new TR 36.833-1-27
- 2046: Inter-band 1 UL / Impacted TSs and TRs: LTE
- 2047: RP#60 completed / Impacted TSs and TRs: 36.101, 36.104, 36.133, new generic TR 36.851
- 2048: RP#60 completed / Impacted TSs and TRs: 36.101, 36.104, 36.133, 36.141, 36.307

| ID | WBS | Task | Duration | Start | Finish | Complete | Baseline start | Baseline finish | Baseline duration | Constraint | Resources | Work | Actual work | Acronym | PCG approved | WI rapporteur name | WI rapporteur e-mail | Release | TSG approved | MCC resp | Special Focus Doc | Acronym_3GU_Export | Status Report | PCG stopped | TSG stopped |
| --- | --- | --- | --- | --- | --- | --- | --- | --- | --- | --- | --- | --- | --- | --- | --- | --- | --- | --- | --- | --- | --- | --- | --- | --- | --- |
| 2049 | 524.22 | **LTE Advanced inter-band Carrier Aggregation of Band 19 and Band 21** | 76d? | 2013-03-04 A | 2013-06-14 A | 100% | 2013-03-04 | 2013-06-14 | 76d? |  | R4 | 1824h | 1824h | LTE_CA_B19_B21 | PCG-30 | NTT DOCOMO | Kei ANDO | Rel-12 | RP-59 | Issam | CA | LTE_CA_B19_B21 |  |  |  |
| 2050 | 524.22.1 | Core part: LTE Advanced inter-band Carrier Aggregation of Band 19 and Band 21 | 76d? | 2013-03-04 A | 2013-06-14 A | 100% | 2013-03-04 | 2013-06-14 | 76d? | finish no earlier than 2013-06-14 | R4 | 608h | 608h | LTE_CA_B19_B21-Core | PCG-30 | NTT DOCOMO | Kei ANDO | Rel-12 | RP-59 | Issam | CA | LTE_CA_B19_B21-Core | RP-130533 |  |  |
| 2051 | 524.22.2 | Perf. part: LTE Advanced inter-band Carrier Aggregation of Band 19 and Band 21 | 76d? | 2013-03-04 A | 2013-06-14 A | 100% | 2013-03-04 | 2013-06-14 | 76d? | finish no earlier than 2013-06-14 | R4 | 608h | 608h | LTE_CA_B19_B21-Perf | PCG-30 | NTT DOCOMO | Kei ANDO | Rel-12 | RP-59 | Issam | CA | LTE_CA_B19_B21-Perf | RP-130534 |  |  |
| 2052 | 524.23 | **Deleted - LTE Advanced inter-band Carrier Aggregation of Band 8 and Band 26** | 204d? | 2013-03-04 A | 2013-12-06 A | 100% | 2013-03-04 | 2013-12-06 | 204d? |  | R4 | 4848h | 4848h | LTE_CA_B8_B26 | PCG-30 | KT | Chungwoo HWANG (cwhwang@kt.com) | Rel-12 | RP-59 | Issam | CA | LTE_CA_B8_B26 |  | PCG-32 | RP-62 |
| 2053 | 524.23.1 | Deleted - Core part: LTE Advanced inter-band Carrier Aggregation of Band 8 and Band 26 | 201d? | 2013-03-04 A | 2013-12-06 A | 100% | 2013-03-04 | 2013-12-06 | 201d? | finish no earlier than 2013-12-06 | R4 | 1608h | 1608h | LTE_CA_B8_B26-Core | PCG-30 | KT | Chungwoo HWANG (cwhwang@kt.com) | Rel-12 | RP-59 | Issam | CA | LTE_CA_B8_B26-Core | RP-131549 | PCG-32 | RP-62 |
| 2054 | 524.23.2 | Deleted - Perf. part: LTE Advanced inter-band Carrier Aggregation of Band 8 and Band 26 | 201d? | 2013-03-04 A | 2013-12-06 A | 100% | 2013-03-04 | 2013-12-06 | 201d? | finish no earlier than 2013-12-06 | R4 | 1608h | 1608h | LTE_CA_B8_B26-Perf | PCG-30 | KT | Chungwoo HWANG (cwhwang@kt.com) | Rel-12 | RP-59 | Issam | CA | LTE_CA_B8_B26-Perf | RP-131550 | PCG-32 | RP-62 |
| 2055 | 524.24 | **LTE Advanced dual uplink inter-band Carrier Aggregation Class A1** | 474d? | 2013-03-04 A | 2014-12-15 A | 100% | 2013-03-04 | 2014-09-12 | 405d? |  | R4 | 11272h | 11272h | LTE_CA_2UL-A1 | PCG-30 | Huawei | Liu Ye (leo.liuye@huawei.com) | Rel-12 | RP-59 | Issam | CA | LTE_CA_2UL-A1 |  |  |  |
| 2056 | 524.24.1 | Core part: LTE Advanced dual uplink inter-band Carrier Aggregation Class A1 | 468d? | 2013-03-04 A | 2014-12-15 A | 100% | 2013-03-04 | 2014-09-12 | 402d? | finish no earlier than 2014-12-15 | R4 | 3744h | 3744h | LTE_CA_2UL-A1-Core | PCG-30 | Huawei | Liu Ye (leo.liuye@huawei.com) | Rel-12 | RP-59 | Issam | CA | LTE_CA_2UL-A1-Core | RP-141732 |  |  |
| 2057 | 524.24.2 | Perf. part: LTE Advanced dual uplink inter-band Carrier Aggregation Class A1 | 467d? | 2013-03-13 A | 2014-12-15 A | 100% | 2013-03-08 | 2014-09-12 | 401d? | finish no earlier than 2014-12-15 | R4 | 3736h | 3736h | LTE_CA_2UL-A1-Perf | PCG-30 | Huawei | Liu Ye (leo.liuye@huawei.com) | Rel-12 | RP-59 | Issam | CA | LTE_CA_2UL-A1-Perf | RP-141732 |  |  |
| 2058 | 524.25 | **LTE Advanced dual uplink inter-band Carrier Aggregation Class A2** | 474d? | 2013-03-04 A | 2014-12-15 A | 100% | 2013-03-04 | 2014-09-12 | 405d? |  | R4 | 11272h | 11272h | LTE_CA_2UL-A2 | PCG-30 | Qualcomm | Gene Fong (gfong@qti.qualcomm.com) | Rel-12 | RP-59 | Issam | CA | LTE_CA_2UL-A2 |  |  |  |
| 2059 | 524.25.1 | Core part: LTE Advanced dual uplink inter-band Carrier Aggregation Class A2 | 468d? | 2013-03-04 A | 2014-12-15 A | 100% | 2013-03-04 | 2014-09-12 | 402d? | finish no earlier than 2014-12-15 | R4 | 3744h | 3744h | LTE_CA_2UL-A2-Core | PCG-30 | Qualcomm | Gene Fong (gfong@qti.qualcomm.com) | Rel-12 | RP-59 | Issam | CA | LTE_CA_2UL-A2-Core | RP-141732 |  |  |
| 2060 | 524.25.2 | Perf. part: LTE Advanced dual uplink inter-band Carrier Aggregation Class A2 | 467d? | 2013-03-13 A | 2014-12-15 A | 100% | 2013-03-08 | 2014-09-12 | 401d? | finish no earlier than 2014-12-15 | R4 | 3736h | 3736h | LTE_CA_2UL-A2-Perf | PCG-30 | Qualcomm | Gene Fong (gfong@qti.qualcomm.com) | Rel-12 | RP-59 | Issam | CA | LTE_CA_2UL-A2-Perf | RP-141732 |  |  |
| 2061 | 524.26 | **LTE Advanced dual uplink inter-band Carrier Aggregation Class A3** | 474d? | 2013-03-04 A | 2014-12-15 A | 100% | 2013-03-04 | 2014-09-12 | 405d? |  | R4 | 11264h | 11264h | LTE_CA_2UL-A3 | PCG-30 | Ericsson | christian.bergljung@ericsson.com | Rel-12 | RP-59 | Issam | CA | LTE_CA_2UL-A3 |  |  |  |
| 2062 | 524.26.1 | Core part: LTE Advanced dual uplink inter-band Carrier Aggregation Class A3 | 467d? | 2013-03-04 A | 2014-12-15 A | 100% | 2013-03-04 | 2014-09-12 | 401d? | finish no earlier than 2014-12-15 | R4 | 3736h | 3736h | LTE_CA_2UL-A3-Core | PCG-30 | Ericsson | christian.bergljung@ericsson.com | Rel-12 | RP-59 | Issam | CA | LTE_CA_2UL-A3-Core | RP-141732 |  |  |
| 2063 | 524.26.2 | Perf. part: LTE Advanced dual uplink inter-band Carrier Aggregation Class A3 | 467d? | 2013-03-13 A | 2014-12-15 A | 100% | 2013-03-08 | 2014-09-12 | 401d? | finish no earlier than 2014-12-15 | R4 | 3736h | 3736h | LTE_CA_2UL-A3-Perf | PCG-30 | Ericsson | christian.bergljung@ericsson.com | Rel-12 | RP-59 | Issam | CA | LTE_CA_2UL-A3-Perf | RP-141732 |  |  |
| 2064 | 524.27 | **LTE Advanced dual uplink inter-band Carrier Aggregation Class A4** | 474d? | 2013-03-04 A | 2014-12-15 A | 100% | 2013-03-04 | 2014-09-12 | 405d? |  | R4 | 11272h | 11272h | LTE_CA_2UL-A4 | PCG-30 | Nokia | petri.j.vasenkari@nokia.com | Rel-12 | RP-59 | Issam | CA | LTE_CA_2UL-A4 |  |  |  |
| 2065 | 524.27.1 | Core part: LTE Advanced dual uplink inter-band Carrier Aggregation Class A4 | 468d? | 2013-03-04 A | 2014-12-15 A | 100% | 2013-03-04 | 2014-09-12 | 402d? | finish no earlier than 2014-12-15 | R4 | 3744h | 3744h | LTE_CA_2UL-A4-Core | PCG-30 | Nokia | petri.j.vasenkari@nokia.com | Rel-12 | RP-59 | Issam | CA | LTE_CA_2UL-A4-Core | RP-141732 |  |  |
| 2066 | 524.27.2 | Perf. part: LTE Advanced dual uplink inter-band Carrier Aggregation Class A4 | 467d? | 2013-03-13 A | 2014-12-15 A | 100% | 2013-03-08 | 2014-09-12 | 401d? | finish no earlier than 2014-12-15 | R4 | 3736h | 3736h | LTE_CA_2UL-A4-Perf | PCG-30 | Nokia | petri.j.vasenkari@nokia.com | Rel-12 | RP-59 | Issam | CA | LTE_CA_2UL-A4-Perf | RP-141732 |  |  |
| 2067 | 524.28 | **LTE Advanced dual uplink inter-band Carrier Aggregation Class A5** | 474d? | 2013-03-04 A | 2014-12-15 A | 100% | 2013-03-04 | 2014-09-12 | 405d? |  | R4 | 11264h | 11264h | LTE_CA_2UL-A5 | PCG-30 | NTT DOCOMO | kei.andou.ye@nttdocomo.com | Rel-12 | RP-59 | Issam | CA | LTE_CA_2UL-A5 |  |  |  |
| 2068 | 524.28.1 | Core part: LTE Advanced dual uplink inter-band Carrier Aggregation Class A5 | 467d? | 2013-03-04 A | 2014-12-15 A | 100% | 2013-03-04 | 2014-09-12 | 401d? | finish no earlier than 2014-12-15 | R4 | 3736h | 3736h | LTE_CA_2UL-A5-Core | PCG-30 | NTT DOCOMO | kei.andou.ye@nttdocomo.com | Rel-12 | RP-59 | Issam | CA | LTE_CA_2UL-A5-Core | RP-141732 |  |  |
| 2069 | 524.28.2 | Perf. part: LTE Advanced dual uplink inter-band Carrier Aggregation Class A5 | 467d? | 2013-03-13 A | 2014-12-15 A | 100% | 2013-03-08 | 2014-09-12 | 401d? | finish no earlier than 2014-12-15 | R4 | 3736h | 3736h | LTE_CA_2UL-A5-Perf | PCG-30 | NTT DOCOMO | kei.andou.ye@nttdocomo.com | Rel-12 | RP-59 | Issam | CA | LTE_CA_2UL-A5-Perf | RP-141732 |  |  |
| 2070 | 524.29 | **LTE Advanced intra-band contiguous Carrier Aggregation in Band 39** | 269d? | 2013-03-04 A | 2014-03-06 A | 100% | 2013-03-04 | 2014-03-06 | 269d? |  | R4 | 6400h | 6400h | LTE_CA_C_B39 | PCG-30 | China Mobile | Li Nan (linan@chinamobile.com) | Rel-12 | RP-59 | Issam | CA | LTE_CA_C_B39 |  |  |  |
| 2071 | 524.29.1 | Core part: LTE Advanced intra-band contiguous Carrier Aggregation in Band 39 | 266d? | 2013-03-04 A | 2014-03-06 A | 100% | 2013-03-04 | 2014-03-06 | 266d? | finish no earlier than 2014-03-06 | R4 | 2128h | 2128h | LTE_CA_C_B39-Core | PCG-30 | China Mobile | Li Nan (linan@chinamobile.com) | Rel-12 | RP-59 | Issam | CA | LTE_CA_C_B39-Core | RP-140428 |  |  |
| 2072 | 524.29.2 | Perf. part: LTE Advanced intra-band contiguous Carrier Aggregation in Band 39 | 265d? | 2013-03-07 A | 2014-03-06 A | 100% | 2013-03-07 | 2014-03-06 | 265d? | finish no earlier than 2014-03-06 | R4 | 2120h | 2120h | LTE_CA_C_B39-Perf | PCG-30 | China Mobile | Li Nan (linan@chinamobile.com) | Rel-12 | RP-59 | Issam | CA | LTE_CA_C_B39-Perf | RP-140428 |  |  |

Notes:
- 2049: Inter-band 1 UL / Impacted TSs and TRs: LTE
- 2050: RP#60 completed / Impacted TSs and TRs: 36.101, 36.104, 36.133, new generic TR 36.851
- 2051: RP#60 completed / Impacted TSs and TRs: 36.141, 36.307
- 2052: Inter-band 1 UL / Impacted TSs and TRs: LTE
- 2053: RP#62 stopped (at 20%) / Impacted TSs and TRs: 36.101, 36.104, 36.133, new generic TR 36.851
- 2054: RP#62 stopped (at 20%) / Impacted TSs and TRs: 36.141, 36.307
- 2055: Inter-band CA 2UL / Impacted TSs and TRs: LTE
- 2056: ; WID: RP-142043->RP-141941; Stat Rep: RP-141084->RP-141732 / Impacted TSs and TRs: 36.101, 36.104, New generic TR 36.860
- 2057: ; WID: RP-142043->RP-141941; Stat Rep: RP-141084->RP-141732 / Impacted TSs and TRs: 36.133
- 2058: Inter-band CA 2UL / Impacted TSs and TRs: LTE
- 2059: ; Stat Rep: RP-141084->RP-141732 / Impacted TSs and TRs: 36.101, 36.104, 36.133, New generic TR 36.860
- 2060: ; Stat Rep: RP-141084->RP-141732 / Impacted TSs and TRs: 36.141, 36.307
- 2061: Inter-band CA 2UL / Impacted TSs and TRs: LTE
- 2062: ; Stat Rep: RP-141084->RP-141732 / Impacted TSs and TRs: 36.101, 36.104, 36.133, New generic TR 36.860
- 2063: ; Stat Rep: RP-141084->RP-141732 / Impacted TSs and TRs: 36.141, 36.307
- 2064: Inter-band CA 2UL. RP#65 updated WID RP-140476=>RP-141160. / Impacted TSs and TRs: LTE
- 2065: ; WID: RP-142043->RP-141967; Stat Rep: RP-141084->RP-141732 / Impacted TSs and TRs: 36.101, 36.104, 36.133, New generic TR 36.860
- 2066: ; WID: RP-142043->RP-141967; Stat Rep: RP-141084->RP-141732 / Impacted TSs and TRs: 36.141, 36.307
- 2067: Inter-band CA 2UL. RP#65 updated WID RP-131146=>RP-141195. Changed Rapp Renesas=>Broadcom=>NTT DOCOMO / Impacted TSs and TRs: LTE
- 2068: ; Stat Rep: RP-141084->RP-141732 / Impacted TSs and TRs: 36.101, 36.104, 36.133, New generic TR 36.860
- 2069: ; Stat Rep: RP-141084->RP-141732 / Impacted TSs and TRs: 36.141, 36.307
- 2070: Intra-band C 2DL/2UL / Impacted TSs and TRs: LTE
- 2071: RP#63 completed / Impacted TSs and TRs: 36.101, 36.104, 36.133, New TR 36.833-1-39 [instead of 36.845]
- 2072: RP#63 completed / Impacted TSs and TRs: 36.141, 36.307

| ID | WBS | Task | Duration | Start | Finish | Complete | Baseline start | Baseline finish | Baseline duration | Constraint | Resources | Work | Actual work | Acronym | PCG approved | WI rapporteur name | WI rapporteur e-mail | Release | TSG approved | MCC resp | Special Focus Doc | Acronym_3GU_Export | Status Report | PCG stopped | TSG stopped |
| --- | --- | --- | --- | --- | --- | --- | --- | --- | --- | --- | --- | --- | --- | --- | --- | --- | --- | --- | --- | --- | --- | --- | --- | --- | --- |
| 2073 | 524.30 | **LTE Advanced intra-band non-contiguous Carrier Aggregation: framework requirements for 2UL** | 397d? | 2013-06-18 A | 2014-12-15 A | 100% | 2013-06-18 | 2014-09-12 | 328d? |  | R4 | 6328h | 6328h | LTE_CA_NC_2UL | PCG-31 | Nokia | petri.j.vasenkari@nokia.com | Rel-12 | RP-60 | Issam | CA | LTE_CA_NC_2UL |  |  |  |
| 2074 | 524.30.1 | Core part: LTE Advanced intra-band non-contiguous Carrier Aggregation: framework requirements for 2UL | 394d? | 2013-06-18 A | 2014-12-15 A | 100% | 2013-06-18 | 2014-09-12 | 328d? | finish no earlier than 2014-12-15 | R4 | 3152h | 3152h | LTE_CA_NC_2UL-Core | PCG-31 | Nokia | petri.j.vasenkari@nokia.com | Rel-12 | RP-60 | Issam | CA | LTE_CA_NC_2UL-Core | RP-141732 |  |  |
| 2075 | 524.31 | **Deleted - LTE Advanced intra-band non-contiguous Carrier Aggregation in Band 41 for 2UL** | 191d? | 2013-06-19 A | 2014-03-06 A | 100% | 2013-06-19 | 2014-03-06 | 191d? |  | R4 | 4576h | 4576h | LTE_CA_NC_B41_2UL | PCG-31 | Sprint | yang.xu@clearwire.com | Rel-12 | RP-60 | Issam | CA | LTE_CA_NC_B41_2UL | RP-140428 | PCG-32 | RP-63 |
| 2076 | 524.31.1 | Deleted - Core part: LTE Advanced intra-band non-contiguous Carrier Aggregation in Band 41 for 2UL | 191d? | 2013-06-19 A | 2014-03-06 A | 100% | 2013-06-19 | 2014-03-06 | 191d? | finish no earlier than 2014-03-06 | R4 | 1528h | 1528h | LTE_CA_NC_B41_2UL-Core | PCG-31 | Sprint | yang.xu@clearwire.com | Rel-12 | RP-60 | Issam | CA | LTE_CA_NC_B41_2UL-Core | RP-140428 | PCG-32 | RP-63 |
| 2077 | 524.31.2 | Deleted - Perf. part: LTE Advanced intra-band non-contiguous Carrier Aggregation in Band 41 for 2UL | 190d? | 2013-06-20 A | 2014-03-06 A | 100% | 2013-06-20 | 2014-03-06 | 190d? | finish no earlier than 2014-03-06 | R4 | 1520h | 1520h | LTE_CA_NC_B41_2UL-Perf | PCG-31 | Sprint | yang.xu@clearwire.com | Rel-12 | RP-60 | Issam | CA | LTE_CA_NC_B41_2UL-Perf | RP-140428 | PCG-32 | RP-63 |
| 2078 | 524.32 | **LTE Advanced intra-band non-contiguous Carrier Aggregation in Band 4 for 2UL** | 396d? | 2013-06-19 A | 2014-12-15 A | 100% | 2013-06-19 | 2014-09-12 | 327d? |  | R4 | 9448h | 9448h | LTE_CA_NC_B4_2UL | PCG-31 | T-Mobile USA | nelson.ueng@t-mobile.com | Rel-12 | RP-60 | Issam | CA | LTE_CA_NC_B4_2UL |  |  |  |
| 2079 | 524.32.1 | Core part: LTE Advanced intra-band non-contiguous Carrier Aggregation in Band 4 for 2UL | 393d? | 2013-06-19 A | 2014-12-15 A | 100% | 2013-06-19 | 2014-09-12 | 327d? | finish no earlier than 2014-12-15 | R4 | 3144h | 3144h | LTE_CA_NC_B4_2UL-Core | PCG-31 | T-Mobile USA | nelson.ueng@t-mobile.com | Rel-12 | RP-60 | Issam | CA | LTE_CA_NC_B4_2UL-Core | RP-141732 |  |  |
| 2080 | 524.32.2 | Perf. part: LTE Advanced intra-band non-contiguous Carrier Aggregation in Band 4 for 2UL | 392d? | 2013-06-25 A | 2014-12-15 A | 100% | 2013-06-20 | 2014-09-12 | 326d? | finish no earlier than 2014-12-15 | R4 | 3136h | 3136h | LTE_CA_NC_B4_2UL-Perf | PCG-31 | T-Mobile USA | nelson.ueng@t-mobile.com | Rel-12 | RP-60 | Issam | CA | LTE_CA_NC_B4_2UL-Perf | RP-141732 |  |  |
| 2081 | 524.33 | **LTE Advanced intra-band contiguous Carrier Aggregation in Band 23** | 127d? | 2013-06-18 A | 2013-12-06 A | 100% | 2013-06-18 | 2013-12-06 | 127d? |  | R4 | 3032h | 3032h | LTE_CA_C_B23 | PCG-31 | Dish Network | mariam.sorond@dish.com, johny.kim@dish.com | Rel-12 | RP-60 | Issam | CA | LTE_CA_C_B23 |  |  |  |
| 2082 | 524.33.1 | Core part: LTE Advanced intra-band contiguous Carrier Aggregation in Band 23 | 126d? | 2013-06-18 A | 2013-12-06 A | 100% | 2013-06-18 | 2013-12-06 | 126d? | finish no earlier than 2013-12-06 | R4 | 1008h | 1008h | LTE_CA_C_B23-Core | PCG-31 | Dish Network | mariam.sorond@dish.com, johny.kim@dish.com | Rel-12 | RP-60 | Issam | CA | LTE_CA_C_B23-Core | RP-131565 |  |  |
| 2083 | 524.33.2 | Perf. part: LTE Advanced intra-band contiguous Carrier Aggregation in Band 23 | 126d? | 2013-06-18 A | 2013-12-06 A | 100% | 2013-06-18 | 2013-12-06 | 126d? | finish no earlier than 2013-12-06 | R4 | 1008h | 1008h | LTE_CA_C_B23-Perf | PCG-31 | Dish Network | mariam.sorond@dish.com, johny.kim@dish.com | Rel-12 | RP-60 | Issam | CA | LTE_CA_C_B23-Perf | RP-131566 |  |  |
| 2084 | 524.34 | **LTE Advanced intra-band non-contiguous Carrier Aggregation in Band 23** | 263d? | 2013-06-18 A | 2014-06-13 A | 100% | 2013-06-18 | 2014-06-13 | 263d? |  | R4 | 5216h | 5216h | LTE_CA_NC_B23 | PCG-31 | Dish Network | mariam.sorond@dish.com, johny.kim@dish.com | Rel-12 | RP-60 | Issam | CA | LTE_CA_NC_B23 |  |  |  |
| 2085 | 524.34.1 | Core part: LTE Advanced intra-band non-contiguous Carrier Aggregation in Band 23 | 126d? | 2013-06-18 A | 2013-12-06 A | 100% | 2013-06-18 | 2013-12-06 | 126d? | finish no earlier than 2013-12-06 | R4 | 1008h | 1008h | LTE_CA_NC_B23-Core | PCG-31 | Dish Network | mariam.sorond@dish.com, johny.kim@dish.com | Rel-12 | RP-60 | Issam | CA | LTE_CA_NC_B23-Core | RP-131577 |  |  |
| 2086 | 524.34.2 | Perf. part: LTE Advanced intra-band non-contiguous Carrier Aggregation in Band 23 | 263d? | 2013-06-18 A | 2014-06-13 A | 100% | 2013-06-18 | 2014-06-13 | 263d? | finish no earlier than 2014-06-13 | R4 | 2104h | 2104h | LTE_CA_NC_B23-Perf | PCG-31 | Dish Network | mariam.sorond@dish.com, johny.kim@dish.com | Rel-12 | RP-60 | Issam | CA | LTE_CA_NC_B23-Perf | RP-140569 |  |  |
| 2087 | 524.35 | **LTE Advanced inter-band Carrier Aggregation of Band 12 and Band 25** | 127d? | 2013-06-18 A | 2013-12-06 A | 100% | 2013-06-18 | 2013-12-06 | 127d? |  | R4 | 3032h | 3032h | LTE_CA_B12_B25 | PCG-31 | US Cellular | sebastian.thalanany@uscellular.com | Rel-12 | RP-60 | Issam | CA | LTE_CA_B12_B25 |  |  |  |
| 2088 | 524.35.1 | Core part: LTE Advanced inter-band Carrier Aggregation of Band 12 and Band 25 | 126d? | 2013-06-18 A | 2013-12-06 A | 100% | 2013-06-18 | 2013-12-06 | 126d? | finish no earlier than 2013-12-06 | R4 | 1008h | 1008h | LTE_CA_B12_B25-Core | PCG-31 | US Cellular | sebastian.thalanany@uscellular.com | Rel-12 | RP-60 | Issam | CA | LTE_CA_B12_B25-Core | RP-131705 |  |  |
| 2089 | 524.35.2 | Perf. part: LTE Advanced inter-band Carrier Aggregation of Band 12 and Band 25 | 126d? | 2013-06-19 A | 2013-12-06 A | 100% | 2013-06-19 | 2013-12-06 | 126d? | finish no earlier than 2013-12-06 | R4 | 1008h | 1008h | LTE_CA_B12_B25-Perf | PCG-31 | US Cellular | sebastian.thalanany@uscellular.com | Rel-12 | RP-60 | Issam | CA | LTE_CA_B12_B25-Perf | RP-131706 |  |  |
| 2090 | 524.36 | **LTE Advanced inter-band Carrier Aggregation of Band 1 and Band 18 - Additional bandwidth combination set** | 61d? | 2013-06-18 A | 2013-09-06 A | 100% | 2013-06-18 | 2013-09-06 | 61d? |  | R4 | 1464h | 1464h | LTE_CA_B1_B18_BWset | PCG-31 | KDDI | Masaaki Obara (ms-obara@kddi.com) | Rel-12 | RP-60 | Issam | CA | LTE_CA_B1_B18_BWset |  |  |  |
| 2091 | 524.36.1 | Core part: LTE Advanced inter-band Carrier Aggregation of Band 1 and Band 18 - Additional bandwidth combination set | 61d? | 2013-06-18 A | 2013-09-06 A | 100% | 2013-06-18 | 2013-09-06 | 61d? | finish no earlier than 2013-09-06 | R4 | 488h | 488h | LTE_CA_B1_B18_BWset-Core | PCG-31 | KDDI | Masaaki Obara (ms-obara@kddi.com) | Rel-12 | RP-60 | Issam | CA | LTE_CA_B1_B18_BWset-Core | RP-131003 |  |  |
| 2092 | 524.36.2 | Perf. part: LTE Advanced inter-band Carrier Aggregation of Band 1 and Band 18 - Additional bandwidth combination set | 61d? | 2013-06-18 A | 2013-09-06 A | 100% | 2013-06-18 | 2013-09-06 | 61d? | finish no earlier than 2013-09-06 | R4 | 488h | 488h | LTE_CA_B1_B18_BWset-Perf | PCG-31 | KDDI | Masaaki Obara (ms-obara@kddi.com) | Rel-12 | RP-60 | Issam | CA | LTE_CA_B1_B18_BWset-Perf | RP-131004 |  |  |
| 2093 | 524.37 | **LTE Advanced inter-band Carrier Aggregation of Band 2 and Band 5** | 61d? | 2013-06-18 A | 2013-09-06 A | 100% | 2013-06-18 | 2013-09-06 | 61d? |  | R4 | 1464h | 1464h | LTE_CA_B2_B5 | PCG-31 | AT&T | marc.grant@att.com | Rel-12 | RP-60 | Issam | CA | LTE_CA_B2_B5 |  |  |  |
| 2094 | 524.37.1 | Core part: LTE Advanced inter-band Carrier Aggregation of Band 2 and Band 5 | 61d? | 2013-06-18 A | 2013-09-06 A | 100% | 2013-06-18 | 2013-09-06 | 61d? | finish no earlier than 2013-09-06 | R4 | 488h | 488h | LTE_CA_B2_B5-Core | PCG-31 | AT&T | marc.grant@att.com | Rel-12 | RP-60 | Issam | CA | LTE_CA_B2_B5-Core | RP-131009 |  |  |
| 2095 | 524.37.2 | Perf. part: LTE Advanced inter-band Carrier Aggregation of Band 2 and Band 5 | 61d? | 2013-06-18 A | 2013-09-06 A | 100% | 2013-06-18 | 2013-09-06 | 61d? | finish no earlier than 2013-12-06 | R4 | 488h | 488h | LTE_CA_B2_B5-Perf | PCG-31 | AT&T | marc.grant@att.com | Rel-12 | RP-60 | Issam | CA | LTE_CA_B2_B5-Perf | RP-131010 |  |  |
| 2096 | 524.38 | **LTE Advanced 3 Band Carrier Aggregation (3DL/1UL) of Band 2, Band 5 and Band 30** | 329d? | 2013-06-18 A | 2014-09-12 A | 100% | 2013-06-18 | 2014-09-12 | 328d? |  | R4 | 7872h | 7872h | LTE_CA_B2_B5_B30 | PCG-31 | AT&T | marc.grant@att.com | Rel-12 | RP-60 | Issam | CA | LTE_CA_B2_B5_B30 |  |  |  |
| 2097 | 524.38.1 | Core part: LTE Advanced 3 Band Carrier Aggregation (3DL/1UL) of Band 2, Band 5 and Band 30 | 328d? | 2013-06-18 A | 2014-09-12 A | 100% | 2013-06-18 | 2014-09-12 | 328d? | finish no earlier than 2014-09-12 | R4 | 2624h | 2624h | LTE_CA_B2_B5_B30-Core | PCG-31 | AT&T | marc.grant@att.com | Rel-12 | RP-60 | Issam | CA | LTE_CA_B2_B5_B30-Core | RP-141084 |  |  |
| 2098 | 524.38.2 | Perf. part: LTE Advanced 3 Band Carrier Aggregation (3DL/1UL) of Band 2, Band 5 and Band 30 | 327d? | 2013-06-18 A | 2014-09-12 A | 100% | 2013-06-18 | 2014-09-12 | 327d? | finish no earlier than 2014-09-12 | R4 | 2616h | 2616h | LTE_CA_B2_B5_B30-Perf | PCG-31 | AT&T | marc.grant@att.com | Rel-12 | RP-60 | Issam | CA | LTE_CA_B2_B5_B30-Perf | RP-141084 |  |  |

Notes:
- 2073: Intra-band non-contig. CA 2DL / Impacted TSs and TRs: LTE
- 2074: ; WID: RP-142043->RP-141962; Stat Rep: RP-141084->RP-141732 / Impacted TSs and TRs: 36.101, 36.104, 36.133, 36.306, 36.331, New TR 36.833-4
- 2075: Intra-band NC 2UL / Impacted TSs and TRs: LTE
- 2076: RP#63 stopped (5% complete). Reason: Market conditions have eliminated the need for this feature, at least for the foreseeable future / Impacted TSs and TRs: 36.101, 36.104, 36.133, new TR 36.833-3-41
- 2077: RP#63 stopped (0% complete). / Impacted TSs and TRs: 36.101, 36.104, 36.133, 36.141, 36.307
- 2078: Intra-band non-contig. CA 2DL / Impacted TSs and TRs: LTE
- 2079: ; WID: RP-142043->RP-141784; Stat Rep: RP-141084->RP-141732 / Impacted TSs and TRs: 36.101, 36.104, 36.133, new TR 36.833-4-04
- 2080: ; WID: RP-142043->RP-141784; Stat Rep: RP-141084->RP-141732 / Impacted TSs and TRs: 36.101, 36.104, 36.133, 36.141, 36.307
- 2081: Intra-band C CA / Impacted TSs and TRs: LTE
- 2082: RP#62 completed / Impacted TSs and TRs: 36.101, 36.104, 36.133, new TR 36.833-1-23 [instead of 36.864]
- 2083: RP#62 completed / Impacted TSs and TRs: 36.141, 36.307
- 2084: Intra-band non-contig. CA 2DL / Impacted TSs and TRs: LTE
- 2085: RP#62 completed / Impacted TSs and TRs: 36.101, 36.104, 36.133, new TR 36.833-2-23
- 2086: RP#64 completed. TR 36.833-2-23v200 for Approval / Impacted TSs and TRs: 36.101, 36.133, 36.141, 36.307, new TR 36.833-2-23
- 2087: Inter-band 1UL/2DL / Impacted TSs and TRs: LTE
- 2088: RP#62 completed / Impacted TSs and TRs: 36.101, 36.104, 36.133, new generic TR 36.851
- 2089: RP#62 completed / Impacted TSs and TRs: 36.141, 36.307
- 2090: Inter-band 1UL/2DL / Impacted TSs and TRs: LTE
- 2091: RP#61 completed / Impacted TSs and TRs: 36.101, new generic TR 36.851
- 2092: RP#61 completed / Impacted TSs and TRs: 36.307
- 2093: Inter-band 2DL / Impacted TSs and TRs: LTE
- 2094: RP#61 completed / Impacted TSs and TRs: 36.101, 36.104, 36.307
- 2095: RP#61 completed / Impacted TSs and TRs: 36.101, 36.104, 36.133, 36.141, 36.307
- 2096: Inter-band 3DL / Impacted TSs and TRs: LTE
- 2097: RP#65 completed. TR 36.853v200 for Approval / Impacted TSs and TRs: 36.101, 36.104, 36.133, 36.141, 36.307, new generic TR 36.853 (3 Band CA with 1UL)
- 2098: RP#65 completed / Impacted TSs and TRs: 36.101, 36.104, 36.133, 36.141, 36.307

| ID | WBS | Task | Duration | Start | Finish | Complete | Baseline start | Baseline finish | Baseline duration | Constraint | Resources | Work | Actual work | Acronym | PCG approved | WI rapporteur name | WI rapporteur e-mail | Release | TSG approved | MCC resp | PCG stopped | TSG stopped | Special Focus Doc | Acronym_3GU_Export | Status Report |
| --- | --- | --- | --- | --- | --- | --- | --- | --- | --- | --- | --- | --- | --- | --- | --- | --- | --- | --- | --- | --- | --- | --- | --- | --- | --- |
| 2099 | 524.39 | **Deleted - LTE Advanced 3 Band Carrier Aggregation (3DL/1UL) of Band 2, Band 17 and Band 30** | 127d? | 2013-06-18 A | 2013-12-06 A | 100% | 2013-06-18 | 2013-12-06 | 127d? |  | R4 | 3024h | 3024h | LTE_CA_B2_B17_B30 | PCG-31 | AT&T | marc.grant@att.com | Rel-12 | RP-60 | Issam | PCG-32 | RP-62 | CA | LTE_CA_B2_B17_B30 |  |
| 2100 | 524.39.1 | Deleted - Core part: LTE Advanced 3 Band Carrier Aggregation (3DL/1UL) of Band 2, Band 17 and Band 30 | 126d? | 2013-06-18 A | 2013-12-06 A | 100% | 2013-06-18 | 2013-12-06 | 126d? | finish no earlier than 2014-06-13 | R4 | 1008h | 1008h | LTE_CA_B2_B17_B30-Core | PCG-31 | AT&T | marc.grant@att.com | Rel-12 | RP-60 | Issam | PCG-32 | RP-62 | CA | LTE_CA_B2_B17_B30-Core | RP-131590 |
| 2101 | 524.39.2 | Deleted - Perf. part: LTE Advanced 3 Band Carrier Aggregation (3DL/1UL) of Band 2, Band 17 and Band 30 | 125d? | 2013-06-19 A | 2013-12-06 A | 100% | 2013-06-19 | 2013-12-06 | 125d? | finish no earlier than 2014-09-12 | R4 | 1000h | 1000h | LTE_CA_B2_B17_B30-Perf | PCG-31 | AT&T | marc.grant@att.com | Rel-12 | RP-60 | Issam | PCG-32 | RP-62 | CA | LTE_CA_B2_B17_B30-Perf | RP-131591 |
| 2102 | 524.40 | **LTE Advanced 3 Band Carrier Aggregation (3DL/1UL) of Band 2, Band 29 and Band 30** | 328d? | 2013-06-19 A | 2014-09-12 A | 100% | 2013-06-19 | 2014-09-12 | 327d? |  | R4 | 7856h | 7856h | LTE_CA_B2_B29_B30 | PCG-31 | AT&T | marc.grant@att.com | Rel-12 | RP-60 | Issam |  |  | CA | LTE_CA_B2_B29_B30 |  |
| 2103 | 524.40.1 | Core part: LTE Advanced 3 Band Carrier Aggregation (3DL/1UL) of Band 2, Band 29 and Band 30 | 327d? | 2013-06-19 A | 2014-09-12 A | 100% | 2013-06-19 | 2014-06-13 | 262d? | finish no earlier than 2014-09-12 | R4 | 2616h | 2616h | LTE_CA_B2_B29_B30-Core | PCG-31 | AT&T | marc.grant@att.com | Rel-12 | RP-60 | Issam |  |  | CA | LTE_CA_B2_B29_B30-Core | RP-141084 |
| 2104 | 524.40.2 | Perf. part: LTE Advanced 3 Band Carrier Aggregation (3DL/1UL) of Band 2, Band 29 and Band 30 | 327d? | 2013-06-19 A | 2014-09-12 A | 100% | 2013-06-19 | 2014-09-12 | 327d? | finish no earlier than 2014-09-12 | R4 | 2616h | 2616h | LTE_CA_B2_B29_B30-Perf | PCG-31 | AT&T | marc.grant@att.com | Rel-12 | RP-60 | Issam |  |  | CA | LTE_CA_B2_B29_B30-Perf | RP-141084 |
| 2105 | 524.41 | **LTE Advanced 3 Band Carrier Aggregation (3DL/1UL) of Band 4, Band 5 and Band 30** | 331d? | 2013-06-14 A | 2014-09-12 A | 100% | 2013-06-14 | 2014-09-12 | 330d? |  | R4 | 7904h | 7904h | LTE_CA_B4_B5_B30 | PCG-31 | AT&T | marc.grant@att.com | Rel-12 | RP-60 | Issam |  |  | CA | LTE_CA_B4_B5_B30 |  |
| 2106 | 524.41.1 | Core part: LTE Advanced 3 Band Carrier Aggregation (3DL/1UL) of Band 4, Band 5 and Band 30 | 330d? | 2013-06-14 A | 2014-09-12 A | 100% | 2013-06-14 | 2014-09-12 | 330d? | finish no earlier than 2014-09-12 | R4 | 2640h | 2640h | LTE_CA_B4_B5_B30-Core | PCG-31 | AT&T | marc.grant@att.com | Rel-12 | RP-60 | Issam |  |  | CA | LTE_CA_B4_B5_B30-Core | RP-141084 |
| 2107 | 524.41.2 | Perf. part: LTE Advanced 3 Band Carrier Aggregation (3DL/1UL) of Band 4, Band 5 and Band 30 | 327d? | 2013-06-19 A | 2014-09-12 A | 100% | 2013-06-19 | 2014-09-12 | 327d? | finish no earlier than 2014-09-12 | R4 | 2616h | 2616h | LTE_CA_B4_B5_B30-Perf | PCG-31 | AT&T | marc.grant@att.com | Rel-12 | RP-60 | Issam |  |  | CA | LTE_CA_B4_B5_B30-Perf | RP-141084 |
| 2108 | 524.42 | **Deleted - LTE Advanced 3 Band Carrier Aggregation (3DL/1UL) of Band 4, Band 17 and Band 30** | 127d? | 2013-06-18 A | 2013-12-06 A | 100% | 2013-06-18 | 2013-12-06 | 127d? |  | R4 | 3040h | 3040h | LTE_CA_B4_B17_B30 | PCG-31 | AT&T | marc.grant@att.com | Rel-12 | RP-60 | Issam | PCG-32 | RP-62 | CA | LTE_CA_B4_B17_B30 |  |
| 2109 | 524.42.1 | Deleted - Core part: LTE Advanced 3 Band Carrier Aggregation (3DL/1UL) of Band 4, Band 17 and Band 30 | 127d? | 2013-06-18 A | 2013-12-06 A | 100% | 2013-06-18 | 2013-12-06 | 127d? | finish no earlier than 2013-12-06 | R4 | 1016h | 1016h | LTE_CA_B4_B17_B30-Core | PCG-31 | AT&T | marc.grant@att.com | Rel-12 | RP-60 | Issam | PCG-32 | RP-62 | CA | LTE_CA_B4_B17_B30-Core | RP-131598 |
| 2110 | 524.42.2 | Deleted - Perf. part: LTE Advanced 3 Band Carrier Aggregation (3DL/1UL) of Band 4, Band 17 and Band 30 | 126d? | 2013-06-19 A | 2013-12-06 A | 100% | 2013-06-19 | 2013-12-06 | 126d? | finish no earlier than 2013-12-06 | R4 | 1008h | 1008h | LTE_CA_B4_B17_B30-Perf | PCG-31 | AT&T | marc.grant@att.com | Rel-12 | RP-60 | Issam | PCG-32 | RP-62 | CA | LTE_CA_B4_B17_B30-Perf | RP-131599 |
| 2111 | 524.43 | **LTE Advanced 3 Band Carrier Aggregation (3DL/1UL) of Band 4, Band 29 and Band 30** | 331d? | 2013-06-14 A | 2014-09-12 A | 100% | 2013-06-14 | 2014-09-12 | 330d? |  | R4 | 7904h | 7904h | LTE_CA_B4_B29_B30 | PCG-31 | AT&T | marc.grant@att.com | Rel-12 | RP-60 | Issam |  |  | CA | LTE_CA_B4_B29_B30 |  |
| 2112 | 524.43.1 | Core part: LTE Advanced 3 Band Carrier Aggregation (3DL/1UL) of Band 4, Band 29 and Band 30 | 330d? | 2013-06-14 A | 2014-09-12 A | 100% | 2013-06-14 | 2014-09-12 | 330d? | finish no earlier than 2014-09-12 | R4 | 2640h | 2640h | LTE_CA_B4_B29_B30-Core | PCG-31 | AT&T | marc.grant@att.com | Rel-12 | RP-60 | Issam |  |  | CA | LTE_CA_B4_B29_B30-Core | RP-141084 |
| 2113 | 524.43.2 | Perf. part: LTE Advanced 3 Band Carrier Aggregation (3DL/1UL) of Band 4, Band 29 and Band 30 | 327d? | 2013-06-19 A | 2014-09-12 A | 100% | 2013-06-19 | 2014-09-12 | 327d? | finish no earlier than 2014-09-12 | R4 | 2616h | 2616h | LTE_CA_B4_B29_B30-Perf | PCG-31 | AT&T | marc.grant@att.com | Rel-12 | RP-60 | Issam |  |  | CA | LTE_CA_B4_B29_B30-Perf | RP-141084 |
| 2114 | 524.44 | **LTE Advanced 3 Band Carrier Aggregation (3DL/1UL) of Band 2, Band 4 and Band 13** | 331d? | 2013-06-14 A | 2014-09-12 A | 100% | 2013-06-14 | 2014-09-12 | 330d? |  | R4 | 7904h | 7904h | LTE_CA_B2_B4_B13 | PCG-31 | Verizon | zheng.zhao@verizonwireless.com | Rel-12 | RP-60 | Issam |  |  | CA | LTE_CA_B2_B4_B13 |  |
| 2115 | 524.44.1 | Core part: LTE Advanced 3 Band Carrier Aggregation (3DL/1UL) of Band 2, Band 4 and Band 13 | 330d? | 2013-06-14 A | 2014-09-12 A | 100% | 2013-06-14 | 2014-09-12 | 330d? | finish no earlier than 2014-09-12 | R4 | 2640h | 2640h | LTE_CA_B2_B4_B13-Core | PCG-31 | Verizon | zheng.zhao@verizonwireless.com | Rel-12 | RP-60 | Issam |  |  | CA | LTE_CA_B2_B4_B13-Core | RP-141084 |
| 2116 | 524.44.2 | Perf. part: LTE Advanced 3 Band Carrier Aggregation (3DL/1UL) of Band 2, Band 4 and Band 13 | 327d? | 2013-06-19 A | 2014-09-12 A | 100% | 2013-06-19 | 2014-09-12 | 327d? | finish no earlier than 2014-09-12 | R4 | 2616h | 2616h | LTE_CA_B2_B4_B13-Perf | PCG-31 | Verizon | zheng.zhao@verizonwireless.com | Rel-12 | RP-60 | Issam |  |  | CA | LTE_CA_B2_B4_B13-Perf | RP-141084 |
| 2117 | 524.45 | **LTE Advanced 3 Band Carrier Aggregation (3DL/1UL) of Band 2, Band 2 and Band 13** | 329d? | 2013-06-18 A | 2014-09-12 A | 100% | 2013-06-18 | 2014-09-12 | 328d? |  | R4 | 7864h | 7864h | LTE_CA_B2_B2_B13 | PCG-31 | Verizon | zheng.zhao@verizonwireless.com | Rel-12 | RP-60 | Issam |  |  | CA | LTE_CA_B2_B2_B13 |  |
| 2118 | 524.45.1 | Core part: LTE Advanced 3 Band Carrier Aggregation (3DL/1UL) of Band 2, Band 2 and Band 13 | 327d? | 2013-06-18 A | 2014-09-12 A | 100% | 2013-06-18 | 2014-09-12 | 327d? | finish no earlier than 2014-09-12 | R4 | 2616h | 2616h | LTE_CA_B2_B2_B13-Core | PCG-31 | Verizon | zheng.zhao@verizonwireless.com | Rel-12 | RP-60 | Issam |  |  | CA | LTE_CA_B2_B2_B13-Core | RP-141084 |
| 2119 | 524.45.2 | Perf. part: LTE Advanced 3 Band Carrier Aggregation (3DL/1UL) of Band 2, Band 2 and Band 13 | 327d? | 2013-06-19 A | 2014-09-12 A | 100% | 2013-06-19 | 2014-09-12 | 327d? | finish no earlier than 2014-09-12 | R4 | 2616h | 2616h | LTE_CA_B2_B2_B13-Perf | PCG-31 | Verizon | zheng.zhao@verizonwireless.com | Rel-12 | RP-60 | Issam |  |  | CA | LTE_CA_B2_B2_B13-Perf | RP-141084 |
| 2120 | 524.46 | **LTE Advanced 3 Band Carrier Aggregation (3DL/1UL) of Band 4, Band 4 and Band 13** | 331d? | 2013-06-14 A | 2014-09-12 A | 100% | 2013-06-14 | 2014-09-12 | 330d? |  | R4 | 7928h | 7928h | LTE_CA_B4_B4_B13 | PCG-31 | Verizon | zheng.zhao@verizonwireless.com | Rel-12 | RP-60 | Issam |  |  | CA | LTE_CA_B4_B4_B13 |  |
| 2121 | 524.46.1 | Core part: LTE Advanced 3 Band Carrier Aggregation (3DL/1UL) of Band 4, Band 4 and Band 13 | 330d? | 2013-06-14 A | 2014-09-12 A | 100% | 2013-06-14 | 2014-09-12 | 330d? | finish no earlier than 2014-09-12 | R4 | 2640h | 2640h | LTE_CA_B4_B4_B13-Core | PCG-31 | Verizon | zheng.zhao@verizonwireless.com | Rel-12 | RP-60 | Issam |  |  | CA | LTE_CA_B4_B4_B13-Core | RP-141084 |
| 2122 | 524.46.2 | Perf. part: LTE Advanced 3 Band Carrier Aggregation (3DL/1UL) of Band 4, Band 4 and Band 13 | 330d? | 2013-06-14 A | 2014-09-12 A | 100% | 2013-06-14 | 2014-09-12 | 330d? | finish no earlier than 2014-09-12 | R4 | 2640h | 2640h | LTE_CA_B4_B4_B13-Perf | PCG-31 | Verizon | zheng.zhao@verizonwireless.com | Rel-12 | RP-60 | Issam |  |  | CA | LTE_CA_B4_B4_B13-Perf | RP-141084 |

Notes:
- 2099: Inter-band 3DL / Impacted TSs and TRs: LTE
- 2100: RP#62 stopped (25% complete) following RP-131652 discussion / Impacted TSs and TRs: 36.101, 36.104, 36.133, 36.141, 36.307, new generic TR 36.853 (3 Band CA with 1UL)
- 2101: RP#62 stopped (25% complete) following RP-131652 discussion / Impacted TSs and TRs: 36.101, 36.104, 36.133, 36.141, 36.307
- 2102: Inter-band 3DL / Impacted TSs and TRs: LTE
- 2103: RP#65 completed. Updated WID RP-131697=>RP-141212 / Impacted TSs and TRs: 36.101, 36.104, 36.133, 36.141, 36.307, new generic TR 36.853 (3 Band CA with 1UL)
- 2104: RP#65 completed / Impacted TSs and TRs: 36.101, 36.104, 36.133, 36.141, 36.307
- 2105: Inter-band CA 3DL / Impacted TSs and TRs: LTE
- 2106: RP#65 completed. Updated WID RP-131698=>RP-141213 / Impacted TSs and TRs: 36.101, 36.104, 36.133, 36.141, 36.307, new generic TR 36.853 (3 Band CA with 1UL)
- 2107: RP#65 completed / Impacted TSs and TRs: 36.101, 36.104, 36.133, 36.141, 36.307
- 2108: Inter-band 3DL / Impacted TSs and TRs: LTE
- 2109: RP#62 stopped (25% complete) following RP-131653 discussion / Impacted TSs and TRs: 36.101, 36.104, 36.133, 36.141, 36.307, new generic TR 36.853 (3 Band CA with 1UL)
- 2110: RP#62 stopped (25% complete) following RP-131653 discussion / Impacted TSs and TRs: 36.101, 36.104, 36.133, 36.141, 36.307
- 2111: Inter-band CA 3DL / Impacted TSs and TRs: LTE
- 2112: RP#65 completed. Updated WID RP-131699=>RP- 141215 / Impacted TSs and TRs: 36.101, 36.104, 36.133, 36.141, 36.307, new generic TR 36.853 (3 Band CA with 1UL)
- 2113: RP#65 completed / Impacted TSs and TRs: 36.101, 36.104, 36.133, 36.141, 36.307
- 2114: Inter-band CA 3DL / Impacted TSs and TRs: LTE
- 2115: RP#65 completed. Updated RP-131684=>RP-141434 / Impacted TSs and TRs: 36.101, 36.104, 36.133, new generic TR 36.853 (3 Band CA with 1UL)
- 2116: RP#65 completed / Impacted TSs and TRs: 36.101, 36.133, 36.141, 36.307
- 2117: Inter-band CA 3DL / Impacted TSs and TRs: LTE
- 2118: RP#65 completed. Updated WID RP-131682=>RP-141435 / Impacted TSs and TRs: 36.101, 36.104, 36.133, new generic TR 36.853 (3 Band CA with 1UL)
- 2119: RP#65 completed / Impacted TSs and TRs: 36.101, 36.133, 36.141, 36.307
- 2120: Inter-band CA 3DL / Impacted TSs and TRs: LTE
- 2121: RP#65 completed. Updated WID RP-131683=>RP-141433 / Impacted TSs and TRs: 36.101, 36.104, 36.133, new generic TR 36.853 (3 Band CA with 1UL)
- 2122: RP#65 completed / Impacted TSs and TRs: 36.101, 36.133, 36.141, 36.307

| ID | WBS | Task | Duration | Start | Finish | Complete | Baseline start | Baseline finish | Baseline duration | Constraint | Resources | Work | Actual work | Acronym | PCG approved | Impacted TSs and TRs | WI rapporteur name | WI rapporteur e-mail | Release | TSG approved | MCC resp | Special Focus Doc | Acronym_3GU_Export | Status Report |
| --- | --- | --- | --- | --- | --- | --- | --- | --- | --- | --- | --- | --- | --- | --- | --- | --- | --- | --- | --- | --- | --- | --- | --- | --- |
| 2123 | 524.47 | **LTE Advanced inter-band Carrier Aggregation of Band 7 and Band 28** | 66d? | 2013-09-09 A | 2013-12-06 A | 100% | 2013-09-09 | 2013-12-06 | 66d? |  | R4 | 1584h | 1584h | LTE_CA_B7_B28 | PCG-31 | LTE | Huawei | Liehai Liu (liuliehai@huawei.com) | Rel-12 | RP-61 | Issam | CA | LTE_CA_B7_B28 |  |
| 2124 | 524.47.1 | Core part: LTE Advanced inter-band Carrier Aggregation of Band 7 and Band 28 | 66d? | 2013-09-09 A | 2013-12-06 A | 100% | 2013-09-09 | 2013-12-06 | 66d? | finish no earlier than 2013-12-06 | R4 | 528h | 528h | LTE_CA_B7_B28-Core | PCG-31 | 36.101, 36.104, 36.307 | Huawei | Liehai Liu (liuliehai@huawei.com) | Rel-12 | RP-61 | Issam | CA | LTE_CA_B7_B28-Core | RP-131545 |
| 2125 | 524.47.2 | Perf. part: LTE Advanced inter-band Carrier Aggregation of Band 7 and Band 28 | 66d? | 2013-09-09 A | 2013-12-06 A | 100% | 2013-09-09 | 2013-12-06 | 66d? | finish no earlier than 2013-12-06 | R4 | 528h | 528h | LTE_CA_B7_B28-Perf | PCG-31 | 36.141 | Huawei | Liehai Liu (liuliehai@huawei.com) | Rel-12 | RP-61 | Issam | CA | LTE_CA_B7_B28-Perf | RP-131546 |
| 2126 | 524.48 | **LTE Advanced inter-band Carrier Aggregation of Band 5 and Band 25** | 66d? | 2013-09-09 A | 2013-12-06 A | 100% | 2013-09-09 | 2013-12-06 | 66d? |  | R4 | 1584h | 1584h | LTE_CA_B5_B25 | PCG-31 | LTE | U.S. Cellular | sebastian.thalanany@uscellular.com | Rel-12 | RP-61 | Issam | CA | LTE_CA_B5_B25 |  |
| 2127 | 524.48.1 | Core part: LTE Advanced inter-band Carrier Aggregation of Band 5 and Band 25 | 66d? | 2013-09-09 A | 2013-12-06 A | 100% | 2013-09-09 | 2013-12-06 | 66d? | finish no earlier than 2013-12-06 | R4 | 528h | 528h | LTE_CA_B5_B25-Core | PCG-31 | 36.101, 36.104, 36.133, new generic TR 36.851 | U.S. Cellular | sebastian.thalanany@uscellular.com | Rel-12 | RP-61 | Issam | CA | LTE_CA_B5_B25-Core | RP-131543 |
| 2128 | 524.48.2 | Perf. part: LTE Advanced inter-band Carrier Aggregation of Band 5 and Band 25 | 66d? | 2013-09-09 A | 2013-12-06 A | 100% | 2013-09-09 | 2013-12-06 | 66d? | finish no earlier than 2013-12-06 | R4 | 528h | 528h | LTE_CA_B5_B25-Perf | PCG-31 | 36.141, 36.307 | U.S. Cellular | sebastian.thalanany@uscellular.com | Rel-12 | RP-61 | Issam | CA | LTE_CA_B5_B25-Perf | RP-131705 |
| 2129 | 524.49 | **LTE Advanced inter-band Carrier Aggregation of Band 1 and Band 11** | 202d? | 2013-09-09 A | 2014-06-13 A | 100% | 2013-09-09 | 2014-06-13 | 202d? |  | R4 | 4848h | 4848h | LTE_CA_B1_B11 | PCG-31 | LTE | SoftBank Mobile | kenichi.kihara@g.softbank.co.jp | Rel-12 | RP-61 | Issam | CA | LTE_CA_B1_B11 |  |
| 2130 | 524.49.1 | Core part: LTE Advanced inter-band Carrier Aggregation of Band 1 and Band 11 | 202d? | 2013-09-09 A | 2014-06-13 A | 100% | 2013-09-09 | 2014-06-13 | 202d? | finish no earlier than 2014-06-13 | R4 | 1616h | 1616h | LTE_CA_B1_B11-Core | PCG-31 | 36.101, 36.104, new generic TR 36.851 | SoftBank Mobile | kenichi.kihara@g.softbank.co.jp | Rel-12 | RP-61 | Issam | CA | LTE_CA_B1_B11-Core | RP-140569 |
| 2131 | 524.49.2 | Perf. part: LTE Advanced inter-band Carrier Aggregation of Band 1 and Band 11 | 202d? | 2013-09-09 A | 2014-06-13 A | 100% | 2013-09-09 | 2014-06-13 | 202d? | finish no earlier than 2014-06-13 | R4 | 1616h | 1616h | LTE_CA_B1_B11-Perf | PCG-31 | 36.141, 36.307 | SoftBank Mobile | kenichi.kihara@g.softbank.co.jp | Rel-12 | RP-61 | Issam | CA | LTE_CA_B1_B11-Perf | RP-140569 |
| 2132 | 524.50 | **LTE Advanced inter-band Carrier Aggregation of Band 8 and Band 11** | 268d? | 2013-09-09 A | 2014-09-12 A | 100% | 2013-09-09 | 2014-09-12 | 267d? |  | R4 | 6416h | 6416h | LTE_CA_B8_B11 | PCG-31 | LTE | SoftBank Mobile | kenichi.kihara@g.softbank.co.jp | Rel-12 | RP-61 | Issam | CA | LTE_CA_B8_B11 |  |
| 2133 | 524.50.1 | Core part: LTE Advanced inter-band Carrier Aggregation of Band 8 and Band 11 | 267d? | 2013-09-09 A | 2014-09-12 A | 100% | 2013-09-09 | 2014-09-12 | 267d? | finish no earlier than 2014-09-12 | R4 | 2136h | 2136h | LTE_CA_B8_B11-Core | PCG-31 | 36.101, 36.104, new generic TR 36.851 | SoftBank Mobile | kenichi.kihara@g.softbank.co.jp | Rel-12 | RP-61 | Issam | CA | LTE_CA_B8_B11-Core | RP-141084 |
| 2134 | 524.50.2 | Perf. part: LTE Advanced inter-band Carrier Aggregation of Band 8 and Band 11 | 267d? | 2013-09-09 A | 2014-09-12 A | 100% | 2013-09-09 | 2014-09-12 | 267d? | finish no earlier than 2014-09-12 | R4 | 2136h | 2136h | LTE_CA_B8_B11-Perf | PCG-31 | 36.141, 36.307 | SoftBank Mobile | kenichi.kihara@g.softbank.co.jp | Rel-12 | RP-61 | Issam | CA | LTE_CA_B8_B11-Perf | RP-141084 |
| 2135 | 524.51 | **LTE Advanced inter-band Carrier Aggregation of Band 5 and Band 7** | 62d? | 2013-09-09 A | 2013-12-02 A | 100% | 2013-09-09 | 2013-12-02 | 62d? |  | R4 | 1488h | 1488h | LTE_CA_B5_B7 | PCG-31 | LTE | LG Uplus | Yeonsang KOO (yskoo@lguplus.co.kr) | Rel-12 | RP-61 | Issam | CA | LTE_CA_B5_B7 |  |
| 2136 | 524.51.1 | Core part: LTE Advanced inter-band Carrier Aggregation of Band 5 and Band 7 | 62d? | 2013-09-09 A | 2013-12-02 A | 100% | 2013-09-09 | 2013-12-02 | 62d? | finish no earlier than 2013-12-02 | R4 | 496h | 496h | LTE_CA_B5_B7-Core | PCG-31 | 36.101, 36.104, 36.133, new generic TR 36.851 | LG Uplus | Yeonsang KOO (yskoo@lguplus.co.kr) | Rel-12 | RP-61 | Issam | CA | LTE_CA_B5_B7-Core | RP-131541 |
| 2137 | 524.51.2 | Perf. part: LTE Advanced inter-band Carrier Aggregation of Band 5 and Band 7 | 62d? | 2013-09-09 A | 2013-12-02 A | 100% | 2013-09-09 | 2013-12-02 | 62d? | finish no earlier than 2013-12-02 | R4 | 496h | 496h | LTE_CA_B5_B7-Perf | PCG-31 | 36.141, 36.307 | LG Uplus | Yeonsang KOO (yskoo@lguplus.co.kr) | Rel-12 | RP-61 | Issam | CA | LTE_CA_B5_B7-Perf | RP-131542 |
| 2138 | 524.52 | **LTE Advanced intra-band contiguous Carrier Aggregation in Band 41 for 3DL** | 400d? | 2013-09-09 A | 2015-03-15 A | 100% | 2013-09-09 | 2014-09-12 | 267d? |  | R4 | 8512h | 8512h | LTE_CA_C_B41_3DL | PCG-31 | LTE | Alcatel-Lucent | man-hung.ng@alcatel-lucent.com | Rel-12 | RP-61 | Issam | CA | LTE_CA_C_B41_3DL |  |
| 2139 | 524.52.1 | Core part: LTE Advanced intra-band contiguous Carrier Aggregation in Band 41 for 3DL | 267d? | 2013-09-09 A | 2014-09-12 A | 100% | 2013-09-09 | 2014-09-12 | 267d? | finish no earlier than 2014-09-12 | R4 | 2136h | 2136h | LTE_CA_C_B41_3DL-Core | PCG-31 | 36.101, 36.104, 36.133, 36.307, New TR 36.833-5-41 | Alcatel-Lucent | man-hung.ng@alcatel-lucent.com | Rel-12 | RP-61 | Issam | CA | LTE_CA_C_B41_3DL-Core | RP-141084 |
| 2140 | 524.52.2 | Perf. part: LTE Advanced intra-band contiguous Carrier Aggregation in Band 41 for 3DL | 397d? | 2013-09-09 A | 2015-03-15 A | 100% | 2013-09-09 | 2014-09-12 | 267d? | finish no earlier than 2015-03-15 | R4 | 3176h | 3176h | LTE_CA_C_B41_3DL-Perf | PCG-31 | 36.141 | Alcatel-Lucent | man-hung.ng@alcatel-lucent.com | Rel-12 | RP-61 | Issam | CA | LTE_CA_C_B41_3DL-Perf | RP-150013 |
| 2141 | 524.53 | **LTE Advanced intra-band non-contiguous Carrier Aggregation in Band 2** | 202d? | 2013-09-09 A | 2014-06-13 A | 100% | 2013-09-09 | 2014-06-13 | 202d? |  | R4 | 4840h | 4840h | LTE_CA_NC_B2 | PCG-31 | LTE | Ericsson | imadur.rahman@ericsson.com | Rel-12 | RP-61 | Issam | CA | LTE_CA_NC_B2 |  |
| 2142 | 524.53.1 | Core part: LTE Advanced intra-band non-contiguous Carrier Aggregation in Band 2 | 202d? | 2013-09-09 A | 2014-06-13 A | 100% | 2013-09-09 | 2014-06-13 | 202d? | finish no earlier than 2014-06-13 | R4 | 1616h | 1616h | LTE_CA_NC_B2-Core | PCG-31 | 36.101, 36.104, 36.133, New TR 36.833-2-02 | Ericsson | imadur.rahman@ericsson.com | Rel-12 | RP-61 | Issam | CA | LTE_CA_NC_B2-Core | RP-140569 |
| 2143 | 524.53.2 | Perf. part: LTE Advanced intra-band non-contiguous Carrier Aggregation in Band 2 | 201d? | 2013-09-10 A | 2014-06-13 A | 100% | 2013-09-10 | 2014-06-13 | 201d? | finish no earlier than 2014-06-13 | R4 | 1608h | 1608h | LTE_CA_NC_B2-Perf | PCG-31 | 36.141, 36.307 | Ericsson | imadur.rahman@ericsson.com | Rel-12 | RP-61 | Issam | CA | LTE_CA_NC_B2-Perf | RP-140569 |
| 2144 | 524.54 | **LTE Advanced inter-band Carrier Aggregation of Band 1 and Band 3** | 202d? | 2013-12-09 A | 2014-09-12 A | 100% | 2013-12-09 | 2014-09-12 | 201d? |  | R4 | 4832h | 4832h | LTE_CA_B1_B3 | PCG-32 | LTE | China Unicom | Hao Chen (chenhao49@chinaunicom.cn) | Rel-12 | RP-62 | Issam | CA | LTE_CA_B1_B3 |  |
| 2145 | 524.54.1 | Core part: LTE Advanced inter-band Carrier Aggregation of Band 1 and Band 3 | 201d? | 2013-12-09 A | 2014-09-12 A | 100% | 2013-12-09 | 2014-09-12 | 201d? | finish no earlier than 2014-09-12 | R4 | 1608h | 1608h | LTE_CA_B1_B3-Core | PCG-32 | 36.101, 36.104, 36.133, new generic TR 36.851 | China Unicom | Hao Chen (chenhao49@chinaunicom.cn) | Rel-12 | RP-62 | Issam | CA | LTE_CA_B1_B3-Core | RP-141084 |
| 2146 | 524.54.2 | Perf. part: LTE Advanced inter-band Carrier Aggregation of Band 1 and Band 3 | 201d? | 2013-12-09 A | 2014-09-12 A | 100% | 2013-12-09 | 2014-09-12 | 201d? | finish no earlier than 2014-09-12 | R4 | 1608h | 1608h | LTE_CA_B1_B3-Perf | PCG-32 | 36.141, 36.307 | China Unicom | Hao Chen (chenhao49@chinaunicom.cn) | Rel-12 | RP-62 | Issam | CA | LTE_CA_B1_B3-Perf | RP-141084 |

Notes:
- 2123: Inter-band 1UL/2DL
- 2124: RP#62 completed
- 2125: RP#62 completed
- 2126: Inter-band 1UL/2DL
- 2127: RP#62 completed
- 2128: RP#62 completed
- 2129: Inter-band CA 2DL
- 2130: RP#64 completed
- 2131: RP#64 completed
- 2132: Inter-band CA 2DL
- 2133: RP#65 completed
- 2134: RP#65 completed
- 2135: Inter-band 1UL/2DL
- 2136: RP#62 completed
- 2137: RP#62 completed
- 2138: Intra-band contig. CA 3DL
- 2139: RP#65 completed
- 2140: ; WID: RP-142043->RP-142017; Stat Rep: RP-141084->RP-141732 1st Apr 15: Compl:70%->100% 1st Apr 15: Stat Rep: RP-141732->RP-150013
- 2141: Intra-band non-contig. CA 2DL
- 2142: RP#64 completed. TR 36.833-2-02v100 for 1-step Approval
- 2143: RP#64 completed
- 2144: Inter-band CA 2DL
- 2145: RP#65 completed
- 2146: RP#65 completed

| ID | WBS | Task | Duration | Start | Finish | Complete | Baseline start | Baseline finish | Baseline duration | Constraint | Resources | Work | Actual work | Acronym | PCG approved | WI rapporteur name | WI rapporteur e-mail | Release | TSG approved | MCC resp | Special Focus Doc | Acronym_3GU_Export | Status Report |
| --- | --- | --- | --- | --- | --- | --- | --- | --- | --- | --- | --- | --- | --- | --- | --- | --- | --- | --- | --- | --- | --- | --- | --- |
| 2147 | 524.55 | **LTE Advanced inter-band Carrier Aggregation of Band 1 and Band 28** | 270d? | 2013-12-09 A | 2014-12-15 A | 100% | 2013-12-09 | 2014-09-12 | 201d? |  | R4 | 6432h | 6432h | LTE_CA_B1_B28 | PCG-32 | KDDI | Masaaki Obara (ms-obara@kddi.com) | Rel-12 | RP-62 | Issam | CA | LTE_CA_B1_B28 |  |
| 2148 | 524.55.1 | Core part: LTE Advanced inter-band Carrier Aggregation of Band 1 and Band 28 | 267d? | 2013-12-09 A | 2014-12-15 A | 100% | 2013-12-09 | 2014-09-12 | 201d? | finish no earlier than 2014-12-15 | R4 | 2136h | 2136h | LTE_CA_B1_B28-Core | PCG-32 | KDDI | Masaaki Obara (ms-obara@kddi.com) | Rel-12 | RP-62 | Issam | CA | LTE_CA_B1_B28-Core | RP-141732 |
| 2149 | 524.55.2 | Perf. part: LTE Advanced inter-band Carrier Aggregation of Band 1 and Band 28 | 267d? | 2013-12-12 A | 2014-12-15 A | 100% | 2013-12-09 | 2014-09-12 | 201d? | finish no earlier than 2014-12-15 | R4 | 2136h | 2136h | LTE_CA_B1_B28-Perf | PCG-32 | KDDI | Masaaki Obara (ms-obara@kddi.com) | Rel-12 | RP-62 | Issam | CA | LTE_CA_B1_B28-Perf | RP-141732 |
| 2150 | 524.56 | **LTE Advanced inter-band Carrier Aggregation of Band 2 and Band 4 - Additional bandwidth combination set** | 65d? | 2013-12-09 A | 2014-03-06 A | 100% | 2013-12-09 | 2014-03-06 | 65d? |  | R4 | 1560h | 1560h | LTE_CA_B2_B4_BWset | PCG-32 | T-Mobile USA | nelson.ueng@t-mobile.com | Rel-12 | RP-62 | Issam | CA | LTE_CA_B2_B4_BWset |  |
| 2151 | 524.56.1 | Core part: LTE Advanced inter-band Carrier Aggregation of Band 2 and Band 4 - Additional bandwidth combination set | 65d? | 2013-12-09 A | 2014-03-06 A | 100% | 2013-12-09 | 2014-03-06 | 65d? | finish no earlier than 2014-03-06 | R4 | 520h | 520h | LTE_CA_B2_B4_BWset-Core | PCG-32 | T-Mobile USA | nelson.ueng@t-mobile.com | Rel-12 | RP-62 | Issam | CA | LTE_CA_B2_B4_BWset-Core | RP-140428 |
| 2152 | 524.56.2 | Perf. part: LTE Advanced inter-band Carrier Aggregation of Band 2 and Band 4 - Additional bandwidth combination set | 65d? | 2013-12-09 A | 2014-03-06 A | 100% | 2013-12-09 | 2014-03-06 | 65d? | finish no earlier than 2014-03-06 | R4 | 520h | 520h | LTE_CA_B2_B4_BWset-Perf | PCG-32 | T-Mobile USA | nelson.ueng@t-mobile.com | Rel-12 | RP-62 | Issam | CA | LTE_CA_B2_B4_BWset-Perf | RP-140428 |
| 2153 | 524.57 | **LTE Advanced inter-band Carrier Aggregation of Band 4 and Band 27** | 136d? | 2013-12-09 A | 2014-06-13 A | 100% | 2013-12-09 | 2014-06-13 | 136d? |  | R4 | 3264h | 3264h | LTE_CA_B4_B27 | PCG-32 | NII Holdings | bill.shvodian@nii.com | Rel-12 | RP-62 | Issam | CA | LTE_CA_B4_B27 |  |
| 2154 | 524.57.1 | Core part: LTE Advanced inter-band Carrier Aggregation of Band 4 and Band 27 | 136d? | 2013-12-09 A | 2014-06-13 A | 100% | 2013-12-09 | 2014-06-13 | 136d? | finish no earlier than 2014-06-13 | R4 | 1088h | 1088h | LTE_CA_B4_B27-Core | PCG-32 | NII Holdings | bill.shvodian@nii.com | Rel-12 | RP-62 | Issam | CA | LTE_CA_B4_B27-Core | RP-140569 |
| 2155 | 524.57.2 | Perf. part: LTE Advanced inter-band Carrier Aggregation of Band 4 and Band 27 | 136d? | 2013-12-09 A | 2014-06-13 A | 100% | 2013-12-09 | 2014-06-13 | 136d? | finish no earlier than 2014-06-13 | R4 | 1088h | 1088h | LTE_CA_B4_B27-Perf | PCG-32 | NII Holdings | bill.shvodian@nii.com | Rel-12 | RP-62 | Issam | CA | LTE_CA_B4_B27-Perf | RP-140569 |
| 2156 | 524.58 | **LTE Advanced inter-band Carrier Aggregation of Band 3 and Band 27** | 65d? | 2013-12-09 A | 2014-03-06 A | 100% | 2013-12-09 | 2014-03-06 | 65d? |  | R4 | 1560h | 1560h | LTE_CA_B3_B27 | PCG-32 | KT | Chungwoo HWANG (cwhwang@kt.com) | Rel-12 | RP-62 | Issam | CA | LTE_CA_B3_B27 | RP-140428 |
| 2157 | 524.58.1 | Core part: LTE Advanced inter-band Carrier Aggregation of Band 3 and Band 27 | 65d? | 2013-12-09 A | 2014-03-06 A | 100% | 2013-12-09 | 2014-03-06 | 65d? | finish no earlier than 2014-03-06 | R4 | 520h | 520h | LTE_CA_B3_B27-Core | PCG-32 | KT | Chungwoo HWANG (cwhwang@kt.com) | Rel-12 | RP-62 | Issam | CA | LTE_CA_B3_B27-Core | RP-140428 |
| 2158 | 524.58.2 | Perf. part: LTE Advanced inter-band Carrier Aggregation of Band 3 and Band 27 | 65d? | 2013-12-09 A | 2014-03-06 A | 100% | 2013-12-09 | 2014-03-06 | 65d? | finish no earlier than 2014-03-06 | R4 | 520h | 520h | LTE_CA_B3_B27-Perf | PCG-32 | KT | Chungwoo HWANG (cwhwang@kt.com) | Rel-12 | RP-62 | Issam | CA | LTE_CA_B3_B27-Perf | RP-140428 |
| 2159 | 524.59 | **LTE Advanced inter-band Carrier Aggregation in Band 8 and Band 20 - Additional channel bandwidth** | 65d? | 2013-12-09 A | 2014-03-06 A | 100% | 2013-12-09 | 2014-03-06 | 65d? |  | R4 | 1560h | 1560h | LTE_CA_B8_B20_BW | PCG-32 | Vodafone | luis.anaya@vodafone.com | Rel-12 | RP-62 | Issam | CA | LTE_CA_B8_B20_BW | RP-140428 |
| 2160 | 524.59.1 | Core part: LTE Advanced inter-band Carrier Aggregation in Band 8 and Band 20 - Additional channel bandwidth | 65d? | 2013-12-09 A | 2014-03-06 A | 100% | 2013-12-09 | 2014-03-06 | 65d? | finish no earlier than 2014-03-06 | R4 | 520h | 520h | LTE_CA_B8_B20_BW-Core | PCG-32 | Vodafone | luis.anaya@vodafone.com | Rel-12 | RP-62 | Issam | CA | LTE_CA_B8_B20_BW-Core | RP-140428 |
| 2161 | 524.59.2 | Perf. part: LTE Advanced inter-band Carrier Aggregation in Band 8 and Band 20 - Additional channel bandwidth | 65d? | 2013-12-09 A | 2014-03-06 A | 100% | 2013-12-09 | 2014-03-06 | 65d? | finish no earlier than 2014-03-06 | R4 | 520h | 520h | LTE_CA_B8_B20_BW-Perf | PCG-32 | Vodafone | luis.anaya@vodafone.com | Rel-12 | RP-62 | Issam | CA | LTE_CA_B8_B20_BW-Perf | RP-140428 |
| 2162 | 524.60 | **LTE Advanced 3 Band Carrier Aggregation (3DL/1UL) for Band 1, Band 3 and Band 8** | 202d? | 2013-12-09 A | 2014-09-12 A | 100% | 2013-12-09 | 2014-09-12 | 201d? |  | R4 | 4832h | 4832h | LTE_CA_B1_B3_B8 | PCG-32 | KT | Ilwhan Kim (ilwhan.kim@kt.com) | Rel-12 | RP-62 | Issam | CA | LTE_CA_B1_B3_B8 |  |
| 2163 | 524.60.1 | Core part: LTE Advanced 3 Band Carrier Aggregation (3DL/1UL) for Band 1, Band 3 and Band 8 | 201d? | 2013-12-09 A | 2014-09-12 A | 100% | 2013-12-09 | 2014-09-12 | 201d? | finish no earlier than 2014-09-12 | R4 | 1608h | 1608h | LTE_CA_B1_B3_B8-Core | PCG-32 | KT | Ilwhan Kim (ilwhan.kim@kt.com) | Rel-12 | RP-62 | Issam | CA | LTE_CA_B1_B3_B8-Core | RP-141084 |
| 2164 | 524.60.2 | Perf. part: LTE Advanced 3 Band Carrier Aggregation (3DL/1UL) for Band 1, Band 3 and Band 8 | 201d? | 2013-12-09 A | 2014-09-12 A | 100% | 2013-12-09 | 2014-09-12 | 201d? | finish no earlier than 2014-09-12 | R4 | 1608h | 1608h | LTE_CA_B1_B3_B8-Perf | PCG-32 | KT | Ilwhan Kim (ilwhan.kim@kt.com) | Rel-12 | RP-62 | Issam | CA | LTE_CA_B1_B3_B8-Perf | RP-141084 |
| 2165 | 524.61 | **LTE Advanced 3 Band Carrier Aggregation (3DL/1UL) for Band 1, Band 5 and Band 7** | 202d? | 2013-12-09 A | 2014-09-12 A | 100% | 2013-12-09 | 2014-09-12 | 201d? |  | R4 | 4832h | 4832h | LTE_CA_B1_B5_B7 | PCG-32 | LG Uplus | Yeonsang KOO (yskoo@lguplus.co.kr) | Rel-12 | RP-62 | Issam | CA | LTE_CA_B1_B5_B7 |  |
| 2166 | 524.61.1 | Core part: LTE Advanced 3 Band Carrier Aggregation (3DL/1UL) for Band 1, Band 5 and Band 7 | 201d? | 2013-12-09 A | 2014-09-12 A | 100% | 2013-12-09 | 2014-09-12 | 201d? | finish no earlier than 2014-09-12 | R4 | 1608h | 1608h | LTE_CA_B1_B5_B7-Core | PCG-32 | LG Uplus | Yeonsang KOO (yskoo@lguplus.co.kr) | Rel-12 | RP-62 | Issam | CA | LTE_CA_B1_B5_B7-Core | RP-141084 |
| 2167 | 524.61.2 | Perf. part: LTE Advanced 3 Band Carrier Aggregation (3DL/1UL) for Band 1, Band 5 and Band 7 | 201d? | 2013-12-09 A | 2014-09-12 A | 100% | 2013-12-09 | 2014-09-12 | 201d? | finish no earlier than 2014-09-12 | R4 | 1608h | 1608h | LTE_CA_B1_B5_B7-Perf | PCG-32 | LG Uplus | Yeonsang KOO (yskoo@lguplus.co.kr) | Rel-12 | RP-62 | Issam | CA | LTE_CA_B1_B5_B7-Perf | RP-141084 |
| 2168 | 524.62 | **LTE Advanced 3 Band Carrier Aggregation (3DL/1UL) for Band 2, Band 4 and Band 5** | 202d? | 2013-12-09 A | 2014-09-12 A | 100% | 2013-12-09 | 2014-09-12 | 201d? |  | R4 | 4832h | 4832h | LTE_CA_B2_B4_B5 | PCG-32 | U.S. Cellular | sebastian.thalanany@uscellular.com | Rel-12 | RP-62 | Issam | CA | LTE_CA_B2_B4_B5 |  |
| 2169 | 524.62.1 | Core part: LTE Advanced 3 Band Carrier Aggregation (3DL/1UL) for Band 2, Band 4 and Band 5 | 201d? | 2013-12-09 A | 2014-09-12 A | 100% | 2013-12-09 | 2014-09-12 | 201d? | finish no earlier than 2014-09-12 | R4 | 1608h | 1608h | LTE_CA_B2_B4_B5-Core | PCG-32 | U.S. Cellular | sebastian.thalanany@uscellular.com | Rel-12 | RP-62 | Issam | CA | LTE_CA_B2_B4_B5-Core | RP-141084 |
| 2170 | 524.62.2 | Perf. part: LTE Advanced 3 Band Carrier Aggregation (3DL/1UL) for Band 2, Band 4 and Band 5 | 201d? | 2013-12-09 A | 2014-09-12 A | 100% | 2013-12-09 | 2014-09-12 | 201d? | finish no earlier than 2014-09-12 | R4 | 1608h | 1608h | LTE_CA_B2_B4_B5-Perf | PCG-32 | U.S. Cellular | sebastian.thalanany@uscellular.com | Rel-12 | RP-62 | Issam | CA | LTE_CA_B2_B4_B5-Perf | RP-141084 |

Notes:
- 2147: Inter-band CA 2DL / Impacted TSs and TRs: LTE
- 2148: ; WID: RP-142043->RP-141803; Stat Rep: RP-141084->RP-141732 / Impacted TSs and TRs: 36.101, 36.104, 36.133, 36.307, new generic TR 36.851
- 2149: ; WID: RP-142043->RP-141803; Stat Rep: RP-141084->RP-141732 / Impacted TSs and TRs: 36.133, 36.141
- 2150: Inter-band 2DL / Impacted TSs and TRs: LTE
- 2151: RP#63 completed / Impacted TSs and TRs: 36.101, new generic TR 36.851
- 2152: RP#63 completed / Impacted TSs and TRs: 36.307
- 2153: Inter-band CA 2DL / Impacted TSs and TRs: LTE
- 2154: RP#64 completed / Impacted TSs and TRs: 36.101, 36.104, 36.133, new generic TR 36.851
- 2155: RP#64 completed / Impacted TSs and TRs: 36.141, 36.307
- 2156: Inter-band CA 2DL/1UL / Impacted TSs and TRs: LTE
- 2157: RP#63 completed. Updated WID RP-131752=>RP-140119 / Impacted TSs and TRs: 36.101, 36.104, 36.133, 36.307, New generic TR 36.851
- 2158: RP#63 completed. Updated WID RP-131752=>RP-140119 / Impacted TSs and TRs: 36.101, 36.104, 36.133, 36.141
- 2159: Inter-band 2DL / Impacted TSs and TRs: LTE
- 2160: RP#63 completed / Impacted TSs and TRs: 36.101, 36.104, 36.307
- 2161: RP#63 completed / Impacted TSs and TRs: 36.141
- 2162: Inter-band CA 3DL / Impacted TSs and TRs: LTE
- 2163: RP#65 completed. Updated WID RP-131753=>RP-141654 / Impacted TSs and TRs: 36.101, 36.104, 36.133, 36.141, 36.307, new generic TR 36.853 (3 Band CA with 1UL)
- 2164: RP#65 completed / Impacted TSs and TRs: 36.101, 36.104, 36.133, 36.141, 36.307
- 2165: Inter-band CA 3DL / Impacted TSs and TRs: LTE
- 2166: RP#65 completed. Updated WID RP-140209=>RP-141462 / Impacted TSs and TRs: 36.101, 36.104, 36.133, new generic TR 36.853 (3 Band CA with 1UL)
- 2167: RP#65 completed / Impacted TSs and TRs: 36.141, 36.307
- 2168: Inter-band CA 3DL / Impacted TSs and TRs: LTE
- 2169: RP#65 completed / Impacted TSs and TRs: 36.101, 36.104, 36.133, new generic TR 36.853 (3 Band CA with 1UL)
- 2170: RP#65 completed / Impacted TSs and TRs: 36.141, 36.307

| ID | WBS | Task | Duration | Start | Finish | Complete | Remaining | Baseline start | Baseline finish | Baseline duration | Total slack | Constraint | Resources | Work | Actual work | Acronym | PCG approved | WI rapporteur name | WI rapporteur e-mail | Release | TSG approved | MCC resp | Special Focus Doc | Acronym_3GU_Export | Status Report |
| --- | --- | --- | --- | --- | --- | --- | --- | --- | --- | --- | --- | --- | --- | --- | --- | --- | --- | --- | --- | --- | --- | --- | --- | --- | --- |
| 2171 | 524.63 | **LTE Advanced 3 Band Carrier Aggregation (3DL/1UL) for Band 2, Band 4 and Band 12** | 268d? | 2013-12-09 A | 2014-12-11 | 99% | 3.04d? | 2013-12-09 | 2014-09-12 | 201d? | 1051d |  | R4 | 5872h | 5204.78h | LTE_CA_B2_B4_B12 | PCG-32 | U.S. Cellular | sebastian.thalanany@uscellular.com | Rel-12 | RP-62 | Issam | CA | LTE_CA_B2_B4_B12 |  |
| 2172 | 524.63.1 | Core part: LTE Advanced 3 Band Carrier Aggregation (3DL/1UL) for Band 2, Band 4 and Band 12 | 201d? | 2013-12-09 A | 2014-09-12 A | 100% |  | 2013-12-09 | 2014-09-12 | 201d? |  | finish no earlier than 2014-09-12 | R4 | 1608h | 1608h | LTE_CA_B2_B4_B12-Core | PCG-32 | U.S. Cellular | sebastian.thalanany@uscellular.com | Rel-12 | RP-62 | Issam | CA | LTE_CA_B2_B4_B12-Core | RP-141084 |
| 2173 | 524.63.2 | Perf. part: LTE Advanced 3 Band Carrier Aggregation (3DL/1UL) for Band 2, Band 4 and Band 12 | 265d? | 2013-12-09 A | 2014-12-11 | 98% | 5.3d? | 2013-12-09 | 2014-09-12 | 201d? | 1051d | finish no earlier than 2014-12-11 | R4 | 2120h | 2077.6h | LTE_CA_B2_B4_B12-Perf | PCG-32 | U.S. Cellular | sebastian.thalanany@uscellular.com | Rel-12 | RP-62 | Issam | CA | LTE_CA_B2_B4_B12-Perf | RP-141084 |
| 2174 | 524.64 | **LTE Advanced 3 Band Carrier Aggregation (3DL/1UL) for Band 2, Band 5 and Band 12** | 202d? | 2013-12-09 A | 2014-09-12 A | 100% |  | 2013-12-09 | 2014-09-12 | 201d? |  |  | R4 | 4832h | 4832h | LTE_CA_B2_B5_B12 | PCG-32 | U.S. Cellular | sebastian.thalanany@uscellular.com | Rel-12 | RP-62 | Issam | CA | LTE_CA_B2_B5_B12 |  |
| 2175 | 524.64.1 | Core part: LTE Advanced 3 Band Carrier Aggregation (3DL/1UL) for Band 2, Band 5 and Band 12 | 201d? | 2013-12-09 A | 2014-09-12 A | 100% |  | 2013-12-09 | 2014-09-12 | 201d? |  | finish no earlier than 2014-09-12 | R4 | 1608h | 1608h | LTE_CA_B2_B5_B12-Core | PCG-32 | U.S. Cellular | sebastian.thalanany@uscellular.com | Rel-12 | RP-62 | Issam | CA | LTE_CA_B2_B5_B12-Core | RP-141084 |
| 2176 | 524.64.2 | Perf. part: LTE Advanced 3 Band Carrier Aggregation (3DL/1UL) for Band 2, Band 5 and Band 12 | 201d? | 2013-12-10 A | 2014-09-12 A | 100% |  | 2013-12-09 | 2014-09-12 | 201d? |  | finish no earlier than 2014-09-12 | R4 | 1608h | 1608h | LTE_CA_B2_B5_B12-Perf | PCG-32 | U.S. Cellular | sebastian.thalanany@uscellular.com | Rel-12 | RP-62 | Issam | CA | LTE_CA_B2_B5_B12-Perf | RP-141084 |
| 2177 | 524.65 | **LTE Advanced 3 Band Carrier Aggregation (3DL/1UL) for Band 2, Band 12 and Band 12** | 202d? | 2013-12-09 A | 2014-09-12 A | 100% |  | 2013-12-09 | 2014-09-12 | 201d? |  |  | R4 | 4832h | 4832h | LTE_CA_B2_B12_B12 | PCG-32 | AT&T | marc.grant@att.com | Rel-12 | RP-62 | Issam | CA | LTE_CA_B2_B12_B12 |  |
| 2178 | 524.65.1 | Core part: LTE Advanced 3 Band Carrier Aggregation (3DL/1UL) for Band 2, Band 12 and Band 12 | 201d? | 2013-12-09 A | 2014-09-12 A | 100% |  | 2013-12-09 | 2014-09-12 | 201d? |  | finish no earlier than 2014-09-12 | R4 | 1608h | 1608h | LTE_CA_B2_B12_B12-Core | PCG-32 | AT&T | marc.grant@att.com | Rel-12 | RP-62 | Issam | CA | LTE_CA_B2_B12_B12-Core | RP-141084 |
| 2179 | 524.65.2 | Perf. part: LTE Advanced 3 Band Carrier Aggregation (3DL/1UL) for Band 2, Band 12 and Band 12 | 201d? | 2013-12-09 A | 2014-09-12 A | 100% |  | 2013-12-09 | 2014-09-12 | 201d? |  | finish no earlier than 2014-09-12 | R4 | 1608h | 1608h | LTE_CA_B2_B12_B12-Perf | PCG-32 | AT&T | marc.grant@att.com | Rel-12 | RP-62 | Issam | CA | LTE_CA_B2_B12_B12-Perf | RP-141084 |
| 2180 | 524.66 | **LTE Advanced 3 Band Carrier Aggregation (3DL/1UL) for Band 2, Band 12 and Band 30** | 202d? | 2013-12-09 A | 2014-09-12 A | 100% |  | 2013-12-09 | 2014-09-12 | 201d? |  |  | R4 | 4832h | 4832h | LTE_CA_B2_B12_B30 | PCG-32 | AT&T | marc.grant@att.com | Rel-12 | RP-62 | Issam | CA | LTE_CA_B2_B12_B30 |  |
| 2181 | 524.66.1 | Core part: LTE Advanced 3 Band Carrier Aggregation (3DL/1UL) for Band 2, Band 12 and Band 30 | 201d? | 2013-12-09 A | 2014-09-12 A | 100% |  | 2013-12-09 | 2014-09-12 | 201d? |  | finish no earlier than 2014-09-12 | R4 | 1608h | 1608h | LTE_CA_B2_B12_B30-Core | PCG-32 | AT&T | marc.grant@att.com | Rel-12 | RP-62 | Issam | CA | LTE_CA_B2_B12_B30-Core | RP-141084 |
| 2182 | 524.66.2 | Perf. part: LTE Advanced 3 Band Carrier Aggregation (3DL/1UL) for Band 2, Band 12 and Band 30 | 201d? | 2013-12-09 A | 2014-09-12 A | 100% |  | 2013-12-09 | 2014-09-12 | 201d? |  | finish no earlier than 2014-09-12 | R4 | 1608h | 1608h | LTE_CA_B2_B12_B30-Perf | PCG-32 | AT&T | marc.grant@att.com | Rel-12 | RP-62 | Issam | CA | LTE_CA_B2_B12_B30-Perf | RP-141084 |
| 2183 | 524.67 | **LTE Advanced 3 Band Carrier Aggregation (3DL/1UL) for Band 3, Band 7 and Band 20** | 202d? | 2013-12-09 A | 2014-09-12 A | 100% |  | 2013-12-09 | 2014-09-12 | 201d? |  |  | R4 | 4832h | 4832h | LTE_CA_B3_B7_B20 | PCG-32 | Vodafone | luis.anaya@vodafone.com | Rel-12 | RP-62 | Issam | CA | LTE_CA_B3_B7_B20 |  |
| 2184 | 524.67.1 | Core part: LTE Advanced 3 Band Carrier Aggregation (3DL/1UL) for Band 3, Band 7 and Band 20 | 201d? | 2013-12-09 A | 2014-09-12 A | 100% |  | 2013-12-09 | 2014-09-12 | 201d? |  | finish no earlier than 2014-09-12 | R4 | 1608h | 1608h | LTE_CA_B3_B7_B20-Core | PCG-32 | Vodafone | luis.anaya@vodafone.com | Rel-12 | RP-62 | Issam | CA | LTE_CA_B3_B7_B20-Core | RP-141084 |
| 2185 | 524.67.2 | Perf. part: LTE Advanced 3 Band Carrier Aggregation (3DL/1UL) for Band 3, Band 7 and Band 20 | 201d? | 2013-12-10 A | 2014-09-12 A | 100% |  | 2013-12-09 | 2014-09-12 | 201d? |  | finish no earlier than 2014-09-12 | R4 | 1608h | 1608h | LTE_CA_B3_B7_B20-Perf | PCG-32 | Vodafone | luis.anaya@vodafone.com | Rel-12 | RP-62 | Issam | CA | LTE_CA_B3_B7_B20-Perf | RP-141084 |
| 2186 | 524.68 | **LTE Advanced 3 Band Carrier Aggregation (3DL/1UL) for Band 4, Band 5 and Band 12** | 202d? | 2013-12-09 A | 2014-09-12 A | 100% |  | 2013-12-09 | 2014-09-12 | 201d? |  |  | R4 | 4832h | 4832h | LTE_CA_B4_B5_B12 | PCG-32 | U.S. Cellular | sebastian.thalanany@uscellular.com | Rel-12 | RP-62 | Issam | CA | LTE_CA_B4_B5_B12 |  |
| 2187 | 524.68.1 | Core part: LTE Advanced 3 Band Carrier Aggregation (3DL/1UL) for Band 4, Band 5 and Band 12 | 201d? | 2013-12-09 A | 2014-09-12 A | 100% |  | 2013-12-09 | 2014-09-12 | 201d? |  | finish no earlier than 2014-09-12 | R4 | 1608h | 1608h | LTE_CA_B4_B5_B12-Core | PCG-32 | U.S. Cellular | sebastian.thalanany@uscellular.com | Rel-12 | RP-62 | Issam | CA | LTE_CA_B4_B5_B12-Core | RP-141084 |
| 2188 | 524.68.2 | Perf. part: LTE Advanced 3 Band Carrier Aggregation (3DL/1UL) for Band 4, Band 5 and Band 12 | 201d? | 2013-12-09 A | 2014-09-12 A | 100% |  | 2013-12-09 | 2014-09-12 | 201d? |  | finish no earlier than 2014-09-12 | R4 | 1608h | 1608h | LTE_CA_B4_B5_B12-Perf | PCG-32 | U.S. Cellular | sebastian.thalanany@uscellular.com | Rel-12 | RP-62 | Issam | CA | LTE_CA_B4_B5_B12-Perf | RP-141084 |
| 2189 | 524.69 | **LTE Advanced 3 Band Carrier Aggregation (3DL/1UL) for Band 4, Band 12 and Band 12** | 202d? | 2013-12-09 A | 2014-09-12 A | 100% |  | 2013-12-09 | 2014-09-12 | 201d? |  |  | R4 | 4832h | 4832h | LTE_CA_B4_B12_B12 | PCG-32 | AT&T | marc.grant@att.com | Rel-12 | RP-62 | Issam | CA | LTE_CA_B4_B12_B12 |  |
| 2190 | 524.69.1 | Core part: LTE Advanced 3 Band Carrier Aggregation (3DL/1UL) for Band 4, Band 12 and Band 12 | 201d? | 2013-12-09 A | 2014-09-12 A | 100% |  | 2013-12-09 | 2014-09-12 | 201d? |  | finish no earlier than 2014-09-12 | R4 | 1608h | 1608h | LTE_CA_B4_B12_B12-Core | PCG-32 | AT&T | marc.grant@att.com | Rel-12 | RP-62 | Issam | CA | LTE_CA_B4_B12_B12-Core | RP-141084 |
| 2191 | 524.69.2 | Perf. part: LTE Advanced 3 Band Carrier Aggregation (3DL/1UL) for Band 4, Band 12 and Band 12 | 201d? | 2013-12-09 A | 2014-09-12 A | 100% |  | 2013-12-09 | 2014-09-12 | 201d? |  | finish no earlier than 2014-09-12 | R4 | 1608h | 1608h | LTE_CA_B4_B12_B12-Perf | PCG-32 | AT&T | marc.grant@att.com | Rel-12 | RP-62 | Issam | CA | LTE_CA_B4_B12_B12-Perf | RP-141084 |
| 2192 | 524.70 | **LTE Advanced 3 Band Carrier Aggregation (3DL/1UL) for Band 4, Band 12 and Band 30** | 202d? | 2013-12-09 A | 2014-09-12 A | 100% |  | 2013-12-09 | 2014-09-12 | 201d? |  |  | R4 | 4832h | 4832h | LTE_CA_B4_B12_B30 | PCG-32 | AT&T | marc.grant@att.com | Rel-12 | RP-62 | Issam | CA | LTE_CA_B4_B12_B30 |  |
| 2193 | 524.70.1 | Core part: LTE Advanced 3 Band Carrier Aggregation (3DL/1UL) for Band 4, Band 12 and Band 30 | 201d? | 2013-12-09 A | 2014-09-12 A | 100% |  | 2013-12-09 | 2014-09-12 | 201d? |  | finish no earlier than 2014-09-12 | R4 | 1608h | 1608h | LTE_CA_B4_B12_B30-Core | PCG-32 | AT&T | marc.grant@att.com | Rel-12 | RP-62 | Issam | CA | LTE_CA_B4_B12_B30-Core | RP-141084 |
| 2194 | 524.70.2 | Perf. part: LTE Advanced 3 Band Carrier Aggregation (3DL/1UL) for Band 4, Band 12 and Band 30 | 201d? | 2013-12-09 A | 2014-09-12 A | 100% |  | 2013-12-09 | 2014-09-12 | 201d? |  | finish no earlier than 2014-09-12 | R4 | 1608h | 1608h | LTE_CA_B4_B12_B30-Perf | PCG-32 | AT&T | marc.grant@att.com | Rel-12 | RP-62 | Issam | CA | LTE_CA_B4_B12_B30-Perf | RP-141084 |

Notes:
- 2171: Inter-band CA 3DL / Impacted TSs and TRs: LTE
- 2172: RP#65 completed / Impacted TSs and TRs: 36.101, 36.104, 36.133, new generic TR 36.853 (3 Band CA with 1UL)
- 2173: RP#65 completion 09/14=>12/14 / Impacted TSs and TRs: 36.141, 36.307
- 2174: Inter-band CA 3DL / Impacted TSs and TRs: LTE
- 2175: RP#65 completed / Impacted TSs and TRs: 36.101, 36.104, 36.133, new generic TR 36.853 (3 Band CA with 1UL)
- 2176: RP#65 completed / Impacted TSs and TRs: 36.141, 36.307
- 2177: Inter-band CA 3DL / Impacted TSs and TRs: LTE
- 2178: RP#65 completed / Impacted TSs and TRs: 36.101, 36.104, 36.133, 36.141, 36.307, new generic TR 36.853
- 2179: RP#65 completed / Impacted TSs and TRs: 36.101, 36.104, 36.133, 36.141, 36.307
- 2180: Inter-band CA 3DL / Impacted TSs and TRs: LTE
- 2181: RP#65 completed. Updated WID RP-131652=>RP-141211. / Impacted TSs and TRs: 36.101, 36.104, 36.133, 36.141, 36.307, new generic TR 36.853 (3 Band CA with 1UL)
- 2182: RP#65 completed / Impacted TSs and TRs: 36.101, 36.104, 36.133, 36.141, 36.307
- 2183: Inter-band CA 3DL / Impacted TSs and TRs: LTE
- 2184: RP#65 completed. Updated WID RP-140244=>RP-141224 / Impacted TSs and TRs: 36.101, 36.104, 36.133, new generic TR 36.853 (3 Band CA with 1UL)
- 2185: RP#65 completed / Impacted TSs and TRs: 36.101, 36.133, 36.141, 36.307
- 2186: Inter-band CA 3DL / Impacted TSs and TRs: LTE
- 2187: RP#65 completed / Impacted TSs and TRs: 36.101, 36.104, 36.133, new generic TR 36.853 (3 Band CA with 1UL)
- 2188: RP#65 completed / Impacted TSs and TRs: 36.141, 36.307
- 2189: Inter-band CA 3DL / Impacted TSs and TRs: LTE
- 2190: RP#65 completed / Impacted TSs and TRs: 36.101, 36.104, 36.133, 36.141, 36.307, new generic TR 36.853 (3 Band CA with 1UL)
- 2191: RP#65 completed / Impacted TSs and TRs: 36.101, 36.104, 36.133, 36.141, 36.307
- 2192: Inter-band CA 3DL / Impacted TSs and TRs: LTE
- 2193: RP#65 completed. Updated WID RP-131653=>RP-141214 / Impacted TSs and TRs: 36.101, 36.104, 36.133, 36.141, 36.307, new generic TR 36.853 (3 Band CA with 1UL)
- 2194: RP#65 completed / Impacted TSs and TRs: 36.101, 36.104, 36.133, 36.141, 36.307

| ID | WBS | Task | Duration | Start | Finish | Complete | Baseline start | Baseline finish | Baseline duration | Constraint | Resources | Work | Actual work | Acronym | PCG approved | WI rapporteur name | WI rapporteur e-mail | Release | TSG approved | MCC resp | Special Focus Doc | Acronym_3GU_Export | Status Report |
| --- | --- | --- | --- | --- | --- | --- | --- | --- | --- | --- | --- | --- | --- | --- | --- | --- | --- | --- | --- | --- | --- | --- | --- |
| 2195 | 524.71 | **LTE Advanced intra-band contiguous Carrier Aggregation in Band 42** | 136d? | 2013-12-09 A | 2014-06-13 A | 100% | 2013-12-09 | 2014-06-13 | 136d? |  | R4 | 3264h | 3264h | LTE_CA_C_B42 | PCG-32 | CATT | Yuexia Song (songyuexia@catt.cn) | Rel-12 | RP-62 | Issam | CA | LTE_CA_C_B42 |  |
| 2196 | 524.71.1 | Core part: LTE Advanced intra-band contiguous Carrier Aggregation in Band 42 | 136d? | 2013-12-09 A | 2014-06-13 A | 100% | 2013-12-09 | 2014-06-13 | 136d? | finish no earlier than 2014-06-13 | R4 | 1088h | 1088h | LTE_CA_C_B42-Core | PCG-32 | CATT | Yuexia Song (songyuexia@catt.cn) | Rel-12 | RP-62 | Issam | CA | LTE_CA_C_B42-Core | RP-140569 |
| 2197 | 524.71.2 | Perf. part: LTE Advanced intra-band contiguous Carrier Aggregation in Band 42 | 136d? | 2013-12-09 A | 2014-06-13 A | 100% | 2013-12-09 | 2014-06-13 | 136d? | finish no earlier than 2014-06-13 | R4 | 1088h | 1088h | LTE_CA_C_B42-Perf | PCG-32 | CATT | Yuexia Song (songyuexia@catt.cn) | Rel-12 | RP-62 | Issam | CA | LTE_CA_C_B42-Perf | RP-140569 |
| 2198 | 524.72 | **LTE Advanced intra-band contiguous Carrier Aggregation in Band 7 - Additional bandwidth combinations** | 136d? | 2013-12-09 A | 2014-06-13 A | 100% | 2013-12-09 | 2014-06-13 | 136d? |  | R4 | 3264h | 3264h | LTE_CA_C_B7_BW | PCG-32 | Orange | Olfa BEN HADDADA | Rel-12 | RP-62 | Issam | CA | LTE_CA_C_B7_BW |  |
| 2199 | 524.72.1 | Core part: LTE Advanced intra-band contiguous Carrier Aggregation in Band 7 - Additional bandwidth combinations | 136d? | 2013-12-09 A | 2014-06-13 A | 100% | 2013-12-09 | 2014-06-13 | 136d? | finish no earlier than 2014-06-13 | R4 | 1088h | 1088h | LTE_CA_C_B7_BW-Core | PCG-32 | Orange | Olfa BEN HADDADA | Rel-12 | RP-62 | Issam | CA | LTE_CA_C_B7_BW-Core | RP-140569 |
| 2200 | 524.72.2 | Perf. part: LTE Advanced intra-band contiguous Carrier Aggregation in Band 7 - Additional bandwidth combinations | 136d? | 2013-12-09 A | 2014-06-13 A | 100% | 2013-12-09 | 2014-06-13 | 136d? | finish no earlier than 2014-06-13 | R4 | 1088h | 1088h | LTE_CA_C_B7_BW-Perf | PCG-32 | Orange | Olfa BEN HADDADA | Rel-12 | RP-62 | Issam | CA | LTE_CA_C_B7_BW-Perf | RP-140569 |
| 2201 | 524.73 | **LTE Advanced intra-band non-contiguous Carrier Aggregation in Band 41 for 3 DL** | 334d? | 2013-12-09 A | 2015-03-15 A | 100% | 2013-12-09 | 2014-09-12 | 200d? |  | R4 | 6920h | 6920h | LTE_CA_NC_B41_3DL | PCG-32 | Sprint, Alcatel-Lucent | man-hung.ng@alcatel-lucent.com | Rel-12 | RP-62 | Issam | CA | LTE_CA_NC_B41_3DL |  |
| 2202 | 524.73.1 | Core part: LTE Advanced intra-band non-contiguous Carrier Aggregation in Band 41 for 3 DL | 200d? | 2013-12-09 A | 2014-09-11 A | 100% | 2013-12-09 | 2014-09-12 | 200d? | finish no earlier than 2014-09-12 | R4 | 1600h | 1600h | LTE_CA_NC_B41_3DL-Core | PCG-32 | Sprint, Alcatel-Lucent | man-hung.ng@alcatel-lucent.com | Rel-12 | RP-62 | Issam | CA | LTE_CA_NC_B41_3DL-Core | RP-141084 |
| 2203 | 524.73.2 | Perf. part: LTE Advanced intra-band non-contiguous Carrier Aggregation in Band 41 for 3 DL | 331d? | 2013-12-09 A | 2015-03-15 A | 100% | 2013-12-09 | 2014-09-12 | 200d? | finish no earlier than 2015-03-15 | R4 | 2648h | 2648h | LTE_CA_NC_B41_3DL-Perf | PCG-32 | Sprint, Alcatel-Lucent | man-hung.ng@alcatel-lucent.com | Rel-12 | RP-62 | Issam | CA | LTE_CA_NC_B41_3DL-Perf | RP-150013 |
| 2204 | 524.74 | **LTE Advanced intra-band non-contiguous Carrier Aggregation in Band 42** | 136d? | 2013-12-09 A | 2014-06-13 A | 100% | 2013-12-09 | 2014-06-13 | 136d? |  | R4 | 3264h | 3264h | LTE_CA_NC_B42 | PCG-32 | Huawei | Liu Liehai (liuliehai@huawei.com) | Rel-12 | RP-62 | Issam | CA | LTE_CA_NC_B42 |  |
| 2205 | 524.74.1 | Core part: LTE Advanced intra-band non-contiguous Carrier Aggregation in Band 42 | 136d? | 2013-12-09 A | 2014-06-13 A | 100% | 2013-12-09 | 2014-06-13 | 136d? | finish no earlier than 2014-06-13 | R4 | 1088h | 1088h | LTE_CA_NC_B42-Core | PCG-32 | Huawei | Liu Liehai (liuliehai@huawei.com) | Rel-12 | RP-62 | Issam | CA | LTE_CA_NC_B42-Core | RP-140569 |
| 2206 | 524.74.2 | Perf. part: LTE Advanced intra-band non-contiguous Carrier Aggregation in Band 42 | 136d? | 2013-12-09 A | 2014-06-13 A | 100% | 2013-12-09 | 2014-06-13 | 136d? | finish no earlier than 2014-06-13 | R4 | 1088h | 1088h | LTE_CA_NC_B42-Perf | PCG-32 | Huawei | Liu Liehai (liuliehai@huawei.com) | Rel-12 | RP-62 | Issam | CA | LTE_CA_NC_B42-Perf | RP-140569 |
| 2207 | 524.75 | **LTE Advanced 3 Band Carrier Aggregation (3DL/1UL) for Band 1, Band 3 and Band 5** | 203d? | 2013-12-06 A | 2014-09-12 A | 100% | 2013-12-06 | 2014-09-12 | 202d? |  | R4 | 4856h | 4856h | LTE_CA_B1_B3_B5 | PCG-32 | SK Telecom | haesung.park@sk.com | Rel-12 | RP-62 | Issam | CA | LTE_CA_B1_B3_B5 |  |
| 2208 | 524.75.1 | Core part: LTE Advanced 3 Band Carrier Aggregation(3DL/1UL) for Band 1, Band 3 and Band 5 | 202d? | 2013-12-06 A | 2014-09-12 A | 100% | 2013-12-06 | 2014-09-12 | 202d? | finish no earlier than 2014-09-12 | R4 | 1616h | 1616h | LTE_CA_B1_B3_B5-Core | PCG-32 | SK Telecom | haesung.park@sk.com | Rel-12 | RP-62 | Issam | CA | LTE_CA_B1_B3_B5-Core | RP-141084 |
| 2209 | 524.75.2 | Perf. part: LTE Advanced 3 Band Carrier Aggregation(3DL/1UL) for Band 1, Band 3 and Band 5 | 202d? | 2013-12-06 A | 2014-09-12 A | 100% | 2013-12-06 | 2014-09-12 | 202d? | finish no earlier than 2014-09-12 | R4 | 1616h | 1616h | LTE_CA_B1_B3_B5-Perf | PCG-32 | SK Telecom | haesung.park@sk.com | Rel-12 | RP-62 | Issam | CA | LTE_CA_B1_B3_B5-Perf | RP-141084 |
| 2210 | 524.76 | **LTE Advanced 3 Band Carrier Aggregation (3DL/1UL) for Band 1, Band 3 and Band 20** | 202d? | 2013-12-09 A | 2014-09-12 A | 100% | 2013-12-09 | 2014-09-12 | 201d? |  | R4 | 4832h | 4832h | LTE_CA_B1_B3_B20 | PCG-32 | Vodafone | luis.anaya@vodafone.com | Rel-12 | RP-62 | Issam | CA | LTE_CA_B1_B3_B20 |  |
| 2211 | 524.76.1 | Core part: LTE Advanced 3 Band Carrier Aggregation (3DL/1UL) for Band 1, Band 3 and Band 20 | 201d? | 2013-12-09 A | 2014-09-12 A | 100% | 2013-12-09 | 2014-09-12 | 201d? | finish no earlier than 2014-09-12 | R4 | 1608h | 1608h | LTE_CA_B1_B3_B20-Core | PCG-32 | Vodafone | luis.anaya@vodafone.com | Rel-12 | RP-62 | Issam | CA | LTE_CA_B1_B3_B20-Core | RP-141084 |
| 2212 | 524.76.2 | Perf. part: LTE Advanced 3 Band Carrier Aggregation (3DL/1UL) for Band 1, Band 3 and Band 20 | 201d? | 2013-12-10 A | 2014-09-12 A | 100% | 2013-12-09 | 2014-09-12 | 201d? | finish no earlier than 2014-09-12 | R4 | 1608h | 1608h | LTE_CA_B1_B3_B20-Perf | PCG-32 | Vodafone | luis.anaya@vodafone.com | Rel-12 | RP-62 | Issam | CA | LTE_CA_B1_B3_B20-Perf | RP-141084 |
| 2213 | 524.77 | **LTE Advanced 3 Band Carrier Aggregation (3DL/1UL) for Band 1, Band 7 and Band 20** | 202d? | 2013-12-09 A | 2014-09-12 A | 100% | 2013-12-09 | 2014-09-12 | 201d? |  | R4 | 4832h | 4832h | LTE_CA_B1_B7_B20 | PCG-32 | Vodafone | luis.anaya@vodafone.com | Rel-12 | RP-62 | Issam | CA | LTE_CA_B1_B7_B20 |  |
| 2214 | 524.77.1 | Core part: LTE Advanced 3 Band Carrier Aggregation (3DL/1UL) for Band 1, Band 7 and Band 20 | 201d? | 2013-12-09 A | 2014-09-12 A | 100% | 2013-12-09 | 2014-09-12 | 201d? | finish no earlier than 2014-09-12 | R4 | 1608h | 1608h | LTE_CA_B1_B7_B20-Core | PCG-32 | Vodafone | luis.anaya@vodafone.com | Rel-12 | RP-62 | Issam | CA | LTE_CA_B1_B7_B20-Core | RP-141084 |
| 2215 | 524.77.2 | Perf. part: LTE Advanced 3 Band Carrier Aggregation (3DL/1UL) for Band 1, Band 7 and Band 20 | 201d? | 2013-12-10 A | 2014-09-12 A | 100% | 2013-12-09 | 2014-09-12 | 201d? | finish no earlier than 2014-09-12 | R4 | 1608h | 1608h | LTE_CA_B1_B7_B20-Perf | PCG-32 | Vodafone | luis.anaya@vodafone.com | Rel-12 | RP-62 | Issam | CA | LTE_CA_B1_B7_B20-Perf | RP-141084 |
| 2216 | 524.78 | **LTE Advanced 3 Band Carrier Aggregation (3DL/1UL) for Band 7, Band 8 and Band 20** | 270d? | 2013-12-09 A | 2014-12-15 A | 100% | 2013-12-09 | 2014-09-12 | 201d? |  | R4 | 6432h | 6432h | LTE_CA_B7_B8_B20 | PCG-32 | Vodafone | luis.anaya@vodafone.com | Rel-12 | RP-62 | Issam | CA | LTE_CA_B7_B8_B20 |  |
| 2217 | 524.78.1 | Core part: LTE Advanced 3 Band Carrier Aggregation (3DL/1UL) for Band 7, Band 8 and Band 20 | 267d? | 2013-12-09 A | 2014-12-15 A | 100% | 2013-12-09 | 2014-09-12 | 201d? | finish no earlier than 2014-12-15 | R4 | 2136h | 2136h | LTE_CA_B7_B8_B20-Core | PCG-32 | Vodafone | luis.anaya@vodafone.com | Rel-12 | RP-62 | Issam | CA | LTE_CA_B7_B8_B20-Core | RP-141732 |
| 2218 | 524.78.2 | Perf. part: LTE Advanced 3 Band Carrier Aggregation (3DL/1UL) for Band 7, Band 8 and Band 20 | 267d? | 2013-12-12 A | 2014-12-15 A | 100% | 2013-12-09 | 2014-09-12 | 201d? | finish no earlier than 2014-12-15 | R4 | 2136h | 2136h | LTE_CA_B7_B8_B20-Perf | PCG-32 | Vodafone | luis.anaya@vodafone.com | Rel-12 | RP-62 | Issam | CA | LTE_CA_B7_B8_B20-Perf | RP-141732 |

Notes:
- 2195: Intra-band contig. CA 2DL/2UL / Impacted TSs and TRs: LTE
- 2196: RP#64 completed. TR 36.833-1-42v100 for 1-step Approval. Updated WID RP-132029=>RP-140728 / Impacted TSs and TRs: 36.101, 36.104, 36.133, new TR 36.833-1-42
- 2197: RP#64 completed. TR 36.833-1-42v100 for 1-step Approval. Updated WID RP-132029=>RP-140728 / Impacted TSs and TRs: 36.141, 36.307
- 2198: Intra-band contig. CA 2DL/2UL / Impacted TSs and TRs: LTE
- 2199: RP#64 completed / Impacted TSs and TRs: 36.101, 36.307
- 2200: RP#64 completed / Impacted TSs and TRs: 36.307
- 2201: Intra-band non-contig. CA 3DL / Impacted TSs and TRs: LTE
- 2202: RP#65 completed / Impacted TSs and TRs: 36.101, 36.104, 36.133, 36.307, new TR 36.833-6-xy
- 2203: CD:Thu 12/03/15->Sun 15/03/15; Compl:60%->70%; Stat Rep: RP-141084->RP-141732 1st Apr 15: Compl:70%->100% 1st Apr 15: Stat Rep: RP-141732->RP-150013 / Impacted TSs and TRs: 36.141
- 2204: Intra-band non-contig. CA 2DL / Impacted TSs and TRs: LTE
- 2205: RP#64 completed. Updated WID RP-140404=>RP-140671. TR 36.833-2-42v100 for 1-step Approval / Impacted TSs and TRs: 36.101, 36.104, 36.133, new TR 36.833-2-42
- 2206: RP#64 completed / Impacted TSs and TRs: 36.141, 36.307
- 2207: Inter-band CA 3DL / Impacted TSs and TRs: LTE
- 2208: RP#65 completed. Updated WID RP-132121=>RP-141454 / Impacted TSs and TRs: 36.101, 36.104, 36.133, new generic TR 36.853 (3 Band CA with 1UL)
- 2209: RP#65 completed. Updated WID RP-132121=>RP-141454 / Impacted TSs and TRs: 36.141, 36.307
- 2210: Inter-band CA 3DL / Impacted TSs and TRs: LTE
- 2211: RP#65 completed. Updated WID RP-141017=>RP-141222 / Impacted TSs and TRs: 36.101, 36.104, 36.133, new generic TR 36.851 (2 Band CA with 1UL), TR 36.853 (3 Band CA with 1UL)
- 2212: RP#65 completed / Impacted TSs and TRs: 36.101, 36.133, 36.141, 36.307
- 2213: Inter-band CA 3DL / Impacted TSs and TRs: LTE
- 2214: RP#65 completed. Updated WID RP-140243=>RP-141223 / Impacted TSs and TRs: 36.101, 36.104, 36.133, new generic TR 36.853 (3 Band CA with 1UL), TR 36.851 (2 Band CA with 1UL)
- 2215: RP#65 completed / Impacted TSs and TRs: 36.101, 36.133, 36.141, 36.307
- 2216: Inter-band CA 3DL / Impacted TSs and TRs: LTE
- 2217: CD:Thu 11/12/14->Mon 15/12/14; Compl:85%->100%; Stat Rep: RP-141084->RP-141732 / Impacted TSs and TRs: 36.101, 36.104, 36.133, new generic TR 36.853 (3 Band CA with 1UL), TR 36.851 (2 Band CA with 1UL)
- 2218: CD:Thu 11/12/14->Mon 15/12/14; Compl:0%->100%; Stat Rep: RP-141084->RP-141732 / Impacted TSs and TRs: 36.101, 36.133, 36.141, 36.307

| ID | WBS | Task | Duration | Start | Finish | Complete | Baseline start | Baseline finish | Baseline duration | Constraint | Resources | Work | Actual work | Acronym | PCG approved | WI rapporteur name | WI rapporteur e-mail | Release | TSG approved | MCC resp | Special Focus Doc | Acronym_3GU_Export | Status Report | PCG stopped | TSG stopped |
| --- | --- | --- | --- | --- | --- | --- | --- | --- | --- | --- | --- | --- | --- | --- | --- | --- | --- | --- | --- | --- | --- | --- | --- | --- | --- |
| 2219 | 524.79 | **Additional bandwidth combinations for LTE Advanced inter-band Carrier Aggregation of Band 2 and Band 29 and of Band 4 and Band 29** | 4d? | 2014-03-03 A | 2014-03-06 A | 100% | 2014-03-03 | 2014-03-06 | 4d? |  | R4 | 64h | 64h | LTE_DL_FDD700_B29_Bwset | PCG-32 | AT&T | marc.grant@att.com | Rel-12 | RP-63 | Issam | CA | LTE_DL_FDD700_B29_Bwset |  |  |  |
| 2220 | 524.79.1 | Core part: Additional bandwidth combinations for LTE Advanced inter-band Carrier Aggregation of Band 2 and Band 29 and of Band 4 and Band 29 | 4d? | 2014-03-03 A | 2014-03-06 A | 100% | 2014-03-03 | 2014-03-06 | 4d? | finish no earlier than 2014-03-06 | R4 | 32h | 32h | LTE_DL_FDD700_B29_BWset-Core | PCG-32 | AT&T | marc.grant@att.com | Rel-12 | RP-63 | Issam | CA | LTE_DL_FDD700_B29_BWset-Core | RP-140428 |  |  |
| 2221 | 524.80 | **Additional bandwidth combination set for LTE Advanced inter-band Carrier Aggregation of Band 3 and Band 20** | 72d? | 2014-03-06 A | 2014-06-13 A | 100% | 2014-03-06 | 2014-06-13 | 72d? |  | R4 | 1152h | 1152h | LTE_CA_B3_B20_BWset | PCG-32 | NSN | iwajlo.angelow@nsn.com | Rel-12 | RP-63 | Issam | CA | LTE_CA_B3_B20_BWset |  |  |  |
| 2222 | 524.80.1 | Core part: Additional bandwidth combination set for LTE Advanced inter-band Carrier Aggregation of Band 3 and Band 20 | 72d? | 2014-03-06 A | 2014-06-13 A | 100% | 2014-03-06 | 2014-06-13 | 72d? | finish no earlier than 2014-06-13 | R4 | 576h | 576h | LTE_CA_B3_B20_BWset-Core | PCG-32 | NSN | iwajlo.angelow@nsn.com | Rel-12 | RP-63 | Issam | CA | LTE_CA_B3_B20_BWset-Core | RP-140569 |  |  |
| 2223 | 524.81 | **Additional bandwidth combination set for LTE Advanced inter-band Carrier Aggregation of Band 7 and Band 20** | 72d? | 2014-03-06 A | 2014-06-13 A | 100% | 2014-03-06 | 2014-06-13 | 72d? |  | R4 | 1152h | 1152h | LTE_CA_B7_B20_BWset | PCG-32 | NSN | iwajlo.angelow@nsn.com | Rel-12 | RP-63 | Issam | CA | LTE_CA_B7_B20_BWset |  |  |  |
| 2224 | 524.81.1 | Core part: Additional bandwidth combination set for LTE Advanced inter-band Carrier Aggregation of Band 7 and Band 20 | 72d? | 2014-03-06 A | 2014-06-13 A | 100% | 2014-03-06 | 2014-06-13 | 72d? | finish no earlier than 2014-06-13 | R4 | 576h | 576h | LTE_CA_B7_B20_BWset-Core | PCG-32 | NSN | iwajlo.angelow@nsn.com | Rel-12 | RP-63 | Issam | CA | LTE_CA_B7_B20_BWset-Core | RP-140569 |  |  |
| 2225 | 524.82 | **Additional bandwidth combinations for LTE Advanced inter-band Carrier Aggregation to support 3DL fallback** | 72d? | 2014-03-06 A | 2014-06-13 A | 100% | 2014-03-06 | 2014-06-13 | 72d? |  | R4 | 1152h | 1152h | LTE_CA_3DL_FB_BW | PCG-32 | Qualcomm | Fong Gene (gfong@qti.qualcomm.com) | Rel-12 | RP-63 | Issam | CA | LTE_CA_3DL_FB_BW |  |  |  |
| 2226 | 524.82.1 | Core part: Additional bandwidth combinations for LTE Advanced inter-band Carrier Aggregation to support 3DL fallback | 72d? | 2014-03-06 A | 2014-06-13 A | 100% | 2014-03-06 | 2014-06-13 | 72d? | finish no earlier than 2014-06-13 | R4 | 576h | 576h | LTE_CA_3DL_FB_BW-Core | PCG-32 | Qualcomm | Fong Gene (gfong@qti.qualcomm.com) | Rel-12 | RP-63 | Issam | CA | LTE_CA_3DL_FB_BW-Core | RP-140569 |  |  |
| 2227 | 524.83 | **LTE Advanced 3 Band Carrier Aggregation (3DL/1UL) of Band 3, Band 7 and Band 7** | 138d? | 2014-03-06 A | 2014-09-12 A | 100% | 2014-03-06 | 2014-09-12 | 137d? |  | R4 | 3296h | 3296h | LTE_CA_B3_B7_B7 | PCG-32 | Nokia Networks | iwajlo.angelow@nsn.com | Rel-12 | RP-63 | Issam | CA | LTE_CA_B3_B7_B7 |  |  |  |
| 2228 | 524.83.1 | Core part: LTE Advanced 3 Band Carrier Aggregation (3DL/1UL) of Band 3, Band 7 and Band 7 | 137d? | 2014-03-06 A | 2014-09-12 A | 100% | 2014-03-06 | 2014-09-12 | 137d? | finish no earlier than 2014-09-12 | R4 | 1096h | 1096h | LTE_CA_B3_B7_B7-Core | PCG-32 | Nokia Networks | iwajlo.angelow@nsn.com | Rel-12 | RP-63 | Issam | CA | LTE_CA_B3_B7_B7-Core | RP-141084 |  |  |
| 2229 | 524.83.2 | Perf. part: LTE Advanced 3 Band Carrier Aggregation (3DL/1UL) of Band 3, Band 7 and Band 7 | 137d? | 2014-03-06 A | 2014-09-12 A | 100% | 2014-03-06 | 2014-09-12 | 137d? | finish no earlier than 2014-09-12 | R4 | 1096h | 1096h | LTE_CA_B3_B7_B7-Perf | PCG-32 | Nokia Networks | iwajlo.angelow@nsn.com | Rel-12 | RP-63 | Issam | CA | LTE_CA_B3_B7_B7-Perf | RP-141084 |  |  |
| 2230 | 524.84 | **LTE Advanced 3 Band Carrier Aggregation (3DL/1UL) of Band 1, Band 19 and Band 21** | 138d? | 2014-03-06 A | 2014-09-12 A | 100% | 2014-03-06 | 2014-09-12 | 137d? |  | R4 | 3296h | 3296h | LTE_CA_B1_B19_B21 | PCG-32 | NTT DOCOMO | teruaki.toeda.zf@nttdocomo.com | Rel-12 | RP-63 | Issam | CA | LTE_CA_B1_B19_B21 |  |  |  |
| 2231 | 524.84.1 | Core part: LTE Advanced 3 Band Carrier Aggregation (3DL/1UL) of Band 1, Band 19 and Band 21 | 137d? | 2014-03-06 A | 2014-09-12 A | 100% | 2014-03-06 | 2014-09-12 | 137d? | finish no earlier than 2014-09-12 | R4 | 1096h | 1096h | LTE_CA_B1_B19_B21-Core | PCG-32 | NTT DOCOMO | teruaki.toeda.zf@nttdocomo.com | Rel-12 | RP-63 | Issam | CA | LTE_CA_B1_B19_B21-Core | RP-141084 |  |  |
| 2232 | 524.84.2 | Perf. part: LTE Advanced 3 Band Carrier Aggregation (3DL/1UL) of Band 1, Band 19 and Band 21 | 137d? | 2014-03-06 A | 2014-09-12 A | 100% | 2014-03-06 | 2014-09-12 | 137d? | finish no earlier than 2014-09-12 | R4 | 1096h | 1096h | LTE_CA_B1_B19_B21-Perf | PCG-32 | NTT DOCOMO | teruaki.toeda.zf@nttdocomo.com | Rel-12 | RP-63 | Issam | CA | LTE_CA_B1_B19_B21-Perf | RP-141084 |  |  |
| 2233 | 524.85 | **LTE Advanced 3 Band Carrier Aggregation (3DL/1UL) of Band 3, Band 3 and Band 7** | 138d? | 2014-03-06 A | 2014-09-12 A | 100% | 2014-03-06 | 2014-09-12 | 137d? |  | R4 | 3296h | 3296h | LTE_CA_B3_B3_B7 | PCG-32 | TeliaSonera | Ralf.Schuh@TeliaSonera.com | Rel-12 | RP-63 | Issam | CA | LTE_CA_B3_B3_B7 |  |  |  |
| 2234 | 524.85.1 | Core part: LTE-Advanced 3 Band Carrier Aggregation (3DL/1UL) of Band 3, Band 3 and Band 7 | 137d? | 2014-03-06 A | 2014-09-12 A | 100% | 2014-03-06 | 2014-09-12 | 137d? | finish no earlier than 2014-09-12 | R4 | 1096h | 1096h | LTE_CA_B3_B3_B7-Core | PCG-32 | TeliaSonera | Ralf.Schuh@TeliaSonera.com | Rel-12 | RP-63 | Issam | CA | LTE_CA_B3_B3_B7-Core | RP-141084 |  |  |
| 2235 | 524.85.2 | Perf. part: LTE-Advanced 3 Band Carrier Aggregation (3DL/1UL) of Band 3, Band 3 and Band 7 | 137d? | 2014-03-06 A | 2014-09-12 A | 100% | 2014-03-06 | 2014-09-12 | 137d? | finish no earlier than 2014-09-12 | R4 | 1096h | 1096h | LTE_CA_B3_B3_B7-Perf | PCG-32 | TeliaSonera | Ralf.Schuh@TeliaSonera.com | Rel-12 | RP-63 | Issam | CA | LTE_CA_B3_B3_B7-Perf | RP-141084 |  |  |
| 2236 | 524.86 | **LTE Advanced intra-band contiguous Carrier Aggregation in Band 40 for 3DL** | 72d? | 2014-03-06 A | 2014-06-13 A | 100% | 2014-03-06 | 2014-06-13 | 72d? |  | R4 | 1728h | 1728h | LTE_CA_C_B40_3DL | PCG-32 | China Mobile | Pan Qun (panqun@chinamobile.com) | Rel-12 | RP-63 | Issam | CA | LTE_CA_C_B40_3DL |  |  |  |
| 2237 | 524.86.1 | Core part: LTE Advanced intra-band contiguous Carrier Aggregation in Band 40 for 3DL | 72d? | 2014-03-06 A | 2014-06-13 A | 100% | 2014-03-06 | 2014-06-13 | 72d? | finish no earlier than 2014-06-13 | R4 | 576h | 576h | LTE_CA_C_B40_3DL-Core | PCG-32 | China Mobile | Pan Qun (panqun@chinamobile.com) | Rel-12 | RP-63 | Issam | CA | LTE_CA_C_B40_3DL-Core | RP-140569 |  |  |
| 2238 | 524.86.2 | Perf. part: LTE Advanced intra-band contiguous Carrier Aggregation in Band 40 for 3DL | 72d? | 2014-03-06 A | 2014-06-13 A | 100% | 2014-03-06 | 2014-06-13 | 72d? | finish no earlier than 2014-06-13 | R4 | 576h | 576h | LTE_CA_C_B40_3DL-Perf | PCG-32 | China Mobile | Pan Qun (panqun@chinamobile.com) | Rel-12 | RP-63 | Issam | CA | LTE_CA_C_B40_3DL-Perf | RP-140569 |  |  |
| 2239 | 524.87 | **Additional bandwidth combination set for LTE Advanced inter-band Carrier Aggregation of Band 4 and Band 12** | 137d? | 2014-03-07 A | 2014-09-12 A | 100% | 2014-03-06 | 2014-12-05 | 197d? |  | R4 | 3288h | 3288h | LTE_CA_B4_B12_BWset | PCG-32 | T-Mobile USA | nelson.ueng@t-mobile.com | Rel-12 | RP-63 | Issam | CA | LTE_CA_B4_B12_BWset |  |  |  |
| 2240 | 524.87.1 | Core part: Additional bandwidth combination set for LTE Advanced inter-band Carrier Aggregation of Band 4 and Band 12 | 137d? | 2014-03-07 A | 2014-09-12 A | 100% | 2014-03-06 | 2014-12-05 | 197d? | finish no earlier than 2014-09-12 | R4 | 1096h | 1096h | LTE_CA_B4_B12_BWset-Core | PCG-32 | T-Mobile USA | nelson.ueng@t-mobile.com | Rel-12 | RP-63 | Issam | CA | LTE_CA_B4_B12_BWset-Core | RP-141084 |  |  |
| 2241 | 524.87.2 | Deleted - Perf. part: Additional bandwidth combination set for LTE Advanced inter-band Carrier Aggregation of Band 4 and Band 12 | 137d? | 2014-03-07 A | 2014-09-12 A | 100% | 2014-03-06 | 2014-12-05 | 197d? | finish no earlier than 2014-09-12 | R4 | 1096h | 1096h | LTE_CA_B4_B12_BWset-Perf | PCG-32 | T-Mobile USA | nelson.ueng@t-mobile.com | Rel-12 | RP-63 | Issam | CA | LTE_CA_B4_B12_BWset-Perf | RP-141084 | PCG-33 | RP-65 |
| 2242 | 524.88 | **LTE Advanced inter-band Carrier Aggregation of Band 41 and Band 42** | 138d? | 2014-03-06 A | 2014-09-12 A | 100% | 2014-03-06 | 2014-09-12 | 137d? |  | R4 | 2776h | 2776h | LTE_CA_B41_B42 | PCG-32 | Huawei | leo.liuye@huawei.com | Rel-12 | RP-63 | Issam | CA | LTE_CA_B41_B42 |  |  |  |
| 2243 | 524.88.1 | Core part: LTE Advanced inter-band Carrier Aggregation of Band 41 and Band 42 | 72d? | 2014-03-06 A | 2014-09-12 A | 100% | 2014-03-06 | 2014-09-12 | 72d? | finish no earlier than 2014-09-12 | R4 | 576h | 576h | LTE_CA_B41_B42-Core | PCG-32 | Huawei | leo.liuye@huawei.com | Rel-12 | RP-63 | Issam | CA | LTE_CA_B41_B42-Core | RP-141084 |  |  |
| 2244 | 524.88.2 | Perf. Part: LTE Advanced inter-band Carrier Aggregation of Band 41 and Band 42 | 137d? | 2014-03-07 A | 2014-09-12 A | 100% | 2014-03-06 | 2014-09-12 | 137d? | finish no earlier than 2014-09-12 | R4 | 1096h | 1096h | LTE_CA_B41_B42-Perf | PCG-32 | Huawei | leo.liuye@huawei.com | Rel-12 | RP-63 | Issam | CA | LTE_CA_B41_B42-Perf | RP-141084 |  |  |

Notes:
- 2219: Inter-band 2DL/1UL / Impacted TSs and TRs: LTE
- 2220: RP#63 approved WI (no Perf. Part) & completed. Rel-10 and Rel-11 versions of 36.307 affected / Impacted TSs and TRs: 36.101, 36.307
- 2221: Inter-band CA 2DL / Impacted TSs and TRs: LTE
- 2222: RP#64 completed / Impacted TSs and TRs: 36.101, TR 36.851
- 2223: Inter-band CA 2DL / Impacted TSs and TRs: LTE
- 2224: RP#64 completed / Impacted TSs and TRs: 36.101, TR 36.851
- 2225: Inter-band CA 2DL / Impacted TSs and TRs: LTE
- 2226: RP#64 completed, Additional BW combinations added for 6 Wis: 3 open Rel-12 Wis (B1_B5_B7, B2_B29_B30, B4_B29_B30) and 3 completed Rel-11 Wis (B3_B5, B4_B5, B4_B12) / Impacted TSs and TRs: 36.101, 36.307
- 2227: Inter-band CA 3DL. Mar15: acronym reverted to LTE_CA_B3_B7_B7_ / Impacted TSs and TRs: LTE
- 2228: RP#65 completed. Updated WID RP-140095=>RP-141196. Mar15: acronym reverted to LTE_CA_B3_B7_B7-Core_ / Impacted TSs and TRs: 36.101, 36.104, 36.133, new generic TR 36.853 (3 Band CA with 1UL)
- 2229: RP#65 completed. Updated WID RP-140095=>RP-141196. Mar15: acronym reverted from LTE_CA_B3_B7_B7-Perf_ / Impacted TSs and TRs: 36.141, 36.307
- 2230: Inter-band CA 3DL / Impacted TSs and TRs: LTE
- 2231: RP#65 completed. Updated WID RP-140106=>RP-141193 / Impacted TSs and TRs: 36.101, 36.104, 36.133, new generic TR 36.853 (3 Band CA with 1UL)
- 2232: RP#65 completed. Updated WID RP-140106=>RP-141193 / Impacted TSs and TRs: 36.141, 36.307
- 2233: Inter-band CA 3DL / Impacted TSs and TRs: LTE
- 2234: RP#65 completed. Updated RP-140390=>RP-141126 / Impacted TSs and TRs: 36.101, 36.104, 36.133, new generic TR 36.853 (3 Band CA with 1UL)
- 2235: RP#65 completed. Updated RP-140390=>RP-141126 / Impacted TSs and TRs: 36.141, 36.307
- 2236: Intra-band contig. CA 3DL / Impacted TSs and TRs: LTE
- 2237: RP#64 completed. Updated WID RP-140453=>RP-140948 / Impacted TSs and TRs: 36.101, 36.104, 36.133, New TR 36.833-5-40
- 2238: RP#64 completed. Updated WID RP-140453=>RP-140948 / Impacted TSs and TRs: 36.141, 36.307
- 2239: Inter-band CA 2DL / Impacted TSs and TRs: LTE
- 2240: RP#65 completed. Updated WID RP-140987=>RP-141235 (removed Perf. Part) / Impacted TSs and TRs: 36.101, generic TR 36.850
- 2241: RP#65 stopped. Updated WID RP-140987=>RP-141235 (removed Perf. Part) / Impacted TSs and TRs: 36.307
- 2242: Inter-band CA 2DL / Impacted TSs and TRs: LTE
- 2243: RP#65 completed / Impacted TSs and TRs: 36.101, 36.104, TR 36.851
- 2244: RP#65 completed / Impacted TSs and TRs: 36.141

| ID | WBS | Task | Duration | Start | Finish | Complete | Remaining | Baseline start | Baseline finish | Baseline duration | Total slack | Constraint | Resources | Work | Actual work | Acronym | PCG approved | WI rapporteur name | WI rapporteur e-mail | Release | TSG approved | MCC resp | Special Focus Doc | Acronym_3GU_Export | Status Report |
| --- | --- | --- | --- | --- | --- | --- | --- | --- | --- | --- | --- | --- | --- | --- | --- | --- | --- | --- | --- | --- | --- | --- | --- | --- | --- |
| 2245 | 524.89 | **LTE Advanced 3 Band Carrier Aggregation (3DL/1UL) of Band 4, Band 4, and Band 12** | 138d? | 2014-03-06 A | 2014-09-12 A | 100% |  | 2014-03-06 | 2014-12-05 | 197d? |  |  | R4 | 3296h | 3296h | LTE_CA_B4_B4_B12 | PCG-32 | T-Mobile USA | nelson.ueng@t-mobile.com | Rel-12 | RP-63 | Issam | CA | LTE_CA_B4_B4_B12 |  |
| 2246 | 524.89.1 | Core part: LTE Advanced 3 Band Carrier Aggregation (3DL/1UL) of Band 4, Band 4, and Band 12 | 137d? | 2014-03-06 A | 2014-09-12 A | 100% |  | 2014-03-06 | 2014-12-05 | 197d? |  | finish no earlier than 2014-09-12 | R4 | 1096h | 1096h | LTE_CA_B4_B4_B12-Core | PCG-32 | T-Mobile USA | nelson.ueng@t-mobile.com | Rel-12 | RP-63 | Issam | CA | LTE_CA_B4_B4_B12-Core | RP-141084 |
| 2247 | 524.89.2 | Perf. part: LTE Advanced 3 Band Carrier Aggregation (3DL/1UL) of Band 4, Band 4, and Band 12 | 137d? | 2014-03-07 A | 2014-09-12 A | 100% |  | 2014-03-06 | 2014-12-05 | 197d? |  | finish no earlier than 2014-09-12 | R4 | 1096h | 1096h | LTE_CA_B4_B4_B12-Perf | PCG-32 | T-Mobile USA | nelson.ueng@t-mobile.com | Rel-12 | RP-63 | Issam | CA | LTE_CA_B4_B4_B12-Perf | RP-141084 |
| 2248 | 524.90 | **LTE Advanced 3 Band Carrier Aggregation (3DL/1UL) of Band 2, Band 4, and Band 4** | 138d? | 2014-03-06 A | 2014-09-12 A | 100% |  | 2014-03-06 | 2014-12-05 | 197d? |  |  | R4 | 3296h | 3296h | LTE_CA_B2_B4_B4 | PCG-32 | T-Mobile USA | nelson.ueng@T-Mobile.com | Rel-12 | RP-63 | Issam | CA | LTE_CA_B2_B4_B4 |  |
| 2249 | 524.90.1 | Core part: LTE Advanced 3 Band Carrier Aggregation (3DL/1UL) of Band 2, Band 4, and Band 4 | 137d? | 2014-03-06 A | 2014-09-12 A | 100% |  | 2014-03-06 | 2014-12-05 | 197d? |  | finish no earlier than 2014-09-12 | R4 | 1096h | 1096h | LTE_CA_B2_B4_B4-Core | PCG-32 | T-Mobile USA | nelson.ueng@T-Mobile.com | Rel-12 | RP-63 | Issam | CA | LTE_CA_B2_B4_B4-Core | RP-141084 |
| 2250 | 524.90.2 | Perf. part: LTE Advanced 3 Band Carrier Aggregation (3DL/1UL) of Band 2, Band 4, and Band 4 | 137d? | 2014-03-07 A | 2014-09-12 A | 100% |  | 2014-03-06 | 2014-12-05 | 197d? |  | finish no earlier than 2014-09-12 | R4 | 1096h | 1096h | LTE_CA_B2_B4_B4-Perf | PCG-32 | T-Mobile USA | nelson.ueng@T-Mobile.com | Rel-12 | RP-63 | Issam | CA | LTE_CA_B2_B4_B4-Perf | RP-141084 |
| 2251 | 524.91 | **Additional bandwidth combinations for LTE Advanced intra-band non-contiguous Carrier Aggregation in Band 25** | 138d? | 2014-03-06 A | 2014-09-12 A | 100% |  | 2014-03-06 | 2014-09-12 | 137d? |  |  | R4 | 3296h | 3296h | LTE_CA_NC_B25_BWset | PCG-32 | Huawei | Liu Liehai (liuliehai@huawei.com) | Rel-12 | RP-63 | Issam | CA | LTE_CA_NC_B25_BWset |  |
| 2252 | 524.91.1 | Core part: Additional bandwidth combinations for LTE Advanced intra-band non-contiguous Carrier Aggregation in Band 25 | 137d? | 2014-03-06 A | 2014-09-12 A | 100% |  | 2014-03-06 | 2014-09-12 | 137d? |  | finish no earlier than 2014-09-12 | R4 | 1096h | 1096h | LTE_CA_NC_B25_BWset-Core | PCG-32 | Huawei | Liu Liehai (liuliehai@huawei.com) | Rel-12 | RP-63 | Issam | CA | LTE_CA_NC_B25_BWset-Core | RP-141084 |
| 2253 | 524.91.2 | Perf. part: Additional bandwidth combinations for LTE Advanced intra-band non-contiguous Carrier Aggregation in Band 25 | 137d? | 2014-03-07 A | 2014-09-12 A | 100% |  | 2014-03-06 | 2014-09-12 | 137d? |  | finish no earlier than 2014-09-12 | R4 | 1096h | 1096h | LTE_CA_NC_B25_BWset-Perf | PCG-32 | Huawei | Liu Liehai (liuliehai@huawei.com) | Rel-12 | RP-63 | Issam | CA | LTE_CA_NC_B25_BWset-Perf | RP-141084 |
| 2254 | 524.92 | **Additional bandwidth combination set for LTE Advanced inter-band Carrier Aggregation of Band 2 and Band 4** | 66d? | 2014-06-15 A | 2014-09-15 A | 100% |  | 2014-06-13 | 2014-09-12 | 66d? |  |  | R4 | 1056h | 1056h | LTE_CA_B2_B4_Bwset2 | PCG-33 | T-Mobile USA | nelson.ueng@T-Mobile.com | Rel-12 | RP-64 |  | CA | LTE_CA_B2_B4_BWset |  |
| 2255 | 524.92.1 | Core part: Additional bandwidth combination set 2 for LTE Advanced inter-band Carrier Aggregation of Band 2 and Band 4 | 66d? | 2014-06-15 A | 2014-09-15 A | 100% |  | 2014-06-13 | 2014-09-12 | 66d? |  | finish no earlier than 2014-09-15 | R4 | 528h | 528h | LTE_CA_B2_B4_BWset2-Core | PCG-33 | T-Mobile USA | nelson.ueng@T-Mobile.com | Rel-12 | RP-64 |  | CA | LTE_CA_B2_B4_BWset-Core | RP-141084 |
| 2256 | 524.93 | **Additional bandwidth combination set for LTE Advanced inter-band Carrier Aggregation of Band 2 and Band 5** | 132d? | 2014-06-18 A | 2014-12-15 | 50% | 66d? | 2014-06-13 | 2014-09-12 | 66d? | 1049d |  | R4 | 3168h | 1584h | LTE_CA_B2_B5_BWset | PCG-33 | AT&T | marc.grant@att.com | Rel-12 | RP-64 |  | CA | LTE_CA_B2_B5_BWset |  |
| 2257 | 524.93.1 | Core part: Additional bandwidth combination set for LTE Advanced inter-band Carrier Aggregation of Band 2 and Band 5 | 132d? | 2014-06-18 A | 2014-12-15 A | 100% |  | 2014-06-13 | 2014-09-12 | 66d? |  | finish no earlier than 2014-12-15 | R4 | 1056h | 1056h | LTE_CA_B2_B5_Bwset-Core | PCG-33 | AT&T | marc.grant@att.com | Rel-12 | RP-64 |  | CA | LTE_CA_B2_B5_Bwset-Core | RP-141732 |
| 2258 | 524.93.2 | Perf. Part: Additional bandwidth combination set for LTE Advanced inter-band Carrier Aggregation of Band 2 and Band 5 | 132d? | 2014-06-18 | 2014-12-15 |  |  | 2014-06-13 | 2014-09-12 | 66d? | 1049d | finish no earlier than 2014-12-15 | R4 | 1056h |  | LTE_CA_B2_B5_BWset-Perf | PCG-33 | AT&T | marc.grant@att.com | Rel-12 | RP-64 |  | CA | LTE_CA_B2_B5_BWset-Perf | RP-141732 |
| 2259 | 524.94 | **E-UTRA UE demodulation/Channel State Information (CSI) performance requirements for multiple Carrier Aggregation configurations** | 198d? | 2014-06-16 A | 2015-03-15 A | 100% |  | 2014-06-13 | 2015-03-13 | 196d? |  |  | R4 | 3152h | 3152h | LTE_CA_Mult | PCG-33 | China Mobile | Zhang Xiaoran (zhangxiaoran@chinamobile.com) | Rel-12 | RP-64 |  | CA | LTE_CA_Mult |  |
| 2260 | 524.94.1 | Perf. Part: E-UTRA UE demodulation/Channel State Information (CSI) performance requirements for multiple Carrier Aggregation configurations | 196d? | 2014-06-16 A | 2015-03-15 A | 100% |  | 2014-06-13 | 2015-03-13 | 196d? |  | finish no earlier than 2015-03-15 | R4 | 1568h | 1568h | LTE_CA_Mult-Perf | PCG-33 | China Mobile | Zhang Xiaoran (zhangxiaoran@chinamobile.com) | Rel-12 | RP-64 |  | CA | LTE_CA_Mult-Perf | RP-150188 |
| 2261 | 524.95 | **LTE Advanced 3 Band Carrier Aggregation (3DL/1UL) of Band 1, Band 3 and Band 19** | 66d? | 2014-06-16 A | 2014-09-12 A | 100% |  | 2014-06-13 | 2014-09-12 | 66d? |  |  | R4 | 1584h | 1584h | LTE_CA_B1_B3_B19 | PCG-33 | NTT DOCOMO | teruaki.toeda.zf@nttdocomo.com | Rel-12 | RP-64 |  | CA | LTE_CA_B1_B3_B19 |  |
| 2262 | 524.95.1 | Core part: LTE Advanced 3 Band Carrier Aggregation (3DL/1UL) of Band 1, Band 3 and Band 19 | 66d? | 2014-06-16 A | 2014-09-12 A | 100% |  | 2014-06-13 | 2014-09-12 | 66d? |  | finish no earlier than 2014-09-12 | R4 | 528h | 528h | LTE_CA_B1_B3_B19-Core | PCG-33 | NTT DOCOMO | teruaki.toeda.zf@nttdocomo.com | Rel-12 | RP-64 |  | CA | LTE_CA_B1_B3_B19-Core | RP-141084 |
| 2263 | 524.95.2 | Perf. Part: LTE Advanced 3 Band Carrier Aggregation (3DL/1UL) of Band 1, Band 3 and Band 19 | 66d? | 2014-06-16 A | 2014-09-12 A | 100% |  | 2014-06-13 | 2014-09-12 | 66d? |  | finish no earlier than 2014-09-12 | R4 | 528h | 528h | LTE_CA_B1_B3_B19-Perf | PCG-33 | NTT DOCOMO | teruaki.toeda.zf@nttdocomo.com | Rel-12 | RP-64 |  | CA | LTE_CA_B1_B3_B19-Perf | RP-141084 |
| 2264 | 524.96 | **LTE Advanced 3 Band Carrier Aggregation (3DL/1UL) of Band 19, Band 42 and Band 42** | 66d? | 2014-06-16 A | 2014-09-12 A | 100% |  | 2014-06-13 | 2014-09-12 | 66d? |  |  | R4 | 1584h | 1584h | LTE_CA_B19_B42_B42 | PCG-33 | NTT DOCOMO | teruaki.toeda.zf@nttdocomo.com | Rel-12 | RP-64 |  | CA | LTE_CA_B19_B42_B42 |  |
| 2265 | 524.96.1 | Core part: LTE Advanced 3 Band Carrier Aggregation (3DL/1UL) of Band 19, Band 42 and Band 42 | 66d? | 2014-06-16 A | 2014-09-12 A | 100% |  | 2014-06-13 | 2014-09-12 | 66d? |  | finish no earlier than 2014-09-12 | R4 | 528h | 528h | LTE_CA_B19_B42_B42-Core | PCG-33 | NTT DOCOMO | teruaki.toeda.zf@nttdocomo.com | Rel-12 | RP-64 |  | CA | LTE_CA_B19_B42_B42-Core | RP-141084 |
| 2266 | 524.96.2 | Perf. Part: LTE Advanced 3 Band Carrier Aggregation (3DL/1UL) of Band 19, Band 42 and Band 42 | 66d? | 2014-06-16 A | 2014-09-12 A | 100% |  | 2014-06-13 | 2014-09-12 | 66d? |  | finish no earlier than 2014-09-12 | R4 | 528h | 528h | LTE_CA_B19_B42_B42-Perf | PCG-33 | NTT DOCOMO | teruaki.toeda.zf@nttdocomo.com | Rel-12 | RP-64 |  | CA | LTE_CA_B19_B42_B42-Perf | RP-141084 |
| 2267 | 524.97 | **LTE Advanced 3 Band Carrier Aggregation (3DL/1UL) of Band 3, Band 42 and Band 42** | 198d? | 2014-06-16 A | 2015-03-15 A | 100% |  | 2014-06-13 | 2014-09-12 | 66d? |  |  | R4 | 4720h | 4720h | LTE_CA_B3_B42_B42 | PCG-33 | NTT DOCOMO | ANDO Kei (kei.andou.ye@nttdocomo.com) | Rel-12 | RP-64 |  | CA | LTE_CA_B3_B42_B42 |  |
| 2268 | 524.97.1 | Core part: LTE Advanced 3 Band Carrier Aggregation (3DL/1UL) of Band 3, Band 42 and Band 42 | 196d? | 2014-06-16 A | 2015-03-15 A | 100% |  | 2014-06-13 | 2014-09-12 | 66d? |  | finish no earlier than 2015-03-15 | R4 | 1568h | 1568h | LTE_CA_B3_B42_B42-Core | PCG-33 | NTT DOCOMO | ANDO Kei (kei.andou.ye@nttdocomo.com) | Rel-12 | RP-64 |  | CA | LTE_CA_B3_B42_B42-Core | RP-150013 |
| 2269 | 524.97.2 | Perf. Part: LTE Advanced 3 Band Carrier Aggregation (3DL/1UL) of Band 3, Band 42 and Band 42 | 196d? | 2014-06-16 A | 2015-03-15 A | 100% |  | 2014-06-13 | 2014-09-12 | 66d? |  | finish no earlier than 2016-03-15 | R4 | 1568h | 1568h | LTE_CA_B3_B42_B42-Perf | PCG-33 | NTT DOCOMO | ANDO Kei (kei.andou.ye@nttdocomo.com) | Rel-12 | RP-64 |  | CA | LTE_CA_B3_B42_B42-Perf | RP-150013 |

Notes:
- 2245: Inter-band CA 3DL / Impacted TSs and TRs: LTE
- 2246: RP#65 completed. Updated WID RP-140116=>RP-141709 / Impacted TSs and TRs: 36.101, 36.104, 36.133, 36.141, 36.307, generic TR 36.853 (3 Band CA with 1UL)
- 2247: RP#65 completed / Impacted TSs and TRs: 36.101, 36.104, 36.133, 36.141, 36.307
- 2248: Inter-band CA 3DL / Impacted TSs and TRs: LTE
- 2249: RP#65 completed. Updated WID RP-140117=>RP-141236 / Impacted TSs and TRs: 36.101, 36.104, 36.133, 36.141, 36.307, generic TR 36.853 (3 Band CA with 1UL)
- 2250: RP#65 completed / Impacted TSs and TRs: 36.101, 36.104, 36.133, 36.141, 36.307
- 2251: Intra-band non-contig. CA 2DL / Impacted TSs and TRs: LTE
- 2252: RP#65 completed / Impacted TSs and TRs: 36.101, 36.307, TR 36.833-2-25
- 2253: RP#65 completed / Impacted TSs and TRs: 36.307
- 2254: Inter-band CA 2DL. Mar 15: acronym changed from LTE_CA_B2_B4_Bwset_ / Impacted TSs and TRs: LTE
- 2255: Dec 14: Prev CD:Fri 12/09/14; Prev %:100%, title changed. Mar 15: Acronym changed to LTE_CA_B2_B4_BWset2-Core_ / Impacted TSs and TRs: 36.101, 36.851
- 2256: 2DL/1UL / Impacted TSs and TRs: LTE
- 2257: ; WID: RP-142043->RP-141803; Stat Rep: RP-141084->RP-141732 / Impacted TSs and TRs: 36.101, 36.851
- 2258: CD:Thu 11/12/14->Mon 15/12/14; Compl:0%->0%; Stat Rep: RP-141084->RP-141732 / Impacted TSs and TRs: 36.307
- 2259: LTE / Impacted TSs and TRs: LTE
- 2260: CD:Thu 12/03/15->Sun 15/03/15; Compl:10%->90%; Stat Rep: RP-141303->RP-141839 1st Apr 15: Compl:90%->100% 1st Apr 15: Stat Rep: RP-141839->RP-150188 / Impacted TSs and TRs: 36.101
- 2261: Inter-band CA 3DL / Impacted TSs and TRs: LTE
- 2262: RP#65 completed / Impacted TSs and TRs: 36.101, 36.104, 36.133, generic TR 36.853 (3 Band CA with 1UL)
- 2263: RP#65 completed / Impacted TSs and TRs: 36.141, 36.307
- 2264: Inter-band CA 3DL / Impacted TSs and TRs: LTE
- 2265: RP#65 completed / Impacted TSs and TRs: 36.101, 36.104, 36.133, generic TR 36.853 (3 Band CA with 1UL)
- 2266: RP#65 completed / Impacted TSs and TRs: 36.141, 36.307
- 2267: 3DL/1UL / Impacted TSs and TRs: LTE
- 2268: CD:Thu 11/12/14->Sun 15/03/15; Compl:50%->70%; Stat Rep: RP-141084->RP-141732 1st Apr 15: Compl:70%->100% 1st Apr 15: Stat Rep: RP-141732->RP-150013 / Impacted TSs and TRs: 36.101, 36.104, 36.133, generic TR 36.853 (3 Band CA with 1UL)
- 2269: CD:Thu 11/12/14->Tue 15/03/16; Compl:50%->70%; Stat Rep: RP-141084->RP-141732 1st Apr 15: Compl:70%->100% 1st Apr 15: CD:Tue 15/03/16->Sun 15/03/15 1st Apr 15: Stat Rep: RP-141732->RP-150013 / Impacted TSs and TRs: 36.141, 36.307

| ID | WBS | Task | Duration | Start | Finish | Complete | Baseline start | Baseline finish | Baseline duration | Constraint | Resources | Work | Actual work | Acronym | PCG approved | WI rapporteur name | WI rapporteur e-mail | Release | TSG approved | Special Focus Doc | Acronym_3GU_Export | Status Report | MCC resp |
| --- | --- | --- | --- | --- | --- | --- | --- | --- | --- | --- | --- | --- | --- | --- | --- | --- | --- | --- | --- | --- | --- | --- | --- |
| 2270 | 524.98 | **LTE Advanced 3 Band Carrier Aggregation (3DL/1UL) of Band 1, Band 42 and Band 42** | 66d? | 2014-06-16 A | 2014-09-12 A | 100% | 2014-06-13 | 2014-09-12 | 66d? |  | R4 | 1584h | 1584h | LTE_CA_B1_B42_B42 | PCG-33 | NTT DOCOMO | ANDO Kei (kei.andou.ye@nttdocomo.com) | Rel-12 | RP-64 | CA | LTE_CA_B1_B42_B42 |  |  |
| 2271 | 524.98.1 | Core part: LTE Advanced 3 Band Carrier Aggregation (3DL/1UL) of Band 1, Band 42 and Band 42 | 66d? | 2014-06-16 A | 2014-09-12 A | 100% | 2014-06-13 | 2014-09-12 | 66d? | finish no earlier than 2014-09-12 | R4 | 528h | 528h | LTE_CA_B1_B42_B42-Core | PCG-33 | NTT DOCOMO | ANDO Kei (kei.andou.ye@nttdocomo.com) | Rel-12 | RP-64 | CA | LTE_CA_B1_B42_B42-Core | RP-141084 |  |
| 2272 | 524.98.2 | Perf. Part: LTE Advanced 3 Band Carrier Aggregation (3DL/1UL) of Band 1, Band 42 and Band 42 | 66d? | 2014-06-16 A | 2014-09-12 A | 100% | 2014-06-13 | 2014-09-12 | 66d? | finish no earlier than 2014-09-12 | R4 | 528h | 528h | LTE_CA_B1_B42_B42-Perf | PCG-33 | NTT DOCOMO | ANDO Kei (kei.andou.ye@nttdocomo.com) | Rel-12 | RP-64 | CA | LTE_CA_B1_B42_B42-Perf | RP-141084 |  |
| 2273 | 524.99 | **Additional bandwidth combination set for LTE Advanced intra-band contiguous Carrier Aggregation in Band 40 for 3DL** | 66d? | 2014-06-16 A | 2014-09-12 A | 100% | 2014-06-13 | 2014-09-12 | 66d? |  | R4 | 1096h | 1096h | LTE_CA_C_B40_3DL_BW | PCG-33 | TeliaSonera | Ralf.Schuh@TeliaSonera.com | Rel-12 | RP-64 | CA | LTE_CA_C_B40_3DL_BW |  |  |
| 2274 | 524.99.1 | Core part: Additional bandwidth combination set for LTE Advanced intra-band contiguous Carrier Aggregation in Band 40 for 3DL | 66d? | 2014-06-16 A | 2014-09-12 A | 100% | 2014-06-13 | 2014-09-12 | 66d? | finish no earlier than 2014-09-12 | R4 | 528h | 528h | LTE_CA_C_B40_3DL_BW-Core | PCG-33 | TeliaSonera | Ralf.Schuh@TeliaSonera.com | Rel-12 | RP-64 | CA | LTE_CA_C_B40_3DL_BW-Core | RP-141084 |  |
| 2275 | 524.99.2 | Perf. part: Additional bandwidth combination set for LTE Advanced intra-band contiguous Carrier Aggregation in Band 40 for 3DL | 5d? | 2014-09-08 A | 2014-09-12 A | 100% |  |  |  | finish no earlier than 2014-09-12 | R4 | 40h | 40h | LTE_CA_C_B40_3DL_BW-Perf | PCG-33 | TeliaSonera | Ralf.Schuh@TeliaSonera.com | Rel-12 | RP-65 |  | LTE_CA_C_B40_3DL_BW-Perf | RP-141084 |  |
| 2276 | 524.100 | **LTE Advanced inter-band Carrier Aggregation of Band 18 and Band 28** | 3d? | 2014-09-10 A | 2014-09-12 A | 100% | 2014-03-06 | 2015-03-13 | 267d? |  | R4 | 72h | 72h | LTE_CA_B18_B28 | PCG-33 | KDDI | Masaaki Obara (ms-obara@kddi.com) | Rel-12 | RP-65 | CA | LTE_CA_B18_B28 |  | Issam |
| 2277 | 524.100.1 | Core part: LTE Advanced inter-band Carrier Aggregation of Band 18 and Band 28 | 3d? | 2014-09-10 A | 2014-09-12 A | 100% | 2014-03-06 | 2015-03-13 | 267d? | finish no earlier than 2014-09-12 | R4 | 24h | 24h | LTE_CA_B18_B28-Core | PCG-33 | KDDI | Masaaki Obara (ms-obara@kddi.com) | Rel-12 | RP-65 | CA | LTE_CA_B18_B28-Core |  | Issam |
| 2278 | 524.100.2 | Perf. Part: LTE Advanced inter-band Carrier Aggregation of Band 18 and Band 28 | 3d? | 2014-09-10 A | 2014-09-12 A | 100% | 2014-03-06 | 2015-03-13 | 267d? | finish no earlier than 2014-09-12 | R4 | 24h | 24h | LTE_CA_B18_B28-Perf | PCG-33 | KDDI | Masaaki Obara (ms-obara@kddi.com) | Rel-12 | RP-65 | CA | LTE_CA_B18_B28-Perf |  | Issam |
| 2279 | 524.101 | **LTE Advanced inter-band Carrier Aggregation of Band 5 and Band 13** | 206d? | 2014-03-06 A | 2014-12-15 A | 100% | 2014-03-06 | 2014-12-05 | 197d? |  | R4 | 4896h | 4896h | LTE_CA_B5_B13 | PCG-32 | Intel | xinrong.wang@intel.com | Rel-12 | RP-63 | CA | LTE_CA_B5_B13 |  | Issam |
| 2280 | 524.101.1 | Core part: LTE Advanced inter-band Carrier Aggregation of Band 5 and Band 13 | 203d? | 2014-03-06 A | 2014-12-15 A | 100% | 2014-03-06 | 2014-12-05 | 197d? | finish no earlier than 2014-12-15 | R4 | 1624h | 1624h | LTE_CA_B5_B13-Core | PCG-32 | Intel | xinrong.wang@intel.com | Rel-12 | RP-63 | CA | LTE_CA_B5_B13-Core | RP-141732 | Issam |
| 2281 | 524.101.2 | Perf. part: LTE Advanced inter-band Carrier Aggregation of Band 5 and Band 13 | 203d? | 2014-03-06 A | 2014-12-15 A | 100% | 2014-03-06 | 2014-12-05 | 197d? | finish no earlier than 2014-12-15 | R4 | 1624h | 1624h | LTE_CA_B5_B13-Perf | PCG-32 | Intel | xinrong.wang@intel.com | Rel-12 | RP-63 | CA | LTE_CA_B5_B13-Perf | RP-141732 | Issam |
| 2282 | 524.102 | **LTE Advanced 3 Band Carrier Aggregation (3DL/1UL) of Band 2, Band 2 and Band 5** | 206d? | 2014-03-06 A | 2014-12-15 A | 100% | 2014-03-06 | 2014-12-05 | 197d? |  | R4 | 4912h | 4912h | LTE_CA_B2_B2_B5 | PCG-32 | Intel | peiling.zhang@intel.com | Rel-12 | RP-63 | CA | LTE_CA_B2_B2_B5 |  | Issam |
| 2283 | 524.102.1 | Core part: LTE Advanced 3 Band Carrier Aggregation (3DL/1UL) of Band 2, Band 2 and Band 5 | 205d? | 2014-03-06 A | 2014-12-15 A | 100% | 2014-03-06 | 2014-12-05 | 197d? | finish no earlier than 2014-12-15 | R4 | 1640h | 1640h | LTE_CA_B2_B2_B5-Core | PCG-32 | Intel | peiling.zhang@intel.com | Rel-12 | RP-63 | CA | LTE_CA_B2_B2_B5-Core | RP-141732 | Issam |
| 2284 | 524.102.2 | Perf. part: LTE Advanced 3 Band Carrier Aggregation (3DL/1UL) of Band 2, Band 2 and Band 5 | 203d? | 2014-03-06 A | 2014-12-15 A | 100% | 2014-03-06 | 2014-12-05 | 197d? | finish no earlier than 2014-12-15 | R4 | 1624h | 1624h | LTE_CA_B2_B2_B5-Perf | PCG-32 | Intel | peiling.zhang@intel.com | Rel-12 | RP-63 | CA | LTE_CA_B2_B2_B5-Perf | RP-141732 | Issam |
| 2285 | 524.103 | **LTE Advanced 3 Band Carrier Aggregation (3DL/1UL) of Band 4, Band 4 and Band 5** | 206d? | 2014-03-06 A | 2014-12-15 A | 100% | 2014-03-06 | 2014-12-05 | 197d? |  | R4 | 4912h | 4912h | LTE_CA_B4_B4_B5 | PCG-32 | Intel | peiling.zhang@intel.com | Rel-12 | RP-63 | CA | LTE_CA_B4_B4_B5 |  | Issam |
| 2286 | 524.103.1 | Core part: LTE Advanced 3 Band Carrier Aggregation (3DL/1UL) of Band 4, Band 4 and Band 5 | 205d? | 2014-03-06 A | 2014-12-15 A | 100% | 2014-03-06 | 2014-12-05 | 197d? | finish no earlier than 2014-12-15 | R4 | 1640h | 1640h | LTE_CA_B4_B4_B5-Core | PCG-32 | Intel | peiling.zhang@intel.com | Rel-12 | RP-63 | CA | LTE_CA_B4_B4_B5-Core | RP-141732 | Issam |
| 2287 | 524.103.2 | Perf. part: LTE Advanced 3 Band Carrier Aggregation (3DL/1UL) of Band 4, Band 4 and Band 5 | 203d? | 2014-03-06 A | 2014-12-15 A | 100% | 2014-03-06 | 2014-12-05 | 197d? | finish no earlier than 2014-12-15 | R4 | 1624h | 1624h | LTE_CA_B4_B4_B5-Perf | PCG-32 | Intel | peiling.zhang@intel.com | Rel-12 | RP-63 | CA | LTE_CA_B4_B4_B5-Perf | RP-141732 | Issam |
| 2288 | 524.104 | **LTE Advanced 3 Band Carrier Aggregation (3DL/1UL) of Band 2, Band 5 and Band 13** | 206d? | 2014-03-06 A | 2014-12-15 A | 100% | 2014-03-06 | 2014-12-05 | 197d? |  | R4 | 4896h | 4896h | LTE_CA_B2_B5_B13 | PCG-32 | Intel | xinrong.wang@intel.com | Rel-12 | RP-63 | CA | LTE_CA_B2_B5_B13 |  | Issam |
| 2289 | 524.104.1 | Core part: LTE Advanced 3 Band Carrier Aggregation (3DL/1UL) of Band 2, Band 5 and Band 13 | 203d? | 2014-03-06 A | 2014-12-15 A | 100% | 2014-03-06 | 2014-12-05 | 197d? | finish no earlier than 2014-12-15 | R4 | 1624h | 1624h | LTE_CA_B2_B5_B13-Core | PCG-32 | Intel | xinrong.wang@intel.com | Rel-12 | RP-63 | CA | LTE_CA_B2_B5_B13-Core | RP-141732 | Issam |
| 2290 | 524.104.2 | Perf. part: LTE Advanced 3 Band Carrier Aggregation (3DL/1UL) of Band 2, Band 5 and Band 13 | 203d? | 2014-03-06 A | 2014-12-15 A | 100% | 2014-03-06 | 2014-12-05 | 197d? | finish no earlier than 2014-12-15 | R4 | 1624h | 1624h | LTE_CA_B2_B5_B13-Perf | PCG-32 | Intel | xinrong.wang@intel.com | Rel-12 | RP-63 | CA | LTE_CA_B2_B5_B13-Perf | RP-141732 | Issam |
| 2291 | 524.105 | **LTE Advanced 3 Band Carrier Aggregation (3DL/1UL) of Band 4, Band 5 and Band 13** | 206d? | 2014-03-06 A | 2014-12-15 A | 100% | 2014-03-06 | 2014-12-05 | 197d? |  | R4 | 4896h | 4896h | LTE_CA_B4_B5_B13 | PCG-32 | Intel | xinrong.wang@intel.com | Rel-12 | RP-63 | CA | LTE_CA_B4_B5_B13 |  | Issam |
| 2292 | 524.105.1 | Core part: LTE Advanced 3 Band Carrier Aggregation (3DL/1UL) of Band 4, Band 5 and Band 13 | 203d? | 2014-03-06 A | 2014-12-15 A | 100% | 2014-03-06 | 2014-12-05 | 197d? | finish no earlier than 2014-12-15 | R4 | 1624h | 1624h | LTE_CA_B4_B5_B13-Core | PCG-32 | Intel | xinrong.wang@intel.com | Rel-12 | RP-63 | CA | LTE_CA_B4_B5_B13-Core | RP-141732 | Issam |
| 2293 | 524.105.2 | Perf. part: LTE Advanced 3 Band Carrier Aggregation (3DL/1UL) of Band 4, Band 5 and Band 13 | 203d? | 2014-03-06 A | 2014-12-15 A | 100% | 2014-03-06 | 2014-12-05 | 197d? | finish no earlier than 2014-12-15 | R4 | 1624h | 1624h | LTE_CA_B4_B5_B13-Perf | PCG-32 | Intel | xinrong.wang@intel.com | Rel-12 | RP-63 | CA | LTE_CA_B4_B5_B13-Perf | RP-141732 | Issam |

Notes:
- 2270: Inter-band CA 3DL / Impacted TSs and TRs: LTE
- 2271: RP#65 completed / Impacted TSs and TRs: 36.101, 36.104, 36.133, generic TR 36.853 (3 Band CA with 1UL)
- 2272: RP#65 completed / Impacted TSs and TRs: 36.141, 36.307
- 2273: Inter-band CA 3DL / Impacted TSs and TRs: LTE
- 2274: RP#65 completed. Updated WID RP-140950=>RP-141127 / Impacted TSs and TRs: 36.101
- 2275: RP#65 updated WID RP-140950=>RP-141127 (added Perf. Part). Completed. / Impacted TSs and TRs: 36.307
- 2276: Inter-band CA 2DL / Impacted TSs and TRs: LTE
- 2277: RP#65 WID approved & completed. Triggered by revised Rel-13 WID RP-140451=>RP-141610 (take out B18_B28 for Rel-12 from the Rel-13 B1_B18_B28) / Impacted TSs and TRs: 36.101, 36.104, 36.133
- 2278: - / Impacted TSs and TRs: 36.141, 36.307
- 2279: Inter-band CA 2DL / Impacted TSs and TRs: LTE
- 2280: CD:Thu 12/03/15->Mon 15/12/14; Compl:50%->100%; Stat Rep: RP-141084->RP-141732; Release: Rel-13->Rel-12 / Impacted TSs and TRs: 36.101, 36.104, 36.133, generic TR 36.851 (2 Band CA with 1UL)
- 2281: CD:Thu 12/03/15->Mon 15/12/14; Compl:10%->100%; Stat Rep: RP-141084->RP-141732; Release: Rel-13->Rel-12 / Impacted TSs and TRs: 36.101, 36.133, 36.141, 36.307
- 2282: Inter-band CA 3DL / Impacted TSs and TRs: LTE
- 2283: CD:Thu 12/03/15->Mon 15/12/14; Compl:90%->100%; Stat Rep: RP-141084->RP-141732; Release: Rel-13->Rel-12 / Impacted TSs and TRs: 36.101, 36.104, 36.133, generic TR 36.853 (3 Band CA with 1UL)
- 2284: CD:Thu 12/03/15->Mon 15/12/14; Compl:10%->100%; Stat Rep: RP-141084->RP-141732; Release: Rel-13->Rel-12 / Impacted TSs and TRs: 36.101, 36.133, 36.141, 36.307
- 2285: Inter-band CA 3DL / Impacted TSs and TRs: LTE
- 2286: CD:Thu 12/03/15->Mon 15/12/14; Compl:90%->100%; Stat Rep: RP-141084->RP-141732; Release: Rel-13->Rel-12 / Impacted TSs and TRs: 36.101, 36.104, 36.133, generic TR 36.853 (3 Band CA with 1UL)
- 2287: CD:Thu 12/03/15->Mon 15/12/14; Compl:10%->100%; Stat Rep: RP-141084->RP-141732; Release: Rel-13->Rel-12 / Impacted TSs and TRs: 36.101, 36.133, 36.141, 36.307
- 2288: Inter-band CA 3DL / Impacted TSs and TRs: LTE
- 2289: CD:Thu 12/03/15->Mon 15/12/14; Compl:50%->100%; Stat Rep: RP-141084->RP-141732; Release: Rel-13->Rel-12 / Impacted TSs and TRs: 36.101, 36.104, 36.133, generic TR 36.853 (3 Band CA with 1UL)
- 2290: CD:Thu 12/03/15->Mon 15/12/14; Compl:10%->100%; Stat Rep: RP-141084->RP-141732; Release: Rel-13->Rel-12 / Impacted TSs and TRs: 36.101, 36.133, 36.141, 36.307
- 2291: Inter-band CA 3DL / Impacted TSs and TRs: LTE
- 2292: CD:Thu 12/03/15->Mon 15/12/14; Compl:50%->100%; Stat Rep: RP-141084->RP-141732; Release: Rel-13->Rel-12 / Impacted TSs and TRs: 36.101, 36.104, 36.133, generic TR 36.853 (3 Band CA with 1UL)
- 2293: CD:Thu 12/03/15->Mon 15/12/14; Compl:10%->100%; Stat Rep: RP-141084->RP-141732; Release: Rel-13->Rel-12 / Impacted TSs and TRs: 36.101, 36.133, 36.141, 36.307

| ID | WBS | Task | Duration | Start | Finish | Complete | Remaining | Baseline start | Baseline finish | Baseline duration | Total slack | Constraint | Resources | Work | Actual work | Acronym | PCG approved | WI rapporteur name | WI rapporteur e-mail | Release | TSG approved | MCC resp | Special Focus Doc | Acronym_3GU_Export | Status Report |
| --- | --- | --- | --- | --- | --- | --- | --- | --- | --- | --- | --- | --- | --- | --- | --- | --- | --- | --- | --- | --- | --- | --- | --- | --- | --- |
| 2294 | 524.106 | **LTE Advanced 3 Band Carrier Aggregation (3DL/1UL) of Band 1, Band 3 and Band 26** | 206d? | 2014-03-06 A | 2014-12-15 A | 100% |  | 2014-03-06 | 2014-12-05 | 197d? |  |  | R4 | 4896h | 4896h | LTE_CA_B1_B3_B26 | PCG-32 | China Telecom | Zhao Dong (zhaodong@ctbri.com.cn) | Rel-12 | RP-63 | Issam | CA | LTE_CA_B1_B3_B26 |  |
| 2295 | 524.106.1 | Core part: LTE Advanced 3 Band Carrier Aggregation (3DL/1UL) of Band 1, Band 3 and Band 26 | 203d? | 2014-03-06 A | 2014-12-15 A | 100% |  | 2014-03-06 | 2014-12-05 | 197d? |  | finish no earlier than 2014-12-15 | R4 | 1624h | 1624h | LTE_CA_B1_B3_B26-Core | PCG-32 | China Telecom | Zhao Dong (zhaodong@ctbri.com.cn) | Rel-12 | RP-63 | Issam | CA | LTE_CA_B1_B3_B26-Core | RP-141732 |
| 2296 | 524.106.2 | Perf. part: LTE Advanced 3 Band Carrier Aggregation (3DL/1UL) of Band 1, Band 3 and Band 26 | 203d? | 2014-03-06 A | 2014-12-15 A | 100% |  | 2014-03-06 | 2014-12-05 | 197d? |  | finish no earlier than 2014-12-15 | R4 | 1624h | 1624h | LTE_CA_B1_B3_B26-Perf | PCG-32 | China Telecom | Zhao Dong (zhaodong@ctbri.com.cn) | Rel-12 | RP-63 | Issam | CA | LTE_CA_B1_B3_B26-Perf | RP-141732 |
| 2297 | 524.107 | **LTE Advanced 3 Band Carrier Aggregation (3DL/1UL) of Band 1, Band 18 and Band 28** | 206d? | 2014-03-06 A | 2014-12-15 A | 100% |  | 2014-03-06 | 2015-03-13 | 267d? |  |  | R4 | 4896h | 4896h | LTE_CA_B1_B18_B28 | PCG-32 | KDDI | Masaaki Obara (ms-obara@kddi.com) | Rel-12 | RP-63 | Issam | CA | LTE_CA_B1_B18_B28 |  |
| 2298 | 524.107.1 | Core part: LTE Advanced 3 Band Carrier Aggregation (3DL/1UL) of Band 1, Band 18 and Band 28 | 203d? | 2014-03-06 A | 2014-12-15 A | 100% |  | 2014-03-06 | 2015-03-13 | 267d? |  | finish no earlier than 2014-12-15 | R4 | 1624h | 1624h | LTE_CA_B1_B18_B28-Core | PCG-32 | KDDI | Masaaki Obara (ms-obara@kddi.com) | Rel-12 | RP-63 | Issam | CA | LTE_CA_B1_B18_B28-Core | RP-141732 |
| 2299 | 524.107.2 | Perf. part: LTE Advanced 3 Band Carrier Aggregation (3DL/1UL) of Band 1, Band 18 and Band 28 | 203d? | 2014-03-11 A | 2014-12-15 A | 100% |  | 2014-03-06 | 2015-03-13 | 267d? |  | finish no earlier than 2014-12-15 | R4 | 1624h | 1624h | LTE_CA_B1_B18_B28-Perf | PCG-32 | KDDI | Masaaki Obara (ms-obara@kddi.com) | Rel-12 | RP-63 | Issam | CA | LTE_CA_B1_B18_B28-Perf | RP-141732 |
| 2300 | 524.108 | **LTE Advanced 3 Band Carrier Aggregation (3DL/1UL) of Band 4, Band 7 and Band 12** | 132d? | 2014-06-18 A | 2014-12-15 A | 100% |  | 2014-06-13 | 2015-03-13 | 196d? |  |  | R4 | 3168h | 3168h | LTE_CA_B4_B7_B12 | PCG-33 | Rogers Wireless | pavlo.nebesny@rci.rogers.com | Rel-12 | RP-64 |  | CA | LTE_CA_B4_B7_B12 |  |
| 2301 | 524.108.1 | Core part: LTE Advanced 3 Band Carrier Aggregation (3DL/1UL) of Band 4, Band 7 and Band 12 | 132d? | 2014-06-18 A | 2014-12-15 A | 100% |  | 2014-06-13 | 2015-03-13 | 196d? |  | finish no earlier than 2014-12-15 | R4 | 1056h | 1056h | LTE_CA_B4_B7_B12-Core | PCG-33 | Rogers Wireless | pavlo.nebesny@rci.rogers.com | Rel-12 | RP-64 |  | CA | LTE_CA_B4_B7_B12-Core | RP-141732 |
| 2302 | 524.108.2 | Perf. Part: LTE Advanced 3 Band Carrier Aggregation (3DL/1UL) of Band 4, Band 7 and Band 12 | 132d? | 2014-06-18 A | 2014-12-15 A | 100% |  | 2014-06-13 | 2015-03-13 | 196d? |  | finish no earlier than 2014-12-15 | R4 | 1056h | 1056h | LTE_CA_B4_B7_B12-Perf | PCG-33 | Rogers Wireless | pavlo.nebesny@rci.rogers.com | Rel-12 | RP-64 |  | CA | LTE_CA_B4_B7_B12-Perf | RP-141732 |
| 2303 | 524.109 | **LTE Advanced 3 Band Carrier Aggregation (3DL/1UL) of Band 4, Band 4 and Band 7** | 132d? | 2014-06-18 A | 2014-12-15 A | 100% |  | 2014-06-13 | 2015-03-13 | 196d? |  |  | R4 | 3168h | 3168h | LTE_CA_B4_B4_B7 | PCG-33 | Rogers Wireless | pavlo.nebesny@rci.rogers.com | Rel-12 | RP-64 |  | CA | LTE_CA_B4_B4_B7 |  |
| 2304 | 524.109.1 | Core part: LTE Advanced 3 Band Carrier Aggregation (3DL/1UL) of Band 4, Band 4 and Band 7 | 132d? | 2014-06-18 A | 2014-12-15 A | 100% |  | 2014-06-13 | 2015-03-13 | 196d? |  | finish no earlier than 2014-12-15 | R4 | 1056h | 1056h | LTE_CA_B4_B4_B7-Core | PCG-33 | Rogers Wireless | pavlo.nebesny@rci.rogers.com | Rel-12 | RP-64 |  | CA | LTE_CA_B4_B4_B7-Core | RP-141732 |
| 2305 | 524.109.2 | Perf. Part: LTE Advanced 3 Band Carrier Aggregation (3DL/1UL) of Band 4, Band 4 and Band 7 | 132d? | 2014-06-18 A | 2014-12-15 A | 100% |  | 2014-06-13 | 2015-03-13 | 196d? |  | finish no earlier than 2014-12-15 | R4 | 1056h | 1056h | LTE_CA_B4_B4_B7-Perf | PCG-33 | Rogers Wireless | pavlo.nebesny@rci.rogers.com | Rel-12 | RP-64 |  | CA | LTE_CA_B4_B4_B7-Perf | RP-141732 |
| 2306 | 524.110 | **LTE Advanced 3 Band Carrier Aggregation (3DL/1UL) of Band 39, Band 41 and Band 41** | 134d? | 2014-06-16 A | 2014-12-15 A | 100% |  | 2014-06-13 | 2014-12-05 | 126d? |  |  | R4 | 3184h | 3184h | LTE_CA_B39_B41_B41 | PCG-33 | China Mobile | PAN Qun (panqun@chinamobile.com) | Rel-12 | RP-64 |  | CA | LTE_CA_B39_B41_B41 |  |
| 2307 | 524.110.1 | Core part: LTE Advanced 3 Band Carrier Aggregation (3DL/1UL) of Band 39, Band 41 and Band 41 | 132d? | 2014-06-16 A | 2014-12-15 A | 100% |  | 2014-06-13 | 2014-12-05 | 126d? |  | finish no earlier than 2014-12-15 | R4 | 1056h | 1056h | LTE_CA_B39_B41_B41-Core | PCG-33 | China Mobile | PAN Qun (panqun@chinamobile.com) | Rel-12 | RP-64 |  | CA | LTE_CA_B39_B41_B41-Core | RP-141732 |
| 2308 | 524.110.2 | Perf. Part: LTE Advanced 3 Band Carrier Aggregation (3DL/1UL) of Band 39, Band 41 and Band 41 | 132d? | 2014-06-18 A | 2014-12-15 A | 100% |  | 2014-06-13 | 2014-12-05 | 126d? |  | finish no earlier than 2014-12-15 | R4 | 1056h | 1056h | LTE_CA_B39_B41_B41-Perf | PCG-33 | China Mobile | PAN Qun (panqun@chinamobile.com) | Rel-12 | RP-64 |  | CA | LTE_CA_B39_B41_B41-Perf | RP-141732 |
| 2309 | 524.111 | **LTE Advanced 3 Band Carrier Aggregation (3DL/1UL) of Band 1, Band 41 and Band 41** | 132d? | 2014-06-18 A | 2014-12-15 | 50% | 66d? | 2014-06-13 | 2015-03-13 | 196d? | 1049d |  | R4 | 3168h | 1584h | LTE_CA_B1_B41_B41 | PCG-33 | KDDI | Masaaki Obara (ms-obara@kddi.com) | Rel-12 | RP-64 |  | CA | LTE_CA_B1_B41_B41 |  |
| 2310 | 524.111.1 | Core part: LTE Advanced 3 Band Carrier Aggregation (3DL/1UL) of Band 1, Band 41 and Band 41 | 132d? | 2014-06-18 A | 2014-12-15 A | 100% |  | 2014-06-13 | 2015-03-13 | 196d? |  | finish no earlier than 2014-12-15 | R4 | 1056h | 1056h | LTE_CA_B1_B41_B41-Core | PCG-33 | KDDI | Masaaki Obara (ms-obara@kddi.com) | Rel-12 | RP-64 |  | CA | LTE_CA_B1_B41_B41-Core | RP-141732 |
| 2311 | 524.111.2 | Perf. Part: LTE Advanced 3 Band Carrier Aggregation (3DL/1UL) of Band 1, Band 41 and Band 41 | 132d? | 2014-06-18 | 2014-12-15 |  |  | 2014-06-13 | 2015-03-13 | 196d? | 1049d | finish no earlier than 2014-12-15 | R4 | 1056h |  | LTE_CA_B1_B41_B41-Perf | PCG-33 | KDDI | Masaaki Obara (ms-obara@kddi.com) | Rel-12 | RP-64 |  | CA | LTE_CA_B1_B41_B41-Perf | RP-141732 |
| 2312 | 524.112 | **LTE Advanced 3 Band Carrier Aggregation (3DL/1UL) of Band 26, Band 41 and Band 41** | 132d? | 2014-06-18 A | 2014-12-15 | 50% | 66d? | 2014-06-13 | 2015-03-13 | 196d? | 1049d |  | R4 | 3168h | 1584h | LTE_CA_B26_B41_B41 | PCG-33 | KDDI | Masaaki Obara (ms-obara@kddi.com) | Rel-12 | RP-64 |  | CA | LTE_CA_B26_B41_B41 |  |
| 2313 | 524.112.1 | Core part: LTE Advanced 3 Band Carrier Aggregation (3DL/1UL) of Band 26, Band 41 and Band 41 | 132d? | 2014-06-18 A | 2014-12-15 A | 100% |  | 2014-06-13 | 2015-03-13 | 196d? |  | finish no earlier than 2014-12-15 | R4 | 1056h | 1056h | LTE_CA_B26_B41_B41-Core | PCG-33 | KDDI | Masaaki Obara (ms-obara@kddi.com) | Rel-12 | RP-64 |  | CA | LTE_CA_B26_B41_B41-Core | RP-141732 |
| 2314 | 524.112.2 | Perf. Part: LTE Advanced 3 Band Carrier Aggregation (3DL/1UL) of Band 26, Band 41 and Band 41 | 132d? | 2014-06-18 | 2014-12-15 |  |  | 2014-06-13 | 2015-03-13 | 196d? | 1049d | finish no earlier than 2014-12-15 | R4 | 1056h |  | LTE_CA_B26_B41_B41-Perf | PCG-33 | KDDI | Masaaki Obara (ms-obara@kddi.com) | Rel-12 | RP-64 |  | CA | LTE_CA_B26_B41_B41-Perf | RP-141732 |
| 2315 | 524.113 | **LTE Advanced 3 Band Carrier Aggregation (3DL/1UL) of Band 25, Band 41 and Band 41** | 68d? | 2014-09-15 A | 2014-12-15 A | 100% |  | 2014-06-13 | 2015-03-13 | 196d? |  |  | R4 | 1632h | 1632h | LTE_CA_B25_B41_B41 | PCG-33 | Alcatel-Lucent | Ng, Man Hung (man-hung.ng@alcatel-lucent.com) | Rel-12 | RP-65 |  | CA | LTE_CA_B25_B41_B41 |  |
| 2316 | 524.113.1 | Core part: LTE Advanced 3 Band Carrier Aggregation (3DL/1UL) of Band 25, Band 41 and Band 41 | 68d? | 2014-09-15 A | 2014-12-15 A | 100% |  | 2014-06-13 | 2015-03-13 | 196d? |  | finish no earlier than 2014-12-15 | R4 | 544h | 544h | LTE_CA_B25_B41_B41-Core | PCG-33 | Alcatel-Lucent | Ng, Man Hung (man-hung.ng@alcatel-lucent.com) | Rel-12 | RP-65 |  | CA | LTE_CA_B25_B41_B41-Core | RP-141732 |
| 2317 | 524.113.2 | Perf. Part: LTE Advanced 3 Band Carrier Aggregation (3DL/1UL) of Band 25, Band 41 and Band 41 | 68d? | 2014-09-15 A | 2014-12-15 A | 100% |  | 2014-06-13 | 2015-03-13 | 196d? |  | finish no earlier than 2014-12-15 | R4 | 544h | 544h | LTE_CA_B25_B41_B41-Perf | PCG-33 | Alcatel-Lucent | Ng, Man Hung (man-hung.ng@alcatel-lucent.com) | Rel-12 | RP-65 |  | CA | LTE_CA_B25_B41_B41-Perf | RP-141732 |

Notes:
- 2294: Inter-band CA 3DL / Impacted TSs and TRs: LTE
- 2295: CD:Thu 11/12/14->Mon 15/12/14; Compl:90%->100%; Stat Rep: RP-141084->RP-141732; Release: Rel-13->Rel-12 / Impacted TSs and TRs: 36.101, 36.104, 36.133, generic TR 36.853 (3 Band CA with 1UL)
- 2296: CD:Thu 11/12/14->Mon 15/12/14; Compl:90%->100%; Stat Rep: RP-141084->RP-141732; Release: Rel-13->Rel-12 / Impacted TSs and TRs: 36.141, 36.307
- 2297: Inter-band CA 3DL / Impacted TSs and TRs: LTE
- 2298: ; WID: RP-142043->RP-141788; Stat Rep: RP-141084->RP-141732; Release: Rel-13->Rel-12 / Impacted TSs and TRs: 36.101, 36.104, 36.133, generic TR 36.853 (3 Band CA with 1UL)
- 2299: ; WID: RP-142043->RP-141788; Stat Rep: RP-141084->RP-141732; Release: Rel-13->Rel-12 / Impacted TSs and TRs: 36.141, 36.307
- 2300: Inter-band CA 3DL/1UL / Impacted TSs and TRs: LTE
- 2301: CD:Thu 12/03/15->Mon 15/12/14; Compl:0%->100%; Stat Rep: RP-141084->RP-141732; Release: Rel-13->Rel-12 / Impacted TSs and TRs: 36.101, 36.104, 36.133, 36.307, generic TR 36.851 (2 Band CA with 1UL), generic TR 36.853 (3 Band CA with 1UL)
- 2302: CD:Thu 12/03/15->Mon 15/12/14; Compl:0%->100%; Stat Rep: RP-141084->RP-141732; Release: Rel-13->Rel-12 / Impacted TSs and TRs: 36.133, 36.141
- 2303: Inter-band CA 3DL/1UL / Impacted TSs and TRs: LTE
- 2304: CD:Thu 12/03/15->Mon 15/12/14; Compl:0%->100%; Stat Rep: RP-141084->RP-141732; Release: Rel-13->Rel-12 / Impacted TSs and TRs: 36.101, 36.104, 36.133, 36.307, generic TR 36.853 (3 Band CA with 1UL)
- 2305: CD:Thu 12/03/15->Mon 15/12/14; Compl:0%->100%; Stat Rep: RP-141084->RP-141732; Release: Rel-13->Rel-12 / Impacted TSs and TRs: 36.133, 36.141
- 2306: Inter-band CA 3DL/1UL / Impacted TSs and TRs: LTE
- 2307: ; WID: RP-140708->RP-142301; Stat Rep: RP-141084->RP-141732; Release: Rel-13->Rel-12 / Impacted TSs and TRs: 36.101, 36.104, 36.133, generic TR 36.853 (3 Band CA with 1UL)
- 2308: ; WID: RP-140708->RP-142301; Stat Rep: RP-141084->RP-141732; Release: Rel-13->Rel-12 / Impacted TSs and TRs: 36.141, 36.307
- 2309: Inter-band CA 3DL/1UL / Impacted TSs and TRs: LTE
- 2310: ; WID: RP-142043->RP-142297; Stat Rep: RP-141084->RP-141732; Release: Rel-13->Rel-12 / Impacted TSs and TRs: 36.101, 36.104, 36.133, generic TR 36.853 (3 Band CA with 1UL)
- 2311: Compl:100%->0%; WID: RP-142043->RP-142297; Stat Rep: RP-141084->RP-141732; Release: Rel-13->Rel-12 / Impacted TSs and TRs: 36.141, 36.307
- 2312: Inter-band CA 3DL/1UL / Impacted TSs and TRs: LTE
- 2313: ; WID: RP-142043->RP-142298; Stat Rep: RP-141084->RP-141732; Release: Rel-13->Rel-12 / Impacted TSs and TRs: 36.101, 36.104, 36.133, generic TR 36.853 (3 Band CA with 1UL)
- 2314: Compl:100%->0%; WID: RP-142043->RP-142298; Stat Rep: RP-141084->RP-141732; Release: Rel-13->Rel-12 / Impacted TSs and TRs: 36.141, 36.307
- 2315: Inter-band CA 3DL/1UL / Impacted TSs and TRs: LTE
- 2316: ; WID: RP-142043->RP-142018; Stat Rep: -->RP-141732; Release: Rel-13->Rel-12 / Impacted TSs and TRs: 36.101, 36.104, 36.307, New TR 36.833-x-yz
- 2317: ; WID: RP-142043->RP-142018; Stat Rep: -->RP-141732; Release: Rel-13->Rel-12 / Impacted TSs and TRs: 36.141

| ID | WBS | Task | Duration | Start | Finish | Complete | Baseline start | Baseline finish | Baseline duration | Constraint | Resources | Work | Actual work | Acronym | PCG approved | WI rapporteur name | WI rapporteur e-mail | Release | TSG approved | Special Focus Doc | Acronym_3GU_Export | Status Report | MCC resp | PCG stopped | TSG stopped |
| --- | --- | --- | --- | --- | --- | --- | --- | --- | --- | --- | --- | --- | --- | --- | --- | --- | --- | --- | --- | --- | --- | --- | --- | --- | --- |
| 2318 | 524.114 | **LTE Advanced 3 Band Carrier Aggregation (3DL/1UL) of Band 39, Band 39 and Band 41** | 68d? | 2014-09-15 A | 2014-12-15 A | 100% | 2014-06-13 | 2015-03-13 | 196d? |  | R4 | 1632h | 1632h | LTE_CA_B39_B39_B41 | PCG-33 | China Mobile | PAN, Qun (panqun@chinamobile.com) | Rel-12 | RP-65 | CA | LTE_CA_B39_B39_B41 |  |  |  |  |
| 2319 | 524.114.1 | Core part: LTE Advanced 3 Band Carrier Aggregation (3DL/1UL) of Band 39, Band 39 and Band 41 | 68d? | 2014-09-15 A | 2014-12-15 A | 100% | 2014-06-13 | 2015-03-13 | 196d? | finish no earlier than 2014-12-15 | R4 | 544h | 544h | LTE_CA_B39_B39_B41-Core | PCG-33 | China Mobile | PAN, Qun (panqun@chinamobile.com) | Rel-12 | RP-65 | CA | LTE_CA_B39_B39_B41-Core | RP-141732 |  |  |  |
| 2320 | 524.114.2 | Perf. Part: LTE Advanced 3 Band Carrier Aggregation (3DL/1UL) of Band 39, Band 39 and Band 41 | 68d? | 2014-09-15 A | 2014-12-15 A | 100% | 2014-06-13 | 2015-03-13 | 196d? | finish no earlier than 2014-12-15 | R4 | 544h | 544h | LTE_CA_B39_B39_B41-Perf | PCG-33 | China Mobile | PAN, Qun (panqun@chinamobile.com) | Rel-12 | RP-65 | CA | LTE_CA_B39_B39_B41-Perf | RP-141732 |  |  |  |
| 2321 | 524.115 | **LTE Advanced 3 Band Carrier Aggregation (3DL/1UL) of Band 2, Band 2 and Band 29** | 68d? | 2014-09-15 A | 2014-12-15 A | 100% | 2014-06-13 | 2015-03-13 | 196d? |  | R4 | 1632h | 1632h | LTE_CA_B2_B2_B29 | PCG-33 | AT&T | marc.grant@att.com | Rel-12 | RP-65 | CA | LTE_CA_B2_B2_B29 |  |  |  |  |
| 2322 | 524.115.1 | Core part: LTE Advanced 3 Band Carrier Aggregation (3DL/1UL) of Band 2, Band 2 and Band 29 | 68d? | 2014-09-15 A | 2014-12-15 A | 100% | 2014-06-13 | 2015-03-13 | 196d? | finish no earlier than 2014-12-15 | R4 | 544h | 544h | LTE_CA_B2_B2_B29-Core | PCG-33 | AT&T | marc.grant@att.com | Rel-12 | RP-65 | CA | LTE_CA_B2_B2_B29-Core | RP-141732 |  |  |  |
| 2323 | 524.115.2 | Perf. Part: LTE Advanced 3 Band Carrier Aggregation (3DL/1UL) of Band 2, Band 2 and Band 29 | 68d? | 2014-09-15 A | 2014-12-15 A | 100% | 2014-06-13 | 2015-03-13 | 196d? | finish no earlier than 2014-12-15 | R4 | 544h | 544h | LTE_CA_B2_B2_B29-Perf | PCG-33 | AT&T | marc.grant@att.com | Rel-12 | RP-65 | CA | LTE_CA_B2_B2_B29-Perf | RP-141732 |  |  |  |
| 2324 | 524.116 | **LTE Advanced 3 Band Carrier Aggregation (3DL/1UL) of Band 2, Band 4 and Band 29** | 68d? | 2014-09-15 A | 2014-12-15 A | 100% | 2014-06-13 | 2015-03-13 | 196d? |  | R4 | 1632h | 1632h | LTE_CA_B2_B4_B29 | PCG-33 | Huawei | SHAN Huiping (shanhuiping@huawei.com) | Rel-12 | RP-65 | CA | LTE_CA_B2_B4_B29 |  |  |  |  |
| 2325 | 524.116.1 | Core part: LTE Advanced 3 Band Carrier Aggregation (3DL/1UL) of Band 2, Band 4 and Band 29 | 68d? | 2014-09-15 A | 2014-12-15 A | 100% | 2014-06-13 | 2015-03-13 | 196d? | finish no earlier than 2014-12-15 | R4 | 544h | 544h | LTE_CA_B2_B4_B29-Core | PCG-33 | Huawei | SHAN Huiping (shanhuiping@huawei.com) | Rel-12 | RP-65 | CA | LTE_CA_B2_B4_B29-Core | RP-141732 |  |  |  |
| 2326 | 524.116.2 | Perf. Part: LTE Advanced 3 Band Carrier Aggregation (3DL/1UL) of Band 2, Band 4 and Band 29 | 68d? | 2014-09-15 A | 2014-12-15 A | 100% | 2014-06-13 | 2015-03-13 | 196d? | finish no earlier than 2014-12-15 | R4 | 544h | 544h | LTE_CA_B2_B4_B29-Perf | PCG-33 | Huawei | SHAN Huiping (shanhuiping@huawei.com) | Rel-12 | RP-65 | CA | LTE_CA_B2_B4_B29-Perf | RP-141732 |  |  |  |
| 2327 | 525 | UE Conformance Test Aspects – Further Rel-12 configurations for LTE Advanced Carrier Aggregation | 393d? | 2013-09-15 A | 2015-03-15 A | 100% | 2013-09-09 | 2014-12-05 | 327d? | finish no earlier than 2015-03-15 | R5 | 3144h | 3144h | LTE_CA_Rel12-UEConTest | PCG-31 | Microsoft | jussi.kuusisto@microsoft.com | Rel-12 | RP-61 | CA | LTE_CA_Rel12-UEConTest | RP-150076 | Ingbert |  |  |
| 2328 | 526 | UE Conformance Test Aspects – Further Rel-12 configurations for LTE Advanced Carrier Aggregation with 3DL | 394d? | 2014-09-15 A | 2016-03-15 A | 100% |  |  |  | finish no earlier than 2016-03-15 | R5 | 3152h | 3152h | LTE_CA_Rel12_3DL-UEConTest | PCG-33 | Microsoft | jussi.kuusisto@microsoft.com | Rel-12 | RP-65 | CA | LTE_CA_Rel12_3DL-UEConTest | RP-151464 |  |  |  |
| 2329 | 527 | **Deleted - Carrier based HetNet ICIC for LTE** | 595d? | 2011-03-18 A | 2013-06-14 A | 100% | 2011-03-18 | 2013-06-14 | 595d? |  | R3; R1; R2 | 28560h | 28560h | LTE_CA_HetNet_ICIC | PCG-26 | Nokia Siemens Networks | krzysztof.kordybach@nsn.com | Rel-12 | RP-51 |  | LTE_CA_HetNet_ICIC |  | Juha | PCG-31 | RP-60 |
| 2330 | 527.1 | Deleted - Core part: Carrier based HetNet ICIC for LTE | 595d? | 2011-03-18 A | 2013-06-14 A | 100% | 2011-03-18 | 2013-06-14 | 595d? | finish no earlier than 2013-06-14 | R3; R1; R2 | 14280h | 14280h | LTE_CA_HetNet_ICIC-Core | PCG-26 | Nokia Siemens Networks | krzysztof.kordybach@nsn.com | Rel-12 | RP-51 |  | LTE_CA_HetNet_ICIC-Core | RP-130500 | Juha | PCG-31 | RP-60 |
| 2331 | 528 | **LTE in the US Wireless Communications Service (WCS) Band 30** | 600d? | 2012-09-12 A | 2014-12-15 A | 100% | 2012-09-12 | 2014-12-05 | 591d? |  | R4; R2; R5 | 20312h | 20312h | LTE_WCS_band | PCG-29 | AT&T | marc.grant@att.com | Rel-12 | RP-57 |  | LTE_WCS_band |  | Issam |  |  |
| 2332 | 528.1 | Core part: LTE in the US Wireless Communications Service (WCS) Band 30 | 202d? | 2012-09-12 A | 2013-06-14 A | 100% | 2012-09-12 | 2013-06-14 | 202d? | finish no earlier than 2013-06-14 | R4; R2 | 3232h | 3232h | LTE_WCS_band-Core | PCG-29 | AT&T | marc.grant@att.com | Rel-12 | RP-57 |  | LTE_WCS_band-Core | RP-130569 | Issam |  |  |
| 2333 | 528.2 | Perf. Part: LTE in the US Wireless Communications Service (WCS) Band 30 | 201d? | 2012-09-13 A | 2013-06-14 A | 100% | 2012-09-13 | 2013-06-14 | 201d? | finish no earlier than 2013-06-14 | R4 | 1608h | 1608h | LTE_WCS_band-Perf | PCG-29 | AT&T | marc.grant@att.com | Rel-12 | RP-57 |  | LTE_WCS_band-Perf | RP-130570 | Issam |  |  |
| 2334 | 528.3 | Test Part: LTE in the US Wireless Communications Service (WCS) Band 30 | 134d? | 2014-06-15 A | 2014-12-15 A | 100% | 2014-06-13 | 2014-12-05 | 126d? | finish no earlier than 2014-12-15 | R5 | 1072h | 1072h | LTE_WCS_band-UEConTest | PCG-33 | Ericsson | fredrik.sundstrom@ericsson.com | Rel-12 | RP-64 |  | LTE_WCS_band-UEConTest | RP-141773 |  |  |  |
| 2335 | 529 | **Introduction of LTE 450 MHz band in Brazil** | 331d? | 2012-09-11 A | 2013-12-06 A | 100% | 2012-09-11 | 2013-12-06 | 331d? |  | R4; R5 | 10000h | 10000h | LTE450_Brazil | PCG-29 | Huawei | Liehai Liu (liuliehai@huawei.com) | Rel-12 | RP-57 |  | LTE450_Brazil |  | Issam |  |  |
| 2336 | 529.1 | Core part: Introduction of LTE 450 MHz band in Brazil | 201d? | 2012-09-11 A | 2013-06-14 A | 100% | 2012-09-11 | 2013-06-14 | 201d? | finish no earlier than 2013-06-14 | R4 | 1608h | 1608h | LTE450_Brazil-Core | PCG-29 | Huawei | Liehai Liu (liuliehai@huawei.com) | Rel-12 | RP-57 |  | LTE450_Brazil-Core | RP-130567 | Issam |  |  |
| 2337 | 529.2 | Perf. part: Introduction of LTE 450 MHz band in Brazil | 261d? | 2012-09-13 A | 2013-09-06 A | 100% | 2012-09-13 | 2013-09-06 | 261d? | finish no earlier than 2013-09-06 | R4 | 2088h | 2088h | LTE450_Brazil-Perf | PCG-29 | Huawei | Liehai Liu (liuliehai@huawei.com) | Rel-12 | RP-57 |  | LTE450_Brazil-Perf | RP-131070 | Issam |  |  |
| 2338 | 529.3 | Test part: Introduction of LTE 450 MHz band in Brazil | 126d? | 2013-06-18 A | 2013-12-06 A | 100% | 2013-06-18 | 2013-12-06 | 126d? | finish no earlier than 2013-12-06 | R5 | 1008h | 1008h | LTE450_Brazil-UEConTest | PCG-31 | Huawei | Xiang Li (tricia.li@huawei.com) | Rel-12 | RP-60 |  | LTE450_Brazil-UEConTest | RP-131457 | Ingbert |  |  |
| 2339 | 530 | **Further Downlink MIMO Enhancement for LTE Advanced** | 927d? | 2012-09-11 A | 2016-03-15 A | 100% | 2012-09-11 | 2014-09-12 | 532d? |  | R1; R4 | 25384.8h | 25384.8h | LTE_eDL_MIMO_enh | PCG-29 | Alcatel-Lucent | Min Zhang (min.hs.zhang@alcatel-lucent.com) | Rel-12 | RP-57 |  | LTE_eDL_MIMO_enh |  | Patrick |  |  |
| 2340 | 530.1 | Core part: Further Downlink MIMO Enhancement for LTE Advanced | 464d? | 2012-09-11 A | 2014-06-13 A | 100% | 2012-09-11 | 2014-06-13 | 464d? | finish no earlier than 2014-06-13 | R1 | 3696.76h | 3696.76h | LTE_eDL_MIMO_enh-Core | PCG-29 | Alcatel-Lucent | Min Zhang (min.hs.zhang@alcatel-lucent.com) | Rel-12 | RP-57 |  | LTE_eDL_MIMO_enh-Core | RP-140652 | Patrick |  |  |
| 2341 | 530.2 | Perf. part: Further Downlink MIMO Enhancement for LTE Advanced | 595d? | 2012-09-15 A | 2014-12-15 A | 100% | 2012-09-18 | 2014-09-12 | 526d? | finish no earlier than 2014-12-15 | R4 | 4760h | 4760h | LTE_eDL_MIMO_enh-Perf | PCG-29 | Alcatel-Lucent | ren.da@alcatel-lucent.com | Rel-12 | RP-57 |  | LTE_eDL_MIMO_enh-Perf | RP-142042 | Issam |  |  |
| 2342 | 530.3 | UE Conformance Test Aspects - Further DL MIMO Enhancement for LTE-Advanced | 262d? | 2015-03-16 A | 2016-03-15 A | 100% |  |  |  | finish no earlier than 2016-03-15 | R5 | 2096h | 2096h | LTE_eDL_MIMO_enh-UEConTest | PCG-34 | ZTE |  | Rel-12 | RP-67 |  |  | RP-151189 |  |  |  |

Notes:
- 2318: Inter-band CA 3DL/1UL / Impacted TSs and TRs: LTE
- 2319: ; WID: RP-141288->RP-142302; Stat Rep: -->RP-141732; Release: Rel-13->Rel-12 / Impacted TSs and TRs: 36.101, 36.104, 36.133, New TR 36.8xx
- 2320: ; WID: RP-141288->RP-142302; Stat Rep: -->RP-141732; Release: Rel-13->Rel-12 / Impacted TSs and TRs: 36.141, 36.307
- 2321: Inter-band CA 3DL/1UL / Impacted TSs and TRs: LTE
- 2322: CD:Thu 11/12/14->Mon 15/12/14; Compl:0%->100%; Stat Rep: -->RP-141732; Release: Rel-13->Rel-12 / Impacted TSs and TRs: 36.101, 36.104, 36.133, New TR 36.8xx
- 2323: CD:Thu 11/12/14->Mon 15/12/14; Compl:0%->100%; Stat Rep: -->RP-141732; Release: Rel-13->Rel-12 / Impacted TSs and TRs: 36.141, 36.307
- 2324: Inter-band CA 3DL/1UL / Impacted TSs and TRs: LTE
- 2325: CD:Fri 11/12/15->Mon 15/12/14; Compl:0%->100%; Stat Rep: -->RP-141732; Release: Rel-13->Rel-12 / Impacted TSs and TRs: 36.101, 36.104, 36.133, New TR 36.8xx
- 2326: CD:Thu 11/12/14->Mon 15/12/14; Compl:0%->100%; Stat Rep: -->RP-141732; Release: Rel-13->Rel-12 / Impacted TSs and TRs: 36.141, 36.307
- 2327: ; Stat Rep: RP-141444->RP-141774 1st Apr 15: Compl:75%->100% 1st Apr 15: WID: RP-140621->RP-150077 1st Apr 15: Stat Rep: RP-141774->RP-150076 / Impacted TSs and TRs: 36.508, 36.521-1, 36.521-2, 36.521-3, 36.523-1, 36.523-2, 36.523-3, 37.571-1, 37.571-3, 37.571-5
- 2328: ; Stat Rep: -->RP-141775 1st Apr 15: Compl:6%->12% 1st Apr 15: CD:Tue 15/09/15->Tue 15/12/15 1st Apr 15: WID: RP-142231->RP-150079 1st Apr 15: Stat Rep: RP-141775->RP-150078 03/07/15: Compl:12%->35% 03/07/15: WID: RP-150079->RP-150594 03/07/15: Stat Re / Impacted TSs and TRs: 36.508, 36.521-1, 36.521-2, 36.521-3, 36.523-1, 36.523-2, 36.523-3, 37.571-1, 37.571-3, 37.571-5
- 2329: RP#60 stopped. RP#58 on hold til June 2013 / Impacted TSs and TRs: LTE
- 2330: RP#60 stopped at 40% completion. RP#58 on hold til June 2013 / Impacted TSs and TRs: 36.300, 36.413, 36.420, 36.423
- 2331: RP#58 RP-121701 work can start based on FCC Order (FCC-12-130) http://hraunfoss.fcc.gov/edocs_public/attachmatch/FCC-12-130A1.pdf / Impacted TSs and TRs: LTE
- 2332: RP#60 completed. Updated WID RP-121419=>RP-130843 / Impacted TSs and TRs: 36.101, 36.104, 36.113, 36.124, 36.133, 36.307, 36.331, new TR 36.846
- 2333: RP#60 completed. Updated WID RP-121419=>RP-130843 / Impacted TSs and TRs: 36.101, 36.133, 36.141
- 2334: ; Stat Rep: RP-141166->RP-141773 / Impacted TSs and TRs: 36.508, 36.521-1, 36.521-2, 36.521-3, 36.523-2, 36.523-3, 37.571-1
- 2335: - / Impacted TSs and TRs: LTE
- 2336: RP#60 completed. TR 36.840 v100 for 1-step Approval / Impacted TSs and TRs: 36.101, 36.104, 36.113, 36.124, 36.133, 37.104, 37.113, 36.307, new TR 36.840
- 2337: RP#61 completed / Impacted TSs and TRs: 36.133, 36.141, 37.141
- 2338: RP#62 completed / Impacted TSs and TRs: 36.508, 36.521-1, 36.521-2, 36.521-3
- 2339: Stage 3 / Impacted TSs and TRs: LTE
- 2340: RP#64 completed / Impacted TSs and TRs: 36.211, 36.212, 36.213, 36.331
- 2341: ; CD:Fri 12/06/15->Mon 15/06/15; WID: RP-141966->RP-142235; Stat Rep: RP-141378->RP-142042 / Impacted TSs and TRs: 36.101
- 2342: 03/07/15: Compl:0%->10% 03/07/15: Stat Rep: ->RP-150606 29/09/15: Compl:10%->70% 29/09/15: Stat Rep: RP-150606->RP-1511891/1/16: Compl:70%->75%

| ID | WBS | Task | Duration | Start | Finish | Complete | Remaining | Baseline start | Baseline finish | Baseline duration | Total slack | Constraint | Resources | Work | Actual work | Acronym | PCG approved | WI rapporteur name | Release | TSG approved | MCC resp | PCG stopped | TSG stopped | Acronym_3GU_Export | Status Report | Special Focus Doc |
| --- | --- | --- | --- | --- | --- | --- | --- | --- | --- | --- | --- | --- | --- | --- | --- | --- | --- | --- | --- | --- | --- | --- | --- | --- | --- | --- |
| 2343 | 531 | **Deleted - New Carrier Type for LTE** | 265d? | 2012-09-11 A | 2013-09-06 A | 100% |  | 2012-09-11 | 2013-09-06 | 265d? |  |  | R1; R2; R4 | 14808h | 14808h | LTE_NCT | PCG-29 | Ericsson | Rel-12 | RP-57 | Patrick | PCG-31 | RP-61 | LTE_NCT |  |  |
| 2344 | 531.1 | Deleted - Core part: New Carrier Type for LTE | 265d? | 2012-09-11 A | 2013-09-06 A | 100% |  | 2012-09-11 | 2013-09-06 | 265d? |  | finish no earlier than 2013-09-06 | R1; R2; R4 | 6360h | 6360h | LTE_NCT-Core | PCG-29 | Ericsson | Rel-12 | RP-57 | Patrick | PCG-31 | RP-61 | LTE_NCT-Core | RP-130984 |  |
| 2345 | 531.2 | Deleted - Perf. part: New Carrier Type for LTE | 261d? | 2012-09-17 A | 2013-09-06 A | 100% |  | 2012-09-17 | 2013-09-06 | 261d? |  | finish no earlier than 2013-09-06 | R4 | 2088h | 2088h | LTE_NCT-Perf | PCG-29 | Ericsson | Rel-12 | RP-57 | Issam | PCG-31 | RP-61 | LTE_NCT-Perf | RP-130985 |  |
| 2346 | 532 | **Further Enhancements to LTE TDD for DL-UL Interference Management and Traffic Adaptation** | 1321d? | 2012-12-07 A | 2017-12-15 | 82% | 232.73d? | 2012-12-07 | 2014-12-05 | 527d? | 264d |  | R1; R2; R3; R4 | 53578.6h | 13425.3h | LTE_TDD_eIMTA | PCG-30 | CATT | Rel-12 | RP-58 | Patrick |  |  | LTE_TDD_eIMTA |  | Small cell |
| 2347 | 532.1 | Core part: Further Enhancements to LTE TDD for DL-UL Interference Management and Traffic Adaptation | 24.58d? | 2012-12-07 A | 2014-06-13 A | 100% |  | 2012-12-07 | 2014-06-13 | 24.58d? |  | finish no earlier than 2014-06-13 | R1; R2; R3; R4 | 786.56h | 786.56h | LTE_TDD_eIMTA-Core | PCG-30 | CATT | Rel-12 | RP-58 | Patrick |  |  | LTE_TDD_eIMTA-Core | RP-140724 | Small cell |
| 2348 | 532.2 | Perf. part: Further Enhancements to LTE TDD for DL-UL Interference Management and Traffic Adaptation | 725d? | 2012-12-15 A | 2015-09-15 A | 100% |  | 2012-12-07 | 2014-12-05 | 527d? |  | finish no earlier than 2015-09-15 | R4 | 5800h | 5800h | LTE_TDD_eIMTA-Perf | PCG-30 | CATT | Rel-12 | RP-58 | Patrick |  |  | LTE_TDD_eIMTA-Perf | RP-151447 | Small cell |
| 2349 | 532.3 | UE Conformance Test Aspects - Further Enhancements to LTE TDD for DL-UL Interference Management and Traffic Adaptation | 590d? | 2015-09-15 A | 2017-12-15 | 60% | 236d? |  |  |  | 264d | finish no earlier than 2017-12-15 | R5 | 4720h | 2832h | LTE_TDD_eIMTA-UEConTest | PCG-35 | CATT | Rel-12 | RP-69 |  |  |  |  |  |  |
| 2350 | 533 | **HetNet Mobility enhancements for LTE** | 641.65d? | 2012-04-13 A | 2014-09-12 A | 100% |  | 2012-04-13 | 2014-09-12 | 640.65d? |  |  | R2; R4 | 11624h | 11624h | HetNet_eMOB_LTE | PCG-30 | Alcatel-Lucent | Rel-12 | RP-58 | Yong-Jun |  |  | HetNet_eMOB_LTE |  |  |
| 2351 | 533.1 | Core part: HetNet Mobility enhancements for LTE | 263.5d? | 2012-04-13 A | 2014-09-12 A | 100% |  | 2012-04-13 | 2014-09-12 | 263.5d? |  | finish no earlier than 2014-09-12 | R2; R4 | 4216h | 4216h | HetNet_eMOB_LTE-Core | PCG-30 | Alcatel-Lucent | Rel-12 | RP-58 | Yong-Jun |  |  | HetNet_eMOB_LTE-Core | RP-141413 |  |
| 2352 | 534 | **Further enhancements for HeNB mobility-X2-GW** | 401d? | 2012-12-10 A | 2014-06-13 A | 100% |  | 2012-12-10 | 2014-06-13 | 401d? |  |  | R3 | 6408h | 6408h | EHNB_enh2_X2GW | PCG-30 | Alcatel-Lucent | Rel-12 | RP-58 | Juha |  |  | EHNB_enh2_X2GW |  | HNB |
| 2353 | 534.1 | Core part: Further enhancements for HeNB mobility-X2-GW | 400d? | 2012-12-10 A | 2014-06-13 A | 100% |  | 2012-12-10 | 2014-06-13 | 400d? |  | finish no earlier than 2014-06-13 | R3 | 3200h | 3200h | EHNB_enh2_X2GW-Core | PCG-30 | Alcatel-Lucent | Rel-12 | RP-58 | Juha |  |  | EHNB_enh2_X2GW-Core | RP-140592 | HNB |
| 2354 | 535 | **8 Rx Antennas for LTE UL** | 265d? | 2012-12-10 A | 2013-12-06 A | 100% |  | 2012-12-10 | 2013-12-06 | 265d? |  |  | R4 | 4208h | 4208h | LTE_UL_8Rx | PCG-30 | China Telecom | Rel-12 | RP-58 | Issam |  |  | LTE_UL_8Rx |  |  |
| 2355 | 535.1 | Perf. part: 8 Rx Antennas for LTE UL | 261d? | 2012-12-10 A | 2013-12-06 A | 100% |  | 2012-12-10 | 2013-12-06 | 261d? |  | finish no earlier than 2013-12-06 | R4 | 2088h | 2088h | LTE_UL_8Rx-Perf | PCG-30 | China Telecom | Rel-12 | RP-58 | Issam |  |  | LTE_UL_8Rx-Perf | RP-131523 |  |
| 2356 | 536 | **LTE TDD-FDD joint operation including Carrier Aggregation** | 444.03d? | 2013-04-12 A | 2014-12-15 A | 100% |  | 2013-04-12 | 2014-12-05 | 435.03d? |  |  | R1; R2; R4 | 14776h | 14776h | LTE_CA_TDD_FDD | PCG-31 | Nokia | Rel-12 | RP-60 | Patrick |  |  | LTE_CA_TDD_FDD |  |  |
| 2357 | 536.1 | Core part: LTE TDD-FDD joint operation including Carrier Aggregation | 87.33d? | 2013-04-12 A | 2014-06-13 A | 100% |  | 2013-04-12 | 2014-06-13 | 87.33d? |  | finish no earlier than 2014-06-13 | R1; R2; R4 | 2096h | 2096h | LTE_CA_TDD_FDD-Core | PCG-31 | Nokia, China Mobile (for TR) | Rel-12 | RP-60 | Patrick |  |  | LTE_CA_TDD_FDD-Core | RP-140982 |  |
| 2358 | 536.2 | Perf. part: LTE TDD-FDD joint operation including Carrier Aggregation | 397d? | 2013-06-15 A | 2014-12-15 A | 100% |  | 2013-06-20 | 2014-12-05 | 386d? |  | finish no earlier than 2014-12-15 | R4 | 3176h | 3176h | LTE_CA_TDD_FDD-Perf | PCG-31 | Nokia | Rel-12 | RP-60 | Issam |  |  | LTE_CA_TDD_FDD-Perf | RP-141972 |  |
| 2359 | 537 | **LTE Coverage Enhancements** | 604.17d? | 2013-03-01 A | 2015-06-15 A | 100% |  | 2013-03-01 | 2014-12-05 | 465.17d? |  |  | R1; R2; R4; R5 | 26709.4h | 21348.1h | Cov_Enh_LTE | PCG-31 | China Telecom | Rel-12 | RP-60 | Patrick |  |  | Cov_Enh_LTE |  |  |
| 2360 | 537.1 | Core part: LTE Coverage Enhancements | 87d? | 2013-03-01 A | 2014-06-13 A | 100% |  | 2013-03-01 | 2014-06-13 | 87d? |  | finish no earlier than 2014-06-13 | R1; R2; R4 | 2088h | 2088h | Cov_Enh_LTE-Core | PCG-31 | China Telecom | Rel-12 | RP-60 | Patrick |  |  | Cov_Enh_LTE-Core | RP-140683 |  |
| 2361 | 537.2 | Perf. part: LTE Coverage Enhancements | 397d? | 2013-06-15 A | 2014-12-15 A | 100% |  | 2013-06-20 | 2014-12-05 | 386d? |  | finish no earlier than 2014-12-15 | R4 | 3176h | 3176h | Cov_Enh_LTE-Perf | PCG-31 | China Telecom | Rel-12 | RP-60 | Issam |  |  | Cov_Enh_LTE-Perf | RP-141833 |  |
| 2362 | 537.3 | Test part: LTE Coverage Enhancements | 198d? | 2014-09-15 A | 2015-06-15 A | 100% |  |  |  |  |  | finish no earlier than 2015-09-15 | R5 | 1584h | 1584h | Cov_Enh_LTE-UEConTest | PCG-33 | China Telecom | Rel-12 | RP-65 |  |  |  | Cov_Enh_LTE-UEConTest | RP-150631 |  |
| 2363 | 538 | **Further MBMS operations support for E-UTRAN** | 330d? | 2013-09-15 A | 2014-12-15 A | 100% |  | 2013-12-09 | 2014-09-12 | 201d? |  |  | R2; R1; R3; R4 | 21280h | 21280h | MBMS_LTE_OS | PCG-31 | Verizon | Rel-12 | RP-61 | Yong-Jun |  |  | MBMS_LTE_OS |  |  |
| 2364 | 538.1 | Core part: Further MBMS operations support for E-UTRAN | 329d? | 2013-09-15 A | 2014-12-15 A | 100% |  | 2014-04-04 | 2014-09-12 | 115.25d? |  | finish no earlier than 2014-12-15 | R2; R1; R3; R4 | 10528h | 10528h | MBMS_LTE_OS-Core | PCG-31 | Verizon | Rel-12 | RP-61 | Yong-Jun |  |  | MBMS_LTE_OS-Core | RP-141821 |  |
| 2365 | 538.2 | Perf. part: Further MBMS operations support for E-UTRAN | 264d? | 2013-12-15 A | 2014-12-15 A | 100% |  | 2013-12-09 | 2014-09-12 | 201d? |  | finish no earlier than 2014-12-15 | R4 | 2112h | 2112h | MBMS_LTE_OS-Perf | PCG-32 | Verizon | Rel-12 | RP-62 | Issam |  |  | MBMS_LTE_OS-Perf | RP-141821 |  |
| 2366 | 539 | **Dual connectivity for LTE** | 919d? | 2013-12-15 A | 2017-06-15 | 96% | 35.01d? | 2013-12-09 | 2014-12-05 | 261d? | 395d |  | R2; R1; R3; R4; S2; C4 | 53088h | 29580h | LTE_SC_enh_dualC | PCG-32 | NTT DOCOMO | Rel-12 | RP-62 | Yong-Jun |  |  | LTE_SC_enh_dualC |  | Small cell |
| 2367 | 539.1 | Core part: Dual connectivity for LTE | 264d? | 2013-12-15 A | 2014-12-15 A | 100% |  | 2014-04-29 | 2014-09-12 | 99d? |  | finish no earlier than 2014-12-15 | R2; R1; R3; R4 | 8448h | 8448h | LTE_SC_enh_dualC-Core | PCG-32 | NTT DOCOMO, NEC | Rel-12 | RP-62 | Yong-Jun |  |  | LTE_SC_enh_dualC-Core | RP-141796 | Small cell |
| 2368 | 539.2 | Perf. part: Dual Connectivity for LTE | 395d? | 2013-12-15 A | 2015-06-15 A | 100% |  | 2013-12-09 | 2014-12-05 | 261d? |  | finish no earlier than 2015-06-15 | R4 | 3160h | 3160h | LTE_SC_enh_dualC-Perf | PCG-32 | NTT DOCOMO | Rel-12 | RP-62 | Issam |  |  | LTE_SC_enh_dualC-Perf | RP-150791 | Small cell |
| 2369 | 539.3 | SA2 part of Dual connectivity for LTE | 131d? | 2014-03-19 A | 2014-09-17 A | 100% |  | 2014-03-19 | 2014-09-17 | 131d? |  | finish no earlier than 2014-09-17 | S2 | 1048h | 1048h | LTE_SC_enh_dualC-S2 | PCG-32 |  | Rel-12 | RP-63 |  |  |  |  |  | Small cell |
| 2370 | 539.4 | CT aspects of Dual connectivity for LTE | 63d? | 2014-09-12 A | 2014-12-09 A | 100% |  |  |  |  |  | finish no earlier than 2014-12-09 | C4 | 504h | 504h | LTE_SC_enh_dualC-CT | PCG-33 | Huawei | Rel-12 | CP-65 |  |  |  | LTE_SC_enh_dualC-CT | CP-140487 | Small cell |
| 2371 | 539.5 | UE Conformance Test Aspects - Dual connectivity for LTE | 525d? | 2015-06-15 A | 2017-06-15 | 90% | 52.5d? |  |  |  | 395d | finish no earlier than 2017-06-15 | R5 | 4200h | 3780h | LTE_SC_enh_dualC-UEConTest | PCG-35 | Ericsson | Rel-12 | TSG-68 |  |  |  |  |  |  |

Notes:
- 2343: RP#61 stopped. Continue discussion on use cases and requirements for a NCT in LTE beyond Rel-12. Action: Ericsson to provide at RP#62 a summary of work done so far / Impacted TSs and TRs: LTE / WI rapporteur e-mail: daniel.n.larsson@ericsson.com
- 2344: RP#61 stopped at 20% completion / Impacted TSs and TRs: 36.101, 36.104, 36.133, 36.211, 36.212, 36.213, 36.321, 36.331 / WI rapporteur e-mail: daniel.n.larsson@ericsson.com
- 2345: RP#61 stopped at 0% completion / Impacted TSs and TRs: 36.101, 36.104, 36.133, 36.141 / WI rapporteur e-mail: daniel.n.larsson@ericsson.com
- 2346: Stage 3. Triggered by Rel-11 TR 36.828 Study on Further Enhancements to LTE TDD for DL-UL Interference Management and Traffic Adaptation (FS_LTE_TDD_eIMTA) UID_510039 / Impacted TSs and TRs: LTE / WI rapporteur e-mail: Zukang Shen (shenzukang@catt.cn)
- 2347: RP#64 completed / Impacted TSs and TRs: 36.101, 36.104, 36.133, 36.211, 36.212, 36.213, 36.214, 36.300, 36.321, 36.331, 36.413, 36.423 / WI rapporteur e-mail: Zukang Shen (shenzukang@catt.cn)
- 2348: ; CD:Thu 18/06/15->Mon 15/06/15; WID: RP-141966->RP-142235; Stat Rep: RP-141342->RP-141948 1st Apr 15: Compl:30%->55% 1st Apr 15: Stat Rep: RP-141948->RP-150154 03/07/15: Compl:55%->95% 03/07/15: CD:Mon 15/06/15->Tue 15/09/15 03/07/15: Stat Rep: RP-150 / Impacted TSs and TRs: 36.101, 36.104, 36.133, 36.141 / WI rapporteur e-mail: Zukang Shen (shenzukang@catt.cn)
- 2349: tested: REL-12 WI LTE_TDD_eIMTA-Core;1/1/16: Compl:0%->5%; 22/3/16: Compl:5%->15% ; ; 21/3/...
- 2350: Stage 3. Triggered by Rel-11 TR 36.839 Study on HetNet mobility enhancements for LTE (FS_HetNet_eMOB_LTE) / Impacted TSs and TRs: LTE / WI rapporteur e-mail: sudeep.palat@alcatel-lucent.com
- 2351: SP#65 completed / Impacted TSs and TRs: 36.133, 36.304, 36.331 / WI rapporteur e-mail: sudeep.palat@alcatel-lucent.com
- 2352: Rel-10 H(e)NB Mobility Enhancements adds signalling via horizontal RAN interfaces (Iurh, X2) to support H(e)NB to H(e)NB mobility. Rel-11 TR37.803 triggered WI UID_560014 partly completed in Rel-11; remaining work including solution definition is Rel-12 / Impacted TSs and TRs: LTE / WI rapporteur e-mail: Philippe.Godin@alcatel-lucent.com
- 2353: RP#64 completed / Impacted TSs and TRs: 36.300, 36.413, 36.423 / WI rapporteur e-mail: Philippe.Godin@alcatel-lucent.com
- 2354: WI has perf. part only (as change from 4Rx to 8Rx has no Core spec impact) / Impacted TSs and TRs: LTE / WI rapporteur e-mail: Shan Yang (yangshan@ctbri.com.cn)
- 2355: RP#62 completed / Impacted TSs and TRs: 36.104, 36.141 / WI rapporteur e-mail: Shan Yang (yangshan@ctbri.com.cn)
- 2356: - / Impacted TSs and TRs: LTE / WI rapporteur e-mail: lars.e.lindh@nokia.com
- 2357: RP#64 completed / Impacted TSs and TRs: 36.101, 36.104, 36.133, 36.201, 36.211, 36.212, 36.213, 36.300, 36.302, 36.306, 36.331, new TR 36.847 / WI rapporteur e-mail: lars.e.lindh@nokia.com, Xiaodong Shen (shenxiaodong@chinamobile.com)
- 2358: ; CD:Thu 18/06/15->Mon 15/06/15; WID: RP-130848->RP-140522; Stat Rep: RP-141374->RP-141972 / Impacted TSs and TRs: 36.101, 36.104, 36.133 / WI rapporteur e-mail: lars.e.lindh@nokia.com
- 2359: Triggered by Rel-11 TR 36.824 (FS_Cov_Enh_LTE) / Impacted TSs and TRs: LTE / WI rapporteur e-mail: Xiaoming She (shexm@ctbri.com.cn)
- 2360: RP#64 completed / Impacted TSs and TRs: 36.101, 36.104, 36.133, 36.211, 36.212, 36.213, 36.300, 36.321, 36.331 / WI rapporteur e-mail: Xiaoming She (shexm@ctbri.com.cn)
- 2361: ; CD:Thu 18/06/15->Mon 15/06/15; WID: RP-141966->RP-142235; Stat Rep: RP-141149->RP-141833 / Impacted TSs and TRs: 36.101, 36.104, 36.133, 36.141 / WI rapporteur e-mail: Xiaoming She (shexm@ctbri.com.cn)
- 2362: ; Stat Rep: -->RP-141834 03/07/15: Compl:5%->100% 03/07/15: CD:Tue 15/09/15->Mon 15/06/15 03/07/15: Stat Rep: RP-141834->RP-150631 / Impacted TSs and TRs: 36.508, 36.523-1, 36.523-2, 36.523-3 / WI rapporteur e-mail: YANG Shan (yangshan@ctbri.com.cn)
- 2363: Solutions for Minimization of Drive Tests (MDT), in order to reduce the need for manual drive testing for MBMS. / Impacted TSs and TRs: LTE / WI rapporteur e-mail: yeesin.chan@verizonwireless.com
- 2364: ; CD:Thu 18/06/15->Mon 15/06/15; WID: RP-130848->RP-140522; Stat Rep: RP-141431->RP-141821 / Impacted TSs and TRs: 36.133, 36.214, 36.300, 36.304, 36.306, 36.331, 36.413, 36.423, 37.320 / WI rapporteur e-mail: yeesin.chan@verizonwireless.com
- 2365: ; CD:Wed 17/12/14->Mon 15/12/14; WID: RP-130848->RP-140522; Stat Rep: RP-141431->RP-141821 / Impacted TSs and TRs: 36.133 / WI rapporteur e-mail: yeesin.chan@verizonwireless.com
- 2366: Triggered by TR 36.842 Study on Small Cell Enhancements for E-UTRA and E-UTRAN Higher-layer aspects (UID_580044) / Impacted TSs and TRs: LTE / WI rapporteur e-mail: tooru.uchino.fv@nttdocomo.com
- 2367: ; CD:Wed 18/03/15->Sun 15/03/15; WID: RP-130848->RP-140522; Stat Rep: RP-141264->RP-141796 / Impacted TSs and TRs: 36.101, 36.104, 36.133, 36.211, 36.212, 36.213, 36.300, 36.302, 36.306, 36.321, 36.322, 36.323, 36.331, 36.410, 36.413, 36.420, 36.423, new RAN3 TS 36.425 / WI rapporteur e-mail: RAN1/2/4 tooru.uchino.fv@nttdocomo.com, RAN3 Chenghock Ng (ngcheng@da.jp.nec.com)
- 2368: ; Stat Rep: RP-141264->RP-141796 1st Apr 15: Compl:15%->45% 1st Apr 15: Stat Rep: RP-141796->RP-150160 03/07/15: Compl:45%->100% 03/07/15: Stat Rep: RP-150160->RP-150791 / Impacted TSs and TRs: 36.101, 36.104, 36.133 / WI rapporteur e-mail: kunihiko.teshima.hg@nttdocomo.com
- 2369: SP#64 Three CRs agreed in SP-140262 (23.251CR0099, 23.401CR2658&CR2707). Dec.14:99->100% / Impacted TSs and TRs: 23.251, 23.401
- 2370: Stage 2/3. CP#65 exception in CP-140487. LM70->100 / Impacted TSs and TRs: 23.007, 23.008, 29.274, 29.281 / WI rapporteur e-mail: Xiaoyan SHI (sean.shixiaoyan@huawei.com)
- 2371: tested Core part: LTE_SC_enh_dualC-Core 29/09/15: Compl:0%->3% 29/09/15: Stat Rep: -->RP-1511671/1/16: Compl:3%->15%1/1/16: CD:Tue 15/03/16->Wed 15/06/16; ...

| ID | WBS | Task | Duration | Start | Finish | Complete | Remaining | Baseline start | Baseline finish | Baseline duration | Total slack | Constraint | Resources | Work | Actual work | Acronym | PCG approved | WI rapporteur name | WI rapporteur e-mail | Release | TSG approved | MCC resp | Special Focus Doc | Acronym_3GU_Export | Status Report |
| --- | --- | --- | --- | --- | --- | --- | --- | --- | --- | --- | --- | --- | --- | --- | --- | --- | --- | --- | --- | --- | --- | --- | --- | --- | --- |
| 2372 | 540 | **E-UTRA Small cell enhancements - Physical layer aspects** | 919d? | 2013-12-15 A | 2017-06-15 | 98% | 17.87d? | 2013-07-19 | 2014-12-05 | 364.75d? | 395d |  | R1; R2; R4 | 32364.7h | 19620.7h | LTE_SC_enh_L1 | PCG-32 | Huawei | Elean FAN (fanxiaoan@huawei.com) | Rel-12 | RP-62 | Patrick | Small cell | LTE_SC_enh_L1 |  |
| 2373 | 540.1 | Core part: E-UTRA Small cell enhancements - Physical layer aspects | 161.25d? | 2013-12-15 A | 2014-12-15 A | 100% |  | 2013-07-19 | 2014-09-12 | 202d? |  | finish no earlier than 2014-12-15 | R1; R2; R4 | 3870h | 3870h | LTE_SC_enh_L1-Core | PCG-32 | Huawei | Elean FAN (fanxiaoan@huawei.com) | Rel-12 | RP-62 | Patrick | Small cell | LTE_SC_enh_L1-Core | RP-141899 |
| 2374 | 540.2 | Perf. part: E-UTRA Small cell enhancements - Physical layer aspects | 394d? | 2013-12-15 A | 2015-06-15 A | 100% |  | 2013-12-09 | 2014-12-05 | 261d? |  | finish no earlier than 2015-06-15 | R4 | 3152h | 3152h | LTE_SC_enh_L1-Perf | PCG-32 | Huawei | Elean FAN (fanxiaoan@huawei.com) | Rel-12 | RP-62 | Issam | Small cell | LTE_SC_enh_L1-Perf | RP-150690 |
| 2375 | 540.3 | UE Conformance Test Aspects - E-UTRA Small cell enhancements - Physical layer aspects | 525d? | 2015-06-15 A | 2017-06-15 | 96% | 21d? |  |  |  | 395d | finish no earlier than 2017-06-15 | R5 | 4200h | 4032h | LTE_SC_enh_L1-UEConTest | PCG-35 | Huawei |  | Rel-12 | TSG-68 |  |  |  |  |
| 2376 | 541 | **Inter-eNB Coordinated Multi-Point (CoMP) for LTE** | 264d? | 2013-12-15 A | 2014-12-15 A | 100% |  | 2014-03-14 | 2014-09-12 | 130.65d? |  |  | R3; R1 | 4738.38h | 4738.38h | COMP_LTE_IeNB | PCG-32 | Samsung | Sung Hwan Won (sunghwan.won@samsung.com) | Rel-12 | RP-62 | Juha |  | COMP_LTE_IeNB |  |
| 2377 | 541.1 | Core part: Inter-eNB Coordinated Multi-Point (CoMP) for LTE | 165.5d? | 2013-12-15 A | 2014-12-15 A | 100% |  | 2014-03-14 | 2014-09-12 | 100.5d? |  | finish no earlier than 2014-12-15 | R3; R1 | 2648h | 2648h | COMP_LTE_IeNB-Core | PCG-32 | Samsung | Sung Hwan Won (sunghwan.won@samsung.com) | Rel-12 | RP-62 | Juha |  | COMP_LTE_IeNB-Core | RP-141804 |
| 2378 | 542 | **Smart Congestion Mitigation in E-UTRAN** | 403d? | 2014-03-05 A | 2015-09-15 A | 100% |  | 2014-03-05 | 2014-09-12 | 138d? |  |  | R2; S1; C1 | 12376h | 12376h | SCM_LTE | PCG-32 | LG Electronics | youngdae.lee@lge.com | Rel-12 | RP-63 | Yong-Jun |  | SCM_LTE |  |
| 2379 | 542.1 | Core part: Smart Congestion Mitigation in E-UTRAN | 137d? | 2014-03-06 A | 2014-09-12 A | 100% |  | 2014-03-06 | 2014-09-12 | 137d? |  | finish no earlier than 2014-09-12 | R2 | 1096h | 1096h | SCM_LTE-Core | PCG-32 | LG Electronics | youngdae.lee@lge.com | Rel-12 | RP-63 | Yong-Jun |  | SCM_LTE-Core | RP-141292 |
| 2380 | 542.2 | Stage 1 Prioritization of Multimedia Telephony (MMTel) and Mobile Originating-SMS for Access Class Barring (ACB) | 3d? | 2014-03-05 A | 2014-03-07 A | 100% |  | 2014-03-05 | 2014-03-07 | 3d? |  | finish no earlier than 2013-12-11 | S1 | 24h | 24h |  | PCG-33 |  |  | Rel-12 | CP-64 |  |  |  |  |
| 2381 | 542.3 | CT aspects of Smart Congestion Mitigation in E-UTRAN (Stage 3) | 66d? | 2014-06-13 A | 2014-09-11 A | 100% |  | 2014-06-13 | 2014-09-12 | 66d? |  | start no earlier than 2014-06-13 | C1 | 528h | 528h | SCM_LTE-CT | PCG-33 | LG Electronics | Kim, Jaehyun (jaehyun7.kim@lge.com) | Rel-12 | CP-64 |  |  | SCM_LTE-CT |  |
| 2382 | 542.4 | UE Conformance Test Aspects - Smart Congestion Mitigation in E-UTRAN | 132d? | 2015-03-16 A | 2015-09-15 A | 100% |  |  |  |  |  | finish no earlier than 2015-09-15 | R5 | 1056h | 1056h | SCM_LTE-UEConTest | PCG-34 | NTT DOCOMO |  | Rel-12 | RP-67 |  |  |  | RP-151445 |
| 2383 | 543 | **Positioning Enhancements for RF Pattern Matching in E-UTRA** | 36d? | 2014-04-25 A | 2014-06-13 A | 100% |  | 2014-04-25 | 2014-06-13 | 36d? |  |  | R3; R2 | 1152h | 1152h | LCS_LTE_RFPMT | PCG-32 | Polaris Wireless | Gordon Scot (sgordon@polariswireless.com) | Rel-12 | RP-63 | Juha |  | LCS_LTE_RFPMT |  |
| 2384 | 543.1 | Core part: Positioning Enhancements for RF Pattern Matching in E-UTRA | 36d? | 2014-04-25 A | 2014-06-13 A | 100% |  | 2014-04-25 | 2014-06-13 | 36d? |  | finish no earlier than 2014-06-13 | R3; R2 | 576h | 576h | LCS_LTE_RFPMT-Core | PCG-32 | Polaris Wireless | Gordon Scot (sgordon@polariswireless.com) | Rel-12 | RP-63 | Juha |  | LCS_LTE_RFPMT-Core | RP-140591 |
| 2385 | 544 | **Network-Assisted Interference Cancellation and Suppression for LTE** | 791d? | 2014-03-11 A | 2017-03-15 | 99% | 0d? | 2014-03-06 | 2015-06-12 | 332d? | 0d |  | R1; R2; R4; R3 | 25043.9h | 11506h | LTE_NAICS | PCG-32 | MediaTek | Craig.Burnet@mediatek.com | Rel-12 | RP-63 | Patrick |  | LTE_NAICS |  |
| 2386 | 544.1 | Core part: Network-Assisted Interference Cancellation and Suppression for LTE | 113.67d? | 2014-07-11 A | 2014-12-15 A | 100% |  | 2014-07-11 | 2014-09-12 | 45.67d? |  | finish no earlier than 2014-12-15 | R1; R2; R4; R3 | 2803.87h | 2803.87h | LTE_NAICS-Core | PCG-32 | MediaTek | Craig.Burnet@mediatek.com | Rel-12 | RP-63 | Patrick |  | LTE_NAICS-Core | RP-141866 |
| 2387 | 544.2 | Perf. part: Network-Assisted Interference Cancellation and Suppression for LTE | 399d? | 2014-03-11 A | 2015-09-15 A | 100% |  | 2014-03-06 | 2015-06-12 | 332d? |  | finish no earlier than 2015-09-15 | R4 | 3192h | 3192h | LTE_NAICS-Perf | PCG-32 | MediaTek | Craig.Burnet@mediatek.com | Rel-12 | RP-63 | Issam |  | LTE_NAICS-Perf | RP-151296 |
| 2388 | 544.3 | UE Conformance Test Aspects: Network-Assisted Interference Cancellation and Suppression for LTE | 393d? | 2015-09-15 A | 2017-03-15 A | 100% |  |  |  |  |  | finish no earlier than 2017-03-15 | R5 | 3144h | 3144h | LTE_NAICS-UEConTest | PCG-35 | Mediatek |  | Rel-12 | RP-69 |  |  |  |  |
| 2389 | 545 | **Performance requirements of interference cancellation and suppression receiver for SU-MIMO** | 467d? | 2014-03-06 A | 2015-12-15 A | 100% |  | 2014-03-06 | 2015-03-13 | 267d? |  |  | R4 | 7448h | 7448h | LTE_SUMIMO_RX | PCG-32 | Huawei | Qian Cheng (Q.Cheng@Huawei.com) | Rel-12 | RP-63 | Issam |  | LTE_SUMIMO_RX |  |
| 2390 | 545.1 | Perf. part: Performance requirements of interference cancellation and suppression receiver for SU-MIMO | 267d? | 2014-03-06 A | 2015-03-15 A | 100% |  | 2014-03-06 | 2015-03-13 | 267d? |  | finish no earlier than 2015-03-15 | R4 | 2136h | 2136h | LTE_SUMIMO_RX-Perf | PCG-32 | Huawei | Qian Cheng (Q.Cheng@Huawei.com) | Rel-12 | RP-63 | Issam |  | LTE_SUMIMO_RX-Perf | RP-150229 |
| 2391 | 545.2 | UE Conformance Test Aspects - Performance Requirements of Interference Cancellation and Suppression Receiver for SU-MIMO for E-UTRA | 197d? | 2015-03-16 A | 2015-12-15 A | 100% |  |  |  |  |  | finish no earlier than 2016-03-15 | R5 | 1576h | 1576h | LTE_SUMIMO_RX-UEConTest | PCG-34 | Huawei |  | Rel-12 | RP-67 |  |  |  | RP-151245 |
| 2392 | 546 | **HSPA signalling enhancements for more efficient resource usage for LCR** | 274d? | 2012-12-11 A | 2013-12-20 A | 100% |  | 2012-12-10 | 2013-12-06 | 265d? |  |  | R1; R2; R3; R4 | 16832h | 16832h | LCR_TDD_HSPA_sign_enh | PCG-30 | CATT | Yanping Xing (xingyanping@catt.cn) | Rel-12 | RP-58 | Patrick |  | LCR_TDD_HSPA_sign_enh |  |
| 2393 | 546.1 | Core part: HSPA signalling enhancements for more efficient resource usage for LCR TDD | 270d? | 2012-12-15 A | 2013-12-20 A | 100% |  | 2012-12-10 | 2013-12-06 | 265d? |  | finish no earlier than 2013-12-15 | R1; R2; R3 | 6480h | 6480h | LCR_TDD_HSPA_sign_enh-Core | PCG-30 | CATT | Yanping Xing (xingyanping@catt.cn) | Rel-12 | RP-58 | Patrick |  | LCR_TDD_HSPA_sign_enh-Core | RP-131499 |
| 2394 | 546.2 | Perf. part: HSPA signalling enhancements for more efficient resource usage for LCR TDD | 198d? | 2012-12-11 A | 2013-09-06 A | 100% |  | 2012-12-11 | 2013-09-06 | 198d? |  | finish no earlier than 2013-09-06 | R4 | 1584h | 1584h | LCR_TDD_HSPA_sign_enh-Perf | PCG-30 | CATT | Yanping Xing (xingyanping@catt.cn) | Rel-12 | RP-58 | Issam |  | LCR_TDD_HSPA_sign_enh-Perf | RP-130968 |
| 2395 | 547 | **HNB Positioning for UTRA** | 127d? | 2013-06-18 A | 2013-12-06 A | 100% |  | 2013-06-18 | 2013-12-06 | 127d? |  |  | R3 | 2032h | 2032h | UTRA_HNB_Pos | PCG-31 | Alcatel-Lucent | Martin.Warner@alcatel-lucent.com | Rel-12 | RP-60 | Juha | HNB | UTRA_HNB_Pos |  |
| 2396 | 547.1 | Core part: HNB Positioning for UTRA | 127d? | 2013-06-18 A | 2013-12-06 A | 100% |  | 2013-06-18 | 2013-12-06 | 127d? |  | finish no earlier than 2013-12-06 | R3 | 1016h | 1016h | UTRA_HNB_Pos-Core | PCG-31 | Alcatel-Lucent | Martin.Warner@alcatel-lucent.com | Rel-12 | RP-60 | Juha | HNB | UTRA_HNB_Pos-Core | RP-131974 |

Notes:
- 2372: Triggered by TR 36.872 Study on Small Cell Enhancements for E-UTRA and E-UTRAN Physical-layer aspects (UID_580041) / Impacted TSs and TRs: LTE
- 2373: ; CD:Tue 12/05/15->Mon 15/12/14; WID: RP-130848->RP-140522; Stat Rep: RP-141632->RP-141899 / Impacted TSs and TRs: 36.101, 36.104, 36.133, 36.211, 36.212, 36.213, 36.214, 36.300, 36.306, 36.321, 36.331, 36.413, 36.423, 36.443
- 2374: ; CD:Wed 18/03/15->Sun 15/03/15; WID: RP-130848->RP-140522; Stat Rep: RP-141632->RP-141899 1st Apr 15: Compl:40%->80% 1st Apr 15: CD:Sun 15/03/15->Mon 15/06/15 1st Apr 15: Stat Rep: RP-141899->RP-150173 03/07/15: Compl:80%->100% 03/07/15: Stat Rep: RP- / Impacted TSs and TRs: 36.101, 36.104, 36.133, 36.141
- 2375: tested Core part: LTE_SC_enh_L1-Core 29/09/15: Compl:0%->10% 29/09/15: CD:Wed 15/06/16->Thu 15/12/16 29/09/15: Stat Rep: -->RP-151247; 1/1/16: Compl:10%->40%; ...
- 2376: Stage 3. Rel-11 did not address support of a network interface for CoMP involving multiple eNBs with non-ideal backhaul (affected operators might not take advantage of performance benefit from inter-eNB CoMP operation). / Impacted TSs and TRs: LTE
- 2377: CD:Thu 11/12/14->Mon 15/12/14; Compl:85%->100%; Stat Rep: RP-140597->RP-141804 / Impacted TSs and TRs: 36.300, 36.423
- 2378: follow-up of TR 36.848 FS_SCM_LTE / Impacted TSs and TRs: LTE
- 2379: RP#65 completed / Impacted TSs and TRs: 36.331
- 2380: SP#63 SP-140065 CR under TEI12 / Impacted TSs and TRs: 22.011
- 2381: CP#65 completed / Impacted TSs and TRs: 24.173, 24.301, 24.341, 27.007
- 2382: 03/07/15: Compl:0%->60% 03/07/15: WID: RP-150202->RP-150797 03/07/15: Stat Rep: ->RP-150794 29/09/15: Compl:60%->100% 29/09/15: Stat Rep: RP-150794->RP-151445
- 2383: follow-up of TR 36.809 FS_LCS_LTE_RFPMT / Impacted TSs and TRs: LTE
- 2384: RP#64 completed / Impacted TSs and TRs: 36.305, 36.455
- 2385: follow-up of TR 36.866 FS_LTE_NAICS / Impacted TSs and TRs: LTE
- 2386: CD:Mon 08/12/14->Mon 15/12/14; Compl:95%->100%; Stat Rep: RP-141621->RP-141866 / Impacted TSs and TRs: 36.211, 36.213, 36.300, 36.331, 36.423
- 2387: CD:Fri 12/06/15->Mon 15/06/15; Compl:0%->25%; Stat Rep: RP-141621->RP-141866 1st Apr 15: Compl:25%->50% 1st Apr 15: Stat Rep: RP-141866->RP-150179 03/07/15: Compl:50%->85% 03/07/15: CD:Mon 15/06/15->Tue 15/09/15 03/07/15: Stat Rep: RP-150179->RP-150862 / Impacted TSs and TRs: 36.101
- 2388: tested: LTE_NAICS was a REL-12 RAN1 WI; 1/1/16: Compl:0%->35%; 1/1/16: WID: RP-151298->RP-151945; ...
- 2389: no Core part / Impacted TSs and TRs: LTE
- 2390: CD:Fri 13/03/15->Sun 15/03/15; Compl:50%->80%; Stat Rep: RP-141255->RP-141906 1st Apr 15: Compl:80%->100% 1st Apr 15: Stat Rep: RP-141906->RP-150229 / Impacted TSs and TRs: 36.101
- 2391: 03/07/15: Compl:0%->5% 03/07/15: Stat Rep: ->RP-150692 29/09/15: Compl:5%->55% 29/09/15: WID: RP-150245->RP-151463 29/09/15: Stat Rep: RP-150692->RP-1512451/1/16: Compl:55%->100%1/1/16: CD:Tue 15/03/16->Tue 15/1
- 2392: Stage 2/3. Triggered by Rel-11 TR 25.874 Study on HSPA feedback and signalling efficiency enhancements for LCR TDD (FS_LCRTDD_HSPAenh) UID_540026 / Impacted TSs and TRs: UTRA
- 2393: Prev CD:Fri 06/12/13; Prev %:100% / Impacted TSs and TRs: 25.222, 25.224, 25.331, 25.423, 25.433
- 2394: RP#61 completed / Impacted TSs and TRs: 25.102
- 2395: RP#62 completed / Impacted TSs and TRs: UTRA
- 2396: RP#62 closed at 85% completion. Not completed work on HNB positioning / No consensus (may be TEI12, if contribution and support). Updated WID RP-130868=>RP-132037 (HNB positiong was not addressed in this WI, however it was NOT remoded from the WID) / Impacted TSs and TRs: 25.305, 25.467, new TS 25.470

| ID | WBS | Task | Duration | Start | Finish | Complete | Remaining | Baseline start | Baseline finish | Baseline duration | Total slack | Constraint | Resources | Work | Actual work | Acronym | PCG approved | WI rapporteur name | WI rapporteur e-mail | Release | TSG approved | MCC resp | Acronym_3GU_Export | Status Report | Special Focus Doc | PCG stopped | TSG stopped |
| --- | --- | --- | --- | --- | --- | --- | --- | --- | --- | --- | --- | --- | --- | --- | --- | --- | --- | --- | --- | --- | --- | --- | --- | --- | --- | --- | --- |
| 2397 | 548 | **Dedicated Channel (DCH) enhancements for UMTS** | 722d? | 2013-09-15 A | 2016-06-15 A | 100% |  | 2013-09-10 | 2014-12-05 | 326d? |  |  | R1; R2; R3; R4 | 32048h | 32048h | UTRA_DCHenh | PCG-31 | Qualcomm | arjunb@qti.qualcomm.com | Rel-12 | RP-61 | Patrick | UTRA_DCHenh |  |  |  |  |
| 2398 | 548.1 | Core part: Dedicated Channel (DCH) enhancements for UMTS | 115.25d? | 2013-11-18 A | 2014-09-12 A | 100% |  | 2013-11-18 | 2014-09-12 | 115.25d? |  | finish no earlier than 2014-09-12 | R1; R2; R3; R4 | 3688h | 3688h | UTRA_DCHenh-Core | PCG-31 | Qualcomm | arjunb@qti.qualcomm.com | Rel-12 | RP-61 | Patrick | UTRA_DCHenh-Core | RP-141137 |  |  |  |
| 2399 | 548.2 | Perf. part: Dedicated Channel (DCH) enhancements for UMTS | 329d? | 2013-09-15 A | 2014-12-15 A | 100% |  | 2013-09-10 | 2014-12-05 | 326d? |  | finish no earlier than 2014-12-15 | R4 | 2632h | 2632h | UTRA_DCHenh-Perf | PCG-31 | Qualcomm | arjunb@qti.qualcomm.com | Rel-12 | RP-61 | Issam | UTRA_DCHenh-Perf | RP-141970 |  |  |  |
| 2400 | 548.3 | UE Conformance Test Aspects - DCH Enhancements for UMTS | 328d? | 2015-03-16 A | 2016-06-15 A | 100% |  |  |  |  |  | finish no earlier than 2016-06-15 | R5 | 2624h | 2624h | UTRA_DCHenh-UEConTest | PCG-34 | Qualcomm | NA | Rel-12 | RP-67 |  |  | RP-151279 |  |  |  |
| 2401 | 549 | **UMTS Mobility enhancements for heterogeneous networks** | 237.85d? | 2013-07-23 A | 2014-06-13 A | 100% |  | 2013-07-23 | 2014-06-13 | 237.85d? |  |  | R2; R3; R4 | 8040h | 8040h | UTRA_HetNet_mob | PCG-31 | Huawei | Xudong Yang (yangxudong@huawei.com) | Rel-12 | RP-61 | Yong-Jun | UTRA_HetNet_mob |  |  |  |  |
| 2402 | 549.1 | Core part: UMTS Mobility enhancements for heterogeneous networks | 67d? | 2013-07-23 A | 2014-06-13 A | 100% |  | 2013-07-23 | 2014-06-13 | 67d? |  | finish no earlier than 2014-06-13 | R2; R3; R4 | 1608h | 1608h | UTRA_HetNet_mob-Core | PCG-31 | Huawei | Xudong Yang (yangxudong@huawei.com) | Rel-12 | RP-61 | Yong-Jun | UTRA_HetNet_mob-Core | RP-140636 |  |  |  |
| 2403 | 549.2 | Perf. part: UMTS Mobility enhancements for heterogeneous networks | 201d? | 2013-09-09 A | 2014-06-13 A | 100% |  | 2013-09-09 | 2014-06-13 | 201d? |  | finish no earlier than 2014-06-13 | R4 | 1608h | 1608h | UTRA_HetNet_mob-Perf | PCG-31 | Huawei | Xudong Yang (yangxudong@huawei.com) | Rel-12 | RP-61 | Issam | UTRA_HetNet_mob-Perf | RP-140636 |  |  |  |
| 2404 | 550 | **UMTS Heterogeneous Networks enhancements** | 271d? | 2013-12-06 A | 2014-12-15 A | 100% |  | 2013-12-06 | 2014-12-05 | 262d? |  |  | R1; R2; R3; R4 | 12408h | 12408h | UTRA_HetNet_enh | PCG-32 | Huawei | carmela.cozzo@huawei.com | Rel-12 | RP-62 | Patrick | UTRA_HetNet_enh |  |  |  |  |
| 2405 | 550.1 | Core part: Heterogeneous Networks enhancements | 202d? | 2013-12-06 A | 2014-09-12 A | 100% |  | 2013-12-06 | 2014-09-12 | 202d? |  | finish no earlier than 2014-09-15 | R1 | 1616h | 1616h | UTRA_HetNet_enh-Core | PCG-32 | Huawei | carmela.cozzo@huawei.com | Rel-12 | RP-62 | Patrick | UTRA_HetNet_enh-Core | RP-141702 |  |  |  |
| 2406 | 550.2 | Perf. part: Heterogeneous Networks enhancements | 265d? | 2013-12-15 A | 2014-12-15 A | 100% |  | 2013-12-09 | 2014-12-05 | 261d? |  | finish no earlier than 2014-12-15 | R4 | 2120h | 2120h | UTRA_HetNet_enh-Perf | PCG-32 | Huawei | carmela.cozzo@huawei.com | Rel-12 | RP-62 | Issam | UTRA_HetNet_enh-Perf | RP-141898 |  |  |  |
| 2407 | 551 | **Enhanced Broadcast of System Information** | 271d? | 2013-12-06 A | 2014-12-15 A | 100% |  | 2013-12-06 | 2014-12-05 | 262d? |  |  | R2; R1; R3; R4 | 16385.6h | 16385.6h | UTRA_SIBenh | PCG-32 | Ericsson | martin.van.der.zee@ericsson.com | Rel-12 | RP-62 | Yong-Jun | UTRA_SIBenh |  |  |  |  |
| 2408 | 551.1 | Core part: Enhanced Broadcast of System Information | 174.8d? | 2013-12-06 A | 2014-09-12 A | 100% |  | 2013-12-06 | 2014-09-12 | 174.8d? |  | finish no earlier than 2014-09-12 | R2; R1; R3; R4 | 5593.6h | 5593.6h | UTRA_SIBenh-Core | PCG-32 | Ericsson | martin.van.der.zee@ericsson.com | Rel-12 | RP-62 | Yong-Jun | UTRA_SIBenh-Core | RP-141230 |  |  |  |
| 2409 | 551.2 | Perf. part: Enhanced Broadcast of System Information | 265d? | 2013-12-15 A | 2014-12-15 A | 100% |  | 2013-12-09 | 2014-12-05 | 261d? |  | finish no earlier than 2014-12-15 | R4 | 2120h | 2120h | UTRA_SIBenh-Perf | PCG-32 | Ericsson | martin.van.der.zee@ericsson.com | Rel-12 | RP-62 | Issam | UTRA_SIBenh-Perf | RP-142080 |  |  |  |
| 2410 | 552 | **Further Enhanced Uplink (EUL) enhancements** | 329d? | 2013-12-15 A | 2015-03-15 A | 100% |  | 2013-12-09 | 2014-12-05 | 261d? |  |  | R2 | 13704h | 13704h | EDCH_enh | PCG-32 | Ericsson | mark.curran@ericsson.com | Rel-12 | RP-62 | Yong-Jun | EDCH_enh |  |  |  |  |
| 2411 | 552.1 | Core part: Further Enhanced Uplink (EUL) enhancements | 264d? | 2013-12-15 A | 2014-12-15 A | 100% |  | 2014-04-29 | 2014-09-12 | 99d? |  | finish no earlier than 2014-12-15 | R2; R1; R3; R4 | 8448h | 8448h | EDCH_enh-Core | PCG-32 | Ericsson | mark.curran@ericsson.com | Rel-12 | RP-62 | Yong-Jun | EDCH_enh-Core | RP-141860 |  |  |  |
| 2412 | 552.2 | Perf. part: Further Enhanced Uplink (EUL) enhancements | 328d? | 2013-12-15 A | 2015-03-15 A | 100% |  | 2013-12-09 | 2014-12-05 | 261d? |  | finish no earlier than 2015-03-15 | R4 | 2624h | 2624h | EDCH_enh-Perf | PCG-32 | Ericsson | mark.curran@ericsson.com | Rel-12 | RP-62 | Issam | EDCH_enh-Perf | RP-150062 |  |  |  |
| 2413 | 553 | (Small) Technical Enhancements and Improvements for Rel-12 | 197.5d? | 2012-12-25 A | 2014-09-16 A | 100% |  | 2012-12-25 | 2014-09-17 | 197.5d? |  | finish no earlier than 2014-09-17 | SP; CP; RP; GP | 6320h | 6320h | TEI12 | PCG-29 |  |  | Rel-12 | RP-56 |  | TEI12 |  |  |  |  |
| 2414 | 554 | (IETF) (Small) Technical Enhancements and Improvements for Rel-12 (draft-ietf-insipid-session-id) | 131d? | 2014-06-13 A | 2014-12-09 A | 100% |  |  |  |  |  | start no earlier than 2014-06-13 | C1-IETF | 1048h | 1048h | TEI12_IETF | PCG-34 | Alcatel-Lucent |  | Rel-12 | CT-66 |  |  |  |  |  |  |
| 2415 | 555 | Test - (Small) Technical Enhancements and Improvements for Rel-12 | 295.5d? | 2014-10-24 A | 2015-12-11 A | 100% |  | 2014-10-24 | 2015-12-11 | 295.5d? |  | finish no earlier than 2015-12-11 | R5; G3new | 4728h | 4728h | TEI12_Test | PCG-31 |  |  | Rel-12 | RP-61 | Ingbert | TEI12_Test |  |  |  |  |
| 2416 | 556 | Release 12 Studies | 296.5d? | 2013-08-05 A | 2014-09-17 | 80% | 59.3d? | 2013-08-05 | 2014-09-17 | 296.5d? | 1114d | finish no earlier than 2014-09-17 | SP; CP; GP; RP | 9488h | 7590.4h |  |  |  |  | Rel-12 |  |  |  |  |  |  |  |
| 2417 | 557 | Study on Alternatives to E.164 for Machine-Type Communications | 513d? | 2010-03-25 A | 2012-03-07 A | 100% |  | 2010-03-25 | 2012-03-07 | 513d? |  | finish no earlier than 2012-03-07 | S1 | 4080h | 4080h | FS_AMTC | PCG-24 | T-Mobile USA | gary.jones@T-Mobile.com | Rel-12 | SP-47 | Alain | FS_AMTC |  | MTC, M2M |  |  |
| 2418 | 558 | Study on enhancements for Machine-Type Communications (MTC) | 720d? | 2010-06-10 A | 2013-03-06 A | 100% |  | 2010-06-10 | 2013-03-06 | 720d? |  | finish no earlier than 2013-03-06 | S1 | 5751.26h | 5751.26h | FS_MTCe | PCG-25 | Huawei | laurence.meriau@huawei.com | Rel-12 | SP-48 | Alain | FS_MTCe |  | MTC, M2M |  |  |
| 2419 | 559 | Study on Integration of Single Sign-On (SSO) frameworks with 3GPP networks | 383d? | 2010-09-23 A | 2012-03-07 A | 100% |  | 2010-09-23 | 2012-03-07 | 383d? |  | finish no earlier than 2011-09-08 | S1 | 3041.15h | 3041.15h | FS_SSO_Int | PCG-25 | InterDigital | christopher.wallace@interdigital.com | Rel-12 | SP-49 | Alain | FS_SSO_Int |  |  |  |  |
| 2420 | 560 | Study on Continuity of Data Sessions to Local Networks | 262.85d? | 2010-12-16 A | 2011-12-14 A | 100% |  | 2010-12-16 | 2011-12-14 | 262.85d? |  | finish no earlier than 2011-12-14 | S1 | 2084.27h | 2084.27h | FS_CSN | PCG-26 | NEC | joerg.swetina@neclab.eu | Rel-12 | SP-50 | Alain | FS_CSN |  |  |  |  |
| 2421 | 561 | Study on non-MTC Mobile Data Applications Impacts | 262.77d? | 2010-12-16 A | 2011-12-14 A | 100% |  | 2010-12-16 | 2011-12-14 | 262.77d? |  | finish no earlier than 2011-12-14 | S1 | 2083.59h | 2083.59h | FS_MODAI | PCG-26 | Huawei, China Mobile | Amar Deol (adeol@huawei.com), Gang Li | Rel-12 | SP-50 | Alain | FS_MODAI |  |  |  |  |
| 2422 | 562 | Study on Proximity-based Services | 384d? | 2011-09-22 A | 2013-03-05 A | 100% |  | 2011-09-22 | 2013-03-05 | 384d? |  | finish no earlier than 2012-12-12 | S1 | 3045.82h | 3045.82h | FS_ProSe | PCG-27 | Qualcomm | Rich Hovey (rhovey@qualcomm.com) | Rel-12 | SP-53 | Alain | FS_ProSe |  | Public Safety (A-A) |  |  |
| 2423 | 563 | Study on User Plane Congestion management | 198d? | 2011-12-14 A | 2012-09-12 A | 100% |  | 2011-12-14 | 2012-09-12 | 198d? |  | finish no earlier than 2012-09-12 | S1 | 1568h | 1568h | FS_UPCON | PCG-28 | KDDI | John Visser (jvisser@rogers.com) | Rel-12 | SP-54 | Alain | FS_UPCON |  |  |  |  |
| 2424 | 564 | Study on RAN Sharing Enhancements | 401d? | 2011-12-14 A | 2013-06-19 A | 100% |  | 2011-12-14 | 2013-06-19 | 401d? |  | finish no earlier than 2013-06-19 | S1 | 3192h | 3192h | FS_RSE | PCG-28 | NEC | joerg.swetina@neclab.eu | Rel-12 | SP-54 | Alain | FS_RSE |  |  |  |  |
| 2425 | 565 | Deleted - Study on UICC/USIM enhancements | 588d? | 2009-12-10 A | 2012-03-07 A | 100% |  | 2009-12-10 | 2012-03-07 | 588d? |  | finish no earlier than 2012-03-07 | S1 | 4704h | 4704h | FS_U2e | PCG-24 | Giesecke & Devrient | ilario.macchi@gi-de.com | Rel-12 | SP-46 | Alain | FS_U2e |  |  | PCG-28 | SP-55 |

Notes:
- 2397: Triggered by Rel-12 TR 25.702 Study on Dedicated Channel (DCH) enhancements for UMTS (FS_UTRA_DCHenh) UID_580040. Stage 2/3 / Impacted TSs and TRs: UTRA
- 2398: RP#65 completed / Impacted TSs and TRs: 25.101, 25.104, 25.133, 25.211, 25.212, 25.213, 25.214, 25.215, 25.306, 25.308, 25.321, 25.331, 25.423, 25.433
- 2399: ; Stat Rep: RP-141137->RP-141970 / Impacted TSs and TRs: 25.101, 25.104, 25.133
- 2400: 03/07/15: Compl:0%->15% 03/07/15: Stat Rep: ->RP-150764 29/09/15: Compl:15%->50% 29/09/15: CD:Tue 15/12/15->Wed 15/06/16 29/09/15: Stat Rep: RP-150764->RP-1512791/1/16: Compl:50%->65%;
- 2401: Triggered by Rel-12 TR 25.800 Study on UMTS heterogeneous networks (FS_UTRA_hetnet) UID_570024. Stage 2/3 / Impacted TSs and TRs: UTRA
- 2402: RP#64 completed. TS 25.300v100 for 1-step Approval / Impacted TSs and TRs: 25.101, 25.104, 25.133, 25.141, 25.304, 25.306, 25.331, 25.433, new TS 25.300
- 2403: RP#64 completed / Impacted TSs and TRs: 25.101, 25.104, 25.133, 25.141
- 2404: Triggered by the 2nd part of TR 25.800 (FS_UTRA_HetNet); the 1st part is addressed by UTRA_HetNet_mob UID_610026 / Impacted TSs and TRs: UTRA
- 2405: RP#65 completed. Updated WID RP-140463=>RP-141701 / Impacted TSs and TRs: 25.101, 25.211, 25.212, 25.213, 25.214, 25.300, 25.302, 25.306, 25.308, 25.319, 25.331, 25.423, 25.433
- 2406: ; Stat Rep: RP-141702->RP-141898 / Impacted TSs and TRs: 25.101, 25.104, 25.133, 25.141
- 2407: Triggered by Rel-12 UTRA TR 25.704 Study on Enhanced Broadcast of System Information (FS_UTRA_SIBenh) / Impacted TSs and TRs: UTRA
- 2408: RP#65 completed / Impacted TSs and TRs: 25.211, 25.212 , 25.213, 25.214, 25.301, 25.302, 25.304, 25.306, 25.321, 25.331, 25.433
- 2409: ; Stat Rep: RP-141230->RP-142080 / Impacted TSs and TRs: 25.101, 25.104, 25.133, 25.141
- 2410: Triggered by Rel-12 UTRA TR 25.700 Study on Further Enhanced Uplink (EUL) enhancements (FS_EDCH_enh) / Impacted TSs and TRs: UTRA
- 2411: ; Stat Rep: RP-141684->RP-141860 / Impacted TSs and TRs: 25.211, 25.212, 25.214, 25.304, 25.306, 25.308, 25.319, 25.321, 25.331, 25.423, 25.425, 25.433, 25.435
- 2412: ; CD:Wed 18/03/15->Sun 15/03/15; Stat Rep: RP-141684->RP-141860 1st Apr 15: Compl:75%->100% 1st Apr 15: Stat Rep: RP-141860->RP-150062 / Impacted TSs and TRs: 25.101, 25.104, 25.133, 25.141
- 2413: -
- 2414: Mar15: In WGLC; 21/3/17: 50%->100 / Impacted TSs and TRs: draft-ietf-insipid-session-id
- 2415: -
- 2416: -
- 2417: SP#55 completed. Determine an alternative to E.164 for identifying individual devices and route messages between those devices / Impacted TSs and TRs: 22.988
- 2418: SP#59 completed. TR 22.888 v100 for Information & Approval. Study addition of new MTC-related use cases and functionality and improvements to existing requirements in TS 22.368 / Impacted TSs and TRs: 22.888
- 2419: SP#55 completed. Linked to SA3 Study on Single Sign On (SSO) Application Security for IMS - based on SIP Digest (UID_480048), SA3 TR 33.924 Extended Identity Management (GBA-IdM) and SA3 TR 33.980 (LibSec) / Impacted TSs and TRs: 22.895
- 2420: SP#54 completed. Linked to SA1 Rel-11 Feature UID_490030 SIPTO Service Continuity of IP Data Session (SIPTO_SC) / Impacted TSs and TRs: 22.896
- 2421: SP#54 completed. Linked to UID_490036 SA2 Rel-11 TR 23.843 Study on Core Network Overload solutions (FS_CNO) / Impacted TSs and TRs: 22.801
- 2422: SP#59 completed / Impacted TSs and TRs: 22.803
- 2423: SP#57 completed. Linked to SAPP (Service Awareness and Privacy Policies), FS_UMONC (Study on Usage Monitoring Control Enhancement), QoS_SSL (QoS Control Based on Subscriber Spending Limits) / Impacted TSs and TRs: 22.805
- 2424: SP#60 completed. Extend Rel-6 Network Sharing UID_31018 (basic scenarios of network/RAN sharing) to cover more complex scenarios that arise due to recent needs for more dynamic co-operation among operators / Impacted TSs and TRs: 22.852
- 2425: SP#55 work stopped. Triggered by GSMA Smart SIM and 3GNBK projects, and to evolve from traditional USAT to multimedia USIM toolkit support, particularly to Smart Card Web Server / Impacted TSs and TRs: 22.817

| ID | WBS | Task | Duration | Start | Finish | Complete | Baseline start | Baseline finish | Baseline duration | Constraint | Resources | Work | Actual work | Acronym | PCG approved | Impacted TSs and TRs | WI rapporteur name | WI rapporteur e-mail | Release | TSG approved | MCC resp | Acronym_3GU_Export | Special Focus Doc | PCG stopped | TSG stopped | Status Report |
| --- | --- | --- | --- | --- | --- | --- | --- | --- | --- | --- | --- | --- | --- | --- | --- | --- | --- | --- | --- | --- | --- | --- | --- | --- | --- | --- |
| 2426 | 566 | **Study on IMS based Peer-to-Peer Content Distribution Services (Stage 2)** | 587d? | 2010-09-23 A | 2012-12-12 A | 100% | 2010-09-23 | 2012-12-12 | 587d? |  | S2; S1; S3 | 19472h | 19472h | FS_IMS_P2P_CDS | PCG-25 | 23.844 | China Mobile | Yu Qing (yuqing@chinamobile.com) | Rel-12 | SP-49 | Maurice | FS_IMS_P2P_CDS |  |  |  |  |
| 2427 | 566.1 | SA1 part of Study on IMS based Peer-to-Peer Content Distribution Services (Stage 2) | 262d? | 2010-09-23 A | 2011-09-21 A | 100% | 2010-09-23 | 2011-09-21 | 262d? | finish no earlier than 2011-09-21 | S1 | 2080h | 2080h | FS_IMS_P2P_CDS | PCG-25 | 23.844 | China Mobile | Yu Qing (yuqing@chinamobile.com) | Rel-12 | SP-49 | Maurice |  |  |  |  |  |
| 2428 | 566.2 | SA2 part of Study on IMS based Peer-to-Peer Content Distribution Services (Stage 2) | 347d? | 2010-09-23 A | 2012-06-20 A | 100% | 2010-09-23 | 2012-06-20 | 347d? | finish no earlier than 2012-06-08 | S2 | 2776h | 2776h | FS_IMS_P2P_CDS | PCG-25 | 23.844 | China Mobile | Yu Qing (yuqing@chinamobile.com) | Rel-12 | SP-49 | Maurice |  |  |  |  |  |
| 2429 | 566.3 | SA3 part of Study on IMS based Peer-to-Peer Content Distribution Services (Stage 2) | 68d? | 2012-09-12 A | 2012-12-12 A | 100% | 2012-09-12 | 2012-12-12 | 68d? | finish no earlier than 2012-12-12 | S3 | 528h | 528h | FS_IMS_P2P_CDS | PCG-29 | 33.844 | China Mobile | Zhu Judy(zhuhongru@chinamobile.com) | Rel-12 | SP-57 | Mirko |  |  |  |  |  |
| 2430 | 567 | **Study on Core Network Overload solutions** | 852d? | 2010-09-23 A | 2013-12-11 A | 100% | 2010-09-23 | 2013-12-11 | 852d? |  | S2 | 18240.6h | 18240.6h | FS_CNO | PCG-25 | 23.843 | Huawei | Mirko.Schramm@huawei.com | Rel-12 | SP-49 | Maurice | FS_CNO |  |  |  |  |
| 2431 | 567.1 | Study on Core Network Overload solutions (Phase 1) | 587d? | 2010-09-23 A | 2012-12-12 A | 100% | 2010-09-23 | 2012-12-12 | 587d? | finish no earlier than 2012-12-12 | S2 | 4684.11h | 4684.11h | FS_CNO | PCG-25 | 23.843 | Huawei | Mirko.Schramm@huawei.com | Rel-12 | SP-49 | Maurice |  |  |  |  |  |
| 2432 | 567.2 | Study on Core Network Overload solutions (Phase 2) | 844d? | 2010-09-23 A | 2013-12-11 A | 100% | 2010-09-23 | 2013-12-11 | 844d? | finish no earlier than 2013-12-11 | S2 | 6744h | 6744h | FS_CNO | PCG-25 | 23.843 | Huawei | Mirko.Schramm@huawei.com | Rel-12 | SP-49 | Maurice |  |  |  |  |  |
| 2433 | 568 | Study on System Enhancements for Energy Efficiency | 399d? | 2010-12-16 A | 2012-06-20 A | 100% | 2010-12-16 | 2012-06-20 | 399d? | finish no earlier than 2012-06-20 | S2 | 3192h | 3192h | FS_SEEE | PCG-26 | 23.866 | Huawei | frank.mademann@huawei.com | Rel-12 | SP-50 | Maurice | FS_SEEE |  |  |  |  |
| 2434 | 569 | Study on S2a Mobility based On GTP and WLAN access to EPC | 657d? | 2011-03-23 A | 2013-09-11 A | 100% | 2011-03-23 | 2013-09-11 | 657d? | finish no earlier than 2013-09-11 | S2 | 5165.94h | 5165.94h | FS_SaMOG | PCG-26 | 23.852 | ZTE | Tricci So (tso@zteusa.com) | Rel-12 | SP-51 | Maurice | FS_SaMOG | WLAN |  |  |  |
| 2435 | 570 | Study on Optimized Offloading to WLAN in 3GPP-RAT Mobility | 326d? | 2012-06-18 A | 2013-09-11 A | 100% | 2012-06-18 | 2013-09-11 | 326d? | finish no earlier than 2013-09-11 | S2 | 2592h | 2592h | FS_WORM | PCG-29 | 23.890 | BlackBerry | Steve Barrett (sbarrett@blackberry.com) | Rel-12 | SP-56 | Maurice | FS_WORM | WLAN |  |  |  |
| 2436 | 571 | Study on Application Based Charging | 190d? | 2012-06-18 A | 2013-03-06 A | 100% | 2012-06-18 | 2013-03-06 | 190d? | finish no earlier than 2013-03-06 | S2 | 1520h | 1520h | FS_ABC | PCG-29 | 23.800 | Allot | Alla Goldner (agoldner@allot.com) | Rel-12 | SP-56 | Maurice | FS_ABC |  |  |  |  |
| 2437 | 572 | **Study on Multi Access PDN connectivity and IP flow Mobility** | 1141.96d? | 2008-08-08 A | 2012-12-12 A | 100% | 2008-08-08 | 2012-12-12 | 1141.96d? |  | S2; S1 | 27327.4h | 27327.4h | FS_MAPIM | PCG-21 | 23.861 | Qualcomm | Gerardo Giaretta (gerardog@qualcomm.com) | Rel-12 | SP-41 | Maurice | FS_MAPIM |  |  |  |  |
| 2438 | 572.1 | SA1 part of Study on Multi Access PDN connectivity and IP flow Mobility | 22d? | 2008-08-08 A | 2011-09-21 A | 100% | 2008-08-08 | 2011-09-21 | 22d? | finish no earlier than 2011-09-21 | S1 | 160h | 160h | FS_MAPIM | PCG-21 | 23.861 | Qualcomm | Gerardo Giaretta (gerardog@qualcomm.com) | Rel-12 | SP-41 | Maurice |  |  |  |  |  |
| 2439 | 572.2 | SA2 part of Study on Multi Access PDN connectivity and IP flow Mobility | 1113d? | 2008-09-18 A | 2012-12-12 A | 100% | 2008-09-18 | 2012-12-12 | 1113d? | finish no earlier than 2012-12-12 | S2 | 8896h | 8896h | FS_MAPIM | PCG-21 | 23.861 | Qualcomm | Gerardo Giaretta (gerardog@qualcomm.com) | Rel-12 | SP-41 | Maurice |  |  |  |  |  |
| 2440 | 573 | Deleted - Study on IP Flow Mobility support for S2a and S2b Interfaces | 190d? | 2012-06-18 A | 2013-03-06 A | 100% | 2012-06-18 | 2013-03-06 | 190d? | finish no earlier than 2013-03-06 | S2 | 1520h | 1520h | FS_NBIFOM | PCG-29 | 23.861 | ZTE | Tricci So (tso@zteusa.com) | Rel-12 | SP-56 | Maurice | FS_NBIFOM |  | PCG-30 | SP-59 |  |
| 2441 | 574 | Study on Extended IMS Media Plane Security features | 719d? | 2010-06-10 A | 2013-03-06 A | 100% | 2010-06-10 | 2013-03-06 | 719d? | finish no earlier than 2013-03-06 | S3 | 5736h | 5736h | FS_eMEDIASEC | PCG-25 | 33.829 | Vodafone | Aguibou.Barry@vodafone.com | Rel-12 | SP-48 | Mirko | FS_eMEDIASEC |  |  |  |  |
| 2442 | 575 | Deleted - Study on Firewall traversal (Stage 2) | 854d? | 2011-06-17 A | 2014-09-17 A | 100% | 2011-06-17 | 2014-09-17 | 854d? | finish no earlier than 2014-09-17 | S3 | 6832h | 6832h | FS_Fire | PCG-27 | 33.830 | Acme Packet | Prashant Kumar (PKumar@acmepacket.com) | Rel-12 | SP-53 | Mirko | FS_Fire |  | PCG-33 | SP-65 |  |
| 2443 | 576 | Study on Security on spoofed call detection and prevention (Stage 2) | 662d? | 2012-03-07 A | 2014-09-17 A | 100% | 2012-03-07 | 2014-09-17 | 662d? | finish no earlier than 2014-09-17 | S3 | 5296h | 5296h | FS_SPOOF | PCG-28 | 33.831 | China Mobile | lixiangjun@chinamobile.com | Rel-12 | SP-55 | Mirko | FS_SPOOF |  |  |  |  |
| 2444 | 577 | Study on Security Assurance Methodology for 3GPP Network Elements | 466d? | 2012-09-13 A | 2014-06-18 A | 100% | 2012-09-13 | 2014-06-18 | 466d? | finish no earlier than 2014-03-07 | S3 | 3696h | 3696h | FS_SECAM | PCG-29 | 33.805 | Orange | loic.habermacher@orange.com | Rel-12 | SP-57 | Mirko | FS_SECAM |  |  |  |  |
| 2445 | 578 | Study on Improved Support for Dynamic Adaptive Streaming over HTTP in 3GPP | 729d? | 2011-12-14 A | 2014-09-16 A | 100% | 2011-12-14 | 2014-09-17 | 729d? | finish no earlier than 2014-09-17 | S4 | 5824h | 5824h | FS_IS_DASH | PCG-28 | 26.938 | Qualcomm | c_tstock@qualcomm.com | Rel-12 | SP-54 | Paolo | FS_IS_DASH |  |  |  |  |
| 2446 | 579 | Study on HTML5 for a new presentation layer in 3GPP services | 266d? | 2013-09-12 A | 2014-09-16 A | 100% | 2013-09-12 | 2014-09-17 | 266d? | finish no earlier than 2014-09-17 | S4 | 2128h | 2128h | FS_HTML5 | PCG-31 | 26.907 | Samsung | Imed Bouazizi (i.bouazizi@sta.samsung.com) | Rel-12 | SP-61 | Paolo | FS_HTML5 |  |  |  |  |
| 2447 | 580 | Study on version handling | 716d? | 2010-03-25 A | 2012-12-12 A | 100% | 2010-03-25 | 2012-12-12 | 716d? | finish no earlier than 2012-12-12 | S5 | 5704h | 5704h | FS_OAM_VH | PCG-24 | 32.830 | Ericsson | thomas.tovinger@ericsson.com | Rel-12 | SP-47 | Mirko | FS_OAM_VH |  |  |  |  |
| 2448 | 581 | Study on management of Heterogeneous Networks | 852d? | 2011-03-23 A | 2014-06-18 A | 100% | 2011-03-23 | 2014-06-18 | 852d? | finish no earlier than 2014-06-18 | S5 | 6816h | 6816h | FS_OAM_HetNet | PCG-26 | 32.835 | Ericsson | ulf.hubinette@ericsson.com | Rel-12 | SP-51 | Mirko | FS_OAM_HetNet |  |  |  |  |
| 2449 | 582 | Study on OAM aspects of Network Sharing | 464d? | 2011-12-07 A | 2013-09-11 A | 100% | 2011-12-07 | 2013-09-11 | 464d? | finish no earlier than 2013-09-11 | S5 | 3696h | 3696h | FS_OAM_SHARE | PCG-28 | 32.851 | Alcatel-Lucent, Huawei | Padma.Sudarsan@alcatel-lucent.com, zoulan@huawei.com | Rel-12 | SP-54 | Mirko | FS_OAM_SHARE |  |  |  |  |
| 2450 | 583 | Study on Enhanced Network Management (NM) centralized Coverage and Capacity Optimization | 590d? | 2011-09-21 A | 2014-09-17 A | 100% | 2011-09-21 | 2014-09-17 | 590d? | finish no earlier than 2014-09-17 | S5 | 4712h | 4712h | FS_SON_NM_CCO | PCG-29 | 32.836 | Ericsson | robert.petersen@ericsson.com | Rel-12 | SP-56 | Mirko | FS_SON_NM_CCO | SON |  |  |  |
| 2451 | 584 | Study on WLAN management | 788d? | 2011-09-21 A | 2014-09-17 A | 100% | 2012-06-20 | 2014-09-17 | 590d? | finish no earlier than 2014-09-17 | S5 | 6304h | 6304h | FS_WLAN_OAM | PCG-29 | 28.680, 28.681, 28.682, 28.683, 28.403 | Intel | joey.chou@intel.com | Rel-12 | SP-56 | Mirko | FS_WLAN_OAM | WLAN |  |  |  |
| 2452 | 585 | Study on Alarm Management | 201d? | 2012-12-07 A | 2013-09-11 A | 100% | 2012-12-07 | 2013-09-11 | 201d? | finish no earlier than 2013-09-11 | S5 | 1592h | 1592h | FS_OAM_AM | PCG-30 | 32.859 | TeliaSonera | tommy.berggren@teliasonera.com | Rel-12 | SP-58 | Mirko | FS_OAM_AM |  |  |  |  |
| 2453 | 586 | Study on Indication of Network to Network Interface (NNI) Routeing scenarios in SIP requests | 400d? | 2012-12-10 A | 2014-06-13 A | 100% | 2012-12-10 | 2014-06-13 | 400d? | finish no earlier than 2014-03-06 | C3 | 3190.27h | 3190.27h | FS_NNI_RS | PCG-30 | 24.802 | Ericsson | Jan.Holm@ericsson.com | Rel-12 | CP-58 | Adrian | FS_NNI_RS |  |  |  |  |
| 2454 | 587 | Study on Diameter Overload Control Mechanisms | 464d? | 2012-01-05 A | 2014-09-11 A | 100% | 2012-01-05 | 2014-09-12 | 464d? | finish no earlier than 2014-09-12 | C4 | 3712h | 3712h | FS_DOCME | PCG-30 | 29.809 | Orange | lionel.morand@orange.com | Rel-12 | CP-58 | Kimmo | FS_DOCME |  |  |  |  |
| 2455 | 588 | Study on XML based access of AF to the PCRF | 203d? | 2013-03-01 A | 2013-12-04 A | 100% | 2013-03-01 | 2014-06-13 | 341d? | finish no earlier than 2014-06-13 | C3 | 1608h | 1608h | FS_XML_AF_PCRF | PCG-30 | 29.817 | Alcatel-Lucent | horst.brinkman@alcatel-lucent.com | Rel-12 | CP-59 | Adrian | FS_XML_AF_PCRF |  |  |  |  |
| 2456 | 589 | Study on Technical aspects on Roaming End-to-end scenarios with VoLTE IMS and other networks | 328d? | 2013-09-09 A | 2014-12-09 A | 100% | 2013-09-09 | 2014-09-12 | 266d? | finish no earlier than 2014-12-09 | C3 | 2624h | 2624h | FS_REVOLTE_IMS | PCG-31 | 29.949 | Deutsche Telekom | Roland Jesske (r.jesske@telekom.de) | Rel-12 | CP-61 | Adrian | FS_REVOLTE_IMS |  |  |  |  |
| 2457 | 590 | Study on Development of conformance requirements for the IP Multimedia Services Identity Module (ISIM) application support in ME | 263d? | 2013-12-09 A | 2014-12-09 A | 100% | 2013-12-09 | 2014-09-12 | 201d? | finish no earlier than 2014-12-09 | C6 | 2104h | 2104h | FS_ISIM_CR | PCG-32 | 31.829 | Gemalto | ly-thanh.phan@gemalto.com | Rel-12 | CP-62 | Xavier | FS_ISIM_CR |  |  |  |  |
| 2458 | 591 | Study on Shared Data Update for Multiple Subscribers | 263d? | 2013-12-06 A | 2014-12-09 A | 100% | 2013-12-06 | 2014-09-12 | 201d? | finish no earlier than 2014-12-09 | C4 | 2104h | 2104h | FS_SHARED_SubData_UPD | PCG-32 | 29.854 | Huawei | Susan Shi (susan.shishufeng@huawei.com) | Rel-12 | CP-62 | Kimmo | FS_SHARED_SubData_UPD |  |  |  |  |
| 2459 | 592 | Study on GERAN improvements for Machine-Type Communications | 661d? | 2010-05-24 A | 2012-11-23 A | 100% | 2010-05-24 | 2012-11-23 | 661d? | finish no earlier than 2012-11-23 | G1; G2 | 10576h | 10576h | FS_NIMTC_GERAN | PCG-24 | 43.868 | Ericsson | paul.schliwa-bertling@ericsson.com | Rel-12 | GP-44 | Paolo | FS_NIMTC_GERAN | MTC, M2M |  |  |  |
| 2460 | 593 | Study on Voice services over Adaptive Multi-user channels on One Slot (VAMOS) enhancements | 267.67d? | 2010-10-27 A | 2014-05-30 A | 100% | 2010-10-27 | 2014-05-30 | 267.67d? | finish no earlier than 2014-05-30 | GP; G2; G1 | 6424h | 6424h | FS_eVAMOS | PCG-27 | 43.801 | China Mobile, Huawei | Chao Luo (chluo@huawei.com), dengjuan@chinamobile.com | Rel-12 | GP-50 | Paolo | FS_eVAMOS |  |  |  |  |
| 2461 | 594 | Study on GERAN enhancements for Mobile Data Applications | 430d? | 2011-04-04 A | 2014-08-29 A | 100% | 2011-04-04 | 2014-08-29 | 430d? | finish no earlier than 2014-08-29 | G2; G1 | 6880h | 6880h | FS_GERAN_eMDA | PCG-27 | 43.802 | Huawei | ming.fang@huawei.com | Rel-12 | GP-50 | Gert | FS_GERAN_eMDA |  |  |  |  |
| 2462 | 595 | Study on Inclusion of RF Pattern Matching Technologies as a positioning method in the E-UTRAN | 722d? | 2010-12-10 A | 2013-09-06 A | 100% | 2010-12-10 | 2013-09-06 | 722d? | finish no earlier than 2013-09-06 | R4 | 5776h | 5776h | FS_LCS_LTE_RFPMT | PCG-26 | LTE 36.809 | Polaris Wireless | Scot Gordon (sgordon@polariswireless.com) | Rel-12 | RP-50 | Issam | FS_LCS_LTE_RFPMT |  |  |  | RP-131082 |
| 2463 | 596 | Study on Provision of low-cost MTC UEs based on LTE | 462d? | 2011-09-19 A | 2013-06-14 A | 100% | 2011-09-19 | 2013-06-14 | 462d? | finish no earlier than 2013-06-14 | R1; R2; R4 | 11088h | 11088h | FS_LC_MTC_LTE | PCG-27 | LTE 36.888 | Vodafone | prakash.bhat@vodafone.com | Rel-12 | RP-53 | Patrick | FS_LC_MTC_LTE | MTC, M2M |  |  | RP-130583 |
| 2464 | 597 | Deleted - Study on Mobile Relay for E-UTRA | 881.5d? | 2005-05-19 A | 2014-06-23 A | 100% | 2005-05-19 | 2014-06-23 | 881.5d? | finish no earlier than 2014-06-23 | R3; R1 | 14104h | 14104h | FS_LTE_mobRelay | PCG-27 | LTE 36.836 | CATT | Haijing Hu (huhaijing@catt.cn) | Rel-12 | RP-53 | Juha | FS_LTE_mobRelay |  | PCG-33 | RP-64 | RP-140726 |
| 2465 | 598 | Study on Scenarios and Requirements of LTE Small Cell Enhancements for E-UTRA and E-UTRAN | 66d? | 2012-09-11 A | 2012-12-07 A | 100% | 2012-09-11 | 2012-12-07 | 66d? | finish no earlier than 2012-12-07 | RP | 528h | 528h | FS_LTE_SC_enh_req | PCG-29 | LTE 36.932 | China Mobile | Hai TANG (tanghai@chinamobile.com) | Rel-12 | RP-57 | Yong-Jun | FS_LTE_SC_enh_req | Small cell |  |  | RP-121651 |
| 2466 | 599 | Study on Small Cell Enhancements for E-UTRA and E-UTRAN – Physical-layer aspects | 265d? | 2012-09-11 A | 2013-09-06 A | 100% | 2012-09-11 | 2013-09-06 | 265d? | finish no earlier than 2013-09-06 | R1; R2; R4 | 6360h | 6360h | FS_LTE_SC_enh_L1 | PCG-30 | LTE 36.872 | Huawei | Elean Fan (fanxiaoan@huawei.com) | Rel-12 | RP-58 | Patrick | FS_LTE_SC_enh_L1 | Small cell |  |  | RP-131618 |
| 2467 | 600 | Study on Small Cell Enhancements for E-UTRA and E-UTRAN – Higher-layer aspects | 265d? | 2012-12-10 A | 2013-12-06 A | 100% | 2012-12-10 | 2013-12-06 | 265d? | finish no earlier than 2013-12-06 | R2; R3 | 4240h | 4240h | FS_LTE_SC_enh_hilayer | PCG-30 | LTE 36.842 | NTT DOCOMO | Hideaki Takahashi (h-takahashi@nttdocomo.co.jp) | Rel-12 | RP-58 | Yong-Jun | FS_LTE_SC_enh_hilayer | Small cell |  |  | RP-131619 |
| 2468 | 601 | Study on LTE Device-to-Device Proximity Services - Radio Aspects | 325d? | 2012-12-17 A | 2014-03-06 A | 100% | 2012-12-17 | 2014-03-06 | 325d? | finish no earlier than 2014-03-06 | R1; R2; R3; R4 | 10400h | 10400h | FS_LTE_D2D_Prox | PCG-30 | LTE 36.843 | Qualcomm | Shailesh Patil (patil@qti.qualcomm.com) | Rel-12 | RP-58 | Patrick | FS_LTE_D2D_Prox | Public Safety (A-A) |  |  | RP-140416 |
| 2469 | 602 | Study on 3D-channel model for Elevation Beamforming and FD-MIMO studies for LTE | 463d? | 2012-12-10 A | 2014-09-12 A | 100% | 2012-12-10 | 2014-09-12 | 463d? | finish no earlier than 2014-09-12 | R1 | 3704h | 3704h | FS_LTE_3D_channel | PCG-30 | LTE 36.873 | Nokia Networks | bishwarup.mondal@nsn.com | Rel-12 | RP-58 | Patrick | FS_LTE_3D_channel |  |  |  | RP-141206 |
| 2470 | 603 | Study on Energy Saving Enhancement for E-UTRAN | 397d? | 2012-12-10 A | 2014-06-13 A | 100% | 2012-12-10 | 2014-06-13 | 397d? | finish no earlier than 2014-06-13 | R3 | 3176h | 3176h | FS_Netw_Energy_enh_LTE | PCG-30 | LTE 36.887 | China Mobile | Kimba Dit Adamou, Boubacar (jinba@chinamobile.com) | Rel-12 | RP-58 | Juha | FS_Netw_Energy_enh_LTE |  |  |  | RP-140604 |
| 2471 | 604 | Study on Expansion of LTE_FDD_1670_US to include 1670-1680MHz Band for LTE in the US | 469d? | 2013-03-01 A | 2014-12-15 A | 100% | 2013-03-01 | 2014-09-12 | 403d? | finish no earlier than 2014-12-15 | R4 | 3752h | 3752h | FS_LTE_FDD_1670_US | PCG-30 | LTE 36.844 | LightSquared | masoud.olfat@lightsquared.com | Rel-13 | RP-59 | Issam | FS_LTE_FDD_1670_US |  |  |  | RP-141815 |
| 2472 | 605 | Study on Cell-specific Reference Signals (CRS) Interference Mitigation for homogenous deployments for LTE | 201d? | 2013-03-04 A | 2013-12-06 A | 100% | 2013-03-04 | 2013-12-06 | 201d? | finish no earlier than 2013-12-06 | R4 | 1608h | 1608h | FS_LTE_CRSIC | PCG-30 | LTE 36.863 | Ericsson | shaohua.li@ericsson.com | Rel-12 | RP-59 | Issam | FS_LTE_CRSIC |  |  |  | RP-131623 |
| 2473 | 606 | Study on Network-Assisted Interference Cancellation and Suppression for LTE | 265d? | 2013-03-08 A | 2014-03-06 A | 100% | 2013-03-08 | 2014-03-06 | 265d? | finish no earlier than 2014-03-06 | R1; R4 | 4240h | 4240h | FS_LTE_NAICS | PCG-30 | LTE 36.866 | MediaTek | jeff.zhuang@mediatek.com | Rel-12 | RP-59 | Patrick | FS_LTE_NAICS |  |  |  | RP-132108 |
| 2474 | 607 | Study on Coordinated Multi-Point (CoMP) operation for LTE with Non-Ideal Backhaul | 126d? | 2013-06-18 A | 2013-12-06 A | 100% | 2013-06-18 | 2013-12-06 | 126d? | finish no earlier than 2013-12-06 | R1 | 1008h | 1008h | FS_COMP_LTE_nibackhaul | PCG-31 | LTE 36.874 | Samsung | Hyojin Lee (hyojin257.lee@samsung.com) | Rel-12 | RP-60 | Patrick | FS_COMP_LTE_nibackhaul |  |  |  | RP-131626 |
| 2475 | 608 | Study on Group Communication for LTE | 130d? | 2013-09-10 A | 2014-03-06 A | 100% | 2013-09-10 | 2014-03-06 | 130d? | finish no earlier than 2014-03-06 | R2; R3 | 2080h | 2080h | FS_LTE_GC | PCG-31 | LTE 36.868 | Alcatel-Lucent | chandrika.worrall@alcatel-lucent.com | Rel-12 | RP-61 | Yong-Jun | FS_LTE_GC | Public Safety (A-A) |  |  | RP-140182 |
| 2476 | 609 | Study on Smart Congestion Mitigation in E-UTRAN | 130d? | 2013-09-09 A | 2014-03-06 A | 100% | 2013-09-09 | 2014-03-06 | 130d? | finish no earlier than 2014-03-06 | R2 | 1040h | 1040h | FS_SCM_LTE | PCG-31 | LTE 36.848 | LG Electronics | youngdae.lee@lge.com | Rel-12 | RP-61 | Yong-Jun | FS_SCM_LTE |  |  |  | RP-140102 |
| 2477 | 610 | Study on RAN aspects of RAN Sharing Enhancements for LTE | 136d? | 2013-12-06 A | 2014-06-13 A | 100% | 2013-12-06 | 2014-06-13 | 136d? | finish no earlier than 2014-06-13 | R3 | 1088h | 1088h | FS_RSE-RAN_LTE | PCG-32 | LTE 36.856 | NEC | Siva.Vakeesar@emea.nec.com | Rel-12 | RP-62 | Juha | FS_RSE-RAN_LTE |  |  |  | RP-140746 |
| 2478 | 611 | Study on RF and EMC requirements for active Antenna Array System (AAS) Base Station | 386d? | 2011-09-19 A | 2013-03-01 A | 100% | 2011-09-19 | 2013-03-01 | 386d? | finish no earlier than 2013-03-01 | R4; R1 | 6176h | 6176h | FS_AAS_BS_LTE_UTRA | PCG-27 | UTRA, LTE 37.840 | Huawei | Ronnie.zhang@huawei.com | Rel-12 | RP-53 | Issam | FS_AAS_BS_LTE_UTRA |  |  |  | RP-130124 |
| 2479 | 612 | Study on LTE-HRPD (High Rate Packet Data in 3GPP2) inter-RAT SON | 340d? | 2012-03-02 A | 2013-06-14 A | 100% | 2012-03-02 | 2013-06-14 | 340d? | finish no earlier than 2013-06-14 | R3 | 2712h | 2712h | FS_LTE_HRPD_SON | PCG-28 | UTRA, LTE 37.813 | China Telecom | Wu Jinlian (wujl@gsta.com) | Rel-12 | RP-55 | Juha | FS_LTE_HRPD_SON | SON |  |  | RP-130585 |
| 2480 | 613 | Study on Passive InterModulation (PIM) handling for UTRA and LTE Base Stations | 403d? | 2012-03-05 A | 2013-09-06 A | 100% | 2012-03-05 | 2013-09-06 | 403d? | finish no earlier than 2013-09-06 | R4; G1 | 6448h | 6448h | FS_BS_PIM | PCG-28 | UTRA, LTE 37.808 | Ericsson | johan.skold@ericsson.com | Rel-12 | RP-55 | Issam | FS_BS_PIM |  |  |  | RP-131076 |
| 2481 | 614 | Study on WLAN/3GPP Radio Interworking | 264d? | 2012-12-10 A | 2013-12-06 A | 100% | 2012-12-10 | 2013-12-06 | 264d? | finish no earlier than 2013-12-06 | R2 | 2104h | 2104h | FS_UTRA_LTE_WLAN_interw | PCG-30 | UTRA, LTE 37.834 | Intel | sasha.sirotkin@intel.com | Rel-12 | RP-58 | Yong-Jun | FS_UTRA_LTE_WLAN_interw | WLAN |  |  | RP-131611 |
| 2482 | 615 | Study on RAN Enhancements for UMTS/HSPA and LTE Interworking | 261d? | 2012-12-10 A | 2013-12-06 A | 100% | 2012-12-10 | 2013-12-06 | 261d? | finish no earlier than 2013-12-06 | R3 | 2088h | 2088h | FS_HSPA_LTE_interworking | PCG-30 | UTRA, LTE 37.852 | China Unicom | Meng Zhang (zhangmeng68@chinaunicom.cn) | Rel-12 | RP-58 | Juha | FS_HSPA_LTE_interworking |  |  |  | RP-131612 |
| 2483 | 616 | Study on Next-Generation SON for UTRA and LTE | 397d? | 2012-12-10 A | 2014-06-13 A | 100% | 2012-12-10 | 2014-06-13 | 397d? | finish no earlier than 2014-06-13 | R3 | 3176h | 3176h | FS_UTRA_LTE_NG_SON | PCG-30 | UTRA, LTE 37.822 | NSN | krzysztof.kordybach@nsn.com | Rel-12 | RP-58 | Juha | FS_UTRA_LTE_NG_SON | SON |  |  | RP-140747 |
| 2484 | 617 | Study on 2GHz FDD for UTRA and LTE in Region 1 (1980-2010MHz and 2170-2200MHz Bands) | 462d? | 2012-12-11 A | 2014-09-12 A | 100% | 2012-12-11 | 2014-09-12 | 462d? | finish no earlier than 2014-09-12 | R4 | 3696h | 3696h | FS_UTRA_LTE_1980_2170_REG1 | PCG-30 | UTRA, LTE 37.846 | DISH Network | johny.kim@dish.com, mariam.sorond@dish.com | Rel-12 | RP-58 | Issam | FS_UTRA_LTE_1980_2170_REG1 |  |  |  | RP-141099 |
| 2485 | 618 | Study on Base Station specification structure | 136d? | 2012-12-10 A | 2013-06-14 A | 100% | 2012-12-10 | 2013-06-14 | 136d? | finish no earlier than 2013-06-14 | R4 | 1088h | 1088h | FS_BSspec_struc | PCG-30 | UTRA, LTE, MSR 37.810 | Ericsson | johan.skold@ericsson.com | Rel-12 | RP-58 | Issam | FS_BSspec_struc |  |  |  | RP-130580 |
| 2486 | 619 | Study on RAN aspects of Machine Type and other mobile data applications Communications enhancements | 137d? | 2013-03-01 A | 2013-09-06 A | 100% | 2013-03-01 | 2013-09-06 | 137d? | finish no earlier than 2013-09-06 | R2 | 1096h | 1096h | FS_MTCe_RAN | PCG-30 | UTRA, LTE 37.869 | ZTE | sergio.parolari@zteitaly.com | Rel-12 | RP-59 | Yong-Jun | FS_MTCe_RAN | MTC, M2M |  |  | RP-131081 |
| 2487 | 620 | Study on UMTS heterogeneous networks | 331d? | 2012-06-12 A | 2013-09-06 A | 100% | 2012-06-12 | 2013-09-06 | 331d? | finish no earlier than 2013-09-06 | R1; R2; R3 | 7944h | 7944h | FS_UTRA_HetNet | PCG-29 | UTRA 25.800 | Huawei | carmela.cozzo@huawei.com | Rel-12 | RP-57 | Patrick | FS_UTRA_HetNet |  |  |  | RP-131606 |
| 2488 | 621 | Study on Scalable UMTS FDD bandwidth | 265d? | 2012-12-10 A | 2013-12-06 A | 100% | 2012-12-10 | 2013-12-06 | 265d? | finish no earlier than 2013-12-06 | R1; R4 | 4240h | 4240h | FS_UTRA_SCAL | PCG-30 | UTRA TR 25.701 | China Unicom | Han Xiao (hanxiao91@chinaunicom.cn) | Rel-12 | RP-58 | Patrick | FS_UTRA_SCAL |  |  |  | RP-132035 |
| 2489 | 622 | Deleted - Study on Scalable UMTS FDD bandwidth by Filtering | 136d? | 2013-12-09 A | 2014-06-13 A | 100% | 2013-12-09 | 2014-06-13 | 136d? | finish no earlier than 2014-06-13 | R1 | 1088h | 1088h | FS_UTRA_SCAL_FILT | PCG-32 | UTRA TR 25.701 | China Unicom | Han Xiao (hanxiao91@chinaunicom.cn) | Rel-12 | RP-62 | Patrick | FS_UTRA_SCAL_FILT |  | PCG-33 | RP-64 | RP-140988 |
| 2490 | 623 | Study on Dedicated Channel (DCH) enhancements for UMTS | 197d? | 2012-12-10 A | 2013-09-06 A | 100% | 2012-12-10 | 2013-09-06 | 197d? | finish no earlier than 2013-09-06 | R1 | 1576h | 1576h | FS_UTRA_DCHenh | PCG-30 | UTRA TR 25.702 | Qualcomm | Arjun Bharadwaj (arjunb@qti.qualcomm.com) | Rel-12 | RP-58 | Patrick | FS_UTRA_DCHenh |  |  |  | RP-131073 |
| 2491 | 624 | Study on Further Enhanced Uplink (EUL) enhancements | 265d? | 2012-12-10 A | 2013-12-06 A | 100% | 2012-12-10 | 2013-12-06 | 265d? | finish no earlier than 2013-12-06 | R2; R1; R3 | 6360h | 6360h | FS_EDCH_enh | PCG-30 | UTRA TR 25.700 | Ericsson | alessandro.caverni@ericsson.com | Rel-12 | RP-58 | Yong-Jun | FS_EDCH_enh |  |  |  | RP-131608 |
| 2492 | 625 | Study on HNB Emergency Warning Area for UTRA | 191d? | 2013-06-18 A | 2014-03-06 A | 100% | 2013-06-18 | 2014-03-06 | 191d? | finish no earlier than 2014-03-06 | R3 | 1520h | 1520h | FS_HNB_warn_area | PCG-31 | UTRA TR 25.703 | Alcatel-Lucent, Ip.access | Martin.Warner@alcatel-lucent.com, Kit.kilgour@ipaccess.com | Rel-12 | RP-60 | Juha | FS_HNB_warn_area | HNB |  |  | RP-140129 |
| 2493 | 626 | Study on Enhanced Broadcast of System Information | 66d? | 2013-09-09 A | 2013-12-06 A | 100% | 2013-09-09 | 2013-12-06 | 66d? | finish no earlier than 2013-12-06 | R2; R1 | 1056h | 1056h | FS_UTRA_SIBenh | PCG-31 | UTRA TR 25.704 | Ericsson | martin.van.der.zee@ericsson.com | Rel-12 | RP-61 | Yong-Jun | FS_UTRA_SIBenh |  |  |  | RP-131610 |
| 2494 | 627 | Release 11 Features | 342.75d? | 2013-06-02 A | 2014-09-16 A | 100% | 2013-06-02 | 2014-09-17 | 342.75d? | finish no earlier than 2014-09-17 | SP; CP; GP; RP | 10968h | 10968h |  |  |  |  |  | Rel-11 |  | All |  |  |  |  |  |

Notes:
- 2426: Triggered by TR 22.906 SA1 Study on IMS based Peer-to-Peer Content Distribution Services UID_450047
- 2427: SP#53 completed
- 2428: SP#56 completed. TR 23.844v100 for Information and Approval
- 2429: SP#58 completed. TR 33.844 v100 for Information and Approval
- 2430: SP#62 completed. Linked to CT4 TR 23.857 Study on EPC Nodes Restoration (UID_490014)
- 2431: Phase 1: complete study of overload control related to MAP /Diameter signalling, other 3GPP Core Network signalling optimization
- 2432: SP#62 completed
- 2433: SP#56 completed
- 2434: SP#61 completed. Covers generic non-3GPP access (e.g. WLAN, WIMAX, CDMA/HRPD). Spin-off Feature SaMOG_WLAN. Linked to Rel-8 Support for non-3GPP accesses, Rel-10 SMOG, Rel-11 BBAI
- 2435: SP#61 completed. Linked to UID_350027 SAE for support for non-3GPP accesses (SAES-SA-FP_n3GPP), UID_410043 MAPIM, UID_450041 IFOM, UID_530046 SaMOG
- 2436: SP#59 completed. Linked to Rel-11 Feature UID_500032 Service Awareness and Privacy Policies (SAPP)
- 2437: Spin-off Features MAPCON, IFOM. SP#58 completed FS_MAPIM part of 23.861 (continued under FS_NBIFOM)
- 2438: SP#53 completed
- 2439: SP#43 TR 23.861v100 for Information. SP#56 Rel-9 TR 23.861v130 renamed & progressed under new Study FS_NBIFOM. SP#58 completed the FS_MAPIM part of TR 23.861 (TR continued under FS_NBIFOM).
- 2440: SP#59 stopped (at 40% completion). SP#56 revives dormant Study FS_MAPIM. TR 23.861 title changed from (Multi Access PDN connectivity and IP flow mobility) to (Network based IP flow mobility)
- 2441: SP#59 completed. Continuation of Rel-9 Feature UID_430036 IMS Media Plane Security (MEDIASEC). Study solutions and extensions to features and functionality described in TR 33.828 and TS 33.328
- 2442: SP#65 stopped. Linked to Rel-12 Service and Media Reachability for Users over Restrictive Firewalls (SMURFs) UID_530043
- 2443: SP#65 completed. TR 33.831v100 for 1-step Approval. Linked to Rel-11 SPUCI TR 33.838
- 2444: SP#64 completed. Spin-off Rel-13 Feature SCAS. Study methodologies for specifying product security assurance and hardening requirements on 3GPP network elements (with associated test cases when feasible)
- 2445: SP#65 completed. TR 26.938v200 for Approval. SP#60 TR 26.938v100 for Information. Linked to Feature UID_470034 HTTP-based Streaming and Download Services
- 2446: SP#65 completed. TR 26.907v200 for Approval. SP#64 TR 26.907v100 for Information.
- 2447: SP#58 completed
- 2448: SP#64 completed
- 2449: SP#61 completed. Linked to Network Sharing UID_31018, SA1 22.951 (Service aspects and requirements for network sharing), SA2 23.251 (Network Sharing; Architecture)
- 2450: SP#65 completed. TR 32.836v200 for Approval. SP#63 split of Rel-12 SP-130045 WID (Enhanced NM Centralized Coverage and Capacity Optimization) into a Rel-12 Study (SP-140028) and a Rel-13 Normative WID (SP-140060)
- 2451: SP#65 revised WID SP-130042=>SP-140536 (split into Rel-12 Study & Rel-13 normative WI). Changed Title from "TR on WLAN impacts to Type-2 management interface to the 3GPP Network Manager". TR 32.841v200 for Approval. Completed; 14/09/15: WID:SP-140536->
- 2452: SP#61 completed
- 2453: CP#64 completed
- 2454: CP#65 completed. TR 29.809 v200 for Approval. Triggered by SA2 Rel-12 TR 23.843 Study on Core Network Overload solutions (FS_CNO) UID_490036. Coordinate with CT3, SA5
- 2455: CP#64 completed. Investigate introducing an XML-based protocol (e.g. SOAP, Restful HTTP, etc.) between AF and PCRF for non-IMS applications
- 2456: CP#65 completion 09/14=>12/14. CP#64 TR 29.949v100 for Information.Dec.14:95->100
- 2457: CP#65 completion 09/14=>12/14. Gathering of all ISIM-related conformance requirements and the assessment of CT6 coverage; June2015: Compl:30%->100
- 2458: CP#65 TR 29.854v200 for Approval. Completion 09/14=>12/14. Dec.14: 80->85%. Mar.15: 100%
- 2459: GP#56 completed. GP#44 approved WID
- 2460: GP#62 completed. TR 43.801v100 for 1-step Approval. GP#50 approved WID. Triggered by Rel-8 TR 45.914 Study Multi-User-Reusing One Timeslot (MUROS) UID_50590 and Rel-9 VAMOS UID_420002
- 2461: GP#63 completed. TR~43.802v200 for Approval. GP#50 approved WID (mobile coucou). Triggered by RAN#51 (Mar 2011) WID in RP-110454 (LTE RAN Enhancements for Diverse Data Applications) UID_510031
- 2462: RP#61 completed. Linked to Rel-10 WI on Inclusion of RF Pattern Matching Technologies as a positioning method in the UTRAN (LCS_UMTS_RFPMT) UID_460005
- 2463: RP#60 completed
- 2464: RP#64 stopped at 80% completion
- 2465: RP#58 completed. TR 36.932 v100 for Information and Approval
- 2466: RP#62 completed. RP#61 TR 36.872v100 for 1-step approval. Triggered by Rel-12 TR 36.932 Study on Scenarios and Requirements of LTE Small Cell Enhancements for E-UTRA and E-UTRAN UID_570023
- 2467: RP#62 completed. Triggered by Rel-12 TR 36.932 Study on Scenarios and Requirements of LTE Small Cell Enhancements for E-UTRA and E-UTRAN UID_570023
- 2468: RP#63 completed. TR 36.843 for 1-step approval (90% complete). Started normative work. Linked to Rel-12 TR 22.803 Study on Proximity-based Services (FS_ProSe) and Feature ProSe
- 2469: RP#65 completed. Updated WID RP-130811=>RP-141237. TR 36.873v210 for Approval. Enhance performance with 3D-beamforming or with FD-MIMO. Study new channel modelling in both vertical and horizontal dimensions awa user locations in the network
- 2470: RP#64 completed. Identify potential solutions for energy saving in E-UTRAN non-overlapping scenario. Evaluate possible enhancements in overlapping scenario, so that a subset can be used for further investigation/standardization
- 2471: CD:Thu 11/12/14->Mon 15/12/14; Compl:80%->100%; Stat Rep: RP-141453->RP-141815
- 2472: RP#62 completed. Updated WID RP-130393=>RP-131840
- 2473: RP#63 completed. TR 36.866 (90% complete) for Approval. Started normative work
- 2474: RP#62 completed. Extension of Rel-11 CoMP Operation for LTE Downlink UID_530332)
- 2475: RP#63 completed. Evaluate ability of LTE to meet public safety requirements agreed in SA for GC (GC is a key functionality of Land Mobile Radio/Private Mobile Radio and public safety systems)
- 2476: RP#63 completed
- 2477: RP#64 completed. TR 36.856v100 for 1-step approval. Triggered by SA1 Re-12 TR 22.852 Study on RAN Sharing Enhancements (FS_RSE) and Rel-13 Feature RSE (TS 22.101 Stage 1)
- 2478: RP#59 completed
- 2479: RP#60 completed
- 2480: RP#61 completed (Conclusion: no spin-off WI). Linked to Rel-10 WI on Multi-standard radio Base Station RF requirements for non-contiguous spectrum deployments (MSR_NC) UID_480025
- 2481: RP#62 completed. Evaluate LTE-WLAN/UTRA-WLAN i/w procedures while improving (non-)seamless mobility. Deployed WLAN often under-utilized; User experience suboptimal when UE connects to overloaded WLAN.
- 2482: RP#62 completed. TR 37.852v100 for Information & Approval
- 2483: RP#64 completed. The study of SON features for small cell functionality covered by the Rel-12 small cell enhancement SIs (e.g. dual connectivity) is not in the scope of this study item
- 2484: RP#65 completed. Within EU these bands can be used for terrestrial mobile as a complement to mobile satellite services. Study adding an FDD band into UTRA/E-UTRA in applicable countries of Region 1
- 2485: RP#60 completed (1-step approval). Study new BS spec structure to avoid duplicate work for new RF features (in case of identical features among different RATs); avoid future discussions on how to implement new featurES in CP-150single-RAT/multi-RAT specs
- 2486: RP#61 completed
- 2487: RP#62 completed
- 2488: RP#62 completed. TR 25.701v200 for Approval
- 2489: RP#64 stopped at 85% completion. Follow-up of Rel-12 Study on scalable UMTS FDD bandwidth (FS_UTRA_SCAL). The result is captured in the same TR 25.701
- 2490: RP#61 completed
- 2491: RP#62 completed. TR 25.700v100 for Approval. Identify potential solutions to increase the uplink capacity, coverage and end-user performance (e.g. latency, achievable rates, etc.)
- 2492: RP#63 completed. TR 25.703 v100 for 1-step approval
- 2493: RP#62 completed. TR 25.704v100 for Information & Approval. Study need to add capacity to present SI Broadcast mechanism unchanged since R99
- 2494: -

| ID | WBS | Task | Duration | Start | Finish | Complete | Baseline start | Baseline finish | Baseline duration | Constraint | Resources | Work | Actual work | Acronym | PCG approved | WI rapporteur name | WI rapporteur e-mail | Release | TSG approved | MCC resp | Acronym_3GU_Export | Special Focus Doc | PCG stopped | TSG stopped |
| --- | --- | --- | --- | --- | --- | --- | --- | --- | --- | --- | --- | --- | --- | --- | --- | --- | --- | --- | --- | --- | --- | --- | --- | --- |
| 2495 | 628 | **Advanced IP Interconnection of Services** | 650d? | 2010-03-25 A | 2012-09-12 A | 100% | 2010-03-25 | 2012-09-12 | 650d? |  | S1; S2; C1; C3 | 34381.9h | 34381.9h | IPXS | PCG-24 | Telefónica | chris.friel@O2.com | Rel-11 | SP-47 | Alain | IPXS |  |  |  |
| 2496 | 628.1 | Stage 1 for Advanced IP Interconnection of Services | 392d | 2010-03-25 A | 2011-09-21 A | 100% | 2010-03-25 | 2011-09-21 | 392d | finish no earlier than 2011-09-21 | S1 | 3120h | 3120h | IPXS | PCG-24 | Telefónica | chris.friel@O2.com | Rel-11 | SP-47 | Alain |  |  |  |  |
| 2497 | 628.2 | Stage 2 for Advanced IP Interconnection of Services | 263d? | 2010-12-16 A | 2011-12-14 A | 100% | 2010-12-16 | 2011-12-14 | 263d? | finish no earlier than 2012-03-21 | S2 | 2085.91h | 2085.91h | IPXS | PCG-26 | Ericsson | fredrik.lindholm@ericsson.com | Rel-11 | SP-50 | Maurice |  |  |  |  |
| 2498 | 628.3 | **Stage 3 for Advanced IP Interconnection of Services** | 265d? | 2011-09-13 A | 2012-09-12 A | 100% | 2011-09-13 | 2012-09-12 | 265d? |  | C1; C3 | 8376h | 8376h | IPXS | PCG-27 | Ericsson | christer.holmberg@ericsson.com | Rel-11 | CP-53 | Frederic |  |  |  |  |
| 2499 | 628.3.1 | CT1 part of Stage 3 for Advanced IP Interconnection of Services | 262d? | 2011-09-16 A | 2012-09-12 A | 100% | 2011-09-16 | 2012-09-12 | 262d? | finish no earlier than 2012-12-07 | C1 | 2048h | 2048h | IPXS | PCG-27 | Ericsson | christer.holmberg@ericsson.com | Rel-11 | CP-53 | Frederic |  |  |  |  |
| 2500 | 628.3.2 | CT3 part of Stage 3 for Advanced IP Interconnection of Services | 262d? | 2011-09-13 A | 2012-09-07 A | 100% | 2011-09-13 | 2012-09-07 | 262d? | finish no earlier than 2012-09-07 | C3 | 2088h | 2088h | IPXS | PCG-27 | Ericsson | christer.holmberg@ericsson.com | Rel-11 | CP-53 | Adrian |  |  |  |  |
| 2501 | 629 | **System Improvements to Machine-Type Communications** | 1119d? | 2009-12-10 A | 2014-03-06 A | 100% | 2009-12-10 | 2014-03-06 | 1119d? |  | S1; S2; S5; C1; C3; C4; C6; R2; R3; R5 | 198763h | 198763h | SIMTC | PCG-25 | KPN | toon.norp@tno.nl | Rel-11 | SP-48 | Alain | SIMTC | MTC, M2M |  |  |
| 2502 | 629.1 | Stage 1 for SIMTC | 337d? | 2010-06-10 A | 2011-09-21 A | 100% | 2010-06-10 | 2011-09-21 | 337d? |  | S1 | 2683.46h | 2683.46h | SIMTC | PCG-25 | KPN | toon.norp@tno.nl | Rel-11 | SP-48 | Alain |  | MTC, M2M |  |  |
| 2503 | 629.2 | TR on Stage 2 for SIMTC | 593d? | 2010-06-10 A | 2012-09-12 A | 100% | 2010-06-10 | 2012-09-12 | 593d? | finish no earlier than 2012-09-12 | S2 | 4736h | 4736h | SIMTC | PCG-25 | Intel | puneet.jain@intel.com | Rel-11 | SP-48 | Maurice |  | MTC, M2M |  |  |
| 2504 | 629.3 | **BB1: Stage 2 Reachability Aspects of SIMTC** | 274d? | 2011-06-09 A | 2012-06-20 A | 100% | 2011-06-09 | 2012-06-20 | 274d? |  | S2 | 10773.1h | 10773.1h | SIMTC-Reach | PCG-27 | Intel | puneet.jain@intel.com | Rel-11 | SP-52 | Maurice | SIMTC-Reach | MTC, M2M |  |  |
| 2505 | 629.3.1 | Deleted - MTC Feature Control (described in TS 22.368, clause 7.1.1 and 23.888, clause 5.7) | 137d? | 2011-06-10 A | 2011-12-14 A | 100% | 2011-06-10 | 2011-12-14 | 137d? | finish no earlier than 2011-11-09 | S2 | 1088h | 1088h | SIMTC-Reach | PCG-27 | Intel | puneet.jain@intel.com | Rel-11 | SP-52 | Maurice |  | MTC, M2M | PCG-28 | SP-54 |
| 2506 | 629.3.2 | On-line device trigger | 273d? | 2011-06-09 A | 2012-06-20 A | 100% | 2011-06-09 | 2012-06-20 | 273d? | finish no earlier than 2012-06-20 | S2 | 2170.29h | 2170.29h | SIMTC-Reach | PCG-27 | Intel | puneet.jain@intel.com | Rel-11 | SP-52 | Maurice |  | MTC, M2M |  |  |
| 2507 | 629.3.3 | MTC Addressing | 138d? | 2011-06-09 A | 2011-12-14 A | 100% | 2011-06-09 | 2011-12-14 | 138d? | finish no earlier than 2012-03-21 | S2 | 1097.24h | 1097.24h | SIMTC-Reach | PCG-27 | Intel | puneet.jain@intel.com | Rel-11 | SP-52 | Maurice |  | MTC, M2M |  |  |
| 2508 | 629.3.4 | Identifiers – especially removal of MSISDN dependencies in the architecture | 273d? | 2011-06-09 A | 2012-06-20 A | 100% | 2011-06-09 | 2012-06-20 | 273d? | finish no earlier than 2012-06-20 | S2 | 2169.53h | 2169.53h | SIMTC-Reach | PCG-27 | Intel | puneet.jain@intel.com | Rel-11 | SP-52 | Maurice |  | MTC, M2M |  |  |
| 2509 | 629.3.5 | MSISDN-less / PS-Only | 196d? | 2011-06-13 A | 2012-03-07 A | 100% | 2011-06-13 | 2012-03-07 | 196d? | finish no earlier than 2012-03-07 | S2 | 1568h | 1568h | SIMTC-Reach | PCG-27 | Intel | puneet.jain@intel.com | Rel-11 | SP-52 | Maurice |  | MTC, M2M |  |  |
| 2510 | 629.3.6 | MTC related interfaces and functional entities to support above features (MTCsp, etc.) | 61d? | 2011-12-14 A | 2012-03-07 A | 100% | 2011-12-14 | 2012-03-07 | 61d? | finish no earlier than 2012-03-07 | S2 | 488h | 488h | SIMTC-Reach | PCG-28 | Intel | puneet.jain@intel.com | Rel-11 | SP-54 | Maurice |  | MTC, M2M |  |  |
| 2511 | 629.4 | **BB1: Stage 3 (CS+PS) Reachability Aspects of SIMTC** | 325d? | 2011-09-19 A | 2012-12-07 A | 100% | 2011-09-19 | 2012-12-07 | 325d? |  | C1; C3; C4; C6 | 19112h | 19112h | SIMTC-ReachCSPS | PCG-27 | Ericsson | mikael.wass@ericsson.com | Rel-11 | CP-53 | Frederic |  | MTC, M2M |  |  |
| 2512 | 629.4.1 | CT1 part of Stage 3 BB1: Reachability Aspects of SIMTC | 257d? | 2011-09-19 A | 2012-09-07 A | 100% | 2011-09-19 | 2012-09-07 | 257d? | finish no earlier than 2012-09-07 | C1 | 2048h | 2048h | SIMTC-ReachCSPS | PCG-27 | Ericsson | mikael.wass@ericsson.com | Rel-11 | CP-53 | Frederic |  | MTC, M2M |  |  |
| 2513 | 629.4.2 | CT3 part of Stage 3 BB1: Reachability Aspects of SIMTC | 257d? | 2011-09-19 A | 2012-09-07 A | 100% | 2011-09-19 | 2012-09-07 | 257d? | finish no earlier than 2012-09-07 | C3 | 2048h | 2048h | SIMTC-ReachCSPS | PCG-27 | Ericsson | mikael.wass@ericsson.com | Rel-11 | CP-53 | Adrian |  | MTC, M2M |  |  |
| 2514 | 629.4.3 | CT4 part of Stage 3 BB1: Reachability Aspects of SIMTC | 324d? | 2011-09-19 A | 2012-12-07 A | 100% | 2011-09-19 | 2012-12-07 | 324d? | finish no earlier than 2012-12-07 | C4 | 2568h | 2568h | SIMTC-ReachCSPS | PCG-27 | Ericsson | mikael.wass@ericsson.com | Rel-11 | CP-53 | Kimmo |  | MTC, M2M |  |  |
| 2515 | 629.4.4 | CT6 part of Stage 3 BB1: Reachability Aspects of SIMTC | 257d? | 2011-09-19 A | 2012-09-07 A | 100% | 2011-09-19 | 2012-09-07 | 257d? | finish no earlier than 2012-09-07 | C6 | 2048h | 2048h | SIMTC-ReachCSPS | PCG-27 | ST Ericsson | Andrzej Winiarski | Rel-11 | CP-53 | Xavier |  | MTC, M2M |  |  |
| 2516 | 629.5 | **Stage 2/3 for CS aspects for SIMTC** | 259d? | 2011-09-16 A | 2012-09-07 A | 100% | 2011-09-16 | 2012-09-07 | 259d? |  | C4; C1; C6 | 16544h | 16544h | SIMTC-CS | PCG-27 | Ericsson | mikael.wass@ericsson.com | Rel-11 | CP-53 | Kimmo | SIMTC-CS | MTC, M2M |  |  |
| 2517 | 629.5.1 | Deleted - Stage 2 CS aspects for SIMTC | 258d? | 2011-09-16 A | 2012-09-06 A | 100% | 2011-09-16 | 2012-09-06 | 258d? | finish no earlier than 2012-09-07 | C4 | 2056h | 2056h | SIMTC-CS | PCG-27 | Ericsson | mikael.wass@ericsson.com | Rel-11 | CP-53 | Kimmo |  | MTC, M2M | PCG-29 | CP-57 |
| 2518 | 629.5.2 | **Stage 3 CS aspects for SIMTC** | 259d? | 2011-09-16 A | 2012-09-07 A | 100% | 2011-09-16 | 2012-09-07 | 259d? |  | C1; C6 | 8272h | 8272h | SIMTC-CS | PCG-27 | Ericsson | mikael.wass@ericsson.com | Rel-11 | CP-53 | Frederic |  | MTC, M2M |  |  |
| 2519 | 629.5.2.1 | CT1 part of Stage 3 CS aspects for SIMTC | 259d? | 2011-09-16 A | 2012-09-07 A | 100% | 2011-09-16 | 2012-09-07 | 259d? | start no earlier than 2011-09-16 | C1 | 2064h | 2064h | SIMTC-CS | PCG-27 | Ericsson | mikael.wass@ericsson.com | Rel-11 | CP-53 | Frederic |  | MTC, M2M |  |  |
| 2520 | 629.5.2.2 | Deleted - CT6 part of Stage 3 CS aspects for SIMTC | 259d? | 2011-09-16 A | 2012-09-07 A | 100% | 2011-09-16 | 2012-09-07 | 259d? | start no earlier than 2011-09-16 | C6 | 2064h | 2064h | SIMTC-CS | PCG-27 | Ericsson | mikael.wass@ericsson.com | Rel-11 | CP-53 | Xavier |  | MTC, M2M | PCG-29 | CP-57 |

Notes:
- 2495: CP#58 completed. Triggered by Rel-10 TR 22.893 UID_380083 Study on advanced requirements for IP interconnect (FS_IPXS)
- 2496: SP#53 completed / Impacted TSs and TRs: 22.101, 22.228
- 2497: SP#54 completed / Impacted TSs and TRs: 23.228
- 2498: CP#58 completed / Impacted TSs and TRs: Stage 3
- 2499: CP#58 completed / Impacted TSs and TRs: 24.229
- 2500: CP#57 completed / Impacted TSs and TRs: 29.165
- 2501: SP#58 completed. Updated WID SP-110877=>SP-120848. Enhancements to Rel-10 Feature UID_410031 (NIMTC) based on Rel-11 Study on enhancements to MTC
- 2502: SP#53 completed. SP#57 added MTC definitions in 21.905 / Impacted TSs and TRs: 22.368, 21.905 (MTC definitions)
- 2503: SP#57 completed. TR 23.888v200 for Approval. Was Rel-10 UID_450028 (TR on Stage 2 for NIMTC) / Impacted TSs and TRs: New TR 23.888
- 2504: SP#56 completed. SP#58 updated WID SP-110877=>S3-121111 (SA3 normative work on Security aspects of SIMTC incorporated in SA2 TS 23.682) / Impacted TSs and TRs: 23.221, New 23.368
- 2505: SP#54 work stopped
- 2506: SP#56 completed / Impacted TSs and TRs: New 23.682
- 2507: SP#54 completed / Impacted TSs and TRs: 23.221, New 23.682
- 2508: SP#56 completed / Impacted TSs and TRs: New 23.682
- 2509: SP#55 completed / Impacted TSs and TRs: 23.060, 23.272, New 23.682
- 2510: SP#55 completed / Impacted TSs and TRs: New 23.682
- 2511: 22/01: acronym modified / Impacted TSs and TRs: Stage 3
- 2512: 22/01: acronym modified / Impacted TSs and TRs: 23.040, 24.008, 24.301, 24.341, 24.368
- 2513: 22/01: acronym modified / Impacted TSs and TRs: 29.061, New TS 29.368
- 2514: 22/01: acronym modified / Impacted TSs and TRs: 23.003, 23.008, 29.002, 29.060, 29.230, New TS (29.336, 29.337)
- 2515: 22/01: acronym modified / Impacted TSs and TRs: 31.102
- 2516: CP#57 completed. Updated WID CP-120418=>CP-120617 / Impacted TSs and TRs: Stage 2/3
- 2517: CP#57 stopped / Impacted TSs and TRs: 23.012
- 2518: CP#57 completed / Impacted TSs and TRs: Stage 3
- 2519: CP#57 completed / Impacted TSs and TRs: 24.008, 24.301
- 2520: CP#57 stopped / Impacted TSs and TRs: 31.102

| ID | WBS | Task | Duration | Start | Finish | Complete | Baseline start | Baseline finish | Baseline duration | Constraint | Resources | Work | Actual work | Acronym | PCG approved | WI rapporteur name | WI rapporteur e-mail | Release | TSG approved | MCC resp | Special Focus Doc | Acronym_3GU_Export | Status Report | PCG stopped | TSG stopped |
| --- | --- | --- | --- | --- | --- | --- | --- | --- | --- | --- | --- | --- | --- | --- | --- | --- | --- | --- | --- | --- | --- | --- | --- | --- | --- |
| 2521 | 629.6 | **Stage 2/3 for SMS in MME architecture option and related PS-only service subscription** | 129d? | 2012-06-15 A | 2012-12-07 A | 100% | 2012-06-15 | 2012-12-07 | 129d? |  | C1; C4 | 3560h | 3560h | SIMTC-PS_Only | PCG-29 | Ericsson | mikael.wass@ericsson.com | Rel-11 | CP-56 | Frederic | MTC, M2M | SIMTC-PS_Only |  |  |  |
| 2522 | 629.6.1 | CT1 part of Stage 2/3 for SMS in MME architecture option and related PS-only service subscription | 62d? | 2012-06-15 A | 2012-09-07 A | 100% | 2012-06-15 | 2012-09-07 | 62d? | finish no earlier than 2012-09-07 | C1 | 488h | 488h | SIMTC-PS_Only | PCG-29 | Ericsson | mikael.wass@ericsson.com | Rel-11 | CP-56 | Frederic | MTC, M2M |  |  |  |  |
| 2523 | 629.6.2 | CT4 part of Stage 2/3 for SMS in MME architecture option and related PS-only service subscription | 129d? | 2012-06-15 A | 2012-12-07 A | 100% | 2012-06-15 | 2012-12-07 | 129d? | finish no earlier than 2012-12-07 | C4 | 1008h | 1008h | SIMTC-PS_Only | PCG-29 | Ericsson | mikael.wass@ericsson.com | Rel-11 | CP-56 | Kimmo | MTC, M2M |  |  |  |  |
| 2524 | 629.7 | **RAN overload control for Machine-Type Communications** | 259d? | 2011-09-16 A | 2012-09-07 A | 100% | 2011-09-16 | 2012-09-07 | 259d? |  | R2; R3; C1; C6 | 20178.3h | 20178.3h | SIMTC-RAN_OC | PCG-27 | Huawei | Jeff Gao (gaoyongqiang@huawei.com) | Rel-11 | RP-53 | Yong-Jun | MTC, M2M | SIMTC-RAN_OC |  |  |  |
| 2525 | 629.7.1 | Core part: RAN overload control for Machine-Type Communications | 258d? | 2011-09-19 A | 2012-09-07 A | 100% | 2011-09-19 | 2012-09-07 | 258d? | finish no earlier than 2012-09-07 | R2; R3 | 4128h | 4128h | SIMTC-RAN_OC-Core | PCG-27 | Huawei | Jeff Gao (gaoyongqiang@huawei.com) | Rel-11 | RP-53 | Yong-Jun | MTC, M2M | SIMTC-RAN_OC-Core |  |  |  |
| 2526 | 629.7.2 | **Stage 3 (CS+PS) Extended Access Barring for UTRAN and E-UTRAN** | 259d? | 2011-09-16 A | 2012-09-07 A | 100% | 2011-09-16 | 2012-09-07 | 259d? |  | C1; C6 | 7762.29h | 7762.29h | SIMTC-RAN_OC | PCG-27 | Ericsson | mikael.wass@ericsson.com | Rel-11 | CP-53 | Frederic | MTC, M2M |  |  |  |  |
| 2527 | 629.7.2.1 | CT1 part of Stage 3 Extended Access Barring for UTRAN and E-UTRAN | 198d? | 2011-09-16 A | 2012-06-15 A | 100% | 2011-09-16 | 2012-06-15 | 198d? | finish no earlier than 2012-09-14 | C1 | 1570.29h | 1570.29h | SIMTC-RAN_OC | PCG-27 | Ericsson | mikael.wass@ericsson.com | Rel-11 | CP-53 | Frederic | MTC, M2M |  |  |  |  |
| 2528 | 629.7.2.2 | CT6 part of Stage 3 Extended Access Barring for UTRAN and E-UTRAN | 257d? | 2011-09-20 A | 2012-09-07 A | 100% | 2011-09-20 | 2012-09-07 | 257d? | finish no earlier than 2012-09-07 | C6 | 2048h | 2048h | SIMTC-RAN_OC | PCG-27 | ST Ericsson | Andrzej Winiarski | Rel-11 | CP-53 | Xavier | MTC, M2M |  |  |  |  |
| 2529 | 629.8 | Test part: System Improvements for Machine-Type Communications | 130d? | 2013-09-09 A | 2014-03-06 A | 100% | 2013-09-09 | 2014-03-06 | 130d? | finish no earlier than 2014-03-06 | R5 | 1040h | 1040h | SIMTC-UEConTest | PCG-31 | Ericsson | calle.hagenfeldt@ericsson.com | Rel-11 | RP-61 | Ingbert | MTC, M2M | SIMTC-UEConTest | RP-140075 |  |  |
| 2530 | 629.9 | BB5: Charging of SIMTC (Stage 2/3) | 269d? | 2011-12-07 A | 2012-12-12 A | 100% | 2011-12-07 | 2012-12-12 | 269d? | finish no earlier than 2012-12-12 | S5 | 2144h | 2144h | SIMTC-CH | PCG-28 | Ericsson | patrik.teppo@ericsson.com | Rel-11 | SP-54 | Mirko | MTC, M2M | SIMTC-CH |  |  |  |
| 2531 | 629.10 | **Deleted - BB2: Stage 2 Signalling Optimizations of SIMTC** | 137d? | 2011-06-10 A | 2011-12-14 A | 100% | 2011-06-10 | 2011-12-14 | 137d? |  | S2 | 5240h | 5240h | SIMTC-Sig | PCG-27 | Intel | puneet.jain@intel.com | Rel-11 | SP-52 | Maurice | MTC, M2M | SIMTC-Sig |  | PCG-28 | SP-55 |
| 2532 | 629.10.1 | Deleted - Effectively maintain connectivity for a large number of MTC Devices (TS 22.368, 7.1.1) | 137d? | 2011-06-10 A | 2011-12-14 A | 100% | 2011-06-10 | 2011-12-14 | 137d? | finish no earlier than 2011-12-07 | S2 | 1088h | 1088h | SIMTC-Sig | PCG-27 | Intel | puneet.jain@intel.com | Rel-11 | SP-52 | Maurice | MTC, M2M |  |  | PCG-28 | SP-55 |
| 2533 | 629.10.2 | Deleted - Small Data Transmissions (TS 22.368, 7.2.5) | 137d? | 2011-06-10 A | 2011-12-14 A | 100% | 2011-06-10 | 2011-12-14 | 137d? | finish no earlier than 2011-12-07 | S2 | 1088h | 1088h | SIMTC-Sig | PCG-27 | Intel | puneet.jain@intel.com | Rel-11 | SP-52 | Maurice | MTC, M2M |  |  | PCG-28 | SP-55 |
| 2534 | 629.10.3 | **Deleted - Stage 3 (CS+PS) Signalling Optimizations of SIMTC** | 62d? | 2011-09-16 A | 2011-12-09 A | 100% | 2011-09-16 | 2011-12-09 | 62d? |  | C1; C6 | 1968h | 1968h | SIMTC-Sig | PCG-27 | Ericsson | mikael.wass@ericsson.com | Rel-11 | CP-53 | Frederic | MTC, M2M |  |  | PCG-28 | CP-55 |
| 2535 | 629.10.3.1 | Deleted - CT1 part of Stage 3 Signalling Optimizations of SIMTC | 62d? | 2011-09-16 A | 2011-12-09 A | 100% | 2011-09-16 | 2011-12-09 | 62d? | finish no earlier than 2011-12-02 | C1 | 488h | 488h | SIMTC-Sig | PCG-27 | Ericsson | mikael.wass@ericsson.com | Rel-11 | CP-53 | Frederic | MTC, M2M |  |  | PCG-28 | CP-55 |
| 2536 | 629.10.3.2 | Deleted - CT6 part of Stage 3 Signalling Optimizations of SIMTC | 62d? | 2011-09-16 A | 2011-12-09 A | 100% | 2011-09-16 | 2011-12-09 | 62d? | finish no earlier than 2011-12-02 | C6 | 488h | 488h | SIMTC-Sig | PCG-27 | ST Ericsson | Andrzej Winiarski | Rel-11 | CP-53 | Xavier | MTC, M2M |  |  | PCG-28 | CP-55 |
| 2537 | 629.11 | **Deleted - BB3: Stage 2 CN-based requirements and Power Considerations of SIMTC** | 139d? | 2011-06-08 A | 2011-12-14 A | 100% | 2011-06-08 | 2011-12-14 | 139d? |  | S2 | 6360h | 6360h | SIMTC-CN_Pow | PCG-27 | Intel | puneet.jain@intel.com | Rel-11 | SP-52 | Maurice | MTC, M2M | SIMTC-CN_Pow |  | PCG-28 | SP-55 |
| 2538 | 629.11.1 | Deleted - Charging Requirements (TS 22.368, 7.1.5) | 137d? | 2011-06-10 A | 2011-12-14 A | 100% | 2011-06-10 | 2011-12-14 | 137d? | finish no earlier than 2012-03-21 | S2 | 1088h | 1088h | SIMTC-CN_Pow | PCG-27 | Intel | puneet.jain@intel.com | Rel-11 | SP-52 | Maurice | MTC, M2M |  |  | PCG-28 | SP-55 |
| 2539 | 629.11.2 | Deleted - Lower Power Consumption (TS 22.368, 7.1.1) | 137d? | 2011-06-10 A | 2011-12-14 A | 100% | 2011-06-10 | 2011-12-14 | 137d? | finish no earlier than 2011-12-07 | S2 | 1088h | 1088h | SIMTC-CN_Pow | PCG-27 | Intel | puneet.jain@intel.com | Rel-11 | SP-52 | Maurice | MTC, M2M |  |  | PCG-28 | SP-55 |
| 2540 | 629.11.3 | Deleted - MTC Monitoring (TS 22.368, 7.2.8) | 139d? | 2011-06-08 A | 2011-12-14 A | 100% | 2011-06-08 | 2011-12-14 | 139d? | finish no earlier than 2011-12-07 | S2 | 1104h | 1104h | SIMTC-CN_Pow | PCG-27 | Intel | puneet.jain@intel.com | Rel-11 | SP-52 | Maurice | MTC, M2M |  |  | PCG-28 | SP-55 |
| 2541 | 629.11.4 | **Deleted - Stage 3 (CS+PS) CN-based requirements and Power Considerations of SIMTC** | 62d? | 2011-09-16 A | 2011-12-09 A | 100% | 2011-09-16 | 2011-12-09 | 62d? |  | C1; C6 | 1968h | 1968h | SIMTC-CN_Pow | PCG-27 | Ericsson | mikael.wass@ericsson.com | Rel-11 | CP-53 | Frederic | MTC, M2M |  |  | PCG-28 | CP-55 |
| 2542 | 629.11.4.1 | Deleted - CT1 part of Stage 3 CN-based requirements and Power Considerations of SIMTC | 62d? | 2011-09-16 A | 2011-12-09 A | 100% | 2011-09-16 | 2011-12-09 | 62d? | finish no earlier than 2011-12-02 | C1 | 488h | 488h | SIMTC-CN_Pow | PCG-27 | Ericsson | mikael.wass@ericsson.com | Rel-11 | CP-53 | Frederic | MTC, M2M |  |  | PCG-28 | CP-55 |
| 2543 | 629.11.4.2 | Deleted - CT6 part of Stage 3 CN-based requirements and Power Considerations of SIMTC | 62d? | 2011-09-16 A | 2011-12-09 A | 100% | 2011-09-16 | 2011-12-09 | 62d? | finish no earlier than 2011-12-02 | C6 | 488h | 488h | SIMTC-CN_Pow | PCG-27 | ST Ericsson | Andrzej Winiarski | Rel-11 | CP-53 | Xavier | MTC, M2M |  |  | PCG-28 | CP-55 |
| 2544 | 629.12 | Deleted - TR on Security aspects of Machine-Type Communications | 662d? | 2009-12-10 A | 2012-06-20 A | 100% | 2009-12-10 | 2012-06-20 | 662d? | finish no earlier than 2012-06-20 | S3 | 5288h | 5288h |  | PCG-25 | Samsung | Rajavelsamy R (rajvel@samsung.com) | Rel-11 | SP-49 | Mirko | MTC, M2M |  |  | PCG-29 | SP-56 |

Notes:
- 2521: CP#58 completed / Impacted TSs and TRs: Stage 2/3
- 2522: CP#57 completed / Impacted TSs and TRs: 23.040, 24.008, 24.011, 24.301, 29.018, 29.118
- 2523: CP#58 completed. TS 29.338 v200 for Approval / Impacted TSs and TRs: 23.003, 23.008, 23.012, 29.002, 29.272, 29.305, New TS 29.338
- 2524: Stage 2,3. TSG#57 completed / Impacted TSs and TRs: UTRA, LTE
- 2525: RP#57 completed / Impacted TSs and TRs: 25.304, 25.331, 25.413, 36.304, 36.331, 36.413
- 2526: CP#57 completed. Updated WID CP-120418=>CP-120617 / Impacted TSs and TRs: Stage 3
- 2527: CP#56 completed / Impacted TSs and TRs: 23.122, 24.008, 24.301
- 2528: CP#57 completed / Impacted TSs and TRs: 31.102
- 2529: RP#63 completed. Updated WID RP-131341=>RP-140077 (added affected TS 36.508). Testing for core part: SIMTC-Reach, SIMTC-CS, SIMTC-PS_Only, SIMTC-RAN_OC / Impacted TSs and TRs: 34.123-1, 34.123-2, 34.123-3, 36.508, 36.523-1, 36.523-2, 36.523-3
- 2530: SP#58 completed / Impacted TSs and TRs: 32.240, 32.251, 32.298, 32.299
- 2531: SP#54 work stopped. SP#58 updated WID SP-110877=>SP-120848 / Impacted TSs and TRs: TBD
- 2532: SP#54 work stopped / Impacted TSs and TRs: TBD
- 2533: SP#54 work stopped / Impacted TSs and TRs: TBD
- 2534: CP#54 work stopped / Impacted TSs and TRs: Stage 3
- 2535: - / Impacted TSs and TRs: 23.122, 24.008, 24.301, 24.368
- 2536: - / Impacted TSs and TRs: 31.102
- 2537: SP#54 work stopped / Impacted TSs and TRs: TBD
- 2538: SP#54 work stopped / Impacted TSs and TRs: TBD
- 2539: SP#54 work stopped / Impacted TSs and TRs: TBD
- 2540: SP#54 work stopped / Impacted TSs and TRs: TBD
- 2541: CP#54 work stopped / Impacted TSs and TRs: Stage 3
- 2542: - / Impacted TSs and TRs: 23.122, 24.008, 24.301, 24.368
- 2543: - / Impacted TSs and TRs: 31.101, 31.102
- 2544: Was Rel-10 UID_460023 (Security for NIMTC). SP#56 stopped (activity transferred to Rel-12 Feature MTCe under UID_560722). / Impacted TSs and TRs: New TR 33.868

| ID | WBS | Task | Type | Duration | Start | Finish | Complete | Baseline start | Baseline finish | Baseline duration | Constraint | Resources | Work | Actual work | Acronym | PCG approved | Impacted TSs and TRs | WI rapporteur name | Release | TSG approved | MCC resp | PCG stopped | TSG stopped | Special Focus Doc | Acronym_3GU_Export |
| --- | --- | --- | --- | --- | --- | --- | --- | --- | --- | --- | --- | --- | --- | --- | --- | --- | --- | --- | --- | --- | --- | --- | --- | --- | --- |
| 2545 | 629.13 | **Deleted - BB4: Secure Connection and Privacy of SIMTC** |  | 336d? | 2011-06-08 A | 2012-09-12 A | 100% | 2011-06-08 | 2012-09-12 | 336d? |  | S3 | 7424h | 7424h | SIMTC-Sec | PCG-27 | TBD | Samsung | Rel-11 | SP-52 | Mirko | PCG-29 | CP-57 | MTC, M2M | SIMTC-Sec |
| 2546 | 629.13.1 | Deleted - Secure Connection MTC Feature (TS 22.368, 7.2.10) |  | 333d? | 2011-06-08 A | 2012-09-12 A | 100% | 2011-06-08 | 2012-09-12 | 333d? | finish no earlier than 2012-09-12 | S3 | 2656h | 2656h | SIMTC-Sec | PCG-27 | TBD | Samsung | Rel-11 | SP-52 | Mirko | PCG-29 | CP-57 | MTC, M2M |  |
| 2547 | 629.13.2 | Deleted - MTC Location Privacy |  | 261d? | 2011-09-19 A | 2012-09-12 A | 100% | 2011-09-19 | 2012-09-12 | 261d? | finish no earlier than 2012-09-12 | S3 | 2080h | 2080h | SIMTC-Priv | PCG-27 | TBD | Samsung | Rel-11 | SP-53 | Mirko | PCG-29 | CP-57 | MTC, M2M | SIMTC-Priv |
| 2548 | 629.14 | Deleted - Stage 2 on SA2 part for System Improvements to Machine-Type Communications |  | 260d? | 2010-06-10 A | 2011-06-08 A | 100% | 2010-06-10 | 2011-06-08 | 260d? | finish no earlier than 2011-06-08 | S2 | 2080h | 2080h | SIMTC | PCG-25 | TBD | Intel | Rel-11 | SP-48 | Maurice | PCG-27 | SP-52 | MTC, M2M |  |
| 2549 | 629.15 | Deleted - Stage 2 on Security part for System Improvements to Machine-Type Communications |  | 260d? | 2010-06-10 A | 2011-06-08 A | 100% | 2010-06-10 | 2011-06-08 | 260d? | finish no earlier than 2011-06-08 | S3 | 2080h | 2080h | SIMTC | PCG-25 | TBD | Samsung | Rel-11 | SP-48 | Mirko | PCG-27 | SP-52 | MTC, M2M |  |
| 2550 | 630 | **Unstructured Supplementary Service Data (USSD) simulation service in IMS** |  | 659d? | 2010-06-10 A | 2012-12-07 A | 100% | 2010-06-10 | 2012-12-07 | 659d? |  | S1; C1; C3 | 28112.1h | 28112.1h | USSI | PCG-25 |  | Deutsche Telekom | Rel-11 | SP-48 | Alain |  |  |  | USSI |
| 2551 | 630.1 | Stage 1 for USSD simulation service in IMS | milestone | 0d? | 2010-06-10 A | 2010-06-10 A | 100% | 2010-06-10 | 2010-06-10 | 0d? | finish no earlier than 2010-06-10 | S1 |  |  | USSI | PCG-25 | 22.173 | Deutsche Telekom | Rel-11 | SP-48 | Alain |  |  |  |  |
| 2552 | 630.2 | **Stage 3 for USSD simulation service in IMS** |  | 403d? | 2011-06-03 A | 2012-12-07 A | 100% | 2011-06-03 | 2012-12-07 | 403d? |  | C1; C3 | 12296.1h | 12296.1h | USSI | PCG-27 |  | Deutsche Telekom | Rel-11 | CP-52 | Frederic |  |  |  |  |
| 2553 | 630.2.1 | CT1 part of Stage 3 for USSD simulation service in IMS |  | 402d? | 2011-06-03 A | 2012-12-07 A | 100% | 2011-06-03 | 2012-12-07 | 402d? | finish no earlier than 2012-12-07 | C1 | 3184.06h | 3184.06h | USSI | PCG-27 | 24.173, 24.229, new TS 24.390 | Deutsche Telekom | Rel-11 | CP-52 | Frederic |  |  |  |  |
| 2554 | 630.2.2 | CT3 part of Stage 3 for USSD simulation service in IMS |  | 334d? | 2011-06-07 A | 2012-09-07 A | 100% | 2011-06-07 | 2012-09-07 | 334d? | finish no earlier than 2012-09-07 | C3 | 2664h | 2664h | USSI | PCG-27 | 29.165 | Deutsche Telekom | Rel-11 | CP-52 | Adrian |  |  |  |  |
| 2555 | 631 | **QoS Control Based on Subscriber Spending Limits** |  | 459d? | 2010-09-23 A | 2012-06-20 A | 100% | 2010-09-23 | 2012-06-20 | 459d? |  | S1; S2; S5; C3 | 23152h | 23152h | QoS_SSL | PCG-25 |  | Vodafone | Rel-11 | SP-49 | Alain |  |  |  | QoS_SSL |
| 2556 | 631.1 | Stage 1 for QoS Control Based on Subscriber Spending Limits |  | 262d? | 2010-09-23 A | 2011-09-21 A | 100% | 2010-09-23 | 2011-09-21 | 262d? | finish no earlier than 2011-09-21 | S1 | 2080h | 2080h | QoS_SSL | PCG-25 | 22.115 | Vodafone | Rel-11 | SP-49 | Alain |  |  |  |  |
| 2557 | 631.2 | Stage 2 for QoS Control Based on Subscriber Spending Limits |  | 133d? | 2011-03-23 A | 2011-09-21 A | 100% | 2011-03-23 | 2011-09-21 | 133d? | finish no earlier than 2011-12-14 | S2 | 1048h | 1048h | QoS_SSL | PCG-26 | 23.203 | Huawei | Rel-11 | SP-51 | Maurice |  |  |  |  |
| 2558 | 631.3 | Charging for QoS Control Based on Subscriber Spending Limits (Stage 2) |  | 397d? | 2010-12-16 A | 2012-06-20 A | 100% | 2010-12-16 | 2012-06-20 | 397d? | finish no earlier than 2012-06-20 | S5 | 3168h | 3168h | QoS_SSL | PCG-26 | 32.240, 32.296 | Nokia Siemens Networks, Huawei | Rel-11 | SP-50 | Mirko |  |  |  |  |
| 2559 | 631.4 | CT3 aspects of QoS Control Based on Subscriber Spending Limits (Stage 3) |  | 273d? | 2011-06-03 A | 2012-06-15 A | 100% | 2011-06-03 | 2012-06-15 | 273d? | finish no earlier than 2012-06-15 | C3 | 2168h | 2168h | QoS_SSL-CT3 | PCG-27 | 29.212, 29.213, 29.214, 29.215, new TS 29.219 | Huawei | Rel-11 | CP-52 | Adrian |  |  |  | QoS_SSL-CT3 |
| 2560 | 632 | **Optimized Service Charging and Allocation of Resources in IMS whilst Roaming** |  | 383d? | 2010-09-23 A | 2012-03-07 A | 100% | 2010-09-23 | 2012-03-07 | 383d? |  | S1; S2 | 14288h | 14288h | OSCAR | PCG-25 |  | Vodafone | Rel-11 | SP-49 | Alain |  |  |  | OSCAR |
| 2561 | 632.1 | TR on Stage 2 aspects of Optimized Service Charging and Allocation of Resources in IMS whilst Roaming |  | 383d? | 2010-09-23 A | 2012-03-07 A | 100% | 2010-09-23 | 2012-03-07 | 383d? | finish no earlier than 2011-12-07 | S2 | 3040h | 3040h | OSCAR | PCG-25 | new TR 23.849 | Vodafone | Rel-11 | SP-49 | Maurice |  |  |  |  |
| 2562 | 632.2 | Stage 1 for Optimized Service Charging and Allocation of Resources in IMS whilst Roaming |  | 262d? | 2010-09-23 A | 2011-09-21 A | 100% | 2010-09-23 | 2011-09-21 | 262d? | finish no earlier than 2011-09-21 | S1 | 2080h | 2080h | OSCAR | PCG-25 | 22.115, 22.173, 22.228 | Vodafone | Rel-11 | SP-49 | Alain |  |  |  |  |
| 2563 | 632.3 | Deleted - Stage 2 for Optimized Service Charging and Allocation of Resources in IMS whilst Roaming |  | 380d? | 2010-09-28 A | 2012-03-07 A | 100% | 2010-09-28 | 2012-03-07 | 380d? | finish no earlier than 2012-03-07 | S2 | 3040h | 3040h | OSCAR | PCG-25 | None | Vodafone | Rel-11 | SP-49 | Maurice | PCG-28 | SP-55 |  |  |
| 2564 | 633 | **Inclusion of Media Resource Broker (Stage 2/3)** |  | 463d? | 2011-09-16 A | 2013-06-14 A | 100% | 2011-09-16 | 2013-06-14 | 463d? |  | C1; C3; IETF | 30500h | 30500h | MRB | PCG-27 | Stage 2/3 | AT&T | Rel-11 | CP-53 | Frederic |  |  |  | MRB |
| 2565 | 633.1 | Stage 2 for Inclusion of Media Resource Broker |  | 259d? | 2011-09-16 A | 2012-09-07 A | 100% | 2011-09-16 | 2012-09-07 | 259d? | finish no earlier than 2012-09-07 | C1 | 2049.98h | 2049.98h | MRB | PCG-27 | 23.218 | AT&T | Rel-11 | CP-53 | Frederic |  |  |  |  |
| 2566 | 633.2 | **Stage 3 for Inclusion of Media Resource Broker** |  | 463d? | 2011-09-16 A | 2013-06-14 A | 100% | 2011-09-16 | 2013-06-14 | 463d? |  | C1; C3; IETF | 17338h | 17338h | MRB | PCG-27 |  | AT&T | Rel-11 | CP-53 | Frederic |  |  |  |  |
| 2567 | 633.2.1 | CT1 part of Stage 3 for Inclusion of Media Resource Broker |  | 258d? | 2011-09-16 A | 2012-09-07 A | 100% | 2011-09-16 | 2012-09-07 | 258d? | finish no earlier than 2012-09-07 | C1 | 2049.98h | 2049.98h | MRB | PCG-27 | 24.229, 29.165 | AT&T | Rel-11 | CP-53 | Frederic |  |  |  |  |
| 2568 | 633.2.2 | (IETF) Inclusion of Media Resource Broker [RFC 6917 (was draft-ietf-mediactrl-mrb)] |  | 462d? | 2011-09-16 A | 2013-06-14 A | 100% | 2011-09-16 | 2013-06-14 | 462d? | finish no earlier than 2013-06-14 | C1-IETF | 3688h | 3688h | MRB | PCG-27 | RFC 6917 (was draft-ietf-mediactrl-mrb) | Keith Drage | Rel-11 | CP-53 | Frederic |  |  |  |  |
| 2569 | 633.2.3 | CT3 part of Stage 3 for Inclusion of Media Resource Broker |  | 62d? | 2012-06-15 A | 2012-09-07 A | 100% | 2012-06-15 | 2012-09-07 | 62d? | finish no earlier than 2012-09-07 | C3 | 488h | 488h | MRB | PCG-29 | 29.165 | AT&T | Rel-11 | CP-56 | Adrian |  |  |  |  |

Notes:
- 2545: SP#57 stopped (activity transferred to Rel-12 Feature MTCe under UID_560522) / WI rapporteur e-mail: Rajavelsamy R (rajvel@samsung.com)
- 2546: SP#57 stopped (activity transferred to Rel-12 Feature MTCe / WI rapporteur e-mail: Rajavelsamy R (rajvel@samsung.com)
- 2547: SP#57 stopped (activity transferred to Rel-12 Feature MTCe / WI rapporteur e-mail: Rajavelsamy R (rajvel@samsung.com)
- 2548: SP#52 stopped / WI rapporteur e-mail: puneet.jain@intel.com
- 2549: SP#52 stopped / WI rapporteur e-mail: Rajavelsamy R (rajvel@samsung.com)
- 2550: CP#58 completed / WI rapporteur e-mail: kurt.bischinger@t-mobile.at
- 2551: SP#48 completed. Specify a CS domain USSD like service over IMS (see GSM Mobile User Initiated USSD) / WI rapporteur e-mail: kurt.bischinger@t-mobile.at
- 2552: SP#58 completed. No stage 2 impact, as reuse existing IMS architecture in TS 23.228 / WI rapporteur e-mail: reinhard.lauster@t-mobile.at
- 2553: CP#58 completed / WI rapporteur e-mail: reinhard.lauster@t-mobile.at, TS 24.390 Rapp: lili.yang@huawei.com
- 2554: CP#57 completed / WI rapporteur e-mail: reinhard.lauster@t-mobile.at
- 2555: TSG#56 completed / WI rapporteur e-mail: mona.mustapha@vodafone.com
- 2556: SP#53 completed. Use cases & service requirements to allow: 1) modification of QoS based on subscribers spending limits 2) enforcing of spending limits for roaming subscribers without having dedicated support in the visited network / WI rapporteur e-mail: mona.mustapha@vodafone.com
- 2557: SP#53 completed / WI rapporteur e-mail: Xu Xia (xiatony@huawei.com)
- 2558: SP#56 completed / WI rapporteur e-mail: Gerald.Goermer@nsn.com, shan.mingjun@huawei.com
- 2559: CP#56 completed / WI rapporteur e-mail: QiaoWeihua@huawei.com
- 2560: SP#55 completed (Stage 2/3 specified under CT1 Rel-11 Feature MRB (Inclusion of Media Resource Broker) UID_530021. Triggered by S1-102236/GSMA RILTE 10_007r1 (IREG LS_038 to 3GPP on Optimal Media Routing drawbacks) / WI rapporteur e-mail: mona.mustapha@vodafone.com
- 2561: SP#55 completed / WI rapporteur e-mail: Susana.Sabater@vodafone.com
- 2562: SP#53 completed / WI rapporteur e-mail: mona.mustapha@vodafone.com
- 2563: SP#55 no normative work in SA2. Stage 2/3 to be done in under CT1 Rel-11 Feature MRB (Inclusion of Media Resource Broker) UID_530021 / WI rapporteur e-mail: Susana.Sabater@vodafone.com
- 2564: Stage 1 and TR on Stage 2 in Rel-11 Feature OSCAR UID_490032 / WI rapporteur e-mail: Martin Dolly (md3135@att.com)
- 2565: CP#57 completed / WI rapporteur e-mail: Martin Dolly (md3135@att.com)
- 2566: CP#60 completed / WI rapporteur e-mail: Martin Dolly (md3135@att.com)
- 2567: CP#57 completed / WI rapporteur e-mail: Martin Dolly (md3135@att.com)
- 2568: CP#60 completed
- 2569: CP#57 completed / WI rapporteur e-mail: Martin Dolly (md3135@att.com)

| ID | WBS | Task | Duration | Start | Finish | Complete | Baseline start | Baseline finish | Baseline duration | Constraint | Resources | Work | Actual work | Acronym | PCG approved | WI rapporteur name | WI rapporteur e-mail | Release | TSG approved | MCC resp | Acronym_3GU_Export | Special Focus Doc | PCG stopped | TSG stopped |
| --- | --- | --- | --- | --- | --- | --- | --- | --- | --- | --- | --- | --- | --- | --- | --- | --- | --- | --- | --- | --- | --- | --- | --- | --- |
| 2570 | 634 | **Non Voice Emergency Services** | 323d? | 2010-12-16 A | 2012-03-07 A | 100% | 2010-12-16 | 2012-03-07 | 323d? |  | S1; S2 | 7736h | 7736h | NOVES | PCG-26 | Qualcomm | dwilliams@qualcomm.com | Rel-11 | SP-50 | Alain | NOVES |  |  |  |
| 2571 | 634.1 | Stage 1 for Non Voice Emergency Services | 202d? | 2010-12-16 A | 2011-09-21 A | 100% | 2010-12-16 | 2011-09-21 | 202d? | finish no earlier than 2011-09-21 | S1 | 1600h | 1600h | NOVES | PCG-26 | Qualcomm | dwilliams@qualcomm.com | Rel-11 | SP-50 | Alain |  |  |  |  |
| 2572 | 634.2 | Stage 2 for Non Voice Emergency Services (Support of IMS Emergency Sessions with Other Media on UTRAN and E-UTRAN) | 121d? | 2011-09-22 A | 2012-03-07 A | 100% | 2011-09-22 | 2012-03-07 | 121d? | finish no earlier than 2012-03-07 | S2 | 968h | 968h | NOVES-IMSESOM | PCG-27 | Alcatel-Lucent | Deb.Barclay@alcatel-lucent.com | Rel-11 | SP-53 | Maurice | NOVES-IMSESOM |  |  |  |
| 2573 | 635 | **Support for 3GPP Voice Interworking with Enterprise IP-PBX** | 516d? | 2011-03-23 A | 2013-03-01 A | 100% | 2011-03-23 | 2013-03-01 | 516d? |  | S1; C1 | 12376h | 12376h | VINE | PCG-26 | Tatara Systems | Phillip Brown (pbrown@tatarasystems.com) | Rel-11 | SP-51 | Alain | VINE |  |  |  |
| 2574 | 635.1 | Stage 1 for Support for 3GPP Voice Interworking with Enterprise IP-PBX | 133d? | 2011-03-23 A | 2011-09-21 A | 100% | 2011-03-23 | 2011-09-21 | 133d? | finish no earlier than 2011-09-21 | S1 | 1048h | 1048h | VINE | PCG-26 | Tatara Systems | Phillip Brown (pbrown@tatarasystems.com) | Rel-11 | SP-51 | Alain |  |  |  |  |
| 2575 | 635.2 | Stage 2/3 for Support for 3GPP Voice Interworking with Enterprise IP-PBX | 385d? | 2011-09-20 A | 2013-03-01 A | 100% | 2011-09-20 | 2013-03-01 | 385d? | finish no earlier than 2013-03-01 | C1 | 3072h | 3072h | VINE-CT1 | PCG-27 | Alcatel-Lucent | keith.drage@alcatel-lucent.com | Rel-11 | CP-53 | Frederic | VINE-CT1 |  |  |  |
| 2576 | 636 | **Anonymous Call Rejection in the CS domain** | 132d? | 2011-06-07 A | 2011-12-02 A | 100% | 2011-06-07 | 2011-12-02 | 132d? |  | S1; C4; C3 | 4616h | 4616h | ACR_CS | PCG-27 | Alcatel-Lucent | Betsy.Covell@alcatel-lucent.com | Rel-11 | SP-52 | Alain | ACR_CS |  |  |  |
| 2577 | 636.1 | Stage 1 for Anonymous Call Rejection in the CS domain | 2d? | 2011-06-07 A | 2011-06-08 A | 100% | 2011-06-07 | 2011-06-08 | 2d? | finish no earlier than 2011-06-07 | S1 | 16h | 16h | ACR_CS | PCG-27 | Alcatel-Lucent | Betsy.Covell@alcatel-lucent.com | Rel-11 | SP-52 | Alain |  |  |  |  |
| 2578 | 636.2 | **Core Network aspects of Anonymous Call Rejection in the CS domain** | 59d? | 2011-09-14 A | 2011-12-02 A | 100% | 2011-09-14 | 2011-12-02 | 59d? |  | C4; C3 | 1432h | 1432h | ACR_CS-CN | PCG-27 | Alcatel-Lucent | bruno.landais@alcatel-lucent.com | Rel-11 | CP-53 | Kimmo | ACR_CS-CN |  |  |  |
| 2579 | 636.2.1 | CT4 part of Core Network aspects of Anonymous Call Rejection in the CS domain (Stage 2/3) | 59d? | 2011-09-14 A | 2011-12-02 A | 100% | 2011-09-14 | 2011-12-02 | 59d? | finish no earlier than 2011-12-02 | C4 | 464h | 464h | ACR_CS-CN | PCG-27 | Alcatel-Lucent | bruno.landais@alcatel-lucent.com | Rel-11 | CP-53 | Kimmo |  |  |  |  |
| 2580 | 636.2.2 | CT3 part of Core Network aspects of Anonymous Call Rejection in the CS domain (Stage 3) | 3d? | 2011-09-14 A | 2011-09-16 A | 100% | 2011-09-14 | 2011-09-16 | 3d? | start no earlier than 2011-09-14 | C3 | 24h | 24h | ACR_CS-CN | PCG-27 | Alcatel-Lucent | bruno.landais@alcatel-lucent.com | Rel-11 | CP-53 | Adrian |  |  |  |  |
| 2581 | 637 | **Support for BroadBand Forum Accesses Interworking** | 792d? | 2009-12-10 A | 2012-12-12 A | 100% | 2009-12-10 | 2012-12-12 | 792d? |  | S2; S1; C1; C3; C4; IETF | 97983.8h | 97983.8h | BBAI | PCG-24 | Ericsson | peter.bleckert@ericsson.com | Rel-11 | SP-46 | Alain | BBAI | HNB, WLAN |  |  |
| 2582 | 637.1 | Stage 1 BB I: BBF interworking with home routed traffic for WLAN and H(e)NB | 76d? | 2009-12-10 A | 2010-03-25 A | 100% | 2009-12-10 | 2010-03-25 | 76d? | start no earlier than 2009-12-10 | S1 | 608h | 608h | BBAI | PCG-24 | Ericsson | Olle.Eriksson@ericsson.com | Rel-11 | SP-46 | Alain |  | HNB, WLAN |  |  |
| 2583 | 637.2 | TR on Stage 2 for BBAI | 588d? | 2010-03-26 A | 2012-06-20 A | 100% | 2010-03-26 | 2012-06-20 | 588d? | finish no earlier than 2012-06-19 | S2 | 4704h | 4704h | BBAI | PCG-24 | Ericsson | marco.spini@huawei.com | Rel-11 | SP-47 | Maurice |  | HNB, WLAN |  |  |
| 2584 | 637.3 | Stage 2 BB I: BBF interworking with home routed traffic for WLAN and H(e)NB | 588d? | 2010-03-26 A | 2012-06-20 A | 100% | 2010-03-26 | 2012-06-20 | 588d? | finish no earlier than 2012-06-20 | S2 | 4688.06h | 4688.06h | BBAI | PCG-24 | Ericsson | stefan.rommer@ericsson.com | Rel-11 | SP-47 | Maurice |  | HNB, WLAN |  |  |
| 2585 | 637.4 | (IETF) Stage 2 BB I: BBF interworking with home routed traffic for WLAN and H(e)NB | 266d? | 2011-12-12 A | 2012-12-12 A | 100% | 2011-12-12 | 2012-12-12 | 266d? | finish no earlier than 2012-11-24 | S2-IETF | 2119.59h | 2119.59h | BBAI | PCG-28 | Lionel Morand | Lionel Morand | Rel-11 | SP-54 | Maurice |  | HNB, WLAN |  |  |
| 2586 | 637.5 | **Stage 3 BB I - Core Network impacts: BBF interworking with home routed traffic for WLAN and H(e)NB** | 326d? | 2011-09-16 A | 2012-12-07 A | 100% | 2011-09-16 | 2012-12-07 | 326d? |  | C1; C3; C4 | 17288.2h | 17288.2h | BBAI_BBI-CT | PCG-27 | Ericsson | Zu.Qiang@Ericsson.com | Rel-11 | CP-53 | Frederic | BBAI_BBI-CT | HNB, WLAN |  |  |
| 2587 | 637.5.1 | TR on Stage 3 BB I for BBAI; UE to network protocols | 198d? | 2011-09-16 A | 2012-06-15 A | 100% | 2011-09-16 | 2012-06-15 | 198d? | finish no earlier than 2012-06-15 | C1 | 1568.15h | 1568.15h | BBAI_BBI-CT | PCG-27 | Ericsson | Zu.Qiang@Ericsson.com | Rel-11 | CP-53 | Frederic |  | HNB, WLAN |  |  |
| 2588 | 637.5.2 | TR on Stage 3 BB I for BBAI; Home (e)Node B – Security Gateway Interface | 77d? | 2012-03-02 A | 2012-06-15 A | 100% | 2012-03-02 | 2012-06-15 | 77d? | finish no earlier than 2012-06-01 | C4 | 608h | 608h | BBAI_BBI-CT | PCG-28 | Ericsson | Zu.Qiang@Ericsson.com | Rel-11 | CP-55 | Kimmo |  | HNB, WLAN |  |  |
| 2589 | 637.5.3 | Deleted - (IETF) on Stage 3 BB I for BBAI; Home (e)Node B – Security Gateway Interface | 77d? | 2012-03-02 A | 2012-06-15 A | 100% | 2012-03-02 | 2012-06-15 | 77d? | finish no earlier than 2012-06-15 | C4-IETF | 616h | 616h | BBAI_BBI-CT | PCG-28 | Lionel Morand |  | Rel-11 | CP-55 | Kimmo |  | HNB, WLAN | PCG-29 | CP-56 |
| 2590 | 637.5.4 | CT1 part of Stage 3 BB I: BBF interworking with home routed traffic for WLAN and H(e)NB | 258d? | 2011-09-16 A | 2012-09-07 A | 100% | 2011-09-16 | 2012-09-07 | 258d? | finish no earlier than 2012-09-07 | C1 | 2048h | 2048h | BBAI_BBI-CT | PCG-27 | Ericsson | Zu.Qiang@Ericsson.com | Rel-11 | CP-53 | Frederic |  | HNB, WLAN |  |  |
| 2591 | 637.5.5 | CT3 part of Stage 3 BB I: BBF interworking with home routed traffic for WLAN and H(e)NB | 259d? | 2011-09-16 A | 2012-09-07 A | 100% | 2011-09-16 | 2012-09-07 | 259d? | finish no earlier than 2012-09-07 | C3 | 2048h | 2048h | BBAI_BBI-CT | PCG-27 | Ericsson | Zu.Qiang@Ericsson.com | Rel-11 | CP-53 | Adrian |  | HNB, WLAN |  |  |
| 2592 | 637.5.6 | CT4 part of Stage 3 BB I: BBF interworking with home routed traffic for WLAN and H(e)NB | 326d? | 2011-09-16 A | 2012-12-07 A | 100% | 2011-09-16 | 2012-12-07 | 326d? | finish no earlier than 2012-12-07 | C4 | 2576h | 2576h | BBAI_BBI-CT | PCG-27 | Ericsson | Zu.Qiang@Ericsson.com | Rel-11 | CP-53 | Kimmo |  | HNB, WLAN |  |  |
| 2593 | 637.6 | Stage 1 BB II: BBF interworking with offload in access network for WLAN and for H(e)NB | 262d? | 2010-09-23 A | 2011-09-21 A | 100% | 2010-09-23 | 2011-09-21 | 262d? | finish no earlier than 2011-09-21 | S1 | 2080h | 2080h | BBAI_BBII-CTofldS1 | PCG-25 | Ericsson | Olle.Eriksson@ericsson.com | Rel-11 | SP-49 | Alain |  | HNB, WLAN |  |  |
| 2594 | 637.7 | Stage 2 BB II: BBF interworking with offload in access network for WLAN and for H(e)NB | 455d? | 2010-09-28 A | 2012-06-20 A | 100% | 2010-09-28 | 2012-06-20 | 455d? | finish no earlier than 2012-06-20 | S2 | 3640h | 3640h | BBAI_BBII-CTofldS2 | PCG-24 | Ericsson | stefan.rommer@ericsson.com | Rel-11 | SP-47 | Maurice |  | HNB, WLAN |  |  |

Notes:
- 2570: SP#55 Stage 2 completed. Triggered by SA1 Rel-11 TR 22.871 Study on Non Voice Emergency Services (FS_NOVES)
- 2571: SP#53 completed / Impacted TSs and TRs: 22.101
- 2572: SP#55 completed / Impacted TSs and TRs: 23.060, 23.167, 23.203, 23.401
- 2573: SP#53 Stage 1 completed. CP#59 completed. Triggered by Rel-11 TR 22.809 Study on Support for 3GPP Voice Interworking with Enterprise IP-PBX (FS_VINE) UID_480033
- 2574: SP#53 completed / Impacted TSs and TRs: 22.228
- 2575: CP#59 completed / Impacted TSs and TRs: 23.218, 24.229
- 2576: CP#54 completed
- 2577: SP#52 completed under TEI11. Approved WID and CRs in SP-110376 (22.082 CR#0005, 22.085 CR#0004, 22.081 CR#0007, 22.088 CR#0003, 22.004 CR#0013) / Impacted TSs and TRs: 22.004, 22.081, 22.082, 22.085, 22.088
- 2578: CP#54 completed / Impacted TSs and TRs: Stage 2/3
- 2579: CP#54 completed / Impacted TSs and TRs: 23.018, 23.081, 23.082, 23.085, 23.088, 23.205, 23.231, 24.088, 29.002, 29.011
- 2580: CP#53 completed / Impacted TSs and TRs: 29.163, 29.292
- 2581: SP#57 updated WID SP-120419=>SP-120539 (removed BB3 objectives not implemented in Stage 2). SP#56 completed. Triggered by BBF WT 203, WT-134 (interworking btw 3GPP EPS and BBF's fixed broadband accesses)
- 2582: SP#57 updated WID SP-120419=>SP-120539 (removed BB3 objectives not implemented in Stage 2). SP#47 completed. Provide service requirements for supporting interworking between 3GPP EPS and the fixed broadband accesses defined by BBF / Impacted TSs and TRs: 22.278 CR#0058
- 2583: TR 23.839 not Approved in Rel-11; progressed in Rel-12 under P4C-TI (UID_560824) / Impacted TSs and TRs: new TR 23.839
- 2584: SP#56 completed / Impacted TSs and TRs: 23.203, new 23.139
- 2585: Solved by IANA-registration. No RFC needed
- 2586: CP#58 completed / Impacted TSs and TRs: Stage 3
- 2587: CP#56 completed. Identify additional FMC specific procedurES in CP-150addition to those in 24.302 (on access authentication & authorization and tunnel management; IP mobility mode selection; security aspects) / Impacted TSs and TRs: new TR 24.820
- 2588: CP#56 completed / Impacted TSs and TRs: new TR 29.839
- 2589: Draft removed from 3GPP documentation / Impacted TSs and TRs: draft-so-ipsecme-ikev2-cpext
- 2590: CP#57 completed / Impacted TSs and TRs: 24.229, new TS 24.139
- 2591: CP#57 completed / Impacted TSs and TRs: 29.212, 29.213, 29.215
- 2592: CP#58 completed / Impacted TSs and TRs: 23.008, 29.273, 29.274, new TS 29.139
- 2593: SP#53 completed. 22/01: acronym modified / Impacted TSs and TRs: 22.278
- 2594: SP#56 completed. 22/01: acronym modified / Impacted TSs and TRs: 23.203, 23.401, 23.402, 23.139

| ID | WBS | Task | Duration | Start | Finish | Complete | Baseline start | Baseline finish | Baseline duration | Constraint | Resources | Work | Actual work | Acronym | PCG approved | Impacted TSs and TRs | WI rapporteur name | WI rapporteur e-mail | Release | TSG approved | MCC resp | Special Focus Doc | Acronym_3GU_Export | PCG stopped | TSG stopped |
| --- | --- | --- | --- | --- | --- | --- | --- | --- | --- | --- | --- | --- | --- | --- | --- | --- | --- | --- | --- | --- | --- | --- | --- | --- | --- |
| 2595 | 637.8 | **Stage 3 BB II - Core Network impacts: BBF interworking with offload in access network for WLAN and for H(e)NB** | 259d? | 2011-09-16 A | 2012-09-07 A | 100% | 2011-09-16 | 2012-09-07 | 259d? |  | C3; C1; C4 | 12888h | 12888h | BBAI_BBII-CT | PCG-27 | Stage 3 | Ericsson | Susana.Fernandez@ericsson.com | Rel-11 | CP-53 | Adrian | HNB, WLAN | BBAI_BBII-CT |  |  |
| 2596 | 637.8.1 | TR on Stage 3 BB II for 3GPP System to Fixed Broadband Access Network Interworking; UE to network protocols | 198d? | 2011-09-16 A | 2012-06-15 A | 100% | 2011-09-16 | 2012-06-15 | 198d? | finish no earlier than 2012-06-15 | C1 | 1576h | 1576h | BBAI_BBII-CT | PCG-27 | 24.820 | Ericsson | Susana.Fernandez@ericsson.com | Rel-11 | CP-53 | Frederic | HNB, WLAN |  |  |  |
| 2597 | 637.8.2 | CT1 part of Stage 3 BB II: BBF interworking with offload in access network for WLAN and for H(e)NB | 259d? | 2011-09-16 A | 2012-09-07 A | 100% | 2011-09-16 | 2012-09-07 | 259d? | finish no earlier than 2012-09-07 | C1 | 2064h | 2064h | BBAI_BBII-CT | PCG-27 | new TS 24.320 | Ericsson | Susana.Fernandez@ericsson.com | Rel-11 | CP-53 | Frederic | HNB, WLAN |  |  |  |
| 2598 | 637.8.3 | CT3 part of Stage 3 BB II: BBF interworking with offload in access network for WLAN and for H(e)NB | 259d? | 2011-09-16 A | 2012-09-07 A | 100% | 2011-09-16 | 2012-09-07 | 259d? | start no earlier than 2011-09-16 | C3 | 2056h | 2056h | BBAI_BBII-CT | PCG-27 | 29.212, 29.213, 29.215 | Ericsson | Susana.Fernandez@ericsson.com | Rel-11 | CP-53 | Adrian | HNB, WLAN |  |  |  |
| 2599 | 637.8.4 | CT4 part of Stage 3 BB II: BBF interworking with offload in access network for WLAN and for H(e)NB | 122d? | 2011-09-16 A | 2012-03-02 A | 100% | 2011-09-16 | 2012-03-02 | 122d? | start no earlier than 2011-09-16 | C4 | 976h | 976h | BBAI_BBII-CT | PCG-27 | 23.008, 29.273 | Ericsson | Susana.Fernandez@ericsson.com | Rel-11 | CP-53 | Kimmo | HNB, WLAN |  |  |  |
| 2600 | 637.9 | Deleted - Stage 1 BB III: BBF convergence and network based mobility | 262d? | 2010-09-23 A | 2011-09-21 A | 100% | 2010-09-23 | 2011-09-21 | 262d? | finish no earlier than 2011-09-21 | S1 | 2080h | 2080h |  | PCG-25 | 22.278 | Huawei | Amar Deol (adeol@huawei.com) | Rel-11 | SP-49 | Alain | HNB, WLAN |  | PCG-29 | SP-57 |
| 2601 | 637.10 | Deleted - Stage 2 BB III: BBF convergence and network based mobility | 380d? | 2010-09-28 A | 2012-03-07 A | 100% | 2010-09-28 | 2012-03-07 | 380d? | finish no earlier than 2012-03-07 | S2 | 3040h | 3040h |  | PCG-24 | 23.203, 23.401, 23.402, 23.139 | Huawei | marco.spini@huawei.com | Rel-11 | SP-47 | Maurice | HNB, WLAN |  | PCG-28 | SP-55 |
| 2602 | 637.11 | **Deleted - Stage 3 BB III - Core Network impacts: BBF convergence and network based mobility** | 122d? | 2011-09-16 A | 2012-03-02 A | 100% | 2011-09-16 | 2012-03-02 | 122d? |  | C3; C1; C4 | 6832h | 6832h |  | PCG-27 | Stage 3 | Huawei | qiaoweihua@huawei.com | Rel-11 | CP-53 | Adrian | HNB, WLAN | BBAI_BBIII-CT | PCG-28 | CP-55 |
| 2603 | 637.11.1 | Deleted - TR on Stage 3 BB III for 3GPP System to Fixed Broadband Access Network Interworking; UE to network protocols | 122d? | 2011-09-16 A | 2012-03-02 A | 100% | 2011-09-16 | 2012-03-02 | 122d? | start no earlier than 2011-09-16 | C1 | 976h | 976h |  | PCG-27 | new TR 24.820 | Huawei | qiaoweihua@huawei.com | Rel-11 | CP-53 | Frederic | HNB, WLAN |  | PCG-28 | CP-55 |
| 2604 | 637.11.2 | Deleted - CT1 part of Stage 3 BB III: BBF convergence and network based mobility | 122d? | 2011-09-16 A | 2012-03-02 A | 100% | 2011-09-16 | 2012-03-02 | 122d? | start no earlier than 2011-09-16 | C1 | 976h | 976h |  | PCG-27 | TBD | Huawei | qiaoweihua@huawei.com | Rel-11 | CP-53 | Frederic | HNB, WLAN |  | PCG-28 | CP-55 |
| 2605 | 637.11.3 | Deleted - CT3 part of Stage 3 BB III: BBF convergence and network based mobility | 122d? | 2011-09-16 A | 2012-03-02 A | 100% | 2011-09-16 | 2012-03-02 | 122d? | start no earlier than 2011-09-16 | C3 | 976h | 976h |  | PCG-27 | 29.212, 29.213, 29.215 | Huawei | qiaoweihua@huawei.com | Rel-11 | CP-53 | Adrian | HNB, WLAN |  | PCG-28 | CP-55 |
| 2606 | 637.11.4 | Deleted - CT4 part of Stage 3 BB III: BBF convergence and network based mobility | 122d? | 2011-09-16 A | 2012-03-02 A | 100% | 2011-09-16 | 2012-03-02 | 122d? | start no earlier than 2011-09-16 | C4 | 976h | 976h |  | PCG-27 | 23.008, 29.273 | Huawei | qiaoweihua@huawei.com | Rel-11 | CP-53 | Kimmo | HNB, WLAN |  | PCG-28 | CP-55 |
| 2607 | 638 | **Single Radio Voice Call Continuity (SRVCC) aspect of enhancements for Multimedia Priority Service** | 398d? | 2010-06-10 A | 2011-12-14 A | 100% | 2010-06-10 | 2011-12-14 | 398d? |  | S2 | 8432h | 8432h | eMPS_SRVCC | PCG-25 | Stage 2 | NTT DoCoMo | Atsushi Minokuchi (minokuchi@nttdocomo.co.jp) | Rel-11 | SP-48 | Maurice | Public Safety (I-A) | eMPS_SRVCC |  |  |
| 2608 | 638.1 | TR on SRVCC for eMPS | 260d? | 2010-06-10 A | 2011-06-08 A | 100% | 2010-06-10 | 2011-06-08 | 260d? | finish no earlier than 2011-06-08 | S2 | 2080h | 2080h | eMPS_SRVCC | PCG-25 | new TR 23.854 | NTT DoCoMo | Atsushi Minokuchi (minokuchi@nttdocomo.co.jp) | Rel-11 | SP-48 | Maurice | Public Safety (I-A) |  |  |  |
| 2609 | 638.2 | Stage 2 on SRVCC for eMPS | 398d? | 2010-06-10 A | 2011-12-14 A | 100% | 2010-06-10 | 2011-12-14 | 398d? | finish no earlier than 2011-12-14 | S2 | 3168h | 3168h | eMPS_SRVCC | PCG-25 | 23.216, 23.237 | NTT DoCoMo | Atsushi Minokuchi (minokuchi@nttdocomo.co.jp) | Rel-11 | SP-48 | Maurice | Public Safety (I-A) |  |  |  |
| 2610 | 639 | **Single Radio Video Call Continuity for 3G-CS** | 440d? | 2010-10-15 A | 2012-06-15 A | 100% | 2010-10-15 | 2012-06-15 | 440d? |  | S2; C1; C3; C4 | 26572.4h | 26572.4h | vSRVCC | PCG-26 |  | Samsung | xiaowan.ke@samsung.com | Rel-11 | SP-50 | Maurice |  | vSRVCC |  |  |
| 2611 | 639.1 | Stage 2 for Single Radio Video Call Continuity for 3G-CS | 199.85d? | 2010-10-15 A | 2011-09-21 A | 100% | 2010-10-15 | 2011-09-21 | 199.85d? | finish no earlier than 2011-12-07 | S2 | 1580.41h | 1580.41h | vSRVCC | PCG-26 | 23.203, 23.216, 23.237 | Samsung | xiaowan.ke@samsung.com | Rel-11 | SP-50 | Maurice |  |  |  |  |
| 2612 | 639.2 | **CN aspects of Single Radio Video Call Continuity for 3G-CS** | 275d? | 2011-06-03 A | 2012-06-15 A | 100% | 2011-06-03 | 2012-06-15 | 275d? |  | C1; C3; C4 | 10912h | 10912h | vSRVCC-CT | PCG-27 |  | NEC | gottfried.punz@neclab.eu | Rel-11 | CP-52 | Frederic |  | vSRVCC-CT |  |  |
| 2613 | 639.2.1 | CT1 aspects of Single Radio Video Call Continuity for 3G-CS | 275d? | 2011-06-03 A | 2012-06-15 A | 100% | 2011-06-03 | 2012-06-15 | 275d? | finish no earlier than 2012-06-15 | C1 | 2184h | 2184h | vSRVCC-CT | PCG-27 | 24.008, 24.237, 24.301 | NEC | gottfried.punz@neclab.eu | Rel-11 | CP-52 | Frederic |  |  |  |  |
| 2614 | 639.2.2 | CT3 aspects of Single Radio Video Call Continuity for 3G-CS | 134d? | 2011-06-03 A | 2011-12-02 A | 100% | 2011-06-03 | 2011-12-02 | 134d? | finish no earlier than 2011-12-02 | C3 | 1064h | 1064h | vSRVCC-CT | PCG-27 | 29.211, 29.212, 29.213, 29.215 | NEC | gottfried.punz@neclab.eu | Rel-11 | CP-52 | Adrian |  |  |  |  |
| 2615 | 639.2.3 | CT4 aspects of Single Radio Video Call Continuity for 3G-CS | 134d? | 2011-06-03 A | 2011-12-02 A | 100% | 2011-06-03 | 2011-12-02 | 134d? | finish no earlier than 2011-12-02 | C4 | 1064h | 1064h | vSRVCC-CT | PCG-27 | 29.280 | NEC | gottfried.punz@neclab.eu | Rel-11 | CP-52 | Kimmo |  |  |  |  |
| 2616 | 640 | **Network-provided Location information for IMS (NETLOC)** | 720d? | 2010-06-10 A | 2013-03-01 A | 100% | 2010-06-10 | 2013-03-01 | 720d? |  | S2; S1; S5; C3; C4; C1 | 57274.7h | 57274.7h | NWK-PL2IMS | PCG-25 |  | T-Mobile | michele.zarri@t-mobile.co.uk | Rel-11 | SP-48 | Maurice |  | NWK-PL2IMS |  |  |
| 2617 | 640.1 | Stage 1 for Network-provided Location information for IMS | 203d? | 2010-12-15 A | 2011-09-21 A | 100% | 2010-12-15 | 2011-09-21 | 203d? | finish no earlier than 2011-09-21 | S1 | 1608h | 1608h | NWK-PL2IMS | PCG-26 | 22.115 | n/a | n/a | Rel-11 | SP-50 | Alain |  |  |  |  |
| 2618 | 640.2 | TR on Stage 2 for Network-provided Location information for IMS | 395d? | 2010-06-10 A | 2011-12-14 A | 100% | 2010-06-10 | 2011-12-14 | 395d? | finish no earlier than 2011-12-06 | S2 | 3160h | 3160h | NWK-PL2IMS | PCG-25 | new TR 23.842 | T-Mobile | michele.zarri@t-mobile.co.uk | Rel-11 | SP-48 | Maurice |  |  |  |  |
| 2619 | 640.3 | Stage 2 for Network-provided Location information for IMS | 455d? | 2010-06-15 A | 2012-03-07 A | 100% | 2010-06-15 | 2012-03-07 | 455d? | finish no earlier than 2012-03-07 | S2 | 3640h | 3640h | NWK-PL2IMS | PCG-25 | 23.060, 23.203, 23.228, 23.401 | T-Mobile | michele.zarri@t-mobile.co.uk | Rel-11 | SP-48 | Maurice |  |  |  |  |
| 2620 | 640.4 | Charging for Network-provided Location information for IMS | 515d? | 2010-09-23 A | 2012-09-12 A | 100% | 2010-09-23 | 2012-09-12 | 515d? | finish no earlier than 2012-09-12 | S5 | 4120h | 4120h | NWK-PL2IMS_CH | PCG-25 | Stage 2 (32.240, 32.260), Stage 3 (32.298, 32.299) | Nokia Siemens Networks | Gerald.Goermer@nsn.com | Rel-11 | SP-49 | Mirko |  | NWK-PL2IMS_CH |  |  |

Notes:
- 2595: CP#57 completed
- 2596: CP#56 completed
- 2597: CP#57 completed
- 2598: CP#57 completed
- 2599: CP#55 completed
- 2600: SP#57 stopped. Updated WID SP-120419=>SP-120539 (removed BB3 objectives not implemented in Stage 2). SP#53 completed
- 2601: SP#57 updated WID SP-120419=>SP-120539 (removed BB3 objectives not implemented in Stage 2). SP#55 stopped
- 2602: CP#55 stopped
- 2603: CP#55 stopped
- 2604: CP#55 stopped
- 2605: CP#55 stopped
- 2606: CP#55 stopped
- 2607: SP#54 completed. Analyze and if needed specify mechanisms for the priority handling of SRVCC with regard to LTE/EPC
- 2608: SP#52 completed
- 2609: SP#54 completed
- 2610: CP#56 completed. Provide Single Radio VIDEO Call Continuity from E-UTRAN to UTRAN-CS based on the agreed architecture alternative in TR 23.886
- 2611: SP#53 completed. Triggered by Feasibility Study on video call handover capability in TR 23.886 UID_470048 Study on Single Radio Video Call Continuity for 3G-CS (FS_vSRVCC)
- 2612: Stage 3. CP#56 completed
- 2613: CP#56 completed
- 2614: CP#54 completed
- 2615: CP#54 completed
- 2616: Covers the case where UE is served by a 3GPP RAN. Architecture making Cell/PLMN ID (UE is camped on) available to IMS nodes when the operator needs to record this information either to fulfil legal obligations or for charging.
- 2617: SP#53 completed
- 2618: SP#54 completed
- 2619: SP#55 completed
- 2620: SP#57 completed

| ID | WBS | Task | Type | Duration | Start | Finish | Complete | Baseline start | Baseline finish | Baseline duration | Constraint | Resources | Work | Actual work | Acronym | PCG approved | WI rapporteur name | WI rapporteur e-mail | Release | TSG approved | MCC resp | Acronym_3GU_Export | Special Focus Doc | PCG stopped | TSG stopped |
| --- | --- | --- | --- | --- | --- | --- | --- | --- | --- | --- | --- | --- | --- | --- | --- | --- | --- | --- | --- | --- | --- | --- | --- | --- | --- |
| 2621 | 640.5 | **CT aspects of Network-provided Location information for IMS (Stage 3)** |  | 266d? | 2012-03-02 A | 2013-03-01 A | 100% | 2012-03-02 | 2013-03-01 | 266d? |  | C3; C4; C1 | 10186.7h | 10186.7h | NWK-PL2IMS-CT | PCG-28 | Huawei | Qiao Weihua (qiaoweihua@huawei.com) | Rel-11 | CP-55 | Adrian | NWK-PL2IMS_CT |  |  |  |
| 2622 | 640.5.1 | CT3 part of CT aspects of Network-provided Location information for IMS |  | 138d? | 2012-03-02 A | 2012-09-07 A | 100% | 2012-03-02 | 2012-09-07 | 138d? | finish no earlier than 2012-09-07 | C3 | 1088h | 1088h | NWK-PL2IMS-CT | PCG-28 | Huawei | Qiao Weihua (qiaoweihua@huawei.com) | Rel-11 | CP-55 | Adrian |  |  |  |  |
| 2623 | 640.5.2 | CT4 part of CT aspects of Network-provided Location information for IMS |  | 77d? | 2012-03-02 A | 2012-06-15 A | 100% | 2012-03-02 | 2012-06-15 | 77d? | finish no earlier than 2012-06-01 | C4 | 608h | 608h | NWK-PL2IMS-CT | PCG-28 | Huawei | Qiao Weihua (qiaoweihua@huawei.com) | Rel-11 | CP-55 | Kimmo |  |  |  |  |
| 2624 | 640.5.3 | CT1 part of CT aspects of Network-provided Location information for IMS |  | 266d? | 2012-03-02 A | 2013-03-01 A | 100% | 2012-03-02 | 2013-03-01 | 266d? | finish no earlier than 2013-06-14 | C1 | 2106.67h | 2106.67h | NWK-PL2IMS-CT | PCG-28 | Huawei | Qiao Weihua (qiaoweihua@huawei.com) | Rel-11 | CP-55 | Frederic |  |  |  |  |
| 2625 | 641 | **Service Awareness and Privacy Policies** |  | 301.15d? | 2010-10-12 A | 2011-12-02 A | 100% | 2010-10-12 | 2011-12-02 | 301.15d? |  | S2; S1; C3 | 10667.6h | 10667.6h | SAPP | PCG-26 | Allot | Alla Goldner (agoldner@allot.com) | Rel-11 | SP-50 | Maurice | SAPP |  |  |  |
| 2626 | 641.1 | Stage 1 for Service Awareness and Privacy Policies |  | 46.15d? | 2010-10-12 A | 2010-12-15 A | 100% | 2010-10-12 | 2010-12-15 | 46.15d? | finish no earlier than 2010-12-15 | S1 | 369.2h | 369.2h | SAPP | PCG-26 | Allot | Alla Goldner (agoldner@allot.com) | Rel-11 | SP-50 | Maurice |  |  |  |  |
| 2627 | 641.2 | Stage 2 for Service Awareness and Privacy Policies |  | 199.85d? | 2010-10-15 A | 2011-09-21 A | 100% | 2010-10-15 | 2011-09-21 | 199.85d? | finish no earlier than 2011-09-21 | S2 | 1582.8h | 1582.8h | SAPP | PCG-26 | Allot | Alla Goldner (agoldner@allot.com) | Rel-11 | SP-50 | Maurice |  |  |  |  |
| 2628 | 641.3 | CT3 part of Service Awareness and Privacy Policies |  | 187d? | 2011-03-18 A | 2011-12-02 A | 100% | 2011-03-18 | 2011-12-02 | 187d? | finish no earlier than 2011-12-02 | C3 | 1488h | 1488h | SAPP-CT3 | PCG-26 | Allot | Alla Goldner (agoldner@allot.com) | Rel-11 | CP-51 | Adrian | SAPP-CT3 |  |  |  |
| 2629 | 642 | **VPLMN Autonomous CSG Roaming** |  | 307d? | 2010-10-15 A | 2011-12-14 A | 100% | 2010-10-15 | 2011-12-14 | 307d? |  | S2; C4 | 6974.61h | 6974.61h | VCSG | PCG-26 | Qualcomm | AC Mahendran (ac@qualcomm.com) | Rel-11 | SP-50 | Maurice | VCSG |  |  |  |
| 2630 | 642.1 | Stage 2 for VPLMN Autonomous CSG Roaming |  | 260.85d? | 2010-10-15 A | 2011-12-14 A | 100% | 2010-10-15 | 2011-12-14 | 260.85d? | finish no earlier than 2011-12-07 | S2 | 2062.61h | 2062.61h | VCSG | PCG-26 | Qualcomm | AC Mahendran (ac@qualcomm.com) | Rel-11 | SP-50 | Maurice |  |  |  |  |
| 2631 | 642.2 | CT aspects of VPLMN Autonomous CSG Roaming | milestone | 0d? | 2011-12-07 A | 2011-12-07 A | 100% | 2011-12-07 | 2011-12-07 | 0d? | finish no earlier than 2012-09-07 | C4 |  |  | VCSG-St3 | PCG-27 | ZTE | Fei Lu (lu.fei1@zte.com.cn) | Rel-11 | CP-53 | Kimmo | VCSG-St3 |  |  |  |
| 2632 | 643 | **Data Identification in Access Network Discovery and Selection Function (ANDSF)** |  | 455d? | 2011-03-23 A | 2012-12-07 A | 100% | 2011-03-23 | 2012-12-07 | 455d? |  | S2; C1 | 12488h | 12488h | DIDA | PCG-26 | Qualcomm | Gerardo Giaretta (gerardo@qualcomm.com) | Rel-11 | SP-51 | Maurice | DIDA |  |  |  |
| 2633 | 643.1 | TR on Stage 2 for Data Identification in ANDSF |  | 193d? | 2011-03-23 A | 2011-12-14 A | 100% | 2011-03-23 | 2011-12-14 | 193d? | finish no earlier than 2011-12-07 | S2 | 1544h | 1544h | DIDA | PCG-26 | Qualcomm | Gerardo Giaretta (gerardo@qualcomm.com) | Rel-11 | SP-51 | Maurice |  |  |  |  |
| 2634 | 643.2 | Stage 2 for Data Identification in ANDSF |  | 253d? | 2011-03-24 A | 2012-03-07 A | 100% | 2011-03-24 | 2012-03-07 | 253d? | finish no earlier than 2012-03-07 | S2 | 2024h | 2024h | DIDA | PCG-26 | Qualcomm | Gerardo Giaretta (gerardo@qualcomm.com) | Rel-11 | SP-51 | Maurice |  |  |  |  |
| 2635 | 643.3 | CT aspects of Data Identification in Access Network Discovery and Selection Function (ANDSF) Stage 3 |  | 205d? | 2012-03-02 A | 2012-12-07 A | 100% | 2012-03-02 | 2012-12-07 | 205d? | finish no earlier than 2012-12-07 | C1 | 1640h | 1640h | DIDA-CT | PCG-28 | Qualcomm | Patrick Stupar (pstupar@qualcomm.com) | Rel-11 | CP-55 | Frederic | DIDA-CT |  |  |  |
| 2636 | 644 | **LOcation-Based Selection of gaTEways foR WLAN** |  | 327d? | 2011-03-23 A | 2012-06-15 A | 100% | 2011-03-23 | 2012-06-15 | 327d? |  | S2; C4 | 10170.5h | 10170.5h | LOBSTER | PCG-26 | ZTE | zhu.chunhui@zte.com.cn | Rel-11 | SP-51 | Maurice | LOBSTER | WLAN |  |  |
| 2637 | 644.1 | Stage 2 for LOcation-Based Selection of gaTEways foR WLAN |  | 194d? | 2011-03-23 A | 2011-12-14 A | 100% | 2011-03-23 | 2011-12-14 | 194d? | finish no earlier than 2011-12-07 | S2 | 1546.52h | 1546.52h | LOBSTER | PCG-26 | ZTE | zhu.chunhui@zte.com.cn | Rel-11 | SP-51 | Maurice |  | WLAN |  |  |
| 2638 | 644.2 | **CT aspects of LOcation-Based Selection of gaTEways foR WLAN** |  | 142d? | 2011-12-02 A | 2012-06-15 A | 100% | 2011-12-02 | 2012-06-15 | 142d? |  | C4 | 3392h | 3392h | LOBSTER-CT | PCG-28 | ZTE | zhou.xingyue@zte.com.cn | Rel-11 | CP-54 | Kimmo | LOBSTER-CT | WLAN |  |  |
| 2639 | 644.2.1 | CT4 part of CT aspects of LOcation-Based Selection of gaTEways foR WLAN |  | 142d? | 2011-12-02 A | 2012-06-15 A | 100% | 2011-12-02 | 2012-06-15 | 142d? | finish no earlier than 2012-06-15 | C4 | 1128h | 1128h | LOBSTER-CT | PCG-28 | ZTE | zhou.xingyue@zte.com.cn | Rel-11 | CP-54 | Kimmo |  | WLAN |  |  |
| 2640 | 644.2.2 | Deleted - CT1 part of CT aspects of LOcation-Based Selection of gaTEways foR WLAN |  | 142d? | 2011-12-02 A | 2012-06-15 A | 100% | 2011-12-02 | 2012-06-15 | 142d? | finish no earlier than 2012-06-15 | C1 | 1128h | 1128h | LOBSTER-CT | PCG-28 | ZTE | zhou.xingyue@zte.com.cn | Rel-11 | CP-54 | Frederic |  | WLAN | PCG-29 | CP-56 |
| 2641 | 645 | **Single Radio Voice Call Continuity from UTRAN/GERAN to E-UTRAN/HSPA** |  | 929d? | 2011-09-12 A | 2015-03-15 A | 100% | 2011-09-12 | 2014-12-05 | 856d? |  | S2; C1; C3; C4; G2; R2; R3; R5 | 83776.8h | 83776.8h | rSRVCC | PCG-27 | Orange | antoine.mouquet@orange-ftgroup.com | Rel-11 | SP-53 | Maurice | rSRVCC |  |  |  |
| 2642 | 645.1 | Stage 2 for Single Radio Voice Call Continuity from UTRAN/GERAN to E-UTRAN/HSPA |  | 197d? | 2011-09-22 A | 2012-06-20 A | 100% | 2011-09-22 | 2012-06-20 | 197d? | finish no earlier than 2012-06-20 | S2 | 1568h | 1568h | rSRVCC | PCG-27 | Orange | antoine.mouquet@orange-ftgroup.com | Rel-11 | SP-53 | Maurice |  |  |  |  |
| 2643 | 645.2 | **CT aspects for Single Radio Voice Call Continuity from UTRAN/GERAN to E-UTRAN/HSPA (Stage 3)** |  | 259d? | 2011-09-16 A | 2012-09-07 A | 100% | 2011-09-16 | 2012-09-07 | 259d? |  | C1; C3; C4 | 12360h | 12360h | rSRVCC-CT | PCG-27 | Ericsson | ivo.sedlacek@ericsson.com | Rel-11 | CP-53 | Frederic | rSRVCC-CT |  |  |  |
| 2644 | 645.2.1 | CT1 part for Single Radio Voice Call Continuity from UTRAN/GERAN to E-UTRAN/HSPA |  | 258d? | 2011-09-16 A | 2012-09-07 A | 100% | 2011-09-16 | 2012-09-07 | 258d? | finish no earlier than 2012-09-07 | C1 | 2048h | 2048h | rSRVCC-CT | PCG-27 | Ericsson | ivo.sedlacek@ericsson.com | Rel-11 | CP-53 | Frederic |  |  |  |  |
| 2645 | 645.2.2 | CT3 part for Single Radio Voice Call Continuity from UTRAN/GERAN to E-UTRAN/HSPA |  | 257d? | 2011-09-19 A | 2012-09-07 A | 100% | 2011-09-19 | 2012-09-07 | 257d? | finish no earlier than 2012-09-07 | C3 | 2048h | 2048h | rSRVCC-CT | PCG-27 | Ericsson | ivo.sedlacek@ericsson.com | Rel-11 | CP-53 | Adrian |  |  |  |  |
| 2646 | 645.2.3 | CT4 part for Single Radio Voice Call Continuity from UTRAN/GERAN to E-UTRAN/HSPA |  | 257d? | 2011-09-19 A | 2012-09-07 A | 100% | 2011-09-19 | 2012-09-07 | 257d? | finish no earlier than 2012-09-07 | C4 | 2048h | 2048h | rSRVCC-CT | PCG-27 | Ericsson | ivo.sedlacek@ericsson.com | Rel-11 | CP-53 | Kimmo |  |  |  |  |
| 2647 | 645.3 | GERAN aspects of Single Radio Voice Call Continuity from UTRAN/GERAN to E-UTRAN/HSPA (Stage 3) |  | 476.1d? | 2011-09-12 A | 2013-06-28 A | 100% | 2011-09-12 | 2013-06-28 | 476.1d? | finish no earlier than 2013-11-22 | G2 | 2048h | 2048h | rSRVCC-GERAN | PCG-27 | ZTE | li.jing4@zte.com.cn | Rel-11 | GP-51 | Gert | rSRVCC-GERAN |  |  |  |

Notes:
- 2621: Stage 3. 3/3: Acronym changed from "NWK-PL2IMS_CT"
- 2622: CP#57 completed. 3/3: Acronym changed from "NWK-PL2IMS_CT" / Impacted TSs and TRs: 29.212, 29.214, 29.215
- 2623: CP#57 completed. 3/3: Acronym changed from "NWK-PL2IMS_CT" / Impacted TSs and TRs: 23.008, 29.002, 29.060, 29.230, 29.272, 29.274, 29.305, 29.328, 29.329
- 2624: CP#57 completed. 3/3: Acronym changed from "NWK-PL2IMS_CT" / Impacted TSs and TRs: 24.229, 24.292
- 2625: CP#54 completed. Triggered by the SA1,SA2 Rel-10 TR 23.813 Study on Policy solutions and enhancements (FS_PP) UID_440047
- 2626: For deep packet inspection (i.e. Traffic Detection Functionality) SA1 indicated that no new requirements are needed (see Objective of FS_PP SA1,SA2 Rel-10 Study on Policy solutions and enhancements UID_440047 TR 23.813)
- 2627: SP#53 completed / Impacted TSs and TRs: 23.203
- 2628: CP#54 completed. Stage 3 to support Application Detection and Control Functionality. Update Gx / introduce Sd reference points and procedures. Update S9 reference point in roaming scenarios / Impacted TSs and TRs: 29.212, 29.213, 29.214, 29.215
- 2629: CP#56 completed. Linked to Rel-10 UID_450053 Enhanced Home NodeB / eNodeB (EHNB). Implements Rel-9 requirements for CSG support in SA1 TS 22.220
- 2630: SP#54 completed / Impacted TSs and TRs: 23.002, 23.060, 23.401
- 2631: CP#57 completed / Impacted TSs and TRs: 23.003, 23.007, 23.008, 23.012, 29.002, 29.230, 29.272
- 2632: SP#58 completed. Linked to Rel-10 IFOM (IP Flow Mobility and seamless WLAN offload) UID_450041. Defines IP flow mobility, seamless and non seamless WLAN offload and respective ANDSF extensions / Impacted TSs and TRs: Stage 2/3
- 2633: SP#54 completed / Impacted TSs and TRs: New TR 23.855
- 2634: SP#55 completed / Impacted TSs and TRs: 23.402
- 2635: CP#58 completed / Impacted TSs and TRs: 24.302, 24.312
- 2636: CP#56 completed. Related to UID_350027 SAE for support for non-3GPP accesses (SAES-SA-FP_n3GPP). Enhancements to ePDG and PDN GW selection functions for S2b and S2c based on UE location
- 2637: SP#54 completed / Impacted TSs and TRs: 23.402
- 2638: Stage 3. CP#56 completed / Impacted TSs and TRs: Stage 3
- 2639: CP#56 completed / Impacted TSs and TRs: 29.273
- 2640: CP#56 stopped / Impacted TSs and TRs: 24.302
- 2641: Stage 1 in Rel-8 TS 22.278 clause 7.1.4.2. Triggered by Rel-11 TR 23.885 Study on Single Radio Voice Call Continuity from UTRAN/GERAN to E-UTRAN/HSPA (FS_rSRVCC) UID_460030
- 2642: SP#56 completed / Impacted TSs and TRs: 23.216, 23.237
- 2643: CP#57 completed / Impacted TSs and TRs: Stage 3
- 2644: CP#57 completed / Impacted TSs and TRs: 23.009, 24.008, 24.229, 24.237, 24.292, 24.301
- 2645: CP#57 completed / Impacted TSs and TRs: 29.165, 29.292
- 2646: CP#57 completed / Impacted TSs and TRs: 23.003, 23.008, 29.002, 29.230, 29.272, 29.280, 29.303, 29.305, 29.328
- 2647: GP#60 completed. GP#51 approved WID / Impacted TSs and TRs: 44.018, 48.008

| ID | WBS | Task | Duration | Start | Finish | Complete | Baseline start | Baseline finish | Baseline duration | Constraint | Resources | Work | Actual work | Acronym | PCG approved | Impacted TSs and TRs | WI rapporteur name | Release | TSG approved | MCC resp | Acronym_3GU_Export | Status Report | Special Focus Doc | PCG stopped | TSG stopped |
| --- | --- | --- | --- | --- | --- | --- | --- | --- | --- | --- | --- | --- | --- | --- | --- | --- | --- | --- | --- | --- | --- | --- | --- | --- | --- |
| 2648 | 645.4 | **UTRAN aspects of Single Radio Voice Call Continuity from UTRAN/GERAN to E-UTRAN/HSPA** | 325d? | 2011-09-19 A | 2012-12-07 A | 100% | 2011-09-19 | 2012-12-07 | 325d? |  | R3; R2 | 10400h | 10400h | rSRVCC-RAN_UTRA | PCG-27 | UTRA | Huawei | Rel-11 | RP-53 | Juha | rSRVCC-RAN_UTRA |  |  |  |  |
| 2649 | 645.4.1 | Core part: UTRAN aspects of Single Radio Voice Call Continuity from UTRAN/GERAN to E-UTRAN/HSPA | 325d? | 2011-09-19 A | 2012-12-07 A | 100% | 2011-09-19 | 2012-12-07 | 325d? | finish no earlier than 2012-12-07 | R3; R2 | 5200h | 5200h | rSRVCC-RAN_UTRA-Core | PCG-27 | 25.331, 25.401, 25.413 | Huawei | Rel-11 | RP-53 | Juha | rSRVCC-RAN_UTRA-Core | RP-121553 |  |  |  |
| 2650 | 645.5 | Test part: Single Radio Voice Call Continuity from UTRAN/GERAN to E-UTRAN/HSPA | 196d? | 2014-06-15 A | 2015-03-15 A | 100% | 2014-06-13 | 2014-12-05 | 126d? | finish no earlier than 2015-03-15 | R5 | 1568h | 1568h | rSRVCC-UEConTest | PCG-33 | 36.508, 36.523-1, 36.523-2, 36.523-3 | Ericsson | Rel-11 | RP-64 |  | rSRVCC-UEConTest | RP-150133 |  |  |  |
| 2651 | 646 | **S2a Mobility based On GTP and WLAN access to EPC** | 651d? | 2011-09-22 A | 2014-03-05 A | 100% | 2011-09-22 | 2014-03-05 | 651d? |  | S2; C4; C1; C3; IETF | 54000h | 54000h | SaMOG_WLAN | PCG-27 | Stage 2/3 | ZTE | Rel-11 | SP-53 | Maurice | SaMOG_WLAN |  | WLAN |  |  |
| 2652 | 646.1 | Stage 2 for S2a Mobility based On GTP and WLAN access to EPC | 121d? | 2011-09-22 A | 2012-03-07 A | 100% | 2011-09-22 | 2012-03-07 | 121d? | finish no earlier than 2012-03-07 | S2 | 968h | 968h | SaMOG_WLAN | PCG-27 | 23.002, 23.203, 23.402 | ZTE | Rel-11 | SP-53 | Maurice |  |  | WLAN |  |  |
| 2653 | 646.2 | **CN aspects of Mobility based On GTP & PMIPv6 for WLAN access to EPC** | 599d? | 2011-12-02 A | 2014-03-05 A | 100% | 2011-12-02 | 2014-03-05 | 599d? |  | C4; C1; C3; IETF | 26992h | 26992h | SaMOG_WLAN-CN | PCG-28 | Stage 3 | Alcatel-Lucent | Rel-11 | CP-54 | Kimmo | SaMOG_WLAN-CN |  | WLAN |  |  |
| 2654 | 646.2.1 | CT4 part of CN aspects of Mobility based On GTP & PMIPv6 for WLAN access to EPC | 203d? | 2011-12-02 A | 2012-09-07 A | 100% | 2011-12-02 | 2012-09-07 | 203d? | finish no earlier than 2012-09-07 | C4 | 1608h | 1608h | SaMOG_WLAN-CN | PCG-28 | 23.003, 23.007, 23.008, 29.273, 29.274, 29.281, 29.303 | Alcatel-Lucent | Rel-11 | CP-54 | Kimmo |  |  | WLAN |  |  |
| 2655 | 646.2.2 | Deleted - (IETF) CT4 part of CN aspects of Mobility based On GTP & PMIPv6 for WLAN access to EPC | 498d? | 2012-04-23 A | 2014-03-05 A | 100% | 2012-04-23 | 2014-03-05 | 498d? | finish no earlier than 2014-03-05 | C4-IETF | 3960h | 3960h | SaMOG_WLAN-CN | PCG-29 | draft-ietf-radext-ieee802ext | Lionel Morand | Rel-11 | CP-56 | Kimmo |  |  | WLAN | PCG-32 | CP-53 |
| 2656 | 646.2.3 | Deleted - CT1 part of CN aspects of Mobility based On GTP & PMIPv6 for WLAN access to EPC | 142d? | 2011-12-02 A | 2012-06-15 A | 100% | 2011-12-02 | 2012-06-15 | 142d? | finish no earlier than 2012-06-15 | C1 | 1128h | 1128h | SaMOG_WLAN-CN | PCG-28 | 24.302 | Alcatel-Lucent | Rel-11 | CP-54 | Frederic |  |  | WLAN | PCG-29 | CP-56 |
| 2657 | 646.2.4 | CT3 part of CN aspects of Mobility based On GTP & PMIPv6 for WLAN access to EPC | 142d? | 2011-12-02 A | 2012-06-15 A | 100% | 2011-12-02 | 2012-06-15 | 142d? | finish no earlier than 2012-09-07 | C3 | 1128h | 1128h | SaMOG_WLAN-CN | PCG-28 | 29.212, 29.213, 29.215 | Alcatel-Lucent | Rel-11 | CP-54 | Adrian |  |  | WLAN |  |  |
| 2658 | 647 | **Roaming Architecture for Voice over IMS with Local Breakout** | 273d? | 2011-11-28 A | 2012-12-07 A | 100% | 2011-11-28 | 2012-12-07 | 273d? |  | S2; S5; C1; C3 | 16904h | 16904h | RAVEL | PCG-28 | Stage 2/3 | Deutsche Telekom | Rel-11 | SP-54 | Maurice | RAVEL |  |  |  |  |
| 2659 | 647.1 | Stage 2 for Roaming Architecture for Voice over IMS with Local Breakout | 12d? | 2011-11-28 A | 2011-12-14 A | 100% | 2011-11-28 | 2011-12-14 | 12d? | finish no earlier than 2012-03-07 | S2 | 96h | 96h | RAVEL | PCG-28 | 23.002, 23.228 | Deutsche Telekom | Rel-11 | SP-54 | Maurice |  |  |  |  |  |
| 2660 | 647.2 | Charging for Roaming Architecture for Voice over IMS with Local Breakout | 196d? | 2011-12-14 A | 2012-09-12 A | 100% | 2011-12-14 | 2012-09-12 | 196d? | finish no earlier than 2012-09-12 | S5 | 1568h | 1568h | RAVEL-CH | PCG-28 | 32.240, 32.260, 32.298, 32.299 | Nokia Siemens Networks | Rel-11 | SP-54 | Mirko | RAVEL-CH |  |  |  |  |
| 2661 | 647.3 | **CT aspects of Roaming Architecture for Voice over IMS with Local Breakout (Stage 3)** | 205d? | 2012-03-02 A | 2012-12-07 A | 100% | 2012-03-02 | 2012-12-07 | 205d? |  | C1; C3 | 6504h | 6504h | RAVEL-CT | PCG-28 | Stage 3 | Deutsche Telekom | Rel-11 | CP-55 | Frederic | RAVEL-CT |  |  |  |  |
| 2662 | 647.3.1 | CT1 part of CT aspects of Roaming Architecture for Voice over IMS with Local Breakout | 204d? | 2012-03-02 A | 2012-12-07 A | 100% | 2012-03-02 | 2012-12-07 | 204d? | finish no earlier than 2012-12-07 | C1 | 1608h | 1608h | RAVEL-CT | PCG-28 | 24.229, 24.292, 24.237 | Deutsche Telekom | Rel-11 | CP-55 | Frederic |  |  |  |  |  |
| 2663 | 647.3.2 | CT3 part of CT aspects of Roaming Architecture for Voice over IMS with Local Breakout | 204d? | 2012-03-02 A | 2012-12-07 A | 100% | 2012-03-02 | 2012-12-07 | 204d? | finish no earlier than 2012-12-07 | C3 | 1616h | 1616h | RAVEL-CT | PCG-28 | 29.165, 29.162, 29.079 | Deutsche Telekom | Rel-11 | CP-55 | Adrian |  |  |  |  |  |
| 2664 | 648 | **IMS Overload Control** | 659d? | 2012-06-18 A | 2014-12-09 A | 100% | 2012-06-18 | 2014-12-05 | 654d? |  | S2; C1; C3; IETF | 52408h | 52408h | IOC | PCG-29 | Stage 2/3 | Orange, China Mobile | Rel-11 | SP-56 | Maurice | IOC |  |  |  |  |
| 2665 | 648.1 | Stage 2 for IMS Overload Control | 64d? | 2012-06-18 A | 2012-09-12 A | 100% | 2012-06-18 | 2012-09-12 | 64d? | finish no earlier than 2012-09-12 | S2 | 504h | 504h | IOC | PCG-29 | 23.228 | Orange, China Mobile | Rel-11 | SP-56 | Maurice |  |  |  |  |  |
| 2666 | 648.2 | **Stage 3 for IMS Overload Control** | 601d? | 2012-09-05 A | 2014-12-09 A | 100% | 2012-09-05 | 2014-12-05 | 596d? |  | C1; C3; IETF | 30816h | 30816h | IOC | PCG-29 |  | Alcatel-Lucent | Rel-11 | CP-57 | Frederic |  |  |  |  |  |
| 2667 | 648.2.1 | CT1 part of Stage 3 for IMS Overload Control | 70d? | 2012-09-05 A | 2012-12-07 A | 100% | 2012-09-05 | 2012-12-07 | 70d? | finish no earlier than 2012-12-07 | C1 | 544h | 544h | IOC | PCG-29 | 24.229 | Alcatel-Lucent | Rel-11 | CP-57 | Frederic |  |  |  |  |  |
| 2668 | 648.2.2 | CT3 part of Stage 3 for IMS Overload Control | 70d? | 2012-09-05 A | 2012-12-07 A | 100% | 2012-09-05 | 2012-12-07 | 70d? | finish no earlier than 2012-12-07 | C3 | 552h | 552h | IOC | PCG-29 | 29.165 | Alcatel-Lucent | Rel-11 | CP-57 | Adrian |  |  |  |  |  |
| 2669 | 648.2.3 | (IETF) CT part of Stage 3 for IMS Overload Control (soc-overload-control) | 361d? | 2013-07-29 A | 2014-12-09 A | 100% | 2013-07-29 | 2014-12-05 | 359d? | finish no earlier than 2014-12-09 | C1-IETF; C3-IETF | 5776h | 5776h | IOC | PCG-29 | RFC 7339 | Keith Drage | Rel-11 | CP-57 | Frederic |  |  |  |  |  |
| 2670 | 648.2.4 | (IETF) CT part of Stage 3 for IMS Overload Control (soc-overload-rate-control) | 361d? | 2013-07-29 A | 2014-12-09 A | 100% | 2013-07-29 | 2014-12-05 | 359d? | finish no earlier than 2014-12-09 | C1-IETF; C3-IETF | 5776h | 5776h | IOC | PCG-29 | RFC 7415 | Keith Drage | Rel-11 | CP-57 | Frederic |  |  |  |  |  |
| 2671 | 648.2.5 | (IETF) CT part of Stage 3 for IMS Overload Control (RFC 7200) | 234d? | 2013-07-29 A | 2014-06-13 A | 100% | 2013-07-29 | 2014-06-13 | 234d? | finish no earlier than 2014-06-13 | C1-IETF; C3-IETF | 3744h | 3744h | IOC | PCG-29 | RFC 7200 (was draft-ietf-soc-load-control-event-package) | Keith Drage | Rel-11 | CP-57 | Frederic |  |  |  |  |  |
| 2672 | 649 | Rel-11 Security small Enhancements | 336d? | 2011-06-08 A | 2012-09-12 A | 100% | 2011-06-08 | 2012-09-12 | 336d? | finish no earlier than 2012-09-12 | S3 | 2680h | 2680h | SEC11 | PCG-27 |  |  | Rel-11 | SP-52 | Mirko | SEC11 |  |  |  |  |
| 2673 | 650 | Lawful Interception in the 3GPP Rel-11 | 272d? | 2011-06-10 A | 2012-06-20 A | 100% | 2011-06-10 | 2012-06-20 | 272d? | finish no earlier than 2012-06-20 | S3 | 2176h | 2176h | LI11 | PCG-27 | 33.106, 33.107, 33.108 | PIDS, Alcatel-Lucent | Rel-11 | SP-52 | Mirko | LI11 |  |  |  |  |

Notes:
- 2648: RP#58 completed / WI rapporteur e-mail: liwei.qiu@huawei.com
- 2649: RP#58 completed / WI rapporteur e-mail: liwei.qiu@huawei.com
- 2650: ; Stat Rep: RP-141167->RP-141771 1st Apr 15: Compl:40%->100% 1st Apr 15: Stat Rep: RP-141771->RP-150133 / WI rapporteur e-mail: calle.hagenfeldt@ericsson.com
- 2651: Triggered by Rel-11 TR 23.852 FS_SaMOG UID_510061, Rel-8 UID_350027 SAE for support for non-3GPP accesses (defines PMIP-S2a) / WI rapporteur e-mail: Chunhui Zhu (zhu.chunhui@zte.com.cn)
- 2652: SP#55 completed / WI rapporteur e-mail: zhu.chunhui@zte.com.cn
- 2653: - / WI rapporteur e-mail: bruno.landais@alcatel-lucent.com
- 2654: CP#57 completed / WI rapporteur e-mail: bruno.landais@alcatel-lucent.com
- 2655: CP#63 Draft removed from 3GPP documentation
- 2656: CP#56 stopped (no CT1 impact) / WI rapporteur e-mail: bruno.landais@alcatel-lucent.com
- 2657: CP#56 completed / WI rapporteur e-mail: bruno.landais@alcatel-lucent.com
- 2658: CP#58 completed. Triggered by Rel-11 TR 23.850 Study on Roaming Architecture for Voice over IMS with Local Breakout (FS_RAVEL). GSMA CPWP LS_in S5-102806 asked 3GPP SA5 to check if CS voice charging principles also apply to voice over IMS / WI rapporteur e-mail: michele.zarri@telekom.com
- 2659: SP#54 completed / WI rapporteur e-mail: michele.zarri@telekom.com
- 2660: Stage 2/3. SP#57 completed / WI rapporteur e-mail: Gerald.Goermer@nsn.com
- 2661: CP#58 completed / WI rapporteur e-mail: reinhard.lauster@)t-mobile.at
- 2662: CP#58 completed / WI rapporteur e-mail: reinhard.lauster@)t-mobile.at
- 2663: CP#58 completed / WI rapporteur e-mail: reinhard.lauster@)t-mobile.at
- 2664: SP#57 Stage 2 completed. Moved Rel-12=>Rel-11 as CT finished Stage 3. Linked to UID_410041 Study on IMS Evolution (TR 23.812). Solutions from IETF SOC WG and existing 3GPP procedures to be re-used if possible & backward compatibility ensured / WI rapporteur e-mail: Antoine MOUQUET, YU Qing
- 2665: SP#57 completed. Moved Rel-12=>Rel-11 as CT finished Stage 3. / WI rapporteur e-mail: antoine.mouquet@orange-ftgroup.com, YU Qing
- 2666: - / WI rapporteur e-mail: Keith Drage
- 2667: CP#58 completed / WI rapporteur e-mail: Keith Drage
- 2668: CP#58 completed / WI rapporteur e-mail: Keith Drage
- 2669: in RFC Ed-queue. Dec.14: 75->100. Mar15: impacted spec updated (was draft-ietf-soc-overload-control). Jun 15: RFC 7339 (was draft-ietf-soc-overload-control) / WI rapporteur e-mail: Keith Drage
- 2670: Submitted to IESG for publication. Dec14: 50->90%. Mar15: 100%. Impacted RFC updated (was draft-ietf-soc-overload-rate-control). Jun 15: RFC 7415 (was draft-ietf-soc-overload-rate-control) / WI rapporteur e-mail: Keith Drage
- 2671: CP#64 completed / WI rapporteur e-mail: Keith Drage
- 2672: SEC11 is an umbrella Feature for Security related TEI11 type of changes that are not part of any other dedicated feature
- 2673: Stage 1/2/3. SP#56 completed / WI rapporteur e-mail: Koen Jaspers (k.b.jaspers@minjus.nl), terry.jacobson@alcatel-lucent.com

| ID | WBS | Task | Duration | Start | Finish | Complete | Baseline start | Baseline finish | Baseline duration | Constraint | Resources | Work | Actual work | Acronym | PCG approved | WI rapporteur name | Release | TSG approved | MCC resp | Acronym_3GU_Export | Status Report | Special Focus Doc |
| --- | --- | --- | --- | --- | --- | --- | --- | --- | --- | --- | --- | --- | --- | --- | --- | --- | --- | --- | --- | --- | --- | --- |
| 2674 | 651 | **ZUC EEA3 and EIA3 (new Encryption & Integrity EPS security Algorithms)** | 857d? | 2009-06-04 A | 2012-09-07 A | 100% | 2009-06-04 | 2012-09-07 | 857d? |  | S3; R5 | 19488h | 19488h | EEA3_EIA3 | PCG-23 | CATR | Rel-11 | SP-44 | Mirko | EEA3_EIA3 |  |  |
| 2675 | 651.1 | ZUC EEA3 and EIA3 | 663d? | 2009-06-04 A | 2011-12-14 A | 100% | 2009-06-04 | 2011-12-14 | 663d? | finish no earlier than 2011-09-21 | S3 | 5288h | 5288h | EEA3_EIA3 | PCG-23 | CATR | Rel-11 | SP-44 | Mirko |  |  |  |
| 2676 | 651.2 | Conformance Test Aspects – ZUC (EEA3 and EIA3 Encryption & Integrity EPS security Algorithms) | 61d? | 2012-06-18 A | 2012-09-07 A | 100% | 2012-06-18 | 2012-09-07 | 61d? | finish no earlier than 2013-03-01 | R5 | 488h | 488h | EEA3_EIA3_UEConTest | PCG-29 | CATR | Rel-11 | RP-56 | Ingbert | EEA3_EIA3_UEConTest | RP-120968 |  |
| 2677 | 652 | Specification of Protection against Unsolicited Communication for IMS (produced TR-only) | 456d? | 2010-06-10 A | 2012-03-07 A | 100% | 2010-06-10 | 2012-03-07 | 456d? | finish no earlier than 2012-03-07 | S3 | 3640h | 3640h | SPUCI | PCG-25 | NEC | Rel-11 | SP-48 | Mirko | SPUCI |  |  |
| 2678 | 653 | H(e)NB security features for UE mobility scenarios (Stage 2) | 252d? | 2011-03-23 A | 2012-03-07 A | 100% | 2011-03-23 | 2012-03-07 | 252d? | finish no earlier than 2012-03-07 | S3 | 2008h | 2008h | HNB_mob_Sec | PCG-26 | Huawei | Rel-11 | SP-51 | Mirko | HNB_mob_Sec |  | HNB |
| 2679 | 654 | **Generic Bootstrapping Architecture (GBA) extensions for re-use of SIP Digest credentials** | 203d? | 2011-12-02 A | 2012-09-07 A | 100% | 2011-12-02 | 2012-09-07 | 203d? |  | S3; C4; C1 | 11824h | 11824h | GBA-ext | PCG-28 | Nokia | Rel-11 | SP-54 | Mirko | GBA-ext |  |  |
| 2680 | 654.1 | Stage 2 for GBA extensions for re-use of SIP Digest credentials | 61d? | 2011-12-14 A | 2012-03-07 A | 100% | 2011-12-14 | 2012-03-07 | 61d? | finish no earlier than 2012-02-28 | S3 | 488h | 488h | GBA-ext | PCG-28 | Nokia | Rel-11 | SP-54 | Mirko |  |  |  |
| 2681 | 654.2 | **Stage 3 for GBA extensions for re-use of SIP Digest credentials** | 203d? | 2011-12-02 A | 2012-09-07 A | 100% | 2011-12-02 | 2012-09-07 | 203d? |  | C4; C1 | 6464h | 6464h | GBA-ext-St3 | PCG-28 | Alcatel-Lucent | Rel-11 | CP-54 | Kimmo | GBA-ext-St3 |  |  |
| 2682 | 654.2.1 | CT4 part of Stage 3 for GBA extensions for re-use of SIP Digest credentials | 203d? | 2011-12-02 A | 2012-09-07 A | 100% | 2011-12-02 | 2012-09-07 | 203d? | finish no earlier than 2012-09-07 | C4 | 1608h | 1608h | GBA-ext-St3 | PCG-28 | Alcatel-Lucent | Rel-11 | CP-54 | Kimmo |  |  |  |
| 2683 | 654.2.2 | CT1 part of Stage 3 for GBA extensions for re-use of SIP Digest credentials | 202d? | 2011-12-05 A | 2012-09-07 A | 100% | 2011-12-05 | 2012-09-07 | 202d? | finish no earlier than 2012-09-07 | C1 | 1608h | 1608h | GBA-ext-St3 | PCG-28 | Alcatel-Lucent | Rel-11 | CP-54 | Frederic |  |  |  |
| 2684 | 655 | Extensions of Acoustic Test Specifications in TS 26.131 and TS 26.132 | 332d? | 2011-06-08 A | 2012-09-12 A | 100% | 2011-06-08 | 2012-09-12 | 332d? | finish no earlier than 2012-09-12 | S4 | 2648h | 2648h | Ext_ATS | PCG-27 | Orange, Qualcomm | Rel-11 | SP-52 | Paolo | Ext_ATS |  |  |
| 2685 | 656 | **Enhancements to Multimedia: PSS, MMS, and MBMS Enhancements and Performance Improvements** | 397d? | 2011-09-07 A | 2013-03-06 A | 100% | 2011-09-07 | 2013-03-06 | 397d? |  | S4 | 10928.6h | 10928.6h | EMM | PCG-27 | Qualcomm | Rel-11 | SP-53 | Paolo | EMM |  |  |
| 2686 | 656.1 | Enhancement to FEC for MBMS | 386d? | 2011-09-21 A | 2013-03-06 A | 100% | 2011-09-21 | 2013-03-06 | 386d? | finish no earlier than 2013-03-06 | S4 | 3048h | 3048h | EMM-EFEC | PCG-27 | Qualcomm | Rel-11 | SP-53 | Paolo | EMM-EFEC |  |  |
| 2687 | 656.2 | Download Delivery Enhancements for MBMS | 325d? | 2011-09-21 A | 2012-12-12 A | 100% | 2011-09-21 | 2012-12-12 | 325d? | finish no earlier than 2012-12-12 | S4 | 2576.59h | 2576.59h | EMM-DDE | PCG-27 | Qualcomm | Rel-11 | SP-53 | Paolo | EMM-DDE |  |  |
| 2688 | 656.3 | IMS-based PSS and MBMS Streaming Synchronization Enhancements | 268d? | 2011-09-07 A | 2012-09-12 A | 100% | 2011-09-07 | 2012-09-12 | 268d? | finish no earlier than 2012-09-12 | S4 | 2128h | 2128h | EMM-IPME | PCG-27 | InterDigital Communications | Rel-11 | SP-53 | Paolo | EMM-IPME |  |  |
| 2689 | 657 | Mobile 3D Video Coding | 71d? | 2012-06-07 A | 2012-09-12 A | 100% | 2012-06-07 | 2012-09-12 | 71d? | finish no earlier than 2012-09-12 | S4 | 560h | 560h | M3DV | PCG-29 | Orange | Rel-11 | SP-56 | Paolo | M3DV |  |  |
| 2690 | 658 | **Rel-11 Operations, Administration, Maintenance and Provisioning (OAM&P)** | 519d? | 2011-03-23 A | 2013-03-07 A | 100% | 2011-03-23 | 2013-03-06 | 519d? |  | S5 | 39394.5h | 39394.5h | OAM11 | PCG-26 |  | Rel-11 | SP-51 | Mirko | OAM11 |  |  |
| 2691 | 658.1 | **Rel-11 Network Infrastructure Management** | 519d? | 2011-03-23 A | 2013-03-07 A | 100% | 2011-03-23 | 2013-03-06 | 519d? |  | S5 | 8256h | 8256h | OAM11-NIM | PCG-26 |  | Rel-11 | SP-51 | Mirko | OAM11-NIM |  |  |
| 2692 | 658.1.1 | IRP framework enhancements to support Management of Converged Networks | 515d? | 2011-03-23 A | 2013-03-07 A | 100% | 2011-03-23 | 2013-03-06 | 515d? | finish no earlier than 2013-03-06 | S5 | 4104h | 4104h | OAM-FMC-IRP | PCG-26 | Nokia Siemens Networks, Ericsson | Rel-11 | SP-51 | Mirko | OAM-FMC-IRP |  |  |
| 2693 | 658.2 | **Rel-11 Performance Management** | 458d? | 2011-03-23 A | 2012-12-12 A | 100% | 2011-03-23 | 2012-12-12 | 458d? |  | S5 | 14530.5h | 14530.5h | OAM11-PM | PCG-26 |  | Rel-11 | SP-51 | Mirko | OAM11-PM |  |  |
| 2694 | 658.2.1 | IMS Performance Management enhancements | 252d? | 2011-03-23 A | 2012-03-07 A | 100% | 2011-03-23 | 2012-03-07 | 252d? | finish no earlier than 2012-09-12 | S5 | 2010.52h | 2010.52h | OAM-ePM-IMS | PCG-26 | ZTE | Rel-11 | SP-51 | Mirko | OAM-ePM-IMS |  |  |
| 2695 | 658.2.2 | Enhanced Management of UE based network performance measurements | 455d? | 2011-03-23 A | 2012-12-12 A | 100% | 2011-03-23 | 2012-12-12 | 455d? | finish no earlier than 2012-12-12 | S5 | 3624h | 3624h | OAM-ePM-UE | PCG-26 | Huawei, Ericsson, Nokia Siemens Networks | Rel-11 | SP-51 | Mirko | OAM-ePM-UE |  |  |
| 2696 | 658.2.3 | CN performance measurements enhancement | 334d? | 2011-06-08 A | 2012-09-12 A | 100% | 2011-06-08 | 2012-09-12 | 334d? | finish no earlier than 2012-09-12 | S5 | 2648h | 2648h | OAM-ePM-CN | PCG-27 | China Mobile | Rel-11 | SP-52 | Mirko | OAM-ePM-CN |  |  |
| 2697 | 658.2.4 | Management of Carrier Aggregation for LTE | 325d? | 2011-09-21 A | 2012-12-12 A | 100% | 2011-09-21 | 2012-12-12 | 325d? | finish no earlier than 2012-12-12 | S5 | 2584h | 2584h | OAM-CA | PCG-27 | Nokia Siemens Networks, Ericsson | Rel-11 | SP-53 | Mirko | OAM-CA |  | CA |

Notes:
- 2674: RP#57 completed testing / WI rapporteur e-mail: Yuan Qi (yuanqi@catr.cn)
- 2675: SP#53 completed new EPS algorithms e.g. for China / Impacted TSs and TRs: 33.401, New (35.221, 35.222, 35.223, 35.924) / WI rapporteur e-mail: Yuan Qi (yuanqi@catr.cn)
- 2676: RP#57 completed. Testing for SA3 TSs 33.401, new (35.221, 35.222, 35.223) / Impacted TSs and TRs: 36.523-1, 36.523-2, 36.523-3 / WI rapporteur e-mail: Ms Jun Chen (chenjun@catr.cn)
- 2677: SP#55 completed (No normative work). TR 33.838v200 for Approval & abandoned new TS 33.237. Continuation of Rel-9 UID_410027/410029. Builds on TR 33.937 Study of Mechanisms for PUCI / Impacted TSs and TRs: New TR 33.838, abandoned New TS 33.237 / WI rapporteur e-mail: Anand R. Prasad (anand@bq.jp.nec.com)
- 2678: SP#55 completed. Add HeNB Security extensions to Extended H(e)NB Features (EHNBF) UID_450053 / Impacted TSs and TRs: 33.320 / WI rapporteur e-mail: Marcus Wong (mwong@huawei.com)
- 2679: Stage 2/3. CP#57 completed / WI rapporteur e-mail: Silke.Holtmanns@nokia.com
- 2680: SP#55 completed / Impacted TSs and TRs: 33.220 / WI rapporteur e-mail: Silke.Holtmanns@nokia.com
- 2681: CP#57 completed / Impacted TSs and TRs: Stage 3 / WI rapporteur e-mail: jean-jacques.trottin@alcatel-lucent.com
- 2682: CP#57 completed / Impacted TSs and TRs: 29.109 / WI rapporteur e-mail: jean-jacques.trottin@alcatel-lucent.com
- 2683: CP#57 completed / Impacted TSs and TRs: 24.109 / WI rapporteur e-mail: jean-jacques.trottin@alcatel-lucent.com
- 2684: SP#57 completed / Impacted TSs and TRs: 26.131, 26.132 / WI rapporteur e-mail: stephane.ragot@orange-ftgroup.com, Andre Schevciw (aschevci@qualcomm.com)
- 2685: Stage 3. SP#59 completed / Impacted TSs and TRs: 26.140, 26.234, 26.247, New TR 26.951=>26.851 / WI rapporteur e-mail: Nikolai Leung (nleung@qualcomm.com)
- 2686: SP#59 completed / Impacted TSs and TRs: 26.346, new TR 26.947 / WI rapporteur e-mail: Thomas Stockhammer (c_tstock@qualcomm.com)
- 2687: SP#58 completed / Impacted TSs and TRs: 26.346, new TR 26.951=>26.851 / WI rapporteur e-mail: Nikolai Leung (nleung@qualcomm.com)
- 2688: SP#58 completed / Impacted TSs and TRs: 26.237, new TR 26.951=>26.851 / WI rapporteur e-mail: hang.liu@interdigital.com
- 2689: SP#57 completed. Triggered by UID_520036 Rel-11 Study on Mobile 3D Video Coding (FS_M3DVC) TR 26.905. / Impacted TSs and TRs: 26.140, 26.234, 26.244, 26.245, 26.247, 26.346, 26.430, 26.905 / WI rapporteur e-mail: gilles.teniou@orange.com
- 2690: OAM11 is an umbrella Feature also for OAM&P related TEI11 type of changes that are not part of any other dedicated feature/WI
- 2691: -
- 2692: SP#59 completed. Triggered by SA5 Studies TR 32.833, 32.828, 32.831 / Impacted TSs and TRs: 32.101/103/150, new (28.620/621/622/623/624/625/626/627/628/629/631/632/633/651/652/653/654/655/656/657/658/659/661/662/663/671/672/673/674/675/676/701/702/703/704/705/706/707/708/709/731/732/733/734/735/736/751/752/753, 32.107/156/157/853/854 / WI rapporteur e-mail: thomas.tovinger@ericsson.com, olaf.pollakowski@nsn.com
- 2693: -
- 2694: SP#55 completed / Impacted TSs and TRs: 32.409 / WI rapporteur e-mail: guo.wenjie1@zte.com.cn
- 2695: SP#58 completed / Impacted TSs and TRs: 32.421, 32.422, 32.423, 32.441, 32.442, 32.446 / WI rapporteur e-mail: Zou Lan (zlan@huawei.com), ulf.hubinette@ericsson.com, gyula.bodog@nsn.com
- 2696: SP#57 completed / Impacted TSs and TRs: 32.406, 32.407, 32.426 / WI rapporteur e-mail: Liang Shuangchun (liangshuangchun@cmdi.chinamobile.com), Li Jian (lijian@chinamobile.com)
- 2697: SP#58 completed. Updated WID SP-110636=>SP-120776. Stage 2 in Rel-10 RAN Feature UID_460007 Carrier Aggregation for LTE (LTE_CA) / Impacted TSs and TRs: 32.425 / WI rapporteur e-mail: yizhi.yao@nsn.com, per.elmdahl@ericsson.com

| ID | WBS | Task | Type | Duration | Start | Finish | Complete | Baseline start | Baseline finish | Baseline duration | Constraint | Resources | Work | Actual work | Acronym | PCG approved | Release | TSG approved | MCC resp | Special Focus Doc | Acronym_3GU_Export | WI rapporteur name | WI rapporteur e-mail |
| --- | --- | --- | --- | --- | --- | --- | --- | --- | --- | --- | --- | --- | --- | --- | --- | --- | --- | --- | --- | --- | --- | --- | --- |
| 2698 | 658.3 | **Rel-11 Self-Organizing Networks (SON) - OAM aspects** |  | 519d? | 2011-03-23 A | 2013-03-06 A | 100% | 2011-03-23 | 2013-03-06 | 519d? |  | S5 | 12456h | 12456h | OAM11-SON | PCG-26 | Rel-11 | SP-51 | Mirko | SON | OAM11-SON |  |  |
| 2699 | 658.3.1 | UTRAN Self-Organizing Networks (SON) management |  | 388d? | 2011-03-23 A | 2012-09-12 A | 100% | 2011-03-23 | 2012-09-12 | 388d? | finish no earlier than 2012-09-12 | S5 | 3088h | 3088h | OAM-SON-UTRAN | PCG-26 | Rel-11 | SP-51 | Mirko | SON | OAM-SON-UTRAN | Huawei | kai.zhangkai@huawei.com |
| 2700 | 658.3.2 | LTE Self-Organizing Networks (SON) coordination management |  | 387d? | 2011-09-21 A | 2013-03-06 A | 100% | 2011-09-21 | 2013-03-06 | 387d? | finish no earlier than 2013-03-06 | S5 | 3072h | 3072h | OAM-SON-LTE_COORD | PCG-27 | Rel-11 | SP-53 | Mirko | SON | OAM-SON-LTE_COORD | Huawei, Nokia Siemens Networks | kai.zhangkai@huawei.com, clemens.suerbaum@nsn.com |
| 2701 | 658.3.3 | Inter-RAT Energy Saving Management |  | 269d? | 2011-12-07 A | 2012-12-12 A | 100% | 2011-12-07 | 2012-12-12 | 269d? | finish no earlier than 2012-12-12 | S5 | 2144h | 2144h | OAM-IRAT-ESM | PCG-28 | Rel-11 | SP-54 | Mirko | SON | OAM-IRAT-ESM | Nokia Siemens Networks, Huawei | clemens.suerbaum@nsn.com, xiahaitao@huawei.com |
| 2702 | 659 | **Rel-11 Charging Management small Enhancements** |  | 717d? | 2010-03-25 A | 2012-12-12 A | 100% | 2010-03-25 | 2012-12-12 | 717d? |  | S5 | 11528h | 11528h | CH11 | PCG-26 | Rel-11 | SP-51 | Mirko |  | CH11 |  |  |
| 2703 | 659.1 | Add solutions for Rc - reference point within the Online Charging System (OCS) |  | 392d? | 2010-03-25 A | 2011-09-21 A | 100% | 2010-03-25 | 2011-09-21 | 392d? | finish no earlier than 2011-08-26 | S5 | 3120h | 3120h | CH-Rc | PCG-24 | Rel-11 | SP-47 | Mirko |  | CH-Rc | Huawei | shan.mingjun@huawei.com |
| 2704 | 659.2 | Charging for Policy Enhancements for Sponsored Connectivity and Coherent Access to Policy related Data Bases |  | 135d? | 2011-03-21 A | 2011-09-21 A | 100% | 2011-03-21 | 2011-09-21 | 135d? | finish no earlier than 2011-09-21 | S5 | 1064h | 1064h | PEST-CH | PCG-26 | Rel-11 | SP-51 | Mirko |  | PEST-CH | Ericsson | patrik.teppo@@ericsson.com |
| 2705 | 659.3 | Unification of Charging session from SIP AS and SRVCC functions in IMS |  | 203d? | 2012-03-07 A | 2012-12-12 A | 100% | 2012-03-07 | 2012-12-12 | 203d? | finish no earlier than 2012-12-12 | S5 | 1608h | 1608h | UCHIMS_AS-SRVCC | PCG-28 | Rel-11 | SP-55 | Mirko |  | UCHIMS_AS-SRVCC | Alcatel-Lucent | maryse.gardella@alcatel-lucent.com |
| 2706 | 660 | **Transit Inter Operator Identifier for IMS Interconnection Charging in multi operator environment** |  | 432d? | 2010-10-27 A | 2012-06-15 A | 100% | 2010-10-27 | 2012-06-15 | 432d? |  | S5; S1; C1 | 15921.1h | 15921.1h | IOI_IMS_CH | PCG-26 | Rel-11 | SP-51 | Mirko |  | IOI_IMS_CH | Deutsche Telekom | matthias.seibel@telekom.de |
| 2707 | 660.1 | Stage 1 for Transit Inter Operator Identifier for IMS Interconnection Charging in multi operator environment |  | 237d? | 2010-10-27 A | 2011-09-21 A | 100% | 2010-10-27 | 2011-09-21 | 237d? |  | S1 | 1896h | 1896h | IOI_IMS_CH | PCG-26 | Rel-11 | SP-51 | Dionisio |  |  | Deutsche Telekom | matthias.seibel@telekom.de |
| 2708 | 660.2 | Stage 2/3 SA5 part of Transit Inter Operator Identifier for IMS Interconnection Charging in multi operator environment |  | 187d? | 2010-10-27 A | 2011-12-07 A | 100% | 2010-10-27 | 2011-12-07 | 187d? | finish no earlier than 2012-03-21 | S5 | 1488h | 1488h | IOI_IMS_CH | PCG-26 | Rel-11 | SP-51 | Mirko |  |  | Deutsche Telekom | matthias.seibel@telekom.de |
| 2709 | 660.3 | Stage 3 for Transit Inter Operator Identifier for IMS Interconnection Charging in multi operator environment |  | 273d? | 2011-06-07 A | 2012-06-15 A | 100% | 2011-06-07 | 2012-06-15 | 273d? | finish no earlier than 2012-06-01 | C1 | 2169.09h | 2169.09h | IOI_IMS_CH | PCG-27 | Rel-11 | CP-52 | Frederic |  |  | Deutsche Telekom | martin.huelsemann@telekom.de] |
| 2710 | 661 | **User Data Convergence - Data Model** |  | 647d? | 2010-03-25 A | 2012-09-07 A | 100% | 2010-03-25 | 2012-09-07 | 647d? |  | C4; S1 | 22984h | 22984h | UDC_DM | PCG-25 | Rel-11 | CP-48 | Kimmo |  | UDC_DM | Telecom Italia | mauro.ficaccio@telecomitalia.it |
| 2711 | 661.1 | Stage 1 for UDC Data Model |  | 392d? | 2010-03-25 A | 2011-09-21 A | 100% | 2010-03-25 | 2011-09-21 | 392d? | finish no earlier than 2010-06-10 | S1 | 3136h | 3136h | UDC_DM | PCG-25 | Rel-11 | CP-48 | Alain |  |  | Telecom Italia | mauro.ficaccio@telecomitalia.it |
| 2712 | 661.2 | TR on User Data Convergence (UDC) Data Model |  | 593d? | 2010-06-04 A | 2012-09-07 A | 100% | 2010-06-04 | 2012-09-07 | 593d? | finish no earlier than 2012-09-07 | C4 | 4736h | 4736h | UDC_DM | PCG-25 | Rel-11 | CP-48 | Kimmo |  |  | Telecom Italia | mauro.ficaccio@telecomitalia.it |
| 2713 | 661.3 | User Data Convergence (UDC) Data Model |  | 596d? | 2010-06-04 A | 2012-09-07 A | 100% | 2010-06-04 | 2012-09-07 | 596d? | finish no earlier than 2012-09-07 | C4 | 4760h | 4760h | UDC_DM | PCG-25 | Rel-11 | CP-48 | Kimmo |  |  | Telecom Italia | mauro.ficaccio@telecomitalia.it |
| 2714 | 662 | Definition of the UICC Application for Hosting Party Module |  | 327d? | 2011-03-18 A | 2012-06-15 A | 100% | 2011-03-18 | 2012-06-15 | 327d? | finish no earlier than 2012-06-15 | C6 | 2608h | 2608h | HPM_UICC | PCG-26 | Rel-11 | CP-51 | Xavier |  | HPM_UICC | Gemalto | Denis.Lheriteau@gemalto.com |
| 2715 | 663 | Usability improvement of Inter-IMS Network to Network Interface (II-NNI) specification for inter-connection by means of Option Item list |  | 273d? | 2011-06-07 A | 2012-06-15 A | 100% | 2011-06-07 | 2012-06-15 | 273d? | finish no earlier than 2012-06-01 | C3 | 2169.56h | 2169.56h | NNI_OI | PCG-27 | Rel-11 | CP-52 | Adrian |  | NNI_OI | NTT | arai.kenjiro@lab.ntt.co.jp |
| 2716 | 664 | **enhanced Nodes Restoration for EPC (Stage 2/3)** |  | 668d? | 2011-06-03 A | 2013-12-06 A | 100% | 2011-06-03 | 2013-12-06 | 668d? |  | C4; C1; C3; IETF | 27728h | 27728h | eNR_EPC | PCG-27 | Rel-11 | CP-52 | Kimmo |  | eNR_EPC | ZTE | lu.fei1@zte.com.cn |
| 2717 | 664.1 | CT4 part of enhanced Nodes Restoration for EPC |  | 402d? | 2011-06-03 A | 2012-12-07 A | 100% | 2011-06-03 | 2012-12-07 | 402d? | finish no earlier than 2012-12-07 | C4 | 3192h | 3192h | eNR_EPC | PCG-27 | Rel-11 | CP-52 | Kimmo |  |  | ZTE | lu.fei1@zte.com.cn |
| 2718 | 664.2 | (IETF) CT4 part of enhanced Nodes Restoration for EPC (RFC 7077) |  | 266d? | 2012-12-07 A | 2013-12-06 A | 100% | 2012-12-07 | 2013-12-06 | 266d? | finish no earlier than 2013-12-06 | C4-IETF | 2104h | 2104h | eNR_EPC | PCG-30 | Rel-11 | CP-58 | Kimmo |  |  | Lionel Morand | Lionel Morand |
| 2719 | 664.3 | CT1 part of enhanced Nodes Restoration for EPC |  | 66d? | 2011-12-02 A | 2012-03-02 A | 100% | 2011-12-02 | 2012-03-02 | 66d? | finish no earlier than 2012-06-15 | C1 | 528h | 528h | eNR_EPC | PCG-28 | Rel-11 | CP-54 | Frederic |  |  | ZTE | lu.fei1@zte.com.cn |
| 2720 | 664.4 | CT3 part of enhanced Nodes Restoration for EPC |  | 67d? | 2012-09-10 A | 2012-12-07 A | 100% | 2012-09-10 | 2012-12-07 | 67d? | finish no earlier than 2012-12-07 | C3 | 528h | 528h | eNR_EPC | PCG-29 | Rel-11 | CP-57 | Adrian |  |  | ZTE | lu.fei1@zte.com.cn |
| 2721 | 665 | **Reference Location Information (Stage 3)** |  | 78d? | 2011-06-03 A | 2011-09-16 A | 100% | 2011-06-03 | 2011-09-16 | 78d? |  | C4; C1 | 1860.74h | 1860.74h | RLI | PCG-27 | Rel-11 | CP-52 | Kimmo |  | RLI | Huawei | susan.shishufeng@Huawei.com |
| 2722 | 665.1 | CT4 part of Reference Location Information (Stage 3) | milestone | 0d? | 2011-06-03 A | 2011-06-03 A | 100% | 2011-06-03 | 2011-06-03 | 0d? | finish no earlier than 2011-06-03 | C4 |  |  | RLI | PCG-27 | Rel-11 | CP-52 | Kimmo |  |  | Huawei | susan.shishufeng@Huawei.com |
| 2723 | 665.2 | CT1 part of Reference Location Information (Stage 3) |  | 78d? | 2011-06-03 A | 2011-09-16 A | 100% | 2011-06-03 | 2011-09-16 | 78d? | finish no earlier than 2011-08-30 | C1 | 612.74h | 612.74h | RLI | PCG-27 | Rel-11 | CP-52 | Frederic |  |  | Huawei | susan.shishufeng@Huawei.com |

Notes:
- 2698: -
- 2699: SP#57 completed. Updated WID SP-110518=>SP-120552 / Impacted TSs and TRs: UTRA 32.405, 32.500, 32.511, 32.521, 32.522, 32.526, 32.642, 32.646
- 2700: SP#59 completed / Impacted TSs and TRs: LTE 32.425, 32.500, 32.521, 32.522, 32.526, 32.762, 32.766
- 2701: SP#58 completed. Triggered by Rel-11 TR 32.834 (Study on OAM aspects of inter-RAT Energy Saving) UID_510045. Needs coordination with RAN WGs / Impacted TSs and TRs: 32.405, 32.551, 32.522, 32.526, 32.642, 32.646, 32.762, 32.766
- 2702: CH11 is an umbrella Feature also for OAM&P related TEI11 type of changes that are not part of any other dedicated feature/WI / Impacted TSs and TRs: TR 30.821
- 2703: SP#53 completed. Stage 3 (Stage 1 in 22.115). Triggered by Rel-10 TR 32.825 SA5 Study on Rc Reference Point Functionalities and Message Flows (UID_410044) / Impacted TSs and TRs: 32.296, 32.299
- 2704: SP#53 completed. Stage 3 / Impacted TSs and TRs: 32.251, 32.298, 32.299
- 2705: Stage 2/3. SP#58 completed / Impacted TSs and TRs: 32.260, 32.275, 32.298, 32.299
- 2706: Stage 2/3. CP#56 completed. Stage 1 in SA1 22.115
- 2707: SP#53 completed under IPXS / Impacted TSs and TRs: 22.115
- 2708: SP#54 completed / Impacted TSs and TRs: 32.240, 32.260, 32.298, 32.299
- 2709: CP#56 completed / Impacted TSs and TRs: 24.229
- 2710: CP#57 completed. SP#48 Stage 1 completed as Rel-10
- 2711: SP#53 completed under Rel-10 UDC / Impacted TSs and TRs: 22.101
- 2712: CP#57 completed / Impacted TSs and TRs: new TR 29.935
- 2713: CP#57 completed / Impacted TSs and TRs: 29.335
- 2714: CP#56 completed / Impacted TSs and TRs: 31.102, New TS 31.104
- 2715: CP#56 completed. Stage 3 (No architectural change, specify the list of selectable items related to control plane signalling directly for the same architecture) / Impacted TSs and TRs: 29.165
- 2716: Triggered by DRAFT TR 23.857 Study on EPC Nodes Restoration UID_490014
- 2717: CP#58 completed / Impacted TSs and TRs: 23.007, 23.008, 23.018, 29.274, 29.275
- 2718: CP#62 completed / Impacted TSs and TRs: RFC 7077 (was draft-ietf-netext-update-notifications)
- 2719: CP#55 completed / Impacted TSs and TRs: 29.118
- 2720: CP#58 completed / Impacted TSs and TRs: 29.212
- 2721: CP#53 completed. Stage 2 clause C.1.1 of SA2 TS 23.167 CR#0182 (WI code: TEI11)
- 2722: CP#52 completed / Impacted TSs and TRs: 23.008, 29.228, 29.328, 29.329
- 2723: CP#53 completed / Impacted TSs and TRs: 24.229

| ID | WBS | Task | Duration | Start | Finish | Complete | Baseline start | Baseline finish | Baseline duration | Constraint | Resources | Work | Actual work | Acronym | PCG approved | WI rapporteur name | WI rapporteur e-mail | Release | TSG approved | MCC resp | Acronym_3GU_Export | PCG stopped | TSG stopped | Special Focus Doc |
| --- | --- | --- | --- | --- | --- | --- | --- | --- | --- | --- | --- | --- | --- | --- | --- | --- | --- | --- | --- | --- | --- | --- | --- | --- |
| 2724 | 666 | **IMS Stage 3 IETF Protocol Alignment - phase 5** | 868d? | 2011-06-07 A | 2014-09-12 A | 100% | 2011-06-07 | 2014-12-05 | 927d? |  | C1; C3; IETF | 34260h | 34260h | IMSProtoc5 | PCG-27 | Alcatel-Lucent | keith.drage@alcatel-lucent.com | Rel-11 | CP-52 | Frederic | IMSProtoc5 |  |  |  |
| 2725 | 666.1 | CT1 part of IMS Stage 3 IETF Protocol Alignment - phase 5 | 333d? | 2011-06-07 A | 2012-09-07 A | 100% | 2011-06-07 | 2012-09-07 | 333d? | finish no earlier than 2012-09-07 | C1 | 2648h | 2648h | IMSProtoc5 | PCG-27 | Alcatel-Lucent | keith.drage@alcatel-lucent.com | Rel-11 | CP-52 | Frederic |  |  |  |  |
| 2726 | 666.2 | (IETF) CT1 part of IMS Stage 3 IETF Protocol Alignment - phase 5 (RFC 7315) | 356.5d? | 2013-03-01 A | 2014-09-12 A | 100% | 2013-03-01 | 2014-12-05 | 416.5d? | finish no earlier than 2014-09-12 | C1-IETF | 2812h | 2812h | IMSProtoc5 | PCG-30 | Roland Jesske | Roland Jesske | Rel-11 | CP-59 | Frederic |  |  |  |  |
| 2727 | 666.3 | (IETF) CT1 part of IMS Stage 3 IETF Protocol Alignment - phase 5 (RFC 7135) | 203d? | 2013-09-06 A | 2014-06-13 A | 100% | 2013-09-06 | 2014-06-13 | 203d? | finish no earlier than 2014-06-13 | C1-IETF | 1608h | 1608h | IMSProtoc5 | PCG-31 | Roland Jesske | Roland Jesske | Rel-11 | CP-61 |  |  |  |  |  |
| 2728 | 666.4 | CT3 part of IMS Stage 3 IETF Protocol Alignment - phase 5 | 333d? | 2011-06-07 A | 2012-09-07 A | 100% | 2011-06-07 | 2012-09-07 | 333d? | finish no earlier than 2012-09-07 | C3 | 2648h | 2648h | IMSProtoc5 | PCG-27 | Alcatel-Lucent | keith.drage@alcatel-lucent.com | Rel-11 | CP-52 | Adrian |  |  |  |  |
| 2729 | 666.5 | Deleted - (IETF) CT3 part of IMS Stage 3 IETF Protocol Alignment - phase 5 (avasarala-dispatch-comm-div-notification) | 466d? | 2012-12-07 A | 2014-09-12 A | 100% | 2012-12-07 | 2014-12-05 | 526d? | finish no earlier than 2014-09-12 | C3-IETF | 3712h | 3712h | IMSProtoc5 | PCG-30 | Andrew Allen | Andrew Allen | Rel-11 | CP-58 | Adrian |  | PCG-33 | CP-65 |  |
| 2730 | 667 | **Service Identification for RRC Improvements in GERAN (Stage 2/3)** | 258d? | 2011-09-19 A | 2012-09-07 A | 100% | 2011-09-19 | 2012-09-07 | 258d? |  | S2; C4; C3; G2 | 16216h | 16216h | SIRIG | PCG-27 | China Mobile | zhanghao@chinamobile.com | Rel-11 | GP-51 | Maurice | SIRIG |  |  |  |
| 2731 | 667.1 | Stage 2 for Service Identification for RRC Improvements in GERAN | 61d? | 2012-06-18 A | 2012-09-07 A | 100% | 2012-06-18 | 2012-09-07 | 61d? | finish no earlier than 2012-09-07 | S2 | 480h | 480h | SIRIG | PCG-29 |  |  | Rel-11 | SP-56 | Maurice |  |  |  |  |
| 2732 | 667.2 | **CN aspects of Service Identification for RRC Improvements in GERAN** | 203d? | 2011-12-02 A | 2012-09-07 A | 100% | 2011-12-02 | 2012-09-07 | 203d? |  | C4; C3 | 5464h | 5464h | SIRIG | PCG-28 | China Mobile | zhanghao@chinamobile.com | Rel-11 | CP-54 | Kimmo |  |  |  |  |
| 2733 | 667.2.1 | CT4 part of CN aspects of Service Identification for RRC Improvements in GERAN | 203d? | 2011-12-02 A | 2012-09-07 A | 100% | 2011-12-02 | 2012-09-07 | 203d? | finish no earlier than 2012-09-07 | C4 | 1608h | 1608h | SIRIG | PCG-28 | China Mobile | zhanghao@chinamobile.com | Rel-11 | CP-54 | Kimmo |  |  |  |  |
| 2734 | 667.2.2 | Deleted - CT3 part of CN aspects of Service Identification for RRC Improvements in GERAN | 77d? | 2012-03-02 A | 2012-06-15 A | 100% | 2012-03-02 | 2012-06-15 | 77d? | finish no earlier than 2012-06-01 | C3 | 608h | 608h | SIRIG | PCG-28 | China Mobile | zhanghao@chinamobile.com | Rel-11 | CP-55 | Adrian |  | PCG-29 | CP-56 |  |
| 2735 | 667.3 | GERAN2 part of Service Identification for RRC Improvements in GERAN | 252d? | 2011-09-19 A | 2012-08-31 A | 100% | 2011-09-19 | 2012-08-31 | 252d? | finish no earlier than 2012-08-31 | G2 | 2016h | 2016h | SIRIG | PCG-27 | China Mobile, Huawei | Juan Deng, Yang Zhao | Rel-11 | GP-51 | Gert |  |  |  |  |
| 2736 | 668 | **SAE Protocol Development - Phase 2** | 259d? | 2011-09-16 A | 2012-09-07 A | 100% | 2011-09-16 | 2012-09-07 | 259d? |  | C1 | 6168h | 6168h | SAES2 | PCG-27 | Nokia Siemens Networks | robert.zaus@nsn.com | Rel-11 | CP-53 | Frederic | SAES2 |  |  |  |
| 2737 | 668.1 | SAE Protocol Development (Stage 3) - Phase 2 | 259d? | 2011-09-16 A | 2012-09-07 A | 100% | 2011-09-16 | 2012-09-07 | 259d? | finish no earlier than 2012-09-07 | C1 | 2048h | 2048h | SAES2 | PCG-27 | Nokia Siemens Networks | robert.zaus@nsn.com | Rel-11 | CP-53 | Frederic |  |  |  |  |
| 2738 | 668.2 | CS Fallback in EPS - Phase 2 | 259d? | 2011-09-16 A | 2012-09-07 A | 100% | 2011-09-16 | 2012-09-07 | 259d? | finish no earlier than 2012-09-07 | C1 | 2048h | 2048h | SAES2-CSFB | PCG-27 | Nokia Siemens Networks | robert.zaus@nsn.com | Rel-11 | CP-53 | Frederic | SAES2-CSFB |  |  |  |
| 2739 | 669 | **GCSMSC and GCR Redundancy for VGCS/VBS (Stage 2/3)** | 258d? | 2011-09-19 A | 2012-09-07 A | 100% | 2011-09-19 | 2012-09-07 | 258d? |  | C1 | 5680h | 5680h | RT_VGCS_Red | PCG-27 | Nokia Siemens Networks | robert.zaus@nsn.com | Rel-11 | CP-53 | Frederic | RT_VGCS_Red |  |  |  |
| 2740 | 669.1 | CT1 part of GCSMSC and GCR Redundancy for VGCS/VBS | 258d? | 2011-09-19 A | 2012-09-07 A | 100% | 2011-09-19 | 2012-09-07 | 258d? | finish no earlier than 2012-09-07 | C1 | 2048h | 2048h | RT_VGCS_Red | PCG-27 | Nokia Siemens Networks | robert.zaus@nsn.com | Rel-11 | CP-53 | Frederic |  |  |  |  |
| 2741 | 669.2 | Deleted - CT4 part of GCSMSC and GCR Redundancy for VGCS/VBS | 197d? | 2011-09-19 A | 2012-06-15 A | 100% | 2011-09-19 | 2012-06-15 | 197d? | finish no earlier than 2012-06-15 | C4 | 1568h | 1568h | RT_VGCS_Red | PCG-27 | Nokia Siemens Networks | robert.zaus@nsn.com | Rel-11 | CP-53 | Kimmo |  | PCG-29 | CP-56 |  |
| 2742 | 670 | Support of RFC 6140 in IMS | 203d? | 2011-12-02 A | 2012-09-07 A | 100% | 2011-12-02 | 2012-09-07 | 203d? | finish no earlier than 2012-09-07 | C1 | 1608h | 1608h | GINI | PCG-28 | Deutsche Telekom | martin.huelsemann@telekom.de | Rel-11 | CP-54 | Frederic | GINI |  |  |  |
| 2743 | 671 | **Enhancements for Multimedia Priority Service (MPS) – Gateway Control Priority** | 203d? | 2011-12-02 A | 2012-09-07 A | 100% | 2011-12-02 | 2012-09-07 | 203d? |  | C4; C3 | 6464h | 6464h | eMPS_Gateway | PCG-28 | Telcordia | Viqar Shaikh | Rel-11 | CP-54 | Kimmo | eMPS_Gateway |  |  | Public Safety (I-A) |
| 2744 | 671.1 | CT4 part of Enhancements for Multimedia Priority Service (MPS) – Gateway Control Priority | 202d? | 2011-12-02 A | 2012-09-07 A | 100% | 2011-12-02 | 2012-09-07 | 202d? | finish no earlier than 2012-09-07 | C4 | 1608h | 1608h | eMPS_Gateway | PCG-28 | Telcordia | Viqar Shaikh | Rel-11 | CP-54 | Kimmo |  |  |  | Public Safety (I-A) |
| 2745 | 671.2 | CT3 part of Enhancements for Multimedia Priority Service (MPS) – Gateway Control Priority | 202d? | 2011-12-02 A | 2012-09-07 A | 100% | 2011-12-02 | 2012-09-07 | 202d? | finish no earlier than 2012-09-07 | C3 | 1608h | 1608h | eMPS_Gateway | PCG-28 | Telcordia | Viqar Shaikh | Rel-11 | CP-54 | Adrian |  |  |  | Public Safety (I-A) |
| 2746 | 672 | Inter-IMS Network to Network Interface (II-NNI) enhancements: SIP timers applicability (Stage 3) | 138d? | 2012-03-02 A | 2012-09-07 A | 100% | 2012-03-02 | 2012-09-07 | 138d? | start no earlier than 2012-03-02 | C3 | 1088h | 1088h | NNI_timers | PCG-28 | Telecom Italia | antonio.ascolese@telecomitalia.it | Rel-11 | CP-55 | Adrian | NNI_timers |  |  |  |
| 2747 | 673 | AT commands for Universal Resource Identifier (URI) support | 188d? | 2012-06-15 A | 2013-03-01 A | 100% | 2012-06-15 | 2013-03-01 | 188d? | finish no earlier than 2013-03-01 | C1 | 1496h | 1496h | ATURI | PCG-29 | Intel | frank.kowalewski@intel.com | Rel-11 | CP-56 | Frederic | ATURI |  |  |  |
| 2748 | 674 | PS Additional Number (Stage 3) | 62d? | 2012-06-15 A | 2012-09-07 A | 100% | 2012-06-15 | 2012-09-07 | 62d? | finish no earlier than 2012-09-07 | C4 | 488h | 488h | PSAN | PCG-29 | Deutsche Telekom | Yvette.koza@t-mobile.at | Rel-11 | CP-56 | Kimmo | PSAN |  |  |  |
| 2749 | 675 | Generic IMS User Group Over Sh | 62d? | 2012-06-15 A | 2012-09-07 A | 100% | 2012-06-15 | 2012-09-07 | 62d? | finish no earlier than 2012-09-07 | C4 | 488h | 488h | GenUG_Sh | PCG-29 | Alcatel-Lucent | jean-jacques.trottin@alcatel-lucent.com | Rel-11 | CP-56 | Kimmo | GenUG_Sh |  |  |  |

Notes:
- 2724: CP#57 completed
- 2725: CP#57 completed / Impacted TSs and TRs: 23.218, 24.229, 24.930
- 2726: CP#65 completed / Impacted TSs and TRs: RFC 7315 (was draft-drage-sipping-rfc3455bis), draft-mohali-dispatch-originating-cdiv-parameter
- 2727: CP#64 completed / Impacted TSs and TRs: RFC 7135 (was draft-polk-local-emergency-rph-namespace)
- 2728: CP#57 completed / Impacted TSs and TRs: 29.163, 29.165
- 2729: CP#64 Draft removed from 3GPP documentation / Impacted TSs and TRs: draft-avasarala-dispatch-comm-div-notification
- 2730: TSG#57, GP#55 completed. CT defined a generic solution (not only for GERAN) / Impacted TSs and TRs: GERAN
- 2731: SP#57 completed / Impacted TSs and TRs: 23.060, 23.251
- 2732: CP#57 completed
- 2733: CP#57 completed / Impacted TSs and TRs: 29.281
- 2734: CP#56 stopped (SA2 decided NO CT3 impact) / Impacted TSs and TRs: 29.212
- 2735: GP#55 completed. GP#51 approved WID / Impacted TSs and TRs: 48.018
- 2736: CP#57 completed. Stage 3 continuation of Rel-8 Feature SAES (3GPP System Architecture Evolution Specification - Evolved Packet System) UID_320005
- 2737: CP#57 completed / Impacted TSs and TRs: 23.122, 24.008, 24.167, 24.229, 24.301, 24.302, 24.303, 24.304, 24.305, 24.312, 29.018, 29.118
- 2738: CP#57 completed / Impacted TSs and TRs: 23.122, 24.008, 24.167, 24.229, 24.301, 24.302, 24.303, 24.304, 24.305, 24.312, 29.018, 29.118
- 2739: CP#57 completed. Stage 2/3 adding a CN internal functionality, not affecting Voice Group Call Service (VGCS)/VBS as perceived by service subscriber. Hence, no Stage 1 impact for VGCS/VBS (42.068, 42.069) / Impacted TSs and TRs: Stage 2/3
- 2740: CP#57 completed / Impacted TSs and TRs: 43.068, 43.069
- 2741: CP#56 stopped (no CT4 impact) / Impacted TSs and TRs: 29.002
- 2742: CP#57 completed. Stage 3. Support procedures and protocol extensions in RFC6140 "Registration for Multiple Phone Numbers in SIP" to IMS for complex UEs. Ensure co-existence with NGCN IP-PBX registration procedures already defined in IMS. / Impacted TSs and TRs: 24.229
- 2743: CP#57 completed. Stage 3. Stage 1 for MPS in 22.153. Details of any MGW actions for priority needs to be further studied within the scope of this WI. / Impacted TSs and TRs: Stage 3
- 2744: CP#57 completed / Impacted TSs and TRs: 23.333, 23.334, 29.232, 29.238, 29.332, 29.333, 29.334
- 2745: CP#57 completed / Impacted TSs and TRs: 29.162, 29.163, 29.292
- 2746: CP#57 completed / Impacted TSs and TRs: 29.165
- 2747: CP#59 completed. Define new AT cmd for URI addresses for IMS services (eg VoLTE). 27.007(AT cmd to control MT functions and GSM/UMTS/LTE network services from TE), 27.005(AT commands for SMS). Currently address types for AT cmd based on dialling# / Impacted TSs and TRs: 27.005, 27.007
- 2748: CP#57 completed. Stage 1 in Rel-11 SA1 TS 22.101 clause 17.7.3 (No Stage 2 needed since no architecture impact) / Impacted TSs and TRs: 23.003, 23.008, 29.002, 29.272, 29.230
- 2749: CP#57 completed / Impacted TSs and TRs: 29.364

| ID | WBS | Task | Duration | Start | Finish | Complete | Baseline start | Baseline finish | Baseline duration | Constraint | Resources | Work | Actual work | Acronym | PCG approved | WI rapporteur name | WI rapporteur e-mail | Release | TSG approved | MCC resp | Acronym_3GU_Export | PCG stopped | TSG stopped | Status Report |
| --- | --- | --- | --- | --- | --- | --- | --- | --- | --- | --- | --- | --- | --- | --- | --- | --- | --- | --- | --- | --- | --- | --- | --- | --- |
| 2750 | 676 | **IMS Operator Determined Call Barring** | 205d? | 2012-09-07 A | 2013-06-14 A | 100% | 2012-09-07 | 2013-06-14 | 205d? |  | C1; C4 | 5411.54h | 5411.54h | IODB | PCG-29 | Orange | Youssef.Chadli@Orange.com | Rel-11 | CP-57 | Frederic | IODB |  |  |  |
| 2751 | 676.1 | CT1 part of IMS Operator Determined Call Barring | 203d? | 2012-09-10 A | 2013-06-14 A | 100% | 2012-09-10 | 2013-06-14 | 203d? | finish no earlier than 2013-06-14 | C1 | 1616h | 1616h | IODB | PCG-29 | Orange | Youssef.Chadli@Orange.com | Rel-11 | CP-57 | Frederic |  |  |  |  |
| 2752 | 676.2 | CT4 part of IMS Operator Determined Call Barring | 69d? | 2012-09-07 A | 2013-03-12 A | 100% | 2012-09-07 | 2013-03-12 | 69d? | finish no earlier than 2012-12-07 | C4 | 515.54h | 515.54h | IODB | PCG-29 | Orange | Youssef.Chadli@Orange.com | Rel-11 | CP-57 | Kimmo |  |  |  |  |
| 2753 | 677 | **Enhanced T.38 FAX support (Stage 3)** | 69d? | 2012-09-06 A | 2012-12-07 A | 100% | 2012-09-06 | 2012-12-07 | 69d? |  | C3; C1; C4 | 2728h | 2728h | MMTel_T.38_FAX | PCG-29 | NEC | Naoaki Suzuki (n-suzuki@en.jp.nec.com) | Rel-11 | CP-57 | Adrian | MMTel_T.38_FAX |  |  |  |
| 2754 | 677.1 | CT3 part of Enhanced T.38 FAX support | 68d? | 2012-09-07 A | 2012-12-07 A | 100% | 2012-09-07 | 2012-12-07 | 68d? | finish no earlier than 2012-12-07 | C3 | 528h | 528h | MMTel_T.38_FAX | PCG-29 | NEC | Naoaki Suzuki (n-suzuki@en.jp.nec.com) | Rel-11 | CP-57 | Adrian |  |  |  |  |
| 2755 | 677.2 | CT1 part of Enhanced T.38 FAX support | 67d? | 2012-09-07 A | 2012-12-07 A | 100% | 2012-09-07 | 2012-12-07 | 67d? | finish no earlier than 2012-12-07 | C1 | 528h | 528h | MMTel_T.38_FAX | PCG-29 | NEC | Naoaki Suzuki (n-suzuki@en.jp.nec.com) | Rel-11 | CP-57 | Frederic |  |  |  |  |
| 2756 | 677.3 | CT4 part of Enhanced T.38 FAX support | 2d? | 2012-09-06 A | 2012-09-07 A | 100% | 2012-09-06 | 2012-09-07 | 2d? | finish no earlier than 2012-12-07 | C4 | 16h | 16h | MMTel_T.38_FAX | PCG-29 | NEC | Naoaki Suzuki (n-suzuki@en.jp.nec.com) | Rel-11 | CP-57 | Kimmo |  |  |  |  |
| 2757 | 678 | **Deleted - Enhancement of the Protocols for SMS over SGs (Stage 3)** | 142d? | 2011-12-02 A | 2012-06-15 A | 100% | 2011-12-02 | 2012-06-15 | 142d? |  | C4; C1 | 5664h | 5664h | PROTOC_SMS_SGs | PCG-28 | Alcatel-Lucent | jean-jacques.trottin@alcatel-lucent.com | Rel-11 | CP-54 | Kimmo | PROTOC_SMS_SGs | PCG-29 | CP-56 |  |
| 2758 | 678.1 | Deleted - TR Study on enhancement of protocols for SMS service over SGs | 142d? | 2011-12-02 A | 2012-06-15 A | 100% | 2011-12-02 | 2012-06-15 | 142d? | finish no earlier than 2012-06-15 | C4 | 1128h | 1128h | PROTOC_SMS_SGs | PCG-28 | Alcatel-Lucent | jean-jacques.trottin@alcatel-lucent.com | Rel-11 | CP-54 | Kimmo |  | PCG-29 | CP-56 |  |
| 2759 | 678.2 | Deleted - CT4 part of Enhancement of the Protocols for SMS over SGs | 142d? | 2011-12-02 A | 2012-06-15 A | 100% | 2011-12-02 | 2012-06-15 | 142d? | finish no earlier than 2012-06-15 | C4 | 1128h | 1128h | PROTOC_SMS_SGs | PCG-28 | Alcatel-Lucent | jean-jacques.trottin@alcatel-lucent.com | Rel-11 | CP-54 | Kimmo |  | PCG-29 | CP-56 |  |
| 2760 | 678.3 | Deleted - CT1 part of Enhancement of the Protocols for SMS over SGs | 142d? | 2011-12-02 A | 2012-06-15 A | 100% | 2011-12-02 | 2012-06-15 | 142d? | finish no earlier than 2012-06-15 | C1 | 1136h | 1136h | PROTOC_SMS_SGs | PCG-28 | Alcatel-Lucent | jean-jacques.trottin@alcatel-lucent.com | Rel-11 | CP-54 | Frederic |  | PCG-29 | CP-56 |  |
| 2761 | 679 | **Full Support of Multi-Operator Core Network by GERAN** | 584d? | 2011-03-04 A | 2013-05-17 A | 100% | 2011-03-04 | 2013-05-17 | 584d? |  | G2; S2; C1 | 31293.3h | 31293.3h | Full_MOCN-GERAN | PCG-26 | Alcatel-Lucent | michel.robert@alcatel-lucent.com | Rel-11 | GP-49 | Paolo | Full_MOCN-GERAN |  |  |  |
| 2762 | 679.1 | GERAN part of Full Support of Multi-Operator Core Network by GERAN | 584d? | 2011-03-04 A | 2013-05-17 A | 100% | 2011-03-04 | 2013-05-17 | 584d? | finish no earlier than 2013-06-07 | G2 | 4656.4h | 4656.4h | Full_MOCN-GERAN | PCG-26 | Alcatel-Lucent | michel.robert@alcatel-lucent.com | Rel-11 | GP-49 | Gert |  |  |  |  |
| 2763 | 679.2 | Stage 2 for Full Support of Multi-Operator Core Network by GERAN | 160.8d? | 2011-06-08 A | 2012-03-07 A | 100% | 2011-06-08 | 2012-03-07 | 160.8d? | finish no earlier than 2012-03-07 | S2 | 1278.4h | 1278.4h | Full_MOCN-GERAN | PCG-26 | Alcatel-Lucent | nicolas.drevon@alcatel-lucent.com | Rel-11 | GP-49 | Maurice |  |  |  |  |
| 2764 | 679.3 | **CN Stage 3 for Full Support of Multi-Operator Core Network by GERAN** | 403d? | 2011-06-03 A | 2012-12-07 A | 100% | 2011-06-03 | 2012-12-07 | 403d? |  | C1; C4 | 9838.51h | 9838.51h | Full_MOCN-GERAN | PCG-26 | Alcatel-Lucent | jennifer.liu@alcatel-lucent.com | Rel-11 | GP-49 | Frederic |  |  |  |  |
| 2765 | 679.3.1 | CT1 part of CN Stage 3 for Full Support of Multi-Operator Core Network by GERAN | 362.8d? | 2011-06-03 A | 2012-12-07 A | 100% | 2011-06-03 | 2012-12-07 | 362.8d? | finish no earlier than 2012-12-07 | C1 | 2886.51h | 2886.51h | Full_MOCN-GERAN | PCG-26 | Alcatel-Lucent | jennifer.liu@alcatel-lucent.com | Rel-11 | GP-49 | Frederic |  |  |  |  |
| 2766 | 679.3.2 | CT4 part of CN Stage 3 for Full Support of Multi-Operator Core Network by GERAN | 64d? | 2012-06-13 A | 2012-09-07 A | 100% | 2012-06-13 | 2012-09-07 | 64d? | finish no earlier than 2012-09-07 | C4 | 504h | 504h | Full_MOCN-GERAN | PCG-29 | Alcatel-Lucent | michel.robert@alcatel-lucent.com | Rel-11 | GP-54 | Kimmo |  |  |  |  |
| 2767 | 679.4 | Stage 2 for Gateway Core Network Sharing for GERAN | 192d? | 2012-06-18 A | 2013-03-06 A | 100% | 2012-06-18 | 2013-03-06 | 192d? | finish no earlier than 2013-03-06 | S2 | 1504h | 1504h | Full_MOCN-GERAN-GWCN | PCG-29 | Vodafone | chris.pudney@vodafone.com | Rel-11 | SP-56 | Maurice | Full_MOCN-GERAN-GWCN |  |  |  |
| 2768 | 680 | **Medium range/local area requirements for multicarrier BTS** | 264d? | 2011-11-25 A | 2012-11-23 A | 100% | 2011-11-25 | 2012-11-23 | 264d? |  | G1 | 6296h | 6296h | MRLA | PCG-28 | Ericsson | Eric Nordström | Rel-11 | GP-52 | Paolo | MRLA |  |  |  |
| 2769 | 680.1 | Core part: Medium range/local area requirements for multicarrier BTS | 263d? | 2011-11-25 A | 2012-11-23 A | 100% | 2011-11-25 | 2012-11-23 | 263d? | finish no earlier than 2012-11-23 | G1 | 2096h | 2096h | MRLA-Core | PCG-28 | Ericsson | Eric Nordström | Rel-11 | GP-52 | Paolo | MRLA-Core |  |  |  |
| 2770 | 680.2 | Perf. part: Medium range/local area requirements for multicarrier BTS | 262d? | 2011-11-28 A | 2012-11-23 A | 100% | 2011-11-28 | 2012-11-23 | 262d? | finish no earlier than 2012-11-23 | G1 | 2088h | 2088h | MRLA-Perf | PCG-28 | Ericsson | Eric Nordström | Rel-11 | GP-52 | Paolo | MRLA-Perf |  |  |  |
| 2771 | 681 | Domain Specific Access Control in GERAN | 131d? | 2012-03-05 A | 2012-08-31 A | 100% | 2012-03-05 | 2012-08-31 | 131d? | finish no earlier than 2012-08-31 | G2 | 1048h | 1048h | GDSAC | PCG-28 | Vodafone | chris.pudney@vodafone.com | Rel-11 | GP-53 | Gert | GDSAC |  |  |  |
| 2772 | 682 | **Extending 850 MHz Upper Band (814 – 849 MHz)** | 589d? | 2010-12-10 A | 2013-03-01 A | 100% | 2010-12-10 | 2013-03-01 | 589d? |  | R4; R2; R3; R5 | 33352h | 33352h | e850_UB | PCG-26 | Sprint | John.J.Humbert@Sprint.com | Rel-11 | RP-50 | Issam | e850_UB |  |  |  |
| 2773 | 682.1 | Core part: Extending 850 MHz Upper Band (814 – 849 MHz) | 324d? | 2010-12-10 A | 2012-03-02 A | 100% | 2010-12-10 | 2012-03-02 | 324d? | finish no earlier than 2012-03-02 | R4; R2; R3 | 7776h | 7776h | e850_UB-Core | PCG-26 | Sprint | John.J.Humbert@Sprint.com | Rel-11 | RP-50 | Issam | e850_UB-Core |  |  | RP-120075 |
| 2774 | 682.2 | Perf. part: Extending 850 MHz Upper Band (814 – 849 MHz) | 324d? | 2010-12-10 A | 2012-03-02 A | 100% | 2010-12-10 | 2012-03-02 | 324d? | finish no earlier than 2012-03-02 | R4 | 2592h | 2592h | e850_UB-Perf | PCG-26 | Sprint | John.J.Humbert@Sprint.com | Rel-11 | RP-50 | Issam | e850_UB-Perf |  |  | RP-120076 |
| 2775 | 682.3 | Test part: Extending 850 MHz Upper Band (814 – 849 MHz) | 517d? | 2011-03-18 A | 2013-03-01 A | 100% | 2011-03-18 | 2013-03-01 | 517d? | finish no earlier than 2013-03-01 | R5 | 4136h | 4136h | e850_UB-UEConTest | PCG-26 | Sprint | John.J.Humbert@Sprint.com | Rel-11 | RP-51 | Ingbert | e850_UB-UEConTest |  |  | RP-130043 |

Notes:
- 2750: LS_in C4-121615 GSMA IREG RILTE concluded that TS 22.041 clause 5.4 Stage 1 requirements are not covered by stage 3 specifications
- 2751: CP#60 completed. Handling of premium rate numbers remained OPEN in Rel-11 (shifted to Rel-12). CP-130384 LS_out sent to SA1 / GSMA informing this TSG CT decision. / Impacted TSs and TRs: New TS 24.315
- 2752: CP#58 completed / Impacted TSs and TRs: 23.008 , 23.015 , 29.328 , 29.329 , 29.364
- 2753: CP#58 completed. Linked to Rel-8 Feature: IMS Multimedia Telephony Service (IMS-MMTel) UID_7038. SA1 added FAX stage 1 requirement only in Rel-10 under TEI10 to TS 22.173 (CR#0064)
- 2754: CP#58 completed / Impacted TSs and TRs: 29.163
- 2755: CP#58 completed / Impacted TSs and TRs: 24.229
- 2756: CP#57 completed / Impacted TSs and TRs: 29.332
- 2757: CP#56 stopped. Reason: Protocols for SMS over SGs is replaced by the SIMTC SMS in MME solution (as solution not only for MTC user but for general subscribers) / Impacted TSs and TRs: Stage 3
- 2758: CP#56 stopped (abandonned new TR 29.818) / Impacted TSs and TRs: new TR 29.818
- 2759: CP#56 stopped (abandonned new TS 29.218 Diameter based protocols for SMS service over SGs) / Impacted TSs and TRs: 29.305, new TS 29.218
- 2760: CP#56 stopped / Impacted TSs and TRs: 23.040, 24.011, 43.068
- 2761: GP#58 completed. GP#49 approved WID. Standardization of management of MOCN supporting MSs/UES in CP-150GERAN. Continuation of Rel-10 MOCN-GERAN UID_490001 / Impacted TSs and TRs: GERAN
- 2762: GP#58 completed. GP#49 approved WID / Impacted TSs and TRs: 44.018, 44.060, 45.002, 45.008, 48.008, 48.018
- 2763: SP#55 completed / Impacted TSs and TRs: 23.251, 23.272
- 2764: CP#58 completed
- 2765: CP#58 completed / Impacted TSs and TRs: 24.008
- 2766: CP#57 completed / Impacted TSs and TRs: 23.003
- 2767: SP#59 completed. (23.251CR0062R2 as TEI11. TS 23.251 specifies both MOCN and GWCN for E-UTRAN and UTRAN, but GWCN is not yet supported on GERAN. Extend Full_MOCN-GERAN to also cover GWCN GERAN / Impacted TSs and TRs: 23.251
- 2768: GP#56 completed. GP#52 approved WID / Impacted TSs and TRs: GERAN
- 2769: Stage 3. GP#56 completed. GP#52 approved WID / Impacted TSs and TRs: 45.005
- 2770: Test spec. GP#56 completed. GP#52 approved WID / Impacted TSs and TRs: 51.021
- 2771: GP#55 completed. GP#53 approved WID. Work is dependent upon Full_MOCN-GERAN (UID_510001) / Impacted TSs and TRs: GERAN 44.018
- 2772: Stage 3. Triggered by R4 Rel-10 LTE TR 37.806 Study on Extending 850 MHz (UID_440016) / Impacted TSs and TRs: UTRA, LTE
- 2773: RP#55 completed / Impacted TSs and TRs: 25.101, 25.104, 25.113, 25.133, 25.141, 25.461, 25.466, 36.101, 36.104, 36.113, 36.124, 36.133, 36.141, 36.307, 36.331, 37.104, 37.113, 37.141
- 2774: RP#55 completed / Impacted TSs and TRs: 25.101, 25.104, 25.113, 25.133, 25.141, 25.461, 25.466, 36.101, 36.104, 36.124, 36.133, 36.141, 36.307, 36.331, 37.104, 37.113, 37.141
- 2775: RP#59 completed / Impacted TSs and TRs: 34.108, 34.121-1, 34.121-2, 34.123-1, 34.123-2, 34.123-3, 36.508, 36.521-1, 36.521-2, 36.521-3, 36.523-1, 36.523-2, 36.523-3

| ID | WBS | Task | Duration | Start | Finish | Complete | Baseline start | Baseline finish | Baseline duration | Constraint | Resources | Work | Actual work | Acronym | PCG approved | WI rapporteur name | WI rapporteur e-mail | Release | TSG approved | MCC resp | Special Focus Doc | Acronym_3GU_Export | Status Report |
| --- | --- | --- | --- | --- | --- | --- | --- | --- | --- | --- | --- | --- | --- | --- | --- | --- | --- | --- | --- | --- | --- | --- | --- |
| 2776 | 683 | **Further Self Optimizing Networks (SON) enhancements** | 325d? | 2011-09-19 A | 2012-12-07 A | 100% | 2011-09-19 | 2012-12-07 | 325d? |  | R3; R2 | 10400h | 10400h | SONenh2_LTE_UTRA | PCG-27 | Nokia Siemens Networks | krzysztof.kordybach@nsn.com | Rel-11 | RP-53 | Juha | SON | SONenh2_LTE_UTRA |  |
| 2777 | 683.1 | Core part: Further Self Optimizing Networks (SON) enhancements | 325d? | 2011-09-19 A | 2012-12-07 A | 100% | 2011-09-19 | 2012-12-07 | 325d? | finish no earlier than 2012-12-07 | R3; R2 | 5200h | 5200h | SONenh2_LTE_UTRA-Core | PCG-27 | Nokia Siemens Networks | krzysztof.kordybach@nsn.com | Rel-11 | RP-53 | Juha | SON | SONenh2_LTE_UTRA-Core | RP-121557 |
| 2778 | 684 | **Enhancement of Minimization of Drive Tests for E-UTRAN and UTRAN** | 590d? | 2011-09-19 A | 2013-12-06 A | 100% | 2011-09-19 | 2013-12-06 | 590d? |  | R2; R1; R3; R4; R5 | 35608h | 35608h | eMDT_UMTSLTE | PCG-27 | MediaTek | Johan Johansson | Rel-11 | RP-53 | Yong-Jun |  | eMDT_UMTSLTE |  |
| 2779 | 684.1 | Core part: Enhancement of Minimization of Drive Tests for E-UTRAN and UTRAN | 325d? | 2011-09-19 A | 2012-12-07 A | 100% | 2011-09-19 | 2012-12-07 | 325d? | finish no earlier than 2012-12-07 | R2; R1; R3; R4 | 10400h | 10400h | eMDT_UMTSLTE-Core | PCG-27 | MediaTek | Johan Johansson | Rel-11 | RP-53 | Yong-Jun |  | eMDT_UMTSLTE-Core | RP-121556 |
| 2780 | 684.2 | Test part: Enhancement of Minimization of Drive Tests for E-UTRAN and UTRAN | 202d? | 2013-03-04 A | 2013-12-06 A | 100% | 2013-03-04 | 2013-12-06 | 202d? | finish no earlier than 2013-12-06 | R5 | 1608h | 1608h | eMDT_UMTSLTE-UEConTest | PCG-30 | NTT DoCoMo | masahiro.tamaoki.eu@nttdocomo.com | Rel-11 | RP-59 | Ingbert |  | eMDT_UMTSLTE-UEConTest | RP-131447 |
| 2781 | 685 | **Network Energy Saving for E-UTRAN** | 258d? | 2011-09-19 A | 2012-09-07 A | 100% | 2011-09-19 | 2012-09-07 | 258d? |  | R3; GP | 6224h | 6224h | Netw_Energy_LTE | PCG-27 | China Mobile | yangning@chinamobile.com | Rel-11 | RP-53 | Juha |  | Netw_Energy_LTE |  |
| 2782 | 685.1 | Core part: Network Energy Saving for E-UTRAN | 257d? | 2011-09-19 A | 2012-09-07 A | 100% | 2011-09-19 | 2012-09-07 | 257d? | finish no earlier than 2012-09-07 | R3 | 2056h | 2056h | Netw_Energy_LTE-Core | PCG-27 | China Mobile | yangning@chinamobile.com | Rel-11 | RP-53 | Juha |  | Netw_Energy_LTE-Core | RP-121016 |
| 2783 | 685.2 | GERAN part: Network Energy Saving for E-UTRAN | 5d? | 2012-08-27 A | 2012-08-31 A | 100% | 2012-08-27 | 2012-08-31 | 5d? | finish no earlier than 2012-08-31 | GP | 40h | 40h |  | PCG-29 | Alcatel-Lucent | marguerite.woch@alcatel-lucent.com | Rel-11 | GP-55 | Paolo |  |  |  |
| 2784 | 686 | **E-UTRA medium range and MSR medium range/local area BS class requirements** | 325d? | 2011-09-19 A | 2012-12-07 A | 100% | 2011-09-19 | 2012-12-07 | 325d? |  | R4; G1 | 12432h | 12432h | medBS_class_LTE_MSR | PCG-27 | Ericsson | johan.skold@ericsson.com | Rel-11 | RP-53 | Issam |  | medBS_class_LTE_MSR |  |
| 2785 | 686.1 | Core part: E-UTRA medium range and MSR medium range/local area BS class requirements | 323d? | 2011-09-19 A | 2012-12-07 A | 100% | 2011-09-19 | 2012-12-07 | 323d? | finish no earlier than 2012-12-07 | R4 | 2576h | 2576h | medBS_class_LTE_MSR-Core | PCG-27 | Ericsson | johan.skold@ericsson.com | Rel-11 | RP-53 | Issam |  | medBS_class_LTE_MSR-Core | RP-121558 |
| 2786 | 686.2 | Perf. part: E-UTRA medium range and MSR medium range/local area BS class requirements | 321d? | 2011-09-23 A | 2012-12-07 A | 100% | 2011-09-23 | 2012-12-07 | 321d? | finish no earlier than 2012-12-07 | R4 | 2568h | 2568h | medBS_class_LTE_MSR-Perf | PCG-27 | Ericsson | johan.skold@ericsson.com | Rel-11 | RP-53 | Issam |  | medBS_class_LTE_MSR-Perf | RP-121559 |
| 2787 | 686.3 | GERAN part: E-UTRA medium range and MSR medium range/local area BS class requirements | 261d? | 2011-11-28 A | 2012-11-23 A | 100% | 2011-11-28 | 2012-11-23 | 261d? | finish no earlier than 2012-11-23 | G1 | 2088h | 2088h | medBS_class_LTE_MSR-GERAN | PCG-28 | Ericsson | Eric Nordström | Rel-11 | GP-52 | Paolo |  | medBS_class_LTE_MSR-GERAN |  |
| 2788 | 687 | **RF Requirements for Multi-Band and Multi-Standard Radio (MB-MSR) Base Station** | 553.1d? | 2012-02-06 A | 2014-03-06 A | 100% | 2012-02-06 | 2014-03-06 | 553.1d? |  | R4; G1 | 20915.2h | 20915.2h | MB_MSR_RF | PCG-28 | Huawei | Liu Ye (leo.liuye@huawei.com) | Rel-11 | RP-55 | Issam |  | MB_MSR_RF |  |
| 2789 | 687.1 | Core part: RF Requirements for Multi-Band and Multi-Standard Radio (MB-MSR) Base Station | 223.1d? | 2012-02-06 A | 2012-12-07 A | 100% | 2012-02-06 | 2012-12-07 | 223.1d? | finish no earlier than 2012-12-07 | R4; G1 | 3569.6h | 3569.6h | MB_MSR_RF-Core | PCG-28 | Huawei | Liu Ye (leo.liuye@huawei.com) | Rel-11 | RP-55 | Issam |  | MB_MSR_RF-Core | RP-121985 |
| 2790 | 687.2 | Perf. part: RF Requirements for Multi-Band and Multi-Standard Radio (MB-MSR) Base Station | 531d? | 2012-03-08 A | 2014-03-06 A | 100% | 2012-03-08 | 2014-03-06 | 531d? | finish no earlier than 2014-03-06 | R4; G1 | 8496h | 8496h | MB_MSR_RF-Perf | PCG-28 | Huawei | Liu Ye (leo.liuye@huawei.com) | Rel-11 | RP-55 | Issam |  | MB_MSR_RF-Perf | RP-140064 |
| 2791 | 688 | **Further enhancements to H(e)NB mobility - Part 1** | 129d? | 2012-06-15 A | 2012-12-07 A | 100% | 2012-06-15 | 2012-12-07 | 129d? |  | R3; R2 | 4128h | 4128h | EHNB_enh1 | PCG-29 | Alcatel-Lucent | Martin.Warner@alcatel-lucent.com | Rel-11 | RP-56 | Juha | HNB | EHNB_enh1 |  |
| 2792 | 688.1 | Core part: Further enhancements to H(e)NB mobility - Part 1 | 129d? | 2012-06-15 A | 2012-12-07 A | 100% | 2012-06-15 | 2012-12-07 | 129d? | finish no earlier than 2012-12-07 | R3; R2 | 2064h | 2064h | EHNB_enh1-Core | PCG-29 | Alcatel-Lucent | Martin.Warner@alcatel-lucent.com | Rel-11 | RP-56 | Juha | HNB | EHNB_enh1-Core | RP-121563 |
| 2793 | 689 | **Further enhancements to H(e)NB mobility - Part 2** | 127d? | 2012-06-19 A | 2012-12-07 A | 100% | 2012-06-19 | 2012-12-07 | 127d? |  | R3; R2 | 4064h | 4064h | EHNB_enh2 | PCG-29 | Alcatel-Lucent | Martin.Warner@alcatel-lucent.com | Rel-11 | RP-56 | Juha | HNB | EHNB_enh2 |  |
| 2794 | 689.1 | Core part: Further enhancements to H(e)NB mobility - Part 2 | 127d? | 2012-06-19 A | 2012-12-07 A | 100% | 2012-06-19 | 2012-12-07 | 127d? | finish no earlier than 2012-12-07 | R3; R2 | 2032h | 2032h | EHNB_enh2-Core | PCG-29 | Alcatel-Lucent | Martin.Warner@alcatel-lucent.com | Rel-11 | RP-56 | Juha | HNB | EHNB_enh2-Core | RP-121564 |
| 2795 | 690 | **Network-Based Positioning Support for LTE** | 1391d? | 2009-03-05 A | 2014-06-13 A | 100% | 2009-03-05 | 2014-06-13 | 1391d? |  | R2; R1; R3; R4 | 91464h | 91464h | LCS_LTE-NBPS | PCG-22 | TruePosition | terri.brooks@trueposition.com | Rel-11 | RP-43 | Yong-Jun |  | LCS_LTE-NBPS |  |
| 2796 | 690.1 | Core part: Network-Based Positioning Support for LTE | 1125d? | 2009-03-05 A | 2013-06-12 A | 100% | 2009-03-05 | 2013-06-12 | 1125d? | finish no earlier than 2013-06-12 | R2; R1; R3; R4 | 36000h | 36000h | LCS_LTE-NBPS-Core | PCG-22 | TruePosition | terri.brooks@trueposition.com | Rel-11 | RP-43 | Yong-Jun |  | LCS_LTE-NBPS-Core | RP-130483 |
| 2797 | 690.2 | Perf. part: Network-Based Positioning Support for LTE | 1377d? | 2009-03-24 A | 2014-06-13 A | 100% | 2009-03-24 | 2014-06-13 | 1377d? | finish no earlier than 2014-06-13 | R4 | 11016h | 11016h | LCS_LTE-NBPS-Perf | PCG-22 | TruePosition | terri.brooks@trueposition.com | Rel-11 | RP-43 | Yong-Jun |  | LCS_LTE-NBPS-Perf | RP-140626 |
| 2798 | 691 | **Service continuity improvements for MBMS for LTE** | 993d? | 2010-06-04 A | 2014-03-06 A | 100% | 2010-06-04 | 2014-03-06 | 993d? |  | R2; R3; R5 | 35496h | 35496h | MBMS_LTE_SC | PCG-25 | Huawei | David.Lecompte@huawei.com | Rel-11 | RP-48 | Yong-Jun |  | MBMS_LTE_SC |  |
| 2799 | 691.1 | Core part: Service continuity improvements for MBMS for LTE | 596d? | 2010-06-04 A | 2012-09-07 A | 100% | 2010-06-04 | 2012-09-07 | 596d? | finish no earlier than 2012-09-07 | R2; R3 | 9536h | 9536h | MBMS_LTE_SC-Core | PCG-25 | Huawei | David.Lecompte@huawei.com | Rel-11 | RP-48 | Yong-Jun |  | MBMS_LTE_SC-Core | RP-121001 |
| 2800 | 691.2 | Test part: Service continuity improvements for MBMS for LTE | 266d? | 2013-03-04 A | 2014-03-06 A | 100% | 2013-03-04 | 2014-03-06 | 266d? | finish no earlier than 2014-03-06 | R5 | 2128h | 2128h | MBMS_LTE_SC-UEConTest | PCG-30 | Ericsson | leif.mattisson@ericsson.com | Rel-11 | RP-59 | Ingbert |  | MBMS_LTE_SC-UEConTest | RP-140074 |

Notes:
- 2776: Stage 1/2/3 / Impacted TSs and TRs: UTRA, LTE
- 2777: RP#58 completed / Impacted TSs and TRs: 25.331, 25.401, 25.410, 25.413, 25.423, 25.433, 36.300, 36.331, 36.413, 36.423
- 2778: Stage 2/3 / Impacted TSs and TRs: UTRA, LTE
- 2779: RP#58 completed / Impacted TSs and TRs: 25.133, 25.123, 25.304, 25.331, 25.413, 25.423, 36.133, 36.304, 36.306, 36.331, 36.413, 36.423, 37.320, 36.300
- 2780: RP#62 completed / Impacted TSs and TRs: 34.108, 34.109, 34.123-1, 34.123-2, 34.123-3, 36.508, 36.509, 36.523-1, 36.523-2, 36.523-3
- 2781: Stage 2/3 / Impacted TSs and TRs: LTE, GERAN
- 2782: RP#57 completed. Inter-RAT aspect can affect UTRA and GERAN as well / Impacted TSs and TRs: 25.413, 36.300, 36.413, 36.423
- 2783: GP#55 approved WID and completed. Stage 3. ChangES in CP-150RIM protocol and in SON Transfer RIM application to provide support for Energy Savings Indication feature / Impacted TSs and TRs: 48.018 [Serving GPRS Support Node (SGSN); BSS GPRS protocol (BSSGP)]
- 2784: Stage 3. GERAN BS RF requirements specs need aligned with RAN4 ongoing Rel-11 Feature UID_530037 E-UTRA medium range and MSR medium range/local area BS class requirements (medBS_class_LTE_MSR) / Impacted TSs and TRs: UTRA, LTE, GERAN
- 2785: RP#58 completed. TR 37.809 v200 for Approval / Impacted TSs and TRs: 25.104, 36.104, 37.104, new TR 37.809
- 2786: RP#58 completed / Impacted TSs and TRs: 25.141, 36.141, 37.141
- 2787: GP#56 completed. GP#52 approved WID / Impacted TSs and TRs: 45.005, 51.021
- 2788: - / Impacted TSs and TRs: UTRA, LTE, GERAN
- 2789: RP#58 completed / Impacted TSs and TRs: 25.104, 25.105, 36.104, 37.104, new TR 37.812
- 2790: RP#63 completed / Impacted TSs and TRs: 25.141, 25.142, 36.141, 37.141
- 2791: Stage 2/3. Triggered by FS_EHNB_enh (UTRA, LTE TR 37.803 under AI 12.3.2). Compare also Rel-10 WI HNB_HENB_mob_enh RP-110183 / Impacted TSs and TRs: UTRA, LTE
- 2792: RP#58 completed / Impacted TSs and TRs: 25.413, 25.467, 25.469, 36.300, 36.413, 36.423
- 2793: Stage 2/3. Legacy UE Handling (X2-GW, 20% complete, moved to Rel-12 UID_580030). Triggered by FS_EHNB_enh (UTRA, LTE TR 37.803 under AI 12.3.2) / Impacted TSs and TRs: UTRA, LTE
- 2794: RP#58 completed Legacy UE Handling (X2-GW, 20% complete, moved to Rel-12 UID_580030). Updated WID RP-121147=>RP-121712 / Impacted TSs and TRs: 25.413, 25.467, 25.469, 25.471
- 2795: - / Impacted TSs and TRs: LTE
- 2796: RP#60 completed / Impacted TSs and TRs: 36.214, 36.300, 36.305, 36.401, 36.413, 36.455, new TS (36.111, 36.456, 36.457, 36.458, 36.459)
- 2797: RP#64 completed. TS 36.112v100 for 1-step Approval / Impacted TSs and TRs: 36.111, new TS 36.112
- 2798: - / Impacted TSs and TRs: LTE
- 2799: RP#57 completed / Impacted TSs and TRs: 25.446, 36.300, 36.304, 36.321, 36.322, 36.323, 36.331, 36.440, 36.441, 36.442, 36.443, 36.444, 36.445
- 2800: RP#63 completed / Impacted TSs and TRs: 36.508, 36.523-1, 36.523-2, 36.523-3

| ID | WBS | Task | Duration | Start | Finish | Complete | Baseline start | Baseline finish | Baseline duration | Constraint | Resources | Work | Actual work | Acronym | PCG approved | WI rapporteur name | WI rapporteur e-mail | Release | TSG approved | MCC resp | Acronym_3GU_Export | Status Report | Special Focus Doc |
| --- | --- | --- | --- | --- | --- | --- | --- | --- | --- | --- | --- | --- | --- | --- | --- | --- | --- | --- | --- | --- | --- | --- | --- |
| 2801 | 692 | **Further Enhanced Non CA-based ICIC for LTE** | 991d? | 2011-03-22 A | 2014-12-15 A | 100% | 2011-03-22 | 2014-09-12 | 922d? |  | R1; R2; R3; R4; R5 | 63112h | 63112h | eICIC_enh_LTE | PCG-26 | China Mobile | ShenXiaodong@chinamobile.com | Rel-11 | RP-51 | Patrick | eICIC_enh_LTE |  |  |
| 2802 | 692.1 | Core part: Further Enhanced Non CA-based ICIC for LTE | 456d? | 2011-03-22 A | 2012-12-07 A | 100% | 2011-03-22 | 2012-12-07 | 456d? | finish no earlier than 2012-12-07 | R1; R2; R3; R4 | 14592h | 14592h | eICIC_enh_LTE-Core | PCG-26 | China Mobile | ShenXiaodong@chinamobile.com | Rel-11 | RP-51 | Patrick | eICIC_enh_LTE-Core | RP-121986 |  |
| 2803 | 692.2 | Perf. part: Further Enhanced Non CA-based ICIC for LTE | 715d? | 2011-03-23 A | 2013-12-06 A | 100% | 2011-03-23 | 2013-12-06 | 715d? | finish no earlier than 2013-12-06 | R4 | 5720h | 5720h | eICIC_enh_LTE-Perf | PCG-26 | China Mobile | ShenXiaodong@chinamobile.com | Rel-11 | RP-51 | Issam | eICIC_enh_LTE-Perf | RP-131463 |  |
| 2804 | 692.3 | Test part: Further Enhanced Non CA-based ICIC for LTE | 395d? | 2013-06-15 A | 2014-12-15 A | 100% | 2013-06-18 | 2014-09-12 | 326d? | finish no earlier than 2014-12-15 | R5 | 3160h | 3160h | eICIC_enh_LTE-UEConTest | PCG-31 | ZTE | Carolyn Taylor (carolyn.tayl@zte.com.cn) | Rel-11 | RP-60 | Ingbert | eICIC_enh_LTE-UEConTest | RP-141847 |  |
| 2805 | 693 | **New Band LTE Downlink FDD 716-728 MHz (Band 29, Carrier Aggregation of Band 2 and Band 29 and of Band 4 and Band 29)** | 456d? | 2011-03-22 A | 2012-12-07 A | 100% | 2011-03-22 | 2012-12-07 | 456d? |  | R4 | 10880h | 10880h | LTE_DL_FDD700 | PCG-26 | AT&T | marc.grant@att.com | Rel-11 | RP-51 | Issam | LTE_DL_FDD700 |  | CA |
| 2806 | 693.1 | Core part: New Band LTE Downlink FDD 716-728 MHz (Band 29), Carrier Aggregation of Band 2 and Band 29 and of Band 4 and Band 29 | 453d? | 2011-03-22 A | 2012-12-07 A | 100% | 2011-03-22 | 2012-12-07 | 453d? | finish no earlier than 2012-12-07 | R4 | 3624h | 3624h | LTE_DL_FDD700-Core | PCG-26 | AT&T | marc.grant@att.com | Rel-11 | RP-51 | Issam | LTE_DL_FDD700-Core | RP-121604 |  |
| 2807 | 693.2 | Perf. part: New Band LTE Downlink FDD 716-728 MHz (Band 29), Carrier Aggregation of Band 2 and Band 29 and of Band 4 and Band 29 | 451d? | 2011-03-29 A | 2012-12-07 A | 100% | 2011-03-29 | 2012-12-07 | 451d? | finish no earlier than 2012-12-07 | R4 | 3608h | 3608h | LTE_DL_FDD700-Perf | PCG-26 | AT&T | marc.grant@att.com | Rel-11 | RP-51 | Issam | LTE_DL_FDD700-Perf | RP-121605 |  |
| 2808 | 694 | **LTE RAN Enhancements for Diverse Data Applications** | 657d? | 2011-03-18 A | 2013-09-06 A | 100% | 2011-03-18 | 2013-09-06 | 657d? |  | R2; R5 | 15248h | 15248h | LTE_eDDA | PCG-26 | BlackBerry | Gordon Young (gyoung@rim.com) | Rel-11 | RP-51 | Yong-Jun | LTE_eDDA |  |  |
| 2809 | 694.1 | Core part: LTE RAN Enhancements for Diverse Data Applications | 456d? | 2011-03-18 A | 2012-12-07 A | 100% | 2011-03-18 | 2012-12-07 | 456d? | finish no earlier than 2012-12-07 | R2 | 3648h | 3648h | LTE_eDDA-Core | PCG-26 | BlackBerry | Gordon Young (gyoung@rim.com) | Rel-11 | RP-51 | Yong-Jun | LTE_eDDA-Core | RP-121571 |  |
| 2810 | 694.2 | Test part: LTE RAN Enhancements for Diverse Data Applications | 136d? | 2013-03-04 A | 2013-09-06 A | 100% | 2013-03-04 | 2013-09-06 | 136d? | finish no earlier than 2013-09-06 | R5 | 1088h | 1088h | LTE_eDDA-UEConTest | PCG-30 | BlackBerry | Enikő Sokondár (esokondar@rim.com) | Rel-11 | RP-59 | Ingbert | LTE_eDDA-UEConTest | RP-130946 |  |
| 2811 | 695 | **LTE E850 - Lower Band for Region 2 (non-US), Band 27** | 516d? | 2011-03-23 A | 2013-03-01 A | 100% | 2011-03-23 | 2013-03-01 | 516d? |  | R1; R2; R4; R5 | 28496h | 28496h | LTE_e850_LB | PCG-26 | NII Holdings | bill.shvodian@nii.com | Rel-11 | RP-51 | Patrick | LTE_e850_LB |  |  |
| 2812 | 695.1 | Core part: LTE E850 - Lower Band for Region 2 (non-US), Band 27 | 328d? | 2011-06-15 A | 2012-09-07 A | 100% | 2011-06-15 | 2012-09-07 | 328d? | finish no earlier than 2012-09-07 | R1; R2; R4 | 7872h | 7872h | LTE_e850_LB-Core | PCG-26 | NII Holdings | bill.shvodian@nii.com | Rel-11 | RP-51 | Patrick | LTE_e850_LB-Core | RP-120570 |  |
| 2813 | 695.2 | Perf. part: LTE E850 - Lower Band for Region 2 (non-US), Band 27 | 326d? | 2011-03-23 A | 2012-06-15 A | 100% | 2011-03-23 | 2012-06-15 | 326d? | finish no earlier than 2012-12-07 | R4 | 2608h | 2608h | LTE_e850_LB-Perf | PCG-26 | NII Holdings | bill.shvodian@nii.com | Rel-11 | RP-51 | Issam | LTE_e850_LB-Perf | RP-120571 |  |
| 2814 | 695.3 | Test part: LTE E850 - Lower Band for Region 2 (non-US), Band 27 | 189d? | 2012-06-18 A | 2013-03-01 A | 100% | 2012-06-18 | 2013-03-01 | 189d? | finish no earlier than 2013-03-01 | R5 | 1504h | 1504h | LTE_e850_LB-UEConTest | PCG-29 | NII Holdings | bill.shvodian@nii.com | Rel-11 | RP-56 | Ingbert | LTE_e850_LB-UEConTest | RP-130045 |  |
| 2815 | 696 | **LTE for 700 MHz Digital Dividend** | 538d? | 2011-06-07 A | 2013-06-14 A | 100% | 2011-06-07 | 2013-06-14 | 538d? |  | R4; R2; R3; R5 | 28032h | 28032h | LTE_APAC700 | PCG-27 | Ericsson | olav.queseth@ericsson.com | Rel-11 | RP-52 | Issam | LTE_APAC700 |  |  |
| 2816 | 696.1 | Core part: LTE for 700 MHz Digital Dividend | 273d? | 2011-06-07 A | 2012-06-15 A | 100% | 2011-06-07 | 2012-06-15 | 273d? | finish no earlier than 2012-06-15 | R4; R2; R3 | 6552h | 6552h | LTE_APAC700-Core | PCG-27 | Ericsson | olav.queseth@ericsson.com | Rel-11 | RP-52 | Issam | LTE_APAC700-Core | RP-120572 |  |
| 2817 | 696.2 | Perf. part: LTE for 700 MHz Digital Dividend | 271d? | 2011-06-09 A | 2012-06-15 A | 100% | 2011-06-09 | 2012-06-15 | 271d? | finish no earlier than 2012-06-15 | R4 | 2168h | 2168h | LTE_APAC700-Perf | PCG-27 | Ericsson | olav.queseth@ericsson.com | Rel-11 | RP-52 | Issam | LTE_APAC700-Perf | RP-120573 |  |
| 2818 | 696.3 | Test part: LTE for 700 MHz Digital Dividend | 262d? | 2012-06-18 A | 2013-06-14 A | 100% | 2012-06-18 | 2013-06-14 | 262d? | finish no earlier than 2013-06-14 | R5 | 2096h | 2096h | LTE_APAC700-UEConTest | PCG-29 | Ericsson | fredrik.sundstrom@ericsson.com | Rel-11 | RP-56 | Ingbert | LTE_APAC700-UEConTest | RP-130467 |  |
| 2819 | 697 | **Relays for LTE (part 2)** | 930d? | 2009-12-04 A | 2013-06-14 A | 100% | 2009-12-04 | 2013-06-14 | 930d? |  | R4 | 17496.4h | 17496.4h | LTE_Relay2 | PCG-24 | Ericsson | christian.hoymann@ericsson.com | Rel-11 | RP-46 | Patrick | LTE_Relay2 |  |  |
| 2820 | 697.1 | Core part: Relays for LTE (part 2) | 333d? | 2011-06-07 A | 2012-09-07 A | 100% | 2011-06-07 | 2012-09-07 | 333d? | finish no earlier than 2012-09-07 | R4 | 2656.39h | 2656.39h | LTE_Relay2-Core | PCG-27 | Ericsson | christian.hoymann@ericsson.com | Rel-11 | RP-52 | Issam | LTE_Relay2-Core | RP-121008 |  |
| 2821 | 697.2 | Perf. part: Relays for LTE (part 2) | 925d? | 2009-12-04 A | 2013-06-14 A | 100% | 2009-12-04 | 2013-06-14 | 925d? | finish no earlier than 2013-06-14 | R4 | 7400h | 7400h | LTE_Relay2-Perf | PCG-24 | Ericsson | christian.hoymann@ericsson.com | Rel-11 | RP-46 | Issam | LTE_Relay2-Perf | RP-130487 |  |
| 2822 | 698 | **Signalling and Procedure for Interference Avoidance for in-device coexistence** | 325d? | 2011-09-19 A | 2012-12-07 A | 100% | 2011-09-19 | 2012-12-07 | 325d? |  | R2; R4 | 12976h | 12976h | SPIA_IDC_LTE | PCG-27 | China Mobile | Zhenping HU | Rel-11 | RP-53 | Yong-Jun | SPIA_IDC_LTE |  |  |
| 2823 | 698.1 | Core part: Signalling and Procedure for Interference Avoidance for in-device coexistence | 325d? | 2011-09-19 A | 2012-12-07 A | 100% | 2011-09-19 | 2012-12-07 | 325d? | finish no earlier than 2012-12-07 | R2; R4 | 5200h | 5200h | SPIA_IDC_LTE-Core | PCG-27 | China Mobile | Zhenping HU | Rel-11 | RP-53 | Yong-Jun | SPIA_IDC_LTE-Core | RP-121573 |  |
| 2824 | 698.2 | Perf. part: Signalling and Procedure for Interference Avoidance for in-device coexistence | 322d? | 2011-09-20 A | 2012-12-07 A | 100% | 2011-09-20 | 2012-12-07 | 322d? | finish no earlier than 2012-12-07 | R4 | 2576h | 2576h | SPIA_IDC_LTE-Perf | PCG-27 | China Mobile | Zhenping HU | Rel-11 | RP-53 | Issam | SPIA_IDC_LTE-Perf | RP-121574 |  |

Notes:
- 2801: - / Impacted TSs and TRs: LTE
- 2802: RP#58 completed / Impacted TSs and TRs: 36.101, 36.133, 36.201, 36.211, 36.212, 36.213, 36.214, 36.300, 36.304, 36.321, 36.331, 36.413, 36.423
- 2803: RP#62 completed / Impacted TSs and TRs: 36.101, 36.104, 36.133, 36.141
- 2804: ; Stat Rep: RP-141131->RP-141847 / Impacted TSs and TRs: 36.508, 36.521-1, 36.521-2, 36.521-3, 36.523-1, 36.523-2, 36.523-3
- 2805: Stage 3 / Impacted TSs and TRs: LTE
- 2806: RP#58 completed / Impacted TSs and TRs: 36.101, 36.104, 36.141, 36.307
- 2807: RP#58 completed / Impacted TSs and TRs: 36.101, 36.104, 36.133, 36.141, 36.307
- 2808: Stage 2/3 / Impacted TSs and TRs: LTE
- 2809: RP#58 completed / Impacted TSs and TRs: 36.300, 36.321, 36.331, new TR 36.822
- 2810: RP#61 completed / Impacted TSs and TRs: 36.523-1, 36.523-2, 36.523-3
- 2811: Stage 3 / Impacted TSs and TRs: LTE
- 2812: RP#56 completed / Impacted TSs and TRs: 25.101, 25.104, 25.461, 25.466, 36.101, 36.104, 36.113, 36.124, 36.307, 37.104, 37.113
- 2813: RP#56 completed / Impacted TSs and TRs: 25.123, 25.133, 25.141, 36.133, 36.141, 37.141
- 2814: RP#59 completed / Impacted TSs and TRs: 36.508, 36.521-1, 36.521-2, 36.521-3, 36.523-2, 36.523-3, 37.571-1
- 2815: Stage 3. Asian Pacific American Caucus (APAC) Asia-Pacific Telecommunity (APT) Wireless Forum / Impacted TSs and TRs: LTE
- 2816: RP#56 completed. TR 36.820 v100 for Information and Approval / Impacted TSs and TRs: 25.461, 25.466, 36.101, 36.104, 36.113, 36.124, 36.133, 36.307, 37.104, 37.113, new TR 36.820
- 2817: RP#56 completed / Impacted TSs and TRs: 36.133, 36.141, 37.141
- 2818: RP#60 completed / Impacted TSs and TRs: 36.508, 36.521-1, 36.521-2, 36.521-3, 36.523-2, 36.523-3, 37.571-1
- 2819: Continuation of Rel-10 (open RAN4 Core & Perf parts) / Impacted TSs and TRs: LTE
- 2820: RP#57 completed. TS 36.116, TR 36.826 v100 for Information & Approval. RP#52 Core part not completed in Rel-10 / Impacted TSs and TRs: 36.133, new RAN4 (36.116, 36.826)
- 2821: RP#60 completed. New TS 36.117 v100 for 1-step Approval. RP#52 transferred completely from Rel-10 UID_460213 / Impacted TSs and TRs: 36.133, new TS 36.117 (E-UTRA Relay conformance testing)
- 2822: Stage 2/3 / Impacted TSs and TRs: LTE
- 2823: RP#58 completed / Impacted TSs and TRs: 36.133, 36.300, 36.306, 36.321, 36.331
- 2824: RP#58 completed / Impacted TSs and TRs: 36.133

| ID | WBS | Task | Duration | Start | Finish | Complete | Remaining | Baseline start | Baseline finish | Baseline duration | Total slack | Constraint | Resources | Work | Actual work | Acronym | PCG approved | WI rapporteur name | Release | TSG approved | MCC resp | Acronym_3GU_Export | Status Report | Special Focus Doc |
| --- | --- | --- | --- | --- | --- | --- | --- | --- | --- | --- | --- | --- | --- | --- | --- | --- | --- | --- | --- | --- | --- | --- | --- | --- |
| 2825 | 699 | **Coordinated Multi-Point Operation for LTE** | 860d? | 2011-09-19 A | 2014-12-15 A | 100% |  | 2011-09-19 | 2014-09-12 | 791d? |  |  | R1; R2; R3; R4; R5 | 66128h | 66128h | COMP_LTE | PCG-27 | Huawei, Samsung | Rel-11 | RP-53 | Patrick | COMP_LTE |  |  |
| 2826 | 699.1 | Core part: Coordinated Multi-Point Operation for LTE – Uplink | 325d? | 2011-09-19 A | 2012-12-07 A | 100% |  | 2011-09-19 | 2012-12-07 | 325d? |  | finish no earlier than 2012-12-07 | R1; R2; R3; R4 | 10400h | 10400h | COMP_LTE_UL-Core | PCG-27 | Huawei | Rel-11 | RP-53 | Patrick | COMP_LTE_UL-Core | RP-121575 |  |
| 2827 | 699.2 | Perf. part: Coordinated Multi-Point Operation for LTE – Uplink | 321d? | 2011-09-23 A | 2012-12-07 A | 100% |  | 2011-09-23 | 2012-12-07 | 321d? |  | finish no earlier than 2012-12-07 | R4 | 2568h | 2568h | COMP_LTE_UL-Perf | PCG-27 | Huawei | Rel-11 | RP-53 | Issam | COMP_LTE_UL-Perf | RP-121576 |  |
| 2828 | 699.3 | Core part: Coordinated Multi-Point Operation for LTE – Downlink | 325d? | 2011-09-19 A | 2012-12-07 A | 100% |  | 2011-09-19 | 2012-12-07 | 325d? |  | finish no earlier than 2012-12-07 | R1; R2; R3; R4 | 10400h | 10400h | COMP_LTE_DL-Core | PCG-27 | Samsung | Rel-11 | RP-53 | Patrick | COMP_LTE_DL-Core | RP-121577 |  |
| 2829 | 699.4 | Perf. part: Coordinated Multi-Point Operation for LTE – Downlink | 582d? | 2011-09-23 A | 2013-12-06 A | 100% |  | 2011-09-23 | 2013-12-06 | 582d? |  | finish no earlier than 2013-12-06 | R4 | 4656h | 4656h | COMP_LTE_DL-Perf | PCG-27 | Samsung | Rel-11 | RP-53 | Issam | COMP_LTE_DL-Perf | RP-131465 |  |
| 2830 | 699.5 | Test part: Coordinated Multi-Point Operation for LTE | 463d? | 2013-03-15 A | 2014-12-15 A | 100% |  | 2013-03-04 | 2014-09-12 | 404d? |  | finish no earlier than 2014-12-15 | R5 | 3704h | 3704h | COMP_LTE-UEConTest | PCG-30 | Samsung | Rel-11 | RP-59 | Ingbert | COMP_LTE-UEConTest | RP-141782 |  |
| 2831 | 700 | **Enhanced downlink control channel(s) for LTE Advanced** | 732d? | 2011-12-09 A | 2014-09-12 A | 100% |  | 2011-12-09 | 2014-09-12 | 731d? |  |  | R1; R2; R4; R5 | 38272h | 38272h | LTE_enh_dl_ctrl | PCG-28 | Alcatel-Lucent | Rel-11 | RP-54 | Patrick | LTE_enh_dl_ctrl |  |  |
| 2832 | 700.1 | Core part: Enhanced downlink control channel(s) for LTE Advanced | 265d? | 2011-12-09 A | 2012-12-07 A | 100% |  | 2011-12-09 | 2012-12-07 | 265d? |  | finish no earlier than 2012-12-07 | R1; R2; R4 | 6360h | 6360h | LTE_enh_dl_ctrl-Core | PCG-28 | Alcatel-Lucent | Rel-11 | RP-54 | Patrick | LTE_enh_dl_ctrl-Core | RP-121579 |  |
| 2833 | 700.2 | Perf. part: Enhanced downlink control channel(s) for LTE Advanced | 659d? | 2011-12-16 A | 2014-06-13 A | 100% |  | 2011-12-16 | 2014-06-13 | 659d? |  | finish no earlier than 2014-06-13 | R4 | 5272h | 5272h | LTE_enh_dl_ctrl-Perf | PCG-28 | Alcatel-Lucent | Rel-11 | RP-54 | Issam | LTE_enh_dl_ctrl-Perf | RP-140651 |  |
| 2834 | 700.3 | Test part: Enhanced downlink control channel(s) for LTE Advanced | 402d? | 2013-03-04 A | 2014-09-12 A | 100% |  | 2013-03-04 | 2014-09-12 | 402d? |  | finish no earlier than 2014-09-12 | R5 | 3216h | 3216h | LTE_enh_dl_ctrl-UEConTest | PCG-30 | Huawei | Rel-11 | RP-59 | Ingbert | LTE_enh_dl_ctrl-UEConTest | RP-141256 |  |
| 2835 | 701 | **Public Safety Broadband High Power UE for Band 14 for Region 2** | 403d? | 2012-03-05 A | 2013-09-06 A | 100% |  | 2012-03-05 | 2013-09-06 | 403d? |  |  | R4; R5 | 9144h | 9144h | LTE_B14_PSBB_HPUE | PCG-28 | Motorola Solutions | Rel-11 | RP-55 | Issam | LTE_B14_PSBB_HPUE |  | Public Safety (A-A) |
| 2836 | 701.1 | Core part: Public Safety Broadband High Power UE for Band 14 for Region 2 | 201d? | 2012-03-05 A | 2012-12-07 A | 100% |  | 2012-03-05 | 2012-12-07 | 201d? |  | finish no earlier than 2012-12-07 | R4 | 1608h | 1608h | LTE_B14_PSBB_HPUE-Core | PCG-28 | Motorola Solutions | Rel-11 | RP-55 | Issam | LTE_B14_PSBB_HPUE-Core | RP-121581 | Public Safety (A-A) |
| 2837 | 701.2 | Test part: Public Safety Broadband High Power UE for Band 14 for Region 2 | 138d? | 2013-03-04 A | 2013-09-06 A | 100% |  | 2013-03-04 | 2013-09-06 | 138d? |  | finish no earlier than 2013-09-06 | R5 | 1088h | 1088h | LTE_B14_PSBB_HPUE-UEConTest | PCG-30 | Motorola Solutions | Rel-11 | RP-59 | Ingbert | LTE_B14_PSBB_HPUE-UEConTest | RP-130949 | Public Safety (A-A) |
| 2838 | 702 | **Improved Minimum Performance Requirements for E-UTRA: Interference Rejection** | 671d? | 2012-03-05 A | 2014-09-12 A | 100% |  | 2012-03-05 | 2014-09-12 | 670d? |  |  | R4; R5 | 14952h | 14952h | LTE_Interf_Rej | PCG-28 | Renesas Mobile | Rel-11 | RP-55 | Issam | LTE_Interf_Rej |  |  |
| 2839 | 702.1 | Perf. part: Improved Minimum Performance Requirements for E-UTRA: Interference Rejection | 201d? | 2012-03-05 A | 2012-12-07 A | 100% |  | 2012-03-05 | 2012-12-07 | 201d? |  | finish no earlier than 2012-12-07 | R4 | 1608h | 1608h | LTE_Interf_Rej-Perf | PCG-28 | Renesas Mobile | Rel-11 | RP-55 | Issam | LTE_Interf_Rej-Perf | RP-121582 |  |
| 2840 | 702.2 | Test part: Improved Minimum Performance Requirements for E-UTRA: Interference Rejection | 327d? | 2013-06-18 A | 2014-09-12 A | 100% |  | 2013-06-18 | 2014-09-12 | 327d? |  | finish no earlier than 2014-09-12 | R5 | 2608h | 2608h | LTE_Interf_Rej-UEConTest | PCG-31 | Broadcom | Rel-11 | RP-60 | Ingbert | LTE_Interf_Rej-UEConTest | RP-141602 |  |
| 2841 | 703 | **Additional special subframe configuration for LTE TDD** | 341d? | 2012-03-05 A | 2013-06-14 A | 100% |  | 2012-03-05 | 2013-06-14 | 341d? |  |  | R4; R2; R3; R5 | 14808h | 14808h | LTE_TDD_add_subframe | PCG-28 | China Mobile | Rel-11 | RP-55 | Issam | LTE_TDD_add_subframe |  |  |
| 2842 | 703.1 | Core part: Additional special subframe configuration for LTE TDD | 137d? | 2012-03-05 A | 2012-09-07 A | 100% |  | 2012-03-05 | 2012-09-07 | 137d? |  | finish no earlier than 2012-09-07 | R4; R2; R3 | 3288h | 3288h | LTE_TDD_add_subframe-Core | PCG-28 | China Mobile | Rel-11 | RP-55 | Issam | LTE_TDD_add_subframe-Core | RP-121019 |  |
| 2843 | 703.2 | Test part: Additional special subframe configuration for LTE TDD | 76d? | 2013-03-04 A | 2013-06-14 A | 100% |  | 2013-03-04 | 2013-06-14 | 76d? |  | finish no earlier than 2013-09-13 | R5 | 608h | 608h | LTE_TDD_add_subframe-UEConTest | PCG-30 | Huawei | Rel-11 | RP-59 | Ingbert | LTE_TDD_add_subframe-UEConTest | RP-130475 |  |
| 2844 | 704 | **Rel-11 LTE Carrier Aggregation** | 1062d? | 2010-12-10 A | 2014-12-15 | 99% | 8.37d? | 2010-12-10 | 2014-12-05 | 1054d? | 1050d |  | R1; R2; R3; R4; R5 | 315760h | 263184h | LTE_CA_Rel-11 | PCG-30 |  | Rel-11 | RP-58 | Patrick | LTE_CA_Rel-11 |  | CA |
| 2845 | 704.1 | **LTE Carrier Aggregation Enhancements** | 995d? | 2011-03-15 A | 2014-12-15 | 93% | 65.41d? | 2011-03-22 | 2014-12-05 | 982d? | 1050d |  | R1; R2; R3; R4; R5 | 70824h | 47768h | LTE_CA_enh | PCG-26 | Nokia | Rel-11 | RP-51 | Patrick | LTE_CA_enh |  | CA |
| 2846 | 704.1.1 | Core part: LTE Carrier Aggregation Enhancements | 646.25d? | 2011-03-22 A | 2013-08-27 | 80% | 129.25d? | 2011-03-22 | 2013-03-01 | 517d? | 1393.75d | finish no earlier than 2013-03-01 | R1; R2; R4; R3 | 20680h | 16544h | LTE_CA_enh-Core | PCG-26 | Nokia | Rel-11 | RP-51 | Patrick | LTE_CA_enh-Core | RP-130059 | CA |
| 2847 | 704.1.2 | Perf. part: LTE Carrier Aggregation Enhancements | 994d? | 2011-03-15 A | 2014-12-15 A | 100% |  | 2011-03-29 | 2014-12-05 | 977d? |  | finish no earlier than 2014-12-15 | R4 | 7936h | 7936h | LTE_CA_enh-Perf | PCG-26 | Nokia | Rel-11 | RP-51 | Issam | LTE_CA_enh-Perf | RP-141969 | CA |
| 2848 | 704.1.3 | Test part: LTE Carrier Aggregation Enhancements | 326d? | 2013-06-18 A | 2014-09-12 A | 100% |  | 2013-06-18 | 2014-09-12 | 326d? |  | finish no earlier than 2014-09-12 | R5 | 2608h | 2608h | LTE_CA_enh-UEConTest | PCG-31 | Microsoft | Rel-11 | RP-60 | Ingbert | LTE_CA_enh-UEConTest | RP-141443 | CA |
| 2849 | 704.2 | UE Conformance Test Aspects – LTE Advanced Carrier Aggregation of Intra-band contiguous and Inter-band configurations | 329d? | 2012-09-11 A | 2013-12-06 A | 100% |  | 2012-09-11 | 2013-12-06 | 329d? |  | finish no earlier than 2013-12-06 | R5 | 2624h | 2624h | LTE_CA_intraC_inter_UEConTest | PCG-29 | Nokia | Rel-11 | RP-57 | Ingbert | LTE_CA_intraC_inter_UEConTest | RP-131446 | CA |

Notes:
- 2825: Stage 3. Triggered by Rel-11 TR 36.819 Study on Coordinated Multi-Point Operation for LTE (FS_CoMP_LTE) / Impacted TSs and TRs: LTE / WI rapporteur e-mail: Juho Lee (juho95.lee@samsung.com), david.mazzarese@huawei.com
- 2826: RP#58 completed / Impacted TSs and TRs: 36.101, 36.104, 36.133, 36.201, 36.211, 36.212, 36.213, 36.214, 36.300, 36.306, 36.321, 36.331, 36.423 / WI rapporteur e-mail: david.mazzarese@huawei.com
- 2827: RP#58 completed / Impacted TSs and TRs: 36.101, 36.104, 36.133, 36.141 / WI rapporteur e-mail: Xinwei Zhi (zhixinwei@huawei.com)
- 2828: RP#58 completed / Impacted TSs and TRs: 36.101, 36.104, 36.133, 36.201, 36.211, 36.212, 36.213, 36.214, 36.300, 36.306, 36.321, 36.331, 36.423 / WI rapporteur e-mail: Juho Lee (juho95.lee@samsung.com)
- 2829: RP#62 completed / Impacted TSs and TRs: 36.101, 36.104, 36.133, 36.141, 36.307 / WI rapporteur e-mail: xutao.zhou@samsung.com
- 2830: Impacted TSs and TRs: 36.508, 36.521-1, 36.521-2, 36.523-1, 36.523-2, 36.523-3 / WI rapporteur e-mail: Stoyan.Baev@partner.samsung.com
- 2831: Stage 3. RP#58 Core completed. Triggered by UID_510037 Rel-11 TR 36.871 Study on further Downlink MIMO enhancements for LTE-Advanced (FS_LTE_eDL_MIMO_enh) / Impacted TSs and TRs: LTE / WI rapporteur e-mail: sigen.ye@alcatel-lucent.com
- 2832: RP#58 completed / Impacted TSs and TRs: 36.101, 36.211, 36.212, 36.213, 36.331 / WI rapporteur e-mail: sigen.ye@alcatel-lucent.com
- 2833: RP#64 completed / Impacted TSs and TRs: 36.101, 36.104, 36.133, 36.141 / WI rapporteur e-mail: teck.hu@alcatel-lucent.com
- 2834: RP#65 completed / Impacted TSs and TRs: 36.508, 36.521-1, 36.521-2, 36.523-1, 36.523-2, 36.523-3 / WI rapporteur e-mail: Xu Kai (xk.xukai@huawei.com)
- 2835: Stage 3 / Impacted TSs and TRs: LTE / WI rapporteur e-mail: xiaowei.jin@motorolasolutions.com
- 2836: RP#58 completed. TR 36.837 v100 for Information and Approval / Impacted TSs and TRs: 36.101, new TR 36.837 / WI rapporteur e-mail: xiaowei.jin@motorolasolutions.com
- 2837: RP#61 completed / Impacted TSs and TRs: 36.521-1, 36.521-2 / WI rapporteur e-mail: xiaowei.jin@motorolasolutions.com
- 2838: RP#58 completed. Triggered by FS_enh_perf_UE_LTE. Adds Perf. requirements for demodulation of the already specified PDSCH with the transmission modes defined in Rel-8 to Rel-10 / Impacted TSs and TRs: LTE / WI rapporteur e-mail: Timo Roman
- 2839: RP#58 completed / Impacted TSs and TRs: 36.101 / WI rapporteur e-mail: Timo Roman
- 2840: RP#65 completed. TR 36.904 for 1-step Approval. Testing for 36.101 / Impacted TSs and TRs: 36.508, 36.521-1, 36.521-2, New TR 36.904 / WI rapporteur e-mail: jarkko.hellsten@kolumbus.fi
- 2841: Stage 3. Exists already for 1UL a WI LTE_CA_B3_B5 / Impacted TSs and TRs: LTE / WI rapporteur e-mail: Xiaodong Shen
- 2842: RP#57 completed / Impacted TSs and TRs: 36.211, 36.213, 36.331, 36.423 / WI rapporteur e-mail: Xiaodong Shen
- 2843: RP#60 completed / Impacted TSs and TRs: 36.508, 36.523-1, 36.523-2, 36.523-3 / WI rapporteur e-mail: Li Xiang (tricia.li@huawei.com)
- 2844: LTE_CA_Rel-11 / Impacted TSs and TRs: LTE
- 2845: Stage 3 / Impacted TSs and TRs: LTE / WI rapporteur e-mail: lars.e.lindh@nokia.com
- 2846: RP#59 completed. New TR 36.823 v100 for Information and Approval / Impacted TSs and TRs: 36.101, 36.104, 36.133, 36.201, 36.211, 36.212, 36.213, 36.300, 36.302, 36.306, 36.321, 36.331, 36.413, 36.423, new TR 36.823 / WI rapporteur e-mail: lars.e.lindh@nokia.com
- 2847: ; Stat Rep: RP-141377->RP-141969 / Impacted TSs and TRs: 36.101, 36.104, 36.133, 36.141 / WI rapporteur e-mail: lars.e.lindh@nokia.com
- 2848: SP#65 completed / Impacted TSs and TRs: 36.508, 36.521-1, 36.521-2, 36.521-3, 36.523-1, 36.523-2, 36.523-3 / WI rapporteur e-mail: jussi.kuusisto@microsoft.com
- 2849: RP#62 completed / Impacted TSs and TRs: 36.508, 36.521-1, 36.521-2, 36.521-3, 36.523-1, 36.523-2, 36.523-3, 37.571-1 / WI rapporteur e-mail: jussi.kuusisto@nokia.com

| ID | WBS | Task | Duration | Start | Finish | Complete | Baseline start | Baseline finish | Baseline duration | Constraint | Resources | Work | Actual work | PCG approved | Release | TSG approved | MCC resp | Special Focus Doc | Acronym | WI rapporteur name | WI rapporteur e-mail | Acronym_3GU_Export | Status Report |
| --- | --- | --- | --- | --- | --- | --- | --- | --- | --- | --- | --- | --- | --- | --- | --- | --- | --- | --- | --- | --- | --- | --- | --- |
| 2850 | 704.3 | **Rel-11 inter-band Carrier Aggregation** | 528d? | 2010-12-10 A | 2012-12-07 A | 100% | 2010-12-10 | 2012-12-07 | 528d? |  | R4 | 180968h | 180968h | PCG-30 | Rel-11 | RP-58 | Issam | CA |  |  |  |  |  |
| 2851 | 704.3.1 | **LTE Advanced Carrier Aggregation of Band 3 and Band 7** | 528d? | 2010-12-10 A | 2012-12-07 A | 100% | 2010-12-10 | 2012-12-07 | 528d? |  | R4 | 12040h | 12040h | PCG-25 | Rel-11 | RP-48 | Issam | CA | LTE_CA_B3_B7 | TeliaSonera | Ralf.Schuh@TeliaSonera.com | LTE_CA_B3_B7 |  |
| 2852 | 704.3.1.1 | Core part: LTE Advanced Carrier Aggregation of Band 3 and Band 7 | 456d? | 2010-12-10 A | 2012-09-07 A | 100% | 2010-12-10 | 2012-09-07 | 456d? | finish no earlier than 2012-09-07 | R4 | 3648h | 3648h | PCG-25 | Rel-11 | RP-48 | Issam | CA | LTE_CA_B3_B7-Core | TeliaSonera | Ralf.Schuh@TeliaSonera.com | LTE_CA_B3_B7-Core | RP-121022 |
| 2853 | 704.3.1.2 | Perf. part: LTE Advanced Carrier Aggregation of Band 3 and Band 7 | 523d? | 2010-12-17 A | 2012-12-07 A | 100% | 2010-12-17 | 2012-12-07 | 523d? | finish no earlier than 2012-12-07 | R4 | 4168h | 4168h | PCG-25 | Rel-11 | RP-48 | Issam | CA | LTE_CA_B3_B7-Perf | TeliaSonera | Ralf.Schuh@TeliaSonera.com | LTE_CA_B3_B7-Perf | RP-121023 |
| 2854 | 704.3.2 | **LTE Advanced Carrier Aggregation of Band 4 and Band 17** | 528d? | 2010-12-10 A | 2012-12-07 A | 100% | 2010-12-10 | 2012-12-07 | 528d? |  | R4 | 12064h | 12064h | PCG-26 | Rel-11 | RP-50 | Issam | CA | LTE_CA_B4_B17 | AT&T | marc.grant@att.com | LTE_CA_B4_B17 |  |
| 2855 | 704.3.2.1 | Core part: LTE Advanced Carrier Aggregation of Band 4 and Band 17 | 459d? | 2010-12-10 A | 2012-09-07 A | 100% | 2010-12-10 | 2012-09-07 | 459d? | finish no earlier than 2012-09-07 | R4 | 3672h | 3672h | PCG-26 | Rel-11 | RP-50 | Issam | CA | LTE_CA_B4_B17-Core | AT&T | marc.grant@att.com | LTE_CA_B4_B17-Core | RP-121024 |
| 2856 | 704.3.2.2 | Perf. part: LTE Advanced Carrier Aggregation of Band 4 and Band 17 | 521d? | 2010-12-17 A | 2012-12-07 A | 100% | 2010-12-17 | 2012-12-07 | 521d? | finish no earlier than 2012-12-07 | R4 | 4168h | 4168h | PCG-26 | Rel-11 | RP-50 | Issam | CA | LTE_CA_B4_B17-Perf | AT&T | marc.grant@att.com | LTE_CA_B4_B17-Perf | RP-121595 |
| 2857 | 704.3.3 | **LTE Advanced Carrier Aggregation of Band 4 and Band 13** | 528d? | 2010-12-10 A | 2012-12-07 A | 100% | 2010-12-10 | 2012-12-07 | 528d? |  | R4 | 12040h | 12040h | PCG-26 | Rel-11 | RP-50 | Issam | CA | LTE_CA_B4_B13 | Ericsson | christian.bergljung@ericsson.com | LTE_CA_B4_B13 |  |
| 2858 | 704.3.3.1 | Core part: LTE Advanced Carrier Aggregation of Band 4 and Band 13 | 456d? | 2010-12-10 A | 2012-09-07 A | 100% | 2010-12-10 | 2012-09-07 | 456d? | finish no earlier than 2012-09-07 | R4 | 3648h | 3648h | PCG-26 | Rel-11 | RP-50 | Issam | CA | LTE_CA_B4_B13-Core | Ericsson | christian.bergljung@ericsson.com | LTE_CA_B4_B13-Core | RP-121026 |
| 2859 | 704.3.3.2 | Perf. part: LTE Advanced Carrier Aggregation of Band 4 and Band 13 | 521d? | 2010-12-21 A | 2012-12-07 A | 100% | 2010-12-21 | 2012-12-07 | 521d? | finish no earlier than 2012-12-07 | R4 | 4168h | 4168h | PCG-26 | Rel-11 | RP-50 | Issam | CA | LTE_CA_B4_B13-Perf | Ericsson | christian.bergljung@ericsson.com | LTE_CA_B4_B13-Perf | RP-121594 |
| 2860 | 704.3.4 | **LTE Advanced Carrier Aggregation of Band 4 and Band 12** | 456d? | 2011-03-22 A | 2012-12-07 A | 100% | 2011-03-22 | 2012-12-07 | 456d? |  | R4; R2 | 18200h | 18200h | PCG-26 | Rel-11 | RP-51 | Issam | CA | LTE_CA_B4_B12 | Leap Wireless | Bill Chandler (bchandler@cricketcommunications.com) | LTE_CA_B4_B12 |  |
| 2861 | 704.3.4.1 | Core part: LTE Advanced Carrier Aggregation of Band 4 and Band 12 | 456d? | 2011-03-22 A | 2012-12-07 A | 100% | 2011-03-22 | 2012-12-07 | 456d? | finish no earlier than 2012-12-07 | R4; R2 | 7296h | 7296h | PCG-26 | Rel-11 | RP-51 | Issam | CA | LTE_CA_B4_B12-Core | Leap Wireless | Bill Chandler (bchandler@cricketcommunications.com) | LTE_CA_B4_B12-Core | RP-121592 |
| 2862 | 704.3.4.2 | Perf. part: LTE Advanced Carrier Aggregation of Band 4 and Band 12 | 451d? | 2011-03-29 A | 2012-12-07 A | 100% | 2011-03-29 | 2012-12-07 | 451d? | finish no earlier than 2012-12-07 | R4 | 3608h | 3608h | PCG-26 | Rel-11 | RP-51 | Issam | CA | LTE_CA_B4_B12-Perf | Leap Wireless | Bill Chandler (bchandler@cricketcommunications.com) | LTE_CA_B4_B12-Perf | RP-121593 |
| 2863 | 704.3.5 | **LTE Advanced Carrier Aggregation of Band 5 and Band 12** | 456d? | 2011-03-22 A | 2012-12-07 A | 100% | 2011-03-22 | 2012-12-07 | 456d? |  | R4; R2 | 18200h | 18200h | PCG-26 | Rel-11 | RP-51 | Issam | CA | LTE_CA_B5_B12 | US Cellular | sebastian.thalanany@uscellular.com | LTE_CA_B5_B12 |  |
| 2864 | 704.3.5.1 | Core part: LTE Advanced Carrier Aggregation of Band 5 and Band 12 | 456d? | 2011-03-22 A | 2012-12-07 A | 100% | 2011-03-22 | 2012-12-07 | 456d? | finish no earlier than 2012-12-07 | R4; R2 | 7296h | 7296h | PCG-26 | Rel-11 | RP-51 | Issam | CA | LTE_CA_B5_B12-Core | US Cellular | sebastian.thalanany@uscellular.com | LTE_CA_B5_B12-Core | RP-121596 |
| 2865 | 704.3.5.2 | Perf. part: LTE Advanced Carrier Aggregation of Band 5 and Band 12 | 451d? | 2011-03-25 A | 2012-12-07 A | 100% | 2011-03-25 | 2012-12-07 | 451d? | finish no earlier than 2012-12-07 | R4 | 3608h | 3608h | PCG-26 | Rel-11 | RP-51 | Issam | CA | LTE_CA_B5_B12-Perf | US Cellular | sebastian.thalanany@uscellular.com | LTE_CA_B5_B12-Perf | RP-121597 |
| 2866 | 704.3.6 | **LTE Advanced Carrier Aggregation of Band 7 and Band 20** | 389d? | 2011-03-22 A | 2012-09-07 A | 100% | 2011-03-22 | 2012-09-07 | 389d? |  | R4 | 9288h | 9288h | PCG-26 | Rel-11 | RP-51 | Issam | CA | LTE_CA_B7_B20 | Huawei | Steven Chen | LTE_CA_B7_B20 |  |
| 2867 | 704.3.6.1 | Core part: LTE Advanced Carrier Aggregation of Band 7 and Band 20 | 386d? | 2011-03-22 A | 2012-09-07 A | 100% | 2011-03-22 | 2012-09-07 | 386d? | finish no earlier than 2012-09-07 | R4 | 3088h | 3088h | PCG-26 | Rel-11 | RP-51 | Issam | CA | LTE_CA_B7_B20-Core | Huawei | Steven Chen | LTE_CA_B7_B20-Core | RP-121032 |
| 2868 | 704.3.6.2 | Perf. part: LTE Advanced Carrier Aggregation of Band 7 and Band 20 | 386d? | 2011-03-25 A | 2012-09-07 A | 100% | 2011-03-25 | 2012-09-07 | 386d? | finish no earlier than 2012-09-07 | R4 | 3088h | 3088h | PCG-26 | Rel-11 | RP-51 | Issam | CA | LTE_CA_B7_B20-Perf | Huawei | Steven Chen | LTE_CA_B7_B20-Perf | RP-121033 |
| 2869 | 704.3.7 | **LTE Advanced Carrier Aggregation of Band 2 and Band 17** | 455d? | 2011-03-23 A | 2012-12-07 A | 100% | 2011-03-23 | 2012-12-07 | 455d? |  | R4 | 10336h | 10336h | PCG-26 | Rel-11 | RP-51 | Issam | CA | LTE_CA_B2_B17 | AT&T | marc.grant@att.com | LTE_CA_B2_B17 |  |
| 2870 | 704.3.7.1 | Core part: LTE Advanced Carrier Aggregation of Band 2 and Band 17 | 386d? | 2011-03-23 A | 2012-09-07 A | 100% | 2011-03-23 | 2012-09-07 | 386d? | finish no earlier than 2012-09-07 | R4 | 3088h | 3088h | PCG-26 | Rel-11 | RP-51 | Issam | CA | LTE_CA_B2_B17-Core | AT&T | marc.grant@att.com | LTE_CA_B2_B17-Core | RP-121034 |
| 2871 | 704.3.7.2 | Perf. part: LTE Advanced Carrier Aggregation of Band 2 and Band 17 | 451d? | 2011-03-25 A | 2012-12-07 A | 100% | 2011-03-25 | 2012-12-07 | 451d? | finish no earlier than 2012-12-07 | R4 | 3608h | 3608h | PCG-26 | Rel-11 | RP-51 | Issam | CA | LTE_CA_B2_B17-Perf | AT&T | marc.grant@att.com | LTE_CA_B2_B17-Perf | RP-121585 |
| 2872 | 704.3.8 | **LTE Advanced Carrier Aggregation of Band 4 and Band 5** | 455d? | 2011-03-23 A | 2012-12-07 A | 100% | 2011-03-23 | 2012-12-07 | 455d? |  | R4 | 10856h | 10856h | PCG-26 | Rel-11 | RP-51 | Issam | CA | LTE_CA_B4_B5 | AT&T | marc.grant@att.com | LTE_CA_B4_B5 |  |
| 2873 | 704.3.8.1 | Core part: LTE Advanced Carrier Aggregation of Band 4 and Band 5 | 451d? | 2011-03-23 A | 2012-12-07 A | 100% | 2011-03-23 | 2012-12-07 | 451d? | finish no earlier than 2012-12-07 | R4 | 3608h | 3608h | PCG-26 | Rel-11 | RP-51 | Issam | CA | LTE_CA_B4_B5-Core | AT&T | marc.grant@att.com | LTE_CA_B4_B5-Core | RP-121757 |
| 2874 | 704.3.8.2 | Perf. part: LTE Advanced Carrier Aggregation of Band 4 and Band 5 | 451d? | 2011-03-25 A | 2012-12-07 A | 100% | 2011-03-25 | 2012-12-07 | 451d? | finish no earlier than 2012-12-07 | R4 | 3608h | 3608h | PCG-26 | Rel-11 | RP-51 | Issam | CA | LTE_CA_B4_B5-Perf | AT&T | marc.grant@att.com | LTE_CA_B4_B5-Perf | RP-121589 |

Notes:
- 2850: LTE_CA_Rel-11 / Impacted TSs and TRs: LTE
- 2851: RP#57 completed. In Europe Band 3,7,20 are interesting for LTE and LTE-Advanced deployment. Different CA combinations for these bands are of high priority for Region 1 / Impacted TSs and TRs: LTE
- 2852: RP#57 completed. RP#59 new generic TR 36.850v100 for Information and Approval / Impacted TSs and TRs: 36.101, 36.104, 36.307, new generic TR 36.850
- 2853: RP#57 completed / Impacted TSs and TRs: 36.133, 36.141
- 2854: Stage 3. RP#57 Core completed. RP#58 Perf completed / Impacted TSs and TRs: LTE
- 2855: RP#57 completed. RP#59 new generic TR 36.850v100 for Information and Approval / Impacted TSs and TRs: 36.101, 36.104, 36.133, 36.141, 36.307, new generic TR 36.850
- 2856: RP#58 completed / Impacted TSs and TRs: 36.101, 36.104, 36.133, 36.307
- 2857: Stage 3. RP#57 Core completed. RP#58 Perf completed / Impacted TSs and TRs: LTE
- 2858: RP#57 completed / Impacted TSs and TRs: 36.101, 36.104, 36.133, 36.307, new generic TR 36.850
- 2859: RP#58 completed / Impacted TSs and TRs: 36.101, 36.133, 36.141
- 2860: Stage 3. RP#58 completed / Impacted TSs and TRs: LTE
- 2861: RP#58 completed. RP#59 new generic TR 36.850v100 for Information and Approval / Impacted TSs and TRs: 36.101, 36.104, 36.307, new generic TR 36.850
- 2862: RP#58 completed / Impacted TSs and TRs: 36.133, 36.141
- 2863: Stage 3. RP#58 completed / Impacted TSs and TRs: LTE
- 2864: RP#58 completed. RP#59 new generic TR 36.850v100 for Information and Approval / Impacted TSs and TRs: 36.101, 36.104, 36.133, 36.141, 36.307, new generic TR 36.850
- 2865: RP#58 completed / Impacted TSs and TRs: 36.101, 36.104, 36.133, 36.307
- 2866: Stage 3. RP#57 completed / Impacted TSs and TRs: LTE
- 2867: RP#57 completed. RP#59 new generic TR 36.850v100 for Information and Approval / Impacted TSs and TRs: 36.101, 36.104, 36.307, new generic TR 36.850
- 2868: RP#57 completed / Impacted TSs and TRs: 36.133, 36.141
- 2869: Stage 3. RP#57 Core completed. RP#58 Perf completed / Impacted TSs and TRs: LTE
- 2870: RP#57 completed. RP#59 new generic TR 36.850v100 for Information and Approval / Impacted TSs and TRs: 36.101, 36.104, 36.133, 36.141, 36.307, new generic TR 36.850
- 2871: RP#58 completed / Impacted TSs and TRs: 36.101, 36.104, 36.133, 36.307
- 2872: Stage 3. RP#58 completed / Impacted TSs and TRs: LTE
- 2873: RP#58 completed. RP#59 new generic TR 36.850v100 for Information and Approval / Impacted TSs and TRs: 36.101, 36.104, 36.133, 36.141, 36.307, new generic TR 36.850
- 2874: RP#58 completed / Impacted TSs and TRs: 36.101, 36.104, 36.133, 36.307

| ID | WBS | Task | Duration | Start | Finish | Complete | Baseline start | Baseline finish | Baseline duration | Constraint | Resources | Work | Actual work | Acronym | PCG approved | WI rapporteur name | WI rapporteur e-mail | Release | TSG approved | MCC resp | Special Focus Doc | Acronym_3GU_Export | Status Report |
| --- | --- | --- | --- | --- | --- | --- | --- | --- | --- | --- | --- | --- | --- | --- | --- | --- | --- | --- | --- | --- | --- | --- | --- |
| 2875 | 704.3.9 | **LTE Advanced Carrier Aggregation of Band 5 and Band 17** | 455d? | 2011-03-23 A | 2012-12-07 A | 100% | 2011-03-23 | 2012-12-07 | 455d? |  | R4 | 10856h | 10856h | LTE_CA_B5_B17 | PCG-26 | AT&T | marc.grant@att.com | Rel-11 | RP-51 | Issam | CA | LTE_CA_B5_B17 |  |
| 2876 | 704.3.9.1 | Core part: LTE Advanced Carrier Aggregation of Band 5 and Band 17 | 451d? | 2011-03-23 A | 2012-12-07 A | 100% | 2011-03-23 | 2012-12-07 | 451d? | finish no earlier than 2012-12-07 | R4 | 3608h | 3608h | LTE_CA_B5_B17-Core | PCG-26 | AT&T | marc.grant@att.com | Rel-11 | RP-51 | Issam | CA | LTE_CA_B5_B17-Core | RP-121598 |
| 2877 | 704.3.9.2 | Perf. part: LTE Advanced Carrier Aggregation of Band 5 and Band 17 | 451d? | 2011-03-25 A | 2012-12-07 A | 100% | 2011-03-25 | 2012-12-07 | 451d? | finish no earlier than 2012-12-07 | R4 | 3608h | 3608h | LTE_CA_B5_B17-Perf | PCG-26 | AT&T | marc.grant@att.com | Rel-11 | RP-51 | Issam | CA | LTE_CA_B5_B17-Perf | RP-121599 |
| 2878 | 704.3.10 | **LTE Advanced Carrier Aggregation of Band 3 and Band 20** | 258d? | 2011-09-19 A | 2012-09-07 A | 100% | 2011-09-19 | 2012-09-07 | 258d? |  | R4 | 6168h | 6168h | LTE_CA_B3_B20 | PCG-27 | Vodafone | tim.frost@vodafone.com | Rel-11 | RP-53 | Issam | CA | LTE_CA_B3_B20 |  |
| 2879 | 704.3.10.1 | Core part: LTE Advanced Carrier Aggregation of Band 3 and Band 20 | 256d? | 2011-09-19 A | 2012-09-07 A | 100% | 2011-09-19 | 2012-09-07 | 256d? | finish no earlier than 2012-09-07 | R4 | 2048h | 2048h | LTE_CA_B3_B20-Core | PCG-27 | Vodafone | tim.frost@vodafone.com | Rel-11 | RP-53 | Issam | CA | LTE_CA_B3_B20-Core | RP-121046 |
| 2880 | 704.3.10.2 | Perf. part: LTE Advanced Carrier Aggregation of Band 3 and Band 20 | 257d? | 2011-09-20 A | 2012-09-07 A | 100% | 2011-09-20 | 2012-09-07 | 257d? | finish no earlier than 2012-09-07 | R4 | 2056h | 2056h | LTE_CA_B3_B20-Perf | PCG-27 | Vodafone | tim.frost@vodafone.com | Rel-11 | RP-53 | Issam | CA | LTE_CA_B3_B20-Perf | RP-121047 |
| 2881 | 704.3.11 | **LTE Advanced Carrier Aggregation of Band 8 and Band 20** | 325d? | 2011-09-19 A | 2012-12-07 A | 100% | 2011-09-19 | 2012-12-07 | 325d? |  | R4 | 7752h | 7752h | LTE_CA_B8_B20 | PCG-27 | Vodafone | Luis.Anaya@vodafone.com | Rel-11 | RP-53 | Issam | CA | LTE_CA_B8_B20 |  |
| 2882 | 704.3.11.1 | Core part: LTE Advanced Carrier Aggregation of Band 8 and Band 20 | 323d? | 2011-09-19 A | 2012-12-07 A | 100% | 2011-09-19 | 2012-12-07 | 323d? | finish no earlier than 2012-12-07 | R4 | 2584h | 2584h | LTE_CA_B8_B20-Core | PCG-27 | Vodafone | Luis.Anaya@vodafone.com | Rel-11 | RP-53 | Issam | CA | LTE_CA_B8_B20-Core | RP-121600 |
| 2883 | 704.3.11.2 | Perf. part: LTE Advanced Carrier Aggregation of Band 8 and Band 20 | 321d? | 2011-09-23 A | 2012-12-07 A | 100% | 2011-09-23 | 2012-12-07 | 321d? | finish no earlier than 2012-12-07 | R4 | 2568h | 2568h | LTE_CA_B8_B20-Perf | PCG-27 | Vodafone | Luis.Anaya@vodafone.com | Rel-11 | RP-53 | Issam | CA | LTE_CA_B8_B20-Perf | RP-121601 |
| 2884 | 704.3.12 | **LTE Advanced Carrier Aggregation of Band 3 and Band 5** | 258d? | 2011-09-19 A | 2012-09-07 A | 100% | 2011-09-19 | 2012-09-07 | 258d? |  | R4 | 6160h | 6160h | LTE_CA_B3_B5 | PCG-27 | SK Telecom | Haesung Park | Rel-11 | RP-53 | Issam | CA | LTE_CA_B3_B5 |  |
| 2885 | 704.3.12.1 | Core part: LTE Advanced Carrier Aggregation of Band 3 and Band 5 | 256d? | 2011-09-19 A | 2012-09-07 A | 100% | 2011-09-19 | 2012-09-07 | 256d? | finish no earlier than 2012-09-07 | R4 | 2048h | 2048h | LTE_CA_B3_B5-Core | PCG-27 | SK Telecom | Haesung Park | Rel-11 | RP-53 | Issam | CA | LTE_CA_B3_B5-Core | RP-121042 |
| 2886 | 704.3.12.2 | Perf. part: LTE Advanced Carrier Aggregation of Band 3 and Band 5 | 256d? | 2011-09-21 A | 2012-09-07 A | 100% | 2011-09-21 | 2012-09-07 | 256d? | finish no earlier than 2012-09-07 | R4 | 2048h | 2048h | LTE_CA_B3_B5-Perf | PCG-27 | SK Telecom | Haesung Park | Rel-11 | RP-53 | Issam | CA | LTE_CA_B3_B5-Perf | RP-121043 |
| 2887 | 704.3.13 | **LTE Advanced Carrier Aggregation of Band 4 and Band 7** | 325d? | 2011-09-19 A | 2012-12-07 A | 100% | 2011-09-19 | 2012-12-07 | 325d? |  | R4 | 7744h | 7744h | LTE_CA_B4_B7 | PCG-27 | Rogers Wireless | takwing.wan@rci.rogers.com | Rel-11 | RP-53 | Issam | CA | LTE_CA_B4_B7 |  |
| 2888 | 704.3.13.1 | Core part: LTE Advanced Carrier Aggregation of Band 4 and Band 7 | 322d? | 2011-09-19 A | 2012-12-07 A | 100% | 2011-09-19 | 2012-12-07 | 322d? | finish no earlier than 2012-12-07 | R4 | 2576h | 2576h | LTE_CA_B4_B7-Core | PCG-27 | Rogers Wireless | takwing.wan@rci.rogers.com | Rel-11 | RP-53 | Issam | CA | LTE_CA_B4_B7-Core | RP-121590 |
| 2889 | 704.3.13.2 | Perf. part: LTE Advanced Carrier Aggregation of Band 4 and Band 7 | 321d? | 2011-09-23 A | 2012-12-07 A | 100% | 2011-09-23 | 2012-12-07 | 321d? | finish no earlier than 2012-12-07 | R4 | 2568h | 2568h | LTE_CA_B4_B7-Perf | PCG-27 | Rogers Wireless | takwing.wan@rci.rogers.com | Rel-11 | RP-53 | Issam | CA | LTE_CA_B4_B7-Perf | RP-121591 |
| 2890 | 704.3.14 | **LTE Advanced Carrier Aggregation of Band 11 and Band 18** | 265d? | 2011-12-09 A | 2012-12-07 A | 100% | 2011-12-09 | 2012-12-07 | 265d? |  | R4; R2 | 10568h | 10568h | LTE_CA_B11_B18 | PCG-28 | KDDI | Masaaki Obara (ms-obara@kddi.com) | Rel-11 | RP-54 | Issam | CA | LTE_CA_B11_B18 |  |
| 2891 | 704.3.14.1 | Core part: LTE Advanced Carrier Aggregation of Band 11 and Band 18 | 265d? | 2011-12-09 A | 2012-12-07 A | 100% | 2011-12-09 | 2012-12-07 | 265d? | finish no earlier than 2012-12-07 | R4; R2 | 4240h | 4240h | LTE_CA_B11_B18-Core | PCG-28 | KDDI | Masaaki Obara (ms-obara@kddi.com) | Rel-11 | RP-54 | Issam | CA | LTE_CA_B11_B18-Core | RP-121602 |
| 2892 | 704.3.14.2 | Perf. part: LTE Advanced Carrier Aggregation of Band 11 and Band 18 | 261d? | 2011-12-15 A | 2012-12-07 A | 100% | 2011-12-15 | 2012-12-07 | 261d? | finish no earlier than 2012-12-07 | R4 | 2088h | 2088h | LTE_CA_B11_B18-Perf | PCG-28 | KDDI | Masaaki Obara (ms-obara@kddi.com) | Rel-11 | RP-54 | Issam | CA | LTE_CA_B11_B18-Perf | RP-121603 |
| 2893 | 704.3.15 | **LTE Advanced Carrier Aggregation of Band 1 and Band 18** | 198d? | 2011-12-09 A | 2012-09-07 A | 100% | 2011-12-09 | 2012-09-07 | 198d? |  | R4; R2 | 7904h | 7904h | LTE_CA_B1_B18 | PCG-28 | KDDI | Masaaki Obara (ms-obara@kddi.com) | Rel-11 | RP-54 | Issam | CA | LTE_CA_B1_B18 |  |
| 2894 | 704.3.15.1 | Core part: LTE Advanced Carrier Aggregation of Band 1 and Band 18 | 198d? | 2011-12-09 A | 2012-09-07 A | 100% | 2011-12-09 | 2012-09-07 | 198d? | finish no earlier than 2012-09-07 | R4; R2 | 3168h | 3168h | LTE_CA_B1_B18-Core | PCG-28 | KDDI | Masaaki Obara (ms-obara@kddi.com) | Rel-11 | RP-54 | Issam | CA | LTE_CA_B1_B18-Core | RP-121052 |
| 2895 | 704.3.15.2 | Perf. part: LTE Advanced Carrier Aggregation of Band 1 and Band 18 | 196d? | 2011-12-13 A | 2012-09-07 A | 100% | 2011-12-13 | 2012-09-07 | 196d? | finish no earlier than 2012-12-07 | R4 | 1568h | 1568h | LTE_CA_B1_B18-Perf | PCG-28 | KDDI | Masaaki Obara (ms-obara@kddi.com) | Rel-11 | RP-54 | Issam | CA | LTE_CA_B1_B18-Perf | RP-121053 |
| 2896 | 704.3.16 | **LTE Advanced Carrier Aggregation of Band 1 and Band 19** | 197d? | 2011-12-12 A | 2012-09-07 A | 100% | 2011-12-12 | 2012-09-07 | 197d? |  | R4; R2 | 6432h | 6432h | LTE_CA_B1_B19 | PCG-28 | NTT DoCoMo | Hiromasa Umeda (umedah@nttdocomo.co.jp) | Rel-11 | RP-54 | Issam | CA | LTE_CA_B1_B19 |  |
| 2897 | 704.3.16.1 | Core part: LTE Advanced Carrier Aggregation of Band 1 and Band 19 | 137d? | 2012-03-05 A | 2012-09-07 A | 100% | 2012-03-05 | 2012-09-07 | 137d? | finish no earlier than 2012-09-07 | R4; R2 | 2192h | 2192h | LTE_CA_B1_B19-Core | PCG-28 | NTT DoCoMo | Hiromasa Umeda (umedah@nttdocomo.co.jp) | Rel-11 | RP-54 | Issam | CA | LTE_CA_B1_B19-Core | RP-120552 |
| 2898 | 704.3.16.2 | Perf. part: LTE Advanced Carrier Aggregation of Band 1 and Band 19 | 136d? | 2011-12-12 A | 2012-06-15 A | 100% | 2011-12-12 | 2012-06-15 | 136d? | finish no earlier than 2012-12-07 | R4 | 1088h | 1088h | LTE_CA_B1_B19-Perf | PCG-28 | NTT DoCoMo | Hiromasa Umeda (umedah@nttdocomo.co.jp) | Rel-11 | RP-54 | Issam | CA | LTE_CA_B1_B19-Perf | RP-120553 |

Notes:
- 2875: Stage 3. RP#58 completed / Impacted TSs and TRs: LTE
- 2876: RP#58 completed. RP#59 new generic TR 36.850v100 for Information and Approval / Impacted TSs and TRs: 36.101, 36.104, 36.133, 36.141, 36.307, new generic TR 36.850
- 2877: RP#58 completed / Impacted TSs and TRs: 36.101, 36.104, 36.133, 36.141, 36.307
- 2878: Stage 3. RP#57 completed / Impacted TSs and TRs: LTE
- 2879: RP#57 completed. RP#59 new generic TR 36.850v100 for Information and Approval / Impacted TSs and TRs: 36.101, 36.104, 36.133, 36.307, new generic TR 36.850
- 2880: RP#57 completed / Impacted TSs and TRs: 36.101, 36.104, 36.133, 36.141, 36.307
- 2881: Stage 3. RP#58 completed / Impacted TSs and TRs: LTE
- 2882: RP#58 completed. RP#59 new generic TR 36.850v100 for Information and Approval / Impacted TSs and TRs: 36.101, 36.104, 36.307, new generic TR 36.850
- 2883: RP#58 completed / Impacted TSs and TRs: 36.101, 36.104, 36.133, 36.141
- 2884: Stage 3. RP#57 completed / Impacted TSs and TRs: LTE
- 2885: RP#57 completed. RP#59 new generic TR 36.850v100 for Information and Approval / Impacted TSs and TRs: 36.101, 36.104, 36.133, 36.307, new generic TR 36.850
- 2886: RP#57 completed / Impacted TSs and TRs: 36.133, 36.141
- 2887: Stage 3. RP#58 completed / Impacted TSs and TRs: LTE
- 2888: RP#58 completed. RP#59 new generic TR 36.850v100 for Information and Approval / Impacted TSs and TRs: 36.101, 36.104, 36.133, 36.141, 36.307, 37.104, new generic TR 36.850
- 2889: RP#58 completed / Impacted TSs and TRs: 36.101, 36.104, 36.133, 36.141, 36.307
- 2890: Stage 3. RP#58 completed / Impacted TSs and TRs: LTE
- 2891: RP#58 completed. RP#59 new generic TR 36.850v100 for Information and Approval / Impacted TSs and TRs: 36.101, 36.104, 36.307, new generic TR 36.850
- 2892: RP#58 completed / Impacted TSs and TRs: 36.133
- 2893: Stage 3. RP#57 completed / Impacted TSs and TRs: LTE
- 2894: RP#57 completed. RP#59 new generic TR 36.850v100 for Information and Approval / Impacted TSs and TRs: 36.101, 36.104, 36.307, new generic TR 36.850
- 2895: RP#57 completed / Impacted TSs and TRs: 36.133, 36.141
- 2896: Stage 3. RP#56 completed. Updated WID RP-111765=>RP-120866 / Impacted TSs and TRs: LTE
- 2897: RP#56 completed. RP#59 new generic TR 36.850v100 for Information and Approval / Impacted TSs and TRs: 36.101, 36.104, 36.133, 36.307, new generic TR 36.850
- 2898: RP#56 completed / Impacted TSs and TRs: 36.133, 36.141

| ID | WBS | Task | Duration | Start | Finish | Complete | Baseline start | Baseline finish | Baseline duration | Constraint | Resources | Work | Actual work | Acronym | PCG approved | WI rapporteur name | Release | TSG approved | MCC resp | Special Focus Doc | Acronym_3GU_Export | Status Report |
| --- | --- | --- | --- | --- | --- | --- | --- | --- | --- | --- | --- | --- | --- | --- | --- | --- | --- | --- | --- | --- | --- | --- |
| 2899 | 704.3.17 | **LTE Advanced Carrier Aggregation of Band 1 and Band 21** | 265d? | 2011-12-09 A | 2012-12-07 A | 100% | 2011-12-09 | 2012-12-07 | 265d? |  | R4; R2 | 9496h | 9496h | LTE_CA_B1_B21 | PCG-28 | NTT DoCoMo | Rel-11 | RP-54 | Issam | CA | LTE_CA_B1_B21 |  |
| 2900 | 704.3.17.1 | Core part: LTE Advanced Carrier Aggregation of Band 1 and Band 21 | 198d? | 2011-12-09 A | 2012-09-07 A | 100% | 2011-12-09 | 2012-09-07 | 198d? | finish no earlier than 2012-09-07 | R4; R2 | 3168h | 3168h | LTE_CA_B1_B21-Core | PCG-28 | NTT DoCoMo | Rel-11 | RP-54 | Issam | CA | LTE_CA_B1_B21-Core | RP-121054 |
| 2901 | 704.3.17.2 | Perf. part: LTE Advanced Carrier Aggregation of Band 1 and Band 21 | 263d? | 2011-12-13 A | 2012-12-07 A | 100% | 2011-12-13 | 2012-12-07 | 263d? | finish no earlier than 2012-12-07 | R4 | 2088h | 2088h | LTE_CA_B1_B21-Perf | PCG-28 | NTT DoCoMo | Rel-11 | RP-54 | Issam | CA | LTE_CA_B1_B21-Perf | RP-121055 |
| 2902 | 704.3.18 | **LTE Advanced Carrier Aggregation of Band 3 and Band 8** | 204d? | 2012-03-05 A | 2012-12-07 A | 100% | 2012-03-05 | 2012-12-07 | 204d? |  | R4 | 4864h | 4864h | LTE_CA_B3_B8 | PCG-28 | KT | Rel-11 | RP-55 | Issam | CA | LTE_CA_B3_B8 |  |
| 2903 | 704.3.18.1 | Core part: LTE Advanced Carrier Aggregation of Band 3 and Band 8 | 201d? | 2012-03-05 A | 2012-12-07 A | 100% | 2012-03-05 | 2012-12-07 | 201d? | finish no earlier than 2012-12-07 | R4 | 1608h | 1608h | LTE_CA_B3_B8-Core | PCG-28 | KT | Rel-11 | RP-55 | Issam | CA | LTE_CA_B3_B8-Core | RP-121586 |
| 2904 | 704.3.18.2 | Perf. part: LTE Advanced Carrier Aggregation of Band 3 and Band 8 | 203d? | 2012-03-06 A | 2012-12-07 A | 100% | 2012-03-06 | 2012-12-07 | 203d? | finish no earlier than 2012-12-07 | R4 | 1624h | 1624h | LTE_CA_B3_B8-Perf | PCG-28 | KT | Rel-11 | RP-55 | Issam | CA | LTE_CA_B3_B8-Perf | RP-121587 |
| 2905 | 704.4 | **Rel-11 intra-band Carrier Aggregation** | 334d? | 2011-06-07 A | 2012-09-07 A | 100% | 2011-06-07 | 2012-09-07 | 334d? |  | RP | 18864h | 18864h |  | PCG-30 |  | Rel-11 | RP-58 |  | CA |  |  |
| 2906 | 704.4.1 | **LTE Advanced Carrier Aggregation in Band 38** | 334d? | 2011-06-07 A | 2012-09-07 A | 100% | 2011-06-07 | 2012-09-07 | 334d? |  | R4 | 7976h | 7976h | LTE_CA_B38 | PCG-27 | Huawei | Rel-11 | RP-52 | Issam | CA | LTE_CA_B38 |  |
| 2907 | 704.4.1.1 | Core part: LTE Advanced Carrier Aggregation in Band 38 | 331d? | 2011-06-07 A | 2012-09-07 A | 100% | 2011-06-07 | 2012-09-07 | 331d? | finish no earlier than 2012-09-07 | R4 | 2648h | 2648h | LTE_CA_B38-Core | PCG-27 | Huawei | Rel-11 | RP-52 | Issam | CA | LTE_CA_B38-Core | RP-121060 |
| 2908 | 704.4.1.2 | Perf. part: LTE Advanced Carrier Aggregation in Band 38 | 333d? | 2011-06-08 A | 2012-09-07 A | 100% | 2011-06-08 | 2012-09-07 | 333d? | finish no earlier than 2012-09-07 | R4 | 2656h | 2656h | LTE_CA_B38-Perf | PCG-27 | Huawei | Rel-11 | RP-52 | Issam | CA | LTE_CA_B38-Perf | RP-121061 |
| 2909 | 704.4.2 | **LTE Advanced Carrier Aggregation in Band 41** | 197d? | 2011-06-07 A | 2012-03-02 A | 100% | 2011-06-07 | 2012-03-02 | 197d? |  | R4 | 4720h | 4720h | LTE_CA_B41 | PCG-27 | Clearwire | Rel-11 | RP-52 | Issam | CA | LTE_CA_B41 |  |
| 2910 | 704.4.2.1 | Core part: LTE Advanced Carrier Aggregation in Band 41 | 196d? | 2011-06-07 A | 2012-03-02 A | 100% | 2011-06-07 | 2012-03-02 | 196d? | finish no earlier than 2012-02-23 | R4 | 1568h | 1568h | LTE_CA_B41-Core | PCG-27 | Clearwire | Rel-11 | RP-52 | Issam | CA | LTE_CA_B41-Core | RP-120126 |
| 2911 | 704.4.2.2 | Perf. part: LTE Advanced Carrier Aggregation in Band 41 | 197d? | 2011-06-07 A | 2012-03-02 A | 100% | 2011-06-07 | 2012-03-02 | 197d? | finish no earlier than 2012-03-02 | R4 | 1576h | 1576h | LTE_CA_B41-Perf | PCG-27 | Clearwire | Rel-11 | RP-52 | Issam | CA | LTE_CA_B41-Perf | RP-120127 |
| 2912 | 704.4.3 | **LTE Advanced Carrier Aggregation in Band 7** | 258d? | 2011-09-19 A | 2012-09-07 A | 100% | 2011-09-19 | 2012-09-07 | 258d? |  | R4 | 6168h | 6168h | LTE_CA_B7 | PCG-27 | China Unicom | Rel-11 | RP-53 | Issam | CA | LTE_CA_B7 |  |
| 2913 | 704.4.3.1 | Core part: LTE Advanced Carrier Aggregation in Band 7 | 256d? | 2011-09-19 A | 2012-09-07 A | 100% | 2011-09-19 | 2012-09-07 | 256d? | finish no earlier than 2012-09-07 | R4 | 2048h | 2048h | LTE_CA_B7-Core | PCG-27 | China Unicom | Rel-11 | RP-53 | Issam | CA | LTE_CA_B7-Core | RP-121062 |
| 2914 | 704.4.3.2 | Perf. part: LTE Advanced Carrier Aggregation in Band 7 | 257d? | 2011-09-20 A | 2012-09-07 A | 100% | 2011-09-20 | 2012-09-07 | 257d? | finish no earlier than 2012-09-07 | R4 | 2056h | 2056h | LTE_CA_B7-Perf | PCG-27 | China Unicom | Rel-11 | RP-53 | Issam | CA | LTE_CA_B7-Perf | RP-121063 |
| 2915 | 705 | **UE Over The Air (Antenna) conformance testing methodology - Laptop mounted equipment Free Space test** | 1842d? | 2009-09-18 A | 2016-09-15 A | 100% | 2009-09-18 | 2014-12-05 | 1374d? |  | R4; R5 | 45192h | 45192h | UEAnt_FSTest | PCG-23 | CATR | Rel-11 | RP-45 | Issam |  | UEAnt_FSTest |  |
| 2916 | 705.1 | Core part: UE Over The Air (Antenna) conformance testing methodology - Laptop mounted equipment Free Space test | 583d? | 2009-09-18 A | 2011-12-09 A | 100% | 2009-09-18 | 2011-12-09 | 583d? | finish no earlier than 2011-12-09 | R4 | 4664h | 4664h | UEAnt_FSTest-Core | PCG-23 | CATR | Rel-11 | RP-45 | Issam |  | UEAnt_FSTest-Core | RP-111456 |
| 2917 | 705.2 | Test part: UE Over The Air (Antenna) conformance testing methodology - Laptop mounted equipment Free Space test | 1388d? | 2011-06-15 A | 2016-09-15 A | 100% | 2011-06-07 | 2014-12-05 | 926d? | finish no earlier than 2016-09-15 | R5 | 11056h | 11056h | UEAnt_FSTest-UEConTest | PCG-27 | ZTE | Rel-11 | RP-52 | Ingbert |  | UEAnt_FSTest-UEConTest | RP-151187 |
| 2918 | 706 | **Eight carrier HSDPA** | 589d? | 2010-09-15 A | 2012-12-07 A | 100% | 2010-09-15 | 2012-12-07 | 589d? |  | R1; R2; R3; R4 | 37768h | 37768h | 8C_HSDPA | PCG-26 | Ericsson | Rel-11 | RP-50 | Patrick |  | 8C_HSDPA |  |
| 2919 | 706.1 | Core part: Eight carrier HSDPA | 461d? | 2010-09-15 A | 2012-06-15 A | 100% | 2010-09-15 | 2012-06-15 | 461d? | finish no earlier than 2012-06-15 | R1; R2; R3; R4 | 14752h | 14752h | 8C_HSDPA-Core | PCG-26 | Ericsson | Rel-11 | RP-50 | Patrick |  | 8C_HSDPA-Core | RP-120971 |
| 2920 | 706.2 | Perf. part: Eight carrier HSDPA | 523d? | 2010-12-15 A | 2012-12-07 A | 100% | 2010-12-15 | 2012-12-07 | 523d? | finish no earlier than 2012-12-07 | R4 | 4168h | 4168h | 8C_HSDPA-Perf | PCG-26 | Ericsson | Rel-11 | RP-50 | Issam |  | 8C_HSDPA-Perf | RP-120972 |
| 2921 | 707 | **UE demodulation performance requirements under multiple-cell scenario for 1.28Mcps TDD** | 324d? | 2010-12-10 A | 2012-03-02 A | 100% | 2010-12-10 | 2012-03-02 | 324d? |  | R4; R5 | 7760h | 7760h | LCR_TDD_UE_demod_mc | PCG-26 | China Mobile | Rel-11 | RP-50 | Issam |  | LCR_TDD_UE_demod_mc |  |
| 2922 | 707.1 | Perf. part: UE demodulation performance requirements under multiple-cell scenario for 1.28Mcps TDD | 201d? | 2010-12-10 A | 2011-09-16 A | 100% | 2010-12-10 | 2011-09-16 | 201d? | finish no earlier than 2011-09-16 | R4 | 1608h | 1608h | LCR_TDD_UE_demod_mc-Perf | PCG-26 | China Mobile | Rel-11 | RP-50 | Issam |  | LCR_TDD_UE_demod_mc-Perf | RP-110996 |
| 2923 | 707.2 | Test part: UE demodulation performance requirements under multiple-cell scenario for 1.28Mcps TDD | 121d? | 2011-09-19 A | 2012-03-02 A | 100% | 2011-09-19 | 2012-03-02 | 121d? | finish no earlier than 2012-02-23 | R5 | 968h | 968h | LCR_TDD_UE_demod_mc-UEConTest | PCG-27 | China Mobile | Rel-11 | RP-53 | Ingbert |  | LCR_TDD_UE_demod_mc-UEConTest | RP-120052 |

Notes:
- 2899: Stage 3. RP#57 completed. Updated WID RP-111764=>RP-121173 / Impacted TSs and TRs: LTE / WI rapporteur e-mail: Hiromasa Umeda (umedah@nttdocomo.co.jp)
- 2900: RP#57 completed. RP#59 new generic TR 36.850v100 for Information and Approval / Impacted TSs and TRs: 36.101, 36.104, 36.133, 36.307, new generic TR 36.850 / WI rapporteur e-mail: Hiromasa Umeda (umedah@nttdocomo.co.jp)
- 2901: RP#57 completed / Impacted TSs and TRs: 36.133, 36.141 / WI rapporteur e-mail: Hiromasa Umeda (umedah@nttdocomo.co.jp)
- 2902: Stage 3. RP#58 completed / Impacted TSs and TRs: LTE / WI rapporteur e-mail: Chungwoo HWANG (cwhwang@kt.com)
- 2903: RP#58 completed. RP#59 new generic TR 36.850v100 for Information and Approval / Impacted TSs and TRs: 36.101, 36.104, 36.133, 36.307, new generic TR 36.850 / WI rapporteur e-mail: Chungwoo HWANG (cwhwang@kt.com)
- 2904: RP#58 completed / Impacted TSs and TRs: 36.133, 36.141 / WI rapporteur e-mail: Chungwoo HWANG (cwhwang@kt.com)
- 2905: LTE_CA_Rel-11 / Impacted TSs and TRs: LTE
- 2906: Stage 3. RP#57 completed. WI only covers intra-band contiguous and not non-contiguous aspects / Impacted TSs and TRs: LTE / WI rapporteur e-mail: ronnie.zhang@huawei.com
- 2907: RP#57 completed. TR 36.830 v100 for Information & Approval / Impacted TSs and TRs: 36.101, 36.104, 36.133, 36.141, 36.307, 37.104, 37.141, new TR 36.833-1-38 [instead of 36.830] / WI rapporteur e-mail: ronnie.zhang@huawei.com
- 2908: RP#57 completed / Impacted TSs and TRs: 36.101, 36.104, 36.133, 36.141, 36.307, 37.104, 37.141 / WI rapporteur e-mail: ronnie.zhang@huawei.com
- 2909: RP#55 completed. WI only covers intra-band contiguous and not non-contiguous aspects. / Impacted TSs and TRs: LTE / WI rapporteur e-mail: michael.hart@clearwire.com
- 2910: RP#55 completed. Updated WID RP-110673=>RP-120249. TR 36.827 v100 for Information + Approval / Impacted TSs and TRs: 36.101, 36.104, 36.133, 36.141, 36.307, 37.104, new TR 36.833-1-41 [instead of 36.827] / WI rapporteur e-mail: michael.hart@clearwire.com
- 2911: RP#55 completed / Impacted TSs and TRs: 36.101, 36.104, 36.133, 36.141, 36.307 / WI rapporteur e-mail: michael.hart@clearwire.com
- 2912: Stage 3. RP#57 completed. Updated WID RP-111356=>RP-121193. WI only covers intra-band contiguous and not non-contiguous aspects / Impacted TSs and TRs: LTE / WI rapporteur e-mail: Zhangchao Ma (mazc@chinaunicom.cn), Zhonghao Zhang (zhangzh306@chinaunicom.cn)
- 2913: RP#57 completed. TR 36.831 v100 for Information & Approval / Impacted TSs and TRs: 36.101, 36.104, 36.133, 36.141, 36.307, 37.104, 37.141, new TR 36.833-1-07 [instead of 36.831] / WI rapporteur e-mail: Zhangchao Ma (mazc@chinaunicom.cn), Zhonghao Zhang (zhangzh306@chinaunicom.cn)
- 2914: RP#57 completed / Impacted TSs and TRs: 36.101, 36.104, 36.133, 36.141, 36.307, 37.104, 37.141 / WI rapporteur e-mail: Zhangchao Ma (mazc@chinaunicom.cn), Zhonghao Zhang (zhangzh306@chinaunicom.cn)
- 2915: - / Impacted TSs and TRs: UTRA / WI rapporteur e-mail: Guo Lin (guolin@emcite.com)
- 2916: RP#54 completed / Impacted TSs and TRs: 25.144, 25.914, 34.114 / WI rapporteur e-mail: Guo Lin (guolin@emcite.com)
- 2917: 1st Apr 15: CD:Mon 15/06/15->Wed 15/06/16 1st Apr 15: Stat Rep: RP-141846->RP-150068 03/07/15: Stat Rep: RP-150068->RP-150603 29/09/15: Stat Rep: RP-150603->RP-151187 / Impacted TSs and TRs: 34.114 / WI rapporteur e-mail: carolyn.tayl@zte.com.cn
- 2918: Stage 3 / Impacted TSs and TRs: UTRA / WI rapporteur e-mail: johan.hultell@ericsson.com
- 2919: RP#57 completed / Impacted TSs and TRs: 25.101, 25.104, 25.133, 25.211, 25.212, 25.213, 25.214, 25.215, 25.308, 25.331, 25.423, 25.433, 26.306 / WI rapporteur e-mail: johan.hultell@ericsson.com
- 2920: RP#57 completed / Impacted TSs and TRs: 25.101, 25.104, 25.133, 25.141 / WI rapporteur e-mail: johan.hultell@ericsson.com
- 2921: Stage 3 / Impacted TSs and TRs: UTRA / WI rapporteur e-mail: Li Nan (linan@chinamobile.com)
- 2922: RP#53 completed. TR 25.873v100 for Approval / Impacted TSs and TRs: 25.102, new TR 25.873 / WI rapporteur e-mail: Li Nan (linan@chinamobile.com)
- 2923: RP#55 completed / Impacted TSs and TRs: 34.108, 34.122 / WI rapporteur e-mail: Ma Shuai (mashuai@chinamobile.com)

| ID | WBS | Task | Duration | Start | Finish | Complete | Baseline start | Baseline finish | Baseline duration | Constraint | Resources | Work | Actual work | Acronym | PCG approved | WI rapporteur name | WI rapporteur e-mail | Release | TSG approved | MCC resp | Acronym_3GU_Export | Status Report |
| --- | --- | --- | --- | --- | --- | --- | --- | --- | --- | --- | --- | --- | --- | --- | --- | --- | --- | --- | --- | --- | --- | --- |
| 2924 | 708 | **Uplink Transmit Diversity for HSPA** | 929d? | 2010-12-10 A | 2014-06-13 A | 100% | 2010-12-10 | 2014-06-13 | 929d? |  | R1; R4; R2; R3; R5 | 83568.3h | 83568.3h | HSPA_UL_TxDiv | PCG-26 | Huawei | zongjie.wang@huawei.com | Rel-11 | RP-50 | Patrick | HSPA_UL_TxDiv |  |
| 2925 | 708.1 | Core part: Uplink Transmit Diversity for HSPA - Closed Loop | 528d? | 2010-12-10 A | 2012-12-07 A | 100% | 2010-12-10 | 2012-12-07 | 528d? | finish no earlier than 2012-12-07 | R1; R4; R2; R3 | 16896h | 16896h | HSPA_UL_TxDiv-CL-Core | PCG-26 | Huawei | zongjie.wang@huawei.com | Rel-11 | RP-50 | Patrick | HSPA_UL_TxDiv-CL-Core | RP-121542 |
| 2926 | 708.2 | Perf. part: Uplink Transmit Diversity for HSPA - Closed Loop | 721d? | 2010-12-14 A | 2013-09-06 A | 100% | 2010-12-14 | 2013-09-06 | 721d? | finish no earlier than 2013-09-06 | R4 | 5760.31h | 5760.31h | HSPA_UL_TxDiv-CL-Perf | PCG-26 | Huawei | zongjie.wang@huawei.com | Rel-11 | RP-50 | Issam | HSPA_UL_TxDiv-CL-Perf | RP-130477 |
| 2927 | 708.3 | Core part: Uplink Transmit Diversity for HSPA - Open Loop | 528d? | 2010-12-10 A | 2012-12-07 A | 100% | 2010-12-10 | 2012-12-07 | 528d? | finish no earlier than 2012-12-07 | R4; R1; R2; R3 | 16896h | 16896h | HSPA_UL_TxDiv-OL-Core | PCG-26 | Huawei | zongjie.wang@huawei.com | Rel-11 | RP-50 | Patrick | HSPA_UL_TxDiv-OL-Core | RP-121544 |
| 2928 | 708.4 | Perf. part: Uplink Transmit Diversity for HSPA - Open Loop | 521d? | 2010-12-14 A | 2012-12-07 A | 100% | 2010-12-14 | 2012-12-07 | 521d? | finish no earlier than 2012-12-07 | R4 | 4168h | 4168h | HSPA_UL_TxDiv-OL-Perf | PCG-26 | Huawei | zongjie.wang@huawei.com | Rel-11 | RP-50 | Issam | HSPA_UL_TxDiv-OL-Perf | RP-121545 |
| 2929 | 708.5 | Test part: Uplink Transmit Diversity for HSPA | 336d? | 2013-03-04 A | 2014-06-13 A | 100% | 2013-03-04 | 2014-06-13 | 336d? | finish no earlier than 2014-06-13 | R5 | 2688h | 2688h | HSPA_UL_TxDiv-UEConTest | PCG-30 | Qualcomm | Shubhang Vora (svora@qti.qualcomm.com) | Rel-11 | RP-59 | Ingbert | HSPA_UL_TxDiv-UEConTest | RP-140767 |
| 2930 | 709 | **Introduction of New Configuration for 4C-HSDPA** | 328d? | 2011-03-22 A | 2012-06-15 A | 100% | 2011-03-22 | 2012-06-15 | 328d? |  | R4; R2 | 10928h | 10928h | 4C_HSDPA_Config | PCG-26 | Telus Communications | jorge.delrio@telus.com | Rel-11 | RP-51 | Issam | 4C_HSDPA_Config |  |
| 2931 | 709.1 | Core part: Introduction of New Configuration for 4C-HSDPA | 192d? | 2011-03-22 A | 2011-12-09 A | 100% | 2011-03-22 | 2011-12-09 | 192d? | finish no earlier than 2011-12-09 | R4; R2 | 3072h | 3072h | 4C_HSDPA_Config-Core | PCG-26 | Telus Communications | jorge.delrio@telus.com | Rel-11 | RP-51 | Issam | 4C_HSDPA_Config-Core | RP-111463 |
| 2932 | 709.2 | Perf. part: Introduction of New Configuration for 4C-HSDPA | 326d? | 2011-03-24 A | 2012-06-15 A | 100% | 2011-03-24 | 2012-06-15 | 326d? | finish no earlier than 2012-06-15 | R4 | 2608h | 2608h | 4C_HSDPA_Config-Perf | PCG-26 | Telus Communications | jorge.delrio@telus.com | Rel-11 | RP-51 | Issam | 4C_HSDPA_Config-Perf | RP-120475 |
| 2933 | 710 | **Non-contiguous 4C-HSDPA operation** | 516d? | 2011-03-23 A | 2013-03-01 A | 100% | 2011-03-23 | 2013-03-01 | 516d? |  | R4; R2; R3 | 24360h | 24360h | NC_4C_HSDPA | PCG-26 | Ericsson | muhammad.kazmi@ericsson.com | Rel-11 | RP-51 | Issam | NC_4C_HSDPA |  |
| 2934 | 710.1 | Core part: Non-contiguous 4C-HSDPA operation | 328d? | 2011-06-15 A | 2012-09-07 A | 100% | 2011-06-15 | 2012-09-07 | 328d? | finish no earlier than 2012-09-07 | R4; R2; R3 | 7872h | 7872h | NC_4C_HSDPA-Core | PCG-26 | Ericsson | muhammad.kazmi@ericsson.com | Rel-11 | RP-51 | Issam | NC_4C_HSDPA-Core | RP-120842 |
| 2935 | 710.2 | Perf. part: Non-contiguous 4C-HSDPA operation | 513d? | 2011-03-23 A | 2013-03-01 A | 100% | 2011-03-23 | 2013-03-01 | 513d? | finish no earlier than 2013-03-01 | R4 | 4104h | 4104h | NC_4C_HSDPA-Perf | PCG-26 | Ericsson | muhammad.kazmi@ericsson.com | Rel-11 | RP-51 | Issam | NC_4C_HSDPA-Perf | RP-130049 |
| 2936 | 711 | **Further Enhancements to CELL_FACH** | 1057d? | 2011-03-18 A | 2015-03-15 A | 100% | 2011-03-18 | 2014-09-12 | 924d? |  | R1; R2; R3; R4; R5 | 66320h | 66320h | Cell_FACH_enh | PCG-26 | Qualcomm | Ravi Agarwal | Rel-11 | RP-51 | Patrick | Cell_FACH_enh |  |
| 2937 | 711.1 | Core part: Further Enhancements to CELL_FACH | 458d? | 2011-03-18 A | 2012-12-07 A | 100% | 2011-03-18 | 2012-12-07 | 458d? | finish no earlier than 2012-12-07 | R2; R1; R3; R4 | 14656h | 14656h | Cell_FACH_enh-Core | PCG-26 | Qualcomm | Ravi Agarwal | Rel-11 | RP-51 | Yong-Jun | Cell_FACH_enh-Core | RP-121547 |
| 2938 | 711.2 | Perf. part: Further Enhancements to CELL_FACH | 717d? | 2011-03-24 A | 2013-12-06 A | 100% | 2011-03-24 | 2013-12-06 | 717d? | finish no earlier than 2013-12-06 | R4 | 5728h | 5728h | Cell_FACH_enh-Perf | PCG-26 | Qualcomm | Heechoon Lee (heechoon@qti.qualcomm.com) | Rel-11 | RP-51 | Issam | Cell_FACH_enh-Perf | RP-131459 |
| 2939 | 711.3 | Test part: Further Enhancements to CELL_FACH | 457d? | 2013-06-15 A | 2015-03-15 A | 100% | 2013-06-18 | 2014-09-12 | 327d? | finish no earlier than 2015-03-15 | R5 | 3656h | 3656h | Cell_FACH_enh-UEConTest | PCG-31 | Ericsson | leif.mattisson@ericsson.com | Rel-11 | RP-60 | Ingbert | Cell_FACH_enh-UEConTest | RP-150132 |
| 2940 | 712 | **HSDPA Multiflow Data Transmission** | 924d? | 2011-09-19 A | 2015-03-15 A | 100% | 2011-09-19 | 2014-12-05 | 851d? |  | R2; R1; R3; R4; R5 | 54136h | 54136h | HSDPA_MFTX | PCG-27 | Nokia Siemens Networks | Alexander Sayenko | Rel-11 | RP-53 | Yong-Jun | HSDPA_MFTX |  |
| 2941 | 712.1 | Core part: HSDPA Multiflow Data Transmission | 325d? | 2011-09-19 A | 2012-12-07 A | 100% | 2011-09-19 | 2012-12-07 | 325d? | finish no earlier than 2012-12-07 | R2; R1; R3; R4 | 10400h | 10400h | HSDPA_MFTX-Core | PCG-27 | Nokia Siemens Networks | Alexander Sayenko | Rel-11 | RP-53 | Yong-Jun | HSDPA_MFTX-Core | RP-121551 |
| 2942 | 712.2 | Perf. part: HSDPA Multiflow Data Transmission | 519d? | 2011-09-20 A | 2013-09-06 A | 100% | 2011-09-20 | 2013-09-06 | 519d? | finish no earlier than 2013-09-06 | R4 | 4152h | 4152h | HSDPA_MFTX-Perf | PCG-27 | Nokia Siemens Networks | kamil.bechta@nsn.com | Rel-11 | RP-53 | Issam | HSDPA_MFTX-Perf | RP-130959 |
| 2943 | 712.3 | Test part: HSDPA Multiflow Data Transmission | 328d? | 2013-12-15 A | 2015-03-15 A | 100% | 2013-12-06 | 2014-12-05 | 262d? | finish no earlier than 2015-03-15 | R5 | 2624h | 2624h | HSDPA_MFTX-UEConTest | PCG-32 | Qualcomm | Shubhang Vora (svora@qti.qualcomm.com) | Rel-11 | RP-62 | Ingbert | HSDPA_MFTX-UEConTest | RP-150126 |
| 2944 | 713 | **Four Branch MIMO transmission for HSDPA** | 590d? | 2011-09-19 A | 2013-12-06 A | 100% | 2011-09-19 | 2013-12-06 | 590d? |  | R1; R2; R3; R4 | 33968h | 33968h | 4Tx_HSDPA | PCG-27 | Ericsson | johan.hultell@ericsson.com | Rel-11 | RP-53 | Patrick | 4Tx_HSDPA |  |
| 2945 | 713.1 | Core part: Four Branch MIMO transmission for HSDPA | 325d? | 2011-09-19 A | 2012-12-07 A | 100% | 2011-09-19 | 2012-12-07 | 325d? | finish no earlier than 2012-12-07 | R1; R2; R3; R4 | 10400h | 10400h | 4Tx_HSDPA-Core | PCG-27 | Ericsson | johan.hultell@ericsson.com | Rel-11 | RP-53 | Patrick | 4Tx_HSDPA-Core | RP-121549 |
| 2946 | 713.2 | Perf. part: Four Branch MIMO transmission for HSDPA | 586d? | 2011-09-21 A | 2013-12-06 A | 100% | 2011-09-21 | 2013-12-06 | 586d? | finish no earlier than 2013-12-06 | R4 | 4688h | 4688h | 4Tx_HSDPA-Perf | PCG-27 | Ericsson | johan.hultell@ericsson.com | Rel-11 | RP-53 | Issam | 4Tx_HSDPA-Perf | RP-131460 |
| 2947 | 714 | **MIMO with 64QAM for HSUPA** | 464d? | 2011-12-09 A | 2013-09-06 A | 100% | 2011-12-09 | 2013-09-06 | 464d? |  | R1; R2; R3; R4 | 26984h | 26984h | MIMO_64QAM_HSUPA | PCG-28 | Nokia Siemens Networks | Karri Ranta-aho | Rel-11 | RP-54 | Patrick | MIMO_64QAM_HSUPA |  |
| 2948 | 714.1 | Core part: MIMO with 64QAM for HSUPA | 265d? | 2011-12-09 A | 2012-12-07 A | 100% | 2011-12-09 | 2012-12-07 | 265d? | finish no earlier than 2012-12-07 | R1; R2; R3; R4 | 8480h | 8480h | MIMO_64QAM_HSUPA-Core | PCG-28 | Nokia Siemens Networks | Karri Ranta-aho | Rel-11 | RP-54 | Patrick | MIMO_64QAM_HSUPA-Core | RP-121554 |
| 2949 | 714.2 | Perf. part: MIMO with 64QAM for HSUPA | 457d? | 2011-12-13 A | 2013-09-06 A | 100% | 2011-12-13 | 2013-09-06 | 457d? | finish no earlier than 2013-09-06 | R4 | 3656h | 3656h | MIMO_64QAM_HSUPA-Perf | PCG-28 | Nokia Siemens Networks | kamil.bechta@nsn.com | Rel-11 | RP-54 | Issam | MIMO_64QAM_HSUPA-Perf | RP-130960 |

Notes:
- 2924: Stage 2/3 / Impacted TSs and TRs: UTRA
- 2925: RP#58 completed / Impacted TSs and TRs: 25.101, 25.104, 25.133, 25.211, 25.212, 25.213, 25.214, 25.215, 25.306, 25.319, 25.321, 25.331, 25.423, 25.433
- 2926: RP#61 completed / Impacted TSs and TRs: 25.101, 25.104, 25.133, 25.141
- 2927: RP#58 completed / Impacted TSs and TRs: 25.101, 25.133, 25.306, 25.319, 25.321, 25.331, 25.423, 25.433
- 2928: RP#58 completed / Impacted TSs and TRs: 25.101, 25.133
- 2929: RP#64 completed / Impacted TSs and TRs: 34.121-1, 34.121-2, 34.123-1, 34.123-2, 34.123-3
- 2930: - / Impacted TSs and TRs: UTRA
- 2931: RP#54 completed. RP#62 existing TS 25.317 replaced by new TS 25.327 / Impacted TSs and TRs: 25.101, 25.104, 25.141, 25.317 replaced by new TS 25.327
- 2932: RP#56 completed. RP#62 existing TS 25.317 replaced by new TS 25.327 / Impacted TSs and TRs: 25.101, 25.104, 25.141, 25.317 replaced by new TS 25.327
- 2933: - / Impacted TSs and TRs: UTRA
- 2934: RP#56 completed / Impacted TSs and TRs: 25.101, 25.104, 25.133, 25.331, 25.423, 25.433
- 2935: RP#59 completed / Impacted TSs and TRs: 25.101, 25.104, 25.133, 25.141
- 2936: - / Impacted TSs and TRs: UTRA
- 2937: RP#58 completed / Impacted TSs and TRs: 25.101, 25.104, 25.133, 25.211, 25.212, 25.213, 25.214, 25.306, 25.308, 25.319, 25.321, 25.331, 25.423, 25.433
- 2938: RP#62 completed / Impacted TSs and TRs: 25.101, 25.104, 25.133, 25.141
- 2939: ; Stat Rep: RP-141164->RP-141770 1st Apr 15: Compl:92%->100% 1st Apr 15: Stat Rep: RP-141770->RP-150132 / Impacted TSs and TRs: 34.108, 34.121-1, 34.121-2, 34.123-1, 34.123-2, 34.123-3, 36.508, 36.523-1, 36.523-2, 36.523-3
- 2940: Stage 2,3 / Impacted TSs and TRs: UTRA
- 2941: RP#58 completed / Impacted TSs and TRs: 25.101, 25.104, 25.133, 25.211, 25.212, 25.214, 25.306, 25.308, 25.321, 25.331, 25.423, 25.433
- 2942: RP#61 completed / Impacted TSs and TRs: 25.101, 25.104, 25.133, 25.141
- 2943: ; Stat Rep: RP-141136->RP-141961 1st Apr 15: Compl:90%->100% 1st Apr 15: Stat Rep: RP-141961->RP-150126 / Impacted TSs and TRs: 34.108, 34.121-1, 34.121-2, 34.123-1, 34.123-2, 34.123-3
- 2944: Stage 3 / Impacted TSs and TRs: UTRA
- 2945: RP#58 completed / Impacted TSs and TRs: 25.101, 25.104, 25.133, 25.211, 25.212, 25.213, 25.214, 25.215, 25.308, 25.331, 25.423, 25.433, 26.306
- 2946: RP#62 completed / Impacted TSs and TRs: 25.101, 25.104, 25.133, 25.141
- 2947: Specified UE and BS performance requirements for uplink MIMO together with QPSK and 16QAM modulations for E-DCH/HSUPA. 64QAM is for future releases / Impacted TSs and TRs: UTRA
- 2948: RP#58 completed / Impacted TSs and TRs: 25.101, 25.104, 25.133, 25.211, 25.212, 25.213, 25.214, 25.215, 25.308, 25.321, 25.331, 25.423, 25.433, 26.306
- 2949: RP#61 completed / Impacted TSs and TRs: 25.101, 25.104, 25.133, 25.141

| ID | WBS | Task | Type | Duration | Start | Finish | Complete | Baseline start | Baseline finish | Baseline duration | Constraint | Resources | Work | Actual work | Acronym | PCG approved | Impacted TSs and TRs | WI rapporteur name | Release | TSG approved | MCC resp | Acronym_3GU_Export | Status Report | Special Focus Doc | PCG stopped | TSG stopped |
| --- | --- | --- | --- | --- | --- | --- | --- | --- | --- | --- | --- | --- | --- | --- | --- | --- | --- | --- | --- | --- | --- | --- | --- | --- | --- | --- |
| 2950 | 715 | **HSDPA Dual-Band Multi-Carrier combinations** |  | 198d? | 2011-12-09 A | 2012-09-07 A | 100% | 2011-12-09 | 2012-09-07 | 198d? |  | R4; R2 | 7920h | 7920h | HSDPA_DB_MC | PCG-28 | UTRA | Ericsson | Rel-11 | RP-54 | Issam | HSDPA_DB_MC |  |  |  |  |
| 2951 | 715.1 | Core part: HSDPA Dual-Band Multi-Carrier combinations |  | 198d? | 2011-12-09 A | 2012-09-07 A | 100% | 2011-12-09 | 2012-09-07 | 198d? | finish no earlier than 2012-09-07 | R4; R2 | 3168h | 3168h | HSDPA_DB_MC-Core | PCG-28 | 25.101, 25.104, 25.141, 25.317 replaced by new TS 25.327 | Ericsson | Rel-11 | RP-54 | Issam | HSDPA_DB_MC-Core | RP-120987 |  |  |  |
| 2952 | 715.2 | Perf. part: HSDPA Dual-Band Multi-Carrier combinations |  | 198d? | 2011-12-09 A | 2012-09-07 A | 100% | 2011-12-09 | 2012-09-07 | 198d? | finish no earlier than 2012-09-07 | R4 | 1584h | 1584h | HSDPA_DB_MC-Perf | PCG-28 | 25.101, 25.104, 25.141 | Ericsson | Rel-11 | RP-54 | Issam | HSDPA_DB_MC-Perf | RP-120988 |  |  |  |
| 2953 | 716 | Split TTCN Test Models for IMS testing in TS 34.229-3 |  | 201d? | 2013-12-09 A | 2014-09-12 A | 100% | 2013-12-09 | 2014-09-12 | 201d? | finish no earlier than 2014-09-12 | R5 | 1608h | 1608h | IMS-CCR_Test2 | PCG-32 | 34.229-3, New TS 34.229-4 | Spirent | Rel-11 | RP-62 | Ingbert | IMS-CCR_Test2 | RP-141155 |  |  |  |
| 2954 | 717 | (Small) Technical Enhancements and Improvements for Rel-11 |  | 595d? | 2010-06-18 A | 2012-09-20 A | 100% | 2010-06-18 | 2012-09-20 | 595d? | finish no earlier than 2012-09-20 | SP; CP; RP; GP | 19040h | 19040h | TEI11 | PCG-25 |  |  | Rel-11 | SP-48 | All | TEI11 |  |  |  |  |
| 2955 | 718 | Test - (Small) Technical Enhancements and Improvements for Rel-11 |  | 397d? | 2012-06-15 A | 2013-12-11 A | 100% | 2012-06-15 | 2013-12-11 | 397d? | finish no earlier than 2013-12-11 | R5; G3new | 6352h | 6352h | TEI11_Test | PCG-29 |  |  | Rel-11 | RP-56 | Ingbert | TEI11_Test |  |  |  |  |
| 2956 | 719 | (IETF) (Small) Technical Enhancements and Improvements for Rel-11 (RFC 7077) |  | 333d? | 2012-09-07 A | 2013-12-06 A | 100% | 2012-09-07 | 2013-12-06 | 333d? | finish no earlier than 2013-11-28 | C4-IETF | 2632.95h | 2632.95h | TEI11_IETF | PCG-29 | RFC 7077 (was draft-ietf-netext-update-notifications) | Lionel Morand | Rel-11 | CP-57 | Kimmo | TEI11_IETF |  |  |  |  |
| 2957 | 720 | Release 11 Studies | milestone | 0d? | 2009-12-10 A | 2009-12-10 A | 100% | 2009-12-10 | 2012-09-14 | 727d? | finish no earlier than 2012-12-07 | SP; CP; GP; RP |  |  |  |  |  |  | Rel-11 |  | All |  |  |  |  |  |
| 2958 | 721 | Study on IMS based Peer-to-Peer Content Distribution Services |  | 195d? | 2009-09-11 A | 2010-06-10 A | 100% | 2009-05-12 | 2010-06-10 | 284d? | finish no earlier than 2010-06-10 | S1; S2 | 3120h | 3120h | FS_IMS_P2P | PCG-23 | 22.906 | China Mobile | Rel-11 | SP-45 | Alain | FS_IMS_P2P |  |  |  |  |
| 2959 | 722 | Study on Non Voice Emergency Services |  | 467d? | 2009-12-10 A | 2011-09-21 A | 100% | 2009-12-10 | 2011-09-21 | 467d? | finish no earlier than 2011-09-21 | S1 | 3720h | 3720h | FS_NOVES | PCG-24 | 22.871 | Qualcomm | Rel-11 | SP-46 | Alain | FS_NOVES |  |  |  |  |
| 2960 | 723 | Study on Support for 3GPP Voice Interworking with Enterprise IP-PBX |  | 130d? | 2010-09-23 A | 2011-03-23 A | 100% | 2010-09-23 | 2011-03-23 | 130d? | finish no earlier than 2011-02-21 | S1; S2 | 2080h | 2080h | FS_VINE | PCG-25 | 22.809 | Tatara Systems | Rel-11 | SP-48 | Alain | FS_VINE |  |  |  |  |
| 2961 | 724 | Study on IMS Network-Independent Public User Identities |  | 185d? | 2010-09-23 A | 2011-06-08 A | 100% | 2010-09-23 | 2011-06-08 | 185d? | finish no earlier than 2011-06-08 | S1 | 1480h | 1480h | FS_INIPUI | PCG-25 | 22.894 | Vodafone | Rel-11 | SP-49 | Alain | FS_INIPUI |  |  |  |  |
| 2962 | 725 | Study on IMS Evolution |  | 849d? | 2008-09-18 A | 2011-12-14 A | 100% | 2008-09-18 | 2011-12-14 | 849d? | finish no earlier than 2011-12-07 | S2 | 6784h | 6784h | FS_eIMS | PCG-21 | 23.812 | China Mobile | Rel-11 | SP-41 | Maurice | FS_eIMS |  |  |  |  |
| 2963 | 726 | Study on Policy solutions and enhancements |  | 521d? | 2009-06-12 A | 2011-06-10 A | 100% | 2000-01-03 | 2002-01-03 | 525d? | finish no earlier than 2011-06-10 | S2; S1 | 8336h | 8336h | FS_PP | PCG-23 | 23.813 | AT&T | Rel-11 | SP-44 | Maurice | FS_PP |  |  |  |  |
| 2964 | 727 | Study on IPv6 Migration |  | 525d? | 2009-06-04 A | 2011-06-08 A | 100% | 2009-06-04 | 2011-06-08 | 525d? | finish no earlier than 2011-06-08 | S2 | 4200h | 4200h | FS_IP6M | PCG-23 | 23.975 | China Mobile | Rel-11 | SP-44 | Maurice | FS_IP6M |  |  |  |  |
| 2965 | 728 | Study on Single Radio Voice Call Continuity from UTRAN/GERAN to E-UTRAN/HSPA |  | 528d? | 2009-12-10 A | 2011-12-14 A | 100% | 2009-12-10 | 2011-12-14 | 528d? | finish no earlier than 2011-09-21 | S2 | 4208h | 4208h | FS_rSRVCC | PCG-24 | 23.885 | Orange | Rel-11 | SP-46 | Maurice | FS_rSRVCC |  |  |  |  |
| 2966 | 729 | Study on Roaming Architecture for Voice over IMS with Local Breakout |  | 194d? | 2011-03-23 A | 2011-12-14 A | 100% | 2011-03-23 | 2011-12-14 | 194d? | finish no earlier than 2011-12-07 | S2 | 1535.79h | 1535.79h | FS_RAVEL | PCG-26 | 23.850 | Deutsche Telekom | Rel-11 | SP-51 | Maurice | FS_RAVEL |  |  |  |  |
| 2967 | 730 | Study on UTRAN key management enhancements |  | 1102d? | 2007-12-20 A | 2012-03-07 A | 100% | 2007-12-20 | 2012-03-07 | 1102d? | finish no earlier than 2012-02-20 | S3 | 8808.12h | 8808.12h | FS_UKM | PCG-21 | 33.859 | Ericsson | Rel-11 | SP-38 | Mirko | FS_UKM |  |  |  |  |
| 2968 | 731 | Study on Single Sign On (SSO) Application Security for IMS - based on SIP Digest |  | 532d? | 2010-06-10 A | 2012-06-20 A | 100% | 2010-06-10 | 2012-06-20 | 532d? | finish no earlier than 2012-06-20 | S3 | 4247.09h | 4247.09h | FS_SSO_APS | PCG-25 | 33.914 converted to 33.804 | Nokia | Rel-11 | SP-48 | Mirko | FS_SSO_APS |  |  |  |  |
| 2969 | 732 | Study on Mobile 3D Video Coding |  | 273d? | 2011-06-08 A | 2012-06-20 A | 100% | 2011-06-08 | 2012-06-20 | 273d? | finish no earlier than 2012-06-20 | S4 | 2168h | 2168h | FS_M3DVC | PCG-27 | 26.905 | Orange | Rel-11 | SP-52 | Paolo | FS_M3DVC |  |  |  |  |
| 2970 | 733 | Study on Management of Converged Networks |  | 591d? | 2010-06-10 A | 2012-09-12 A | 100% | 2010-06-10 | 2012-09-12 | 591d? | finish no earlier than 2012-09-12 | S5 | 4720h | 4720h | FS_ManCon | PCG-25 | 32.833 | Nokia Siemens Networks | Rel-11 | SP-48 | Mirko | FS_ManCon |  |  |  |  |
| 2971 | 734 | Study on User Data Convergence (UDC) information model handling and provisioning: Example Use Cases |  | 321d? | 2010-09-23 A | 2011-12-14 A | 100% | 2010-09-23 | 2011-12-14 | 321d? | finish no earlier than 2011-12-14 | S5 | 2560h | 2560h | FS_UDC_AppUseCase | PCG-25 | 32.901 | Alcatel-Lucent | Rel-11 | SP-49 | Mirko | FS_UDC_AppUseCase |  |  |  |  |
| 2972 | 735 | Study on OAM aspects of inter-RAT Energy Saving |  | 194d? | 2011-03-23 A | 2011-12-14 A | 100% | 2011-03-23 | 2011-12-14 | 194d? | start no earlier than 2011-03-23 | S5 | 1528h | 1528h | FS_OAM_ES_iRAT | PCG-26 | 32.834 | Nokia Siemens Networks | Rel-11 | SP-51 | Mirko | FS_OAM_ES_iRAT |  | SON |  |  |
| 2973 | 736 | Study on impacts on UE-Core Network signalling from Energy Saving |  | 261d? | 2010-06-04 A | 2011-06-03 A | 100% | 2010-06-04 | 2011-06-03 | 261d? | finish no earlier than 2011-06-03 | C1 | 2088h | 2088h | FS_UE-CN_ES | PCG-25 | 24.826 | NEC | Rel-11 | CP-48 | Frederic | FS_UE-CN_ES |  |  |  |  |
| 2974 | 737 | Study on EPC Nodes Restoration |  | 588d? | 2010-09-17 A | 2012-12-07 A | 100% | 2010-09-17 | 2012-12-07 | 588d? | finish no earlier than 2012-12-07 | C4 | 4664h | 4664h | FS_EPC_NR | PCG-25 | 23.857 | ZTE | Rel-11 | CP-49 | Kimmo | FS_EPC_NR |  |  |  |  |
| 2975 | 738 | Study on Signal Precoding enhancements for EGPRS2 DL |  | 394d? | 2010-09-03 A | 2012-03-02 A | 100% | 2010-09-03 | 2012-03-02 | 394d? | finish no earlier than 2012-03-02 | G1; G2 | 6304h | 6304h | FS_SPEED | PCG-25 | GERAN 45.860 | Ericsson | Rel-11 | GP-46 | Paolo | FS_SPEED |  |  |  |  |
| 2976 | 739 | Study on Coordinated Multi-Point operation for LTE |  | 203d? | 2010-12-10 A | 2011-09-16 A | 100% | 2010-12-10 | 2011-09-16 | 203d? | finish no earlier than 2011-09-16 | R1; R2; R3 | 4872h | 4872h | FS_CoMP_LTE | PCG-24 | LTE 36.819 | Samsung | Rel-11 | RP-47 | Patrick | FS_CoMP_LTE | RP-111343 |  |  |  |
| 2977 | 740 | Study on Signalling and procedure for interference avoidance for in-device coexistence |  | 338d? | 2010-06-04 A | 2011-09-16 A | 100% | 2010-06-04 | 2011-09-16 | 338d? | finish no earlier than 2011-09-16 | R2; R4 | 5408h | 5408h | FS_SPIA_IDC | PCG-25 | LTE 36.816 | China Mobile | Rel-11 | RP-48 | Yong-Jun | FS_SPIA_IDC | RP-111057 |  |  |  |
| 2978 | 741 | Study on HetNet mobility enhancements for LTE |  | 391d? | 2011-03-18 A | 2012-09-07 A | 100% | 2011-03-18 | 2012-09-07 | 391d? | finish no earlier than 2012-09-07 | R2; R1; R3; R4 | 12512h | 12512h | FS_HetNet_eMOB_LTE | PCG-26 | LTE 36.839 | Alcatel-Lucent | Rel-11 | RP-51 | Yong-Jun | FS_HetNet_eMOB_LTE | RP-121085 |  |  |  |
| 2979 | 742 | Study on further Downlink MIMO enhancements for LTE-Advanced |  | 193d? | 2011-03-18 A | 2011-12-09 A | 100% | 2011-03-18 | 2011-12-09 | 193d? | finish no earlier than 2011-12-09 | R1 | 1544h | 1544h | FS_LTE_eDL_MIMO_enh | PCG-26 | LTE 36.871 | Alcatel-Lucent | Rel-11 | RP-51 | Patrick | FS_LTE_eDL_MIMO_enh | RP-111550 |  |  |  |
| 2980 | 743 | Study on Further Enhancements to LTE TDD for DL-UL Interference Management and Traffic Adaptation |  | 328d? | 2011-03-22 A | 2012-06-15 A | 100% | 2011-03-22 | 2012-06-15 | 328d? | finish no earlier than 2012-06-15 | R1; R4 | 5248h | 5248h | FS_LTE_TDD_eIMTA | PCG-26 | LTE 36.828 | CATT | Rel-11 | RP-51 | Patrick | FS_LTE_TDD_eIMTA | RP-120587 | Small cell |  |  |
| 2981 | 744 | Study on LTE Coverage Enhancements |  | 197d? | 2011-09-19 A | 2012-06-15 A | 100% | 2011-09-19 | 2012-06-15 | 197d? | finish no earlier than 2012-06-15 | R1; R2 | 3152h | 3152h | FS_Cov_Enh_LTE | PCG-27 | LTE 36.824 | China Telecom | Rel-11 | RP-53 | Patrick | FS_Cov_Enh_LTE | RP-120589 |  |  |  |
| 2982 | 745 | Study on Enhanced performance requirement for LTE UE |  | 121d? | 2011-09-19 A | 2012-03-02 A | 100% | 2011-09-19 | 2012-03-02 | 121d? | finish no earlier than 2012-03-02 | R4; R1 | 1936h | 1936h | FS_enh_perf_UE_LTE | PCG-27 | LTE 36.829 | NTT DoCoMo | Rel-11 | RP-53 | Issam | FS_enh_perf_UE_LTE | RP-120167 |  |  |  |
| 2983 | 746 | Study on Measurements of radio performances for LTE terminals - Total Radiated Power (TRP) and Total Radiated Sensitivity (TRS) test methodology |  | 136d? | 2012-03-05 A | 2012-09-07 A | 100% | 2012-03-05 | 2012-09-07 | 136d? | finish no earlier than 2012-09-07 | R4 | 1088h | 1088h | FS_LTE_OTA | PCG-28 | LTE 25.914, New TR 37.902 | CATR | Rel-11 | RP-55 | Issam | FS_LTE_OTA | RP-121083 |  |  |  |
| 2984 | 747 | Study on Measurement of Radiated Performance for MIMO and multi-antenna reception for HSPA and LTE terminals |  | 712.8d? | 2009-03-06 A | 2012-03-02 A | 100% | 2009-03-06 | 2012-03-02 | 712.8d? | finish no earlier than 2012-03-02 | R4 | 5702.4h | 5702.4h | FS_HSPA_LTE_measRP_MIMO_multi-antenna | PCG-22 | UTRA, LTE 37.976 | Vodafone | Rel-11 | RP-43 | Issam | FS_HSPA_LTE_measRP_MIMO_multi-antenna | RP-120154 |  |  |  |
| 2985 | 748 | Study on Extending 850 MHz |  | 860d? | 2009-05-30 A | 2012-09-07 A | 100% | 2009-05-30 | 2012-09-07 | 860d? | finish no earlier than 2012-09-07 | R4 | 6880h | 6880h | FS_e850 | PCG-23 | UTRA, LTE 37.806 | Ericsson | Rel-11 | RP-44 | Issam | FS_e850 | RP-121080 |  |  |  |
| 2986 | 749 | Study on RAN improvements for Machine-Type Communications |  | 523d? | 2009-09-18 A | 2011-09-16 A | 100% | 2009-09-18 | 2011-09-16 | 523d? | finish no earlier than 2011-09-16 | R2; R1; R3; R4 | 16736h | 16736h | FS_NIMTC_RAN | PCG-23 | UTRA, LTE 37.868 | Huawei | Rel-11 | RP-45 | Yong-Jun | FS_NIMTC_RAN | RP-111052 | MTC, M2M |  |  |
| 2987 | 750 | Study on UE Application Layer Data Throughput Performance |  | 264d? | 2010-09-16 A | 2011-09-16 A | 100% | 2010-09-16 | 2011-09-16 | 264d? | finish no earlier than 2011-09-16 | R5; R4 | 4224h | 4224h | FS_UE_App_Data_Perf | PCG-26 | UTRA, LTE 37.901 | Spirent | Rel-11 | RP-50 | Ingbert | FS_UE_App_Data_Perf | RP-111543 |  |  |  |
| 2988 | 751 | Study on further enhancements for HNB and HeNB |  | 330d? | 2011-03-18 A | 2012-06-15 A | 100% | 2011-03-18 | 2012-06-15 | 330d? | finish no earlier than 2012-06-15 | R3; R2 | 5280h | 5280h | FS_EHNB_enh | PCG-26 | UTRA, LTE 37.803 | Alcatel-Lucent | Rel-11 | RP-51 | Juha | FS_EHNB_enh | RP-120579 | HNB |  |  |
| 2989 | 752 | Study on Interference analysis between 800~900 MHz bands |  | 326d? | 2011-03-23 A | 2012-06-15 A | 100% | 2011-03-23 | 2012-06-15 | 326d? | finish no earlier than 2012-06-15 | R4 | 2608h | 2608h | FS_B800_B900_Interf_LTE | PCG-26 | UTRA, LTE impacts TR 37.804 | LG Uplus | Rel-11 | RP-51 | Issam | FS_B800_B900_Interf_LTE | RP-120586 |  |  |  |
| 2990 | 753 | Study on UMTS/LTE in 900 MHz band (Japan, Korea) |  | 272d? | 2011-06-07 A | 2012-06-15 A | 100% | 2011-06-07 | 2012-06-15 | 272d? | finish no earlier than 2012-06-15 | R4 | 2176h | 2176h | FS_UTRA_LTE_900MHz | PCG-27 | UTRA, LTE 37.804 | NTT DoCoMo | Rel-11 | SP-52 | Issam | FS_UTRA_LTE_900MHz | RP-120580 |  |  |  |
| 2991 | 754 | Study on Uplink MIMO |  | 203d? | 2010-12-10 A | 2011-09-16 A | 100% | 2010-12-10 | 2011-09-16 | 203d? | finish no earlier than 2011-09-16 | R1 | 1624h | 1624h | FS_UTRA_UL_MIMO | PCG-26 | UTRA 25.871 | Qualcomm | Rel-11 | RP-50 | Patrick | FS_UTRA_UL_MIMO | RP-111048 |  |  |  |
| 2992 | 755 | Study on HSDPA Multipoint Transmission |  | 203d? | 2010-12-10 A | 2011-09-16 A | 100% | 2010-12-10 | 2011-09-16 | 203d? | finish no earlier than 2011-09-16 | R1; R2; R3 | 4872h | 4872h | FS_HSDPA_MP_TX | PCG-26 | UTRA 25.872 | Nokia Siemens Networks | Rel-11 | RP-50 | Patrick | FS_HSDPA_MP_TX | RP-111049 |  |  |  |
| 2993 | 756 | Study on UE Over The Air (OTA) test method with Head and Hand Phantoms |  | 258d? | 2011-09-19 A | 2012-09-07 A | 100% | 2011-09-19 | 2012-09-07 | 258d? | finish no earlier than 2012-09-07 | R4; R5 | 4128h | 4128h | FS_OTA_phantoms_UTRA | PCG-27 | UTRA 25.914 | Nokia | Rel-11 | RP-53 | Issam | FS_OTA_phantoms_UTRA | RP-121078 |  |  |  |
| 2994 | 757 | Study on HSPA feedback and signalling efficiency enhancements for LCR TDD |  | 199d? | 2011-12-07 A | 2012-09-07 A | 100% | 2011-12-07 | 2012-09-07 | 199d? | finish no earlier than 2012-09-07 | R1 | 1584h | 1584h | FS_LCRTDD_HSPAenh | PCG-28 | UTRA 25.874 | TD Tech | Rel-11 | RP-54 | Patrick | FS_LCRTDD_HSPAenh | RP-121079 |  |  |  |
| 2995 | 758 | Deleted - Study on Enhanced Uplink Transmission for LTE |  | 328d? | 2011-03-22 A | 2012-06-15 A | 100% | 2011-03-22 | 2012-06-15 | 328d? | finish no earlier than 2012-06-15 | R1 | 2624h | 2624h | FS_eUL_TX_LTE | PCG-26 | LTE 36.8xy | Huawei | Rel-11 | RP-51 | Patrick | FS_eUL_TX_LTE | RP-120585 |  | PCG-29 | RP-56 |
| 2996 | 759 | Release 10 Features |  | 728d? | 2008-12-11 A | 2011-09-21 A | 100% | 2008-12-11 | 2011-09-21 | 728d? | finish no earlier than 2011-09-21 | CP; GP; RP; SP | 23296h | 23296h |  |  |  |  | Rel-10 |  |  |  |  |  |  |  |

Notes:
- 2950: Stage 3 / WI rapporteur e-mail: muhammad.kazmi@ericsson.com
- 2951: RP#57 completed. RP#62 existing TS 25.317 replaced by new TS 25.327 / WI rapporteur e-mail: muhammad.kazmi@ericsson.com
- 2952: RP#57 completed / WI rapporteur e-mail: muhammad.kazmi@ericsson.com
- 2953: SP#65 completed. TS 34.229-4 for Approval. Split out of old TS 34.229-3 a new TS 34.229-4 / WI rapporteur e-mail: richard.catmur@spirent.com
- 2954: SP#50 EU-Alert is introduced under Public Warning System in parallel with the already existing ETWS and CMAS. SA1 22.268 CR#9r1 adds EU-ALERT specific requirements & CT1 23.041 CRs#
- 2955: -
- 2956: CP#62 completed / WI rapporteur e-mail: Lionel Morand
- 2957: -
- 2958: SP#48 completed. 3/3/15: start date corrected (was 05/09) / WI rapporteur e-mail: Li Gang (ligangyf@chinamobile.com)
- 2959: SP#53 completed. Spin-off Feature UID_500030 Non Voice Emergency Services (NOVES) / WI rapporteur e-mail: dwilliams@qualcomm.com
- 2960: SP#51 completed. Support Interworking between 3GPP networks and Enterprise environments to provide enterprise voice services via 3GPP mobile devices / WI rapporteur e-mail: Phillip Brown (pbrown@tatarasystems.com)
- 2961: SP#52 completed / WI rapporteur e-mail: mona.mustapha@vodafone.com
- 2962: SP#54 completed / WI rapporteur e-mail: Li Gang (ligangyf@chinamobile.com), Yu Qing (yuqing@chinamobile.com)
- 2963: SP#52 completed. 3/3/15: start and finish dates corrected (was start on Jan-00, ends on Jan-02) / WI rapporteur e-mail: farooq.bari@att.com
- 2964: SP#52 completed / WI rapporteur e-mail: Li Lianyuan (lilianyuan@chinamobile.com), Liu Hong (liuhongyfw@chinamobile.com)
- 2965: SP#54 completed. Study on "reverse direction" from UTRAN/GERAN to E-UTRAN/HSPA (Rel-8 SRVCC was in the other direction E-UTRAN/HSPA to GERAN/UTRAN) / WI rapporteur e-mail: delphin.barankanira@orange-ftgroup.com
- 2966: SP#54 completed. Linked to Rel-11 OSCAR (Optimized Service Charging and Allocation of ResourcES in CP-150IMS whilst Roaming) UID_490032. Related to LBO/home routing decision / WI rapporteur e-mail: michele.zarri@telekom.com
- 2967: SP#55 completed / WI rapporteur e-mail: karl.norrman@ericsson.com
- 2968: SP#56 completed. SP#55 TR 33.914v200 approved (converted 33.804). Study reuse of non-UICC credentials (in particular SIP Digest) to provide security for access to applications. Provide reference material for IMS based non-UICC based SSO to applications / WI rapporteur e-mail: Silke.Holtmanns@nokia.com
- 2969: SP#56 completed. Extends Rel-10 work on 3D video formats UID_480044 Improved Video Coding Support for PSS and MBMS / WI rapporteur e-mail: gilles.teniou@orange-ftgroup.com
- 2970: SP#57 completed. TR 32.833v200 for Approval / WI rapporteur e-mail: Jörg Schmidt (J.Schmidt@nsn.com)
- 2971: SP#54 completed / WI rapporteur e-mail: Nick Mazzarella (njmazzarella@alcatel-lucent.com)
- 2972: SP#54 completed. Triggered by Rel-10 UID_430044 TR 32.826 Study on Energy Savings Management (FS_OAM_ESM) and UID_470037 OAM aspects of Energy Saving in Radio Networks (OAM-ES) / WI rapporteur e-mail: clemens.suerbaum@nsn.com
- 2973: CP#52 completed. Linked to SA5 UID_430044 (FS_OAM-ESM) & UID_470037 (OAM-ES), RAN3 UID_470015 (FS_Energy_LTE), RAN1 UID_460016 (FS_Energy_UMTS) / WI rapporteur e-mail: gottfried.punz@nw.neclab.eu
- 2974: CP#58 completed. Continue work in Rel-11 especially to cover handling of Idle mode Signalling Reduction (ISR). Linked to SA2 UID_490036 Study on Core Network Overload solutions / WI rapporteur e-mail: lu.fei1@zte.com.cn
- 2975: GP#53 completed (03/12). GP#46 approved WID. / WI rapporteur e-mail: marten.sundberg@ericsson.com
- 2976: RP#53 completed / WI rapporteur e-mail: bruno.clerckx@samsung.com
- 2977: RP#53 completed. Studied coexistence scenario of LTE and Industrial, Scientific and Medical (ISM) Radio within the same device working in adjacent frequencies / WI rapporteur e-mail: Zhenping Hu (huzhenping@chinamobile.com)
- 2978: RP#57 completed. TR 36.839 v100 for Information & Approval / WI rapporteur e-mail: sudeep.palat@alcatel-lucent.com
- 2979: RP#54 completed / WI rapporteur e-mail: federico.boccardi@alcatel-lucent.com
- 2980: RP#56 completed. TR 36.828 for Information and Approval / WI rapporteur e-mail: Zukang Shen (shenzukang@catt.cn)
- 2981: RP#56 completed. TR 36.824 v200 for Approval / WI rapporteur e-mail: Peng Chen (chenpeng@ctbri.com.cn)
- 2982: RP#55 completed. TR 36.829 v100 for Information + Approval / WI rapporteur e-mail: Yuta Sagae
- 2983: RP#57 completed / WI rapporteur e-mail: Xudong An (anxudong@emcite.com)
- 2984: RP#55 completed. TR 37.976 v200 for Approval / WI rapporteur e-mail: Tim.frost@vodafone.com
- 2985: RP#57 completed. TR 37.806 v200 for Approval / WI rapporteur e-mail: christian.bergljung@ericsson.com
- 2986: RP#53 completed. TR 37.868v100 for Approval (No WID change: RAN overload only). Triggered by TR 22.868 Study on Facilitating Machine to Machine Communication in GSM and UMTS (M2M) UID_7027 and Rel-10 NIMTC UID_410030 / WI rapporteur e-mail: Jeff Gao (gaoyq@huawei.com)
- 2987: RP#54 completed / WI rapporteur e-mail: ron.borsato@spirent.com
- 2988: RP#56 completed. TR 37.803 v200 for Approval / WI rapporteur e-mail: Martin.Warner@alcatel-lucent.com
- 2989: RP#56 completed. Impacts TR 37.804 Study on UMTS/LTE in 900 MHz band (Japan, Korea) UID_520018 / WI rapporteur e-mail: Koo Yeon Sang (yskoo@lguplus.co.kr)
- 2990: RP#56 completed. Updated WID RP-111751=>RP-120617. TR 37.804 v100 for Information and Approval. Linked to Study on Interference analysis between 800~900 MHz bands UID_510038 / WI rapporteur e-mail: Masahiro Fujii (fujiima@nttdocomo.co.jp)
- 2991: RP#53 completed (1-step Approval) / WI rapporteur e-mail: Sharad Sambhwani
- 2992: RP#53 completed / WI rapporteur e-mail: karri.ranta-aho@nsn.com
- 2993: RP#57 completed / WI rapporteur e-mail: petri.j.vasenkari@nokia.com
- 2994: RP#57 completed. TR 25.874 v100 for Information & Approval / WI rapporteur e-mail: limei.wei@td-tech.com
- 2995: RP#56 stopped. RP-120856 discussion: most content moved to Rel-11 Coordinated Multi-Point Operation for LTE Uplink (COMP_LTE_UL) and RAN1 has no time to look at it / WI rapporteur e-mail: Yongxing Zhou
- 2996: -

| ID | WBS | Task | Duration | Start | Finish | Complete | Baseline start | Baseline finish | Baseline duration | Constraint | Resources | Work | Actual work | Acronym | PCG approved | WI rapporteur name | WI rapporteur e-mail | Release | TSG approved | MCC resp | Special Focus Doc | Acronym_3GU_Export | PCG stopped | TSG stopped | Status Report |
| --- | --- | --- | --- | --- | --- | --- | --- | --- | --- | --- | --- | --- | --- | --- | --- | --- | --- | --- | --- | --- | --- | --- | --- | --- | --- |
| 2997 | 760 | **Enhancements for Multimedia Priority Service** | 1311d? | 2006-03-13 A | 2011-03-18 A | 100% | 2006-03-13 | 2011-03-18 | 1311d? |  | S1; S2; C4; C3; C1 | 72120h | 72120h | eMPS | PCG-21 | Telcordia | jgarraha@telcordia.com | Rel-10 | SP-39 | Alain | Public Safety (I-A) | eMPS |  |  |  |
| 2998 | 760.1 | Stage 1 on enhancements for Multimedia Priority Service | 584d? | 2006-03-13 A | 2008-06-05 A | 100% | 2006-03-13 | 2008-06-05 | 584d? | start no earlier than 2006-03-12 | S1 | 4672h | 4672h | ePRIOR-St1 | PCG-21 | Telcordia | jgarraha@telcordia.com | Rel-10 | SP-39 | Alain | Public Safety (I-A) | ePRIOR |  |  |  |
| 2999 | 760.2 | **Stage 2 on enhancements for Multimedia Priority Service** | 206d? | 2009-12-10 A | 2010-09-23 A | 100% | 2009-12-10 | 2010-09-23 | 206d? |  | S2 | 6592h | 6592h | ePRIOR-St2 | PCG-24 | Telcordia, NTT DoCoMo | Vijay Varma, Katsutoshi Nishida | Rel-10 | SP-46 | Maurice | Public Safety (I-A) |  |  |  |  |
| 3000 | 760.2.1 | Stage 2 on eMPS for CSFB | 206d? | 2009-12-10 A | 2010-09-23 A | 100% | 2009-12-10 | 2010-09-23 | 206d? | finish no earlier than 2010-09-24 | S2 | 1648h | 1648h | ePRIOR-St2 | PCG-24 | Telcordia, NTT DoCoMo | Vijay Varma, Katsutoshi Nishida | Rel-10 | SP-46 | Maurice | Public Safety (I-A) |  |  |  |  |
| 3001 | 760.2.2 | Stage 2 on eMPS for EPS Bearer Service | 206d? | 2009-12-10 A | 2010-09-23 A | 100% | 2009-12-10 | 2010-09-23 | 206d? | finish no earlier than 2010-12-09 | S2 | 1648h | 1648h | ePRIOR-St2 | PCG-24 | Telcordia, NTT DoCoMo | Vijay Varma, Katsutoshi Nishida | Rel-10 | SP-46 | Maurice | Public Safety (I-A) |  |  |  |  |
| 3002 | 760.2.3 | Stage 2 on eMPS for IMS Aspects | 206d? | 2009-12-10 A | 2010-09-23 A | 100% | 2009-12-10 | 2010-09-23 | 206d? | finish no earlier than 2010-12-09 | S2 | 1648h | 1648h | ePRIOR-St2 | PCG-24 | Telcordia, NTT DoCoMo | Vijay Varma, Katsutoshi Nishida | Rel-10 | SP-46 | Maurice | Public Safety (I-A) |  |  |  |  |
| 3003 | 760.3 | Deleted - TR 23.854 on Stage 2 on enhancements for Multimedia Priority Service | 266d? | 2009-12-10 A | 2010-12-16 A | 100% | 2009-12-10 | 2010-12-16 | 266d? | finish no earlier than 2011-03-17 | S2 | 2128h | 2128h |  | PCG-24 | Telcordia, NTT DoCoMo | Vijay Varma, Katsutoshi Nishida | Rel-10 | SP-46 | Maurice | Public Safety (I-A) |  | PCG-27 | SP-50 |  |
| 3004 | 760.4 | **Stage 3 on enhancements for Multimedia Priority Service** | 131d? | 2010-09-17 A | 2011-03-18 A | 100% | 2010-09-17 | 2011-03-18 | 131d? |  | C4; C3; C1 | 6288h | 6288h | eMPS-CN | PCG-25 | Ericsson | Philip.hodges@ericsson.com | Rel-10 | CP-49 | Kimmo | Public Safety (I-A) | eMPS-CN |  |  |  |
| 3005 | 760.4.1 | CT4 part on Stage 3 on enhancements for Multimedia Priority Service | 131d? | 2010-09-17 A | 2011-03-18 A | 100% | 2010-09-17 | 2011-03-18 | 131d? | start no earlier than 2010-09-17 | C4 | 1048h | 1048h | eMPS-CN | PCG-25 | Ericsson | Philip.hodges@ericsson.com | Rel-10 | CP-49 | Kimmo | Public Safety (I-A) |  |  |  |  |
| 3006 | 760.4.2 | CT3 part on Stage 3 on enhancements for Multimedia Priority Service | 131d? | 2010-09-17 A | 2011-03-18 A | 100% | 2010-09-17 | 2011-03-18 | 131d? | start no earlier than 2010-09-17 | C3 | 1048h | 1048h | eMPS-CN | PCG-25 | Ericsson | Philip.hodges@ericsson.com | Rel-10 | CP-49 | Adrian | Public Safety (I-A) |  |  |  |  |
| 3007 | 760.4.3 | CT1 part on Stage 3 on enhancements for Multimedia Priority Service | 131d? | 2010-09-17 A | 2011-03-18 A | 100% | 2010-09-17 | 2011-03-18 | 131d? | start no earlier than 2010-09-17 | C1 | 1048h | 1048h | eMPS-CN | PCG-25 | Ericsson | Philip.hodges@ericsson.com | Rel-10 | CP-49 | Frederic | Public Safety (I-A) |  |  |  |  |
| 3008 | 761 | **Network Improvements for Machine-Type Communications** | 1365d? | 2008-09-18 A | 2013-11-22 A | 100% | 2008-09-18 | 2013-11-22 | 1365d? |  | S1; S2; S5; C1; C4; C6; G2; R2; R3; R5; G3new | 149017h | 149017h | NIMTC | PCG-21 | KPN | toon.norp@tno.nl | Rel-10 | SP-41 | Alain | MTC, M2M | NIMTC |  |  |  |
| 3009 | 761.1 | Stage 1 for Network Improvements for Machine-Type Communications | 397d? | 2008-09-18 A | 2010-03-25 A | 100% | 2008-09-18 | 2010-03-25 | 397d? | finish no earlier than 2009-12-10 | S1 | 3176h | 3176h | NIMTC | PCG-21 | KPN | toon.norp@tno.nl | Rel-10 | SP-41 | Alain | MTC, M2M |  |  |  |  |
| 3010 | 761.2 | Deleted - TR on Stage 2 for Network Improvements for Machine-Type Communications | 321d? | 2009-09-24 A | 2010-12-16 A | 100% | 2009-09-24 | 2010-12-16 | 321d? | finish no earlier than 2010-11-30 | S2 | 2568h | 2568h | NIMTC | PCG-23 | Samsung | erik.guttman@partner.samsung.com | Rel-10 | SP-45 | Maurice | MTC, M2M |  | PCG-26 | SP-50 |  |
| 3011 | 761.3 | Stage 2 for Network Improvements for Machine-Type Communications | 19d? | 2010-08-30 A | 2010-09-23 A | 100% | 2010-08-30 | 2010-09-23 | 19d? | finish no earlier than 2010-09-17 | S2 | 152h | 152h | NIMTC | PCG-23 | Samsung | erik.guttman@partner.samsung.com | Rel-10 | SP-45 | Maurice | MTC, M2M |  |  |  |  |
| 3012 | 761.4 | Deleted - Security for Network Improvements for Machine-Type Communications | 193.15d? | 2009-12-10 A | 2010-09-23 A | 100% | 2009-12-10 | 2010-09-23 | 193.15d? | finish no earlier than 2010-09-23 | S3 | 1545.2h | 1545.2h | NIMTC | PCG-24 | Samsung | Rajavelsamy R (rajvel@samsung.com) | Rel-10 | SP-46 | Mirko | MTC, M2M |  | PCG-25 | SP-49 |  |
| 3013 | 761.5 | Charging for Network Improvements for Machine-Type Communication | 3d? | 2011-03-21 A | 2011-03-23 A | 100% | 2011-03-21 | 2011-03-23 | 3d? | start no earlier than 2011-03-21 | S5 | 24h | 24h | NIMTC-CH | PCG-26 | Ericsson | patrik.teppo@@ericsson.com | Rel-10 | SP-51 | Mirko | MTC, M2M | NIMTC-CH |  |  |  |
| 3014 | 761.6 | **CN part of Stage 3 for Network Improvements for Machine-Type Communications** | 261d? | 2010-06-04 A | 2011-06-03 A | 100% | 2010-06-04 | 2011-06-03 | 261d? |  | C1; C4; C6 | 12976h | 12976h | NIMTC-CN | PCG-25 | Ericsson | mikael.wass@ericsson.com | Rel-10 | CP-48 | Frederic | MTC, M2M | NIMTC-CN |  |  |  |
| 3015 | 761.6.1 | CT1 part of Stage 3 for Network Improvements for Machine-Type Communications | 261d? | 2010-06-04 A | 2011-06-03 A | 100% | 2010-06-04 | 2011-06-03 | 261d? | finish no earlier than 2011-06-03 | C1 | 2088h | 2088h | NIMTC-CN | PCG-25 | Ericsson | mikael.wass@ericsson.com | Rel-10 | CP-48 | Frederic | MTC, M2M |  |  |  |  |
| 3016 | 761.6.2 | Deleted - CT3 part of Stage 3 for Network Improvements for Machine-Type Communications | 261d? | 2010-06-04 A | 2011-06-03 A | 100% | 2010-06-04 | 2011-06-03 | 261d? | finish no earlier than 2010-12-10 | C3 | 2088h | 2088h | NIMTC-CN | PCG-25 | Ericsson | mikael.wass@ericsson.com | Rel-10 | CP-48 | Adrian | MTC, M2M |  | PCG-27 | CP-52 |  |
| 3017 | 761.6.3 | CT4 part of Stage 3 for Network Improvements for Machine-Type Communications | 261d? | 2010-06-04 A | 2011-06-03 A | 100% | 2010-06-04 | 2011-06-03 | 261d? | finish no earlier than 2011-03-18 | C4 | 2088h | 2088h | NIMTC-CN | PCG-25 | Ericsson | mikael.wass@ericsson.com | Rel-10 | CP-48 | Kimmo | MTC, M2M |  |  |  |  |
| 3018 | 761.6.4 | CT6 part of Stage 3 for Network Improvements for Machine-Type Communications | 56d? | 2011-03-18 A | 2011-06-03 A | 100% | 2011-03-18 | 2011-06-03 | 56d? | finish no earlier than 2011-06-03 | C6 | 448h | 448h | NIMTC-CN | PCG-26 | Sagem-Orga | heiko.kruse@sagem-orga.com | Rel-10 | CP-51 | Xavier | MTC, M2M |  |  |  |  |
| 3019 | 761.7 | GERAN part of Network Improvements for Machine-Type Communications (Stage 3) | 261d? | 2010-09-03 A | 2011-09-02 A | 100% | 2010-09-03 | 2011-09-02 | 261d? | finish no earlier than 2011-09-02 | G2 | 2088h | 2088h | NIMTC | PCG-25 | Vodafone, Ericsson | leo.patanapongpibul@vodafone.com, john.diachina@ericsson.com | Rel-10 | GP-47 | Gert | MTC, M2M |  |  |  |  |
| 3020 | 761.8 | MS Conformance Test Aspects for GERAN - Network Improvements for Machine-Type Communications | 333d? | 2012-08-27 A | 2013-11-22 A | 100% | 2012-08-27 | 2013-11-22 | 333d? | finish no earlier than 2013-11-22 | G3new | 2656h | 2656h | NIMTC_GERAN-MSTest | PCG-29 | ST-Ericsson | hakan.e.grunditz@stericsson.com | Rel-10 | GP-55 | Ingbert | MTC, M2M | NIMTC_GERAN-MSTest |  |  |  |
| 3021 | 761.9 | RAN mechanisms to avoid CN overload due to Machine-Type Communications | 131d? | 2010-09-17 A | 2011-03-18 A | 100% | 2010-09-17 | 2011-03-18 | 131d? | finish no earlier than 2011-03-18 | R2; R3 | 2096h | 2096h | NIMTC-RAN_overload | PCG-25 | Huawei | Jeff Gao (gaoyq@huawei.com) | Rel-10 | RP-49 | Yong-Jun | MTC, M2M | NIMTC-RAN_overload |  |  | RP-110063 |
| 3022 | 761.10 | UE Conformance Test Aspects - Network Improvements for Machine-Type Communications | 202d? | 2012-09-11 A | 2013-06-14 A | 100% | 2012-09-11 | 2013-06-14 | 202d? | finish no earlier than 2013-06-14 | R5 | 1616h | 1616h | NIMTC-UEConTest | PCG-29 | Ericsson | calle.hagenfeldt@ericsson.com | Rel-10 | RP-57 | Ingbert | MTC, M2M | NIMTC-UEConTest |  |  | RP-130465 |

Notes:
- 2997: CP#51 completed. SP#49 moved Stage 1 from Rel-9 & Completed Stage 2. SP#40 Stage 1 completed. Continuation of Rel-8 Feature PRIOR (UID_340044)
- 2998: 22/01: acronym modified / Impacted TSs and TRs: 22.153, 22.278
- 2999: 22/01: acronym modified
- 3000: 22/01: acronym modified / Impacted TSs and TRs: 23.002, 23.203, 23.221, 23.228, 23.272, 23.401
- 3001: 22/01: acronym modified / Impacted TSs and TRs: 23.002, 23.203, 23.221, 23.228, 23.272, 23.401
- 3002: 22/01: acronym modified / Impacted TSs and TRs: 23.002, 23.203, 23.221, 23.228, 23.272, 23.401
- 3003: SP#49 TR 23.854 v100 for Information. SP#50 moved to Rel-11 SRVCC aspect of enhancements for Multimedia Priority Service UID_480135 (place holder for solution alternatives and agreed functions to be reflected in affected existing TS) / Impacted TSs and TRs: new TR 23.854
- 3004: CP#51 completed / Impacted TSs and TRs: Stage 3
- 3005: CP#51 completed / Impacted TSs and TRs: 23.008, 29.002, 29.228, 29.229, 29.272, 29.274, 29.277, 29.328, 29.329
- 3006: CP#51 completed / Impacted TSs and TRs: 29.212, 29.213, 29.214
- 3007: CP#51 completed / Impacted TSs and TRs: 24.008, 24.229, 24.301
- 3008: Triggered by Rel-8 UID_7027 Study on Facilitating Machine to Machine Communication in GSM and UMTS (FS_M2M) TR 22.868
- 3009: SP#47 completed / Impacted TSs and TRs: 22.011, New 22.368
- 3010: SP#50 updated WID SP-090832=>SP-100863 (TR 23.888 not submitted for approval to conclude Rel-10 NIMTC as it will continue to serve as basis for Rel-11 SIMTC work item) / Impacted TSs and TRs: New TR 23.888
- 3011: SP#49 completed / Impacted TSs and TRs: 23.060, 23.236, 23.401
- 3012: SP#49 stopped (activity transferred to Rel-11 Feature SIMTC under UID_490028 "TR on Security aspects of Machine-Type Communications". / Impacted TSs and TRs: New TR 33.868
- 3013: SP#51 completed / Impacted TSs and TRs: 32.251, 32.298, 32.299
- 3014: CP#52 completed / Impacted TSs and TRs: Stage 3
- 3015: CP#52 completed / Impacted TSs and TRs: 23.122, 24.008, 24.301, New 24.368
- 3016: CP#52 stopped (SA2 decided to move impact from CT3 to CT4). Updated WID CP-110147=>CP-110442 (no CT3 impact) / Impacted TSs and TRs: 29.212, 29.213, 29.215
- 3017: CP#52 completed / Impacted TSs and TRs: 23.003, 23.008, 29.002, 29.060, 29.230, 29.272, 29.274, 29.275, 29.282
- 3018: CP#52 completed / Impacted TSs and TRs: 31.102
- 3019: GP#51 completed. GP#47 approved WID / Impacted TSs and TRs: 44.018, 44.060
- 3020: GP#60 completed. GP#55 approved WID. Testing for CT1 part of Stage 3 for NIMTC UID_480105, GERAN part of NIMTC (Stage 3) UID_490003 / Impacted TSs and TRs: 51.010-1, 51.010-2
- 3021: RP#51 completed / Impacted TSs and TRs: UTRA, LTE 25.331, 25.413, 36.331, 36.413
- 3022: RP#60 completed. Testing for CT1 part of Stage 3 UID_480105, RAN mechanisms to avoid CN overload due to MTC UID_490024 / Impacted TSs and TRs: 34.123-1, 34.123-2, 34.123-3, 36.523-1, 36.523-2, 36.523-3

| ID | WBS | Task | Duration | Start | Finish | Complete | Baseline start | Baseline finish | Baseline duration | Constraint | Resources | Work | Actual work | Acronym | PCG approved | WI rapporteur name | Release | TSG approved | MCC resp | Acronym_3GU_Export | Special Focus Doc |
| --- | --- | --- | --- | --- | --- | --- | --- | --- | --- | --- | --- | --- | --- | --- | --- | --- | --- | --- | --- | --- | --- |
| 3023 | 762 | **Multi Access PDN Connectivity** | 527d? | 2009-03-13 A | 2011-03-18 A | 100% | 2009-03-13 | 2011-03-18 | 527d? |  | S2; C4; C1; C3 | 23680h | 23680h | MAPCON | PCG-22 | Telecom Italia | Rel-10 | SP-43 | Maurice | MAPCON |  |
| 3024 | 762.1 | Stage 2 for Multi Access PDN Connectivity | 401d? | 2009-03-13 A | 2010-09-23 A | 100% | 2009-03-13 | 2010-09-23 | 401d? |  | S2 | 3208h | 3208h | MAPCON |  | Telecom Italia | Rel-10 | TSG-43 | Maurice |  |  |
| 3025 | 762.2 | **CT aspects of Multi Access PDN Connectivity** | 90d? | 2010-11-15 A | 2011-03-18 A | 100% | 2010-11-15 | 2011-03-18 | 90d? |  | C4; C1; C3 | 3608h | 3608h | MAPCON-St3 | PCG-26 | ZTE | Rel-10 | CP-50 | Kimmo | MAPCON-St3 |  |
| 3026 | 762.2.1 | CT4 aspects of Multi Access PDN Connectivity | 20d? | 2010-11-15 A | 2010-12-10 A | 100% | 2010-11-15 | 2010-12-10 | 20d? | start no earlier than 2010-12-10 | C4 | 160h | 160h | MAPCON-St3 | PCG-26 | ZTE | Rel-10 | CP-50 | Kimmo |  |  |
| 3027 | 762.2.2 | CT1 aspects of Multi Access PDN Connectivity | 71d? | 2010-12-10 A | 2011-03-18 A | 100% | 2010-12-10 | 2011-03-18 | 71d? | start no earlier than 2010-12-10 | C1 | 568h | 568h | MAPCON-St3 | PCG-26 | ZTE | Rel-10 | CP-50 | Frederic |  |  |
| 3028 | 762.2.3 | CT3 aspects of Multi Access PDN Connectivity | 90d? | 2010-11-15 A | 2011-03-18 A | 100% | 2010-11-15 | 2011-03-18 | 90d? | finish no earlier than 2011-03-18 | C3 | 720h | 720h | MAPCON-St3 | PCG-26 | ZTE | Rel-10 | CP-50 | Adrian |  |  |
| 3029 | 763 | **IMS Service Continuity – Inter Device Transfer enhancements** | 924d? | 2009-06-04 A | 2012-12-07 A | 100% | 2009-06-04 | 2012-12-07 | 924d? |  | S1; S2; C1; IETF | 41168h | 41168h | IMS_SC_eIDT | PCG-23 | Huawei | Rel-10 | SP-44 | Alain | IMS_SC_eIDT |  |
| 3030 | 763.1 | Stage 1 - IMS Service Continuity – Inter Device Transfer enhancements | 211d? | 2009-06-04 A | 2010-03-25 A | 100% | 2009-06-04 | 2010-03-25 | 211d? | finish no earlier than 2010-03-25 | S1 | 1688h | 1688h | IMS_SC_eIDT | PCG-23 | Huawei | Rel-10 | SP-44 | Alain |  |  |
| 3031 | 763.2 | Stage 2 - IMS Inter-UE Transfer enhancements | 261d? | 2009-09-24 A | 2010-09-23 A | 100% | 2009-09-24 | 2010-09-23 | 261d? | finish no earlier than 2010-09-23 | S2 | 2088h | 2088h | IMS_SC_eIDT | PCG-23 | Huawei | Rel-10 | SP-45 | Maurice |  |  |
| 3032 | 763.3 | Stage 3 - IMS Inter-UE Transfer enhancements | 261d? | 2010-03-19 A | 2011-03-18 A | 100% | 2010-03-19 | 2011-03-18 | 261d? | start no earlier than 2010-03-19 | C1 | 2088h | 2088h | IMS_SC_eIDT | PCG-24 | Huawei | Rel-10 | CP-47 | Frederic |  |  |
| 3033 | 763.4 | (IETF) Stage 3 - IMS Inter-UE Transfer enhancements | 717d? | 2010-03-19 A | 2012-12-07 A | 100% | 2010-03-19 | 2012-12-07 | 717d? | finish no earlier than 2012-12-04 | C1-IETF | 5736h | 5736h | IMS_SC_eIDT | PCG-27 | christer.holmberg@ericsson.com | Rel-10 | CP-52 | Frederic |  |  |
| 3034 | 764 | **IP-Short-Message-Gateway enhancements for CPM-SMS Interworking** | 257d? | 2009-09-24 A | 2010-09-17 A | 100% | 2009-09-24 | 2010-09-17 | 257d? |  | S1; S2; C3 | 9904.8h | 9904.8h | CPM-SMS | PCG-23 | China Mobile | Rel-10 | SP-45 | Alain | CPM-SMS |  |
| 3035 | 764.1 | Stage 1 for CPM-SMS | 131d? | 2009-09-24 A | 2010-03-25 A | 100% | 2009-09-24 | 2010-03-25 | 131d? | finish no earlier than 2010-03-25 | S1 | 1048h | 1048h | CPM-SMS | PCG-23 | China Mobile | Rel-10 | SP-45 | Alain |  |  |
| 3036 | 764.2 | Stage 2 for CPM-SMS | 130.1d? | 2009-09-24 A | 2010-03-25 A | 100% | 2009-09-24 | 2010-03-25 | 130.1d? | finish no earlier than 2010-03-25 | S2 | 1040.8h | 1040.8h | CPM-SMS | PCG-23 | Orange | Rel-10 | SP-45 | Maurice |  |  |
| 3037 | 764.3 | Stage 3 for IP-Short-Message-Gateway enhancements for CPM-SMS Interworking | 206d? | 2009-12-04 A | 2010-09-17 A | 100% | 2009-12-04 | 2010-09-17 | 206d? | finish no earlier than 2010-09-17 | C3 | 1648h | 1648h | CPM-SMS | PCG-24 | Ericsson | Rel-10 | CP-46 | Adrian |  |  |
| 3038 | 765 | **Completion of Communications on Not Logged-in** | 387d? | 2009-09-24 A | 2011-03-18 A | 100% | 2009-09-24 | 2011-03-18 | 387d? |  | S1; C1; C3 | 11992h | 11992h | CCNL | PCG-23 | Deutsche Telekom | Rel-10 | SP-45 | Alain | CCNL |  |
| 3039 | 765.1 | Stage 1 for Completion of Communications on Not Logged-in | 1d? | 2009-09-24 A | 2009-09-24 A | 100% | 2009-09-24 | 2009-09-24 | 1d? | start no earlier than 2009-09-24 | S1 | 8h | 8h | CCNL | PCG-23 | Deutsche Telekom | Rel-10 | SP-45 | Alain |  |  |
| 3040 | 765.2 | CT1 part of Stage 3 for Completion of Communications on Not Logged-in | 261d? | 2010-03-19 A | 2011-03-18 A | 100% | 2010-03-19 | 2011-03-18 | 261d? | finish no earlier than 2011-03-18 | C1 | 2088h | 2088h | CCNL | PCG-24 | Deutsche Telekom | Rel-10 | CP-47 | Frederic |  |  |
| 3041 | 765.3 | CT3 part of Stage 3 for Completion of Communications on Not Logged-in | 76d? | 2010-06-04 A | 2010-09-17 A | 100% | 2010-06-04 | 2010-09-17 | 76d? | finish no earlier than 2010-09-17 | C3 | 608h | 608h | CCNL | PCG-25 | Deutsche Telekom | Rel-10 | CP-48 | Adrian |  |  |
| 3042 | 766 | **Local IP Access and Selected Internet IP Traffic Offload** | 390d? | 2009-09-24 A | 2011-03-23 A | 100% | 2009-09-24 | 2011-03-23 | 390d? |  | S2; S1; S3; S5; C4; C1 | 66128h | 66128h | LIPA_SIPTO | PCG-23 | Huawei, China Mobile | Rel-10 | SP-45 | Maurice | LIPA_SIPTO | HNB |
| 3043 | 766.1 | Stage 1 for Local IP Access and Selected Internet IP Traffic Offload | 131d? | 2009-09-24 A | 2010-03-25 A | 100% | 2009-09-24 | 2010-03-25 | 131d? | finish no earlier than 2010-03-25 | S1 | 1048h | 1048h | LIPA_SIPTO | PCG-23 | Huawei, China Mobile | Rel-10 | SP-45 | Alain |  | HNB |
| 3044 | 766.2 | TR on Local IP Access and Selected Internet IP Traffic Offload | 387d? | 2009-09-24 A | 2011-03-18 A | 100% | 2009-09-24 | 2011-03-18 | 387d? | finish no earlier than 2011-03-18 | S2 | 3096h | 3096h | LIPA_SIPTO | PCG-23 | Huawei, China Mobile | Rel-10 | SP-45 | Maurice |  | HNB |
| 3045 | 766.3 | Security for Local IP Access and Selected Internet IP Traffic Offload | 261d? | 2009-09-24 A | 2010-09-23 A | 100% | 2009-09-24 | 2010-09-23 | 261d? | finish no earlier than 2010-09-23 | S3 | 2088h | 2088h | LIPA_SIPTO | PCG-23 | Huawei, Qualcomm | Rel-10 | SP-45 | Mirko |  | HNB |
| 3046 | 766.4 | OAM&P for Local IP Access and Selected Internet IP Traffic Offload | 390d? | 2009-09-24 A | 2011-03-23 A | 100% | 2009-09-24 | 2011-03-23 | 390d? | finish no earlier than 2011-03-23 | S5 | 3120h | 3120h | LIPA_SIPTO | PCG-23 | Huawei, China Mobile | Rel-10 | SP-45 | Mirko |  | HNB |
| 3047 | 766.5 | Charging for Local IP Access and Selected Internet IP Traffic Offload | 335d? | 2009-12-10 A | 2011-03-23 A | 100% | 2009-12-10 | 2011-03-23 | 335d? | finish no earlier than 2011-03-23 | S5 | 2680h | 2680h | LIPA_SIPTO | PCG-24 | Huawei, China Mobile | Rel-10 | SP-46 | Mirko |  | HNB |

Notes:
- 3023: CP#51 completed. SP#49 Stage 2 completed. Triggered by TR 23.861 UID_410043 FS_MAPIM. Stage 1 in Rel-9 22.278 (6.2 - IP session control) / WI rapporteur e-mail: ivano.guardini@telecomitalia.it
- 3024: SP#49 completed. Triggered by TR 23.861 UID_410043 FS_MAPIM. Stage 1 in Rel-9 22.278 (6.2 - IP session control) / Impacted TSs and TRs: 23.237, 23.401, 23.402 / WI rapporteur e-mail: ivano.guardini@telecomitalia.it
- 3025: CP#51 completed / WI rapporteur e-mail: Xingyue (Joy) Zhou (zhou.xingyue@zte.com.cn)
- 3026: CP#50 completed / Impacted TSs and TRs: 29.273, 29.272, 29.002, 23.008 / WI rapporteur e-mail: Xingyue (Joy) Zhou (zhou.xingyue@zte.com.cn)
- 3027: CP#51 completed / Impacted TSs and TRs: 24.302, 24.312 / WI rapporteur e-mail: Xingyue (Joy) Zhou (zhou.xingyue@zte.com.cn)
- 3028: CP#51 completed / Impacted TSs and TRs: 29.215 / WI rapporteur e-mail: Xingyue (Joy) Zhou (zhou.xingyue@zte.com.cn)
- 3029: CP#51 completed. SP#47 Stage 1 completed. Rel-9 set Inter-Device Transfer requirements UID_410033 (IMS_SCC-IDT). Adds IDT scenarios and requirements / WI rapporteur e-mail: Amar Deol (adeol@huawei.com)
- 3030: SP#47 completed / Impacted TSs and TRs: 22.228 / WI rapporteur e-mail: Amar Deol (adeol@huawei.com)
- 3031: SP#49 completed / Impacted TSs and TRs: 23.237, 23.292, new 23.831 / WI rapporteur e-mail: Lee Valerius (lvalerius@huawei.com)
- 3032: CP#51 completed. WID updated CP-100334=>CP-110285 / Impacted TSs and TRs: 24.216, 24.229, 24.237, new (24.837, 24.337) / WI rapporteur e-mail: georg.mayer@huawei.com
- 3033: CP#58 completed / Impacted TSs and TRs: RFC 6809 (was draft-ietf-sipcore-proxy-feature) / WI rapporteur e-mail: christer.holmberg@ericsson.com
- 3034: CP#49 completed. SP#47 Stage 1 completed. IP-SM-GW enhancements for interworking with OMA CPM / WI rapporteur e-mail: Qing Huang (huangqing@chinamobile.com)
- 3035: SP#47 completed. External requirements (Stage 1 in OMA-RD-CPM-V1_0-20090310-C) / Impacted TSs and TRs: 22.340 / WI rapporteur e-mail: Qing Huang
- 3036: SP#47 completed / Impacted TSs and TRs: 23.204, new TR 23.824 / WI rapporteur e-mail: antoine.mouquet@orange-ftgroup.com
- 3037: CP#49 completed. Linked to Rel-8 UID_340031 Service-Level Interworking for Messaging Services (MESSIW) 23.204 / Impacted TSs and TRs: 29.311 / WI rapporteur e-mail: Jan Holm
- 3038: CP#51 completed. SP#45 Stage 1 completed / WI rapporteur e-mail: Kurt Bischinger
- 3039: SP#45 completed / Impacted TSs and TRs: 22.173 CR#0056r1 / WI rapporteur e-mail: Kurt Bischinger
- 3040: CP#51 completed / Impacted TSs and TRs: 24.173, 24.642 / WI rapporteur e-mail: martin.huelsemann@telekom.de
- 3041: CP#49 completed / Impacted TSs and TRs: 29.165 / WI rapporteur e-mail: martin.huelsemann@telekom.de
- 3042: TSG#51 completed. Updated WID SP-100696=>SP-110131. SP#49 Stage 2 & Security completed. UID_400035 Enhanced Home NodeB/eNodeB (EHNB) formerly covered Local IP Access to Internet and Local access to Home Network from the Home NodeB/eNodeB / WI rapporteur e-mail: patrice.hede@huawei.com, Tao Sun (suntao@chinamobile.com)
- 3043: SP#47 completed / Impacted TSs and TRs: 22.101, 22.220 / WI rapporteur e-mail: Amar Deol (adeolf@huawei.com), Gang Li (ligangyf@chinamobile.com)
- 3044: SP#51 completed. TR 23.829 for Approval / Impacted TSs and TRs: New TR 23.829 / WI rapporteur e-mail: patrice.hede@huawei.com, Tao Sun (suntao@chinamobile.com)
- 3045: SP#49 completed / Impacted TSs and TRs: 33.102, 33.107, 33.108, 33.320, 33.401 / WI rapporteur e-mail: Marcus Wong (mwong@huawei.com), Brian Rosenberg (bmr@qualcomm.com)
- 3046: SP#51 completed. Updated WID SP-100696=>SP-110131 / Impacted TSs and TRs: 32.581, 32.582, 32.584, 32.591, 32.592, 32.642, 32.646, 32.772, 32.782 / WI rapporteur e-mail: Zou Lan (zlan@huawei.com), Chen Gang (chengang@chinamobile.com)
- 3047: SP#51 completed. Updated WID SP-100696=>SP-110131 / Impacted TSs and TRs: 32.251 / WI rapporteur e-mail: shan.mingjun@huawei.com, Ai Chen (chenai@chinamobile.com)

| ID | WBS | Task | Duration | Start | Finish | Complete | Baseline start | Baseline finish | Baseline duration | Constraint | Resources | Work | Actual work | Acronym | PCG approved | WI rapporteur name | WI rapporteur e-mail | Release | TSG approved | MCC resp | Special Focus Doc | Acronym_3GU_Export |
| --- | --- | --- | --- | --- | --- | --- | --- | --- | --- | --- | --- | --- | --- | --- | --- | --- | --- | --- | --- | --- | --- | --- |
| 3048 | 766.6 | **Stage 2/3 for Local IP Access** | 387d? | 2009-09-24 A | 2011-03-18 A | 100% | 2009-09-24 | 2011-03-18 | 387d? |  | S2; C4; C1 | 17968h | 17968h | LIPA | PCG-23 | Huawei, China Mobile | patrice.hede@huawei.com, Tao Sun (suntao@chinamobile.com) | Rel-10 | SP-45 | Maurice | HNB | LIPA |
| 3049 | 766.6.1 | Stage 2 for Local IP Access | 261d? | 2009-09-24 A | 2010-09-23 A | 100% | 2009-09-24 | 2010-09-23 | 261d? | finish no earlier than 2010-08-10 | S2 | 2088h | 2088h | LIPA | PCG-23 | Huawei, China Mobile | patrice.hede@huawei.com, Tao Sun (suntao@chinamobile.com) | Rel-10 | SP-45 | Maurice | HNB |  |
| 3050 | 766.6.2 | **Stage 3 for Local IP Access** | 206d? | 2010-06-04 A | 2011-03-18 A | 100% | 2010-06-04 | 2011-03-18 | 206d? |  | C4; C1 | 6592h | 6592h | LIPA | PCG-25 | China Mobile | Zhang Hao (zhanghao@chinamobile.com) | Rel-10 | CP-48 | Kimmo | HNB |  |
| 3051 | 766.6.2.1 | CT4 part of Stage 3 for Local IP Access | 206d? | 2010-06-04 A | 2011-03-18 A | 100% | 2010-06-04 | 2011-03-18 | 206d? | finish no earlier than 2011-03-18 | C4 | 1648h | 1648h | LIPA | PCG-25 | China Mobile | Zhang Hao (zhanghao@chinamobile.com) | Rel-10 | CP-48 | Kimmo | HNB |  |
| 3052 | 766.6.2.2 | CT1 part of Stage 3 for Local IP Access | 206d? | 2010-06-04 A | 2011-03-18 A | 100% | 2010-06-04 | 2011-03-18 | 206d? | finish no earlier than 2011-03-18 | C1 | 1648h | 1648h | LIPA | PCG-25 | China Mobile | Zhang Hao (zhanghao@chinamobile.com) | Rel-10 | CP-48 | Frederic | HNB |  |
| 3053 | 766.7 | **Stage 2/3 for SIPTO for macro networks** | 387d? | 2009-09-24 A | 2011-03-18 A | 100% | 2009-09-24 | 2011-03-18 | 387d? |  | S2; C4; C1 | 17408h | 17408h | SIPTO | PCG-23 | Huawei, China Mobile | patrice.hede@huawei.com, Tao Sun (suntao@chinamobile.com) | Rel-10 | SP-45 | Maurice | HNB | SIPTO |
| 3054 | 766.7.1 | Stage 2 for SIPTO for macro networks | 261d? | 2009-09-24 A | 2010-09-23 A | 100% | 2009-09-24 | 2010-09-23 | 261d? | finish no earlier than 2010-09-23 | S2 | 2088h | 2088h | SIPTO | PCG-23 | Huawei, China Mobile | patrice.hede@huawei.com, Tao Sun (suntao@chinamobile.com) | Rel-10 | SP-45 | Maurice | HNB |  |
| 3055 | 766.7.2 | **Stage 3 for SIPTO for macro networks** | 206d? | 2010-06-04 A | 2011-03-18 A | 100% | 2010-06-04 | 2011-03-18 | 206d? |  | C4; C1 | 6032h | 6032h | SIPTO | PCG-25 | Huawei | Caixia Qi (qcxmay@huawei.com) | Rel-10 | CP-48 | Kimmo | HNB |  |
| 3056 | 766.7.2.1 | CT4 part of Stage 3 for SIPTO for macro networks | 206d? | 2010-06-04 A | 2011-03-18 A | 100% | 2010-06-04 | 2011-03-18 | 206d? | finish no earlier than 2011-03-18 | C4 | 1648h | 1648h | SIPTO | PCG-25 | Huawei | Caixia Qi (qcxmay@huawei.com) | Rel-10 | CP-48 | Kimmo | HNB |  |
| 3057 | 766.7.2.2 | CT1 part of Stage 3 for SIPTO for macro networks | 136d? | 2010-06-04 A | 2010-12-10 A | 100% | 2010-06-04 | 2010-12-10 | 136d? | finish no earlier than 2011-03-18 | C1 | 1088h | 1088h | SIPTO | PCG-25 | Huawei | Caixia Qi (qcxmay@huawei.com) | Rel-10 | CP-48 | Frederic | HNB |  |
| 3058 | 767 | **IP Flow Mobility and seamless WLAN offload** | 390d? | 2009-09-24 A | 2011-03-23 A | 100% | 2009-09-24 | 2011-03-23 | 390d? |  | S2; S1; S5; C1; C3 | 26808h | 26808h | IFOM | PCG-23 | Qualcomm | Gerardo Giaretta (gerardo@qualcomm.com) | Rel-10 | SP-45 | Maurice | WLAN | IFOM |
| 3059 | 767.1 | Stage 1 for IP Flow Mobility and seamless WLAN offload | 56d? | 2009-09-24 A | 2009-12-10 A | 100% | 2009-09-24 | 2009-12-10 | 56d? | finish no earlier than 2009-12-10 | S1 | 448h | 448h | IFOM | PCG-23 | Qualcomm | David Williams (dwilliam@qualcomm.com) | Rel-10 | SP-45 | Alain | WLAN |  |
| 3060 | 767.2 | Stage 2 for IP Flow Mobility and seamless WLAN offload | 261d? | 2009-09-24 A | 2010-09-23 A | 100% | 2009-09-24 | 2010-09-23 | 261d? | finish no earlier than 2010-09-23 | S2 | 2088h | 2088h | IFOM | PCG-23 | Qualcomm | Gerardo Giaretta (gerardo@qualcomm.com) | Rel-10 | SP-45 | Maurice | WLAN |  |
| 3061 | 767.3 | Charging for IP Flow Mobility and seamless WLAN offload | 260d? | 2010-03-25 A | 2011-03-23 A | 100% | 2010-03-25 | 2011-03-23 | 260d? | finish no earlier than 2011-03-23 | S5 | 2080h | 2080h | IFOM | PCG-24 | Alcatel-Lucent | maryse.gardella@alcatel-lucent.com | Rel-10 | SP-47 | Mirko | WLAN |  |
| 3062 | 767.4 | **Stage 3 for IP Flow Mobility and seamless WLAN offload** | 206d? | 2010-06-04 A | 2011-03-18 A | 100% | 2010-06-04 | 2011-03-18 | 206d? |  | C1; C3 | 6592h | 6592h | IFOM-CT | PCG-25 | Qualcomm | Patrick Stupar (pstupar@qualcomm.com) | Rel-10 | CP-48 | Frederic | WLAN | IFOM-CT |
| 3063 | 767.4.1 | CT1 part of Stage 3 for IP Flow Mobility and seamless WLAN offload | 206d? | 2010-06-04 A | 2011-03-18 A | 100% | 2010-06-04 | 2011-03-18 | 206d? | finish no earlier than 2011-03-18 | C1 | 1648h | 1648h | IFOM-CT | PCG-25 | Qualcomm | Patrick Stupar (pstupar@qualcomm.com) | Rel-10 | CP-48 | Frederic | WLAN |  |
| 3064 | 767.4.2 | CT3 part of Stage 3 for IP Flow Mobility and seamless WLAN offload | 206d? | 2010-06-04 A | 2011-03-18 A | 100% | 2010-06-04 | 2011-03-18 | 206d? | finish no earlier than 2011-03-18 | C3 | 1648h | 1648h | IFOM-CT | PCG-25 | Qualcomm | Patrick Stupar (pstupar@qualcomm.com) | Rel-10 | CP-48 | Adrian | WLAN |  |
| 3065 | 768 | **Enabling Coder Selection and Rate Adaptation for UTRAN and E-UTRAN for Load Adaptive Applications** | 827.4d? | 2009-07-15 A | 2012-09-07 A | 100% | 2009-07-15 | 2012-09-07 | 827.4d? |  | S2; S4; C4; C3; C1; IETF | 85939.2h | 85939.2h | ECSRA_LAA | PCG-23 | Qualcomm | AC Mahendran (ac@qualcomm.com) | Rel-10 | SP-45 | Maurice |  | ECSRA_LAA |
| 3066 | 768.1 | TR on Enabling Coder Selection and Rate Adaptation for UTRAN and E-UTRAN for Load Adaptive Applications | 186d? | 2010-01-07 A | 2010-09-23 A | 100% | 2010-01-07 | 2010-09-23 | 186d? | finish no earlier than 2010-09-23 | S2; S4 | 2976h | 2976h | ECSRA_LAA | PCG-23 | Qualcomm | AC Mahendran (ac@qualcomm.com) | Rel-10 | SP-45 | Maurice |  |  |
| 3067 | 768.2 | SA4 review of TR on Enabling Coder Selection and Rate Adaptation for UTRAN and E-UTRAN for Load Adaptive Applications | 320d? | 2009-09-24 A | 2010-12-15 A | 100% | 2009-09-24 | 2010-12-15 | 320d? | finish no earlier than 2010-12-15 | S4 | 2560h | 2560h | ECSRA_LAA | PCG-23 | Qualcomm | AC Mahendran (ac@qualcomm.com) | Rel-10 | SP-45 | Paolo |  |  |
| 3068 | 768.3 | Stage 2 for Enabling Coder Selection and Rate Adaptation for UTRAN and E-UTRAN for Load Adaptive Applications | 261d? | 2009-09-24 A | 2010-09-23 A | 100% | 2009-09-24 | 2010-09-23 | 261d? | finish no earlier than 2010-09-23 | S2 | 2088h | 2088h | ECSRA_LAA | PCG-23 | Qualcomm | AC Mahendran (ac@qualcomm.com) | Rel-10 | SP-45 | Maurice |  |  |
| 3069 | 768.4 | SA4 aspects of Enabling Coder Selection and Rate Adaptation for UTRAN and E-UTRAN for Load Adaptive Applications | 130d? | 2010-09-23 A | 2011-03-23 A | 100% | 2010-09-23 | 2011-03-23 | 130d? | finish no earlier than 2011-03-23 | S4 | 1040h | 1040h | ECSRA_LAA | PCG-25 | Qualcomm | AC Mahendran (ac@qualcomm.com) | Rel-10 | SP-49 | Paolo |  |  |
| 3070 | 768.5 | **CN aspects of Enabling Coder Selection and Rate Adaptation for UTRAN and E-UTRAN for Load Adaptive Applications** | 827.4d? | 2009-07-15 A | 2012-09-07 A | 100% | 2009-07-15 | 2012-09-07 | 827.4d? |  | C4; C3; C1 | 37560h | 37560h | ECSRA_LAA-CN | PCG-25 | Ericsson | philip.hodges@ericsson.com | Rel-10 | CP-49 | Kimmo |  | ECSRA_LAA-CN |
| 3071 | 768.5.1 | CT4 part of CN aspects of Enabling Coder Selection and Rate Adaptation for UTRAN and E-UTRAN for Load Adaptive Applications | 186d? | 2010-09-17 A | 2011-06-03 A | 100% | 2010-09-17 | 2011-06-03 | 186d? | start no earlier than 2010-09-17 | C4 | 1488h | 1488h | ECSRA_LAA-CN | PCG-25 | Ericsson | philip.hodges@ericsson.com | Rel-10 | CP-49 | Kimmo |  |  |
| 3072 | 768.5.2 | (IETF) CT3, CT4 part of CN aspects of Enabling Coder Selection and Rate Adaptation for UTRAN and E-UTRAN for Load Adaptive Applications | 827.4d? | 2009-07-15 A | 2012-09-07 A | 100% | 2009-07-15 | 2012-09-07 | 827.4d? | finish no earlier than 2012-09-07 | C3-IETF; C4-IETF | 13238.4h | 13238.4h | ECSRA_LAA-CN | PCG-27 | Lionel Morand |  | Rel-10 | CP-53 | Adrian |  |  |
| 3073 | 768.5.3 | CT3 part of CN aspects of Enabling Coder Selection and Rate Adaptation for UTRAN and E-UTRAN for Load Adaptive Applications | 186d? | 2010-09-17 A | 2011-06-03 A | 100% | 2010-09-17 | 2011-06-03 | 186d? | finish no earlier than 2011-06-03 | C3 | 1488h | 1488h | ECSRA_LAA-CN | PCG-25 | Ericsson | philip.hodges@ericsson.com | Rel-10 | CP-49 | Adrian |  |  |
| 3074 | 768.5.4 | CT1 part of CN aspects of Enabling Coder Selection and Rate Adaptation for UTRAN and E-UTRAN for Load Adaptive Applications | 186d? | 2010-09-17 A | 2011-06-03 A | 100% | 2010-09-17 | 2011-06-03 | 186d? | start no earlier than 2010-09-17 | C1 | 1488h | 1488h | ECSRA_LAA-CN | PCG-25 | Ericsson | philip.hodges@ericsson.com | Rel-10 | CP-49 | Frederic |  |  |

Notes:
- 3048: -
- 3049: SP#49 completed (has impacts to RAN) / Impacted TSs and TRs: 23.060, 23.401
- 3050: CP#51 completed
- 3051: CP#51 completed / Impacted TSs and TRs: 23.008, 23.015, 29.002, 29.060, 29.272, 29.274, 29.281, 29.303
- 3052: CP#51 completed / Impacted TSs and TRs: 24.008, 24.301
- 3053: -
- 3054: SP#49 completed (SIPTO GW selection for wild card APN and for GERAN. Serving-GW selection for SIPTO. Corrections and Clarifications of the SIPTO procedure) / Impacted TSs and TRs: 23.060, 23.401
- 3055: CP#51 completed. Updated WID CP-100419=>CP-110091
- 3056: CP#51 completed. Updated WID CP-100419=>CP-110091 / Impacted TSs and TRs: 23.003, 23.008, 29.002, 29.272, 29.303
- 3057: CP#50 completed / Impacted TSs and TRs: 24.008, 24.301
- 3058: SP#51 completed. Triggered by Rel-10 TR 23.861 (UID_410043 Study on Multi Access PDN connectivity and IP flow mobility - MAPIM)
- 3059: SP#46 completed / Impacted TSs and TRs: 22.278
- 3060: SP#49 completed / Impacted TSs and TRs: 23.203, 23.402, new 23.261
- 3061: SP#51 completed / Impacted TSs and TRs: 32.240, 32.251, 32.252, 32.298, 32.299
- 3062: CP#51 completed / Impacted TSs and TRs: Stage 3
- 3063: CP#51 completed / Impacted TSs and TRs: 24.008, 24.301, 24.302, 24.303, 24.312, 24.327
- 3064: CP#51 completed / Impacted TSs and TRs: 29.212, 29.213, 29.214, 29.215
- 3065: CP#52 completed. Triggered by Rel-9 UID_440013 Vocoder rate adaptation for LTE / Impacted TSs and TRs: UTRA, LTE
- 3066: SP#48 completed / Impacted TSs and TRs: new 23.860
- 3067: SP#50 completed / Impacted TSs and TRs: new 23.860
- 3068: SP#49 completed / Impacted TSs and TRs: 23.060, 23.203, 23.228, 23.401
- 3069: SP#51 completed / Impacted TSs and TRs: 26.114
- 3070: CP#52 completed / Impacted TSs and TRs: Stage 2/3
- 3071: CP#52 completed / Impacted TSs and TRs: 23.334, 29.334, 29.238, 23.333, 29.333, 29.232, 29.332
- 3072: CP#57 completed / Impacted TSs and TRs: RFC 6679 (was draft-ietf-avtcore-ecn-for-rtp)
- 3073: CP#52 completed / Impacted TSs and TRs: 29.162, 29.163, 29.213, 29.235, 29.292
- 3074: CP#52 completed / Impacted TSs and TRs: 24.229

| ID | WBS | Task | Type | Duration | Start | Finish | Complete | Baseline start | Baseline finish | Baseline duration | Constraint | Resources | Work | Actual work | Acronym | PCG approved | Impacted TSs and TRs | WI rapporteur name | WI rapporteur e-mail | Release | TSG approved | MCC resp | Special Focus Doc | Acronym_3GU_Export | PCG stopped | TSG stopped |
| --- | --- | --- | --- | --- | --- | --- | --- | --- | --- | --- | --- | --- | --- | --- | --- | --- | --- | --- | --- | --- | --- | --- | --- | --- | --- | --- |
| 3075 | 769 | **Extended H(e)NB features** |  | 467d? | 2008-12-11 A | 2010-09-23 A | 100% | 2008-12-11 | 2010-09-23 | 467d? |  | S1; S2; S3 | 15552h | 15552h | EHNBF | PCG-23 | UTRA, LTE | NEC | joerg.swetina@neclab.eu | Rel-10 | SP-45 | Alain | HNB | EHNBF |  |  |
| 3076 | 769.1 | Stage 1 of Extended H(e)NB features |  | 131d? | 2009-09-24 A | 2010-03-25 A | 100% | 2009-09-24 | 2010-03-25 | 131d? | finish no earlier than 2010-03-25 | S1 | 1048h | 1048h | EHNBF | PCG-23 | 22.220 | NEC | joerg.swetina@neclab.eu | Rel-10 | SP-45 | Alain | HNB |  |  |  |
| 3077 | 769.2 | IMS aspects of Architecture for Home NodeB |  | 336d? | 2008-12-11 A | 2010-03-25 A | 100% | 2008-12-11 | 2010-03-25 | 336d? | finish no earlier than 2010-03-25 | S2 | 2688h | 2688h | EHNB-IMS | PCG-22 | New 23.832 | Alcatel-Lucent | Nicolas Drevon | Rel-10 | SP-42 | Maurice | HNB | EHNB-IMS |  |  |
| 3078 | 769.3 | Extended H(e)NB Security features (Stage 2) |  | 76d? | 2010-06-10 A | 2010-09-23 A | 100% | 2010-06-10 | 2010-09-23 | 76d? | finish no earlier than 2010-09-23 | S3 | 608h | 608h | EHNBF-Sec | PCG-25 | 33.320 | Huawei | Marcus Wong (mwong@huawei.com) | Rel-10 | SP-48 | Mirko | HNB | EHNBF-Sec |  |  |
| 3079 | 770 | **Optimal Media Routing** |  | 314d? | 2010-03-25 A | 2011-06-08 A | 100% | 2010-03-25 | 2011-06-08 | 314d? |  | S2; S5; C3; C1 | 22696h | 22696h | OMR | PCG-24 |  | Alcatel-Lucent | andy.bennett@alcatel-lucent.com | Rel-10 | SP-46 | Maurice |  | OMR |  |  |
| 3080 | 770.1 | Stage 2 for Optimal Media Routing | milestone | 0d? | 2010-03-25 A | 2010-03-25 A | 100% | 2010-03-25 | 2010-03-25 | 0d? |  | S2 |  |  | OMR | PCG-24 | 23.228 | Alcatel-Lucent | andy.bennett@alcatel-lucent.com | Rel-10 | SP-46 | Maurice |  |  |  |  |
| 3081 | 770.2 | **Stage 3 for Optimal Media Routing** |  | 261d? | 2010-06-04 A | 2011-06-03 A | 100% | 2010-06-04 | 2011-06-03 | 261d? |  | C3; C1; C4 | 11648h | 11648h | OMR | PCG-25 |  | Alcatel-Lucent | jim.calme@alcatel-lucent.com | Rel-10 | CP-48 | Adrian |  |  |  |  |
| 3082 | 770.2.1 | CT3 part of Stage 3 for Optimal Media Routeing |  | 261d? | 2010-06-04 A | 2011-06-03 A | 100% | 2010-06-04 | 2011-06-03 | 261d? | finish no earlier than 2011-06-03 | C3 | 2088h | 2088h | OMR | PCG-25 | 29.162, 29.163, 29.165, 29.235, new TS 29.079 | Alcatel-Lucent | jim.calme@alcatel-lucent.com | Rel-10 | CP-48 | Adrian |  |  |  |  |
| 3083 | 770.2.2 | CT1 part of Stage 3 for Optimal Media Routeing |  | 206d? | 2010-06-04 A | 2011-03-18 A | 100% | 2010-06-04 | 2011-03-18 | 206d? | finish no earlier than 2011-03-18 | C1 | 1648h | 1648h | OMR | PCG-25 | 24.229 | Alcatel-Lucent | jim.calme@alcatel-lucent.com | Rel-10 | CP-48 | Frederic |  |  |  |  |
| 3084 | 770.2.3 | Deleted - CT4 part of Stage 3 for Optimal Media Routeing |  | 206d? | 2010-06-04 A | 2011-03-18 A | 100% | 2010-06-04 | 2011-03-18 | 206d? | finish no earlier than 2011-03-18 | C4 | 1648h | 1648h | OMR | PCG-25 |  | Alcatel-Lucent | jim.calme@alcatel-lucent.com | Rel-10 | CP-48 | Kimmo |  |  | PCG-26 | CP-51 |
| 3085 | 770.3 | Charging for Optimal Media Routing |  | 125d? | 2010-12-16 A | 2011-06-08 A | 100% | 2010-12-16 | 2011-06-08 | 125d? | finish no earlier than 2011-06-08 | S5 | 1000h | 1000h | OMR | PCG-26 | 32.260, 32.298, 32.299 | Alcatel-Lucent | maryse.gardella@alcatel-lucent.com | Rel-10 | SP-50 | Mirko |  |  |  |  |
| 3086 | 771 | **IMS Emergency Session Enhancements** |  | 312d? | 2010-03-25 A | 2011-06-03 A | 100% | 2010-03-25 | 2011-06-03 | 312d? |  | S1; S2; C1 | 9552h | 9552h | IESE | PCG-24 |  | Deutsche Telekom, T-Mobile | michele.zarri@t-mobile.co.uk | Rel-10 | SP-47 | Maurice | Public Safety (I-A) | IESE |  |  |
| 3087 | 771.1 | Stage 1 for IMS Emergency Session Enhancements |  | 1d? | 2010-03-25 A | 2010-03-25 A | 100% | 2010-03-25 | 2010-03-25 | 1d? | start no earlier than 2010-03-25 | S1 | 8h | 8h | IESE | PCG-24 | 22.101 CR#0343 | Deutsche Telekom, T-Mobile | Kurt Bischinger | Rel-10 | SP-47 | Alain | Public Safety (I-A) |  |  |  |
| 3088 | 771.2 | Stage 2 for IMS Emergency Session Enhancements |  | 131d? | 2010-03-25 A | 2010-09-23 A | 100% | 2010-03-25 | 2010-09-23 | 131d? | finish no earlier than 2010-09-23 | S2 | 1048h | 1048h | IESE | PCG-24 | 23.167 | Deutsche Telekom, T-Mobile | michele.zarri@t-mobile.co.uk | Rel-10 | SP-47 | Maurice | Public Safety (I-A) |  |  |  |
| 3089 | 771.3 | Stage 3 for IMS Emergency Session Enhancements |  | 126d? | 2010-12-10 A | 2011-06-03 A | 100% | 2010-12-10 | 2011-06-03 | 126d? | finish no earlier than 2011-06-03 | C1 | 1008h | 1008h | IESE | PCG-26 | 24.229 | Deutsche Telekom | reinhard.lauster@t-mobile.at | Rel-10 | CP-50 | Frederic | Public Safety (I-A) |  |  |  |
| 3090 | 772 | **S2b Mobility based on GTP** |  | 202d? | 2010-06-10 A | 2011-03-18 A | 100% | 2010-06-10 | 2011-03-18 | 202d? |  | S2; C4; C3; C1 | 12800h | 12800h | SMOG | PCG-25 |  | Alcatel-Lucent | bruno.landais@alcatel-lucent.com | Rel-10 | SP-48 | Maurice | WLAN | SMOG |  |  |
| 3091 | 772.1 | Stage 2 for S2b Mobility based on GTP |  | 76d? | 2010-06-10 A | 2010-09-23 A | 100% | 2010-06-10 | 2010-09-23 | 76d? | finish no earlier than 2010-09-23 | S2 | 608h | 608h | SMOG | PCG-25 | 23.002, 23.203, 23.402 | Alcatel-Lucent | bruno.landais@alcatel-lucent.com | Rel-10 | SP-48 | Maurice | WLAN |  |  |  |
| 3092 | 772.2 | **Stage 3 for S2b Mobility based on GTP** |  | 131d? | 2010-09-17 A | 2011-03-18 A | 100% | 2010-09-17 | 2011-03-18 | 131d? |  | C4; C3; C1 | 5728h | 5728h | SMOG-St3 | PCG-25 |  | Alcatel-Lucent | bruno.landais@alcatel-lucent.com | Rel-10 | CP-49 | Kimmo | WLAN | SMOG-St3 |  |  |
| 3093 | 772.2.1 | CT4 part of Stage 3 for S2b Mobility based on GTP |  | 131d? | 2010-09-17 A | 2011-03-18 A | 100% | 2010-09-17 | 2011-03-18 | 131d? | finish no earlier than 2011-03-18 | C4 | 1048h | 1048h | SMOG-St3 | PCG-25 | 23.003, 23.007, 23.008, 29.273, 29.274, 29.281, 29.303 | Alcatel-Lucent | bruno.landais@alcatel-lucent.com | Rel-10 | CP-49 | Kimmo | WLAN |  |  |  |
| 3094 | 772.2.2 | CT3 part of Stage 3 for S2b Mobility based on GTP |  | 131d? | 2010-09-17 A | 2011-03-18 A | 100% | 2010-09-17 | 2011-03-18 | 131d? | finish no earlier than 2011-03-18 | C3 | 1048h | 1048h | SMOG-St3 | PCG-25 | 29.212, 29.213, 29.215 | Alcatel-Lucent | bruno.landais@alcatel-lucent.com | Rel-10 | CP-49 | Adrian | WLAN |  |  |  |
| 3095 | 772.2.3 | CT1 part of Stage 3 for S2b Mobility based on GTP |  | 61d? | 2010-09-17 A | 2010-12-10 A | 100% | 2010-09-17 | 2010-12-10 | 61d? | finish no earlier than 2010-12-10 | C1 | 488h | 488h | SMOG-St3 | PCG-25 | 24.302 | Alcatel-Lucent | bruno.landais@alcatel-lucent.com | Rel-10 | CP-49 | Frederic | WLAN |  |  |  |
| 3096 | 773 | **Policy Enhancements for Sponsored Connectivity and Coherent Access to Policy related Databases** |  | 113.15d? | 2010-10-12 A | 2011-03-18 A | 100% | 2010-10-12 | 2011-03-18 | 113.15d? |  | S2; C3 | 2378.4h | 2378.4h | PEST | PCG-26 |  | Qualcomm | AC Mahendran (ac@qualcomm.com) | Rel-10 | SP-50 | Maurice |  | PEST |  |  |
| 3097 | 773.1 | Stage 2 for Policy Enhancements for Sponsored Connectivity and Coherent Access to Policy related Databases | milestone | 0d? | 2010-10-12 A | 2010-12-15 A | 100% | 2010-10-12 | 2010-12-15 | 0d? | finish no earlier than 2010-12-15 | S2 |  |  | PEST | PCG-26 | 23.002, 23.203 | Qualcomm | AC Mahendran (ac@qualcomm.com) | Rel-10 | SP-50 | Maurice |  |  |  |  |
| 3098 | 773.2 | CT3 aspects of Policy Enhancements for Sponsored Connectivity and Coherent Access to Policy related Databases |  | 71d? | 2010-12-10 A | 2011-03-18 A | 100% | 2010-12-10 | 2011-03-18 | 71d? | finish no earlier than 2011-03-18 | C3 | 568h | 568h | PEST-CT3 | PCG-26 | 29.212, 29.213, 29.214, 29.215 | ZTE | zhou.xiaoyun@zte.com.cn | Rel-10 | CP-50 | Adrian |  | PEST-CT3 |  |  |

Notes:
- 3075: SP#49 completed. Adds extensions to Rel-9 functionality in UID_400035 Enhanced Home NodeB / eNodeB (EHNB)
- 3076: SP#47 completed
- 3077: SP#47 completed. Chosen solution has no normative impacts
- 3078: SP#49 completed
- 3079: CP#52 completed. SP#47 Stage 2 completed. Triggered by TR 23.894 (UID_370050 Study on System enhancements for the use of IMS servicES in CP-150local breakout)
- 3080: SP#47 completed
- 3081: CP#51 completion 03/11=>06/11. WID updated CP-100327=>CP-110134
- 3082: CP#52 completed
- 3083: CP#51 completed. WID updated CP-100327=>CP-110134
- 3084: CP#51 stopped (CT4 specs not impacted). WID updated CP-100327=>CP-110134
- 3085: SP#52 completed. Stage 3: Linked to CT3 TS 29.079 OMR within the IMS; Stage 3 (UID_480110)
- 3086: CP#52 completed. SP#49 completed. Source of external requirements: ETSI TISPAN TS 181.019 (Business Communication Requirements)
- 3087: SP#47 completed
- 3088: SP#49 completed
- 3089: CP#52 completed
- 3090: CP#51 completed. SP#49 Stage 2 completed. Related to Rel-10 UID_470049 Study on S2b mobility based on GTP (TR23.834), UID_350027 SAE for support for non-3GPP accesses. Stage1 in Rel-8 UID_320022 Reqs for evolution of 3GPP system architecture (AIPN-SAE)
- 3091: SP#49 completed
- 3092: CP#51 Stage 3 completed
- 3093: CP#51 completed
- 3094: CP#51 completed
- 3095: CP#50 completed
- 3096: CP#51 completed. SP#50 Stage 2 completed. Triggered by the SA1,SA2 Rel-10 TR 23.813 Study on Policy solutions and enhancements (FS_PP) UID_440047. Provides Video Call seamless service continuity for 3G/LTE terminal user
- 3097: SP#51 updated WID SP-100702=>SP-110196. SP#49 work completed as SA2 CRs approved under TEI10 (SP-10557)
- 3098: CP#51 completed

| ID | WBS | Task | Duration | Start | Finish | Complete | Baseline start | Baseline finish | Baseline duration | Constraint | Resources | Work | Actual work | Acronym | PCG approved | WI rapporteur name | WI rapporteur e-mail | Release | TSG approved | MCC resp | Acronym_3GU_Export | PCG stopped | TSG stopped |
| --- | --- | --- | --- | --- | --- | --- | --- | --- | --- | --- | --- | --- | --- | --- | --- | --- | --- | --- | --- | --- | --- | --- | --- |
| 3099 | 774 | **Lawful Interception in the 3GPP Rel-10** | 315d? | 2010-03-25 A | 2011-06-08 A | 100% | 2010-03-25 | 2011-06-08 | 315d? |  | S3 | 20480h | 20480h | LI10 | PCG-24 | PIDS, BT | Koen Jaspers (k.b.jaspers@minjus.nl), alex.leadbeater@bt.com | Rel-10 | SP-47 | Mirko | LI10 |  |  |
| 3100 | 774.1 | LI for CAT (Customer Alerting Tones) | 315d? | 2010-03-25 A | 2011-06-08 A | 100% | 2010-03-25 | 2011-06-08 | 315d? | finish no earlier than 2011-03-23 | S3 | 2520h | 2520h | LI10 | PCG-24 | PIDS, BT | Koen Jaspers (k.b.jaspers@minjus.nl), alex.leadbeater@bt.com | Rel-10 | SP-47 | Mirko |  |  |  |
| 3101 | 774.2 | LI for CRS (Customized Ringing Signal) | 315d? | 2010-03-25 A | 2011-06-08 A | 100% | 2010-03-25 | 2011-06-08 | 315d? | finish no earlier than 2011-03-23 | S3 | 2520h | 2520h | LI10 | PCG-24 | PIDS, BT | Koen Jaspers (k.b.jaspers@minjus.nl), alex.leadbeater@bt.com | Rel-10 | SP-47 | Mirko |  |  |  |
| 3102 | 774.3 | LI for EPS enhancements | 315d? | 2010-03-25 A | 2011-06-08 A | 100% | 2010-03-25 | 2011-06-08 | 315d? | finish no earlier than 2011-03-23 | S3 | 2520h | 2520h | LI10 | PCG-24 | PIDS, BT | Koen Jaspers (k.b.jaspers@minjus.nl), alex.leadbeater@bt.com | Rel-10 | SP-47 | Mirko |  |  |  |
| 3103 | 774.4 | LI for VCC (Voice Call Continuity) | 260d? | 2010-03-25 A | 2011-03-23 A | 100% | 2010-03-25 | 2011-03-23 | 260d? | finish no earlier than 2011-03-23 | S3 | 2080h | 2080h | LI10 | PCG-24 | PIDS, BT | Koen Jaspers (k.b.jaspers@minjus.nl), alex.leadbeater@bt.com | Rel-10 | SP-47 | Mirko |  |  |  |
| 3104 | 774.5 | LI for MEDIASEC (IMS Media security) | 260d? | 2010-03-25 A | 2011-03-23 A | 100% | 2010-03-25 | 2011-03-23 | 260d? | finish no earlier than 2011-03-23 | S3 | 2080h | 2080h | LI10 | PCG-24 | PIDS, BT | Koen Jaspers (k.b.jaspers@minjus.nl), alex.leadbeater@bt.com | Rel-10 | SP-47 | Mirko |  |  |  |
| 3105 | 774.6 | LI for H(e)NB also with Local IP Access and Selected IP Traffic Offload (LIPA, SIPTO) | 260d? | 2010-03-25 A | 2011-03-23 A | 100% | 2010-03-25 | 2011-03-23 | 260d? | finish no earlier than 2011-03-23 | S3 | 2080h | 2080h | LI10 | PCG-24 | PIDS, BT | Koen Jaspers (k.b.jaspers@minjus.nl), alex.leadbeater@bt.com | Rel-10 | SP-47 | Mirko |  |  |  |
| 3106 | 774.7 | LI for MBMS enhancements | 260d? | 2010-03-25 A | 2011-03-23 A | 100% | 2010-03-25 | 2011-03-23 | 260d? | finish no earlier than 2011-03-23 | S3 | 2080h | 2080h | LI10 | PCG-24 | PIDS, BT | Koen Jaspers (k.b.jaspers@minjus.nl), alex.leadbeater@bt.com | Rel-10 | SP-47 | Mirko |  |  |  |
| 3107 | 774.8 | LI for LCLS (Local Call Local Switch) | 260d? | 2010-03-25 A | 2011-03-23 A | 100% | 2010-03-25 | 2011-03-23 | 260d? | finish no earlier than 2011-03-23 | S3 | 2080h | 2080h | LI10 | PCG-24 | PIDS, BT | Koen Jaspers (k.b.jaspers@minjus.nl), alex.leadbeater@bt.com | Rel-10 | SP-47 | Mirko |  |  |  |
| 3108 | 775 | Optimization of IMS based PSS and MBMS User Service | 260d? | 2010-03-25 A | 2011-03-23 A | 100% | 2010-03-25 | 2011-03-23 | 260d? | finish no earlier than 2011-03-23 | S4 | 2080h | 2080h | OPT_IMS_PSS_MBMS_US | PCG-24 | Ericsson | markus.kampmann@ericsson.com | Rel-10 | SP-47 | Paolo | OPT_IMS_PSS_MBMS_US |  |  |
| 3109 | 776 | **HTTP-based Streaming and Download Services** | 392d? | 2010-03-25 A | 2011-09-21 A | 100% | 2010-03-25 | 2011-09-21 | 392d? |  | S4; IETF | 10468.8h | 10468.8h | HTTP_SDS | PCG-24 | Qualcomm | Thomas Stockhammer (c_tstock@qualcomm.com) | Rel-10 | SP-47 | Paolo | HTTP_SDS |  |  |
| 3110 | 776.1 | HTTP-based Streaming and Download Services in 3GPP | 315d? | 2010-03-25 A | 2011-06-08 A | 100% | 2010-03-25 | 2011-06-08 | 315d? | finish no earlier than 2011-05-26 | S4 | 2520h | 2520h | HTTP_SDS | PCG-24 | Qualcomm | Thomas Stockhammer (c_tstock@qualcomm.com) | Rel-10 | SP-47 | Paolo |  |  |  |
| 3111 | 776.2 | (IETF) HTTP-based Streaming and Download Services in 3GPP | 211.6d? | 2010-03-25 A | 2011-09-21 A | 100% | 2010-03-25 | 2011-09-21 | 211.6d? | start no earlier than 2010-03-25 | S4-IETF | 1676.8h | 1676.8h | HTTP_SDS | PCG-27 |  |  | Rel-10 | CP-52 | Paolo |  |  |  |
| 3112 | 777 | PSS and MBMS enhancements | 205d? | 2010-06-10 A | 2011-03-23 A | 100% | 2010-06-10 | 2011-03-23 | 205d? | finish no earlier than 2011-03-23 | S4 | 1640h | 1640h | MBS_Enh | PCG-25 | Ericsson | Markus.Kampmann@ericsson.com | Rel-10 | SP-48 | Paolo | MBS_Enh |  |  |
| 3113 | 778 | Enhancements and Addition of Audio Tests to 26.131 and 26.132 | 260d? | 2010-06-10 A | 2011-06-08 A | 100% | 2010-06-10 | 2011-06-08 | 260d? | finish no earlier than 2011-06-08 | S4 | 2080h | 2080h | EAAT | PCG-25 | Vodafone | ramin.afchar@vodafone.com | Rel-10 | SP-48 | Paolo | EAAT |  |  |
| 3114 | 779 | Video Coding Enhancements in MTSI | 3d? | 2011-03-21 A | 2011-03-23 A | 100% | 2011-03-21 | 2011-03-23 | 3d? | start no earlier than 2011-03-21 | S4 | 24h | 24h | VCEM | PCG-26 | Ericsson | frederic.gabin@ericsson.com | Rel-10 | SP-51 | Paolo | VCEM |  |  |
| 3115 | 780 | **Rel-10 Operations, Administration, Maintenance and Provisioning (OAM&P)** | 467d? | 2009-12-10 A | 2011-09-21 A | 100% | 2009-12-10 | 2011-09-21 | 467d? |  | S5; C4 | 54144h | 54144h | OAM10 | PCG-24 |  |  | Rel-10 | SP-46 | Mirko | OAM10 |  |  |
| 3116 | 780.1 | **Rel-10 Network Infrastructure Management** | 467d? | 2009-12-10 A | 2011-09-21 A | 100% | 2009-12-10 | 2011-09-21 | 467d? |  | S5 | 14592h | 14592h | OAM10-NIM | PCG-24 |  |  | Rel-10 | SP-46 | Mirko | OAM10-NIM |  |  |
| 3117 | 780.1.1 | Common RAT Network Resource Model (NRM) | 390d? | 2009-12-10 A | 2011-06-08 A | 100% | 2009-12-10 | 2011-06-08 | 390d? | finish no earlier than 2011-06-08 | S5 | 3120h | 3120h | RAT_NRM_common | PCG-24 | Ericsson | robert.petersen@ericsson.com | Rel-10 | SP-46 | Mirko | RAT_NRM_common |  |  |
| 3118 | 780.1.2 | IRP Solution Set specification organisation improvements | 260d? | 2010-03-25 A | 2011-03-23 A | 100% | 2010-03-25 | 2011-03-23 | 260d? | finish no earlier than 2011-03-23 | S5 | 2080h | 2080h | OAM-IRP-SS | PCG-24 | Nokia Siemens Networks, Huawei | Jörg Schmidt (J.Schmidt@nsn.com), Lan Zou (zlan@huawei.com) | Rel-10 | SP-47 | Mirko | OAM-IRP-SS |  |  |
| 3119 | 780.1.3 | Deleted - Service Oriented Architecture (SOA) for IRP continuation from Rel-9 | 260d? | 2010-03-25 A | 2011-03-23 A | 100% | 2010-03-25 | 2011-03-23 | 260d? | finish no earlier than 2011-06-08 | S5 | 2080h | 2080h | OAM-SOA-IRP | PCG-24 | Nokia Siemens Networks, Ericsson | Jörg Schmidt (J.Schmidt@NSN.com), edwin.tse@ericsson.com | Rel-10 | SP-47 | Mirko | OAM-SOA-IRP | PCG-26 | SP-51 |
| 3120 | 780.1.4 | IRP Overview, Profiles & Usage Guide | 260d? | 2010-06-10 A | 2011-06-08 A | 100% | 2010-06-10 | 2011-06-08 | 260d? | finish no earlier than 2011-06-08 | S5 | 2080h | 2080h | OAM-NIM-IRP_OPU | PCG-25 | Nokia Siemens Networks | Jörg Schmidt (J.Schmidt@NSN.com) | Rel-10 | SP-48 | Mirko | OAM-NIM-IRP_OPU |  |  |
| 3121 | 780.1.5 | Alarm Correlation and Root Cause Analysis | 133d? | 2011-03-23 A | 2011-09-21 A | 100% | 2011-03-23 | 2011-09-21 | 133d? | finish no earlier than 2011-09-21 | S5 | 1048h | 1048h | OAM-AC-RCA | PCG-26 | Ericsson | brendan.hassett@ericsson.com | Rel-10 | SP-51 | Mirko | OAM-AC-RCA |  |  |
| 3122 | 780.1.6 | Inventory Management Network Resource Model enhancements | 56d? | 2011-03-23 A | 2011-06-08 A | 100% | 2011-03-23 | 2011-06-08 | 56d? | start no earlier than 2011-03-23 | S5 | 448h | 448h | OAM-IM-NMR | PCG-26 | Nokia Siemens Networks | olaf.pollakowski@nsn.com | Rel-10 | SP-51 | Mirko | OAM-IM-NMR |  |  |

Notes:
- 3099: SP#52 completed / Impacted TSs and TRs: 33.106 (LI requirements), 33.107 (LI architecture and functions), 33.108 (Handover interface for LI)
- 3100: SP#52 completed / Impacted TSs and TRs: 33.106, 33.107, 33.108
- 3101: SP#52 completed / Impacted TSs and TRs: 33.106, 33.107, 33.108
- 3102: SP#52 completed / Impacted TSs and TRs: 33.106, 33.107, 33.108
- 3103: SP#51 completed / Impacted TSs and TRs: 33.106, 33.107, 33.108
- 3104: SP#51 completed / Impacted TSs and TRs: 33.106, 33.107, 33.108
- 3105: SP#51 completed / Impacted TSs and TRs: 33.106, 33.107, 33.108
- 3106: SP#51 completed / Impacted TSs and TRs: 33.106, 33.107, 33.108
- 3107: SP#51 completed / Impacted TSs and TRs: 33.106, 33.107, 33.108
- 3108: SP#51 completed. Work to enhance UID_430046 Rel-9 IMS_PSS_MBMS_US_EXT / Impacted TSs and TRs: 26.237
- 3109: SP#52 completed. Work to enhance UID_430038 Rel-9 PSS and MBMS extensions
- 3110: SP#52 completed / Impacted TSs and TRs: 26.234, 26.244, 26.346, new TS 26.247
- 3111: SP#53/IETF#81: Draft not included in 3GPP documentation. Dec.14: IETF RFC added / Impacted TSs and TRs: RFC 6381 (was draft-gellens-mime-bucket-bis)
- 3112: SP#51 completed. Linked to Rel-9 Feature UID_430038 PSS and MBMS extensions (PMA-MBS_Ext). / Impacted TSs and TRs: 26.234, 26.346
- 3113: SP#52 completed. Reduce fragmentation in acoustic testing (3GPP SA4, ETSI STQ, GCF CAG, CTIA) & Review existing acoustic tests to determine need for new spec / Impacted TSs and TRs: 26.131, 26.132
- 3114: SP#51 completed. Linked to Rel-7 UID_7040 Multimedia Telephony Service for IMS - Media handling and interaction in MTSI (MTSI-MHI) / Impacted TSs and TRs: 26.114
- 3115: OAM10 is an umbrella Feature also for OAM&P related TEI10 type of changes that are not part of any other dedicated feature/WI / Impacted TSs and TRs: TR 30.820
- 3116: umbrella BB
- 3117: SP#52 completed. Share equipment btw several RATs (RET,TMA,repeaters) to reduce costs. With existing modelling is difficult to see that several cells are affected when an antenna tilt is changed etc / Impacted TSs and TRs: 32.616, 32.642, 32.646, 32.652, 32.656, 32.762, 32.766 new (32.791, 32.792, 32.796)
- 3118: SP#51 completed / Impacted TSs and TRs: 32.153, new (32.111-6,32.126,32.176,32.306,32.316,32.326,32.336,32.346,32.356,32.366,32.376,32.386,32.396,32.416,32.446,32.506/26/36,32.606,32.616,32.626,32.636,32.646,32.656,32.666,32.676,32.696,32.716,32.726,32.736,32.746,32.756,32.766,32.776,32.786)
- 3119: SP#51 work stopped (Reason: lack of progress). Continuation of Rel-9 UID_440065 SOA for IRP (covering SOA Architecture & SOA-supporting Solution Set) to address SOA conforming Registration & Discovery capabilities / Impacted TSs and TRs: 32.101, 32.150
- 3120: SP#52 completed. Updated WID SP-100777=>SP-110277 / Impacted TSs and TRs: new TS 32.103
- 3121: SP#53 completed. Triggered by Rel-10 TR 32.832 Study on Alarm Correlation and Alarm Root Cause Analysis UID_480045 & TR 32.829 Study on Harmonization of 3GPP Alarm IRP and TMF Interface Program Fault Management UID_460038 / Impacted TSs and TRs: 32.111-1, 32.111-2, 32.111-6
- 3122: SP#52 completed. Inventory NRM specified in Rel-6 is mainly hardware related. Rel-10 TR 32.828 recommends extending the scope of inventory NRM. Additionally, NGMN Top OPE Recs, v1.0 sets inventory enhancements as one of top 10 priority items / Impacted TSs and TRs: 32.690, 32.691, 32.692, 32.696

| ID | WBS | Task | Duration | Start | Finish | Complete | Baseline start | Baseline finish | Baseline duration | Constraint | Resources | Work | Actual work | Acronym | PCG approved | Release | TSG approved | MCC resp | Special Focus Doc | Acronym_3GU_Export | WI rapporteur name |
| --- | --- | --- | --- | --- | --- | --- | --- | --- | --- | --- | --- | --- | --- | --- | --- | --- | --- | --- | --- | --- | --- |
| 3123 | 780.2 | **Rel-10 Self-Organizing Networks (SON) - OAM aspects** | 390d? | 2009-12-10 A | 2011-06-08 A | 100% | 2009-12-10 | 2011-06-08 | 390d? |  | S5 | 11000h | 11000h | OAM10-SON | PCG-24 | Rel-10 | SP-46 | Mirko | SON | OAM10-SON |  |
| 3124 | 780.2.1 | SON Self-optimization management continuation | 390d? | 2009-12-10 A | 2011-06-08 A | 100% | 2009-12-10 | 2011-06-08 | 390d? | finish no earlier than 2011-03-23 | S5 | 3120h | 3120h | LTE-SON-OAM_SO | PCG-24 | Rel-10 | SP-46 | Mirko | SON | LTE-SON-OAM_SO | Huawei |
| 3125 | 780.2.2 | SON Self-healing management | 335d? | 2009-12-10 A | 2011-03-23 A | 100% | 2009-12-10 | 2011-03-23 | 335d? | finish no earlier than 2011-03-23 | S5 | 2680h | 2680h | LTE-SON-OAM_SH | PCG-24 | Rel-10 | SP-46 | Mirko | SON | LTE-SON-OAM_SH | ZTE |
| 3126 | 780.2.3 | OAM aspects of Energy Saving in Radio Networks | 260d? | 2010-03-25 A | 2011-03-23 A | 100% | 2010-03-25 | 2011-03-23 | 260d? | finish no earlier than 2011-03-23 | S5 | 2080h | 2080h | OAM-ES | PCG-24 | Rel-10 | SP-47 | Mirko | SON | OAM-ES | Nokia Siemens Networks |
| 3127 | 780.3 | Rel-10 Subscription Management (SuM) evolution | 260d? | 2010-03-25 A | 2011-03-23 A | 100% | 2010-03-25 | 2011-03-23 | 260d? | finish no earlier than 2011-03-23 | S5 | 2080h | 2080h | OAM10-SuM | PCG-24 | Rel-10 | SP-47 | Mirko |  | OAM10-SuM | Ericsson |
| 3128 | 780.4 | **Rel-10 Performance Management** | 315d? | 2010-03-25 A | 2011-06-08 A | 100% | 2010-03-25 | 2011-06-08 | 315d? |  | S5; C4 | 19000h | 19000h |  | PCG-24 | Rel-10 | SP-47 | Mirko |  |  |  |
| 3129 | 780.4.1 | Key Performance Indicators (KPIs) for IMS | 260d? | 2010-03-25 A | 2011-03-23 A | 100% | 2010-03-25 | 2011-03-23 | 260d? | finish no earlier than 2011-03-23 | S5 | 2080h | 2080h | OAM-PM-KPI_IMS | PCG-24 | Rel-10 | SP-47 | Mirko |  | OAM-PM-KPI_IMS | China Mobile |
| 3130 | 780.4.2 | Key Performance Indicators (KPIs) for EPC | 260d? | 2010-03-25 A | 2011-03-23 A | 100% | 2010-03-25 | 2011-03-23 | 260d? | finish no earlier than 2011-03-23 | S5 | 2080h | 2080h | OAM-PM-KPI_EPC | PCG-24 | Rel-10 | SP-47 | Mirko |  | OAM-PM-KPI_EPC | China Mobile |
| 3131 | 780.4.3 | **Management of UE based network performance measurements** | 315d? | 2010-03-25 A | 2011-06-08 A | 100% | 2010-03-25 | 2011-06-08 | 315d? |  | S5; C4 | 7720h | 7720h | OAM-PM-UE | PCG-24 | Rel-10 | SP-47 | Mirko |  | OAM-PM-UE | Huawei, Nokia Siemens Networks, Ericsson |
| 3132 | 780.4.3.1 | SA5 aspects of Management of UE based network performance measurements | 315d? | 2010-03-25 A | 2011-06-08 A | 100% | 2010-03-25 | 2011-06-08 | 315d? | finish no earlier than 2011-06-08 | S5 | 2520h | 2520h |  | PCG-24 | Rel-10 | SP-47 | Mirko |  |  | Huawei, Nokia Siemens Networks, Ericsson |
| 3133 | 780.4.3.2 | CN aspects of Management of UE based network performance measurements | 20d? | 2011-02-21 A | 2011-03-18 A | 100% | 2011-02-21 | 2011-03-18 | 20d? | start no earlier than 2011-02-21 | C4 | 160h | 160h |  | PCG-26 | Rel-10 | CP-51 | Kimmo |  |  | Nokia Siemens Networks |
| 3134 | 780.4.4 | 3G HNB and LTE HeNB Subsystem performance measurements | 260d? | 2010-03-25 A | 2011-03-23 A | 100% | 2010-03-25 | 2011-03-23 | 260d? | finish no earlier than 2011-03-23 | S5 | 2080h | 2080h | OAM-PM-HeNS | PCG-24 | Rel-10 | SP-47 | Mirko | HNB | OAM-PM-HeNS | China Mobile |
| 3135 | 781 | **Rel-10 Charging Management small Enhancements** | 470d? | 2009-06-04 A | 2011-03-23 A | 100% | 2009-06-04 | 2011-03-23 | 470d? |  | S5 | 7520h | 7520h | CH10 | PCG-24 | Rel-10 | SP-47 | Mirko | WLAN | CH10 |  |
| 3136 | 781.1 | IWLAN mobility charging | 470d? | 2009-06-04 A | 2011-03-23 A | 100% | 2009-06-04 | 2011-03-23 | 470d? | finish no earlier than 2011-03-23 | S5 | 3760h | 3760h | eIWLAN_Mob | PCG-23 | Rel-10 | SP-44 | Mirko | WLAN | eIWLAN_Mob | Orange |
| 3137 | 782 | **Advice of Charge (AoC) service support enhancements** | 312d? | 2010-03-25 A | 2011-06-03 A | 100% | 2010-03-25 | 2011-06-03 | 312d? |  | S5; C1 | 8560h | 8560h | eAoC | PCG-24 | Rel-10 | SP-47 | Mirko |  | eAoC | Deutsche Telekom |
| 3138 | 782.1 | SA5 part - AoC enhancements | 260d? | 2010-03-25 A | 2011-03-23 A | 100% | 2010-03-25 | 2011-03-23 | 260d? | finish no earlier than 2011-03-23 | S5 | 2080h | 2080h | eAoC | PCG-24 | Rel-10 | SP-47 | Mirko |  |  | Deutsche Telekom |
| 3139 | 782.2 | CT1 part - AoC enhancements (Stage 3) | 186d? | 2010-09-17 A | 2011-06-03 A | 100% | 2010-09-17 | 2011-06-03 | 186d? | finish no earlier than 2011-06-03 | C1 | 1488h | 1488h | eAoC | PCG-25 | Rel-10 | CP-49 | Frederic |  |  | Deutsche Telekom |
| 3140 | 783 | IMS Stage 3 IETF Protocol Alignment - phase 4 | 261d? | 2010-03-19 A | 2011-03-18 A | 100% | 2010-03-19 | 2011-03-18 | 261d? | finish no earlier than 2011-03-18 | C1 | 2088h | 2088h | IMSProtoc4 | PCG-24 | Rel-10 | CP-47 | Frederic |  | IMSProtoc4 | Alcatel-Lucent |
| 3141 | 784 | Enhanced User Data Convergence (UDC) Model | 206d? | 2010-06-04 A | 2011-03-18 A | 100% | 2010-06-04 | 2011-03-18 | 206d? | finish no earlier than 2011-03-18 | C4 | 1648h | 1648h | eUDC | PCG-25 | Rel-10 | CP-48 | Kimmo |  | eUDC | China Mobile |
| 3142 | 785 | **Further improvements of II-NNI Stage 3 based on operational feedback and evolution of other specifications** | 724d? | 2010-06-04 A | 2013-03-01 A | 100% | 2010-06-04 | 2013-03-01 | 724d? |  | C3 | 10625.9h | 10625.9h | II-NNI2 | PCG-25 | Rel-10 | CP-48 | Adrian |  | II-NNI2 | Orange |
| 3143 | 785.1 | Further improvements of II-NNI Stage 3 | 206d? | 2010-06-04 A | 2011-03-18 A | 100% | 2010-06-04 | 2011-03-18 | 206d? | start no earlier than 2010-06-04 | C3 | 1648h | 1648h | II-NNI2 | PCG-25 | Rel-10 | CP-48 | Adrian |  |  | Orange |
| 3144 | 785.2 | (IETF) Further improvements of II-NNI Stage 3 (RFC 6794) | 230d? | 2012-04-20 A | 2013-03-01 A | 100% | 2012-04-20 | 2013-03-01 | 230d? | finish no earlier than 2013-03-01 | C3-IETF | 1832h | 1832h | II-NNI2 | PCG-29 | Rel-10 | CP-56 | Adrian |  |  | Lionel Morand |
| 3145 | 785.3 | (IETF) Further improvements of II-NNI Stage 3 (RFC 6809) | 170d? | 2012-04-20 A | 2012-12-07 A | 100% | 2012-04-20 | 2012-12-07 | 170d? | finish no earlier than 2012-12-04 | C3-IETF | 1353.89h | 1353.89h | II-NNI2 | PCG-29 | Rel-10 | CP-56 | Adrian |  |  | christer.holmberg@ericsson.com |
| 3146 | 786 | AT Commands for IMS-configuration | 206d? | 2010-06-04 A | 2011-03-18 A | 100% | 2010-06-04 | 2011-03-18 | 206d? |  | C1 | 1648h | 1648h | AT_IMS | PCG-25 | Rel-10 | CP-48 | Frederic |  | AT_IMS | Ericsson |
| 3147 | 787 | AT Commands for USIM Application Toolkit (USAT) | 131d? | 2010-09-17 A | 2011-03-18 A | 100% | 2010-09-17 | 2011-03-18 | 131d? |  | C1 | 52.4h | 52.4h | AT_UICC | PCG-25 | Rel-10 | CP-49 | Frederic |  | AT_UICC | ST-Ericsson |
| 3148 | 788 | Communication Control for IMS by USIM (Stage 3) | 131d? | 2010-09-17 A | 2011-03-18 A | 100% | 2010-09-17 | 2011-03-18 | 131d? | start no earlier than 2010-09-17 | C6 | 1048h | 1048h | CC_IMS_USIM | PCG-25 | Rel-10 | CP-49 | Xavier |  | CC_IMS_USIM | Gemalto |
| 3149 | 789 | Dynamic view of SIP message for Inter-IMS Network to Network Interface (II-NNI) (Stage 3) | 126d? | 2010-12-10 A | 2011-06-03 A | 100% | 2010-12-10 | 2011-06-03 | 126d? | finish no earlier than 2011-06-03 | C3 | 1008h | 1008h | NNI_DV | PCG-26 | Rel-10 | CP-50 | Adrian |  | NNI_DV | NTT |
| 3150 | 790 | Introduction of Smart Card Web Server launch functionality | 71d? | 2010-12-10 A | 2011-03-18 A | 100% | 2010-12-10 | 2011-03-18 | 71d? | finish no earlier than 2011-03-18 | C6 | 568h | 568h | SCWS_L | PCG-26 | Rel-10 | CP-50 | Xavier |  | SCWS_L | Telecom Italia |
| 3151 | 791 | USAT using AT Commands | 71d? | 2010-12-10 A | 2011-03-18 A | 100% | 2010-12-10 | 2011-03-18 | 71d? | finish no earlier than 2011-03-18 | C6 | 568h | 568h | USAT_AT | PCG-26 | Rel-10 | CP-50 | Xavier |  | USAT_AT | Giesecke & Devrient |

Notes:
- 3123: umbrella BB
- 3124: SP#52 completed. Cont'd Rel-9 SON self-optimization management UID_390007 / Impacted TSs and TRs: 32.425, 32.521, 32.522, 32.526, 32.762, 32.766 / WI rapporteur e-mail: Lan Zou (zlan@huawei.com)
- 3125: SP#51 completed. WID updated SP-100776=>SP-110150. Work moved to Rel-10 after split of the Rel-9 UID_390007 SON self-optimization (removed Self-Healing handling) / Impacted TSs and TRs: 32.522, 32.526, 32.762, 32.766, new TS 32.541 / WI rapporteur e-mail: zhu.weihong@zte.com.cn
- 3126: SP#51 completed. WID updated SP-100226=>SP-110128. Triggered by Rel-10 TR 32.826 Study on Telecommunication Management; Energy Savings Management (FS_OAM_ESM) UID_430044 / Impacted TSs and TRs: 32.425, 32.522, 32.526, 32.626, 32.762, 32.766, new TS 32.551 / WI rapporteur e-mail: clemens.suerbaum@nsn.com
- 3127: SP#51 completed / Impacted TSs and TRs: 32.172, 32.175, 32.176 / WI rapporteur e-mail: leo.yang@ericsson.com
- 3128: umbrella BB
- 3129: SP#51 completed / Impacted TSs and TRs: new 32.454 / WI rapporteur e-mail: Li Jian (lijian@chinamobile.com), Liang Shuangchun (liangshuangchun@cmdi.chinamobile.com)
- 3130: SP#51 completed / Impacted TSs and TRs: new 32.455 / WI rapporteur e-mail: Li Jian (lijian@chinamobile.com), Liang Shuangchun (liangshuangchun@cmdi.chinamobile.com)
- 3131: SP#52 completed. Stage 2/3. Linked to UID_460003 Minimization of drive tests for E-UTRAN and UTRAN (MDT_UMTSLTE) / WI rapporteur e-mail: Zou Lan (zlan@huawei.com), gyula.bodog@nsn.com, ulf.hubinette@ericsson.com
- 3132: SP#52 completed / Impacted TSs and TRs: 32.421, 32.422, 32.423, 32.441, 32.442, 32.446 / WI rapporteur e-mail: Zou Lan (zlan@huawei.com), gyula.bodog@nsn.com, ulf.hubinette@ericsson.com
- 3133: CP#51 completed under the SA5 WI code / Impacted TSs and TRs: 23.008 (CR#0330), 29.002 (CR#1007), 29.230 (CR#0207), 29.272 (CR#0329) / WI rapporteur e-mail: ulrich.wiehe@nsn.com
- 3134: SP#51 completed / Impacted TSs and TRs: 32.582, 32.592, new (32.452, 32.453) / WI rapporteur e-mail: Chen Gang (chengang@chinamobile.com)
- 3135: CH10 is an umbrella Feature also for OAM&P related TEI10 type of changes that are not part of any other dedicated feature/WI / Impacted TSs and TRs: TR 30.820
- 3136: SP#51 completed. RAT differentiation for charging. Completes Rel-8 Feature IWLAN_Mob UID_370049 Mobility between 3GPP-WLAN Interworking and 3GPP Systems. Cooperation with CT1,CT3 on affected protocols / Impacted TSs and TRs: 32.240, 32.252, 32.298, 32.299 / WI rapporteur e-mail: Jean-Luc Garcia (jl.garcia@orange-ftgroup.com)
- 3137: CP#52 completed. SP#51 completed SA5. Continuation of Rel-8 BB UID_80042: Advice of Charge (AoC) support in IMS Charging (IMSTSS). Stage 2/3 work / WI rapporteur e-mail: matthias.seibel@telekom.de
- 3138: SP#51 completed. SA1 Stage 1 in 22.115 / Impacted TSs and TRs: 32.275, 32.280, 32.298, 32.299 / WI rapporteur e-mail: matthias.seibel@telekom.de
- 3139: CP#52 completed. SA1 Stage 1 in 22.115, 22.173, 22.024. Add mobile-specific CAI format and volume charging elements. Extensions to existing AoC XML / Impacted TSs and TRs: 24.647 / WI rapporteur e-mail: reinhard.lauster@t-mobile.at
- 3140: CP#51 completed. Ensure protocol alignment between 3GPP Stage 3 IMS work and IETF. Review capabilities provided in SIP by IETF and document whether these capabilities are supported in the IM CN Subsystem or not / Impacted TSs and TRs: 23.218, 24.229, 24.930 / WI rapporteur e-mail: keith.drage@alcatel-lucent.com
- 3141: CP#51 completed. Specify CRUD (Create/Read/Update/Delete) operations based on SOAP protocol, which may be used by the applications having no high real-time requirement to the data access operations / Impacted TSs and TRs: 29.335 / WI rapporteur e-mail: Lan Sizhong (lansizhong@chinamobile.com)
- 3142: Improvements of Rel-9 Feature UID_440027 Operational description of the Inter-IMS Network to Network Interface (II-NNI) / WI rapporteur e-mail: beata.dobrowolska@orange-ftgroup.com
- 3143: CP#51 completed / Impacted TSs and TRs: 29.165 / WI rapporteur e-mail: beata.dobrowolska@orange-ftgroup.com
- 3144: CP#59 completed AUTH 48 RFC-to-be-6794 / Impacted TSs and TRs: RFC 6794 (was draft-ietf-sip-session-policy-framework) / WI rapporteur e-mail: Lionel Morand
- 3145: CP#58 completed / Impacted TSs and TRs: RFC 6809 (was draft-ietf-sipcore-proxy-feature) / WI rapporteur e-mail: Christer Holmberg
- 3146: CP#51 completed. Specify 1) IMS-related AT-commands to configure MT and 2) IMS-related unsolicited response codes from MT to present to end-user / Impacted TSs and TRs: 27.007 / WI rapporteur e-mail: atle.monrad@ericsson.com
- 3147: CP#51 completed / Impacted TSs and TRs: 27.007 / WI rapporteur e-mail: magnus.mk.karlsson@stericsson.com
- 3148: CP#51 completed. Stage 1 in TS 22.038 USAT service description. Linked to CT6's UID_1273 Rel-5 BB Provisioning of IP-based multimedia services (24.229, 31.103) and UID_390021 Rel-8 BB CT6 aspects of SAE (31.102, 31.111) / Impacted TSs and TRs: 31.102, 31.103, 31.111 / WI rapporteur e-mail: Denis.Lheriteau@gemalto.com
- 3149: CP#52 completed. Linked to CT3 Rel-10 Feature UID_480014 Further improvements of II-NNI Stage 3 based on operational feedback and evolution of other specifications (II-NNI2) / Impacted TSs and TRs: 29.165 / WI rapporteur e-mail: arai.kenjiro@lab.ntt.co.jp
- 3150: CP#51 completed. Define a solution which allows enabling to launch Smart Card Web Server servicES in CP-150an easy and simple manner / Impacted TSs and TRs: 31.102 / WI rapporteur e-mail: davide.pratone@telecomitalia.it
- 3151: CP#51 completed. Stage 3 based on SA1 22.038CR#37r1 (Make USAT proactive capability reqs applicable to ME as a whole without regard to any particular configuration; e.g. a modem connected to an external display) / Impacted TSs and TRs: Stage 3 31.102, 31.111 / WI rapporteur e-mail: enric.fort@gi-de.com

| ID | WBS | Task | Type | Duration | Start | Finish | Complete | Baseline start | Baseline finish | Baseline duration | Constraint | Resources | Work | Actual work | Acronym | PCG approved | WI rapporteur name | WI rapporteur e-mail | Release | TSG approved | MCC resp | Acronym_3GU_Export | Status Report | Special Focus Doc | PCG stopped | TSG stopped |
| --- | --- | --- | --- | --- | --- | --- | --- | --- | --- | --- | --- | --- | --- | --- | --- | --- | --- | --- | --- | --- | --- | --- | --- | --- | --- | --- |
| 3152 | 792 | **Single Radio Voice Call Continuity (SRVCC) enhancements (Stage 3)** |  | 528d? | 2010-12-10 A | 2012-12-07 A | 100% | 2010-12-10 | 2012-12-07 | 528d? |  | C1; C4; IETF | 17295.4h | 17295.4h | eSRVCC | PCG-26 | China Mobile | Jiang Y (jiangyi@chinamobile.com) | Rel-10 | CP-50 | Frederic | eSRVCC |  |  |  |  |
| 3153 | 792.1 | CT1 part of Stage 3 for SRVCC enhancements |  | 71d? | 2010-12-10 A | 2011-03-18 A | 100% | 2010-12-10 | 2011-03-18 | 71d? | finish no earlier than 2011-03-18 | C1 | 568h | 568h | eSRVCC | PCG-26 | China Mobile | Jiang Y (jiangyi@chinamobile.com) | Rel-10 | CP-50 | Frederic |  |  |  |  |  |
| 3154 | 792.2 | CT4 part of Stage 3 for SRVCC enhancements |  | 71d? | 2010-12-10 A | 2011-03-18 A | 100% | 2010-12-10 | 2011-03-18 | 71d? | finish no earlier than 2011-03-18 | C4 | 568h | 568h | eSRVCC | PCG-26 | China Mobile | Jiang Y (jiangyi@chinamobile.com) | Rel-10 | CP-50 | Kimmo |  |  |  |  |  |
| 3155 | 792.3 | (IETF) CT1 part of Stage 3 for SRVCC enhancements (RFC 6809) |  | 436.8d? | 2010-12-10 A | 2012-12-07 A | 100% | 2010-12-10 | 2012-12-07 | 436.8d? | finish no earlier than 2013-03-01 | C1-IETF | 3487.38h | 3487.38h | eSRVCC | PCG-27 | christer.holmberg@ericsson.com | christer.holmberg@ericsson.com | Rel-10 | CP-52 | Frederic |  |  |  |  |  |
| 3156 | 793 | **Single Radio Voice Call Continuity (SRVCC) in alerting phase (Stage 3)** |  | 589d? | 2010-12-10 A | 2013-03-01 A | 100% | 2010-12-10 | 2013-03-01 | 589d? |  | C1; R5 | 11440h | 11440h | aSRVCC | PCG-26 | ZTE | li.shitao@zte.com.cn | Rel-10 | CP-50 | Frederic | aSRVCC |  |  |  |  |
| 3157 | 793.1 | CT aspects of Single Radio Voice Call Continuity (SRVCC) in alerting phase (Stage 3) |  | 126d? | 2010-12-10 A | 2011-06-03 A | 100% | 2010-12-10 | 2011-06-03 | 126d? | finish no earlier than 2011-06-03 | C1 | 1008h | 1008h | aSRVCC | PCG-26 | ZTE | li.shitao@zte.com.cn | Rel-10 | CP-50 | Frederic |  |  |  |  |  |
| 3158 | 793.2 | Conformance test aspects SRVCC in alerting phase |  | 126d? | 2012-09-11 A | 2013-03-01 A | 100% | 2012-09-11 | 2013-03-01 | 126d? | finish no earlier than 2013-03-01 | R5 | 1008h | 1008h | aSRVCC-UEConTest | PCG-29 | NTT DoCoMo | Takao.Shimizu.rp@nttdocomo.com | Rel-10 | RP-57 | Ingbert | aSRVCC-UEConTest | RP-130042 |  |  |  |
| 3159 | 794 | **PCRF failure and restoration** |  | 71d? | 2010-12-10 A | 2011-03-18 A | 100% | 2010-12-10 | 2011-03-18 | 71d? |  | C4; C3 | 2130h | 2130h | PCRF_FR | PCG-26 | NEC | Toshiyuki Tamura (tamurato@aj.jp.nec.com) | Rel-10 | CP-50 | Kimmo | PCRF_FR |  |  |  |  |
| 3160 | 794.1 | CT4 part of PCRF failure and restoration |  | 71d? | 2010-12-10 A | 2011-03-18 A | 100% | 2010-12-10 | 2011-03-18 | 71d? | finish no earlier than 2011-03-18 | C4 | 568h | 568h | PCRF_FR | PCG-26 | NEC | Toshiyuki Tamura (tamurato@aj.jp.nec.com) | Rel-10 | CP-50 | Kimmo |  |  |  |  |  |
| 3161 | 794.2 | CT3 part of PCRF failure and restoration |  | 53.25d? | 2010-12-10 A | 2011-03-18 A | 100% | 2010-12-10 | 2011-03-18 | 53.25d? | start no earlier than 2010-12-10 | C3 | 426h | 426h | PCRF_FR | PCG-26 | NEC | Toshiyuki Tamura (tamurato@aj.jp.nec.com) | Rel-10 | CP-50 | Adrian |  |  |  |  |  |
| 3162 | 795 | Formalization of WLAN Files | milestone | 0d? | 2011-02-23 A | 2011-03-18 A | 100% | 2011-02-23 | 2011-03-18 | 0d? | start no earlier than 2011-03-16 | C1 |  |  | FoWF | PCG-26 | Deutsche Telekom | dieter.jacobsohn@telekom.de | Rel-10 | CP-51 | Frederic | FoWF |  | WLAN |  |  |
| 3163 | 796 | CS and IMS Interworking for CAT service - Early Session model |  | 58d? | 2011-03-16 A | 2011-06-03 A | 100% | 2011-03-16 | 2011-06-03 | 58d? |  | C3 | 464h | 464h | CIIC_ES | PCG-26 | ZTE | li.shitao@zte.com.cn | Rel-10 | CP-51 | Adrian | CIIC_ES |  |  |  |  |
| 3164 | 797 | EPC Node Restoration without Idle mode Signalling Reduction (ISR) activated |  | 3d? | 2011-03-16 A | 2011-03-18 A | 100% | 2011-03-16 | 2011-03-18 | 3d? | finish no earlier than 2011-03-18 | C4 | 24h | 24h | EPC_NR | PCG-26 | Alcatel-Lucent | bruno.landais@alcatel-lucent.com | Rel-10 | CP-51 | Kimmo | EPC_NR |  |  |  |  |
| 3165 | 798 | EPC Node Restoration with Idle mode Signalling Reduction (ISR) activated |  | 58d? | 2011-03-16 A | 2011-06-03 A | 100% | 2011-03-16 | 2011-06-03 | 58d? | finish no earlier than 2011-03-18 | C4 | 464h | 464h | EPC_NR_ISR | PCG-26 | NEC | Toshiyuki Tamura (tamurato@aj.jp.nec.com) | Rel-10 | CP-51 | Kimmo | EPC_NR_ISR |  |  |  |  |
| 3166 | 799 | Mobile Terminating Roaming Forwarding with pre-paging |  | 58d? | 2011-03-16 A | 2011-06-03 A | 100% | 2011-03-16 | 2011-06-03 | 58d? | finish no earlier than 2011-03-18 | C4 | 464h | 464h | MTRF | PCG-26 | Ericsson | philip.hodges@ericsson.com | Rel-10 | CP-51 | Kimmo | MTRF |  |  |  |  |
| 3167 | 800 | **UICC access to IMS Specification** |  | 58d? | 2011-03-16 A | 2011-06-03 A | 100% | 2011-03-16 | 2011-06-03 | 58d? |  | C6; C1 | 1416h | 1416h | IMS-UICC-S | PCG-26 | Gemalto | Denis.Lheriteau@gemalto.com | Rel-10 | CP-51 | Xavier | IMS-UICC-S |  |  |  |  |
| 3168 | 800.1 | CT6 part of UICC access to IMS Specification |  | 3d? | 2011-03-16 A | 2011-03-18 A | 100% | 2011-03-16 | 2011-03-18 | 3d? | start no earlier than 2011-03-16 | C6 | 24h | 24h | IMS-UICC-S | PCG-26 | Gemalto | Denis.Lheriteau@gemalto.com | Rel-10 | CP-51 | Xavier |  |  |  |  |  |
| 3169 | 800.2 | CT1 part of UICC access to IMS Specification |  | 58d? | 2011-03-16 A | 2011-06-03 A | 100% | 2011-03-16 | 2011-06-03 | 58d? | start no earlier than 2011-03-16 | C1 | 464h | 464h | IMS-UICC-S | PCG-26 | Gemalto | Denis.Lheriteau@gemalto.com | Rel-10 | CP-51 | Frederic |  |  |  |  |  |
| 3170 | 801 | Deleted - Testing for Terminal support of Rel-10 USIM, ISIM and USAT features |  | 463d? | 2012-03-05 A | 2013-12-03 A | 100% | 2012-03-05 | 2013-12-03 | 463d? | finish no earlier than 2013-06-14 | C6 | 3704h | 3704h | USIM_R10_Test | PCG-28 | Gemalto | Denis.Praca@gemalto.com | Rel-10 | CP-55 | Xavier | USIM_R10_Test |  |  | PCG-32 | CP-62 |
| 3171 | 802 | **CN aspects of Local Call Local Switch** |  | 472d? | 2009-05-29 A | 2011-03-18 A | 100% | 2009-05-29 | 2011-03-18 | 472d? |  | C4 | 13008h | 13008h | LCLS-CN | PCG-23 | Vodafone | David.Hutton@vodafone.com | Rel-10 | CP-44 | Kimmo | LCLS-CN |  |  |  |  |
| 3172 | 802.1 | TR on CN aspects of Local Call Local Switch |  | 341d? | 2009-05-29 A | 2010-09-16 A | 100% | 2009-05-29 | 2010-09-16 | 341d? | finish no earlier than 2010-09-17 | C4 | 2728h | 2728h | LCLS-CN | PCG-23 | Vodafone | David.Hutton@vodafone.com | Rel-10 | CP-44 | Kimmo |  |  |  |  |  |
| 3173 | 802.2 | Stage 2/3 for CN aspects of Local Call Local Switch |  | 131d? | 2010-09-17 A | 2011-03-18 A | 100% | 2010-09-17 | 2011-03-18 | 131d? | finish no earlier than 2011-03-18 | C4 | 1048h | 1048h | LCLS-CN | PCG-25 | Vodafone | David.Hutton@vodafone.com | Rel-10 | CP-49 | Kimmo |  |  |  |  |  |
| 3174 | 802.3 | Deleted - CT3 aspects of Local Call Local Switch |  | 341d? | 2009-05-29 A | 2010-09-16 A | 100% | 2009-05-29 | 2010-09-16 | 341d? | finish no earlier than 2010-09-17 | C3 | 2728h | 2728h | LCLS-CN | PCG-23 | Vodafone | David.Hutton@vodafone.com | Rel-10 | CP-44 | Adrian |  |  |  | PCG-25 | CP-49 |
| 3175 | 802.4 | Deleted - CT1 aspects of Local Call Local Switch |  | 341d? | 2009-05-29 A | 2010-09-16 A | 100% | 2009-05-29 | 2010-09-16 | 341d? | finish no earlier than 2010-09-17 | C1 | 2728h | 2728h | LCLS-CN | PCG-23 | Vodafone | David.Hutton@vodafone.com | Rel-10 | CP-44 | Frederic |  |  |  | PCG-25 | CP-49 |
| 3176 | 803 | Local Call Local Switch | milestone | 0d? | 2007-05-07 A | 2007-05-07 A | 100% | 2007-05-07 | 2011-05-20 | 1055.8d? |  | GP; G2 |  |  | LCLS | PCG-22 | Huawei | wang_zhixi@huawei.com | Rel-10 | GP-41 | Paolo | LCLS |  |  |  |  |

Notes:
- 3152: Triggered by SA2 TR 23.856 Study on Single Radio Voice Call Continuity enhancements (FS_eSRVCC) UID_440049
- 3153: CP#51 completed / Impacted TSs and TRs: 24.229, 24.237
- 3154: CP#51 completed / Impacted TSs and TRs: 23.003, 23.008, 29.002, 29.230, 29.272, 29.305, 29.328, 29.329
- 3155: CP#58 completed / Impacted TSs and TRs: RFC 6809 (was draft-ietf-sipcore-proxy-feature)
- 3156: Builds on Rel-8 UID_390057 (IMS-Cont) TS 23.216 Stage 2. Provide Stage 3 for SRVCC PS-CS transfer of a call in alerting phase. Stage 2 TEI10 in TS 23.237 (6.3.2.1.4c/d, 6.3.2.1.7a/b)
- 3157: CP#52 completed / Impacted TSs and TRs: 24.008, 24.237
- 3158: RP#59 completed / Impacted TSs and TRs: 36.523-1, 36.523-2, 36.523-3, 34.229-1, 34.229-2, 34.229-3
- 3159: CP#51 completed. Triggered by CT3 TR 29.816 Study on Policy and Charging Rules Function (PCRF) failure and restoration (FS_PCRF-FR) UID_450013 / Impacted TSs and TRs: Stage 2/3 work
- 3160: CP#51 completed / Impacted TSs and TRs: Stage 2 23.007, Stage 3 29.230
- 3161: CP#51 completed / Impacted TSs and TRs: Stage 3 29.212, 29.213, 29.214, 29.215
- 3162: CP#51 completed. TS 24.235 for Info+Approval. Define the ME files as specified in 24.234 in OMA Device Management structure / Impacted TSs and TRs: Stage 3: 24.234, New 24.235
- 3163: CP#52 completed. Stage 1 in Rel-8 TS 22.182 Customized Alerting Tones (CAT) service. Stage 3 TS 24.182 defines 3 impl models: Gateway, Forking, Early Session. Specify missing CAT service interworking procedures btw CS & IMS networks / Impacted TSs and TRs: Stage 3 29.163, 29.235, 29.292
- 3164: CP#51 completed. Triggered by DRAFT TR 23.857 Study on EPC Nodes Restoration (FS_EPC_NR) UID_490014 / Impacted TSs and TRs: Stage 2/3: 23.007, 29.274
- 3165: CP#52 completed. Triggered by DRAFT TR 23.857 Study on EPC Nodes Restoration (FS_EPC_NR) UID_490014 / Impacted TSs and TRs: Stage 2/3: 23.007, 29.274
- 3166: CP#52 completed. Provides Stage 2/3 alternative solution to Mobile Terminating Roaming Retry to solve roaming events during paging, in particular to support CSFB. Hence, no new Stage 1 requirements exist / Impacted TSs and TRs: Stage 2/3: 23.012, 23.018, 23.116, 29.002
- 3167: CP#52 completed. Triggered by Rel-10 TR 31.828 Study on UICC access to IMS (FS_IMS-UICC) UID_480017. Specify mechanism in UICC and ME to make use of IMS functionality implemented in ME for case a) an ISIM is present b) no ISIM is present in UICC
- 3168: CP#51 completed / Impacted TSs and TRs: 31.102, 31.103, 31.111
- 3169: CP#52 completed / Impacted TSs and TRs: 24.229
- 3170: CP#62 stopped (at 70% completion 06/13). Testing for New featurES in CP-150Rel-10 specifications for USIM, ISIM applications and USIM Application Toolkit (USAT) in TS 31.102, 31.103, 31.111 / Impacted TSs and TRs: 31.121, 31.124, New TS 31.ABC (Conformance Testing of specific features)
- 3171: CP#51 completed / Impacted TSs and TRs: GERAN Stage 2/3
- 3172: CP#49 completed / Impacted TSs and TRs: new TR 23.889
- 3173: CP#51 completed / Impacted TSs and TRs: 23.003, 23.009, 23.205, 23.231, 29.002, 29.205, 29.232, new TS 23.284
- 3174: CP#49 stopped. Result of study TR 23.889: no CT3 specification impact
- 3175: CP#49 stopped. Result of study TR 23.889: no CT1 specification impact
- 3176: GP#50 completed. GP#41 WID approved / Impacted TSs and TRs: GERAN Stage 3: 48.008, 48.103

| ID | WBS | Task | Duration | Start | Finish | Complete | Baseline start | Baseline finish | Baseline duration | Constraint | Resources | Work | Actual work | Acronym | PCG approved | WI rapporteur name | Release | TSG approved | MCC resp | Acronym_3GU_Export | Status Report | Special Focus Doc |
| --- | --- | --- | --- | --- | --- | --- | --- | --- | --- | --- | --- | --- | --- | --- | --- | --- | --- | --- | --- | --- | --- | --- |
| 3177 | 804 | **Tightened Link Level Performance Requirements for Single Antenna MS** | 659d? | 2010-09-03 A | 2013-03-01 A | 100% | 2010-09-03 | 2013-03-01 | 659d? |  | G1; G2; C1; G3new | 30856h | 30856h | TIGHTER | PCG-25 | Renesas Mobile | Rel-10 | GP-46 | Paolo | TIGHTER |  |  |
| 3178 | 804.1 | CT1 part for TIGHTER | 196d? | 2010-09-03 A | 2011-06-03 A | 100% | 2010-09-03 | 2011-06-03 | 196d? | finish no earlier than 2011-06-03 | C1 | 1568h | 1568h | TIGHTER | PCG-25 | Renesas Mobile | Rel-10 | GP-46 | Frederic |  |  |  |
| 3179 | 804.2 | TIGHTER Performance Requirements | 186d? | 2010-09-03 A | 2011-05-20 A | 100% | 2010-09-03 | 2011-05-20 | 186d? | finish no earlier than 2011-05-20 | G1; G2 | 2976h | 2976h | TIGHTER | PCG-25 | Renesas Mobile | Rel-10 | GP-46 | Paolo |  |  |  |
| 3180 | 804.3 | TIGHTER Testing | 654d? | 2010-09-08 A | 2013-03-01 A | 100% | 2010-09-08 | 2013-03-01 | 654d? | finish no earlier than 2013-03-01 | G3new | 5224h | 5224h | TIGHTER | PCG-25 | Renesas Mobile | Rel-10 | GP-46 | Ingbert |  |  |  |
| 3181 | 805 | **Support of Multi-Operator Core Network by GERAN** | 206d? | 2010-05-21 A | 2011-03-04 A | 100% | 2010-05-21 | 2011-03-04 | 206d? |  | G2; S2; C1 | 8392h | 8392h | MOCN-GERAN | PCG-25 | Alcatel-Lucent | Rel-10 | GP-47 | Gert | MOCN-GERAN |  |  |
| 3182 | 805.1 | Stage 2 for Support of Multi-Operator Core Network by GERAN | 150d? | 2010-05-21 A | 2010-12-16 A | 100% | 2010-05-21 | 2010-12-16 | 150d? | finish no earlier than 2010-12-15 | S2 | 1200h | 1200h | MOCN-GERAN | PCG-25 | Alcatel-Lucent | Rel-10 | GP-47 | Maurice |  |  |  |
| 3183 | 805.2 | CT1 part of Stage 3 for Support of Multi-Operator Core Network by GERAN | 146d? | 2010-05-21 A | 2010-12-10 A | 100% | 2010-05-21 | 2010-12-10 | 146d? | finish no earlier than 2010-12-10 | C1 | 1168h | 1168h | MOCN-GERAN | PCG-25 | Alcatel-Lucent | Rel-10 | GP-47 | Frederic |  |  |  |
| 3184 | 805.3 | GERAN2 part of Stage 3 for Support of Multi-Operator Core Network by GERAN | 135d? | 2010-08-30 A | 2011-03-04 A | 100% | 2010-08-30 | 2011-03-04 | 135d? | finish no earlier than 2011-03-04 | G2 | 1080h | 1080h | MOCN-GERAN | PCG-25 | Alcatel-Lucent | Rel-10 | GP-47 | Gert |  |  |  |
| 3185 | 806 | **Enhancements of Iur-g interface** | 196d? | 2010-09-03 A | 2011-06-03 A | 100% | 2010-09-03 | 2011-06-03 | 196d? |  | G2; R3 | 5752h | 5752h | eIurg | PCG-25 | China Mobile, ZTE | Rel-10 | GP-47 | Gert | eIurg |  |  |
| 3186 | 806.1 | GERAN part for Enhancements of Iur-g interface (Stage 2/3) | 131d? | 2010-09-03 A | 2011-03-04 A | 100% | 2010-09-03 | 2011-03-04 | 131d? | finish no earlier than 2011-03-04 | G2 | 1048h | 1048h | eIurg-GERAN | PCG-25 | China Mobile, ZTE | Rel-10 | GP-47 | Gert | eIurg-GERAN |  |  |
| 3187 | 806.2 | Core part: Enhancements of Iur-g interface (Stage 2/3) | 196d? | 2010-09-03 A | 2011-06-03 A | 100% | 2010-09-03 | 2011-06-03 | 196d? | finish no earlier than 2011-06-03 | R3 | 1568h | 1568h | eIurg-RAN | PCG-25 | ZTE | Rel-10 | RP-49 | Juha | eIurg-RAN | RP-110526 |  |
| 3188 | 807 | 1.28 Mcps TDD Repeater | 599d? | 2007-12-04 A | 2010-03-19 A | 100% | 2007-12-04 | 2010-03-19 | 599d? | finish no earlier than 2010-03-19 | R4 | 4792h | 4792h | RANimp-Repeaters1.28TDD | PCG-21 | RITT | Rel-10 | RP-38 | Issam | RANimp-Repeaters1.28TDD | RP-100039 |  |
| 3189 | 808 | 1.28 Mcps TDD Multi-carrier HSUPA | 321d? | 2009-09-18 A | 2010-12-10 A | 100% | 2009-09-18 | 2010-12-10 | 321d? | finish no earlier than 2010-12-10 | R1; R2; R3; R4 | 10272h | 10272h | TDD_MC_HSUPA | PCG-23 | CATR | Rel-10 | RP-45 | Patrick | TDD_MC_HSUPA | RP-101079 |  |
| 3190 | 809 | **1.28 Mcps TDD Home NodeB RF requirements** | 266d? | 2009-12-04 A | 2010-12-10 A | 100% | 2009-12-04 | 2010-12-10 | 266d? |  | R4 | 5304h | 5304h | HNB_LCRTDD_RF | PCG-24 | TD Tech | Rel-10 | RP-46 | Issam | HNB_LCRTDD_RF |  | HNB |
| 3191 | 809.1 | Core part: 1.28Mcps TDD Home NodeB RF requirements | 131d? | 2009-12-04 A | 2010-06-04 A | 100% | 2009-12-04 | 2010-06-04 | 131d? | finish no earlier than 2010-12-10 | R4 | 1048h | 1048h | HNB_LCRTDD_RF-Core | PCG-24 | TD Tech | Rel-10 | RP-46 | Issam | HNB_LCRTDD_RF-Core | RP-100446 | HNB |
| 3192 | 809.2 | Perf. part: 1.28Mcps TDD Home NodeB RF requirements | 266d? | 2009-12-04 A | 2010-12-10 A | 100% | 2009-12-04 | 2010-12-10 | 266d? | finish no earlier than 2010-12-10 | R4 | 2128h | 2128h | HNB_LCRTDD_RF-Perf | PCG-24 | TD Tech | Rel-10 | RP-46 | Issam | HNB_LCRTDD_RF-Perf | RP-101081 | HNB |
| 3193 | 810 | **Multi-User Multiple-Input and Multiple-Output (MU-MIMO) for 1.28Mcps TDD** | 316d? | 2010-03-19 A | 2011-06-03 A | 100% | 2010-03-19 | 2011-06-03 | 316d? |  | R1; R2; R3; R4 | 17224h | 17224h | MUMIMO_LCR_TDD | PCG-24 | CATT | Rel-10 | RP-47 | Patrick | MUMIMO_LCR_TDD |  |  |
| 3194 | 810.1 | Core part: MU-MIMO for 1.28Mcps TDD | 191d? | 2010-03-19 A | 2010-12-10 A | 100% | 2010-03-19 | 2010-12-10 | 191d? | finish no earlier than 2010-12-10 | R1; R2; R3 | 4584h | 4584h | MUMIMO_LCR_TDD-Core | PCG-24 | CATT | Rel-10 | RP-47 | Patrick | MUMIMO_LCR_TDD-Core | RP-101085 |  |
| 3195 | 810.2 | Perf. part: MU-MIMO for 1.28Mcps TDD | 316d? | 2010-03-19 A | 2011-06-03 A | 100% | 2010-03-19 | 2011-06-03 | 316d? | finish no earlier than 2011-06-03 | R4 | 2528h | 2528h | MUMIMO_LCR_TDD-Perf | PCG-24 | CATT | Rel-10 | RP-47 | Issam | MUMIMO_LCR_TDD-Perf | RP-110520 |  |
| 3196 | 811 | **AGNSS Minimum Performance for UTRAN** | 523d? | 2009-09-18 A | 2011-09-16 A | 100% | 2009-09-18 | 2011-09-16 | 523d? |  | R4; R5 | 13624h | 13624h | AGNSSPerf_UTRAN | PCG-23 | Thales | Rel-10 | RP-45 | Issam | AGNSSPerf_UTRAN |  |  |
| 3197 | 811.1 | AGNSS Minimum Performance Specification Development | 321d? | 2009-09-18 A | 2010-12-10 A | 100% | 2009-09-18 | 2010-12-10 | 321d? | finish no earlier than 2010-12-10 | R4 | 2568h | 2568h | AGNSSPerf_UTRAN | PCG-23 | Thales | Rel-10 | RP-45 | Issam | AGNSSPerf_UTRAN | RP-101078 |  |
| 3198 | 811.2 | AGNSS test case development for UMTS | 336d? | 2010-06-04 A | 2011-09-16 A | 100% | 2010-06-04 | 2011-09-16 | 336d? | finish no earlier than 2011-09-16 | R5 | 2688h | 2688h | AGNSSPerf_UTRAN | PCG-25 | Thales | Rel-10 | RP-48 | Ingbert | AGNSSPerf_UTRAN | RP-110979 |  |
| 3199 | 812 | **Inclusion of RF Pattern Matching Technologies as positioning method in the UTRAN** | 336d? | 2009-12-04 A | 2011-03-18 A | 100% | 2009-12-04 | 2011-03-18 | 336d? |  | R2; R3 | 10752h | 10752h | LCS_UMTS_RFPMT | PCG-24 | Polaris Wireless | Rel-10 | RP-46 | Yong-Jun | LCS_UMTS_RFPMT | RP-110048 |  |
| 3200 | 812.1 | Core part: Inclusion of RF Pattern Matching Technologies as positioning method in the UTRAN | 336d? | 2009-12-04 A | 2011-03-18 A | 100% | 2009-12-04 | 2011-03-18 | 336d? | finish no earlier than 2011-03-18 | R2; R3 | 5376h | 5376h | LCS_UMTS_RFPMT-Core | PCG-24 | Polaris Wireless | Rel-10 | RP-46 | Yong-Jun | LCS_UMTS_RFPMT-Core | RP-110048 |  |

Notes:
- 3177: GP#46 approved WID / Impacted TSs and TRs: GERAN / WI rapporteur e-mail: carsten.juncker@renesasmobile.com
- 3178: CP#52 completed / Impacted TSs and TRs: 24.008 / WI rapporteur e-mail: marko.niemi@renesasmobile.com
- 3179: GP#50 completed / Impacted TSs and TRs: 45.005, 45.015 / WI rapporteur e-mail: carsten.juncker@renesasmobile.com
- 3180: GP#57 completed / Impacted TSs and TRs: 51.010 / WI rapporteur e-mail: carsten.juncker@renesasmobile.com
- 3181: GP#47 approved WID. 900 MHz spectrum re-farming to other RATs lead operators to reduce GSM capacity and therefore share their GSM networks. Hence the need for the most suitable (GE)RAN sharing method / Impacted TSs and TRs: GERAN / WI rapporteur e-mail: michel.robert@alcatel-lucent.com
- 3182: SP#50 completed / Impacted TSs and TRs: 23.251 / WI rapporteur e-mail: michel.robert@alcatel-lucent.com
- 3183: CP#50 completed / Impacted TSs and TRs: 24.008 CR#1644 / WI rapporteur e-mail: michel.robert@alcatel-lucent.com
- 3184: GP#49 completed / Impacted TSs and TRs: 48.008 CR#0325, 48.018 CR#0303 / WI rapporteur e-mail: michel.robert@alcatel-lucent.com
- 3185: GP#47 approved WID / Impacted TSs and TRs: GERAN,UTRA / WI rapporteur e-mail: Ms Juan Deng (dengjuan@chinamobile.com), Xinhui Wang (wangxinhui@zte.com.cn)
- 3186: GP#49 completed. GP#48 updated WID GP-101659=>GP-101758 (restricting the scope to GERAN BSC and TD-SCDMA RNC only). GP#47 approved WID / Impacted TSs and TRs: 43.130, 48.008 / WI rapporteur e-mail: Ms Juan Deng (dengjuan@chinamobile.com), Xinhui Wang (wangxinhui@zte.com.cn)
- 3187: RP#52 completed / Impacted TSs and TRs: UTRA Stage 2 (25.401, 25.420), Stage 3 (25.423) / WI rapporteur e-mail: Liu Junqiang (liu.junqiang@zte.com.cn)
- 3188: RP#47 completed / Impacted TSs and TRs: UTRA 25.113, New 25.116, 25.153 (testing) / WI rapporteur e-mail: qinyan@chinattl.com
- 3189: RP#50 completed / Impacted TSs and TRs: UTRA 25.102, 25.105, 25.123, 25.221, 25.222, 25.223, 25.224, 25.225, 25.306, 25.319, 25.321, 25.331, 25.423, 25.427, 25.433 / WI rapporteur e-mail: Aihui Song (songaihui@mail.ritt.com.cn)
- 3190: RP#50 completed. Triggered by FS_RAN-HNBLCRTDD UID_410016 Study on 1.28 Mcps TDD Home NodeB (TR 25.866) / Impacted TSs and TRs: UTRA / WI rapporteur e-mail: Li Rong (lirong@td-tech.com)
- 3191: RP#48 completed / Impacted TSs and TRs: 25.105 / WI rapporteur e-mail: Li Rong (lirong@td-tech.com)
- 3192: RP#50 completed. TR 25.968 v100 for Approval / Impacted TSs and TRs: 25.142, new TR 25.968 / WI rapporteur e-mail: Li Rong (lirong@td-tech.com)
- 3193: RP#52 completed / Impacted TSs and TRs: UTRA / WI rapporteur e-mail: Yanping Xing (xingyanping@datangmobile.cn)
- 3194: RP#50 completed / Impacted TSs and TRs: 25.221, 25.222, 25.224, 25.306, 25.308, 25.319, 25.331, 25.423, 25.425, 25.433, 25.435 / WI rapporteur e-mail: Yanping Xing (xingyanping@datangmobile.cn)
- 3195: RP#52 completed / Impacted TSs and TRs: 25.102, 25.105, 25.142 / WI rapporteur e-mail: Sanjun Feng (fengsanjun@datangmobile.cn)
- 3196: RP#53 completed. Triggered by Rel-7 UID_20050 (GNSS in UTRAN) and Rel-8 UID_400051 (Support for Additional NSS). Linked to GERAN Rel-9 UID_38002 (AGNSS Performances and Testing Procedures) / Impacted TSs and TRs: UTRA / WI rapporteur e-mail: Michel.monnerat@thalesaleniaspace.com
- 3197: RP#50 completed / Impacted TSs and TRs: new 25.172 / WI rapporteur e-mail: Michel.monnerat@thalesaleniaspace.com
- 3198: RP#53 completed / Impacted TSs and TRs: 34.108, 34.109, 34.123-1, 34.123-2, 34.123-3, 36.37.571-5, new 34.172 / WI rapporteur e-mail: Michel.monnerat@thalesaleniaspace.com
- 3199: RP#51 completed. Triggered by Study UID_380079 Evaluation of the inclusion of Path Loss Based Technology in the UTRAN (25.907) / Impacted TSs and TRs: UTRA / WI rapporteur e-mail: Norman Shaw (nshaw@polariswireless.com)
- 3200: RP#51 completed / Impacted TSs and TRs: 25.305, 25.453 / WI rapporteur e-mail: Norman Shaw (nshaw@polariswireless.com)

| ID | WBS | Task | Duration | Start | Finish | Complete | Baseline start | Baseline finish | Baseline duration | Constraint | Resources | Work | Actual work | Acronym | PCG approved | WI rapporteur name | WI rapporteur e-mail | Release | TSG approved | MCC resp | Acronym_3GU_Export | Status Report | PCG stopped | TSG stopped | Special Focus Doc |
| --- | --- | --- | --- | --- | --- | --- | --- | --- | --- | --- | --- | --- | --- | --- | --- | --- | --- | --- | --- | --- | --- | --- | --- | --- | --- |
| 3201 | 813 | **Four carrier HSDPA** | 992d? | 2009-12-04 A | 2013-09-06 A | 100% | 2009-12-04 | 2013-09-06 | 992d? |  | R1; R2; R3; R4; R5 | 57872h | 57872h | 4C_HSDPA | PCG-24 | Qualcomm | Arjun Bharadwaj (arjunb@qualcomm.com) | Rel-10 | RP-46 | Patrick | 4C_HSDPA |  |  |  |  |
| 3202 | 813.1 | Core part: Four carrier HSDPA | 336d? | 2009-12-04 A | 2011-03-18 A | 100% | 2009-12-04 | 2011-03-18 | 336d? | finish no earlier than 2011-03-18 | R1; R2; R3; R4 | 10752h | 10752h | 4C_HSDPA-Core | PCG-24 | Qualcomm | Arjun Bharadwaj (arjunb@qualcomm.com) | Rel-10 | RP-46 | Patrick | 4C_HSDPA-Core | RP-110046 |  |  |  |
| 3203 | 813.2 | Perf. part: Four carrier HSDPA | 466d? | 2009-12-04 A | 2011-09-16 A | 100% | 2009-12-04 | 2011-09-16 | 466d? | finish no earlier than 2011-09-16 | R4 | 3728h | 3728h | 4C_HSDPA-Perf | PCG-24 | Qualcomm | Arjun Bharadwaj (arjunb@qualcomm.com) | Rel-10 | RP-46 | Issam | 4C_HSDPA-Perf | RP-110986 |  |  |  |
| 3204 | 813.3 | Test part: Four carrier HSDPA | 464d? | 2011-12-02 A | 2013-09-06 A | 100% | 2011-12-02 | 2013-09-06 | 464d? | finish no earlier than 2013-09-06 | R5 | 3712h | 3712h | 4C_HSDPA-UEConTest | PCG-28 | Qualcomm | Shubhang Vora (svora@qualcomm.com) | Rel-10 | RP-54 | Ingbert | 4C_HSDPA-UEConTest | RP-130940 |  |  |  |
| 3205 | 814 | **Performance Requirements for two-antenna 1.28Mcps TDD Type 1 and Type 2 UE receiver** | 316d? | 2010-03-19 A | 2011-06-03 A | 100% | 2010-03-19 | 2011-06-03 | 316d? |  | R4 | 5504h | 5504h | 2ant_UE_LCR_TDD | PCG-24 | TD Tech | dafei.wang@td-tech.com | Rel-10 | RP-47 | Issam | 2ant_UE_LCR_TDD |  |  |  |  |
| 3206 | 814.1 | Core part: Performance Requirements for two-antenna 1.28Mcps TDD Type 1 and Type 2 UE receiver | 56d? | 2010-03-19 A | 2010-06-04 A | 100% | 2010-03-19 | 2010-06-04 | 56d? | finish no earlier than 2010-06-04 | R4 | 448h | 448h | 2ant_UE_LCR_TDD-Core | PCG-24 | TD Tech | dafei.wang@td-tech.com | Rel-10 | RP-47 | Issam | 2ant_UE_LCR_TDD-Core | RP-100454 |  |  |  |
| 3207 | 814.2 | Perf. part: Performance Requirements for two-antenna 1.28Mcps TDD Type 1 and Type 2 UE receiver | 316d? | 2010-03-19 A | 2011-06-03 A | 100% | 2010-03-19 | 2011-06-03 | 316d? | finish no earlier than 2011-06-03 | R4 | 2528h | 2528h | 2ant_UE_LCR_TDD-Perf | PCG-24 | TD Tech | dafei.wang@td-tech.com | Rel-10 | RP-47 | Issam | 2ant_UE_LCR_TDD-Perf | RP-110521 |  |  |  |
| 3208 | 815 | **Automatic Neighbour Relation (ANR) for UTRAN** | 663d? | 2010-06-04 A | 2012-12-07 A | 100% | 2010-06-04 | 2012-12-07 | 663d? |  | R3; R2; R5 | 22672h | 22672h | ANR_UTRAN | PCG-25 | ZTE | Zhai.hengxing@zte.com.cn | Rel-10 | RP-48 | Juha | ANR_UTRAN |  |  |  |  |
| 3209 | 815.1 | Core part: Automatic Neighbour Relation (ANR) for UTRAN | 261d? | 2010-06-04 A | 2011-06-03 A | 100% | 2010-06-04 | 2011-06-03 | 261d? | finish no earlier than 2011-06-03 | R3; R2 | 4176h | 4176h | ANR_UTRAN-Core | PCG-25 | ZTE | Zhai.hengxing@zte.com.cn | Rel-10 | RP-48 | Juha | ANR_UTRAN-Core | RP-110522 |  |  |  |
| 3210 | 815.2 | Test part: Automatic Neighbour Relation (ANR) for UTRAN | 323d? | 2011-09-19 A | 2012-12-07 A | 100% | 2011-09-19 | 2012-12-07 | 323d? | finish no earlier than 2012-12-07 | R5 | 2584h | 2584h | ANR_UTRAN-UEConTest | PCG-27 | Ericsson | leif.mattisson@ericsson.com | Rel-10 | RP-53 | Ingbert | ANR_UTRAN-UEConTest | RP-121529 |  |  |  |
| 3211 | 816 | **Support of New Band Combinations for Dual-Band Dual Cell HSDPA** | 261d? | 2010-06-04 A | 2011-06-03 A | 100% | 2010-06-04 | 2011-06-03 | 261d? |  | R4; R2 | 9568h | 9568h | DB_DC_HSDPA | PCG-25 | AT&T | Vince Spatafora (vs5785@att.com) | Rel-10 | RP-48 | Issam | DB_DC_HSDPA |  |  |  |  |
| 3212 | 816.1 | Core part: Support of New Band Combinations for Dual-Band Dual Cell HSDPA | 261d? | 2010-06-04 A | 2011-06-03 A | 100% | 2010-06-04 | 2011-06-03 | 261d? | finish no earlier than 2011-06-03 | R4; R2 | 4176h | 4176h | DB_DC_HSDPA-Core | PCG-25 | AT&T | Vince Spatafora (vs5785@att.com) | Rel-10 | RP-48 | Issam | DB_DC_HSDPA-Core | RP-110523 |  |  |  |
| 3213 | 816.2 | Deleted - Perf. part: Support of New Band Combinations for Dual-Band Dual Cell HSDPA | 76d? | 2010-06-04 A | 2010-09-17 A | 100% | 2010-06-04 | 2010-09-17 | 76d? | finish no earlier than 2010-09-17 | R4; R2 | 1216h | 1216h | DB_DC_HSDPA-Perf | PCG-25 | AT&T | Vince Spatafora (vs5785@att.com) | Rel-10 | RP-48 | Issam | DB_DC_HSDPA-Perf | RP-100759 | PCG-25 | RP-49 |  |
| 3214 | 817 | **MIMO operation with non-MIMO coexistence in HSDPA** | 459d? | 2010-06-04 A | 2012-03-02 A | 100% | 2010-06-04 | 2012-03-02 | 459d? |  | R4; R5 | 12936h | 12936h | MIMO_HSDPA | PCG-25 | Qualcomm | Heechoon Lee | Rel-10 | RP-48 | Issam | MIMO_HSDPA |  |  |  |  |
| 3215 | 817.1 | Core part: MIMO operation with non-MIMO coexistence in HSDPA | 186d? | 2010-09-17 A | 2011-06-03 A | 100% | 2010-09-17 | 2011-06-03 | 186d? | finish no earlier than 2011-06-03 | R4 | 1488h | 1488h | MIMO_HSDPA-Core | PCG-25 | Qualcomm | Heechoon Lee | Rel-10 | RP-49 | Issam | MIMO_HSDPA-Core | RP-110524 |  |  |  |
| 3216 | 817.2 | Perf. part: MIMO operation with non-MIMO coexistence in HSDPA | 261d? | 2010-06-04 A | 2011-06-03 A | 100% | 2010-06-04 | 2011-06-03 | 261d? | finish no earlier than 2011-06-03 | R4 | 2088h | 2088h | MIMO_HSDPA-Perf | PCG-25 | Qualcomm | Heechoon Lee | Rel-10 | RP-48 | Issam | MIMO_HSDPA-Perf | RP-110525 |  |  |  |
| 3217 | 817.3 | Test part: MIMO operation with non-MIMO coexistence in HSDPA | 252d? | 2011-03-18 A | 2012-03-02 A | 100% | 2011-03-18 | 2012-03-02 | 252d? | finish no earlier than 2012-03-02 | R5 | 2016h | 2016h | MIMO_HSDPA-UEConTest | PCG-26 | Qualcomm | Shubhang Vora (svora@qualcomm.com) | Rel-10 | RP-51 | Ingbert | MIMO_HSDPA-UEConTest | RP-120042 |  |  |  |
| 3218 | 818 | Interfrequency detected set measurements for UMTS | 61d? | 2010-09-17 A | 2010-12-10 A | 100% | 2010-09-17 | 2010-12-10 | 61d? | finish no earlier than 2010-12-10 | R2; R4 | 976h | 976h | Interf_dset_meas_UMTS | PCG-25 | Nokia | Chris.callender@nokia.com | Rel-10 | RP-49 | Yong-Jun | Interf_dset_meas_UMTS | RP-101093 |  |  |  |
| 3219 | 819 | **Carrier Aggregation for LTE** | 793d? | 2009-12-04 A | 2012-12-07 A | 100% | 2009-12-04 | 2012-12-07 | 793d? |  | R1; R2; R3; R4; R5 | 51024h | 51024h | LTE_CA | PCG-24 | Nokia | Asbjorn.grovlen@nokia.com | Rel-10 | RP-46 | Patrick | LTE_CA |  |  |  | CA |
| 3220 | 819.1 | Core part: Carrier Aggregation for LTE | 391d? | 2009-12-04 A | 2011-06-03 A | 100% | 2009-12-04 | 2011-06-03 | 391d? | finish no earlier than 2011-06-03 | R1; R2; R3; R4 | 12512h | 12512h | LTE_CA-Core | PCG-24 | Nokia | lars.e.lindh@nokia.com | Rel-10 | RP-46 | Patrick | LTE_CA-Core | RP-110535 |  |  | CA |
| 3221 | 819.2 | Perf. part: Carrier Aggregation for LTE | 528d? | 2009-12-04 A | 2011-12-09 A | 100% | 2009-12-04 | 2011-12-09 | 528d? | finish no earlier than 2011-12-09 | R4 | 4224h | 4224h | LTE_CA-Perf | PCG-24 | Nokia | lars.e.lindh@nokia.com | Rel-10 | RP-46 | Issam | LTE_CA-Perf | RP-111452 |  |  | CA |
| 3222 | 819.3 | Test part: Carrier Aggregation for LTE | 321d? | 2011-09-19 A | 2012-12-07 A | 100% | 2011-09-19 | 2012-12-07 | 321d? | finish no earlier than 2012-12-07 | R5 | 2568h | 2568h | LTE_CA-UEConTest | PCG-27 | Nokia | jussi.kuusisto@nokia.com | Rel-10 | RP-53 | Ingbert | LTE_CA-UEConTest | RP-121528 |  |  | CA |
| 3223 | 820 | **Enhanced Downlink Multiple Antenna Transmission for LTE** | 930d? | 2009-12-04 A | 2013-06-14 A | 100% | 2009-12-04 | 2013-06-14 | 930d? |  | R1; R2; R4; R5 | 44624h | 44624h | LTE_eDL_MIMO | PCG-24 | NTT DoCoMo | Hidekazu Taoka (taoka@nttdocomo.com) | Rel-10 | RP-46 | Patrick | LTE_eDL_MIMO |  |  |  |  |
| 3224 | 820.1 | Core part: Enhanced Downlink Multiple Antenna Transmission for LTE | 336d? | 2009-12-04 A | 2011-03-18 A | 100% | 2009-12-04 | 2011-03-18 | 336d? | finish no earlier than 2011-03-18 | R1; R2; R4 | 8064h | 8064h | LTE_eDL_MIMO-Core | PCG-24 | NTT DoCoMo | Hidekazu Taoka (taoka@nttdocomo.com) | Rel-10 | RP-46 | Patrick | LTE_eDL_MIMO-Core | RP-110067 |  |  |  |
| 3225 | 820.2 | Perf. part: Enhanced Downlink Multiple Antenna Transmission for LTE | 589d? | 2009-12-04 A | 2012-03-02 A | 100% | 2009-12-04 | 2012-03-02 | 589d? | finish no earlier than 2012-03-02 | R4 | 4712h | 4712h | LTE_eDL_MIMO-Perf | PCG-24 | NTT DoCoMo | Hidekazu Taoka (taoka@nttdocomo.com) | Rel-10 | RP-46 | Issam | LTE_eDL_MIMO-Perf | RP-120053 |  |  |  |
| 3226 | 820.3 | Test part: Enhanced Downlink Multiple Antenna Transmission for LTE | 261d? | 2012-06-18 A | 2013-06-14 A | 100% | 2012-06-18 | 2013-06-14 | 261d? | finish no earlier than 2013-06-14 | R5 | 2088h | 2088h | LTE_eDL_MIMO-UEConTest | PCG-29 | ZTE | Carolyn Taylor (carolyn.tayl@zte.com.cn) | Rel-10 | RP-56 | Ingbert | LTE_eDL_MIMO-UEConTest | RP-130464 |  |  |  |

Notes:
- 3201: RP#53 completed / Impacted TSs and TRs: UTRA
- 3202: RP#51 completed. RP#52 TR 25.864 v200 for Approval / Impacted TSs and TRs: 25.101, 25.104, 25.133, 25.211, 25.212, 25.213, 25.214, 25.215, 25.308, 25.331, 25.423, 25.433, 26.306, new TR 25.864
- 3203: RP#53 completed / Impacted TSs and TRs: 25.101, 25.104, 25.133, 25.141
- 3204: RP#61 completed / Impacted TSs and TRs: 34.108, 34.121-1, 34.121-2, 34.123-1, 34.123-2, 34.123-3
- 3205: Stage 3. RP#52 completed / Impacted TSs and TRs: UTRA
- 3206: RP#48 completed / Impacted TSs and TRs: 25.102
- 3207: RP#52 completed / Impacted TSs and TRs: 25.102
- 3208: RP#52 Core completed. Automatic Neighbour Relation (ANR) function for UTRAN relieves operators from the burden of manually managing the Neighbour cell Relations (NRs) / Impacted TSs and TRs: UTRA
- 3209: RP#52 completed / Impacted TSs and TRs: 25.331, 25.413, 25.423, new TS 25.484 (Stage 2)
- 3210: RP#58 completed / Impacted TSs and TRs: 34.108, 34.123-1, 34.123-2, 34.123-3
- 3211: RP#52 completed. Rel-9 Dual-Band Dual-Cell HSDPA (UID_430015 Support for different bands for Dual-Cell HSDPA) has one combination per region in principle. This work adds additional combinations: Band I and XI (Region 3) and Band II and V (Region 2) / Impacted TSs and TRs: UTRA
- 3212: RP#52 completed. RP#62 existing TS 25.317 replaced by new TS 25.327 / Impacted TSs and TRs: 25.101, 25.104, 25.141, 25.317 replaced by new TS 25.327
- 3213: RP#49 stopped (Reason: no need for Performance work) / Impacted TSs and TRs: 25.101, 25.104, 25.141, 25.317
- 3214: RP#52 completed. RP#49 updated WID RP-100687=>RP-100993 (changed Title: MIMO Testing in HSDPA => MIMO operation with non-MIMO coexistence in HSDPA) / Impacted TSs and TRs: UTRA
- 3215: RP#52 completed / Impacted TSs and TRs: 25.104
- 3216: RP#52 completed / Impacted TSs and TRs: 25.101, 25.141
- 3217: RP#55 completed / Impacted TSs and TRs: 34.108, 34.121-1, 34.121-2, 34.123-1, 34.123-2, 34.123-3
- 3218: RP#50 completed / Impacted TSs and TRs: UTRA 25.133, 25.331
- 3219: - / Impacted TSs and TRs: LTE
- 3220: RP#52 completed. RP#56 new RAN4 TR (36.807, 36.808) v200 for Approval / Impacted TSs and TRs: 36.101, 36.104, 36.133, 36.211, 36.212, 36.213, 36.300, 36.302, 36.306, 36.321, 36.331, 36.413, 36.423, 37.104, new RAN4 TR (36.807, 36.808)
- 3221: RP#54 completed / Impacted TSs and TRs: 36.101, 36.104, 36.133, 36.141, 37.141
- 3222: RP#58 completed / Impacted TSs and TRs: 36.508, 36.521-1, 36.521-2, 36.521-3, 36.523-1, 36.523-2, 36.523-3, 37.571-1, 37.571-3, 37.571-5
- 3223: - / Impacted TSs and TRs: LTE
- 3224: RP#51 completed. RP#56 new RAN4 TR 36.807 v200 for Approval / Impacted TSs and TRs: 36.101, 36.104, 36.133, 36.201, 36.211, 36.212, 36.213, 36.300, 36.306, 36.321, 36.331, new RAN4 TR 36.807
- 3225: RP#55 completed / Impacted TSs and TRs: 36.101, 36.104, 36.133, 36.141
- 3226: RP#60 completed. Testing for 36.101, 36.133 / Impacted TSs and TRs: 36.508, 36.521-1, 36.521-2

| ID | WBS | Task | Duration | Start | Finish | Complete | Baseline start | Baseline finish | Baseline duration | Constraint | Resources | Work | Actual work | Acronym | PCG approved | WI rapporteur name | WI rapporteur e-mail | Release | TSG approved | MCC resp | Acronym_3GU_Export | Status Report | PCG stopped | TSG stopped |
| --- | --- | --- | --- | --- | --- | --- | --- | --- | --- | --- | --- | --- | --- | --- | --- | --- | --- | --- | --- | --- | --- | --- | --- | --- |
| 3227 | 821 | **Uplink Multiple Antenna Transmission for LTE** | 3445d? | 2000-01-03 A | 2013-03-01 A | 100% | 2000-01-03 | 2013-03-01 | 3445d? |  | R1; R2; R4; R5 | 125976h | 125976h | LTE_UL_MIMO | PCG-24 | Huawei | Mattias.wennstrom@huawei.com | Rel-10 | RP-46 | Patrick | LTE_UL_MIMO |  |  |  |
| 3228 | 821.1 | Core part: UL multiple antenna transmission for LTE | 391d? | 2000-01-03 A | 2001-06-29 A | 100% | 2000-01-03 | 2001-06-29 | 391d? |  | R1; R2; R4 | 9384h | 9384h | LTE_UL_MIMO-Core | PCG-24 | Huawei | Mattias.wennstrom@huawei.com | Rel-10 | RP-46 | Patrick | LTE_UL_MIMO-Core | RP-110537 |  |  |
| 3229 | 821.2 | Perf. part: UL multiple antenna transmission for LTE | 466d? | 2009-12-04 A | 2011-09-16 A | 100% | 2009-12-04 | 2011-09-16 | 466d? | finish no earlier than 2011-09-16 | R4 | 3728h | 3728h | LTE_UL_MIMO-Perf | PCG-24 | Huawei | Mattias.wennstrom@huawei.com | Rel-10 | RP-46 | Issam | LTE_UL_MIMO-Perf | RP-110992 |  |  |
| 3230 | 821.3 | Test part: UL multiple antenna transmission for LTE | 328d? | 2011-12-02 A | 2013-03-01 A | 100% | 2011-12-02 | 2013-03-01 | 328d? | finish no earlier than 2013-03-01 | R5 | 2624h | 2624h | LTE_UL_MIMO-UEConTest | PCG-28 | Huawei | Zhang Xin (suzanna.zhang@huawei.com) | Rel-10 | RP-54 | Ingbert | LTE_UL_MIMO-UEConTest | RP-130038 |  |  |
| 3231 | 822 | **Relays for LTE** | 394d? | 2009-12-04 A | 2011-06-08 A | 100% | 2009-12-04 | 2011-06-08 | 394d? |  | R1; R2; R4; S2; S3; C4; C6 | 36856h | 36856h | LTE_Relay | PCG-24 | Ericsson | christian.hoymann@ericsson.com | Rel-10 | RP-46 | Patrick | LTE_Relay |  |  |  |
| 3232 | 822.1 | Core part: Relays for LTE | 391d? | 2009-12-04 A | 2011-06-03 A | 100% | 2009-12-04 | 2011-06-03 | 391d? | finish no earlier than 2011-06-03 | R1; R2; R4 | 9384h | 9384h | LTE_Relay-Core | PCG-24 | Ericsson | christian.hoymann@ericsson.com | Rel-10 | RP-46 | Patrick | LTE_Relay-Core | RP-110540 |  |  |
| 3233 | 822.2 | Deleted - Perf. part: Relays for LTE | 391d? | 2009-12-04 A | 2011-06-03 A | 100% | 2009-12-04 | 2011-06-03 | 391d? | finish no earlier than 2011-09-16 | R4 | 3128h | 3128h | LTE_Relay-Perf | PCG-24 | Ericsson | christian.hoymann@ericsson.com | Rel-10 | RP-46 | Issam | LTE_Relay-Perf | RP-110541 | PCG-27 | RP-52 |
| 3234 | 822.3 | Stage 2 for Relays for LTE | 3d? | 2011-06-06 A | 2011-06-08 A | 100% | 2011-06-06 | 2011-06-08 | 3d? | start no earlier than 2011-06-06 | S2 | 24h | 24h | LTE_Relay | PCG-27 | Vodafone | chris.pudney@vodafone.com | Rel-10 | SP-52 | Maurice | LTE_Relay |  |  |  |
| 3235 | 822.4 | **LTE Relay Nodes Security** | 69d? | 2010-12-16 A | 2011-03-22 A | 100% | 2010-12-16 | 2011-03-22 | 69d? |  | S3; C6 | 2232h | 2232h | LTE_Relay-Sec | PCG-26 | Qualcomm | Adrian Escott (aescott@qualcomm.com) | Rel-10 | SP-50 | Mirko | LTE_Relay-Sec |  |  |  |
| 3236 | 822.4.1 | TR on LTE Relay Nodes Security | 69d? | 2010-12-16 A | 2011-03-22 A | 100% | 2010-12-16 | 2011-03-22 | 69d? | finish no earlier than 2011-03-23 | S3 | 552h | 552h | LTE_Relay-Sec | PCG-26 | Qualcomm | Adrian Escott (aescott@qualcomm.com) | Rel-10 | SP-50 | Mirko |  |  |  |  |
| 3237 | 822.4.2 | Security for LTE Relay Nodes (Stage 2) | 69d? | 2010-12-16 A | 2011-03-22 A | 100% | 2010-12-16 | 2011-03-22 | 69d? | finish no earlier than 2011-03-23 | S3 | 552h | 552h | LTE_Relay-Sec | PCG-26 | Qualcomm | Adrian Escott (aescott@qualcomm.com) | Rel-10 | SP-50 | Mirko |  |  |  |  |
| 3238 | 822.4.3 | CT6 aspects of LTE Relay Node Security | 3d? | 2011-03-16 A | 2011-03-18 A | 100% | 2011-03-16 | 2011-03-18 | 3d? | start no earlier than 2011-03-16 | C6 | 24h | 24h | LTE_Relay-Sec | PCG-26 | n/a | n/a | Rel-10 | CP-51 | Xavier |  |  |  |  |
| 3239 | 822.5 | Core Network Impacts for Relay Nodes | 3d? | 2011-03-16 A | 2011-03-18 A | 100% | 2011-03-16 | 2011-03-18 | 3d? | finish no earlier than 2011-03-18 | C4 | 24h | 24h | LTE_Relay-CN | PCG-26 | Vodafone | David.Hutton@vodafone.com | Rel-10 | CP-51 | Kimmo | LTE_Relay-CN |  |  |  |
| 3240 | 823 | **Enhanced Inter-Cell Interference Control (ICIC) for non-Carrier Aggregation (CA) based deployments of heterogeneous networks for LTE** | 1119d? | 2010-03-19 A | 2014-06-13 A | 100% | 2010-03-19 | 2014-06-13 | 1119d? |  | R1; R2; R3; R4; R5 | 64384h | 64384h | eICIC_LTE | PCG-24 | China Mobile | Xiaodong XU (xuxiaodong@chinamobile.com) | Rel-10 | RP-47 | Patrick | eICIC_LTE |  |  |  |
| 3241 | 823.1 | Core part: Enhanced Inter-Cell Interference Control (ICIC) for non-Carrier Aggregation (CA) based deployments of heterogeneous networks for LTE | 316d? | 2010-03-19 A | 2011-06-03 A | 100% | 2010-03-19 | 2011-06-03 | 316d? | finish no earlier than 2011-06-03 | R1; R2; R3; R4 | 10112h | 10112h | eICIC_LTE-Core | PCG-24 | China Mobile | Xiaodong XU (xuxiaodong@chinamobile.com) | Rel-10 | RP-47 | Patrick | eICIC_LTE-Core | RP-110543 |  |  |
| 3242 | 823.2 | Perf. part: Enhanced Inter-Cell Interference Control (ICIC) for non-Carrier Aggregation (CA) based deployments of heterogeneous networks for LTE | 589d? | 2010-03-19 A | 2012-06-15 A | 100% | 2010-03-19 | 2012-06-15 | 589d? | finish no earlier than 2012-06-15 | R4 | 4712h | 4712h | eICIC_LTE-Perf | PCG-24 | China Mobile | Xiaodong XU (xuxiaodong@chinamobile.com) | Rel-10 | RP-47 | Issam | eICIC_LTE-Perf | RP-120461 |  |  |
| 3243 | 823.3 | Test part: Enhanced Inter-Cell Interference Control (ICIC) for non-Carrier Aggregation (CA) based deployments of heterogeneous networks for LTE | 600d? | 2012-03-05 A | 2014-06-13 A | 100% | 2012-03-05 | 2014-06-13 | 600d? | finish no earlier than 2014-06-13 | R5 | 4800h | 4800h | eICIC_LTE-UEConTest | PCG-28 | Qualcomm | Anjali Mishra (ajha@qualcomm.com) | Rel-10 | RP-55 | Ingbert | eICIC_LTE-UEConTest | RP-140766 |  |  |
| 3244 | 824 | **LTE TDD in 2600MHz for US** | 191d? | 2010-03-19 A | 2010-12-10 A | 100% | 2010-03-19 | 2010-12-10 | 191d? |  | R4; R2; R3; R5 | 11344h | 11344h | LTE_TDD_2600_US | PCG-24 | Clearwire | michael.hart@clearwire.com | Rel-10 | RP-47 | Issam | LTE_TDD_2600_US |  |  |  |
| 3245 | 824.1 | Core part: LTE TDD in 2600MHz for US | 129d? | 2010-03-19 A | 2010-09-15 A | 100% | 2010-03-19 | 2010-09-17 | 131d? | finish no earlier than 2010-09-17 | R4; R2; R3 | 3096h | 3096h | LTE_TDD_2600_US-Core | PCG-24 | Clearwire | michael.hart@clearwire.com | Rel-10 | RP-47 | Issam | LTE_TDD_2600_US-Core | RP-100782 |  |  |
| 3246 | 824.2 | Perf. part: LTE TDD in 2600MHz for US | 131d? | 2010-03-19 A | 2010-09-17 A | 100% | 2010-03-19 | 2010-09-17 | 131d? | finish no earlier than 2010-09-17 | R4 | 1048h | 1048h | LTE_TDD_2600_US-Perf | PCG-24 | Clearwire | michael.hart@clearwire.com | Rel-10 | RP-47 | Issam | LTE_TDD_2600_US-Perf | RP-100783 |  |  |
| 3247 | 824.3 | UE conformance test part: LTE TDD in 2600MHz for US | 136d? | 2010-06-04 A | 2010-12-10 A | 100% | 2010-06-04 | 2010-12-10 | 136d? | finish no earlier than 2010-12-10 | R5 | 1088h | 1088h | LTE_TDD_2600_US-UEConTest | PCG-25 | Clearwire | michael.hart@clearwire.com | Rel-10 | RP-48 | Ingbert | LTE_TDD_2600_US-UEConTest | RP-101071 |  |  |
| 3248 | 825 | **Adding 2 GHz band LTE FDD (Band 23) for Ancillary Terrestrial Component (ATC) of Mobile Satellite Service (MSS) in North America** | 454d? | 2010-03-19 A | 2011-12-09 A | 100% | 2010-03-19 | 2011-12-09 | 454d? |  | R2; R4; R5 | 19568h | 19568h | S_Band_LTE_ATC_MSS | PCG-24 | DBSD | Mariam.Sorond@ico.com | Rel-10 | RP-47 | Yong-Jun | S_Band_LTE_ATC_MSS |  |  |  |
| 3249 | 825.1 | Core part: Adding 2 GHz band LTE FDD (Band 23) for ATC of MSS in North America | 316d? | 2010-03-19 A | 2011-06-03 A | 100% | 2010-03-19 | 2011-06-03 | 316d? | finish no earlier than 2011-06-03 | R4; R2 | 5056h | 5056h | S_Band_LTE_ATC_MSS-Core | PCG-24 | DBSD | Mariam.Sorond@ico.com | Rel-10 | RP-47 | Issam | S_Band_LTE_ATC_MSS-Core | RP-110545 |  |  |
| 3250 | 825.2 | Perf. part: Adding 2 GHz band LTE FDD (Band 23) for ATC of MSS in North America | 316d? | 2010-03-19 A | 2011-06-03 A | 100% | 2010-03-19 | 2011-06-03 | 316d? | finish no earlier than 2011-06-03 | R4 | 2528h | 2528h | S_Band_LTE_ATC_MSS-Perf | PCG-24 | DBSD | Mariam.Sorond@ico.com | Rel-10 | RP-47 | Issam | S_Band_LTE_ATC_MSS-Perf | RP-110546 |  |  |
| 3251 | 825.3 | Test part: Adding 2 GHz band LTE FDD (Band 23) for ATC of MSS in North America | 137d? | 2011-06-07 A | 2011-12-09 A | 100% | 2011-06-07 | 2011-12-09 | 137d? | finish no earlier than 2011-12-09 | R5 | 1088h | 1088h | S_Band_LTE_ATC_MSS-UEConTest | PCG-27 | DBSD | Mariam.Sorond@ico.com | Rel-10 | RP-52 | Ingbert | S_Band_LTE_ATC_MSS-UEConTest | RP-111444 |  |  |

Notes:
- 3227: - / Impacted TSs and TRs: LTE
- 3228: RP#52 completed. TR 36.817 v110 for Approval. RP#56 new TR 36.807 v200 for Approval / Impacted TSs and TRs: 36.101, 36.104, 36.133, 36.201, 36.211, 36.212, 36.213, 36.300, 36.306, 36.321, 36.331, new RAN4 (TR 36.807, 36.817)
- 3229: RP#53 completed / Impacted TSs and TRs: 36.101, 36.104, 36.133, 36.141, 36.817
- 3230: RP#59 completed / Impacted TSs and TRs: 36.508, 36.521-1, 36.521-2, 36.521-3, 36.523-1, 36.523-2, 36.523-3
- 3231: RP#52 completed (open RAN4 Core & Perf parts moved to new Rel-11) / Impacted TSs and TRs: LTE
- 3232: RP#52 completed. Updated WID RP-101417=>RP-101911 (contains only Core part completed in Rel-10). Open RAN4 Core & Perf parts moved to new Rel-11 / Impacted TSs and TRs: 36.201, 36.211, 36.212, 36.213, 36.300, 36.321, 36.323, 36.331, New RAN1 TS 36.216
- 3233: RP#52 stopped at 30% (no CRs so far) . Transferred completely to Rel-11 together with remaining core part / Impacted TSs and TRs: 36.133, New TS 36.117 (E-UTRA Relay conformance testing)
- 3234: SP#52 SP-110338 (S2-85/S2-112851) 23.401 Cat F CR#2128 Completion of Relay procedure overview / Impacted TSs and TRs: 23.401
- 3235: -
- 3236: SP#51 completed / Impacted TSs and TRs: 33.816
- 3237: SP#51 completed (impacting Stage 3 in CT and RAN) / Impacted TSs and TRs: 33.401 (CR#0437,0438), CT1 24.301, CT4 (29.272, 29.274), CT6 31.102, RAN2 (36.331, 36.323), RAN3 36.413
- 3238: CP#51 completed / Impacted TSs and TRs: 31.101, 31.102
- 3239: CP#51 completed / Impacted TSs and TRs: 23.003, 23.008, 29.303, 29.230, 29.272
- 3240: RP#56 completed / Impacted TSs and TRs: LTE
- 3241: RP#52 completed / Impacted TSs and TRs: 36.101, 36.133, 36.201, 36.211, 36.212, 36.213, 36.214, 36.300, 36.321, 36.331, 36.413, 36.423
- 3242: RP#56 completed / Impacted TSs and TRs: 36.101, 36.133
- 3243: RP#64 completed / Impacted TSs and TRs: 36.508, 36.521-1, 36.521-2, 36.521-3, 36.523-1, 36.523-2, 36.523-3
- 3244: RP#50 Testing completed. RP#49 Core+Perf completed / Impacted TSs and TRs: LTE
- 3245: RP#49 completed 1st Apr 15: CD:Fri 17/09/10->Wed 15/09/10 / Impacted TSs and TRs: 25.461, 25.466, 36.101, 36.104, 36.113, 36.124, 36.133, 36.141, 36.307, 36.331, 37.104, 37.113, 37.141, new TR 36.812
- 3246: RP#49 completed / Impacted TSs and TRs: 36.101, 36.104, 36.133, 36.141, 36.307, 37.104, 37.141, new TR 36.812
- 3247: RP#50 completed / Impacted TSs and TRs: 36.508, 36.521-1, 36.521-2, 36.521-3, 36.523-1, 36.523-2, 36.523-3
- 3248: RP#52 completed. Updated WID RP-101401=>RP-110775 (changed in Title "LTE" to "LTE FDD (Band 23)" / Impacted TSs and TRs: LTE
- 3249: RP#52 completed / Impacted TSs and TRs: 25.101, 25.104, 25.141, 25.461, 25.466, 36.101, 36.104, 36.113, 36.124, 36.133, 36.307, 37.104, 37.141, new TR 36.811
- 3250: RP#52 completed / Impacted TSs and TRs: 36.101, 36.104, 36.113, 36.124, 36.133, 36.141, 36.307, 36.811
- 3251: RP#54 completed / Impacted TSs and TRs: 36.508, 36.521-1, 36.521-2, 36.521-3, 36.523-1, 36.523-2, 36.523-3

| ID | WBS | Task | Duration | Start | Finish | Complete | Baseline start | Baseline finish | Baseline duration | Constraint | Resources | Work | Actual work | Acronym | PCG approved | WI rapporteur name | WI rapporteur e-mail | Release | TSG approved | MCC resp | Acronym_3GU_Export | Status Report | Special Focus Doc |
| --- | --- | --- | --- | --- | --- | --- | --- | --- | --- | --- | --- | --- | --- | --- | --- | --- | --- | --- | --- | --- | --- | --- | --- |
| 3252 | 826 | **Adding L-Band (Band 24) LTE for Ancillary Terrestrial Component (ATC) of Mobile Satellite Service (MSS) in North America** | 463d? | 2009-12-11 A | 2011-09-16 A | 100% | 2009-12-11 | 2011-09-16 | 463d? |  | R4; R2; R5 | 18864h | 18864h | L_Band_LTE_ATC_MSS | PCG-24 | LightSquared | Eric.Jacks@lightsquared.com, Maqbool.Aliani@lightsquared.com | Rel-10 | RP-47 | Issam | L_Band_LTE_ATC_MSS |  |  |
| 3253 | 826.1 | Core part: Adding L-Band (Band 24) LTE for ATC of MSS in North America | 261d? | 2009-12-11 A | 2010-12-10 A | 100% | 2009-12-11 | 2010-12-10 | 261d? | finish no earlier than 2010-12-10 | R4; R2 | 4176h | 4176h | L_Band_LTE_ATC_MSS-Core | PCG-24 | LightSquared | Eric.Jacks@lightsquared.com, Maqbool.Aliani@lightsquared.com | Rel-10 | RP-47 | Issam | L_Band_LTE_ATC_MSS-Core | RP-101117 |  |
| 3254 | 826.2 | Perf. part: Adding L-Band (Band 24) LTE for ATC of MSS in North America | 316d? | 2010-03-19 A | 2011-06-03 A | 100% | 2010-03-19 | 2011-06-03 | 316d? | finish no earlier than 2011-06-03 | R4 | 2528h | 2528h | L_Band_LTE_ATC_MSS-Perf | PCG-24 | LightSquared | Eric.Jacks@lightsquared.com, Maqbool.Aliani@lightsquared.com | Rel-10 | RP-47 | Issam | L_Band_LTE_ATC_MSS-Perf | RP-110548 |  |
| 3255 | 826.3 | Test part: Adding L-Band (Band 24) LTE for ATC of MSS in North America | 131d? | 2011-03-18 A | 2011-09-16 A | 100% | 2011-03-18 | 2011-09-16 | 131d? | finish no earlier than 2011-09-16 | R5 | 1048h | 1048h | L_Band_LTE_ATC_MSS-UEConTest | PCG-26 | LightSquared | masoud.olfat@lightsquared.com | Rel-10 | RP-51 | Ingbert | L_Band_LTE_ATC_MSS-UEConTest | RP-110980 |  |
| 3256 | 827 | **LTE Self Optimizing Networks (SON) enhancements** | 316d? | 2010-03-19 A | 2011-06-03 A | 100% | 2010-03-19 | 2011-06-03 | 316d? |  | R3; R2; R4 | 15168h | 15168h | SONenh_LTE | PCG-24 | Nokia Siemens Networks | krzysztof.kordybach@nsn.com | Rel-10 | RP-47 | Juha | SONenh_LTE |  | SON |
| 3257 | 827.1 | Core part: LTE Self Optimizing Networks (SON) enhancements | 316d? | 2010-03-19 A | 2011-06-03 A | 100% | 2010-03-19 | 2011-06-03 | 316d? | finish no earlier than 2011-06-03 | R3; R2; R4 | 7584h | 7584h | SONenh_LTE-Core | PCG-24 | Nokia Siemens Networks | krzysztof.kordybach@nsn.com | Rel-10 | RP-47 | Juha | SONenh_LTE-Core | RP-110547 | SON |
| 3258 | 828 | **Further enhancements to MBMS for LTE** | 459d? | 2010-06-04 A | 2012-03-02 A | 100% | 2010-06-04 | 2012-03-02 | 459d? |  | R2; R3; R5 | 14840h | 14840h | MBMS_LTE_enh | PCG-25 | Huawei | Ms Zhao Junhui (zhaojh@huawei.com) | Rel-10 | RP-48 | Yong-Jun | MBMS_LTE_enh |  |  |
| 3259 | 828.1 | Core part: Further enhancements to MBMS for LTE | 206d? | 2010-06-04 A | 2011-03-18 A | 100% | 2010-06-04 | 2011-03-18 | 206d? | finish no earlier than 2011-03-18 | R2; R3 | 3296h | 3296h | MBMS_LTE_enh-Core | PCG-25 | Huawei | Ms Zhao Junhui (zhaojh@huawei.com) | Rel-10 | RP-48 | Yong-Jun | MBMS_LTE_enh-Core | RP-110083 |  |
| 3260 | 828.2 | Test part: Further enhancements to MBMS for LTE | 66d? | 2011-12-02 A | 2012-03-02 A | 100% | 2011-12-02 | 2012-03-02 | 66d? | finish no earlier than 2012-03-02 | R5 | 528h | 528h | MBMS_LTE_enh-UEConTest | PCG-28 | Huawei | Zhang Xin (suzanna.zhang@huawei.com) | Rel-10 | RP-54 | Ingbert | MBMS_LTE_enh-UEConTest | RP-120049 |  |
| 3261 | 829 | **UMTS/LTE 3500 MHz** | 1456d? | 2007-11-30 A | 2013-06-14 A | 100% | 2007-11-30 | 2013-06-14 | 1456d? |  | R4; R2; R3; R5 | 87360h | 87360h | RInImp8-UMTSLTE3500 | PCG-21 | Ericsson | johan.skold@ericsson.com | Rel-10 | RP-38 | Issam | RInImp8-UMTSLTE3500 |  |  |
| 3262 | 829.1 | Core part: UMTS/LTE 3500 MHz | 994d? | 2007-11-30 A | 2011-09-16 A | 100% | 2007-11-30 | 2011-09-16 | 994d? | finish no earlier than 2011-09-16 | R4; R2; R3 | 23856h | 23856h | RInImp8-UMTSLTE3500 | PCG-21 | Ericsson | johan.skold@ericsson.com | Rel-10 | RP-38 | Issam | RInImp8-UMTSLTE3500 | RP-110987 |  |
| 3263 | 829.2 | Conformance Test Aspects – LTE 3500 | 1189d? | 2008-12-05 A | 2013-06-14 A | 100% | 2008-12-05 | 2013-06-14 | 1189d? | finish no earlier than 2013-06-14 | R5 | 9512h | 9512h | LTE-UEConTest_LTE3500 | PCG-22 | Ericsson | fredrik.sundstrom@ericsson.com | Rel-10 | RP-42 | Ingbert | LTE-UEConTest_LTE3500 | RP-130461 |  |
| 3264 | 829.3 | Conformance Test Aspects – UMTS 3500 | 925d? | 2008-12-05 A | 2012-06-15 A | 100% | 2008-12-05 | 2012-06-15 | 925d? | finish no earlier than 2012-06-15 | R5 | 7400h | 7400h | RInImp-UEConTest_UMTS3500 | PCG-22 | Ericsson | fredrik.sundstrom@ericsson.com | Rel-10 | RP-42 | Ingbert | RInImp-UEConTest_UMTS3500 | RP-120450 |  |
| 3265 | 830 | **Minimization of Drive Tests for E-UTRAN and UTRAN** | 854d? | 2009-12-04 A | 2013-03-01 A | 100% | 2009-12-04 | 2013-03-01 | 854d? |  | R2; R4; R3; R5 | 39784h | 39784h | MDT_UMTSLTE | PCG-24 | Nokia Siemens Networks | malgorzata.tomala@nsn.com | Rel-10 | RP-46 | Yong-Jun | MDT_UMTSLTE |  |  |
| 3266 | 830.1 | Core part: Minimization of Drive Tests for E-UTRAN and UTRAN | 391d? | 2009-12-04 A | 2011-06-03 A | 100% | 2009-12-04 | 2011-06-03 | 391d? | finish no earlier than 2011-06-03 | R2; R4; R3 | 9384h | 9384h | MDT_UMTSLTE-Core | PCG-24 | Nokia Siemens Networks | malgorzata.tomala@nsn.com | Rel-10 | RP-46 | Yong-Jun | MDT_UMTSLTE-Core | RP-110528 |  |
| 3267 | 830.2 | Test part: Minimization of Drive Tests for E-UTRAN | 384d? | 2011-09-19 A | 2013-03-01 A | 100% | 2011-09-19 | 2013-03-01 | 384d? | finish no earlier than 2013-03-01 | R5 | 3072h | 3072h | MDT_UMTSLTE-UEConTest | PCG-27 | Ericsson | leif.mattisson@ericsson.com | Rel-10 | RP-53 | Ingbert | MDT_UMTSLTE-UEConTest | RP-130036 |  |
| 3268 | 831 | **HNB and HeNB Mobility Enhancements** | 718d? | 2010-03-19 A | 2012-12-07 A | 100% | 2010-03-19 | 2012-12-07 | 718d? |  | R3; R2; R5 | 23016h | 23016h | HNB_HENB_mob_enh | PCG-24 | Alcatel-Lucent | Martin,Warner@alcatel-lucent.com | Rel-10 | RP-47 | Juha | HNB_HENB_mob_enh |  | HNB |
| 3269 | 831.1 | Core part: HNB and HeNB Mobility Enhancements | 261d? | 2010-03-19 A | 2011-03-18 A | 100% | 2010-03-19 | 2011-03-18 | 261d? | start no earlier than 2010-03-19 | R3; R2 | 4176h | 4176h | HNB_HENB_mob_enh-Core | PCG-24 | Alcatel-Lucent | Martin.Warner@alcatel-lucent.com | Rel-10 | RP-47 | Juha | HNB_HENB_mob_enh-Core | RP-110058 | HNB |
| 3270 | 831.2 | Test part: HeNB Mobility Enhancements | 201d? | 2012-03-05 A | 2012-12-07 A | 100% | 2012-03-05 | 2012-12-07 | 201d? | finish no earlier than 2012-12-07 | R5 | 1608h | 1608h | HNB_HENB_mob_enh-UEConTest_LTE | PCG-28 | Qualcomm | Anjali Mishra (ajha@qualcom.com) | Rel-10 | RP-55 | Ingbert | HNB_HENB_mob_enh-UEConTest_LTE | RP-121533 | HNB |
| 3271 | 832 | **Expanded 1900 MHz Band for UTRA and LTE** | 596d? | 2010-06-04 A | 2012-09-07 A | 100% | 2010-06-04 | 2012-09-07 | 596d? |  | R4; R2; R5 | 25312h | 25312h | E1900 | PCG-25 | Sprint | nick.j.baustert@sprint.com | Rel-10 | RP-48 | Issam | E1900 |  |  |
| 3272 | 832.1 | Core part: Expanded 1900 MHz Band for UTRA and LTE | 261d? | 2010-06-04 A | 2011-06-03 A | 100% | 2010-06-04 | 2011-06-03 | 261d? | finish no earlier than 2011-06-03 | R4; R2 | 4176h | 4176h | E1900-Core | PCG-25 | Sprint | nick.j.baustert@sprint.com | Rel-10 | RP-48 | Issam | E1900-Core | RP-110529 |  |
| 3273 | 832.2 | Perf. part: Expanded 1900 MHz Band for UTRA and LTE | 261d? | 2010-06-04 A | 2011-06-03 A | 100% | 2010-06-04 | 2011-06-03 | 261d? | finish no earlier than 2011-06-03 | R4; R2 | 4176h | 4176h | E1900-Perf | PCG-25 | Sprint | nick.j.baustert@sprint.com | Rel-10 | RP-48 | Issam | E1900-Perf | RP-110530 |  |
| 3274 | 832.3 | Test part: Expanded 1900 MHz Band for UTRA and LTE | 333d? | 2011-06-07 A | 2012-09-07 A | 100% | 2011-06-07 | 2012-09-07 | 333d? | finish no earlier than 2012-09-07 | R5 | 2656h | 2656h | E1900-UEConTest | PCG-27 | Sprint | nick.j.baustert@sprint.com | Rel-10 | RP-52 | Ingbert | E1900-UEConTest | RP-120957 |  |
| 3275 | 833 | **Multi-Standard Radio Base Station RF requirements for non-contiguous spectrum deployments** | 389d? | 2010-06-04 A | 2011-11-25 A | 100% | 2010-06-04 | 2011-11-25 | 389d? |  | R4; G1 | 16160h | 16160h | MSR_NC | PCG-25 | Ericsson | johan.skold@ericsson.com | Rel-10 | RP-48 | Issam | MSR_NC |  |  |
| 3276 | 833.1 | Core part: Multi-Standard Radio BS RF requirements for non-contiguous spectrum deployments | 261d? | 2010-06-04 A | 2011-06-03 A | 100% | 2010-06-04 | 2011-06-03 | 261d? | finish no earlier than 2011-06-03 | R4 | 2088h | 2088h | MSR_NC-Core | PCG-25 | Ericsson | johan.skold@ericsson.com | Rel-10 | RP-48 | Issam | MSR_NC-Core | RP-110531 |  |
| 3277 | 833.2 | Perf. part: Multi-Standard Radio BS RF requirements for non-contiguous spectrum deployments | 336d? | 2010-06-04 A | 2011-09-16 A | 100% | 2010-06-04 | 2011-09-16 | 336d? | finish no earlier than 2011-09-16 | R4 | 2688h | 2688h | MSR_NC-Perf | PCG-25 | Ericsson | johan.skold@ericsson.com | Rel-10 | RP-48 | Issam | MSR_NC-Perf | RP-110988 |  |

Notes:
- 3252: RP#53 completed / Impacted TSs and TRs: LTE
- 3253: RP#51 completed / Impacted TSs and TRs: 25.101, 25.104, 25.141, 25.461, 25.466, 34.124, 36.101, 36.104, 36.113, 36.124, 36.133, 36.307, 37.104, 37.141, new RAN4 TR 36.813
- 3254: RP#52 completed / Impacted TSs and TRs: 34.121-1, 36.101, 36.104, 36.113, 36.124, 36.133, 36.141, 36.307, 36.521-1, 36.813
- 3255: RP#53 completed / Impacted TSs and TRs: 36.508, 36.521-1, 36.521-2, 36.521-3, 36.523-2
- 3256: RP#52 completed / Impacted TSs and TRs: LTE
- 3257: RP#52 completed (Stage 1,2,3) / Impacted TSs and TRs: 36.300, 36.331, 36.413, 36.423
- 3258: RP#51 completed. SA2 decided not to support MBR>GBR in Rel-10 MBMS. For SA2, MBR=GBR in Rel-10 MBMS. Hence RAN removed enabling statistical multiplexing gains for variable bit rate services in Objectives / Impacted TSs and TRs: LTE
- 3259: RP#51 completed / Impacted TSs and TRs: 25.446, 36.300, 36.321, 36.322, 36.323, 36.331, 36.440, 36.441, 36.442, 36.443, 36.444, 36.445
- 3260: RP#55 completed / Impacted TSs and TRs: 36.508, 36.523-1, 36.523-2, 36.523-3
- 3261: - / Impacted TSs and TRs: UTRA, LTE
- 3262: RP#53 completed. TR 37.801v200 for Approval / Impacted TSs and TRs: 25.101, 25.104, 25.113, 25.133, 25.141, 25.307, 25.307, 25.331, 25.461, 25.463, 34.124, 36.101, 36.104, 36.113, 36.141, 36.331, new 37.801
- 3263: RP#60 completed / Impacted TSs and TRs: 36.508, 36.521-1, 36.521-2, 36.521-3
- 3264: RP#56 completed / Impacted TSs and TRs: 34.108, 34.121-1, 34.121-2
- 3265: Triggered by UID_430021 TR 36.805 (Study on Minimization of drive-tests in NGN) / Impacted TSs and TRs: UTRA, LTE
- 3266: RP#52 completed / Impacted TSs and TRs: 25.133, 25.215, 25.304, 25.331, 25.423, 36.133, 36.214, 36.300, 36.304, 36.331, 36.413, 36.423, new 37.320 (Stage 2)
- 3267: RP#59 completed. Testing for LTE only / Impacted TSs and TRs: LTE 34.108, 34.109, 34.123-1, 34.123-2, 34.123-3, 36.508, 36.509, 36.523-1, 36.523-2, 36.523-3
- 3268: - / Impacted TSs and TRs: UTRA, LTE
- 3269: RP#51 completed / Impacted TSs and TRs: 25.413, 25.467, 25.469, 36.300, 36.413, 36.423, new 25.471
- 3270: RP#58 completed / Impacted TSs and TRs: 34.108, 34.123-1, 34.123-2, 34.123-3, 36.508, 36.523-1, 36.523-2, 36.523-3
- 3271: Expand UTRA and E-UTRA band 2 to include frequencies between 1910 1915 MHz and 1990-1995 MHz (US FCC allocation) / Impacted TSs and TRs: UTRA, LTE
- 3272: RP#52 completed / Impacted TSs and TRs: 25.101, 25.104, 25.113, 25.133, 25.141, 25.461, 25.466, 36.101, 36.104, 36.113, 36.124, 36.133, 36.141, 36.307, 36.331, new TR 36.818
- 3273: RP#52 completed / Impacted TSs and TRs: 25.101, 25.104, 25.113, 25.133, 25.141, 25.461, 25.466, 36.101, 36.104, 36.113, 36.124, 36.133, 36.141, 36.307, 36.331, new TR 36.818
- 3274: RP#57 completed / Impacted TSs and TRs: 34.108, 34.121-1, 34.121-2, 34.123-1, 34.123-2, 34.123-3, 36.508, 36.521-1, 36.521-2, 36.521-3, 36.523-1, 36.523-2, 36.523-3
- 3275: - / Impacted TSs and TRs: UTRA, LTE, GERAN
- 3276: RP#52 completed / Impacted TSs and TRs: 25.104, 36.104, 37.104, new TR 37.802
- 3277: RP#53 completed / Impacted TSs and TRs: 25.141, 36.141, 37.141, 37.802

| ID | WBS | Task | Type | Duration | Start | Finish | Complete | Remaining | Baseline start | Baseline finish | Baseline duration | Total slack | Constraint | Resources | Work | Actual work | Acronym | PCG approved | WI rapporteur name | WI rapporteur e-mail | Release | TSG approved | MCC resp | Acronym_3GU_Export | Impacted TSs and TRs | PCG stopped | TSG stopped | Status Report | Special Focus Doc |
| --- | --- | --- | --- | --- | --- | --- | --- | --- | --- | --- | --- | --- | --- | --- | --- | --- | --- | --- | --- | --- | --- | --- | --- | --- | --- | --- | --- | --- | --- |
| 3278 | 833.3 | **GERAN part: Multi-Standard Radio BS RF requirements for non-contiguous spectrum deployments** |  | 324d? | 2010-09-03 A | 2011-11-25 A | 100% |  | 2010-09-03 | 2011-11-25 | 324d? |  |  | G1 | 5160h | 5160h | MSR_NC-GERAN | PCG-25 | Ericsson | mats.y.samuelsson@ericsson.com | Rel-10 | GP-47 | Paolo | MSR_NC-GERAN |  |  |  |  |  |
| 3279 | 833.3.1 | GERAN Core part: Multi-Standard Radio BS RF requirements for non-contiguous spectrum deployments |  | 261d? | 2010-09-03 A | 2011-09-02 A | 100% |  | 2010-09-03 | 2011-09-02 | 261d? |  | finish no earlier than 2011-09-02 | G1 | 2088h | 2088h | MSR_NC-GERAN | PCG-25 | Ericsson | mats.y.samuelsson@ericsson.com | Rel-10 | GP-47 | Paolo |  | 45.005 |  |  |  |  |
| 3280 | 833.3.2 | GERAN BS Test part: Multi-Standard Radio BS RF requirements for non-contiguous spectrum deployments |  | 62d? | 2011-09-02 A | 2011-11-25 A | 100% |  | 2011-09-02 | 2011-11-25 | 62d? |  | finish no earlier than 2011-11-25 | G1 | 496h | 496h | MSR_NC-GERAN | PCG-28 | Ericsson | mats.y.samuelsson@ericsson.com | Rel-10 | GP-52 | Paolo |  | 51.021 |  |  |  |  |
| 3281 | 834 | (Small) Technical Enhancements and Improvements for Rel-10 |  | 470d? | 2009-06-04 A | 2011-03-23 A | 100% |  | 2009-06-04 | 2011-03-23 | 470d? |  | finish no earlier than 2011-03-23 | SP; CP; RP; GP | 15040h | 15040h | TEI10 | PCG-23 |  |  | Rel-10 | SP-44 |  | TEI10 |  |  |  |  |  |
| 3282 | 835 | (IETF) (Small) Technical Enhancements and Improvements for Rel-10 (draft-atarius) |  | 1244d? | 2009-06-04 A | 2014-12-09 | 75% | 312.5d? | 2009-06-04 | 2014-12-05 | 1242d? | 1053d | finish no earlier than 2014-12-09 | C1-IETF | 9952h | 7452h | TEI10_IETF | PCG-27 | Andrew Allen | Andrew Allen | Rel-10 | CP-52 | Frederic | TEI10_IETF | draft-atarius-dispatch-meid-urn |  |  |  |  |
| 3283 | 836 | (IETF) (Small) Technical Enhancements and Improvements for Rel-10 (RFC6275) |  | 562d? | 2009-06-04 A | 2011-07-29 A | 100% |  | 2009-06-04 | 2011-07-29 | 562d? |  | finish no earlier than 2011-07-29 | C1-IETF | 4496h | 4496h | TEI10_IETF1 | PCG-27 |  |  | Rel-10 | CP-53 | Frederic | TEI10_IETF1 | RFC 6275 (was draft-ietf-mext-rfc3775bis) |  |  |  |  |
| 3284 | 837 | Test - (Small) Technical Enhancements and Improvements for Rel-10 |  | 271d? | 2011-12-01 A | 2012-12-07 A | 100% |  | 2011-12-01 | 2012-12-07 | 271d? |  | finish no earlier than 2012-12-07 | R5; G3new | 4336h | 4336h | TEI10_Test | PCG-28 | n/a |  | Rel-10 | RP-54 | Ingbert | TEI10_Test |  |  |  |  |  |
| 3285 | 838 | **Deleted - Registration in Densely-populated area (RED)** |  | 665d? | 2007-03-12 A | 2009-09-24 A | 100% |  | 2007-03-12 | 2009-09-24 | 665d? |  |  | S1 | 9544h | 9544h | RED |  | NTT DoCoMo | tanakai@nttdocomo.co.jp | Rel-10 | SP-35 | Alain | RED |  | PCG-24 | SP-46 |  |  |
| 3286 | 838.1 | Deleted - Stage 1 for RED |  | 4d? | 2007-03-12 A | 2007-03-15 A | 100% |  | 2007-03-12 | 2007-03-15 | 4d? |  | start no earlier than 2007-03-12 | S1 | 32h | 32h | RED |  | NTT DoCoMo | takakurat@s1.nttdocomo.co.jp | Rel-10 | SP-35 | Alain |  | 22.101 CR#0207 | PCG-24 | SP-46 |  |  |
| 3287 | 838.2 | Deleted - Stage 2 for RED |  | 524d? | 2007-09-25 A | 2009-09-24 A | 100% |  | 2007-09-25 | 2009-09-24 | 524d? |  | finish no earlier than 2009-09-24 | S2 | 4192h | 4192h | RED |  | NTT DoCoMo | tanakai@nttdocomo.co.jp | Rel-10 | SP-37 | Maurice |  | draft TR 23.880 withdrawn, 23.002, 23.060, 23.221, 23.236 | PCG-23 | SP-45 |  |  |
| 3288 | 839 | **Deleted - Network Selection for non-3GPP Access** |  | 471d? | 2007-12-07 A | 2009-09-24 A | 100% |  | 2007-12-07 | 2009-09-24 | 471d? |  |  | S1; C6 | 15072h | 15072h | N3GtoNSP | PCG-21 | Telefónica O2 | chris.friel@O2.com | Rel-10 | SP-38 | Alain | N3GtoNSP |  | PCG-23 | SP-45 |  |  |
| 3289 | 839.1 | Deleted - Stage 1 for N3GtoNSP |  | 471d? | 2007-12-07 A | 2009-09-24 A | 100% |  | 2007-12-07 | 2009-09-24 | 471d? |  | finish no earlier than 2009-12-10 | S1 | 3768h | 3768h | N3GtoNSP | PCG-21 | Telefónica O2 | chris.friel@O2.com | Rel-10 | SP-38 | Alain |  | 22.011 | PCG-23 | SP-45 |  |  |
| 3290 | 839.2 | Deleted - CT6 issues for N3GtoNSP |  | 471d? | 2007-12-07 A | 2009-09-24 A | 100% |  | 2007-12-07 | 2009-09-24 | 471d? |  | finish no earlier than 2009-12-04 | C6 | 3768h | 3768h | N3GtoNSP | PCG-21 | Telefónica O2 | chris.friel@O2.com | Rel-10 | CP-38 | Xavier |  | 36.300 | PCG-23 | CP-45 |  |  |
| 3291 | 840 | **Deleted - GTP-based S8 chaining** |  | 337d? | 2008-12-11 A | 2010-03-25 A | 100% |  | 2008-12-11 | 2010-03-25 | 337d? |  |  | S2 | 5392h | 5392h | GTPchaining | PCG-22 | Huawei | Haining Wang (wanghaining@huawei.com) | Rel-10 | SP-42 | Maurice | GTPchaining |  | PCG-24 | SP-47 |  |  |
| 3292 | 840.1 | Deleted - Stage 2 for GTPchaining |  | 337d? | 2008-12-11 A | 2010-03-25 A | 100% |  | 2008-12-11 | 2010-03-25 | 337d? |  | finish no earlier than 2010-03-25 | S2 | 2696h | 2696h | GTPchaining | PCG-22 | Huawei | Haining Wang (wanghaining@huawei.com) | Rel-10 | SP-42 | Maurice |  | 23.402 | PCG-24 | SP-47 |  |  |
| 3293 | 841 | Deleted - UTRAN 2 ms TTI uplink range improvement |  | 272d? | 2009-03-06 A | 2010-03-19 A | 100% |  | 2009-03-06 | 2010-03-19 | 272d? |  | finish no earlier than 2010-03-19 | R1; R2; R3; R4 | 8704h | 8704h | RANimp-2mTTI_ULimp | PCG-22 | Nokia Siemens Networks | Karri Ranta-aho (karri.ranta-aho@nsn.com) | Rel-10 | RP-43 | Patrick | RANimp-2mTTI_ULimp | 25.133, 25.212, 25.214, 25.321, 25.331 | PCG-24 | RP-47 | RP-100040 |  |
| 3294 | 842 | Deleted - Enhanced Home NodeB / eNodeB continuation of Rel-9 |  | 337d? | 2008-12-11 A | 2010-03-25 A | 100% |  | 2008-12-11 | 2010-03-25 | 337d? |  |  | S2 | 2696h | 2696h | eEHNB | PCG-23 | Alcatel-Lucent | Nicolas Drevon | Rel-10 | SP-44 | Maurice | eEHNB |  | PCG-24 | SP-47 |  | HNB |
| 3295 | 843 | **Deleted - Fixed Wireless Customer-Premises Equipment (CPE) RF Requirements** |  | 391d? | 2009-12-04 A | 2011-06-03 A | 100% |  | 2009-12-04 | 2011-06-03 | 391d? |  |  | R4; R5 | 12512h | 12512h | FW_CPE_RF | PCG-24 | Verizon Wireless | zheng.zhao@verizonwireless.com | Rel-10 | RP-46 | Issam | FW_CPE_RF | LTE | PCG-27 | RP-52 |  |  |
| 3296 | 843.1 | Deleted - Core part: Fixed Wireless Customer-Premises Equipment (CPE) RF Requirements |  | 391d? | 2009-12-04 A | 2011-06-03 A | 100% |  | 2009-12-04 | 2011-06-03 | 391d? |  | finish no earlier than 2011-06-03 | R4 | 3128h | 3128h | FW_CPE_RF-Core | PCG-24 | Verizon Wireless | zheng.zhao@verizonwireless.com | Rel-10 | RP-46 | Issam | FW_CPE_RF-Core | 36.101 | PCG-27 | RP-52 | RP-110539 |  |
| 3297 | 843.2 | Deleted - Test part: Fixed Wireless Customer-Premises Equipment (CPE) RF Requirements |  | 391d? | 2009-12-04 A | 2011-06-03 A | 100% |  | 2009-12-04 | 2011-06-03 | 391d? |  | finish no earlier than 2011-06-03 | R5 | 3128h | 3128h | FW_CPE_RF-UEConTest | PCG-24 | Verizon Wireless | zheng.zhao@verizonwireless.com | Rel-10 | RP-46 | Ingbert | FW_CPE_RF-UEConTest | 36.521-1 | PCG-27 | RP-52 | RP-110504 |  |
| 3298 | 844 | **Deleted - Latency reductions for LTE** |  | 266d? | 2009-12-04 A | 2010-12-10 A | 100% |  | 2009-12-04 | 2010-12-10 | 266d? |  |  | R2; R1 | 8512h | 8512h | LTE_LATRED | PCG-24 | Ericsson | henrik.enbuske@ericsson.com | Rel-10 | RP-46 | Yong-Jun | LTE_LATRED | LTE | PCG-26 | RP-50 |  |  |
| 3299 | 844.1 | Deleted - Core part: Latency reductions for LTE |  | 266d? | 2009-12-04 A | 2010-12-10 A | 100% |  | 2009-12-04 | 2010-12-10 | 266d? |  | finish no earlier than 2010-12-10 | R2; R1 | 4256h | 4256h | LTE_LATRED-Core | PCG-24 | Ericsson | henrik.enbuske@ericsson.com | Rel-10 | RP-46 | Yong-Jun | LTE_LATRED-Core | 36.213, 36.300, 36.306, 36.321, 36.331 | PCG-26 | RP-50 | RP-101112 |  |
| 3300 | 845 | **Deleted - Enhanced Interference Management for Home NodeBs** |  | 131d? | 2010-03-19 A | 2010-09-17 A | 100% |  | 2010-03-19 | 2010-09-17 | 131d? |  |  | R3 | 2096h | 2096h | HNB_IM | PCG-24 | Qualcomm | Andrei Radulescu (aradules@qualcomm.com) | Rel-10 | RP-47 | Juha | HNB_IM | UTRA | PCG-25 | RP-49 | RP-100754 | HNB |
| 3301 | 845.1 | Deleted - Core part: Enhanced Interference Management for Home NodeBs |  | 131d? | 2010-03-19 A | 2010-09-17 A | 100% |  | 2010-03-19 | 2010-09-17 | 131d? |  | finish no earlier than 2010-09-17 | R3 | 1048h | 1048h | HNB_IM-Core | PCG-24 | Qualcomm | Andrei Radulescu (aradules@qualcomm.com) | Rel-10 | RP-47 | Juha | HNB_IM-Core | 25.413, 25.467, 25.469 | PCG-25 | RP-49 | RP-100754 | HNB |
| 3302 | 846 | Release 10 Studies | milestone | 0d? | 2009-03-12 A | 2009-03-12 A | 100% |  | 2009-03-12 | 2011-03-23 | 531d? |  | finish no earlier than 2011-03-23 | CP; GP; RP; SP |  |  |  |  |  |  | Rel-10 |  |  |  |  |  |  |  |  |

Notes:
- 3278: -
- 3279: GP#51 completed. GP#47 approved WID
- 3280: GP#52 completed
- 3281: -
- 3282: Not completed internet-draft, waiting for draft-montemurro to complete
- 3283: SP#53/IETF#81: RFC 6275 completed
- 3284: -
- 3285: SP#35 Stage 1 completed. SP#45 Stage 2 work stopped. SP#46 work stopped/abandoned
- 3286: SP#35 completed. SP#46 work stopped/abandoned
- 3287: SP#45 Stage 2 work stopped
- 3288: SP#45 work stopped/abandoned
- 3289: SP#45 work stopped/abandoned
- 3290: SP#45 work stopped/abandoned
- 3291: SP#47 work stopped (depending on ongoing related CT4 work). Stage 1 in UID_320022 Rel-8 Requirements for evolution of the 3GPP system architecture (AIPN-SAE): 22.278, 22.011, 22.246
- 3292: SP#47 work stopped
- 3293: RP#47 work stopped/abandoned (no CR approved). Cell sets the TTI (Transmission Time Interval) to 2 ms
- 3294: SP#47 deleted (SA2 work moved under SA1 UID_450053). SP#44 Umbrella Feature created to host WIs moved out of Rel-9 (SA2 UID_420034 on IMS aspects of Architecture for Home NodeB)
- 3295: RP#52 work stopped (lack of contributions). Add new power classES in CP-150E-UTRAN UL to allow CPE type applications to be operated at higher max output power
- 3296: RP#52 work stopped at 55% (lack of contributions)
- 3297: RP#52 work stopped (lack of contributions)
- 3298: RP#50 work stopped (RP-101266)
- 3299: RP#50 work stopped (RP-101266)
- 3300: RP#49 stopped (no further standardization needed). Ensure that Enhanced Interference Management methods identified in Rel-9 for HNBs do not fail in deployments with a large penetration of CSG-aware UEs
- 3301: RP#49 stopped (no further standardization needed)
- 3302: -

| ID | WBS | Task | Type | Duration | Start | Finish | Complete | Baseline start | Baseline finish | Baseline duration | Constraint | Resources | Work | Actual work | Acronym | Impacted TSs and TRs | WI rapporteur name | Release | TSG approved | MCC resp | Acronym_3GU_Export | PCG approved | Status Report | PCG stopped | TSG stopped |
| --- | --- | --- | --- | --- | --- | --- | --- | --- | --- | --- | --- | --- | --- | --- | --- | --- | --- | --- | --- | --- | --- | --- | --- | --- | --- |
| 3303 | 847 | **Study on enhanced voice service requirements for the Evolved Packet System (EPS)** |  | 670d? | 2007-09-03 A | 2010-03-25 A | 100% | 2007-09-03 | 2010-03-25 | 670d? |  | S1; S4 | 18744h | 18744h | FS_EV_EPS | 22.813 | France Telecom | Rel-10 | SP-37 | Alain | FS_EV_EPS |  |  |  |  |
| 3304 | 847.1 | Use cases definition and service and system requirements |  | 334d? | 2007-09-03 A | 2008-12-11 A | 100% | 2007-09-03 | 2008-12-11 | 334d? | finish no earlier than 2008-12-11 | S1 | 2672h | 2672h | FS_EV_EPS-S1 | 22.813 | France Telecom | Rel-10 | SP-37 | Alain | FS_EV_EPS-S1 |  |  |  |  |
| 3305 | 847.2 | Codec specific part of FS_EV_EPS |  | 669d? | 2007-09-03 A | 2010-03-25 A | 100% | 2007-09-03 | 2010-03-25 | 669d? | finish no earlier than 2010-03-25 | S4 | 5352h | 5352h | FS_EV_EPS-S4 | 22.813 | Ericsson | Rel-10 | SP-37 | Paolo | FS_EV_EPS-S4 |  |  |  |  |
| 3306 | 848 | Study on advanced requirements for IP interconnect |  | 528d? | 2007-12-04 A | 2009-12-10 A | 100% | 2007-12-04 | 2009-12-10 | 528d? | finish no earlier than 2009-12-10 | S1 | 4224h | 4224h | FS_IPXS | 22.893 | Telefónica O2 | Rel-10 | SP-38 | Alain | FS_IPXS | PCG-21 |  |  |  |
| 3307 | 849 | Study on Personal Broadcast Service |  | 397d? | 2008-09-18 A | 2010-03-25 A | 100% | 2008-09-18 | 2010-03-25 | 397d? | finish no earlier than 2010-03-25 | S1 | 3168h | 3168h | FS_PBS | 22.947 | ETRI | Rel-10 | SP-41 | Alain | FS_PBS | PCG-21 |  |  |  |
| 3308 | 850 | Study on LCS support in SAE for non-3GPP accesses |  | 397d? | 2008-09-18 A | 2010-03-25 A | 100% | 2008-09-18 | 2010-03-25 | 397d? | finish no earlier than 2010-03-25 | S1 | 3168h | 3168h | FS_LCS_n3GPP | 22.814 | SK Telecom | Rel-10 | SP-41 | Alain | FS_LCS_n3GPP | PCG-21 |  |  |  |
| 3309 | 851 | Study on Haptic Services |  | 272d? | 2009-03-12 A | 2010-03-25 A | 100% | 2009-03-12 | 2010-03-25 | 272d? | finish no earlier than 2010-03-25 | S1 | 2168h | 2168h | FS_Haptics | 22.987 | SK Telecom | Rel-10 | SP-43 | Alain | FS_Haptics | PCG-22 |  |  |  |
| 3310 | 852 | Study on System enhancements for the use of IMS services in Local BreakOut and Optimal Routing of Media |  | 575d? | 2007-10-01 A | 2009-12-10 A | 100% | 2007-10-01 | 2009-12-10 | 575d? | finish no earlier than 2009-12-10 | S2 | 4600h | 4600h | FS_IMS_LBO_ORM | 23.894 | Telecom Italia, BT | Rel-10 | SP-37 | Maurice | FS_IMS_LBO_ORM |  |  |  |  |
| 3311 | 853 | Study on Intra Domain Connection of RAN Nodes to Multiple CN Nodes |  | 533d? | 2008-03-12 A | 2010-03-25 A | 100% | 2008-03-12 | 2010-03-25 | 533d? | finish no earlier than 2010-03-25 | S2 | 4264h | 4264h | FS_IDC | 23.924 (was 23.823) | China Mobile | Rel-10 | SP-39 | Maurice | FS_IDC | PCG-21 |  |  |  |
| 3312 | 854 | Study on Single Radio Voice Call Continuity enhancements |  | 341d? | 2009-06-04 A | 2010-09-23 A | 100% | 2009-06-04 | 2010-09-23 | 341d? | finish no earlier than 2010-09-23 | S2 | 2728h | 2728h | FS_eSRVCC | 23.856 | China Mobile | Rel-10 | SP-44 | Maurice | FS_eSRVCC | PCG-23 |  |  |  |
| 3313 | 855 | Study on Single Radio Video Call Continuity for 3G-CS |  | 131d? | 2010-03-25 A | 2010-09-23 A | 100% | 2010-03-25 | 2010-09-23 | 131d? | finish no earlier than 2010-09-23 | S2 | 1048h | 1048h | FS_vSRVCC | 23.886 | Samsung | Rel-10 | SP-47 | Maurice | FS_vSRVCC | PCG-24 |  |  |  |
| 3314 | 856 | Study on S2b Mobility based on GTP |  | 56d? | 2010-03-25 A | 2010-06-10 A | 100% | 2010-03-25 | 2010-06-10 | 56d? | finish no earlier than 2010-06-07 | S2 | 448h | 448h | FS_SMOG | 23.834 | Alcatel-Lucent | Rel-10 | SP-47 | Maurice | FS_SMOG | PCG-24 |  |  |  |
| 3315 | 857 | Study on Surround Sound codec extension for PSS and MBMS |  | 530d? | 2009-03-12 A | 2011-03-23 A | 100% | 2009-03-12 | 2011-03-23 | 530d? | finish no earlier than 2011-03-23 | S4 | 4240h | 4240h | FS_SS_PSS_MBMS | 26.950 | Fraunhofer Gesellschaft | Rel-10 | SP-43 | Paolo | FS_SS_PSS_MBMS | PCG-22 |  |  |  |
| 3316 | 858 | Study on Improved Video Coding Support |  | 205d? | 2010-06-10 A | 2011-03-23 A | 100% | 2010-06-10 | 2011-03-23 | 205d? | finish no earlier than 2011-03-23 | S4 | 1640h | 1640h | FS_IVCS | 26.904 | Nokia, ETRI | Rel-10 | SP-48 | Paolo | FS_IVCS | PCG-25 |  |  |  |
| 3317 | 859 | Study on Rc Reference Point Functionalities and Message Flows |  | 397d? | 2008-09-18 A | 2010-03-25 A | 100% | 2008-09-18 | 2010-03-25 | 397d? | finish no earlier than 2010-03-23 | S5 | 3170.08h | 3170.08h | FS_OAM_Rc | 32.825 | Huawei | Rel-10 | SP-41 | Mirko | FS_OAM_Rc | PCG-21 |  |  |  |
| 3318 | 860 | Study on Telecommunication Management; Energy Savings Management |  | 271d? | 2009-03-12 A | 2010-03-25 A | 100% | 2009-03-12 | 2010-03-25 | 271d? | finish no earlier than 2010-03-25 | S5 | 2168h | 2168h | FS_OAM_ESM | 32.826 | Orange, Vodafone | Rel-10 | SP-43 | Mirko | FS_OAM_ESM | PCG-22 |  |  |  |
| 3319 | 861 | Study on Integration of Device Management Information with Itf-N |  | 211d? | 2009-06-04 A | 2010-03-25 A | 100% | 2009-06-04 | 2010-03-25 | 211d? | finish no earlier than 2010-03-25 | S5 | 1688h | 1688h | FS_IDMI_Itf-N | 32.827 | Motorola | Rel-10 | SP-44 | Mirko | FS_IDMI_Itf-N | PCG-23 |  |  |  |
| 3320 | 862 | Study on Alignment of 3GPP Generic NRM IRP and TMF Shared Information Data (SID) model |  | 335d? | 2009-12-10 A | 2011-03-23 A | 100% | 2009-12-10 | 2011-03-23 | 335d? | finish no earlier than 2011-03-23 | S5 | 2680h | 2680h | FS_3GNRM_TMFSID | 32.828 | Nokia Siemens Networks | Rel-10 | SP-46 | Mirko | FS_3GNRM_TMFSID | PCG-24 |  |  |  |
| 3321 | 863 | Study on Harmonization of 3GPP Alarm IRP and TMF Interface Program (TIP) Fault Management |  | 335d? | 2009-12-10 A | 2011-03-23 A | 100% | 2009-12-10 | 2011-03-23 | 335d? | finish no earlier than 2011-03-23 | S5 | 2680h | 2680h | FS_3G_TMF_FM | 32.829 | Nokia Siemens Networks, Alcatel-Lucent | Rel-10 | SP-46 | Mirko | FS_3G_TMF_FM | PCG-24 |  |  |  |
| 3322 | 864 | Study on Alarm Correlation and Alarm Root Cause Analysis |  | 205d? | 2010-06-10 A | 2011-03-23 A | 100% | 2010-06-10 | 2011-03-23 | 205d? | finish no earlier than 2011-03-23 | S5 | 1640h | 1640h | FS_AC_ARCA | 32.832 | Ericsson | Rel-10 | SP-48 | Mirko | FS_AC_ARCA | PCG-25 |  |  |  |
| 3323 | 865 | Study on Alignment of 3GPP PM IRP and TMF Interface Program (TIP) PM |  | 205d? | 2010-06-10 A | 2011-03-23 A | 100% | 2010-06-10 | 2011-03-23 | 205d? | finish no earlier than 2011-03-23 | S5 | 1640h | 1640h | FS_3G_TMF_PM | 32.831 | Alcatel-Lucent | Rel-10 | SP-48 | Mirko | FS_3G_TMF_PM | PCG-25 |  |  |  |
| 3324 | 866 | Study on Policy and Charging Rules Function (PCRF) failure and restoration |  | 261d? | 2009-08-18 A | 2010-09-17 A | 100% | 2009-08-18 | 2010-09-17 | 261d? | finish no earlier than 2010-09-17 | C3 | 2088h | 2088h | FS_PCRF-FR | 29.816 | NEC | Rel-10 | CP-45 | Adrian | FS_PCRF-FR | PCG-23 |  |  |  |
| 3325 | 867 | Study on User Data Convergence (UDC) evolution |  | 206d? | 2010-06-04 A | 2011-03-18 A | 100% | 2010-06-04 | 2011-03-18 | 206d? | finish no earlier than 2011-03-18 | C4 | 1648h | 1648h | FS_UDCe | 23.845 | Alcatel-Lucent | Rel-10 | CP-48 | Kimmo | FS_UDCe | PCG-25 |  |  |  |
| 3326 | 868 | Study on UICC access to IMS |  | 206d? | 2010-06-04 A | 2011-03-18 A | 100% | 2010-06-04 | 2011-03-18 | 206d? | finish no earlier than 2011-03-18 | C6 | 1648h | 1648h | FS_IMS-UICC | 31.828 | Gemalto | Rel-10 | CP-48 | Xavier | FS_IMS-UICC | PCG-25 |  |  |  |
| 3327 | 869 | Study on Uplink Tx Diversity for HSPA |  | 208.4d? | 2009-08-18 A | 2010-06-04 A | 100% | 2009-08-18 | 2010-06-04 | 208.4d? | finish no earlier than 2010-06-04 | R4 | 1667.2h | 1667.2h | FS_UL-TxDiv-HSPA | UTRA 25.863 | Qualcomm | Rel-10 | RP-45 | Issam | FS_UL-TxDiv-HSPA | PCG-23 | RP-100499 |  |  |
| 3328 | 870 | Study on Solutions for Energy Saving within UTRA Node B |  | 206d? | 2009-12-04 A | 2010-09-17 A | 100% | 2009-12-04 | 2010-09-17 | 206d? | finish no earlier than 2010-09-17 | R1; R3 | 3296h | 3296h | FS_Energy_UMTS | UTRA 25.927 | Vodafone | Rel-10 | RP-46 | Patrick | FS_Energy_UMTS | PCG-24 | RP-100796 |  |  |
| 3329 | 871 | Study on Potential solutions for energy saving for E-UTRAN |  | 348.75d? | 2010-02-02 A | 2011-06-03 A | 100% | 2010-02-02 | 2011-06-03 | 348.75d? | finish no earlier than 2011-06-03 | R3; R2 | 5580h | 5580h | FS_Energy_LTE | LTE 36.927 | China Mobile | Rel-10 | RP-47 | Juha | FS_Energy_LTE | PCG-24 | RP-110597 |  |  |
| 3330 | 872 | Study on Improvements of distributed antenna for 1.28Mcps TDD |  | 200.55d? | 2010-03-05 A | 2010-12-10 A | 100% | 2010-03-05 | 2010-12-10 | 200.55d? | finish no earlier than 2010-12-10 | R1; R2; R3 | 4813.2h | 4813.2h | FS_distr_ant_LCR_TDD | UTRA 25.865 | ZTE | Rel-10 | RP-47 | Patrick | FS_distr_ant_LCR_TDD | PCG-24 | RP-101287 |  |  |
| 3331 | 873 | Deleted - Study on Unauthenticated PS Emergency Calls |  | 471d? | 2008-06-05 A | 2010-03-25 A | 100% | 2008-06-05 | 2010-03-25 | 471d? | finish no earlier than 2010-03-25 | S1 | 3768h | 3768h | FS_UAPSEC | 22.984 | Nokia Siemens Networks | Rel-10 | SP-40 | Alain | FS_UAPSEC | PCG-21 |  | PCG-24 | SP-47 |
| 3332 | 874 | Deleted - Study on enhancements to IMS border functions for IMS Interconnection of services |  | 586d? | 2008-09-18 A | 2010-12-15 A | 100% | 2008-09-18 | 2010-12-15 | 586d? | finish no earlier than 2010-12-15 | S2 | 4688h | 4688h | FS_eIMS_IBCF | 23.848 | Starent Networks | Rel-10 | SP-41 | Maurice | FS_eIMS_IBCF | PCG-21 |  | PCG-26 | SP-50 |
| 3333 | 875 | Deleted - Study on EPC Charging enhancement |  | 211d? | 2009-06-04 A | 2010-03-25 A | 100% | 2009-06-04 | 2010-03-25 | 211d? | finish no earlier than 2010-03-25 | S5 | 1688h | 1688h | FS_EPCcharg |  | Nokia Siemens Networks | Rel-10 | SP-44 | Mirko | FS_EPCcharg | PCG-23 |  | PCG-24 | SP-47 |
| 3334 | 876 | Deleted - Study on Interworking Proxy between GTP based and PMIP based interfaces |  | 186d? | 2009-09-18 A | 2010-06-04 A | 100% | 2009-09-18 | 2010-06-04 | 186d? | finish no earlier than 2010-06-04 | C4 | 1488h | 1488h | FS_GTP-MIP-IW | 29.875 | NTT DoCoMo | Rel-10 | CP-45 | Kimmo | FS_GTP-MIP-IW | PCG-23 |  | PCG-25 | CP-48 |
| 3335 | 877 | Release 9 Features | milestone | 0d? | 2000-01-01 A | 2000-01-01 A | 100% | 2000-01-01 | 2000-01-01 | 0d? |  | CP; GP; RP; SP |  |  |  |  |  | Rel-9 |  |  |  |  |  |  |  |

Notes:
- 3303: SP#47 completed. TR 22.813-100 for Approval. Spin-off Feature UID_470030 Codec for Enhanced Voice Services / WI rapporteur e-mail: philippe.lottin@orange.com
- 3304: SP#47 completed. TR 22.813-100 for Approval / WI rapporteur e-mail: philippe.lottin@orange.com
- 3305: SP#47 completed. TR 22.813-100 for Approval / WI rapporteur e-mail: stefan.bruhn@ericson.com
- 3306: SP#46 completed. Linked to Rel-8 Feature UID_380060 IP Interconnection of Services (IPinterc). Spin-off Feature Rel-11 UID_470051 Advanced IP Interconnection of Services / WI rapporteur e-mail: chris.friel@O2.com
- 3307: SP#47 completed / WI rapporteur e-mail: Jaihyung Cho
- 3308: SP#47 completed / WI rapporteur e-mail: jinhan.song@sktelecom.com
- 3309: SP#47 completed. Covers Mobile/Fixed/Cordless/etc terminals. Haptic (human-machine tactile communication) extend service offering & richness of user experience beyond current visual & auditory senses / WI rapporteur e-mail: jinhan.song@sktelecom.com
- 3310: SP#46 completed. Spin-off Feature UID_460028 Optimal Media Routeing (OMR). Linked to Study on Multimedia Session Continuity UID_350051, Study on Centralized IMS Service Control UID_330012, IMS inter-operator service interconnection interface UID_360011 / WI rapporteur e-mail: mario.madella@telecomitalia.it, victor.kueh@bt.com
- 3311: SP#47 completed. Concluded no further normative work expected. Linked to 23.236 / WI rapporteur e-mail: LIU HONG (liuhongyfw@chinamobile.com)
- 3312: SP#49 completed (Conclusion: select the SIP anchoring based solution for normative work CR (TEI10) introducing and completing stage-2). Analyzed performance of Rel-8 SRVCC solution from E-UTRAN/HSPA to UTRAN/GERAN / WI rapporteur e-mail: Hou zhiqiang (houzhiqiang@chinamobile.com), Jiang Yi (jiangyi@chinamobile.com)
- 3313: SP#49 completed. TR 23.886v100 for Approval. Related to Rel-8 UID_350030 Single Radio Voice Call Continuity for 3GPP (SAES-SRVCC). Study how to provide Video Call seamless service continuity for 3G/LTE terminal user / WI rapporteur e-mail: Haris Zisimopoulos (haris.z@samsung.com)
- 3314: SP#48 completed. Triggered by Rel-8 UID_350027 SAE for support for non-3GPP accesses. Nature of relationship: S2b one of the interfaces defined for non-3GPP accesses support in EPS. Stage 1 in Rel-8 UID_320022 (AIPN-SAE) 22.278,22.101 / WI rapporteur e-mail: bruno.landais@alcatel-lucent.com
- 3315: SP#51 completed. Extend Rel-8 UID_34043 (Extending PSS and MBMS User Services for optimized Mobile TV) / WI rapporteur e-mail: jan.plogsties@iis.franhofer.de
- 3316: SP#51 completed. Extends Rel-9 Improved Video Support for PSS and MBMS (UID_430039) / WI rapporteur e-mail: imed.bouazizi@nokia.com, jaihyung@etri.re.kr
- 3317: SP#47 completed / WI rapporteur e-mail: shan.mingjun@huawei.com
- 3318: SP#47 completed. Study result might impact Feature UID_420011 Self Organising Networks (SON) / WI rapporteur e-mail: Jean-Michel Cornilly (Orange)
- 3319: SP#47 completed / WI rapporteur e-mail: Yizhi Yao (yzyao@motorola.com)
- 3320: SP#51 completed / WI rapporteur e-mail: olaf.pollakowski@nsn.com
- 3321: SP#51 completed / WI rapporteur e-mail: olaf.pollakowski@nsn.com, Padma.Sudarsan@alcatel-lucent.com
- 3322: SP#51 completed / WI rapporteur e-mail: edwin.tse@ericsson.com
- 3323: SP#51 completed / WI rapporteur e-mail: Padma.Sudarsan@alcatel-lucent.com
- 3324: CP#49 completed / WI rapporteur e-mail: gottfried.punz@nw.neclab.eu
- 3325: CP#51 completed. Study UDC evolution from FeaturES in CP-150Rel-9 UID_400034 and Rel-10 UID_480011 UDC Data Model / WI rapporteur e-mail: jean-jacques.trottin@alcatel-lucent.com
- 3326: CP#51 completed / WI rapporteur e-mail: Denis.Lheriteau@gemalto.com
- 3327: RP#48 completed / WI rapporteur e-mail: Heechoon Lee (heechoon@qualcomm.com)
- 3328: RP#49 completed. Based on ETSI EE TS 102 706. / WI rapporteur e-mail: Prakash.bhat@vodafone.com
- 3329: RP#52 completed / WI rapporteur e-mail: Yang Ning (yangning@chinamobile.com)
- 3330: RP#50 completed. TR 25.865 v101 for Approval / WI rapporteur e-mail: huang.he4@zte.com.cn
- 3331: SP#47 work stopped/abandoned / WI rapporteur e-mail: Juergen.Merkel@nsn.com
- 3332: SP#50 work stopped. Additional work may be addressed as part of the Rel-11 Feature UID_470051 Advanced IP Interconnection of Services (IPXS) / WI rapporteur e-mail: Rajat Ghai (rghai@starentnetworks.com)
- 3333: SP#47 work stopped. Issue covered by Rel-10 UID_460039 Charging for LIPA_SIPTO and UID_4700xy Charging for IFOM / WI rapporteur e-mail: Gerald.Goermer@nsn.com
- 3334: CP#48 work stopped/abandoned / WI rapporteur e-mail: takaaki.matsuura.sp@s1.nttdocomo.com
- 3335: -

| ID | WBS | Task | Duration | Start | Finish | Complete | Baseline start | Baseline finish | Baseline duration | Constraint | Resources | Work | Actual work | Acronym | PCG approved | WI rapporteur name | WI rapporteur e-mail | Release | TSG approved | MCC resp | Special Focus Doc | Acronym_3GU_Export | Status Report |
| --- | --- | --- | --- | --- | --- | --- | --- | --- | --- | --- | --- | --- | --- | --- | --- | --- | --- | --- | --- | --- | --- | --- | --- |
| 3336 | 878 | **Enhanced Home NodeB / eNodeB** | 921d? | 2008-06-05 A | 2011-12-09 A | 100% | 2008-06-05 | 2011-12-09 | 921d? |  | S1; S2; S3; S5; C1; C6; R2; R3; R4; R5; GP | 113136h | 113136h | EHNB | PCG-21 | T-Mobile | michael.kurz@t-mobile.at | Rel-9 | SP-40 | Alain | HNB | EHNB |  |
| 3337 | 878.1 | Stage 1 for EHNB | 261d? | 2008-06-05 A | 2009-06-04 A | 100% | 2008-06-05 | 2009-06-04 | 261d? | finish no earlier than 2009-06-04 | S1 | 2088h | 2088h | EHNB | PCG-21 | T-Mobile | michael.kurz@t-mobile.at | Rel-9 | SP-40 | Alain | HNB |  |  |
| 3338 | 878.2 | Architecture aspects of EHNB | 266d? | 2008-09-18 A | 2009-09-24 A | 100% | 2008-09-18 | 2009-09-24 | 266d? | finish no earlier than 2009-09-22 | S2 | 2128h | 2128h | EHNB | PCG-21 | T-Mobile | sebastian.speicher@telekom.de | Rel-9 | SP-41 | Maurice | HNB |  |  |
| 3339 | 878.3 | Security aspects of Enhanced Home NodeB / eNodeB | 262d? | 2008-12-11 A | 2009-12-10 A | 100% | 2008-12-11 | 2009-12-10 | 262d? | finish no earlier than 2009-12-10 | S3 | 2096h | 2096h | EHNB-Sec | PCG-22 | Huawei | Marcus Wong (mwong@huawei.com) | Rel-9 | SP-42 | Mirko | HNB | EHNB-Sec |  |
| 3340 | 878.4 | CT1 aspects - Support of Home NB and Home eNB enhancements | 321d? | 2009-09-18 A | 2010-12-10 A | 100% | 2009-09-18 | 2010-12-10 | 321d? | finish no earlier than 2010-12-10 | C1 | 2568h | 2568h | EHNB-CT1 | PCG-23 | Qualcomm | Ramachandran Subramanian (rsubrama@qualcomm.com) | Rel-9 | CP-45 | Frederic | HNB | EHNB-CT1 |  |
| 3341 | 878.5 | CT6 aspects - Support of Home NB and Home eNB enhancements | 131d? | 2009-09-18 A | 2010-03-19 A | 100% | 2009-09-18 | 2010-03-19 | 131d? | finish no earlier than 2010-03-19 | C6 | 1048h | 1048h | EHNB-CT6 | PCG-23 | Qualcomm | Ramachandran Subramanian (rsubrama@qualcomm.com) | Rel-9 | CP-45 | Xavier | HNB | EHNB-CT6 |  |
| 3342 | 878.6 | 3G HNB Gateway and LTE HeNB Gateway OAM&P | 336d? | 2008-12-11 A | 2010-03-25 A | 100% | 2008-12-11 | 2010-03-25 | 336d? | finish no earlier than 2010-03-25 | S5 | 2688h | 2688h | HNB-OAM_GW | PCG-22 | China Mobile | GangChen (chengang@chinamobile.com) | Rel-9 | SP-42 | Mirko | HNB | HNB-OAM_GW |  |
| 3343 | 878.7 | 3G HNB and LTE HeNB OAM&P Type 1 Interface | 272d? | 2009-03-12 A | 2010-03-25 A | 100% | 2009-03-12 | 2010-03-25 | 272d? | finish no earlier than 2010-03-25 | S5 | 2168h | 2168h | HNB_eHNB-OAM_Type1 | PCG-22 | Huawei | Zou Lan (zlan@huawei.com) | Rel-9 | SP-43 | Mirko | HNB | HNB_eHNB-OAM_Type1 |  |
| 3344 | 878.8 | 3G HNB and LTE HeNB OAM&P Type 2 Interface | 225d? | 2009-05-15 A | 2010-03-25 A | 100% | 2009-05-15 | 2010-03-25 | 225d? | finish no earlier than 2010-03-25 | S5 | 1800h | 1800h | HNB_eHNB-OAM_Type2 | PCG-23 | Ericsson | edwin.tse@ericsson.com | Rel-9 | SP-44 | Mirko | HNB | HNB_eHNB-OAM_Type2 |  |
| 3345 | 878.9 | LTE FDD Home eNodeB RF Requirements | 336d? | 2008-12-05 A | 2010-03-19 A | 100% | 2008-12-05 | 2010-03-19 | 336d? | finish no earlier than 2010-03-19 | R4 | 2688h | 2688h | HeNB-RF_FDD | PCG-22 | Motorola | Ying Cai (yingcai@motorola.com) | Rel-9 | RP-42 | Issam | HNB | HeNB-RF_FDD | RP-100035 |
| 3346 | 878.10 | LTE TDD Home eNodeB RF Requirements | 271d? | 2009-03-06 A | 2010-03-19 A | 100% | 2009-03-06 | 2010-03-19 | 271d? | finish no earlier than 2010-03-19 | R4 | 2168h | 2168h | HeNB-RF_TDD | PCG-22 | China Mobile | Nan Li (linan@chinamobile.com) | Rel-9 | RP-43 | Issam | HNB | HeNB-RF_TDD | RP-100036 |
| 3347 | 878.11 | Home NB and Home eNB enhancements - RAN3 aspects | 197d? | 2009-03-06 A | 2009-12-04 A | 100% | 2009-03-06 | 2009-12-04 | 197d? | finish no earlier than 2009-12-04 | R3 | 1576h | 1576h | EHNB-RAN3 | PCG-22 | Alcatel-Lucent | Martin Warner (mw15@alcatel-lucent.com) | Rel-9 | RP-43 | Juha | HNB | EHNB-RAN3 | RP-091050 |
| 3348 | 878.12 | Home NB and Home eNB enhancements - RAN2 aspects | 271d? | 2009-03-06 A | 2010-03-19 A | 100% | 2009-03-06 | 2010-03-19 | 271d? | finish no earlier than 2010-03-19 | R2 | 2168h | 2168h | EHNB-RAN2 | PCG-22 | Huawei | Yang Xudong (yangxudong@huawei.com) | Rel-9 | RP-43 | Yong-Jun | HNB | EHNB-RAN2 | RP-100037 |
| 3349 | 878.13 | Conformance Test Aspects – Home NB enhancements for FDD | 322d? | 2010-09-17 A | 2011-12-09 A | 100% | 2010-09-17 | 2011-12-09 | 322d? | finish no earlier than 2011-12-09 | R5 | 2568h | 2568h | EHNB-UTRA_FDD_UEConTest | PCG-25 | Huawei | trica_li@huawei.com | Rel-9 | RP-49 | Ingbert | HNB | EHNB-UTRA_FDD_UEConTest | RP-111679 |
| 3350 | 878.14 | Conformance Test Aspects – Home eNB enhancements | 201d? | 2010-12-10 A | 2011-09-16 A | 100% | 2010-12-10 | 2011-09-16 | 201d? | finish no earlier than 2011-09-16 | R5 | 1608h | 1608h | EHNB-LTE_UEConTest | PCG-26 | Qualcomm | Mrs Lena Chaponniere (lchaponn@qualcomm.com) | Rel-9 | RP-50 | Ingbert | HNB | EHNB-LTE_UEConTest | RP-110972 |
| 3351 | 878.15 | Home NB and Home eNB enhancements - GERAN aspects | 341d? | 2009-05-18 A | 2010-09-03 A | 100% | 2009-05-18 | 2010-09-03 | 341d? | finish no earlier than 2010-09-03 | GP | 2728h | 2728h | EHNB-GERAN | PCG-23 | Nokia Siemens Networks | leonardo.provvedi@roke.co.uk | Rel-9 | GP-42 | Paolo | HNB | EHNB-GERAN |  |
| 3352 | 879 | **Value-Added Services for Short Message Service** | 586d? | 2007-09-10 A | 2009-12-04 A | 100% | 2007-09-10 | 2009-12-04 | 586d? |  | S1; C4; C1 | 20264h | 20264h | VAS4SMS |  | China Mobile | Wu Bin (wubin@chinamobile.com) | Rel-9 | SP-37 | Alain |  | VAS4SMS |  |
| 3353 | 879.1 | Stage 1 for VAS4SMS | 133d? | 2007-09-10 A | 2008-03-12 A | 100% | 2007-09-10 | 2008-03-12 | 133d? | finish no earlier than 2008-03-21 | S1 | 1064h | 1064h | VAS4SMS |  | China Mobile | Wu Bin (wubin@chinamobile.com) | Rel-9 | SP-37 | Alain |  |  |  |
| 3354 | 879.2 | CT4 aspects of VAS4SMS Interface and Signalling Flow | 322d? | 2008-09-12 A | 2009-12-04 A | 100% | 2008-09-12 | 2009-12-04 | 322d? | finish no earlier than 2009-12-04 | C4 | 2568h | 2568h | VAS4SMS | PCG-21 | China Mobile | Wu Bin (wubin@chinamobile.com) | Rel-9 | CP-41 | Kimmo |  |  |  |
| 3355 | 879.3 | CT1 aspects of VAS4SMS Interface and Signalling Flow | 321d? | 2008-09-09 A | 2009-12-04 A | 100% | 2008-09-09 | 2009-12-04 | 321d? | finish no earlier than 2009-12-04 | C1 | 2568h | 2568h | VAS4SMS | PCG-21 | China Mobile | Wu Bin (wubin@chinamobile.com) | Rel-9 | CP-41 | Frederic |  |  |  |
| 3356 | 880 | **Definition of End-User Identity** | 334d? | 2007-09-03 A | 2008-12-11 A | 100% | 2007-09-03 | 2008-12-11 | 334d? |  | S1 | 5344h | 5344h | EUI |  | Nokia Siemens Networks | Juergen.Merkel@nsn.com | Rel-9 | SP-38 | Alain |  | EUI |  |
| 3357 | 880.1 | Stage 1 for Definition of End-User Identity | 334d? | 2007-09-03 A | 2008-12-11 A | 100% | 2007-09-03 | 2008-12-11 | 334d? | finish no earlier than 2008-12-11 | S1 | 2672h | 2672h | EUI | PCG-21 | Nokia Siemens Networks | Juergen.Merkel@nsn.com | Rel-9 | SP-38 | Alain |  |  |  |
| 3358 | 881 | **Customized Ringing Signal** | 522d? | 2007-12-06 A | 2009-12-03 A | 100% | 2007-12-06 | 2009-12-03 | 522d? |  | S1; C1 | 11296h | 11296h | CRS | PCG-21 | SK Telecom, China Mobile | Donghee Shim (SK Telecom), Jianping Zheng (China Mobile) | Rel-9 | SP-38 | Alain |  | CRS |  |
| 3359 | 881.1 | Stage 1 for Customized Ringing Signal | 266d? | 2007-12-06 A | 2008-12-11 A | 100% | 2007-12-06 | 2008-12-11 | 266d? | finish no earlier than 2008-12-11 | S1 | 2128h | 2128h | CRS | PCG-21 | SK Telecom, China Mobile | Donghee Shim (SK Telecom), Jianping Zheng (China Mobile) | Rel-9 | SP-38 | Alain |  |  |  |
| 3360 | 881.2 | Stage 3 for IMS Customized Ringing Signal (CRS) Service | 136d? | 2009-05-29 A | 2009-12-03 A | 100% | 2009-05-29 | 2009-12-03 | 136d? | finish no earlier than 2010-06-04 | C1 | 816h | 816h | CRS | PCG-23 | China Mobile | wangzhao | Rel-9 | CP-44 | Frederic |  |  |  |

Notes:
- 3336: RP#54 Testing completed / Impacted TSs and TRs: UTRA, LTE
- 3337: CP#49 the SA1-reqs are moving. CT1 will align when the work in SA1 is clear. (was SP#44 completed.) / Impacted TSs and TRs: 22.220, 22.011
- 3338: SP#45 completed / Impacted TSs and TRs: 23.401, 23.402, 23.060, New 23.830
- 3339: SP#46 completed / Impacted TSs and TRs: New 33.320
- 3340: CP#50 completed (Roaming aspects for manual CSG selection, Support of temporary users and CSG membership changes, Support of user controlled and operator controlled lists) / Impacted TSs and TRs: 23.122, 24.008, 24.285, 24.301
- 3341: CP#47 completed. Storing of CSG related data items on the USIM / Impacted TSs and TRs: 31.102
- 3342: SP#47 completed / Impacted TSs and TRs: 32.632, 32.633, 32.635, New (32.771, 32.772, 32.773, 32.775, 32.781, 32.782, 32.783, 32.785)
- 3343: SP#47 completed / Impacted TSs and TRs: 32.581, 32.582, 32.583, 32.584, New (32.591, 32.592, 32.593, 32.594)
- 3344: SP#47 completed / Impacted TSs and TRs: New (32.571, 32.572)
- 3345: RP#47 completed / Impacted TSs and TRs: 36.104, 36.141, New TR 36.921
- 3346: RP#47 completed / Impacted TSs and TRs: 36.104, 36.141, 36.300, 36.331, 36.413, New TR 36.922
- 3347: RP#46 completed (based on high priority items specified in RP-090995) / Impacted TSs and TRs: 25.413, 25.467, 25.467, 25.468, 25.469, 25.469, 36.401, 36.413, New 25.444
- 3348: RP#47 completed / Impacted TSs and TRs: 25.304, 25.331, 25.367, 36.300, 36.304, 36.331
- 3349: UTRA. RP#54 completed. Testing for UID_430026 Support of Home NB and Home eNB enhancements RAN2 aspects (25.304, 25.331, 25.367) / Impacted TSs and TRs: 34.108, 34.121-1, 34.121-2, 34.123-1, 34.123-2, 34.123-3
- 3350: RP#53 completed / Impacted TSs and TRs: 36.508, 36.523-1, 36.523-2, 36.523-3
- 3351: GP#47 completed. GP#42 WID approved / Impacted TSs and TRs: 43.055, 43.129, 44.018, 44.060, 45.008, 48.008, 48.018
- 3352: CP#46 completed
- 3353: SP#39 completed. SP#43 Feature moved to Rel-9 / Impacted TSs and TRs: new 22.142
- 3354: CP#46 completed / Impacted TSs and TRs: new 23.142
- 3355: CP#46 completed / Impacted TSs and TRs: 23.040
- 3356: SP#42 closed. Stage 1 work closed at 5% completion due to lack of input (added only the EUI definition in 21.905)
- 3357: SP#42 closed. Stage 1 work closed at 5% completion due to lack of input (added only the EUI definition in 21.905) / Impacted TSs and TRs: 21.905
- 3358: CP#48 completed
- 3359: SP#42 completed. / Impacted TSs and TRs: 22.173, new 22.183
- 3360: CP#48 completed / Impacted TSs and TRs: 24.173, new 24.183

| ID | WBS | Task | Type | Duration | Start | Finish | Complete | Baseline start | Baseline finish | Baseline duration | Constraint | Resources | Work | Actual work | Acronym | PCG approved | Impacted TSs and TRs | WI rapporteur name | Release | TSG approved | MCC resp | Special Focus Doc | Acronym_3GU_Export | Status Report |
| --- | --- | --- | --- | --- | --- | --- | --- | --- | --- | --- | --- | --- | --- | --- | --- | --- | --- | --- | --- | --- | --- | --- | --- | --- |
| 3361 | 882 | **Public Warning System** |  | 1315d? | 2007-12-06 A | 2012-12-07 A | 100% | 2007-12-06 | 2012-12-07 | 1315d? |  | S1; C1; C4; R2; R3; R5 | 73920h | 73920h | PWS | PCG-21 | LTE | T-Mobile | Rel-9 | SP-38 | Alain | Public Safety (I-A) | PWS |  |
| 3362 | 882.1 | Stage 1 for Public Warning System |  | 266d? | 2007-12-06 A | 2008-12-11 A | 100% | 2007-12-06 | 2008-12-11 | 266d? | finish no earlier than 2008-12-11 | S1 | 2128h | 2128h | PWS | PCG-21 | 22.268 | T-Mobile | Rel-9 | SP-38 | Alain | Public Safety (I-A) |  |  |
| 3363 | 882.2 | **Stage 3 for Public Warning System** |  | 137d? | 2009-05-29 A | 2009-12-04 A | 100% | 2009-05-29 | 2009-12-04 | 137d? |  | C1; C4 | 4368h | 4368h | PWS-St3 | PCG-23 |  | Qualcomm | Rel-9 | CP-44 | Frederic | Public Safety (I-A) | PWS-St3 |  |
| 3364 | 882.2.1 | CT1 aspects of Stage 3 for Public Warning System |  | 137d? | 2009-05-29 A | 2009-12-04 A | 100% | 2009-05-29 | 2009-12-04 | 137d? | finish no earlier than 2009-12-04 | C1 | 1088h | 1088h | PWS-St3 | PCG-23 | 23.041 | Qualcomm | Rel-9 | CP-44 | Frederic | Public Safety (I-A) |  |  |
| 3365 | 882.2.2 | CT4 aspects of Stage 3 for Public Warning System |  | 136d? | 2009-05-30 A | 2009-12-04 A | 100% | 2009-05-30 | 2009-12-04 | 136d? | finish no earlier than 2009-12-04 | C4 | 1088h | 1088h | PWS-St3 | PCG-23 | 29.168 | Qualcomm | Rel-9 | CP-44 | Kimmo | Public Safety (I-A) |  |  |
| 3366 | 882.3 | Public Warning System (PWS) – RAN aspects |  | 136d? | 2009-05-30 A | 2009-12-04 A | 100% | 2009-05-30 | 2009-12-04 | 136d? | finish no earlier than 2009-12-04 | R2; R3 | 2176h | 2176h | PWS-RAN | PCG-23 | LTE 36.300, 36.302, 36.331, 36.413 | AT&T | Rel-9 | RP-44 | Yong-Jun | Public Safety (I-A) | PWS-RAN | RP-091052 |
| 3367 | 882.4 | Conformance Test Aspects – Public Warning System (PWS) – RAN aspects for LTE |  | 267d? | 2011-12-02 A | 2012-12-07 A | 100% | 2011-12-02 | 2012-12-07 | 267d? | finish no earlier than 2012-12-07 | R5 | 2128h | 2128h | PWS-RAN_UEConTest | PCG-28 | 36.508, 36.523-1, 36.523-2, 36.523-3 | Qualcomm | Rel-9 | RP-54 | Ingbert | Public Safety (I-A) | PWS-RAN_UEConTest | RP-121525 |
| 3368 | 883 | **Support of Personal Area Networks and Enhancements to Personal Network Management** |  | 523d? | 2008-06-05 A | 2010-06-04 A | 100% | 2008-06-05 | 2010-06-04 | 523d? |  | S1; C1 | 12544h | 12544h | PAN_EPNM | PCG-21 |  | Vodafone | Rel-9 | SP-40 | Alain |  | PAN_EPNM |  |
| 3369 | 883.1 | Stage 1 for Support of Personal Area Networks and Enhancements to Personal Network Management | milestone | 0d? | 2008-06-05 A | 2008-06-05 A | 100% | 2008-06-05 | 2008-06-05 | 0d? | finish no earlier than 2008-06-05 | S1 |  |  | PAN_EPNM | PCG-21 | 22.259 | Vodafone | Rel-9 | SP-40 | Alain |  |  |  |
| 3370 | 883.2 | Stage 2 for Support of Personal Area Networks and Enhancements to Personal Network Management |  | 196d? | 2009-03-06 A | 2009-12-04 A | 100% | 2009-03-06 | 2009-12-04 | 196d? | finish no earlier than 2009-12-04 | C1 | 1568h | 1568h | PAN_EPNM | PCG-22 | 23.259 | Huawei | Rel-9 | CP-43 | Frederic |  |  |  |
| 3371 | 883.3 | Stage 3 for Support of Personal Area Networks and Enhancements to Personal Network Management |  | 326d? | 2009-03-09 A | 2010-06-04 A | 100% | 2009-03-09 | 2010-06-04 | 326d? | finish no earlier than 2010-06-04 | C1 | 2608h | 2608h | PAN_EPNM | PCG-22 | 24.259 | Huawei | Rel-9 | CP-43 | Frederic |  |  |  |
| 3372 | 884 | **Multi-Media Telephony Service enhancements** |  | 472d? | 2008-06-05 A | 2010-03-25 A | 100% | 2008-06-05 | 2010-03-25 | 472d? |  | S1; S5; C1 | 17840h | 17840h | eMMTel | PCG-21 |  | France Telecom | Rel-9 | SP-40 | Alain |  | eMMTel |  |
| 3373 | 884.1 | Stage 1 for eMMTel |  | 136d? | 2008-06-05 A | 2008-12-11 A | 100% | 2008-06-05 | 2008-12-11 | 136d? | start no earlier than 2008-06-05 | S1 | 1088h | 1088h | eMMTel | PCG-21 | 22.173 | France Telecom | Rel-9 | SP-40 | Alain |  |  |  |
| 3374 | 884.2 | Multimedia Telephony (MMTel) Service and Supplementary Services - Online Charging and completion for Offline Charging (all supplementary services) |  | 272d? | 2009-03-12 A | 2010-03-25 A | 100% | 2009-03-12 | 2010-03-25 | 272d? | finish no earlier than 2010-03-25 | S5 | 2168h | 2168h | eMMTel-SS-CH | PCG-22 | 32.275, 32.298, 32.299 | Alcatel-Lucent | Rel-9 | SP-43 | Mirko |  | eMMTel-SS-CH |  |
| 3375 | 884.3 | Support of Real-time Transfer of Tariff Information (RTTI) in IMS charging |  | 271d? | 2009-03-12 A | 2010-03-25 A | 100% | 2009-03-12 | 2010-03-25 | 271d? | finish no earlier than 2010-03-25 | S5 | 2168h | 2168h | IMSTSS-RTTI-CH | PCG-22 | 32.240, 32.280, 32.298, 32.299 | Orange | Rel-9 | SP-43 | Mirko |  | IMSTSS-RTTI-CH |  |
| 3376 | 884.4 | Stage 3 - Enhancements for Completion of Communications Supplementary service |  | 136d? | 2009-05-30 A | 2009-12-04 A | 100% | 2009-05-30 | 2009-12-04 | 136d? | finish no earlier than 2009-12-04 | C1 | 1088h | 1088h | eMMTel-CC | PCG-23 | 24.642 | France Telecom | Rel-9 | CP-44 | Frederic |  | eMMTel-CC |  |
| 3377 | 885 | **User Data Convergence (UDC)** |  | 527d? | 2008-06-05 A | 2010-06-10 A | 100% | 2008-06-05 | 2010-06-10 | 527d? |  | S1; S5; C4 | 25056h | 25056h | UDC | PCG-21 |  | Nokia Siemens Networks | Rel-9 | SP-40 | Alain |  | UDC |  |
| 3378 | 885.1 | Stage 1 for User Data Convergence (UDC) |  | 136d? | 2008-06-05 A | 2008-12-11 A | 100% | 2008-06-05 | 2008-12-11 | 136d? | start no earlier than 2008-06-05 | S1 | 1088h | 1088h | UDC | PCG-21 | 22.101, new 22.985 | Nokia Siemens Networks | Rel-9 | SP-40 | Alain |  |  |  |
| 3379 | 885.2 | **Stage 2/3 for User Data Convergence (UDC) Technical Realization** |  | 272d? | 2009-03-06 A | 2010-03-19 A | 100% | 2009-03-06 | 2010-03-19 | 272d? |  | C4 | 5376h | 5376h | UDC-CN | PCG-22 |  | Ericsson | Rel-9 | CP-43 | Kimmo |  | UDC-CN |  |
| 3380 | 885.2.1 | User Data Convergence (UDC) Technical Realization (Stage 2) |  | 271d? | 2009-03-06 A | 2010-03-19 A | 100% | 2009-03-06 | 2010-03-19 | 271d? | finish no earlier than 2010-03-19 | C4 | 2168h | 2168h | UDC-CN | PCG-22 | new 23.335 | Ericsson | Rel-9 | CP-43 | Kimmo |  |  |  |
| 3381 | 885.2.2 | User Data Convergence (UDC) Protocol Description |  | 130d? | 2009-09-18 A | 2010-03-19 A | 100% | 2009-09-18 | 2010-03-19 | 130d? | finish no earlier than 2010-03-19 | C4 | 1040h | 1040h | UDC-CN | PCG-23 | new 29.335 | China Mobile, Ericsson | Rel-9 | CP-45 | Kimmo |  |  |  |
| 3382 | 885.3 | **User Data Convergence (UDC) Modelling and Management** |  | 266d? | 2009-06-04 A | 2010-06-10 A | 100% | 2009-06-04 | 2010-06-10 | 266d? |  | S5 | 5944h | 5944h | UDC-MMAN | PCG-23 |  | T-Mobile, China Mobile, Ericsson | Rel-9 | SP-44 | Mirko |  | UDC-MMAN |  |
| 3383 | 885.3.1 | UDC – Framework for Model Handling and Management |  | 266d? | 2009-06-04 A | 2010-06-10 A | 100% | 2009-06-04 | 2010-06-10 | 266d? | finish no earlier than 2010-06-10 | S5 | 2128h | 2128h | UDC-MMAN-MFRM | PCG-23 | 32.172, new 32.181 | T-Mobile | Rel-9 | SP-44 | Mirko |  | UDC-MMAN-MFRM |  |
| 3384 | 885.3.2 | UDC – Common Baseline Information Model |  | 211d? | 2009-06-04 A | 2010-03-25 A | 100% | 2009-06-04 | 2010-03-25 | 211d? | finish no earlier than 2010-03-25 | S5 | 1688h | 1688h | UDC-MMAN-CBIM | PCG-23 | 32.172, new 32.182 | China Mobile, Ericsson | Rel-9 | SP-44 | Mirko |  | UDC-MMAN-CBIM |  |

Notes:
- 3361: TSG#46 completed. Larger scope than Rel-8 Feature UID_370051 (ETWS). Triggered by TR 22.968 Study UID_320025 (FS_PWS) / WI rapporteur e-mail: Mark.Younge@t-mobile.com
- 3362: SP#42 completed / WI rapporteur e-mail: Mark.Younge@t-mobile.com
- 3363: RP#46 completed / WI rapporteur e-mail: Ramachandran Subramanian (rsubrama@qualcomm.com)
- 3364: CP#46 completed / WI rapporteur e-mail: Ramachandran Subramanian (rsubrama@qualcomm.com)
- 3365: CP#46 completed / WI rapporteur e-mail: Ramachandran Subramanian (rsubrama@qualcomm.com)
- 3366: RP#46 completed / WI rapporteur e-mail: don.zelmer@att.com
- 3367: RP#58 completed / WI rapporteur e-mail: Shubhang Vora (svora@qualcomm.com)
- 3368: CP#48 completed / WI rapporteur e-mail: armin.toepfer@vodafone.com
- 3369: SP#40 completed / WI rapporteur e-mail: armin.toepfer@vodafone.com
- 3370: CP#46 completed / WI rapporteur e-mail: Lili Yang (kadyyang@huawei.com)
- 3371: CP#48 completed / WI rapporteur e-mail: Lili Yang (kadyyang@huawei.com)
- 3372: SP#47 completed / WI rapporteur e-mail: philippe.lottin@orange.com
- 3373: SP#42 completed / WI rapporteur e-mail: philippe.lottin@orange.com
- 3374: SP#47 completed / WI rapporteur e-mail: maryse.gardella@alcatel-lucent.com
- 3375: SP#47 completed. Linked to SA5 Rel-8 UID_380042 AoC support in IMS Charging (IMSTSS) / WI rapporteur e-mail: Jean-Luc Garcia (jl.garcia@orange-ftgroup.com)
- 3376: CP#46 completed / WI rapporteur e-mail: Youssef.chadli@orange-ftgroup.com
- 3377: SP#48 completed. Triggered by Rel-8 SA5 Study of Common Profile Storage Framework of User Data for network services and management (UID_320006) TR 32.808 / WI rapporteur e-mail: juergen.merkel@nsn.com
- 3378: SP#42 completed / WI rapporteur e-mail: juergen.merkel@nsn.com
- 3379: - / WI rapporteur e-mail: emiliano.merino@ericsson.com
- 3380: CP#47 completed / WI rapporteur e-mail: emiliano.merino@ericsson.com
- 3381: CP#47 completed / WI rapporteur e-mail: Lan Si Zhong (lansizhong@chinamobile.com), emiliano.merino@ericsson.com
- 3382: SP#48 completed / WI rapporteur e-mail: istvan.aba@t-mobile.at, lansizhong@chinamobile.com, miguel.a.garcia@ericsson.com
- 3383: SP#48 completed / WI rapporteur e-mail: istvan.aba@t-mobile.at
- 3384: SP#47 completed / WI rapporteur e-mail: Lan Si Zhong, Miguel Garcia

| ID | WBS | Task | Duration | Start | Finish | Complete | Baseline start | Baseline finish | Baseline duration | Constraint | Resources | Work | Actual work | Acronym | PCG approved | WI rapporteur name | WI rapporteur e-mail | Release | TSG approved | MCC resp | Acronym_3GU_Export | Status Report | Special Focus Doc |
| --- | --- | --- | --- | --- | --- | --- | --- | --- | --- | --- | --- | --- | --- | --- | --- | --- | --- | --- | --- | --- | --- | --- | --- |
| 3385 | 886 | **IMS Services Centralization and Continuity** | 393d? | 2008-09-18 A | 2010-03-19 A | 100% | 2008-09-18 | 2010-03-19 | 393d? |  | S1; S2; C1 | 30992h | 30992h | IMS_SCC | PCG-21 | NEC | joerg.swetina@neclab.eu | Rel-9 | SP-41 | Alain | IMS_SCC |  |  |
| 3386 | 886.1 | Stage 1 - Inter-Device Transfer – Requirements | 61d? | 2008-09-18 A | 2008-12-11 A | 100% | 2008-09-18 | 2008-12-11 | 61d? | finish no earlier than 2009-06-18 | S1 | 488h | 488h | IMS_SCC-IDT | PCG-21 | NEC | joerg.swetina@neclab.eu | Rel-9 | SP-41 | Alain | IMS_SCC-IDT |  |  |
| 3387 | 886.2 | **Stage 2/3 for IMS Service Continuity Enhancements: Service, Policy and Interactions** | 393d? | 2008-09-18 A | 2010-03-19 A | 100% | 2008-09-18 | 2010-03-19 | 393d? |  | S2; C1 | 9456h | 9456h | IMS_SCC-SPI | PCG-21 | Huawei | HengLiang Zhang (hl_zhang@huawei.com) | Rel-9 | SP-41 | Maurice | IMS_SCC-SPI |  |  |
| 3388 | 886.2.1 | Stage 2 for IMS Service Continuity Enhancements: Service, Policy and Interactions | 186d? | 2008-09-18 A | 2009-06-04 A | 100% | 2008-09-18 | 2009-06-04 | 186d? | finish no earlier than 2009-06-04 | S2 | 1488h | 1488h | IMS_SCC-SPI | PCG-21 | Huawei | HengLiang Zhang (hl_zhang@huawei.com) | Rel-9 | SP-41 | Maurice |  |  |  |
| 3389 | 886.2.2 | Stage 3 for IMS Service Continuity Enhancements: Service, Policy, Interactions and Inter UE Transfer | 212d? | 2009-05-29 A | 2010-03-19 A | 100% | 2009-05-29 | 2010-03-19 | 212d? | finish no earlier than 2010-03-19 | C1 | 1696h | 1696h | IMS_SCC-SPI | PCG-23 | Qualcomm | Roozbeh Atarius (ratarius@qualcomm.com) | Rel-9 | CP-44 | Frederic |  |  |  |
| 3390 | 886.3 | **Stage 2/3 for IMS Centralized Services** | 393d? | 2008-09-18 A | 2010-03-19 A | 100% | 2008-09-18 | 2010-03-19 | 393d? |  | S2; C1 | 9448h | 9448h | IMS_SCC-ICS | PCG-21 | Alcatel-Lucent | andy.bennett@alcatel-lucent.com | Rel-9 | SP-41 | Maurice | IMS_SCC-ICS |  |  |
| 3391 | 886.3.1 | Stage 2 for IMS Centralized Services | 186d? | 2008-09-18 A | 2009-06-04 A | 100% | 2008-09-18 | 2009-06-04 | 186d? | finish no earlier than 2009-06-04 | S2 | 1488h | 1488h | IMS_SCC-ICS | PCG-21 | Alcatel-Lucent | andy.bennett@alcatel-lucent.com | Rel-9 | SP-41 | Maurice |  |  |  |
| 3392 | 886.3.2 | Stage 3 for Enhancements to IMS Centralized Services | 212d? | 2009-05-29 A | 2010-03-19 A | 100% | 2009-05-29 | 2010-03-19 | 212d? | finish no earlier than 2010-03-19 | C1 | 1688h | 1688h | IMS_SCC-ICS | PCG-23 | Nokia Siemens Networks | Peter.Leis@nsn.com | Rel-9 | CP-44 | Frederic |  |  |  |
| 3393 | 886.4 | Stage 3 - IMS Centralized Services support via I1 interface | 271d? | 2009-03-06 A | 2010-03-19 A | 100% | 2009-03-06 | 2010-03-19 | 271d? | finish no earlier than 2010-03-19 | C1 | 2168h | 2168h | IMS_SCC-ICS_I1 | PCG-22 | Huawei | Lili Yang(kadyyang@huawei.com) | Rel-9 | CP-43 | Frederic | IMS_SCC-ICS_I1 |  |  |
| 3394 | 887 | **Service Specific Access Control in EPS** | 922d? | 2008-12-11 A | 2012-06-15 A | 100% | 2008-12-11 | 2012-06-15 | 922d? |  | S1; C1; R5 | 26000h | 26000h | SSAC | PCG-22 | NTT DoCoMo | Frederic Thepot (thepot@docomolab-euro.com) | Rel-9 | SP-42 | Alain | SSAC |  |  |
| 3395 | 887.1 | Stage 1 for Service Specific Access Control in EPS | 1d? | 2008-12-11 A | 2008-12-11 A | 100% | 2008-12-11 | 2008-12-11 | 1d? | start no earlier than 2008-12-11 | S1 | 8h | 8h | SSAC | PCG-22 | NTT DoCoMo | Frederic Thepot (thepot@docomolab-euro.com) | Rel-9 | SP-42 | Alain |  |  |  |
| 3396 | 887.2 | Stage 3 for Service Specific Access Control in EPS | 212d? | 2009-05-29 A | 2010-03-19 A | 100% | 2009-05-29 | 2010-03-19 | 212d? | finish no earlier than 2010-03-19 | C1 | 1696h | 1696h | SSAC | PCG-23 | NTT DoCoMo | Hideyuki Yamashita (yamashitahi@s1.nttdocomo.co.jp) | Rel-9 | CP-44 | Frederic |  |  |  |
| 3397 | 887.3 | Conformance Test Aspects - Service Specific Access Control | 272d? | 2011-06-07 A | 2012-06-15 A | 100% | 2011-06-07 | 2012-06-15 | 272d? | finish no earlier than 2012-06-15 | R5 | 2168h | 2168h | SSAC_UEConTest | PCG-27 | NTT DoCoMo | Takao.Shimizu.rp@nttdocomo.com | Rel-9 | RP-52 | Ingbert | SSAC_UEConTest | RP-120447 |  |
| 3398 | 888 | **Support for IMS Emergency Calls over GPRS and EPS** | 3785d? | 2000-01-03 A | 2014-06-13 A | 100% | 2000-01-03 | 2014-06-13 | 3785d? |  | S1; S2; S3; C1; C3; C4; R2; R3; R5; IETF | 293512h | 293512h | IMS_EMER_GPRS_EPS | PCG-21 | Alcatel-Lucent | Deborah Barclay | Rel-9 | SP-38 | Maurice | IMS_EMER_GPRS_EPS |  | Public Safety (I-A) |
| 3399 | 888.1 | Stage 1 for IMS Emergency Calls over GPRS and EPS | 239d? | 2008-01-14 A | 2008-12-11 A | 100% | 2008-01-14 | 2008-12-11 | 239d? | finish no earlier than 2008-12-11 | S1 | 1912h | 1912h | IMS_EMER_GPRS_EPS | PCG-21 | Alcatel-Lucent | Deborah Barclay | Rel-9 | SP-38 | Alain |  |  | Public Safety (I-A) |
| 3400 | 888.2 | Stage 2 for IMS Emergency Calls over GPRS and EPS | 364d? | 2008-01-14 A | 2009-06-04 A | 100% | 2008-01-14 | 2009-06-04 | 364d? | finish no earlier than 2009-06-04 | S2 | 2912h | 2912h | IMS_EMER_GPRS_EPS | PCG-21 | Alcatel-Lucent | Deborah Barclay | Rel-9 | SP-38 | Maurice |  |  | Public Safety (I-A) |
| 3401 | 888.3 | Security aspects for IMS Emergency Calls over GPRS and EPS | 391d? | 2008-12-12 A | 2010-06-10 A | 100% | 2008-12-12 | 2010-06-10 | 391d? | finish no earlier than 2010-03-25 | S3 | 3128h | 3128h | IMS_EMER_GPRS_EPS-Sec | PCG-22 | Alcatel-Lucent | Deborah Barclay | Rel-9 | SP-42 | Mirko | IMS_EMER_GPRS_EPS-Sec |  | Public Safety (I-A) |
| 3402 | 888.4 | **Stage 3 for IMS Emergency Calls over GPRS and EPS** | 801d? | 2009-05-29 A | 2012-06-15 A | 100% | 2009-05-29 | 2012-06-15 | 801d? |  | C1; C3; C4; R5 | 33331.7h | 33331.7h | IMS_EMER_GPRS_EPS | PCG-23 | Alcatel-Lucent | Frank Alfano (falfano@alcatel-lucent.com) | Rel-9 | CP-44 | Frederic |  |  | Public Safety (I-A) |
| 3403 | 888.4.1 | CT1 aspects - Stage 3 for IMS Emergency Calls over GPRS and EPS | 212d? | 2009-05-29 A | 2010-03-19 A | 100% | 2009-05-29 | 2010-03-19 | 212d? | finish no earlier than 2010-03-19 | C1 | 1696h | 1696h | IMS_EMER_GPRS_EPSC1 | PCG-23 | Alcatel-Lucent | Frank Alfano (falfano@alcatel-lucent.com) | Rel-9 | CP-44 | Frederic |  |  | Public Safety (I-A) |
| 3404 | 888.4.2 | Conformance Test Aspects - CT1 aspects for IMS Emergency Calls over GPRS and EPS | 532d? | 2010-06-04 A | 2012-06-15 A | 100% | 2010-06-04 | 2012-06-15 | 532d? | finish no earlier than 2012-06-15 | R5 | 4256h | 4256h | IMS_EMER_GPRS_EPS_UEConTest | PCG-25 | Samsung | stoyan.baev@partner.samsung.com | Rel-9 | RP-48 | Ingbert | IMS_EMER_GPRS_EPS_UEConTest | RP-120445 | Public Safety (I-A) |
| 3405 | 888.4.3 | CT3 aspects - Stage 3 for IMS Emergency Calls over GPRS and EPS | 82d? | 2009-05-29 A | 2009-09-18 A | 100% | 2009-05-29 | 2009-09-18 | 82d? | start no earlier than 2009-05-29 | C3 | 651.68h | 651.68h | IMS_EMER_GPRS_EPSC3 | PCG-23 | Alcatel-Lucent | Frank Alfano (falfano@alcatel-lucent.com) | Rel-9 | CP-44 | Adrian |  |  | Public Safety (I-A) |
| 3406 | 888.4.4 | CT4 aspects - Stage 3 for IMS Emergency Calls over GPRS and EPS | 137d? | 2009-05-29 A | 2009-12-04 A | 100% | 2009-05-29 | 2009-12-04 | 137d? | finish no earlier than 2009-12-04 | C4 | 1096h | 1096h | IMS_EMER_GPRS_EPSC4 | PCG-23 | Alcatel-Lucent | Frank Alfano (falfano@alcatel-lucent.com) | Rel-9 | CP-44 | Kimmo |  |  | Public Safety (I-A) |
| 3407 | 888.5 | Support for IMS Emergency Calls over LTE | 207d? | 2000-01-03 A | 2000-10-16 A | 100% | 2000-01-03 | 2000-10-16 | 207d? |  | R2; R3 | 3312h | 3312h | IMS_EMER_LTE | PCG-22 | Alcatel-Lucent | Sudeep Palat (spalat@alcatel-lucent.com) | Rel-9 | RP-42 | Yong-Jun | IMS_EMER_LTE | RP-090698 | Public Safety (I-A) |
| 3408 | 888.6 | Conformance Test Aspects – Support for IMS Emergency Calls over LTE | 187d? | 2010-03-25 A | 2010-12-10 A | 100% | 2010-03-25 | 2010-12-10 | 187d? | finish no earlier than 2010-12-10 | R5 | 1496h | 1496h | IMS_EMER_LTE_UEConTest | PCG-24 | Ericsson | leif.mattisson@ericsson.com | Rel-9 | RP-47 | Ingbert | IMS_EMER_LTE_UEConTest | RP-101068 | Public Safety (I-A) |

Notes:
- 3385: CP#47 completed
- 3386: SP#42 completed / Impacted TSs and TRs: 22.101, 22.228
- 3387: -
- 3388: SP#57 Removal of the MSC server assisted mid-call feature from Rel-9 by 23.237CR#0433 (CT1 proposed moving this feature to Rel-10). SP#44 completed. TR 23.838 for Approval / Impacted TSs and TRs: 23.237, 23.292, 23.216, new 23.838
- 3389: CP#47 completed / Impacted TSs and TRs: 24.216, 24.229, 24.237
- 3390: -
- 3391: SP#44 completed. TR 23.883 for Information + Approval / Impacted TSs and TRs: 23.292, new 23.883
- 3392: CP#47 completed / Impacted TSs and TRs: 24.292, 24.604, 24.607, 24.608, 24.611, 24.623
- 3393: CP#47 completed / Impacted TSs and TRs: 24.237, 24.292, new 24.294
- 3394: CP#47 completed. Triggered by TR 22.986 Study on Service Specific Access Control in EPS. As EPS is a PS-Domain only system, Domain Specific Access Control (DSAC) doesn't apply, hence SSAC allows restriction of voice and non-voice calls separately
- 3395: SP#42 completed. If UE supports E-UTRA and IMS, SSAC is a mandatory Rel-9 function (during congestion in emergency case earthquake/tsunami improves mobile communications). / Impacted TSs and TRs: 22.011 CR0136
- 3396: CP#47 completed / Impacted TSs and TRs: 24.173, 27.007
- 3397: RP#56 completed. Testing for Stage 3 for Service Specific Access Control in EPS (24.173, 27.007) UID_440040 / Impacted TSs and TRs: 34.229-1, 34.229-2, 34.229-3
- 3398: RP#56 completed testing. CP#47 completed. SP#48 completed / Impacted TSs and TRs: GERAN, LTE
- 3399: SP#42 completed / Impacted TSs and TRs: 22.101
- 3400: SP#44 completed / Impacted TSs and TRs: 23.869, 23.060, 23.167, 23.203, 23.221, 23.228, 23.271, 23.401, 23.402
- 3401: SP#48 completed / Impacted TSs and TRs: 33.401, 33.402
- 3402: RP#56 completed testing. CP#47 completed / Impacted TSs and TRs: GERAN, LTE
- 3403: CP#47 completed / Impacted TSs and TRs: 23.122, 24.008, 24.229, 24.301, 24.302
- 3404: RP#56 completed / Impacted TSs and TRs: 34.108, 34.123-1, 34.123-2, 34.123-3, 34.229-1, 34.229-2, 34.229-3, 36.508, 36.523-1, 36.523-2, 36.523-3
- 3405: CP#45 completed / Impacted TSs and TRs: 29.212, 29.213, 29.214, 29.215
- 3406: CP#46 completed / Impacted TSs and TRs: 23.003, 23.008, 29.060, 29.272, 29.273, 29.274, 29.275, 29.276
- 3407: RP#45 completed / Impacted TSs and TRs: 36.331, 36.413
- 3408: RP#50 completed / Impacted TSs and TRs: 36.508, 36.523-1, 36.523-2, 36.523-3

| ID | WBS | Task | Type | Duration | Start | Finish | Complete | Baseline start | Baseline finish | Baseline duration | Constraint | Resources | Work | Actual work | Acronym | PCG approved | WI rapporteur name | WI rapporteur e-mail | Release | TSG approved | MCC resp | Special Focus Doc | Acronym_3GU_Export | Status Report |
| --- | --- | --- | --- | --- | --- | --- | --- | --- | --- | --- | --- | --- | --- | --- | --- | --- | --- | --- | --- | --- | --- | --- | --- | --- |
| 3409 | 888.7 | **Single Radio Voice Call Continuity (SRVCC) support for IMS Emergency Calls** |  | 1511d? | 2008-09-18 A | 2014-06-13 A | 100% | 2008-09-18 | 2014-06-13 | 1511d? |  | S2; C1; C4; C3; IETF | 112300h | 112300h | IMS_EMER_GPRS_EPS-SRVCC | PCG-21 | China Mobile | Yu Qing (Yuqing@chinamobile.com) | Rel-9 | SP-41 | Maurice | Public Safety (I-A) | IMS_EMER_GPRS_EPS-SRVCC |  |
| 3410 | 888.7.1 | SRVCC support for IMS Emergency Calls |  | 322d? | 2008-09-18 A | 2009-12-10 A | 100% | 2008-09-18 | 2009-12-10 | 322d? | finish no earlier than 2009-12-10 | S2 | 2576h | 2576h | IMS_EMER_GPRS_EPS-SRVCC | PCG-21 | China Mobile | Yu Qing (Yuqing@chinamobile.com) | Rel-9 | SP-41 | Maurice | Public Safety (I-A) |  |  |
| 3411 | 888.7.2 | **CT aspects of SRVCC support for IMS Emergency Calls** |  | 1330d? | 2009-05-29 A | 2014-06-13 A | 100% | 2009-05-29 | 2014-06-13 | 1330d? |  | C1; C4; C3; IETF | 49284h | 49284h | IMS_EMER_GPRS_EPS-SRVCC | PCG-24 | China Mobile | jiangyi@chinamobile.com | Rel-9 | CP-46 | Frederic | Public Safety (I-A) |  |  |
| 3412 | 888.7.2.1 | CT1 aspects of SRVCC support for IMS Emergency Calls |  | 137d? | 2009-05-29 A | 2009-12-04 A | 100% | 2009-05-29 | 2009-12-04 | 137d? | finish no earlier than 2009-12-04 | C1 | 1096h | 1096h | IMS_EMER_GPRS_EPS-SRVCC | PCG-23 | China Mobile | jiangyi@chinamobile.com | Rel-9 | CP-44 | Frederic | Public Safety (I-A) |  |  |
| 3413 | 888.7.2.2 | CT4 aspects of SRVCC support for IMS Emergency Calls |  | 137d? | 2009-05-29 A | 2009-12-04 A | 100% | 2009-05-29 | 2009-12-04 | 137d? | finish no earlier than 2009-12-04 | C4 | 1096h | 1096h | IMS_EMER_GPRS_EPS-SRVCC | PCG-23 | China Mobile | jiangyi@chinamobile.com | Rel-9 | CP-44 | Kimmo | Public Safety (I-A) |  |  |
| 3414 | 888.7.2.3 | CT3 aspects of SRVCC support for IMS Emergency Calls |  | 1d? | 2009-12-04 A | 2009-12-04 A | 100% | 2009-12-04 | 2009-12-04 | 1d? | finish no earlier than 2009-12-04 | C3 | 8h | 8h | IMS_EMER_GPRS_EPS-SRVCC | PCG-24 | China Mobile | jiangyi@chinamobile.com | Rel-9 | CP-46 | Kimmo | Public Safety (I-A) |  |  |
| 3415 | 888.7.2.4 | (IETF) CT3 aspects of SRVCC support for IMS Emergency Calls (RFC 7254) |  | 568d? | 2012-04-20 A | 2014-06-13 A | 100% | 2012-04-20 | 2014-06-13 | 568d? | finish no earlier than 2014-06-13 | C3-IETF | 4524h | 4524h | IMS_EMER_GPRS_EPS-SRVCC | PCG-29 | Andrew Allen | Andrew Allen | Rel-9 | CP-56 | Adrian | Public Safety (I-A) |  |  |
| 3416 | 889 | **LCS for LTE and EPS** |  | 981d? | 2008-06-05 A | 2012-03-02 A | 100% | 2008-06-05 | 2012-03-02 | 981d? |  | S2; C1; C4; R2; R1; R3; R4; R5 | 83592h | 83592h | LCS_LTE_EPS | PCG-22 |  |  | Rel-9 | SP-43 | Maurice | Public Safety (I-A) | LCS_LTE_EPS |  |
| 3417 | 889.1 | **LCS Control Plane Solution for EPS** |  | 468d? | 2008-06-05 A | 2010-03-19 A | 100% | 2008-06-05 | 2010-03-19 | 468d? |  | S2; C4; C1 | 16712h | 16712h | LCS_EPS-CPS | PCG-21 | Polaris Wireless | Robert Gross (rgross@polariswireless.com) | Rel-9 | SP-40 | Maurice | Public Safety (I-A) | LCS_EPS-CPS |  |
| 3418 | 889.1.1 | Stage 2 for LCS Control Plane Solution for EPS |  | 261d? | 2008-06-05 A | 2009-06-04 A | 100% | 2008-06-05 | 2009-06-04 | 261d? | finish no earlier than 2009-06-04 | S2 | 2088h | 2088h | LCS_EPS-CPS | PCG-21 | Polaris Wireless | Robert Gross (rgross@polariswireless.com) | Rel-9 | SP-40 | Maurice | Public Safety (I-A) |  |  |
| 3419 | 889.1.2 | CT4 aspects of Control Plane LCS in the EPC |  | 212d? | 2009-05-29 A | 2010-03-19 A | 100% | 2009-05-29 | 2010-03-19 | 212d? | finish no earlier than 2010-03-19 | C4 | 1696h | 1696h | LCS_EPS-CPS | PCG-23 | Polaris Wireless | Robert Gross (rgross@polariswireless.com) | Rel-9 | CP-44 | Kimmo | Public Safety (I-A) |  |  |
| 3420 | 889.1.3 | CT1 aspects of Control Plane LCS in the EPC |  | 212d? | 2009-05-29 A | 2010-03-19 A | 100% | 2009-05-29 | 2010-03-19 | 212d? | finish no earlier than 2010-03-19 | C1 | 1696h | 1696h | LCS_EPS-CPS | PCG-23 | Polaris Wireless | Robert Gross (rgross@polariswireless.com) | Rel-9 | CP-44 | Frederic | Public Safety (I-A) |  |  |
| 3421 | 889.2 | Positioning Support for LTE | milestone | 0d? | 2008-12-05 A | 2008-12-05 A | 100% | 2008-12-05 | 2010-06-04 | 392d? | finish no earlier than 2010-06-04 | R2; R1; R3; R4 |  |  | LCS_LTE | PCG-22 | Qualcomm | Nathan Tenny (ntenny@qualcomm.com) | Rel-9 | RP-42 | Yong-Jun | Public Safety (I-A) | LCS_LTE | RP-100442 |
| 3422 | 889.3 | Conformance Test Aspects – Positioning Support for LTE |  | 512d? | 2010-03-19 A | 2012-03-02 A | 100% | 2010-03-19 | 2012-03-02 | 512d? | finish no earlier than 2012-03-02 | R5 | 4096h | 4096h | LCS_LTE_UEConTest | PCG-24 | Qualcomm | Shubhang Vora (svoral@qualcomm.com) | Rel-9 | RP-47 | Ingbert | Public Safety (I-A) | LCS_LTE_UEConTest | RP-120034 |
| 3423 | 890 | **MBMS support in EPS** |  | 921d? | 2008-06-05 A | 2011-12-09 A | 100% | 2008-06-05 | 2011-12-09 | 921d? |  | S2; S3; S5; C3; C4; R2; R3; R4; R5 | 82896h | 82896h | MBMS_EPS | PCG-21 | China Mobile | Liu Hong (liuhongyfw@chinamobile.com) | Rel-9 | SP-40 | Maurice |  | MBMS_EPS |  |
| 3424 | 890.1 | Stage 2 for MBMS support in EPS |  | 261d? | 2008-06-05 A | 2009-06-04 A | 100% | 2008-06-05 | 2009-06-04 | 261d? | finish no earlier than 2009-06-04 | S2 | 2088h | 2088h | MBMS_EPS | PCG-21 | China Mobile | Liu Hong (liuhongyfw@chinamobile.com) | Rel-9 | SP-40 | Maurice |  |  |  |
| 3425 | 890.2 | Security for MBMS support in EPS |  | 261d? | 2008-12-11 A | 2009-12-10 A | 100% | 2008-12-11 | 2009-12-10 | 261d? | finish no earlier than 2009-12-10 | S3 | 2088h | 2088h | MBMS_EPS | PCG-22 | China Mobile | Liu Hong (liuhongyfw@chinamobile.com) | Rel-9 | SP-42 | Mirko |  |  |  |
| 3426 | 890.3 | MBMS Charging in EPS |  | 201d? | 2009-03-06 A | 2009-12-10 A | 100% | 2009-03-06 | 2009-12-10 | 201d? | finish no earlier than 2009-12-10 | S5 | 1600h | 1600h | MBMS_EPS | PCG-22 | ZTE | guo.wenjie1@zte.com.cn | Rel-9 | SP-43 | Mirko |  |  |  |
| 3427 | 890.4 | CT4 aspects of MBMS support in EPS (Stage 3) |  | 137d? | 2009-05-29 A | 2009-12-04 A | 100% | 2009-05-29 | 2009-12-04 | 137d? | finish no earlier than 2009-12-04 | C4 | 1096h | 1096h | MBMS_EPS | PCG-23 | China Mobile, ZTE | wangjingyf@chinamobile.com, lu.fei1@zte.com.cn | Rel-9 | CP-44 | Kimmo |  |  |  |
| 3428 | 890.5 | CT3 aspects of MBMS support in EPS (Stage 3) |  | 137d? | 2009-05-29 A | 2009-12-04 A | 100% | 2009-05-29 | 2009-12-04 | 137d? | start no earlier than 2009-05-29 | C3 | 1096h | 1096h | MBMS_EPS | PCG-23 | ZTE, China Mobile | zhou.xiaoyun@zte.com.cn, wangjingyf@chinamobile.com | Rel-9 | CP-44 | Adrian |  |  |  |
| 3429 | 890.6 | MBMS support in LTE |  | 272d? | 2009-03-06 A | 2010-03-19 A | 100% | 2009-03-06 | 2010-03-19 | 272d? | finish no earlier than 2010-03-19 | R2; R3; R4 | 6528h | 6528h | MBMS_LTE | PCG-22 | Huawei | arnaud.meylan@huawei.com | Rel-9 | RP-43 | Yong-Jun |  | MBMS_LTE | RP-100033 |
| 3430 | 890.7 | Conformance Test Aspects – MBMS support in LTE |  | 262d? | 2010-12-10 A | 2011-12-09 A | 100% | 2010-12-10 | 2011-12-09 | 262d? | finish no earlier than 2011-12-09 | R5 | 2088h | 2088h | MBMS_LTE-UEConTest | PCG-26 | Huawei | Zhang Xin (zhangxin0208@huawei.com) | Rel-9 | RP-50 | Ingbert |  | MBMS_LTE-UEConTest | RP-111437 |
| 3431 | 891 | **Access Network Discovery and Selection Function enhancements** |  | 333d? | 2008-12-11 A | 2010-03-19 A | 100% | 2008-12-11 | 2010-03-19 | 333d? |  | S2; C1 | 7384h | 7384h | eANDSF | PCG-22 | Motorola | Apostolis Salkintzis (salki@motorola.com) | Rel-9 | SP-42 | Maurice |  | eANDSF |  |
| 3432 | 891.1 | Stage 2 for Access Network Discovery and Selection Function enhancements |  | 126d? | 2008-12-11 A | 2009-06-04 A | 100% | 2008-12-11 | 2009-06-04 | 126d? | finish no earlier than 2009-06-04 | S2 | 1008h | 1008h | eANDSF | PCG-22 | Motorola | Apostolis Salkintzis (salki@motorola.com) | Rel-9 | SP-42 | Maurice |  |  |  |
| 3433 | 891.2 | CT1 aspects of Access Network Discovery and Selection Function enhancements |  | 131d? | 2009-09-18 A | 2010-03-19 A | 100% | 2009-09-18 | 2010-03-19 | 131d? | finish no earlier than 2010-03-19 | C1 | 1048h | 1048h | eANDSF | PCG-23 | Panasonic | benjamin.limck@sg.panasonic.com | Rel-9 | CP-45 | Frederic |  |  |  |

Notes:
- 3409: CP#56 added IETF dependency
- 3410: SP#46 completed / Impacted TSs and TRs: 23.870, 23.216, 23.237
- 3411: CP#46 completed
- 3412: CP#46 completed / Impacted TSs and TRs: 24.229, 24.237
- 3413: CP#46 completed / Impacted TSs and TRs: 29.205, 29.280
- 3414: CP#46 completed / Impacted TSs and TRs: 29.163
- 3415: CP#64 completed / Impacted TSs and TRs: RFC 7254 (was draft-montemurro-gsma-imei-urn)
- 3416: - / Impacted TSs and TRs: LTE
- 3417: Triggered by abandoned Study UID_380068 (FS_LCS_EPS). Linked to Feature UID_380064 Support for IMS Emergency Calls over GPRS and EPS
- 3418: SP#44 completed / Impacted TSs and TRs: 23.891, 23.271, 23.401, 23.402
- 3419: CP#47 completed (IANA registrations outstanding). Stage 3 SLs and SLg interfaces & transport of positioning messages between E-SMLC and MME in the scope of UID_420006 (Positioning Support for LTE) / Impacted TSs and TRs: 24.080, 29.002, 29.272, 29.230, new 24.171, 29.171, 29.172, 29.173
- 3420: CP#47 completed / Impacted TSs and TRs: 24.301
- 3421: RP#48 completed. UID_400038 (LCS Control Plane Solution for EPS) depends on this WI / Impacted TSs and TRs: 34.213, 36.133, 36.211, 36.214, 36.300, 36.305, 36.331, 36.355, 36.410, 36.413, 36.455, new 36.171
- 3422: RP#55 completed. RP#56 TS 37.571-4 v200 for Approval / Impacted TSs and TRs: 36.508, 36.509, new (37.571-1, 37.571-2, 37.571-3, 37.571-4, 37.571-5)
- 3423: RP#47 completed. SP#46, CP#46 completed / Impacted TSs and TRs: LTE
- 3424: SP#44 completed / Impacted TSs and TRs: 23.246
- 3425: SP#46 completed / Impacted TSs and TRs: 33.246
- 3426: SP#46 completed / Impacted TSs and TRs: 32.273, 32.251, 32.298, 32.299
- 3427: CP#46 completed / Impacted TSs and TRs: 29.274, 29.281, 23.007, 23.008
- 3428: CP#46 completed / Impacted TSs and TRs: 29.061
- 3429: RP#47 completed / Impacted TSs and TRs: 25.446, 36.101, 36.104, 36.141, 36.300, 36.304, 36.321, 36.322, 36.323, 36.331, 36.440, 36.441, 36.442, 36.444, 36.445
- 3430: RP#54 completed / Impacted TSs and TRs: 36.508, 36.521-1, 36.521-2, 36.523-1, 36.523-2, 36.523-3
- 3431: CP#47 completed. No new Rel-9 use cases defined. Implement service requirements not covered in Rel-8 / Impacted TSs and TRs: 22.278, SA3 33.402 CR#0055
- 3432: SP#44 completed / Impacted TSs and TRs: 23.402, 23.002
- 3433: CP#47 completed / Impacted TSs and TRs: 24.302, 24.312

| ID | WBS | Task | Duration | Start | Finish | Complete | Baseline start | Baseline finish | Baseline duration | Constraint | Resources | Work | Actual work | Acronym | PCG approved | WI rapporteur name | WI rapporteur e-mail | Release | TSG approved | MCC resp | Acronym_3GU_Export | Impacted TSs and TRs | Status Report |
| --- | --- | --- | --- | --- | --- | --- | --- | --- | --- | --- | --- | --- | --- | --- | --- | --- | --- | --- | --- | --- | --- | --- | --- |
| 3434 | 892 | **Multiple PDN Connection to the Same APN for PMIP-based Interfaces** | 267d? | 2009-03-13 A | 2010-03-19 A | 100% | 2009-03-13 | 2010-03-19 | 267d? |  | S2; C4; C1 | 8392h | 8392h | MUPSAP | PCG-22 | Samsung | erik.guttman@partner.samsung.com | Rel-9 | SP-43 | Maurice | MUPSAP |  |  |
| 3435 | 892.1 | Stage 2 for Multiple PDN Connection to the Same APN for PMIP-based Interfaces | 61d? | 2009-03-13 A | 2009-06-04 A | 100% | 2009-03-13 | 2009-06-04 | 61d? | finish no earlier than 2009-06-04 | S2 | 488h | 488h | MUPSAP | PCG-22 | Samsung | erik.guttman@partner.samsung.com | Rel-9 | SP-43 | Maurice |  | 23.060, 23.203, 23.401, 23.402 |  |
| 3436 | 892.2 | CT4 aspects of Multiple PDN Connection to the Same APN for PMIP-based Interfaces | 56d? | 2009-09-18 A | 2009-12-04 A | 100% | 2009-09-18 | 2009-12-04 | 56d? | finish no earlier than 2009-12-04 | C4 | 448h | 448h | MUPSAP | PCG-23 | Samsung | Surjyakanta Mohapatra (surjya.kanta@samsung.com) | Rel-9 | CP-45 | Kimmo |  | 29.275, 23.008, 29.282 |  |
| 3437 | 892.3 | CT1 aspects of Multiple PDN Connection to the Same APN for PMIP-based Interfaces | 131d? | 2009-09-18 A | 2010-03-19 A | 100% | 2009-09-18 | 2010-03-19 | 131d? | finish no earlier than 2010-03-19 | C1 | 1048h | 1048h | MUPSAP | PCG-23 | Samsung | Surjyakanta Mohapatra (surjya.kanta@samsung.com) | Rel-9 | CP-45 | Frederic |  | 24.302 |  |
| 3438 | 893 | **System aspects of vocoder rate adaptation for LTE** | 1403.68d? | 2007-05-07 A | 2012-09-12 A | 100% | 2007-05-07 | 2012-09-12 | 1403.68d? |  | S2; S4; C1; C3; R2; IETF | 108798h | 108798h | LTEimp-Vocoder | PCG-23 | Qualcomm | AC Mahendran (ac@qualcomm.com) | Rel-9 | SP-45 | Maurice | LTEimp-Vocoder | LTE |  |
| 3439 | 893.1 | SA2 system aspects of vocoder rate adaptation for LTE | 81d? | 2009-06-04 A | 2009-09-24 A | 100% | 2009-06-04 | 2009-09-24 | 81d? | start no earlier than 2009-06-04 | S2 | 648h | 648h | LTEimp-Vocoder | PCG-23 | Qualcomm | AC Mahendran (ac@qualcomm.com) | Rel-9 | SP-45 | Maurice |  | 23.401 CR#1103r3 |  |
| 3440 | 893.2 | SA4 system aspects of vocoder rate adaptation for LTE | 136d? | 2009-06-04 A | 2009-12-10 A | 100% | 2009-06-04 | 2009-12-10 | 136d? | finish no earlier than 2009-12-07 | S4 | 1088h | 1088h | LTEimp-Vocoder | PCG-23 | Qualcomm | Nikolai Leung | Rel-9 | SP-45 | Paolo |  | 26.114 |  |
| 3441 | 893.3 | Vocoder rate adaptation for LTE | 81d? | 2009-05-30 A | 2009-09-18 A | 100% | 2009-05-30 | 2009-09-18 | 81d? | finish no earlier than 2009-09-18 | R2 | 648h | 648h | LTEimp-Vocoder | PCG-23 | Alcatel-Lucent | Sudeep Palat (spalat@alcatel-lucent.com) | Rel-9 | RP-44 | Yong-Jun |  | 36.300 CR#0114 | RP-090704 |
| 3442 | 893.4 | (IETF) SA4 system aspects of vocoder rate adaptation for LTE | 677.6d? | 2009-06-04 A | 2012-09-12 A | 100% | 2009-06-04 | 2012-09-12 | 677.6d? | finish no earlier than 2012-09-14 | S4-IETF | 5420.8h | 5420.8h | LTEimp-Vocoder | PCG-27 | Lionel Morand |  | Rel-9 | SP-52 | Paolo |  | RFC 6679 (was draft-ietf-avtcore-ecn-for-rtp) |  |
| 3443 | 893.5 | (IETF) CT aspects of vocoder rate adaptation for LTE | 1400.68d? | 2007-05-07 A | 2012-09-07 A | 100% | 2007-05-07 | 2012-09-07 | 1400.68d? | finish no earlier than 2012-09-07 | C1-IETF; C3-IETF; C4-IETF | 33616.3h | 33616.3h | LTEimp-Vocoder | PCG-27 | Lionel Morand |  | Rel-9 | CP-52 | Frederic |  | RFC 6679 (was draft-ietf-avtcore-ecn-for-rtp) |  |
| 3444 | 894 | Access Security Enhancements | 505d? | 2007-07-02 A | 2009-06-04 A | 100% | 2007-07-02 | 2009-06-04 | 505d? | finish no earlier than 2009-06-03 | S3 | 4040h | 4040h | ACCSEC2 |  | Ericsson | Bengt.Sahlin@ericsson.com | Rel-9 | SP-26 | Mirko | ACCSEC2 | 33.102, 43.020 |  |
| 3445 | 895 | **Protection against Unsolicited Communication for IMS (PUCI)** | 322d? | 2008-09-18 A | 2009-12-10 A | 100% | 2008-09-18 | 2009-12-10 | 322d? |  | S3; S1 | 8216h | 8216h | PUCI | PCG-21 | NEC | Anand R. Prasad (anand@bq.jp.nec.com) | Rel-9 | SP-41 | Alain | PUCI |  |  |
| 3446 | 895.1 | Stage 1 for PUCI | 61d? | 2008-09-18 A | 2008-12-11 A | 100% | 2008-09-18 | 2008-12-11 | 61d? | finish no earlier than 2009-06-18 | S1 | 488h | 488h | PUCI | PCG-21 | NEC | Anand R. Prasad (anand@bq.jp.nec.com) | Rel-9 | SP-41 | Alain |  | 22.228 |  |
| 3447 | 895.2 | SA3 work on PUCI | 322d? | 2008-09-18 A | 2009-12-10 A | 100% | 2008-09-18 | 2009-12-10 | 322d? | finish no earlier than 2009-12-10 | S3 | 2576h | 2576h | PUCI | PCG-21 | NEC | Anand R. Prasad (anand@bq.jp.nec.com) | Rel-9 | SP-41 | Mirko |  | New 33.937 |  |
| 3448 | 896 | **IMS Media Plane Security** | 922d? | 2009-03-13 A | 2012-09-14 A | 100% | 2009-03-13 | 2012-09-14 | 922d? |  | S3; C1; C4; C3; IETF | 67928h | 67928h | MEDIASEC | PCG-22 | Vodafone | Peter.Howard@vodafone.com | Rel-9 | SP-43 | Mirko | MEDIASEC |  |  |
| 3449 | 896.1 | SA3 aspects of IMS Media Plane Security | 271d? | 2009-03-13 A | 2010-03-25 A | 100% | 2009-03-13 | 2010-03-25 | 271d? | finish no earlier than 2010-03-25 | S3 | 2168h | 2168h | MEDIASEC | PCG-22 | Vodafone | Peter.Howard@vodafone.com | Rel-9 | SP-43 | Mirko |  | New 33.828, 33.328 |  |
| 3450 | 896.2 | (IETF) SA3, CT1, CT3 aspects of IMS Media Plane Security | 919d? | 2009-03-18 A | 2012-09-14 A | 100% | 2009-03-18 | 2012-09-14 | 919d? | finish no earlier than 2012-09-14 | S3-IETF; C1-IETF; C3-IETF | 22056h | 22056h | MEDIASEC | PCG-27 | Peter Dawes |  | Rel-9 | SP-52 | Mirko |  | draft-dawes-dispatch-mediasec-parameter |  |
| 3451 | 896.3 | **CN aspects of IMS Media Plane Security** | 186d? | 2009-09-18 A | 2010-06-04 A | 100% | 2009-09-18 | 2010-06-04 | 186d? |  | C1; C4; C3 | 6824h | 6824h | MEDIASEC_CORE | PCG-23 | Vodafone | peter.dawes@vodafone.com | Rel-9 | CP-45 | Frederic | MEDIASEC_CORE |  |  |
| 3452 | 896.3.1 | CT1 aspects of IMS Media Plane Security | 33d? | 2009-09-18 A | 2010-03-19 A | 100% | 2009-09-18 | 2010-03-19 | 33d? | finish no earlier than 2010-03-19 | C1 | 264h | 264h | MEDIASEC_CORE | PCG-23 | Vodafone | peter.dawes@vodafone.com | Rel-9 | CP-45 | Frederic |  | 23.218, 24.229 |  |
| 3453 | 896.3.2 | CT4 aspects of IMS Media Plane Security | 131d? | 2009-09-18 A | 2010-03-19 A | 100% | 2009-09-18 | 2010-03-19 | 131d? | finish no earlier than 2010-03-19 | C4 | 1048h | 1048h | MEDIASEC_CORE | PCG-23 | Vodafone | peter.dawes@vodafone.com | Rel-9 | CP-45 | Kimmo |  | 29.238, 23.334, 29.334 |  |
| 3454 | 896.3.3 | CT3 aspects of IMS Media Plane Security | 131d? | 2009-12-04 A | 2010-06-04 A | 100% | 2009-12-04 | 2010-06-04 | 131d? | finish no earlier than 2010-06-04 | C3 | 1048h | 1048h | MEDIASEC_CORE | PCG-24 | Vodafone | peter.dawes@vodafone.com | Rel-9 | CP-46 | Adrian |  | 29.162 |  |
| 3455 | 897 | **GBAPush enhancements (Generic push layer)** | 533d? | 2008-03-12 A | 2010-03-25 A | 100% | 2008-03-12 | 2010-03-25 | 533d? |  | S3 | 8528h | 8528h | eGBAPush | PCG-23 | Ericsson | Rolf Blom | Rel-9 | SP-44 | Mirko | eGBAPush | New 33.224 |  |
| 3456 | 897.1 | SA3 part of eGBAPush (Generic push layer) | 533d? | 2008-03-12 A | 2010-03-25 A | 100% | 2008-03-12 | 2010-03-25 | 533d? | finish no earlier than 2010-03-25 | S3 | 4264h | 4264h | eGBAPush | PCG-21 | Ericsson | Rolf Blom | Rel-9 | SP-39 | Mirko |  | New 33.224 |  |
| 3457 | 898 | Extended Identity Management | 136d? | 2009-06-04 A | 2009-12-10 A | 100% | 2009-06-04 | 2009-12-10 | 136d? | finish no earlier than 2009-12-10 | S3 | 1088h | 1088h | GBA-IdM | PCG-23 | Nokia | Silke.Holtmanns@nokia.com | Rel-9 | SP-44 | Mirko | GBA-IdM | New 33.924, CT4 29.109 (added service code) |  |

Notes:
- 3434: CP#47 completed. Continues Rel-8 SAES Stage 2 UID_320005. Stage 1 in 22.278 (EPS Service requirements)
- 3435: SP#44 completed
- 3436: CP#46 completed
- 3437: CP#47 completed
- 3438: Triggered by RAN2 UID_440013 Vocoder rate adaptation for LTE
- 3439: SP#45 completed (CR adding support for Explicit Congestion Notification)
- 3440: SP#46 completed
- 3441: RP#45 completed
- 3442: SP#57 completed
- 3443: CP#57 completed
- 3444: SP#44 completed. Stopped TR 33.801. CRs 33.102,43.020 on A5/2 removal done long time ago. A5/4 introduction CRs will be done under UID_440057 128 bit encryption for GSM and GPRS. SP#26 approved WID (improved GERAN security)
- 3445: SP#46 TR 33.937 completed but no specification work done in Rel-9. Related work in OMA Categorization Based Content Screening
- 3446: SP#42 completed
- 3447: SP#46 completed. No normative work done in Rel-9
- 3448: -
- 3449: SP#47 completed
- 3450: CP#57 completed, ietf-draft discontinued, documented within 3GPP
- 3451: CP#48 completed
- 3452: CP#47 completed
- 3453: CP#47 completed
- 3454: CP#48 completed
- 3455: SP#43 umbrella to host 33.224, moved from Rel-8 to Rel-9. SP#47 completed
- 3456: SP#47 completed
- 3457: SP#46 completed. Stage 1 not identified (GBA Liberty Interworking has been outlined and GBAOpenID interworking is analogous)

| ID | WBS | Task | Duration | Start | Finish | Complete | Baseline start | Baseline finish | Baseline duration | Constraint | Resources | Work | Actual work | Acronym | PCG approved | WI rapporteur name | Release | TSG approved | MCC resp | Acronym_3GU_Export | PCG stopped | TSG stopped |
| --- | --- | --- | --- | --- | --- | --- | --- | --- | --- | --- | --- | --- | --- | --- | --- | --- | --- | --- | --- | --- | --- | --- |
| 3458 | 899 | **Network Domain Security (NDS) enhancements to support backhaul security** | 924d? | 2009-06-04 A | 2012-12-07 A | 100% | 2009-06-04 | 2012-12-07 | 924d? |  | S3; IETF | 23452.8h | 23452.8h | NDS_Backhaul | PCG-23 | Vodafone | Rel-9 | SP-44 | Mirko | NDS_Backhaul |  |  |
| 3459 | 899.1 | SA3 part of Network Domain Security (NDS) enhancements to support backhaul security | 211d? | 2009-06-04 A | 2010-03-25 A | 100% | 2009-06-04 | 2010-03-25 | 211d? | finish no earlier than 2010-03-25 | S3 | 1688h | 1688h | NDS_Backhaul | PCG-23 | Vodafone | Rel-9 | SP-44 | Mirko |  |  |  |
| 3460 | 899.2 | (IETF) SA3 part of Network Domain Security (NDS) enhancements to support backhaul security | 740.6d? | 2009-06-04 A | 2012-12-07 A | 100% | 2009-06-04 | 2012-12-07 | 740.6d? | finish no earlier than 2012-12-07 | S3-IETF | 5924.8h | 5924.8h | NDS_Backhaul | PCG-27 | Bengt Sahlin | Rel-9 | SP-52 | Mirko |  |  |  |
| 3461 | 899.3 | Deleted - CT4 part of Network Domain Security (NDS) enhancements to support backhaul security | 132d? | 2009-06-04 A | 2009-12-04 A | 100% | 2009-06-04 | 2009-12-04 | 132d? | finish no earlier than 2009-12-04 | C4 | 1056h | 1056h | NDS_Backhaul | PCG-23 | Vodafone | Rel-9 | SP-44 | Kimmo |  | PCG-24 | CP-46 |
| 3462 | 900 | **128 bit encryption for GSM and GPRS** | 136d? | 2009-06-04 A | 2009-12-10 A | 100% | 2009-06-04 | 2009-12-10 | 136d? |  | S3; C1; C4; G2; G3new | 10392h | 10392h | A5/4-GEA4 | PCG-23 | Ericsson | Rel-9 | SP-44 | Mirko | A5/4-GEA4 |  |  |
| 3463 | 900.1 | SA3 part of 128 bit encryption for GSM and GPRS | 136d? | 2009-06-04 A | 2009-12-10 A | 100% | 2009-06-04 | 2009-12-10 | 136d? | finish no earlier than 2010-01-06 | S3 | 1088h | 1088h | A5/4-GEA4 | PCG-23 | Ericsson | Rel-9 | SP-44 | Mirko |  |  |  |
| 3464 | 900.2 | CT1 part of 128 bit encryption for GSM and GPRS | 77d? | 2009-06-04 A | 2009-09-18 A | 100% | 2009-06-04 | 2009-09-18 | 77d? | start no earlier than 2009-06-04 | C1 | 616h | 616h | A5/4-GEA4 | PCG-23 | Ericsson | Rel-9 | SP-44 | Frederic |  |  |  |
| 3465 | 900.3 | CT4 part of 128 bit encryption for GSM and GPRS | 136d? | 2009-06-04 A | 2009-12-10 A | 100% | 2009-06-04 | 2009-12-10 | 136d? | start no earlier than 2009-06-04 | C4 | 1088h | 1088h | A5/4-GEA4 | PCG-23 | Ericsson | Rel-9 | SP-44 | Kimmo |  |  |  |
| 3466 | 900.4 | GERAN2 part of 128 bit encryption for GSM and GPRS | 67d? | 2009-06-04 A | 2009-09-04 A | 100% | 2009-06-04 | 2009-09-04 | 67d? | finish no earlier than 2009-09-04 | G2 | 536h | 536h | A5/4-GEA4 | PCG-23 | Ericsson | Rel-9 | SP-44 | Gert |  |  |  |
| 3467 | 900.5 | GERAN3new (testing) part of 128 bit encryption for GSM and GPRS | 122d? | 2009-06-04 A | 2009-11-20 A | 100% | 2009-06-04 | 2009-11-20 | 122d? | finish no earlier than 2009-11-20 | G3new | 976h | 976h | A5/4-GEA4 | PCG-23 | Ericsson | Rel-9 | SP-44 | Ingbert |  |  |  |
| 3468 | 900.6 | Deleted - SA2 part of 128 bit encryption for GSM and GPRS | 81d? | 2009-06-04 A | 2009-09-24 A | 100% | 2009-06-04 | 2009-09-24 | 81d? | finish no earlier than 2009-09-24 | S2 | 648h | 648h | A5/4-GEA4 | PCG-23 | Ericsson | Rel-9 | SP-44 | Maurice |  | PCG-23 | SP-45 |
| 3469 | 901 | Timed Graphics | 337d? | 2008-12-11 A | 2010-03-25 A | 100% | 2008-12-11 | 2010-03-25 | 337d? | finish no earlier than 2010-03-25 | S4 | 2696h | 2696h | TG | PCG-22 | Ericsson | Rel-9 | SP-42 | Paolo | TG |  |  |
| 3470 | 902 | Managing MTSI Media Adaptation | 197d? | 2009-03-12 A | 2009-12-10 A | 100% | 2009-03-12 | 2009-12-10 | 197d? | finish no earlier than 2009-12-10 | S4 | 1568h | 1568h | M3A | PCG-22 | Samsung | Rel-9 | SP-43 | Paolo | M3A |  |  |
| 3471 | 903 | **PSS and MBMS Aspects** | 272d? | 2009-03-12 A | 2010-03-25 A | 100% | 2009-03-12 | 2010-03-25 | 272d? |  | S4 | 6512h | 6512h | PMA | PCG-23 | Ericsson, Nokia | Rel-9 | SP-44 | Paolo | PMA |  |  |
| 3472 | 903.1 | PSS and MBMS extensions | 271d? | 2009-03-12 A | 2010-03-25 A | 100% | 2009-03-12 | 2010-03-25 | 271d? | finish no earlier than 2010-03-25 | S4 | 2168h | 2168h | PMA-MBS_Ext | PCG-22 | Ericsson | Rel-9 | SP-43 | Paolo | PMA-MBS_Ext |  |  |
| 3473 | 903.2 | Improved Video Support for PSS and MBMS | 271d? | 2009-03-12 A | 2010-03-25 A | 100% | 2009-03-12 | 2010-03-25 | 271d? | finish no earlier than 2010-03-25 | S4 | 2168h | 2168h | PMA-IVS | PCG-22 | Nokia | Rel-9 | SP-43 | Paolo | PMA-IVS |  |  |
| 3474 | 904 | IMS based PSS and MBMS User Service extensions | 197d? | 2009-03-12 A | 2009-12-10 A | 100% | 2009-03-12 | 2009-12-10 | 197d? | finish no earlier than 2009-12-10 | S4 | 1576h | 1576h | IMS_PSS_MBMS_US_EXT | PCG-22 | Ericsson | Rel-9 | SP-43 | Paolo | IMS_PSS_MBMS_US_EXT |  |  |
| 3475 | 905 | Syndicated Feed Reception within 3GPP environments | 136d? | 2009-06-04 A | 2009-12-10 A | 100% | 2009-06-04 | 2009-12-10 | 136d? | start no earlier than 2009-06-04 | S4 | 1088h | 1088h | SFR | PCG-23 | Ericsson | Rel-9 | SP-44 | Paolo | SFR |  |  |
| 3476 | 906 | Distortion Measurement Test Methods and Requirements | 131d? | 2009-09-24 A | 2010-03-25 A | 100% | 2009-09-24 | 2010-03-25 | 131d? | finish no earlier than 2010-03-25 | S4 | 1048h | 1048h | DTMR | PCG-23 | Motorola | Rel-9 | SP-45 | Paolo | DTMR |  |  |
| 3477 | 907 | **Rel-9 Operations, Administration, Maintenance and Provisioning (OAM&P)** | 601d? | 2008-02-22 A | 2010-06-10 A | 100% | 2008-02-22 | 2010-06-10 | 601d? |  | S5 | 36890.4h | 36890.4h | OAM9 | PCG-22 |  | Rel-9 | SP-42 | Mirko | OAM9 |  |  |
| 3478 | 907.1 | **Rel-9 Network Infrastructure Management** | 337d? | 2008-12-11 A | 2010-03-25 A | 100% | 2008-12-11 | 2010-03-25 | 337d? |  | S5 | 8760h | 8760h | OAM9-NIM | PCG-22 |  | Rel-9 | SP-42 | Mirko | OAM9-NIM |  |  |
| 3479 | 907.1.1 | Software Management for Network Elements | 336d? | 2008-12-11 A | 2010-03-25 A | 100% | 2008-12-11 | 2010-03-25 | 336d? | finish no earlier than 2010-03-25 | S5 | 2688h | 2688h | OAM9-NE_SWM | PCG-22 | Huawei, Nokia Siemens Networks | Rel-9 | SP-42 | Mirko | OAM9-NE_SWM |  |  |
| 3480 | 907.1.2 | Service Oriented Architecture (SOA) for IRP | 211d? | 2009-06-04 A | 2010-03-25 A | 100% | 2009-06-04 | 2010-03-25 | 211d? | finish no earlier than 2010-03-25 | S5 | 1688h | 1688h |  | PCG-23 | Ericsson, Nokia Siemens Networks | Rel-9 | SP-44 | Mirko |  |  |  |
| 3481 | 907.1.3 | IRP SOAP Solution Sets continuation from Rel-8 | 211d? | 2009-06-04 A | 2010-03-25 A | 100% | 2009-06-04 | 2010-03-25 | 211d? | finish no earlier than 2010-03-25 | S5 | 1688h | 1688h |  | PCG-23 | Ericsson | Rel-9 | SP-44 | Mirko |  |  |  |

Notes:
- 3458: Continuation of Rel-8 UID_390044 SAE security architecture. Covers gaps in backhaul security in SAE (also applicable to UTRAN and GERAN backhaul) / WI rapporteur e-mail: Peter.Howard@vodafone.com
- 3459: SP#47 completed / Impacted TSs and TRs: 33.102, 33.210, 33.310, 33.401, 33.402 / WI rapporteur e-mail: Peter.Howard@vodafone.com
- 3460: CP#58 completed / Impacted TSs and TRs: RFC 6712 (was draft-ietf-pkix-cmp-transport-protocols)
- 3461: CP#46 completed. No impact on CT4 specs / WI rapporteur e-mail: Peter.Howard@vodafone.com
- 3462: Allow 128 as an alternative to 64 bit keys (Stage 2/3 + Test spec) / WI rapporteur e-mail: Karl Norrman
- 3463: SP#46 completed / Impacted TSs and TRs: 33.102,43.020, New 55.226 / WI rapporteur e-mail: Karl Norrman
- 3464: CP#45 completed / Impacted TSs and TRs: 24.008,44.064 / WI rapporteur e-mail: Karl Norrman
- 3465: CP#46 completed. Kc128 enhancements are carried as UMTS keys => no impact on CT4 29.002, 29.060 / WI rapporteur e-mail: Karl Norrman
- 3466: GP#43 WID approved + completed / Impacted TSs and TRs: 44.018,48.008,48.018,48.058 / WI rapporteur e-mail: Karl Norrman
- 3467: GP#44 completed. GP#43 WID approved / Impacted TSs and TRs: 51.010 / WI rapporteur e-mail: Karl Norrman
- 3468: SP#45 work stopped/abandoned / Impacted TSs and TRs: 23.060 / WI rapporteur e-mail: Karl Norrman
- 3469: SP#47 completed. Provide graphics in parallel to a video stream (without requiring an umbrella scene descriptor such as 3GPP DIMS in TS 26.142) / Impacted TSs and TRs: 26.114, 26.140, 26.234, 26.244, 26.245, 26.346, New 26.430 / WI rapporteur e-mail: clinton.priddle@ericsson.com
- 3470: SP#46 completed. Work extending Rel-8 UID_34041 MTSI Video - Dynamic Rate Adaptation/Signalling of Image Size. Update speech/video adaptation algorithms used by network to control MTSI client terminal in congestion or poor transmission conditions. / Impacted TSs and TRs: 26.114 / WI rapporteur e-mail: kyunghun.jung@samsung.com
- 3471: Umbrella WI / WI rapporteur e-mail: Clinton.Priddle@ericsson.com, imed.bouazizi@nokia.com
- 3472: SP#47 completed. Extends Rel-8 UID_34043 (PSS_MBMS_OMTV) & ensures compatibility with UID_34046 (IMS_PSS_MBMS_US) / Impacted TSs and TRs: 26.234, 26.346 / WI rapporteur e-mail: Clinton.Priddle@ericsson.com
- 3473: SP#47 completed / Impacted TSs and TRs: 26.234, 26.244, 26.346, new 26.903 / WI rapporteur e-mail: imed.bouazizi@nokia.com
- 3474: SP#46 completed. Work extending Rel-8 UID_34046 (IMS_PSS_MBMS_US), SA2 UID_410034 IMSSCC-SPI (IMS Service Continuity Enhancements: Service, Policy and Interactions) / Impacted TSs and TRs: 26.237 / WI rapporteur e-mail: Markus Kampmann
- 3475: SP#46 completed. TS 26.150v100 for Approval. RSS optimized for mobile use. Reuse/reference OMA's enabler DCD. / Impacted TSs and TRs: New 26.150 / WI rapporteur e-mail: Thorsten.Lohmar@ericsson.com
- 3476: SP#47 completed / Impacted TSs and TRs: 26.131, 26.132 / WI rapporteur e-mail: Stephen Kendall (wcsk01@motorola.com)
- 3477: OAM9 is an umbrella Feature also for OAM&P related TEI9 type of changes that are not part of any other dedicated feature/WI / Impacted TSs and TRs: TR 30.819
- 3478: SP#42 umbrella BB created to host OAM WIs
- 3479: SP#47 completed / Impacted TSs and TRs: 32.531, 32.532, 32.533, new 32.537 / WI rapporteur e-mail: Bidipta Das (bidipta@huawei.com), Clemens Suerbaum (clemens.suerbaum@nsn.com)
- 3480: SP#47 completed (covering SOA Architecture & SOA-supporting Solution Set). Triggered by UID_400029 Study on Service Oriented Architecture (SOA) for IRP (TR 32.824) / Impacted TSs and TRs: 32.101, 32.102, 32.150 / WI rapporteur e-mail: edwin.tse@ericsson.com, Jörg Schmidt (joerg@cox.net)
- 3481: SP#47 completed. Continuation of Rel-8 UID_400030 IRP SOAP Solution Sets / Impacted TSs and TRs: New (32.127/ 327/ 337/ 357/ 387/ 397/ 447/ 397/ 447/ 507/ 537), 32.121,32.122,32.123,32,32.321,32.322,32.323,32.325,32.331,32.332,32.333,32.335,32.351,32.352,32.353,32.381,32.382,32.383,32.385,32.391,32.392,32.393,32.395,32.441,32.442,32.443 / WI rapporteur e-mail: John Power

| ID | WBS | Task | Duration | Start | Finish | Complete | Baseline start | Baseline finish | Baseline duration | Constraint | Resources | Work | Actual work | Acronym | PCG approved | Release | TSG approved | MCC resp | Acronym_3GU_Export | Impacted TSs and TRs | WI rapporteur name | Special Focus Doc | PCG stopped | TSG stopped |
| --- | --- | --- | --- | --- | --- | --- | --- | --- | --- | --- | --- | --- | --- | --- | --- | --- | --- | --- | --- | --- | --- | --- | --- | --- |
| 3482 | 907.2 | **Rel-9 Performance Management** | 327d? | 2009-03-12 A | 2010-06-10 A | 100% | 2009-03-12 | 2010-06-10 | 327d? |  | S5 | 7890.41h | 7890.41h | OAM9-PM | PCG-22 | Rel-9 | SP-42 | Mirko | OAM9-PM |  |  |  |  |  |
| 3483 | 907.2.1 | Enhancement of UTRAN Performance Measurements | 136d? | 2009-06-04 A | 2009-12-10 A | 100% | 2009-06-04 | 2009-12-10 | 136d? | start no earlier than 2009-06-04 | S5 | 1088h | 1088h |  | PCG-23 | Rel-9 | SP-44 | Mirko |  | 32.405 | China Mobile |  |  |  |
| 3484 | 907.2.2 | Enhancement of E-UTRAN Performance Measurements | 327d? | 2009-03-12 A | 2010-06-10 A | 100% | 2009-03-12 | 2010-06-10 | 327d? | finish no earlier than 2010-06-10 | S5 | 2616h | 2616h |  | PCG-22 | Rel-9 | SP-43 | Mirko |  | 32.425 | Motorola, Huawei |  |  |  |
| 3485 | 907.2.3 | Enhancement of EPC Performance Measurements | 197d? | 2009-03-12 A | 2009-12-10 A | 100% | 2009-03-12 | 2009-12-10 | 197d? | finish no earlier than 2010-03-25 | S5 | 1570.41h | 1570.41h |  | PCG-22 | Rel-9 | SP-43 | Mirko |  | 32.426 | China Mobile |  |  |  |
| 3486 | 907.3 | **Rel-9 Self-Organizing Networks (SON) - OAM aspects** | 601d? | 2008-02-22 A | 2010-06-10 A | 100% | 2008-02-22 | 2010-06-10 | 601d? |  | S5 | 11736h | 11736h | OAM9-SON | PCG-22 | Rel-9 | SP-43 | Mirko | OAM9-SON |  |  | SON |  |  |
| 3487 | 907.3.1 | SON self-optimization management (moved from Rel-8 LTE_SON-OAM) | 600d? | 2008-02-22 A | 2010-06-10 A | 100% | 2008-02-22 | 2010-06-10 | 600d? | finish no earlier than 2010-06-10 | S5 | 4800h | 4800h |  | PCG-21 | Rel-9 | SP-39 | Mirko |  | 32.425, new (32.521, 32.522, 32.523, 32.525) | Huawei | SON |  |  |
| 3488 | 907.3.2 | Automatic Radio Network Configuration Data Preparation | 266d? | 2009-06-04 A | 2010-06-10 A | 100% | 2009-06-04 | 2010-06-10 | 266d? | finish no earlier than 2010-06-10 | S5 | 2128h | 2128h |  | PCG-23 | Rel-9 | SP-44 | Mirko |  | 32.501, 32.502, 32.503, 32.505, new 32.507 | Nokia Siemens Networks | SON |  |  |
| 3489 | 907.4 | Rel-9 Subscription Management (SuM) evolution | 266d? | 2009-06-04 A | 2010-06-10 A | 100% | 2009-06-04 | 2010-06-10 | 266d? | finish no earlier than 2010-06-10 | S5 | 2128h | 2128h | OAM9-SuM | PCG-23 | Rel-9 | SP-44 | Mirko | OAM9-SuM | 32.140, 32.141, 32.152, 32.172, 32.175 | Ericsson |  |  |  |
| 3490 | 907.5 | Deleted - Rel-9 Trace | 196d? | 2009-03-13 A | 2009-12-10 A | 100% | 2009-03-13 | 2009-12-10 | 196d? | finish no earlier than 2009-12-10 | S5 | 1568h | 1568h | OAM9-Trace | PCG-22 | Rel-9 | SP-42 | Mirko | OAM9-Trace |  |  |  | PCG-24 | SP-46 |
| 3491 | 908 | Rel-9 Charging Management small Enhancements | 211d? | 2009-06-04 A | 2010-03-25 A | 100% | 2009-06-04 | 2010-03-25 | 211d? |  | S5 | 1688h | 1688h | CH9 | PCG-23 | Rel-9 | SP-44 | Mirko | CH9 | TR 30.819 |  |  |  |  |
| 3492 | 909 | **CS-IBCF and CS-TrGW definition in 3GPP specifications** | 472d? | 2008-05-30 A | 2010-03-19 A | 100% | 2008-05-30 | 2010-03-19 | 472d? |  | C3; C4 | 14490.3h | 14490.3h | CS-IBCF | PCG-21 | Rel-9 | CP-40 | Adrian | CS-IBCF |  | Telecom Italia |  |  |  |
| 3493 | 909.1 | CT3 aspects of CS-IBCF and CS-TrGW definition in 3GPP specifications | 472d? | 2008-05-30 A | 2010-03-19 A | 100% | 2008-05-30 | 2010-03-19 | 472d? | finish no earlier than 2009-12-04 | C3 | 3770.34h | 3770.34h | CS-IBCF | PCG-21 | Rel-9 | CP-40 | Adrian |  | 29.235 | Telecom Italia |  |  |  |
| 3494 | 909.2 | CT4 aspects of CS-IBCF and CS-TrGW definition in 3GPP specifications | 396d? | 2008-05-30 A | 2009-12-04 A | 100% | 2008-05-30 | 2009-12-04 | 396d? | finish no earlier than 2009-12-04 | C4 | 3168h | 3168h | CS-IBCF | PCG-21 | Rel-9 | CP-40 | Kimmo |  | 23.231, 29.232, new 29.238 | Telecom Italia |  |  |  |
| 3495 | 910 | **IMS – Interconnection Border Control Function (IBCF) – Transition Gateway (TrGW); Ix Interface; Stage 3** | 322d? | 2008-09-12 A | 2009-12-04 A | 100% | 2008-09-12 | 2009-12-04 | 322d? |  | C4; C3 | 10086.4h | 10086.4h | IMS_IBCF | PCG-21 | Rel-9 | CP-41 | Kimmo | IMS_IBCF |  | Alcatel-Lucent |  |  |  |
| 3496 | 910.1 | CT4 part of IMS – Interconnection Border Control Function (IBCF) – Transition Gateway (TrGW); Ix Interface; Stage 3 | 321d? | 2008-09-12 A | 2009-12-04 A | 100% | 2008-09-12 | 2009-12-04 | 321d? | finish no earlier than 2009-12-04 | C4 | 2568h | 2568h | IMS_IBCF | PCG-21 | Rel-9 | CP-41 | Kimmo |  | new 29.238 | Alcatel-Lucent |  |  |  |
| 3497 | 910.2 | CT3 part of IMS – Interconnection Border Control Function (IBCF) – Transition Gateway (TrGW); Ix Interface; Stage 3 | 295.8d? | 2008-09-12 A | 2009-12-04 A | 100% | 2008-09-12 | 2009-12-04 | 295.8d? | finish no earlier than 2010-03-19 | C3 | 2366.4h | 2366.4h | IMS_IBCF | PCG-21 | Rel-9 | CP-41 | Adrian |  | 29.162, 29.235 | Alcatel-Lucent |  |  |  |
| 3498 | 911 | IMS Application Level Gateway Control Function (ALGCF) – IMS Access Media Gateway (IMA-MGW); Iq Interface; Stage 2 and Stage 3 | 321d? | 2008-09-12 A | 2009-12-04 A | 100% | 2008-09-12 | 2009-12-04 | 321d? | finish no earlier than 2009-12-04 | C4 | 2568h | 2568h | IMS_AGCF | PCG-21 | Rel-9 | CP-41 | Kimmo | IMS_AGCF | New 23.334, 29.334 | Alcatel-Lucent |  |  |  |
| 3499 | 912 | **Enhancements of IMS Customized Alerting Tone (CAT) Service** | 392d? | 2008-12-05 A | 2010-06-04 A | 100% | 2008-12-05 | 2010-06-04 | 392d? |  | C1 | 5846.4h | 5846.4h | eCAT | PCG-22 | Rel-9 | CP-42 | Frederic | eCAT |  | China Mobile |  |  |  |
| 3500 | 912.1 | Stage 3 for Enhancements of IMS Customized Alerting Tone (CAT) Service | 391d? | 2008-12-05 A | 2010-06-04 A | 100% | 2008-12-05 | 2010-06-04 | 391d? | finish no earlier than 2010-06-04 | C1 | 3128h | 3128h | eCAT-SS | PCG-22 | Rel-9 | CP-42 | Frederic | eCAT-SS | 24.182 | China Mobile |  |  |  |
| 3501 | 913 | **Completion of IMS Restoration Procedures** | 212d? | 2009-05-29 A | 2010-03-19 A | 100% | 2009-05-29 | 2010-03-19 | 212d? |  | C3; C4; C1 | 10176h | 10176h | eIMS_RP | PCG-23 | Rel-9 | CP-44 | Kimmo | eIMS_RP |  | Ericsson |  |  |  |
| 3502 | 913.1 | CT4 aspects of Completion of IMS Restoration Procedures | 212d? | 2009-05-29 A | 2010-03-19 A | 100% | 2009-05-29 | 2010-03-19 | 212d? | finish no earlier than 2010-03-19 | C4 | 1696h | 1696h | eIMS_RP | PCG-23 | Rel-9 | CP-44 | Kimmo |  | 23.380, 23.820 | Ericsson |  |  |  |
| 3503 | 913.2 | CT1 aspects of Completion of IMS Restoration Procedures | 212d? | 2009-05-29 A | 2010-03-19 A | 100% | 2009-05-29 | 2010-03-19 | 212d? | finish no earlier than 2010-03-19 | C1 | 1696h | 1696h | eIMS_RP | PCG-23 | Rel-9 | CP-44 | Kimmo |  | 24.229 | Ericsson |  |  |  |
| 3504 | 913.3 | CT3 aspects of Completion of IMS Restoration Procedures | 212d? | 2009-05-29 A | 2010-03-19 A | 100% | 2009-05-29 | 2010-03-19 | 212d? | finish no earlier than 2010-03-19 | C3 | 1696h | 1696h | eIMS_RP | PCG-24 | Rel-9 | CP-46 | Kimmo |  | 29.061, 29.212, 29.213, 29.214, 29.215 | Ericsson |  |  |  |
| 3505 | 914 | **IMS Stage 3 IETF Protocol Alignment - phase 3** | 1458d? | 2009-05-29 A | 2014-12-05 A | 100% | 2009-05-29 | 2014-12-05 | 1455d? |  | C1; IETF | 40216h | 40216h | IMSProtoc3 | PCG-23 | Rel-9 | CP-44 | Frederic | IMSProtoc3 |  | Alcatel-Lucent |  |  |  |
| 3506 | 914.1 | CT1 aspects of IMS Stage 3 - IETF Protocol Alignment - phase 3 | 212d? | 2009-05-29 A | 2010-03-19 A | 100% | 2009-05-29 | 2010-03-19 | 212d? | finish no earlier than 2010-03-19 | C1 | 1696h | 1696h | IMSProtoc3 | PCG-23 | Rel-9 | CP-44 | Frederic |  | 23.218, 24.229, 24.930 | Alcatel-Lucent |  |  |  |
| 3507 | 914.2 | (IETF) CT1 IMS Stage 3 - IETF Protocol Alignment (RFC 7329) | 1242d? | 2009-05-29 A | 2014-12-05 A | 100% | 2009-05-29 | 2014-12-05 | 1240d? | finish no earlier than 2014-12-09 | C1-IETF | 9936h | 9936h | IMSProtoc3 | PCG-27 | Rel-9 | CP-52 | Frederic |  | RFC 7329 (was draft-kaplan-insipid-session-id) | christer.holmberg@ericsson.com |  |  |  |
| 3508 | 914.3 | (IETF) CT1 IMS Stage 3 - IETF Protocol Alignment (RFC 7044) | 659d? | 2011-09-13 A | 2014-03-07 A | 100% | 2011-09-13 | 2014-03-07 | 659d? | finish no earlier than 2014-02-10 | C1-IETF | 5256h | 5256h | IMSProtoc3 | PCG-27 | Rel-9 | CP-53 | Frederic |  | RFC 7044 (was draft-ietf-sipcore-rfc4244bis) | christer.holmberg@ericsson.com |  |  |  |

Notes:
- 3482: SP#42 umbrella BB created to host OAM WIs
- 3483: SP#46 completed / WI rapporteur e-mail: liangshuangchun@cmdi.chinamobile.com, lijian@chinamobile.com, Bao Haitao
- 3484: SP#48 completed / WI rapporteur e-mail: Yizhi Yao (yzyao@motorola.com),Lan Zou (zlan@huawei.com)
- 3485: SP#46 completed / WI rapporteur e-mail: Li Jian (lijian@chinamobile.com), Liang Shuangchun (liangshuangchun@cmdi.chinamobile.com)
- 3486: SP#43 umbrella BB created to host OAM WIs
- 3487: SP#48 completed / WI rapporteur e-mail: Lan Zou (zlan@huawei.com)
- 3488: SP#48 completed / WI rapporteur e-mail: clemens.suerbaum@nsn.com
- 3489: SP#48 completed / WI rapporteur e-mail: frode.nergard@ericsson.com
- 3490: SP#46 stopped (no work in Rel-9)
- 3491: CH9 is an umbrella Feature also for OAM&P related TEI9 type of changes that are not part of any other dedicated feature/WI
- 3492: CP#47 completed. Rel-8 UID_380061 (Ipinterc) covers Stage 1 in SA1 22.101, 22.228 / WI rapporteur e-mail: mauro.ficaccio@telecomitalia.it
- 3493: CP#47 completed / WI rapporteur e-mail: mauro.ficaccio@telecomitalia.it
- 3494: CP#46 completed / WI rapporteur e-mail: mauro.ficaccio@telecomitalia.it
- 3495: CP#46 completed / WI rapporteur e-mail: bruno.landais@alcatel-lucent.fr
- 3496: CP#46 completed / WI rapporteur e-mail: bruno.landais@alcatel-lucent.fr
- 3497: CP#46 completed / WI rapporteur e-mail: bruno.landais@alcatel-lucent.fr
- 3498: CP#46 completed / WI rapporteur e-mail: bruno.landais@alcatel-lucent.fr
- 3499: CP#48 completed. Stage 1 in 22.182 / WI rapporteur e-mail: Jiang Yi
- 3500: CP#48 completed / WI rapporteur e-mail: Jiang Yi
- 3501: CP#47 completed. Continuation of Rel-8 Feature UID_400012 IMS Restoration Procedures / WI rapporteur e-mail: Emiliano Merino (emiliano.merino@ericsson.com)
- 3502: CP#47 completed / WI rapporteur e-mail: Emiliano Merino (emiliano.merino@ericsson.com)
- 3503: CP#47 completed / WI rapporteur e-mail: Emiliano Merino (emiliano.merino@ericsson.com)
- 3504: CP#47 completed / WI rapporteur e-mail: Emiliano Merino (emiliano.merino@ericsson.com)
- 3505: CP#47 completed / WI rapporteur e-mail: Keith Drage (drage@alcatel-lucent.com)
- 3506: CP#47 completed / WI rapporteur e-mail: Keith Drage (drage@alcatel-lucent.com)
- 3507: CP#65 completed / WI rapporteur e-mail: christer.holmberg@ericsson.com
- 3508: CP#63 completed / WI rapporteur e-mail: christer.holmberg@ericsson.com

| ID | WBS | Task | Type | Duration | Start | Finish | Complete | Baseline start | Baseline finish | Baseline duration | Constraint | Resources | Work | Actual work | Acronym | PCG approved | WI rapporteur name | WI rapporteur e-mail | Release | TSG approved | MCC resp | Acronym_3GU_Export | TSG stopped | Special Focus Doc | Status Report |
| --- | --- | --- | --- | --- | --- | --- | --- | --- | --- | --- | --- | --- | --- | --- | --- | --- | --- | --- | --- | --- | --- | --- | --- | --- | --- |
| 3509 | 915 | **Operational description of the Inter-IMS Network to Network Interface (II-NNI)** |  | 1460d? | 2009-05-29 A | 2014-12-09 A | 100% | 2009-05-29 | 2014-12-05 | 1455d? |  | C3; IETF | 58408h | 58408h | II-NNI | PCG-23 | Orange | sebastien.daudet@orange-ftgroup.com | Rel-9 | CP-44 | Adrian | II-NNI |  |  |  |
| 3510 | 915.1 | Operational description of the Inter-IMS Network to Network Interface |  | 267d? | 2009-05-29 A | 2010-06-04 A | 100% | 2009-05-29 | 2010-06-04 | 267d? | start no earlier than 2009-05-29 | C3 | 2136h | 2136h | II-NNI | PCG-23 | Orange |  | Rel-9 | CP-44 | Adrian |  |  |  |  |
| 3511 | 915.2 | (IETF) Operational description of the Inter-IMS Network to Network Interface (RFC 7329) |  | 633d? | 2012-04-20 A | 2014-09-12 A | 100% | 2012-04-20 | 2014-12-05 | 693d? | finish no earlier than 2014-09-12 | C3-IETF | 5040h | 5040h | II-NNI | PCG-29 | christer.holmberg@ericsson.com | christer.holmberg@ericsson.com | Rel-9 | CP-56 | Adrian |  |  |  |  |
| 3512 | 915.3 | (IETF) Operational description of the Inter-IMS Network to Network Interface (RFC 7316) |  | 634d? | 2012-04-20 A | 2014-09-12 A | 100% | 2012-04-20 | 2014-12-05 | 694d? | finish no earlier than 2014-12-09 | C3-IETF | 5064h | 5064h | II-NNI | PCG-29 | Keith Drage | Keith Drage | Rel-9 | CP-56 | Adrian |  |  |  |  |
| 3513 | 915.4 | (IETF) Operational description of the Inter-IMS Network to Network Interface |  | 696d? | 2012-04-20 A | 2014-12-09 A | 100% | 2012-04-20 | 2014-12-05 | 694d? | finish no earlier than 2014-12-09 | C3-IETF | 5560h | 5560h | II-NNI | PCG-29 | Roland Jesske | Roland Jesske | Rel-9 | CP-56 | Adrian |  |  |  |  |
| 3514 | 915.5 | (IETF) Operational description of the Inter-IMS Network to Network Interface |  | 696d? | 2012-04-20 A | 2014-12-09 A | 100% | 2012-04-20 | 2014-12-05 | 694d? | finish no earlier than 2014-12-09 | C3-IETF | 5536h | 5536h | II-NNI | PCG-29 | Roland Jesske | Roland Jesske | Rel-9 | CP-56 | Adrian |  |  |  |  |
| 3515 | 915.6 | (IETF) Operational description of the Inter-IMS Network to Network Interface |  | 697d? | 2012-04-20 A | 2014-12-09 A | 100% | 2012-04-20 | 2014-12-05 | 695d? | finish no earlier than 2014-12-09 | C3-IETF | 5560h | 5560h | II-NNI | PCG-29 | Keith Drage | Keith Drage | Rel-9 | CP-56 | Adrian |  |  |  |  |
| 3516 | 915.7 | Deleted - (IETF) Operational description of the Inter-IMS Network to Network Interface |  | 433d? | 2012-04-20 A | 2013-12-06 A | 100% | 2012-04-20 | 2014-12-05 | 694d? | finish no earlier than 2013-12-06 | C3-IETF | 3456h | 3456h | II-NNI | PCG-29 | Peter Dawes | peter.dawes@vodafone.com | Rel-9 | CP-56 | Adrian |  | SP-69 |  |  |
| 3517 | 915.8 | Deleted - (IETF) Operational description of the Inter-IMS Network to Network Interface (avasarala-dispatch-comm-div-notification) |  | 340d? | 2013-03-01 A | 2014-06-13 A | 100% | 2013-03-01 | 2014-06-13 | 340d? | finish no earlier than 2014-06-13 | C3-IETF | 2696h | 2696h | II-NNI | PCG-30 | Andrew Allen | Andrew Allen | Rel-9 | CP-59 | Adrian |  | SP-69 |  |  |
| 3518 | 916 | Definition of Ml interface for Control Plane LCS (Stage 3) |  | 131d? | 2009-09-18 A | 2010-03-19 A | 100% | 2009-09-18 | 2010-03-19 | 131d? | finish no earlier than 2010-03-19 | C1 | 1048h | 1048h | EMC2 | PCG-23 | Alcatel-Lucent | Keith Drage (drage@alcatel-lucent.com) | Rel-9 | CP-45 | Frederic | EMC2 |  | Public Safety (I-A) |  |
| 3519 | 917 | PCC enhancements |  | 56d? | 2009-09-18 A | 2009-12-04 A | 100% | 2009-09-18 | 2009-12-04 | 56d? | finish no earlier than 2009-12-04 | C3 | 448h | 448h | PCC-Enh | PCG-23 | Huawei | Wei Weihua (weiwh@huawei.com) | Rel-9 | CP-45 | Adrian | PCC-Enh |  |  |  |
| 3520 | 918 | 3GPP IMS Conferencing Management Object (MO) |  | 2d? | 2009-12-03 A | 2009-12-04 A | 100% | 2009-12-03 | 2009-12-04 | 2d? | start no earlier than 2009-12-03 | C1 | 16h | 16h | IMS_ConfMO | PCG-24 |  |  | Rel-9 | CP-46 | Frederic | IMS_ConfMO |  |  |  |
| 3521 | 919 | In Case of Emergency (ICE) Graphics |  | 3d? | 2010-03-17 A | 2010-03-19 A | 100% | 2010-03-17 | 2010-03-19 | 3d? | finish no earlier than 2010-03-19 | C6 | 24h | 24h | ICE_Graphics | PCG-24 | Sagem-Orga | heiko.kruse@sagem-orga.com | Rel-9 | CP-47 | Xavier | ICE_Graphics |  |  |  |
| 3522 | 920 | **Rel-9 Improvements of the Radio Interface** |  | 397d? | 2008-09-12 A | 2010-03-19 A | 100% | 2008-09-12 | 2010-03-19 | 397d? |  | RP; GP | 19744h | 19744h | RInImp9 | PCG-21 |  |  | Rel-9 | RP-41 | Issam | RInImp9 |  |  |  |
| 3523 | 920.1 | LCR TDD UE OTA Performance Requirements |  | 186d? | 2008-09-12 A | 2009-05-29 A | 100% | 2008-09-12 | 2009-05-29 | 186d? | finish no earlier than 2009-05-29 | R4 | 1488h | 1488h | RInImp9-RFLCROTA | PCG-21 | RITT | Wu Xiang (wuxiang@chinattl.com) | Rel-9 | RP-41 | Issam | RInImp9-RFLCROTA |  |  | RP-090389 |
| 3524 | 920.2 | **RF requirements for Multicarrier and Multi-RAT BS** |  | 347d? | 2008-11-21 A | 2010-03-19 A | 100% | 2008-11-21 | 2010-03-19 | 347d? |  | R4; G1 | 10336h | 10336h | RInImp9-RFmulti | PCG-21 | Ericsson | Johan.skold@ericsson.com | Rel-9 | RP-41 | Issam | RInImp9-RFmulti |  |  |  |
| 3525 | 920.2.1 | RAN4 part of RF requirements for Multicarrier and Multi RAT BS |  | 337d? | 2008-12-05 A | 2010-03-19 A | 100% | 2008-12-05 | 2010-03-19 | 337d? | finish no earlier than 2010-03-19 | R4 | 2696h | 2696h | RInImp9-Rfmulti | PCG-22 | Ericsson | johan.skold@ericsson.com | Rel-9 | RP-42 | Issam |  |  |  | RP-100027 |
| 3526 | 920.2.2 | GERAN part of RF requirements for Multicarrier and Multi RAT BS |  | 261d? | 2008-11-21 A | 2009-11-20 A | 100% | 2008-11-21 | 2009-11-20 | 261d? | finish no earlier than 2009-11-20 | G1 | 2088h | 2088h | RInImp9-RFmulti-GERAN | PCG-22 | Ericsson | mats.y.samuelsson@ericsson.com | Rel-9 | GP-40 | Paolo | RInImp9-RFmulti-GERAN |  |  |  |
| 3527 | 920.3 | Extended UMTS/LTE 800 MHz | milestone | 0d? | 2008-12-05 A | 2008-12-05 A | 100% | 2008-12-05 | 2009-09-18 | 207d? |  | R4; R2; R3 |  |  | RInImp9-UMTSLTE800 | PCG-22 | NTT DoCoMo | Shingo Suwa (suwas@nttdocomo.co.jp) | Rel-9 | RP-42 | Issam | RInImp9-UMTSLTE800 |  |  | RP-090687 |
| 3528 | 920.4 | UMTS/LTE 800 MHz for Europe | milestone | 0d? | 2009-03-06 A | 2009-03-06 A | 100% | 2009-03-06 | 2010-03-19 | 272d? | finish no earlier than 2010-03-19 | R4; R2; R3 |  |  | RInImp9-UMTSLTE800EU | PCG-22 | Ericsson | olav.queseth@ericsson.com | Rel-9 | RP-43 | Issam | RInImp9-UMTSLTE800EU |  |  | RP-100028 |
| 3529 | 920.5 | Performance requirement for LCR TDD with UE speeds up to 350 km/h |  | 196d? | 2009-03-06 A | 2009-12-04 A | 100% | 2009-03-06 | 2009-12-04 | 196d? | finish no earlier than 2009-12-04 | R4 | 1568h | 1568h | RInImp9-LCRTDD350 | PCG-22 | CATT | Yuexia Song (songyuexia@catt.cn) | Rel-9 | RP-43 | Issam | RInImp9-LCRTDD350 |  |  | RP-091035 |
| 3530 | 920.6 | Extended UMTS/LTE 1500 MHz | milestone | 0d? | 2009-05-30 A | 2009-05-30 A | 100% | 2009-05-30 | 2010-03-19 | 211d? | finish no earlier than 2010-03-19 | R4; R2; R3 |  |  | UMTSLTE1500 | PCG-23 | NTT DoCoMo | Shingo Suwa (suwas@nttdocomo.co.jp) | Rel-9 | RP-44 | Issam | UMTSLTE1500 |  |  | RP-100029 |
| 3531 | 921 | **Rel-9 Improvements of the Radio Interface - UE Conformance Testing** |  | 350d? | 2009-05-19 A | 2010-09-17 A | 100% | 2009-05-19 | 2010-09-17 | 350d? |  | R5 | 8184h | 8184h |  | PCG-23 |  |  | Rel-9 | RP-44 | Ingbert |  |  |  |  |
| 3532 | 921.1 | Conformance Test Aspects – UMTS/LTE in 800 MHz for Europe |  | 350d? | 2009-05-19 A | 2010-09-17 A | 100% | 2009-05-19 | 2010-09-17 | 350d? | finish no earlier than 2010-09-17 | R5 | 2800h | 2800h | RInImp-UEConTest-UMTSLTE800EU | PCG-23 | Ericsson | fredrik.sundstrom@ericsson.com | Rel-9 | RP-44 | Ingbert | RInImp-UEConTest-UMTSLTE800EU |  |  | RP-100736 |
| 3533 | 921.2 | Conformance Test Aspects – Extended UMTS/LTE 1500 MHz |  | 186d? | 2009-09-18 A | 2010-06-04 A | 100% | 2009-09-18 | 2010-06-04 | 186d? | finish no earlier than 2010-06-04 | R5 | 1488h | 1488h | UMTSLTE1500_UEConTest | PCG-23 | NTT DoCoMo | Nguyen Dung Dao (dao@nttdocomo.co.jp) | Rel-9 | RP-45 | Ingbert | UMTSLTE1500_UEConTest |  |  | RP-100487 |
| 3534 | 921.3 | TDD UE Over The Air (Antenna) conformance testing methodology |  | 81d? | 2009-05-30 A | 2009-09-18 A | 100% | 2009-05-30 | 2009-09-18 | 81d? | finish no earlier than 2009-09-18 | R5 | 648h | 648h | UEAnt_TDDTest | PCG-23 | CATR | Qu Yan (quyan@emcite.com) | Rel-9 | RP-44 | Ingbert | UEAnt_TDDTest |  |  | RP-090727 |
| 3535 | 921.4 | Conformance Test Aspects – Performance requirement for LCR TDD with UE speeds up to 350 km/h |  | 56d? | 2010-03-19 A | 2010-06-04 A | 100% | 2010-03-19 | 2010-06-04 | 56d? | finish no earlier than 2010-06-04 | R5 | 448h | 448h | RInImp9-LCRTDD350_UEConTest | PCG-24 | CATT | Xiaozhong Chen (chexiaozhong@datangmobile.cn) | Rel-9 | RP-47 | Ingbert | RInImp9-LCRTDD350_UEConTest |  |  | RP-100496 |
| 3536 | 922 | Conformance Test Aspects – SMS over IMS in E-UTRAN |  | 131d? | 2009-09-18 A | 2010-03-19 A | 100% | 2009-09-18 | 2010-03-19 | 131d? | finish no earlier than 2010-06-18 | R5 | 1048h | 1048h | SMSoverIMS_UEConTest | PCG-23 | Alcatel-Lucent | Nidal Khrais (khrais@alcatel-lucent.com) | Rel-9 | RP-45 | Ingbert | SMSoverIMS_UEConTest |  |  | RP-100072 |

Notes:
- 3509: -
- 3510: CP#48 completed / Impacted TSs and TRs: 29.165
- 3511: CP#65 complete / Impacted TSs and TRs: RFC 7329 (was draft-kaplan-insipid-session-id)
- 3512: CP#65 complete / Impacted TSs and TRs: RFC 7316 (was draft-vanelburg-dispatch-private-network-ind)
- 3513: In RFC Editors Queue. Dec.14: 75->90; 7/3/16: 90%->100 / Impacted TSs and TRs: draft-ietf-salud-alert-info-urns
- 3514: In RFC Editors Queue. Mar15: 90->100%. RFC updated (was draft-ietf-cuss-sip-uui). Jun 15: RFC 7433 (was draft-ietf-cuss-sip-uui) / Impacted TSs and TRs: RFC 7433
- 3515: In RFC Editors Queue. Dec.14: 75->90. Mar15: 90->100%. RFC updated (was draft-ietf-cuss-sip-uui-isdni). June 15: RFC 7434 (was draft-ietf-cuss-sip-uui-isdn) / Impacted TSs and TRs: RFC 7434
- 3516: CP#62 removed from Rel-8 to Rel-11. Not completed internet-draft / Impacted TSs and TRs: Rel-12 remains draft-dawes-sipping-debug
- 3517: CP#64 Draft removed from 3GPP documentation / Impacted TSs and TRs: draft-avasarala-dispatch-comm-div-notification
- 3518: CP#47 completed [Stage 3 for Rel-7 Emergency Calls (EMC1)]. Related to Rel-9 UID_400038 LCS Control Plane Solution for EPS. Stage 2 in Rel-9 UID_400038 (23.271), UID_410037 (23.167) / Impacted TSs and TRs: 24.229
- 3519: CP#46 completed / Impacted TSs and TRs: 29.212, 29.213, 29.215
- 3520: CP#46 completed. Linked to Rel-6 UID_11051 (IMS Management objects) under the Feature UID_32021 (IMS Phase 2). MO compatible with OMA DM v1.2 & upwards and defined using OMA DM Device Description Framework (OMA-ERELD _DM-V1_2) / Impacted TSs and TRs: New 24.166
- 3521: CP#47 approved WID and completed. Added capability to store ICE graphical information (picture). Linked to CT6 Rel-8 ICE Feature UID_380059 In Case of Emergency numbers storage and easy access on UICC / Impacted TSs and TRs: 31.102 CR#0433
- 3522: RP#41 umbrella Feature created to host Rel-9 WIs / Impacted TSs and TRs: GERAN, UTRA, LTE
- 3523: RP#44 completed technical work (RAN4 internal TR abandoned) / Impacted TSs and TRs: UTRA (no TR 25.8xy produced)
- 3524: RP#47 completed. RF requirements specification applicable to Multi-Standard Radio (MSR) Base Station with multiple carriers and/or multiple 3GPP Radio Access Technologies (RAT) / Impacted TSs and TRs: GERAN, UTRA, LTE
- 3525: RP#48 completed / Impacted TSs and TRs: UTRA, LTE 25.104, 25.105, 36.104, new 37.104, 37.113, 37.141, 37.900
- 3526: GP#44 Core spec completed. GP#40 WID approved / Impacted TSs and TRs: GERAN 45.005, 51.021
- 3527: RP#45 completed / Impacted TSs and TRs: UTRA, LTE 25.101, 25.104, 25.113, 25.133, 34.124, 36.101, 36.104, 36.113, 36.124, 36.133, 36.141, 25.306, 25.307, 25.331, 36.331, 25.461, 25.466, new 36.800
- 3528: RP#47 completed / Impacted TSs and TRs: UTRA, LTE 25.101, 25.104, 25.113, 25.133, 25.141, 34.124, 36.101, 36.104, 36.113, 36.124, 36.133, 36.141, new 36.810, 25.306, 25.307, 25.331, 36.331, 25.461, 25.466
- 3529: RP#46 completed / Impacted TSs and TRs: UTRA 25.102, 25.105, 25.142
- 3530: RP#47 completed. For potential deployment in Japan / Impacted TSs and TRs: UTRA, LTE 25.101, 25.104, 25.113, 25.133, 25.141, 25.306, 25.307, 25.331, 25.461, 25.466, 34.124, 36.101, 36.104, 36.113, 36.124, 36.133, 36.141, 36.331, new (36.821, 36.307)
- 3531: - / Impacted TSs and TRs: UTRA, LTE
- 3532: RP#49 completed. Testing for UID_430009 UMTS/LTE 800 MHz for Europe / Impacted TSs and TRs: UTRA, LTE 34.108, 34.121-1, 34.121-2, 36.508, 36.521-1, 36.521-2, 36.521-3
- 3533: RP#48 completed / Impacted TSs and TRs: UTRA, LTE 34.108, 34.121-1, 34.121-2, 34.123-1, 34.123-2, 36.508, 36.521-1, 36.521-2, 36.521-3, 36.523-1, 36.523-2, 36.523-3
- 3534: RP#45 completed. Finalized TDD UE test methodology based on R4 TR 25.914 (UE and MS antenna performance evaluation method) and TS 25.144 Over the Air (Antenna) minimum performance requirements for the speech mode (terminal close to head) / Impacted TSs and TRs: UTRA 34.114
- 3535: RP#48 completed. Testing for UID_430010 Performance requirement for LCR TDD with UE speeds up to 350 km/h / Impacted TSs and TRs: UTRA 34.122
- 3536: RP#47 completed / Impacted TSs and TRs: LTE 34.229-1, 34.229-2, 34.229-3

| ID | WBS | Task | Type | Duration | Start | Finish | Complete | Baseline start | Baseline finish | Baseline duration | Constraint | Resources | Work | Actual work | PCG approved | Release | TSG approved | MCC resp | Acronym | WI rapporteur name | WI rapporteur e-mail | Status Report | Acronym_3GU_Export | Special Focus Doc |
| --- | --- | --- | --- | --- | --- | --- | --- | --- | --- | --- | --- | --- | --- | --- | --- | --- | --- | --- | --- | --- | --- | --- | --- | --- |
| 3537 | 923 | **Rel-9 RAN improvements** |  | 395d? | 2009-03-06 A | 2010-09-08 A | 100% | 2000-01-03 | 2010-03-19 | 2667d? |  | RP | 12640h | 12640h | PCG-22 | Rel-9 | RP-43 | Issam |  |  |  |  |  |  |
| 3538 | 923.1 | Dual-Cell HSUPA | milestone | 0d? | 2009-03-06 A | 2009-03-06 A | 100% | 2009-03-06 | 2010-03-19 | 272d? | finish no earlier than 2010-03-19 | R1; R2; R3; R4 |  |  | PCG-22 | Rel-9 | RP-43 | Patrick | RANimp-DC_HSUPA | Nokia Siemens Networks | Karri Ranta-aho (karri.ranta-aho@nsn.com) | RP-100030 | RANimp-DC_HSUPA |  |
| 3539 | 923.2 | Support for different bands for Dual-Cell HSDPA | milestone | 0d? | 2009-03-06 A | 2009-03-06 A | 100% | 2009-03-06 | 2009-12-04 | 197d? |  | R4; R2; R3 |  |  | PCG-22 | Rel-9 | RP-43 | Issam | RANimp-MultiBand_DC_HSDPA | Nokia Siemens Networks | Tuomo Säynäjäkangas (tuomo.saynajakangas@nsn.com) | RP-091038 | RANimp-MultiBand_DC_HSDPA |  |
| 3540 | 923.3 | Combination of DC-HSDPA with MIMO | milestone | 0d? | 2009-03-06 A | 2009-03-06 A | 100% | 2009-03-06 | 2009-12-04 | 197d? |  | R1; R2; R3; R4 |  |  | PCG-22 | Rel-9 | RP-43 | Patrick | RANimp-DC_MIMO | Ericsson | johan.bergman@ericsson.com | RP-091039 | RANimp-DC_MIMO |  |
| 3541 | 923.4 | Transmit Antenna Array (TxAA) extension for non-MIMO UEs | milestone | 0d? | 2009-03-06 A | 2009-03-06 A | 100% | 2009-03-06 | 2009-12-04 | 197d? |  | R1; R2; R3; R4 |  |  | PCG-22 | Rel-9 | RP-43 | Patrick | RANimp-TxAA_nonMIMO | Nokia | Arto Lehti (arto.lehti@nokia.com) | RP-091040 | RANimp-TxAA_nonMIMO |  |
| 3542 | 923.5 | Cell Portion for 1.28 Mcps TDD |  | 395d? | 2009-03-06 A | 2010-09-08 A | 100% | 2000-01-03 | 2000-07-07 | 136d? | finish no earlier than 2009-03-06 | R3; R1; R4 | 9480h | 9480h | PCG-23 | Rel-9 | RP-44 | Juha | CP_LCRTDD | CATT | Ying Zhang (zhangying2@datangmobile.cn) | RP-091041 | CP_LCRTDD |  |
| 3543 | 924 | **Rel-9 RAN improvements - UE Conformance Testing** |  | 588d? | 2010-09-17 A | 2012-12-07 A | 100% | 2010-09-17 | 2012-12-07 | 588d? |  | R5 | 11848h | 11848h | PCG-25 | Rel-9 | RP-49 | Ingbert |  |  |  |  |  |  |
| 3544 | 924.1 | Conformance Test Aspects – Combination of DC-HSDPA with MIMO |  | 186d? | 2010-09-17 A | 2011-06-03 A | 100% | 2010-09-17 | 2011-06-03 | 186d? | finish no earlier than 2011-06-03 | R5 | 1488h | 1488h | PCG-25 | Rel-9 | RP-49 | Ingbert | RANimp-DC_MIMO_UEConTest | Ericsson | leif.mattisson@ericsson.com | RP-110510 | RANimp-DC_MIMO_UEConTest |  |
| 3545 | 924.2 | Conformance Test Aspects – Dual-Cell HSUPA |  | 453d? | 2011-03-18 A | 2012-12-07 A | 100% | 2011-03-18 | 2012-12-07 | 453d? | finish no earlier than 2012-12-07 | R5 | 3624h | 3624h | PCG-26 | Rel-9 | RP-51 | Ingbert | RANimp-DC_HSUPA_UEConTest | Ericsson | leif.mattisson@ericsson.com | RP-121524 | RANimp-DC_HSUPA_UEConTest |  |
| 3546 | 924.3 | Conformance Test Aspects – Support for different bands for Dual-Cell HSDPA |  | 254d? | 2011-03-18 A | 2012-03-02 A | 100% | 2011-03-18 | 2012-03-02 | 254d? | finish no earlier than 2012-03-02 | R5 | 2032h | 2032h | PCG-26 | Rel-9 | RP-51 | Ingbert | RANimp-MultiBand_DC_HSDPA_UEConTest | Ericsson | leif.mattisson@ericsson.com | RP-120036 | RANimp-MultiBand_DC_HSDPA_UEConTest |  |
| 3547 | 925 | **LTE improvements** |  | 587d? | 2009-03-06 A | 2011-06-03 A | 100% | 2009-03-06 | 2011-06-03 | 587d? |  | R1; R2; R4; R5 | 21840h | 21840h | PCG-22 | Rel-9 | RP-42 | Patrick | LTEimp |  |  |  | LTEimp |  |
| 3548 | 925.1 | LTE Pico NodeB RF Requirements |  | 196d? | 2009-03-06 A | 2009-12-04 A | 100% | 2009-03-06 | 2009-12-04 | 196d? | finish no earlier than 2010-03-05 | R4 | 1568h | 1568h | PCG-22 | Rel-9 | RP-43 | Issam | LTEimp-Pico_eNB-RF | Huawei | Liyan Yin (yinliyan@huawei.com) | RP-091045 | LTEimp-Pico_eNB-RF |  |
| 3549 | 925.2 | Enhanced Dual-Layer transmission for LTE | milestone | 0d? | 2009-03-06 A | 2009-03-06 A | 100% | 2009-03-06 | 2010-03-19 | 272d? | finish no earlier than 2010-03-18 | R1; R2; R4 |  |  | PCG-22 | Rel-9 | RP-43 | Patrick | LTEimp-eDL | China Mobile | Xu Xiaodong (xuxiaodong@chinamobile.com) | RP-100034 | LTEimp-eDL |  |
| 3550 | 925.3 | UE Conformance Test Aspects – Enhanced Dual-layer transmission for LTE TDD |  | 186d? | 2010-09-17 A | 2011-06-03 A | 100% | 2010-09-17 | 2011-06-03 | 186d? | finish no earlier than 2011-06-03 | R5 | 1488h | 1488h | PCG-25 | Rel-9 | RP-49 | Ingbert | LTEimp-eDL_UEConTest | China Mobile | Shanpeng Xiao (xiaoshanpeng@chinamobile.com) | RP-110509 | LTEimp-eDL_UEConTest |  |
| 3551 | 926 | Rel-9 Self-Organizing Networks (SON) | milestone | 0d? | 2009-03-06 A | 2009-03-06 A | 100% | 2009-03-06 | 2010-03-19 | 272d? | finish no earlier than 2010-03-19 | R3; R2 |  |  | PCG-22 | Rel-9 | SP-42 | Juha | SON | Nokia Siemens Networks | krzysztof.kordybach@nsn.com | RP-100038 | SON | SON |
| 3552 | 927 | **AGNSS Performances and Testing Procedures** |  | 787d? | 2008-05-16 A | 2011-05-20 A | 100% | 2008-05-16 | 2011-05-20 | 787d? |  | G1; G3new | 22664h | 22664h |  | Rel-9 |  | Paolo | AGNSSPTP | Thales | Michel.monnerat@thalesaleniaspace.com |  | AGNSSPTP |  |
| 3553 | 927.1 | AGNSS Minimum Performances |  | 472d? | 2008-05-16 A | 2010-03-05 A | 100% | 2008-05-16 | 2010-03-05 | 472d? | finish no earlier than 2010-03-05 | G1 | 3776h | 3776h |  | Rel-9 |  | Paolo | AGNSSPTP-Perfreq | Thales | Michel.monnerat@thalesaleniaspace.com |  | AGNSSPTP-Perfreq |  |
| 3554 | 927.2 | AGNSS Testing Procedures |  | 787d? | 2008-05-16 A | 2011-05-20 A | 100% | 2008-05-16 | 2011-05-20 | 787d? | finish no earlier than 2011-05-20 | G3new | 6296h | 6296h |  | Rel-9 |  | Ingbert | AGNSSPTP-MStest | Thales | Michel.monnerat@thalesaleniaspace.com |  | AGNSSPTP-MStest |  |
| 3555 | 928 | **Voice services over Adaptive Multi-user channels on One Slot** |  | 860d? | 2008-11-21 A | 2012-03-02 A | 100% | 2008-11-21 | 2012-03-02 | 860d? |  | GP; G1; G2; G3new | 71592h | 71592h | PCG-22 | Rel-9 | SP-42 | Paolo | VAMOS | Nokia Siemens Networks, China Mobile | juergen.hofmann@nsn.com, liuxiaoyu@chinamobile.com |  | VAMOS |  |
| 3556 | 928.1 | Stage 2 for Voice services over Adaptive Multi-user channels on One Slot |  | 392d? | 2008-11-21 A | 2010-05-21 A | 100% | 2008-11-21 | 2010-05-21 | 392d? | finish no earlier than 2010-05-21 | GP; G1; G2 | 9408h | 9408h | PCG-22 | Rel-9 | GP-40 | Paolo | VAMOS | Nokia Siemens Networks, China Mobile | juergen.hofmann@nsn.com, liuxiaoyu@chinamobile.com |  |  |  |
| 3557 | 928.2 | Stage 3 for Voice services over Adaptive Multi-user channels on One Slot |  | 596d? | 2008-11-24 A | 2011-03-04 A | 100% | 2008-11-24 | 2011-03-04 | 596d? | finish no earlier than 2011-03-04 | GP; G1; G2 | 14304h | 14304h | PCG-22 | Rel-9 | GP-40 | Paolo | VAMOS | Nokia Siemens Networks, China Mobile | juergen.hofmann@nsn.com, liuxiaoyu@chinamobile.com |  |  |  |
| 3558 | 928.3 | VAMOS Radio Performance Requirements |  | 651d? | 2008-11-24 A | 2011-05-20 A | 100% | 2008-11-24 | 2011-05-20 | 651d? | finish no earlier than 2011-05-20 | GP; G1; G2 | 15624h | 15624h | PCG-22 | Rel-9 | GP-40 | Paolo | VAMOS | Nokia Siemens Networks, China Mobile | juergen.hofmann@nsn.com, liuxiaoyu@chinamobile.com |  |  |  |
| 3559 | 928.4 | VAMOS - MS conformance testing |  | 392d? | 2010-09-03 A | 2012-03-02 A | 100% | 2010-09-03 | 2012-03-02 | 392d? | finish no earlier than 2012-03-02 | G3new | 3128h | 3128h | PCG-25 | Rel-9 | GP-47 | Ingbert | VAMOS_MStest | BlackBerry | Raveendra Seetharam (rseetharam@rim.com) |  | VAMOS_MStest |  |
| 3560 | 928.5 | VAMOS - BTS conformance testing |  | 201d? | 2010-11-26 A | 2011-09-02 A | 100% | 2010-11-26 | 2011-09-02 | 201d? | finish no earlier than 2011-09-02 | G1 | 1608h | 1608h | PCG-26 | Rel-9 | GP-48 | Paolo | VAMOS_BTStest | Nokia Siemens Networks | eddie.riddington@nsn.com |  | VAMOS_BTStest |  |

Notes:
- 3537: RP#47 completed / Impacted TSs and TRs: UTRA
- 3538: RP#47 completed / Impacted TSs and TRs: 25.101, 25.104, 25.133, 25.211, 25.212, 25.213, 25.214, 25.215, 25.319, 25.306, 25.321, 25.331, 25.423, 25.433
- 3539: RP#46 completed. RP#62 existing TS 25.317 replaced by new TS 25.327 / Impacted TSs and TRs: 25.101, 25.104, 25.133, 25.306, 25.308, 25.331, 25.423, 25.433, new 25.317 replaced by new TS 25.327
- 3540: RP#46 completed / Impacted TSs and TRs: 25.101, 25.104, 25.133, 25.211, 25.212, 25.213, 25.214, 25.215, 25.308, 25.321, 25.331, 26.306, 25.423, 25.433
- 3541: RP#46 completed / Impacted TSs and TRs: 25.101, 25.104, 25.211, 25.212, 25.213, 25.214, 25.215, 25.308, 25.306, 25.321, 25.331, 25.423, 25.433
- 3542: RP#46 completed / Impacted TSs and TRs: 25.102, 25.105, 25.123, 25.225, 25.423, 25.433
- 3543: -
- 3544: UTRA. RP#52 completed. Testing for Rel-9 UID_430016 Combination of DC-HSDPA with MIMO / Impacted TSs and TRs: UTRA 34.108, 34.121-1, 34.121-2, 34.123-1, 34.123-2, 34.123-3
- 3545: RP#58 completed. Testing for Rel-9 UID_430014 Dual-Cell HSUPA / Impacted TSs and TRs: UTRA 34.108, 34.121-1, 34.121-2, 34.123-1, 34.123-2, 34.123-3
- 3546: RP#55 completed. Testing for Rel-9 UID_430015 Support for different bands for Dual-Cell HSDPA / Impacted TSs and TRs: UTRA 34.108, 34.121-1, 34.121-2, 34.123-1, 34.123-2, 34.123-3
- 3547: - / Impacted TSs and TRs: LTE
- 3548: RP#46 completed / Impacted TSs and TRs: 36.104, 36.141, new 36.931
- 3549: RP#47 completed / Impacted TSs and TRs: 36.101, 36.211, 36.212, 36.213, 36.331
- 3550: RP#52 completed. Testing for UID_430029 (Enhanced Dual-Layer transmission for LTE) / Impacted TSs and TRs: 36.508, 36.521-1, 36.521-2
- 3551: RP#47 completed / Impacted TSs and TRs: LTE 25.413, 36.300, 36.413, 36.423, 48.018, New 36.902
- 3552: GP#46 still ongoing MS testing. Linked to Rel-10 RAN4 UID_450027 (AGNSS Minimum Performance for UTRAN)
- 3553: GP#45 completed (open performance requirements alignment GPS/Galileo) / Impacted TSs and TRs: 45.005
- 3554: GP#50 completed / Impacted TSs and TRs: 51.010-1, new 51.010-7
- 3555: Triggered by UID_50590 (MUROS) Study on Multi-User Reusing-One-Slot
- 3556: GP#46 completed. GP#40 WID approved / Impacted TSs and TRs: 45.001
- 3557: GP#49 completed. GP#40 WID approved / Impacted TSs and TRs: 24.008, 44.018, 45.002, 45.003, 45.004, 45.008, 48.008, 48.058
- 3558: GP#50 completed. GP#40 WID approved / Impacted TSs and TRs: 45.005
- 3559: GP#53 completed. GP#47 WID approved / Impacted TSs and TRs: 51.010-1, 51.010-2
- 3560: GP#51 completed. GP#48 WID approved / Impacted TSs and TRs: 51.021

| ID | WBS | Task | Type | Duration | Start | Finish | Complete | Baseline start | Baseline finish | Baseline duration | Constraint | Resources | Work | Actual work | Acronym | PCG approved | WI rapporteur name | WI rapporteur e-mail | Release | TSG approved | MCC resp | Acronym_3GU_Export | PCG stopped | TSG stopped | Special Focus Doc | Status Report |
| --- | --- | --- | --- | --- | --- | --- | --- | --- | --- | --- | --- | --- | --- | --- | --- | --- | --- | --- | --- | --- | --- | --- | --- | --- | --- | --- |
| 3561 | 929 | **Cell Broadcast protocol Base Station Controller – Cell Broadcast Centre (BSC-CBC)** |  | 222d? | 2009-05-15 A | 2010-03-19 A | 100% | 2009-05-15 | 2010-03-19 | 222d? |  | GP; C1 | 7024h | 7024h | CEBRO | PCG-23 | Ericsson | claes-goran.persson@ericsson.com | Rel-9 | GP-42 | Paolo | CEBRO |  |  |  |  |
| 3562 | 929.1 | GERAN part of Cell Broadcast protocol Base Station Controller – Cell Broadcast Centre |  | 212d? | 2009-05-15 A | 2010-03-05 A | 100% | 2009-05-15 | 2010-03-05 | 212d? | finish no earlier than 2010-03-05 | GP | 1696h | 1696h | CEBRO | PCG-23 | Ericsson | claes-goran.persson@ericsson.com | Rel-9 | GP-42 | Paolo |  |  |  |  |  |
| 3563 | 929.2 | CT1 part of Cell Broadcast protocol Base Station Controller – Cell Broadcast Centre |  | 222d? | 2009-05-15 A | 2010-03-19 A | 100% | 2009-05-15 | 2010-03-19 | 222d? | finish no earlier than 2010-03-19 | C1 | 1776h | 1776h | CEBRO | PCG-23 | Ericsson | claes-goran.persson@ericsson.com | Rel-9 | GP-42 | Frederic |  |  |  |  |  |
| 3564 | 930 | Hybrid Location |  | 136d? | 2009-05-18 A | 2009-11-20 A | 100% | 2009-05-18 | 2009-11-20 | 136d? | finish no earlier than 2009-11-20 | GP | 1088h | 1088h | HILT | PCG-23 | TruePosition | Matt Ward (mward@trueposition.com) | Rel-9 | GP-42 | Paolo | HILT |  |  |  |  |
| 3565 | 931 | (Small) Technical Enhancements and Improvements for Rel-9 |  | 325d? | 2008-09-15 A | 2009-12-10 A | 100% | 2008-09-15 | 2009-12-10 | 325d? | finish no earlier than 2009-12-10 | SP; CP; RP; GP | 10400h | 10400h | TEI9 | PCG-22 |  |  | Rel-9 | SP-42 | All | TEI9 |  |  |  |  |
| 3566 | 932 | Test - (Small) Technical Enhancements and Improvements for Rel-9 |  | 286d? | 2009-11-20 A | 2010-12-24 A | 100% | 2009-11-20 | 2010-12-24 | 286d? | finish no earlier than 2010-12-24 | R5; G3new | 4576h | 4576h | TEI9_Test | PCG-24 |  |  | Rel-9 | GP-44 | Ingbert | TEI9_Test |  |  |  |  |
| 3567 | 933 | **Deleted - Services Alignment and Migration** |  | 467d? | 2006-12-06 A | 2008-09-18 A | 100% | 2006-12-06 | 2008-09-18 | 467d? |  | S1 | 7472h | 7472h | ServAl |  | Telefónica O2 | chris.friel@O2.com | Rel-9 | SP-33 | Alain | ServAl | PCG-21 | SP-41 |  |  |
| 3568 | 933.1 | Deleted - Stage 1 for ServAl |  | 467d? | 2006-12-06 A | 2008-09-18 A | 100% | 2006-12-06 | 2008-09-18 | 467d? | finish no earlier than 2008-12-11 | S1 | 3736h | 3736h |  | PCG-21 | Telefónica O2 | chris.friel@O2.com | Rel-9 | SP-33 | Alain |  | PCG-21 | SP-41 |  |  |
| 3569 | 934 | Deleted - Harmonization of Gq'/Rx for Common IMS |  | 304d? | 2008-01-14 A | 2009-03-12 A | 100% | 2008-01-14 | 2009-03-12 | 304d? | finish no earlier than 2009-03-12 | S2 | 2432h | 2432h | IMS_Comm_GqRx_Harm | PCG-21 | Alcatel-Lucent | geoffrey.cristallo@alcatel-lucent.be | Rel-9 | SP-38 | Maurice | IMS_Comm_GqRx_Harm | PCG-22 | SP-43 |  |  |
| 3570 | 935 | Deleted - Support of WiMAX - LTE Mobility |  | 407d? | 2008-06-06 A | 2009-12-25 A | 100% | 2008-06-06 | 2009-12-25 | 407d? | start no earlier than 2008-06-06 | R2 | 3248h | 3248h | WiMAX_LTE_Mobility | PCG-21 | Samsung |  | Rel-9 | RP-38 | Yong-Jun | WiMAX_LTE_Mobility | PCG-21 | SP-39 |  |  |
| 3571 | 936 | Deleted - Support of WiMAX - UMTS Mobility |  | 407d? | 2008-06-06 A | 2009-12-25 A | 100% | 2008-06-06 | 2009-12-25 | 407d? | start no earlier than 2008-06-06 | R2 | 3248h | 3248h | WiMAX_UMTS_Mobility | PCG-21 | Intel |  | Rel-9 | RP-38 | Yong-Jun | WiMAX_UMTS_Mobility | PCG-21 | SP-39 |  |  |
| 3572 | 937 | Deleted - Definition of 3GPP UICC services over the new high-speed interface | milestone | 0d? | 2010-03-19 A | 2010-03-19 A | 100% | 2010-03-19 | 2010-03-19 | 0d? |  | C6 |  |  | UICCHS | PCG-21 | Gemalto | Denis.Lheriteau@gemalto.com | Rel-9 | CP-38 | Xavier | UICCHS | PCG-24 | CP-47 |  |  |
| 3573 | 938 | **Deleted - SAES Enhancements (non RAN aspects)** |  | 381d? | 2007-06-25 A | 2008-12-08 A | 100% | 2007-06-25 | 2008-12-08 | 381d? |  | S2 | 11664h | 11664h | SAES_Ph2 | PCG-21 | Nokia Siemens Networks |  | Rel-9 | SP-39 | Maurice | SAES_Ph2 | PCG-21 | SP-39 |  |  |
| 3574 | 938.1 | Deleted - Functions and procedures for SAE to support LTE MBMS |  | 381d? | 2007-06-25 A | 2008-12-08 A | 100% | 2007-06-25 | 2008-12-08 | 381d? | finish no earlier than 2008-12-08 | S2 | 3048h | 3048h | SAES_Ph2 |  |  |  | Rel-9 | SP-35 | Maurice |  | PCG-21 | SP-39 |  |  |
| 3575 | 938.2 | Deleted - CS over EPS |  | 194d? | 2008-03-12 A | 2008-12-08 A | 100% | 2008-03-12 | 2008-12-08 | 194d? | finish no earlier than 2008-12-08 | S2 | 1552h | 1552h | SAES_Ph2 | PCG-21 |  |  | Rel-9 | SP-39 | Maurice |  | PCG-21 | SP-39 |  |  |
| 3576 | 938.3 | **Deleted - SAE for generic support for non-3GPP accesses** |  | 251d? | 2007-06-25 A | 2008-06-09 A | 100% | 2007-06-25 | 2008-06-09 | 251d? |  | S2 | 4016h | 4016h | SAES_Ph2 | PCG-21 |  |  | Rel-9 | SP-39 | Maurice |  | PCG-21 | SP-39 |  |  |
| 3577 | 938.3.1 | Deleted - Single Radio Aspects of SAE for Optimized Handover with WiMAX |  | 251d? | 2007-06-25 A | 2008-06-09 A | 100% | 2007-06-25 | 2008-06-09 | 251d? | finish no earlier than 2008-06-09 | S2 | 2008h | 2008h | SAES_Ph2 | PCG-21 |  |  | Rel-9 | SP-39 | Maurice |  | PCG-21 | SP-39 |  |  |
| 3578 | 939 | Deleted - Lawful Interception in the 3GPP Rel-9 |  | 211d? | 2009-06-04 A | 2010-03-25 A | 100% | 2009-06-04 | 2010-03-25 | 211d? | finish no earlier than 2010-03-25 | S3 | 1688h | 1688h | LI9 | PCG-23 | PIDS, Nortel | Koen Jaspers, Ronald Ryan | Rel-9 | SP-44 | Mirko | LI9 | PCG-24 | SP-47 |  |  |
| 3579 | 940 | Release 9 Studies | milestone | 0d? | 2008-06-05 A | 2008-06-05 A | 100% | 2008-06-05 | 2010-03-19 | 468d? |  | CP; RP; SP |  |  |  |  |  |  | Rel-9 |  |  |  |  |  |  |  |
| 3580 | 941 | Study on Service Specific Access Control in EPS |  | 136d? | 2008-06-05 A | 2008-12-11 A | 100% | 2008-06-05 | 2008-12-11 | 136d? | start no earlier than 2008-06-05 | S1 | 1088h | 1088h | FS_SSAC | PCG-21 | NTT DoCoMo | Shin-ichi Isobe (isobes@nttdocomo.co.jp) | Rel-9 | SP-40 | Alain | FS_SSAC |  |  |  |  |
| 3581 | 942 | Study on CS Domain Services over EPS access |  | 492d? | 2007-04-25 A | 2009-03-12 A | 100% | 2007-04-25 | 2009-03-12 | 492d? | finish no earlier than 2009-03-12 | S2 | 3936h | 3936h | FS_CSoPS |  | T-Mobile | Karl-Heinz.Nenner@T-Mobile.net | Rel-9 | SP-35 | Maurice | FS_CSoPS |  |  |  |  |
| 3582 | 943 | Study on Extended Support of IMS Emergency Calls |  | 319d? | 2007-09-24 A | 2008-12-11 A | 100% | 2007-09-24 | 2008-12-11 | 319d? | finish no earlier than 2009-06-18 | S2 | 2552h | 2552h | FS_IMS-eCall |  | Qualcomm | Stephen Edge | Rel-9 | SP-37 | Maurice | FS_IMS-eCall |  |  | Public Safety (I-A) |  |
| 3583 | 944 | Study on Service Continuity for Emergency Voice Calls |  | 721d? | 2006-06-08 A | 2009-03-12 A | 100% | 2006-06-08 | 2009-03-12 | 721d? | finish no earlier than 2009-03-12 | S2 | 5768h | 5768h | FS_VCCEm |  | Nortel | Ricky Kaura (rkaura@nortel.com) | Rel-9 | SP-32 | Maurice | FS_VCCEm |  |  | Public Safety (I-A) |  |
| 3584 | 945 | Study on Security Aspects of Remote Provisioning and Change of Subscription for M2M Equipment |  | 1483.15d? | 2004-04-06 A | 2009-12-10 A | 100% | 2004-04-06 | 2009-12-10 | 1483.15d? | finish no earlier than 2009-12-10 | S3; C6 | 23730.4h | 23730.4h | FS_UM2M |  | Ericsson | vesa.lehtovirta@ericsson.com | Rel-9 | SP-37 | Mirko | FS_UM2M |  |  | MTC, M2M |  |
| 3585 | 946 | Study on System Maintenance over Itf-N |  | 602d? | 2007-06-07 A | 2009-09-24 A | 100% | 2007-06-07 | 2009-09-24 | 602d? | finish no earlier than 2009-09-24 | S5 | 4808h | 4808h | FS_OAM-Maint-Itf-N |  | ZTE | Shuqiang Huang (huangsq@zte.com.cn) | Rel-9 | SP-36 | Mirko | FS_OAM-Maint-Itf-N |  |  |  |  |
| 3586 | 947 | Study on Self-Organizing Networks (SON) related OAM interfaces for Home NodeB |  | 522d? | 2007-06-07 A | 2009-06-04 A | 100% | 2007-06-07 | 2009-06-04 | 522d? | finish no earlier than 2009-12-10 | S5 | 4168h | 4168h | FS_OAM-SON-HNB |  | Huawei | Zou Lan (zlan@huawei.com) | Rel-9 | SP-36 | Mirko | FS_OAM-SON-HNB |  |  | HNB, SON |  |
| 3587 | 948 | Study on Self-healing of Self-Organizing Networks (SON) |  | 416d? | 2008-02-22 A | 2009-09-24 A | 100% | 2008-02-22 | 2009-09-24 | 416d? | finish no earlier than 2009-09-24 | S5 | 3320.15h | 3320.15h | FS_OAM-SON-SH | PCG-21 | ZTE | zhu.weihong@zte.com.cn | Rel-9 | SP-39 | Mirko | FS_OAM-SON-SH |  |  | SON |  |
| 3588 | 949 | Study on Service Oriented Architecture (SOA) for IRP |  | 262d? | 2008-06-05 A | 2009-06-04 A | 100% | 2008-06-05 | 2009-06-04 | 262d? | finish no earlier than 2009-05-20 | S5 | 2088h | 2088h | FS_OAM_SOA_IRP | PCG-21 | Ericsson | edwin.tse@ericsson.com | Rel-9 | SP-40 | Mirko | FS_OAM_SOA_IRP |  |  |  |  |
| 3589 | 950 | Study on Evaluation of the inclusion of Path Loss Based Technology in the UTRAN |  | 516d? | 2007-12-17 A | 2009-12-04 A | 100% | 2007-12-17 | 2009-12-04 | 516d? | finish no earlier than 2009-09-18 | R4 | 4120h | 4120h | FS_RAN-Pathloss | PCG-21 | Polaris Wireless | Norman Shaw (nshaw@polariswireless.com) | Rel-9 | RP-38 | Issam | FS_RAN-Pathloss |  |  |  | RP-091080 |
| 3590 | 951 | Study on LTE-Advanced |  | 781.2d? | 2007-03-23 A | 2010-03-19 A | 100% | 2007-03-23 | 2010-03-19 | 781.2d? | finish no earlier than 2010-03-19 | R1; R2; R3; R4 | 24998.4h | 24998.4h | FS_RAN_LTEA | PCG-21 | NTT DoCoMo | Tetsushi Abe | Rel-9 | RP-39 | Patrick | FS_RAN_LTEA |  |  | CA | RP-100080 |
| 3591 | 952 | Study on 1.28 Mcps TDD Home NodeB |  | 387d? | 2008-02-20 A | 2009-12-04 A | 100% | 2008-02-20 | 2009-12-04 | 387d? | finish no earlier than 2009-12-04 | R4 | 3096h | 3096h | FS_RAN-HNBLCRTDD | PCG-21 | TD Tech | Li Rong (lirong@td-tech.com) | Rel-9 | RP-41 | Issam | FS_RAN-HNBLCRTDD |  |  | HNB | RP-091081 |
| 3592 | 953 | Study on E-UTRAN Mobility Evaluation and Enhancement |  | 126d? | 2008-12-05 A | 2009-05-29 A | 100% | 2008-12-05 | 2009-05-29 | 126d? | finish no earlier than 2009-05-29 | R1 | 1008h | 1008h | FS_EUTRAN_mob | PCG-22 | Qualcomm | Rajat Prakash (rprakash@qualcomm.com) | Rel-9 | RP-42 | Patrick | FS_EUTRAN_mob |  |  |  | RP-090426 |
| 3593 | 954 | Study on Minimization of drive-tests in Next Generation Networks |  | 196d? | 2009-03-06 A | 2009-12-04 A | 100% | 2009-03-06 | 2009-12-04 | 196d? | finish no earlier than 2009-12-04 | R2 | 1568h | 1568h | FS_NGN_min_drive-tests | PCG-22 | Qualcomm | Masato Kitazoe (mkitazoe@qualcomm.com) | Rel-9 | RP-43 | Yong-Jun | FS_NGN_min_drive-tests |  |  |  | RP-091084 |
| 3594 | 955 | Study on Enhanced Interference Management for HNBs |  | 61d? | 2009-03-06 A | 2009-05-29 A | 100% | 2009-03-06 | 2009-05-29 | 61d? | start no earlier than 2009-03-06 | R4 | 488h | 488h | FS_eInterfMgmt_HNB | PCG-22 | Qualcomm | Farhad Meshkati (fmeshkat@qualcomm.com) | Rel-9 | RP-43 | Issam | FS_eInterfMgmt_HNB |  |  | HNB | RP-090429 |
| 3595 | 956 | Study on Enhanced Interference Management Mechanisms for HNBs |  | 81d? | 2009-05-30 A | 2009-09-18 A | 100% | 2009-05-30 | 2009-09-18 | 81d? | finish no earlier than 2009-09-18 | R3 | 648h | 648h | FS_eInterfMgmtMchsm_HNB | PCG-23 | Qualcomm | Farhad Meshkati (fmeshkat@qualcomm.com) | Rel-9 | RP-44 | Juha | FS_eInterfMgmtMchsm_HNB |  |  | HNB | RP-090733 |
| 3596 | 957 | Deleted - Study on Protection against SMS and MMS spam |  | 862d? | 2006-06-08 A | 2009-09-24 A | 100% | 2006-06-08 | 2009-09-24 | 862d? | finish no earlier than 2009-09-24 | S3 | 6896h | 6896h | FS_CPSMal |  | Orange | eric.gauthier@orange.ch | Rel-9 | SP-32 | Mirko | FS_CPSMal | PCG-23 | SP-45 |  |  |
| 3597 | 958 | Release 8 Features |  | 914.3d? | 2006-09-19 A | 2010-03-19 A | 100% | 2006-09-19 | 2010-03-19 | 914.3d? | start no earlier than 2000-01-03 | CP; GP; RP; SP | 29257.6h | 29257.6h |  |  |  |  | Rel-8 |  |  |  |  |  |  |  |

Notes:
- 3561: CP#47 completed. GP#45 completed. GP#42 WID approved
- 3562: GP#45 completed. GP#42 WID approved / Impacted TSs and TRs: new 48.049
- 3563: CP#47 completed / Impacted TSs and TRs: 23.041
- 3564: GP#44 completed. GP#42 WID approved (Hybrid Integrated Location Technology=HILT) / Impacted TSs and TRs: 43.059, 48.071
- 3565: SP#46 completed
- 3566: GP#44 created
- 3567: SP#41 closed (no tangible result of this work; no CR against TR 22.983). Triggered by Study UID_370086 (FSServAl)
- 3568: SP#41 closed (no tangible result of this work; no CR against TR 22.983) / Impacted TSs and TRs: 22.983
- 3569: SP#43 stopped. LS_out to TISPAN informs about stopping this activity / Impacted TSs and TRs: 23.822, 23.203
- 3570: RP#39: No agreed WID / Impacted TSs and TRs: 36.306, 36.331, 36.413, 36.300, 36.214, 36.133, 36.304
- 3571: RP#39: No agreed WID / Impacted TSs and TRs: 25.306, 25.331, 25.413
- 3572: CP#47 work stopped/abandoned / Impacted TSs and TRs: 31.xyz
- 3573: SP#39 created to host Rel-9 Wis. BUT no agreed WID
- 3574: SP#39 SAE functionality moved to Rel-9. WID returned to SA2 for re-consideration & remove MBMS for EPS from Rel 8
- 3575: SP#39 SAE functionality moved to Rel-9. BUT no agreed WID
- 3576: SP#39 SAE functionality moved to Rel-9. BUT no agreed WID
- 3577: SP#39 SAE functionality moved to Rel-9. BUT no agreed WID
- 3578: SP#47 stopped. WI + new topics moved to Rel-10 / Impacted TSs and TRs: 33.106, 33.107, 33.108
- 3579: -
- 3580: SP#42 completed. Spin-off Feature UID_420020 (SSAC) / Impacted TSs and TRs: 22.986
- 3581: SP#43 completed. Linked to Combinational Services UID_31064, Services Alignment and Migration (ServAl) UID_330017 and 3GPP System Architecture Evolution (SAES) UID_3208 / Impacted TSs and TRs: 23.879
- 3582: SP#42 completed / Impacted TSs and TRs: 23.868
- 3583: SP#43 completed / Impacted TSs and TRs: 23.826
- 3584: SP#46 completed. Triggered by the SA1 Rel-8 Study on Facilitating Machine to Machine Communication in GSM and UMTS (FS_M2M) UID_7027 in TR 22.868. / Impacted TSs and TRs: 33.812
- 3585: SP#45 completed / Impacted TSs and TRs: 32.822
- 3586: SP#44 completed. Linked to SA5 TR 32.816 Study of Management for LTE and SAE (UID_340036) / Impacted TSs and TRs: 32.821
- 3587: SP#45 completed. Linked to SA5 TR 32.816 Study of Management for LTE and SAE (UID_340036) / Impacted TSs and TRs: 32.823
- 3588: SP#44 completed. Spin-off implementation WI UID_440064 Service Oriented Architecture (SOA) for IRP / Impacted TSs and TRs: 32.824
- 3589: RP#46 completed / Impacted TSs and TRs: 25.907
- 3590: RP#47 completed / Impacted TSs and TRs: 36.913 , New 36.814, 36.912, R2 36.806 (Relay architectures for E-UTRA), R4 36.815 (LTE-Advanced feasibility studies in RAN4)
- 3591: RP#46 completed / Impacted TSs and TRs: 25.866
- 3592: RP#44 closed (RP-090452 R1 LS to RAN on Conclusions for LTE Mobility Study Item - no further Rel-9 action / no TR needed) / Impacted TSs and TRs: none
- 3593: RP#46 completed / Impacted TSs and TRs: 36.805
- 3594: RP#44 completed. Linked to UID_420008 LTE FDD Home eNodeB RF Requirements. Spin-off RAN3 UID_440015 Study on Enhanced Interference Management Mechanisms for HNBs / Impacted TSs and TRs: 25.967
- 3595: RP#45 completed. Triggered by RAN4 UID_430027 Study on Enhanced Interference Management for HNBs / Impacted TSs and TRs: 25.967
- 3596: SP#45 work stopped/abandoned / Impacted TSs and TRs: 33.9xx
- 3597: -

| ID | WBS | Task | Duration | Start | Finish | Complete | Baseline start | Baseline finish | Baseline duration | Constraint | Resources | Work | Actual work | Acronym | WI rapporteur name | WI rapporteur e-mail | Release | TSG approved | MCC resp | Acronym_3GU_Export | PCG approved |
| --- | --- | --- | --- | --- | --- | --- | --- | --- | --- | --- | --- | --- | --- | --- | --- | --- | --- | --- | --- | --- | --- |
| 3598 | 959 | **3GPP System Architecture Evolution Specification - Evolved Packet System (non RAN aspects)** | 1618d? | 2006-04-12 A | 2012-06-15 A | 100% | 2006-04-12 | 2012-06-15 | 1618d? |  | S1; S2; S3; S5; C1; C3; C4; C6; IETF | 512323h | 510115h | SAES | T-Mobile | michael.kurz@t-mobile.at | Rel-8 | TSG-32 | Alain | SAES |  |
| 3599 | 959.1 | Requirements for evolution of the 3GPP system architecture | 395d? | 2006-06-08 A | 2007-12-12 A | 100% | 2006-06-08 | 2007-12-12 | 395d? | finish no earlier than 2007-11-30 | S1 | 3160h | 3160h | AIPN-SAE | T-Mobile | michael.kurz@t-mobile.at | Rel-8 | TSG-32 | Alain | AIPN-SAE |  |
| 3600 | 959.2 | **High level and common (for all accesses) functions** | 629d? | 2007-01-02 A | 2009-05-29 A | 100% | 2007-01-02 | 2009-05-29 | 629d? |  | S2; S3; C1; C3; C4 | 62664h | 62664h | EPS-ComF | Nokia Siemens Networks | balazs.bertenyi@nsn.com | Rel-8 | SP-37 | Maurice | EPS-ComF |  |
| 3601 | 959.2.1 | Stage 2 for High level functions | 370d? | 2007-01-02 A | 2008-06-02 A | 100% | 2007-01-02 | 2008-06-02 | 370d? | finish no earlier than 2008-06-02 | S2 | 2960h | 2960h | SAES-SA-HLF | Motorola | Irfan.Ali@motorola.com | Rel-8 | TSG-35 | Maurice | SAES-SA-HLF |  |
| 3602 | 959.2.2 | Stage 2 Security Architecture | 197d? | 2008-03-12 A | 2008-12-11 A | 100% | 2008-03-12 | 2008-12-11 | 197d? | finish no earlier than 2008-12-11 | S3 | 1576h | 1576h | SAES | Nokia Siemens Networks | marc.blommaert.ext@nsn.com | Rel-8 | SP-39 | Mirko |  | PCG-21 |
| 3603 | 959.2.3 | Stage 3 (CT1) for SAE impact on services, network functions and capabilities | 545d? | 2007-02-05 A | 2009-03-06 A | 100% | 2007-02-05 | 2009-03-06 | 545d? | finish no earlier than 2009-03-06 | C1 | 4360h | 4360h | SAES | Nokia Siemens Networks | robert.zaus@nsn.com | Rel-8 | TSG-34 | Frederic |  |  |
| 3604 | 959.2.4 | Stage 3 SAE impact on existing capabilities | 480d? | 2007-02-05 A | 2008-12-05 A | 100% | 2007-02-05 | 2008-12-05 | 480d? | finish no earlier than 2008-12-12 | C3 | 3840h | 3840h | SAES | Huawei | Wei Weihua (weiwh@huawei.com) | Rel-8 | TSG-34 | Adrian |  |  |
| 3605 | 959.2.5 | Stage 3 (CT4) of SAE impact on existing capabilities | 545d? | 2007-02-05 A | 2009-03-06 A | 100% | 2007-02-05 | 2009-03-06 | 545d? | finish no earlier than 2009-03-06 | C4 | 4360h | 4360h | SAES | Huawei | shahab.lavasani@huawei.com | Rel-8 | TSG-34 | Kimmo |  |  |
| 3606 | 959.2.6 | Stage 2/3 for Network selection procedures | 480d? | 2007-02-05 A | 2008-12-05 A | 100% | 2007-02-05 | 2008-12-05 | 480d? | finish no earlier than 2009-03-06 | C1 | 3840h | 3840h | SAES | Nokia Siemens Networks | robert.zaus@nsn.com | Rel-8 | TSG-34 | Frederic |  |  |
| 3607 | 959.2.7 | Stage 3 EPC interworking with external PDNs (SGi) | 605d? | 2007-02-05 A | 2009-05-29 A | 100% | 2007-02-05 | 2009-05-29 | 605d? | finish no earlier than 2009-05-29 | C3 | 4840h | 4840h | SAES-St3-intwk | Huawei | Wei Weihua (weiwh@huawei.com) | Rel-8 | TSG-34 | Adrian | SAES-St3-intwk |  |
| 3608 | 959.2.8 | Stage 3 PCC within SAE | 605d? | 2007-02-05 A | 2009-05-29 A | 100% | 2007-02-05 | 2009-05-29 | 605d? | finish no earlier than 2009-05-29 | C3 | 4840h | 4840h | SAES-St3-PCC | Ericsson | j.javier.pastor@ericsson.com | Rel-8 | TSG-34 | Adrian | SAES-St3-PCC |  |
| 3609 | 959.2.9 | Stage 3 for SAE / LTE identities | 545d? | 2007-02-05 A | 2009-03-06 A | 100% | 2007-02-05 | 2009-03-06 | 545d? | finish no earlier than 2009-03-06 | C4 | 4360h | 4360h | SAES | Huawei | shahab.lavasani@huawei.com | Rel-8 | TSG-34 | Kimmo |  |  |
| 3610 | 959.2.10 | Unified guidelines for Diameter usage within 3GPP | 316d? | 2007-09-21 A | 2008-12-05 A | 100% | 2007-09-21 | 2008-12-05 | 316d? | finish no earlier than 2008-12-05 | C3 | 2528h | 2528h | SAES-DIAM | Huawei | Javier Gonzalez Gallego | Rel-8 | CP-37 | Adrian | SAES-DIAM |  |
| 3611 | 959.3 | **SAE for LTE access** | 569d? | 2007-01-02 A | 2009-03-06 A | 100% | 2007-01-02 | 2009-03-06 | 569d? |  | S2; C1; C3; C4 | 80584h | 80584h | SAES-LTE | Motorola | Irfan.Ali@motorola.com | Rel-8 | TSG-35 | Maurice | SAES-LTE |  |
| 3612 | 959.3.1 | CT4 Stage 3 for protocol between EPCs | 545d? | 2007-02-05 A | 2009-03-06 A | 100% | 2007-02-05 | 2009-03-06 | 545d? | finish no earlier than 2009-03-06 | C4 | 4360h | 4360h | SAES-LTE | Huawei | shahab.lavasani@huawei.com | Rel-8 | TSG-34 | Kimmo |  |  |
| 3613 | 7.2.2.1 | **SAES-SA-FP_LTE with GTP variant** | 569d? | 2007-01-02 A | 2009-03-06 A | 100% | 2007-01-02 | 2009-03-06 | 569d? |  | S2; C4 | 16448h | 16448h | SAES-SA-FP_LTE-GTP | Nokia Siemens Networks | balazs.bertenyi@nsn.com | Rel-8 | TSG-35 | Maurice | SAES-SA-FP_LTE-GTP |  |
| 3614 | 959.3.2.1 | Stage 2 for SAES-SA-FP_LTE with GTP variant | 373d? | 2007-01-02 A | 2008-06-05 A | 100% | 2007-01-02 | 2008-06-05 | 373d? | finish no earlier than 2008-06-02 | S2 | 2984h | 2984h | SAES-SA-FP_LTE-GTP-St2 | Nokia Siemens Networks | balazs.bertenyi@nsn.com | Rel-8 | TSG-37 | Maurice | SAES-SA-FP_LTE-GTP-St2 |  |
| 3615 | 959.3.2.2 | CT4 Stage 3 for GTP v2 protocol | 545d? | 2007-02-05 A | 2009-03-06 A | 100% | 2007-02-05 | 2009-03-06 | 545d? | finish no earlier than 2009-03-06 | C4 | 4360h | 4360h | SAES-SA-FP_LTE-GTP | Huawei | shahab.lavasani@huawei.com | Rel-8 | TSG-34 | Kimmo | SAES-SA-FP_LTE-GTP |  |
| 3616 | 7.2.2.2 | **SAES-SA-FP_LTE with PMIP variant** | 569d? | 2007-01-02 A | 2009-03-06 A | 100% | 2007-01-02 | 2009-03-06 | 569d? |  | S2; C4 | 20288h | 20288h | SAES-SA-FP_LTE-IETF | Nokia Siemens Networks | balazs.bertenyi@nsn.com | Rel-8 | TSG-34 | Maurice | SAES-SA-FP_LTE-IETF |  |
| 3617 | 959.3.3.1 | Stage 2 for SAES-SA-FP_LTE with PMIP variant | 373d? | 2007-01-02 A | 2008-06-05 A | 100% | 2007-01-02 | 2008-06-05 | 373d? | finish no earlier than 2008-06-02 | S2 | 2984h | 2984h | SAES-SA-FP_LTE-IETF-St2 | Nokia Siemens Networks | balazs.bertenyi@nsn.com | Rel-8 | TSG-37 | Maurice | SAES-SA-FP_LTE-IETF-St2 |  |
| 3618 | 959.3.3.2 | CT4 Stage 3 for PMIP protocol within EPC | 545d? | 2007-02-05 A | 2009-03-06 A | 100% | 2007-02-05 | 2009-03-06 | 545d? | finish no earlier than 2009-03-06 | C4 | 4360h | 4360h | SAES-SA-FP_LTE-IETF | Huawei | shahab.lavasani@huawei.com | Rel-8 | CP-37 | Kimmo | SAES-SA-FP_LTE-IETF |  |
| 3619 | 959.3.3.3 | Mobile IPv4 (MIPv4) based Mobility protocols | 480d? | 2007-02-05 A | 2008-12-05 A | 100% | 2007-02-05 | 2008-12-05 | 480d? | finish no earlier than 2008-12-05 | C4 | 3840h | 3840h | SAES-SA-FP_LTE-IETF | Motorola | Lewis Milton | Rel-8 | CP-41 | Kimmo |  |  |
| 3620 | 959.3.4 | Stage 3 for UE Non-Access-Stratum (NAS) mobility procedures in idle and active mode | 545d? | 2007-02-05 A | 2009-03-06 A | 100% | 2007-02-05 | 2009-03-06 | 545d? | finish no earlier than 2009-03-06 | C1 | 4360h | 4360h | SAES-LTE | Nokia Siemens Networks | robert.zaus@nsn.com | Rel-8 | TSG-34 | Frederic |  |  |
| 3621 | 959.3.5 | Stage 3 for Session management, bearer control and QoS aspects | 545d? | 2007-02-05 A | 2009-03-06 A | 100% | 2007-02-05 | 2009-03-06 | 545d? | finish no earlier than 2009-03-06 | C1 | 4360h | 4360h | SAES-LTE | Nokia Siemens Networks | robert.zaus@nsn.com | Rel-8 | TSG-34 | Frederic |  |  |
| 3622 | 959.3.6 | Stage 3 for security aspects of LTE Access | 545d? | 2007-02-05 A | 2009-03-06 A | 100% | 2007-02-05 | 2009-03-06 | 545d? | finish no earlier than 2009-03-06 | C1 | 4360h | 4360h | SAES-LTE | Nokia Siemens Networks | robert.zaus@nsn.com | Rel-8 | TSG-34 | Frederic |  |  |
| 3623 | 959.3.7 | Stage 3 for QoS mechanisms | 480d? | 2007-02-05 A | 2008-12-05 A | 100% | 2007-02-05 | 2008-12-05 | 480d? | finish no earlier than 2008-12-12 | C3 | 3840h | 3840h | SAES-LTE | Ericsson | j.javier.pastor@ericsson.com | Rel-8 | TSG-34 | Adrian |  |  |
| 3624 | 959.3.8 | Stage 3 for EPC - HSS interface | 545d? | 2007-02-05 A | 2009-03-06 A | 100% | 2007-02-05 | 2009-03-06 | 545d? | finish no earlier than 2009-03-06 | C4 | 4360h | 4360h | SAES-LTE | Huawei | shahab.lavasani@huawei.com | Rel-8 | TSG-34 | Kimmo |  |  |

Notes:
- 3598: Role model for SAE/LTE system wide project management by SA2 in SP-060166
- 3599: SP#38 completed / Impacted TSs and TRs: 22.011, 22.246, New 22.278
- 3600: CP#44 completed
- 3601: SP#40 completed / Impacted TSs and TRs: New 23.402
- 3602: SP#42 completed / Impacted TSs and TRs: 33.210, 33.310, New 33.401
- 3603: CP#43 completed / Impacted TSs and TRs: 24.229, 27.007, New 24.305
- 3604: CP#42 completed / Impacted TSs and TRs: 29.061
- 3605: CP#43 completed / Impacted TSs and TRs: New (29.274, 29.275)
- 3606: CP#42 completed / Impacted TSs and TRs: 23.122, New 24.302
- 3607: CP#44 completed / Impacted TSs and TRs: 29.061
- 3608: CP#44 completed / Impacted TSs and TRs: 29.212, 29.213, 29.214, New 29.215
- 3609: CP#43 completed / Impacted TSs and TRs: 23.003
- 3610: CP#42 completed / Impacted TSs and TRs: New 29.909
- 3611: CP#43 completed
- 3612: CP#43 completed / Impacted TSs and TRs: 29.274, 29.275
- 3613: CP#43 completed
- 3614: SP#40 completed / Impacted TSs and TRs: 23.401, 23.060, 23.002, 23.246, 23.203, 23.107, 23.234, 23.271
- 3615: CP#43 completed / Impacted TSs and TRs: 29.274
- 3616: CP#43 completed
- 3617: SP#40 completed
- 3618: CP#43 completed / Impacted TSs and TRs: 29.275, 29.282
- 3619: CP#42 completed / Impacted TSs and TRs: 29.279
- 3620: CP#43 completed / Impacted TSs and TRs: 24.007, 24.301
- 3621: CP#43 completed / Impacted TSs and TRs: 24.007, 24.301
- 3622: CP#43 completed / Impacted TSs and TRs: 24.008, 24.301
- 3623: CP#42 completed / Impacted TSs and TRs: 29.213
- 3624: CP#43 completed / Impacted TSs and TRs: 29.272

| ID | WBS | Task | Type | Duration | Start | Finish | Complete | Baseline start | Baseline finish | Baseline duration | Constraint | Resources | Work | Actual work | Acronym | WI rapporteur name | WI rapporteur e-mail | Release | TSG approved | MCC resp | Acronym_3GU_Export | Impacted TSs and TRs | PCG approved | TSG stopped |
| --- | --- | --- | --- | --- | --- | --- | --- | --- | --- | --- | --- | --- | --- | --- | --- | --- | --- | --- | --- | --- | --- | --- | --- | --- |
| 3625 | 959.4 | **SAE for Interoperation between LTE and legacy cellular PS accesses** |  | 545d? | 2007-02-05 A | 2009-03-06 A | 100% | 2007-02-05 | 2009-03-06 | 545d? |  | S2; C1; C4 | 48872h | 48872h | SAES-SA-FP_3GPP | Motorola | Irfan.Ali@motorola.com | Rel-8 | TSG-35 | Maurice | SAES-SA-FP_3GPP |  |  |  |
| 3626 | 959.4.1 | Stage 2 for Interoperation between LTE and 2G/3G |  | 424d? | 2007-02-05 A | 2008-09-18 A | 100% | 2007-02-05 | 2008-09-18 | 424d? | finish no earlier than 2008-09-11 | S2 | 3392h | 3392h | EPSto2_3G | Motorola | Irfan.Ali@motorola.com | Rel-8 | SP-37 | Maurice | EPSto2_3G | 23.401, 23.402 |  |  |
| 3627 | 959.4.2 | Stage 3 for Inter-system mobility between E-UTRAN and 2G/3G |  | 545d? | 2007-02-05 A | 2009-03-06 A | 100% | 2007-02-05 | 2009-03-06 | 545d? | finish no earlier than 2009-03-06 | C1 | 4360h | 4360h | SAES-SA-FP_3GPP | Nokia Siemens Networks | robert.zaus@nsn.com | Rel-8 | CP-38 | Frederic | SAES-SA-FP_3GPP | 24.008, 24.301 | PCG-21 |  |
| 3628 | 959.4.3 | Stage 2 GPRS enhancements for LTE access |  | 272d? | 2007-09-04 A | 2008-09-18 A | 100% | 2007-09-04 | 2008-09-18 | 272d? | start no earlier than 2007-09-04 | S2 | 2176h | 2176h | SAES-GPRS_LTE | Vodafone | chris.pudney@vodafone.com | Rel-8 | TSG-34 | Maurice | SAES-GPRS_LTE | 23.401 |  |  |
| 3629 | 959.4.4 | Stage 2 GPRS for EPC (23.060, etc.) |  | 179d? | 2008-01-14 A | 2008-09-18 A | 100% | 2008-01-14 | 2008-09-18 | 179d? | finish no earlier than 2008-09-18 | S2 | 1432h | 1432h | SAES-SA-FP_3GPP | Nokia Siemens Networks | balazs.bertenyi@nsn.com | Rel-8 | SP-39 | Maurice |  | 23.060 | PCG-21 |  |
| 3630 | 959.4.5 | Stage 3 for EPC - GPRS |  | 545d? | 2007-02-05 A | 2009-03-06 A | 100% | 2007-02-05 | 2009-03-06 | 545d? | finish no earlier than 2009-03-06 | C4 | 4360h | 4360h | SAES-SA-FP_3GPP | Huawei | shahab.lavasani@huawei.com | Rel-8 | TSG-34 | Kimmo |  | 29.274, 29.275, 29.281 |  |  |
| 3631 | 959.4.6 | Stage 3 for EPC to UTRAN |  | 545d? | 2007-02-05 A | 2009-03-06 A | 100% | 2007-02-05 | 2009-03-06 | 545d? | finish no earlier than 2009-03-06 | C4 | 4360h | 4360h | SAES-SA-FP_3GPP | Huawei | shahab.lavasani@huawei.com | Rel-8 | CP-38 | Kimmo |  | 29.274, 29.275, 29.281 | PCG-21 |  |
| 3632 | 959.4.7 | Stage 3 for EPC to 3GPP2 |  | 545d? | 2007-02-05 A | 2009-03-06 A | 100% | 2007-02-05 | 2009-03-06 | 545d? | finish no earlier than 2009-03-06 | C4 | 4360h | 4360h | SAES-SA-FP_3GPP | Huawei | shahab.lavasani@huawei.com | Rel-8 | CP-38 | Kimmo |  | 29.277, 29.276 | PCG-21 |  |
| 3633 | 959.4.8 | Stage 2 for Interoperation between LTE and CDMA2000 |  | 329d? | 2007-06-18 A | 2008-09-18 A | 100% | 2007-06-18 | 2008-09-18 | 329d? | finish no earlier than 2008-04-25 | S2 | 2632h | 2632h | EPStoC2k | Motorola, Vodafone | Irfan.Ali@motorola.com, chris.pudney@vodafone.com | Rel-8 | CP-37 | Maurice | EPStoC2k | 23.401, 23.402 |  |  |
| 3634 | 959.4.9 | Stage 3 for Inter-system mobility between E-UTRAN and CDMA2000 |  | 545d? | 2007-02-05 A | 2009-03-06 A | 100% | 2007-02-05 | 2009-03-06 | 545d? | finish no earlier than 2009-03-06 | C1 | 4360h | 4360h | SAES-SA-FP_3GPP | Nokia Siemens Networks | robert.zaus@nsn.com | Rel-8 |  | Frederic |  | 24.301, 24.302 |  |  |
| 3635 | 959.4.10 | Stage 3 for MME - SGSN signalling free protocol |  | 545d? | 2007-02-05 A | 2009-03-06 A | 100% | 2007-02-05 | 2009-03-06 | 545d? | finish no earlier than 2009-03-06 | C4 | 4360h | 4360h | SAES-SA-FP_3GPP | Huawei | shahab.lavasani@huawei.com | Rel-8 | TSG-34 | Kimmo |  | 29.272, 29.274 |  |  |
| 3636 | 959.5 | **SAE for support for non-3GPP accesses** |  | 1429d? | 2007-01-02 A | 2012-06-15 A | 100% | 2007-01-02 | 2012-06-15 | 1429d? |  | S2; S3; C1; C4; IETF | 123829h | 123829h | SAES-SA-FP_n3GPP | Motorola | Irfan.Ali@motorola.com | Rel-8 | TSG-35 | Maurice | SAES-SA-FP_n3GPP |  |  |  |
| 3637 | 7.2.4.1 | Stage 2 for Host-based Mobility aspects |  | 373d? | 2007-01-02 A | 2008-06-05 A | 100% | 2007-01-02 | 2008-06-05 | 373d? | finish no earlier than 2008-04-11 | S2 | 2984h | 2984h | SAES-SA-FP_n3GPP-HBMob | Motorola | Irfan.Ali@motorola.com | Rel-8 |  | Maurice | SAES-SA-FP_n3GPP-HBMob | 23.402 |  |  |
| 3638 | 7.2.4.2 | Stage 2 for Network-based Mobility aspects |  | 448d? | 2007-01-02 A | 2008-09-18 A | 100% | 2007-01-02 | 2008-09-18 | 448d? | finish no earlier than 2008-09-18 | S2 | 3584h | 3584h | SAES-SA-FP_n3GPP-NBMob | Motorola | Irfan.Ali@motorola.com | Rel-8 |  | Maurice | SAES-SA-FP_n3GPP-NBMob | 23.402 |  |  |
| 3639 | 959.5.3 | Stage 3 for Mobility management based on DSMIPv6 |  | 480d? | 2007-02-05 A | 2008-12-05 A | 100% | 2007-02-05 | 2008-12-05 | 480d? | finish no earlier than 2008-12-05 | C1 | 3840h | 3840h | SAES-SA-FP_n3GPP | Nokia Siemens Networks | robert.zaus@nsn.com | Rel-8 |  | Frederic |  | 24.303 |  |  |
| 3640 | 959.5.4 | (IETF) Stage 3 for Mobility management based on DSMIPv6 (draft-ietf-mip6-hiopt) |  | 589d? | 2007-02-05 A | 2012-06-15 A | 100% | 2007-02-05 | 2012-06-15 | 589d? | finish no earlier than 2012-09-14 | C1-IETF | 4712h | 4712h | SAES-SA-FP_n3GPP | Mark Jones |  | Rel-8 | CP-52 | Frederic |  | RFC 6610 (was draft-ietf-mip6-hiopt) | PCG-27 |  |
| 3641 | 959.5.5 | (IETF) Stage 3 for Mobility management based on DSMIPv6 (RFC6275) |  | 356d? | 2007-02-05 A | 2011-07-29 A | 100% | 2007-02-05 | 2011-07-29 | 356d? | finish no earlier than 2011-07-29 | C1-IETF | 2848h | 2848h | SAES-SA-FP_n3GPP |  |  | Rel-8 | CP-52 | Frederic |  | RFC 6275 (was draft-ietf-mext-rfc3775bis) | PCG-27 |  |
| 3642 | 959.5.6 | Stage 3 for Mobility management based on MIP v4 |  | 480d? | 2007-02-05 A | 2008-12-05 A | 100% | 2007-02-05 | 2008-12-05 | 480d? | start no earlier than 2007-02-05 | C1 | 3840h | 3840h | SAES-SA-FP_n3GPP | Nokia Siemens Networks | robert.zaus@nsn.com | Rel-8 | CP-39 | Frederic |  | 24.304 | PCG-21 |  |
| 3643 | 959.5.7 | Stage 3 for Inter-system mobility between E-UTRAN and non 3GPP accesses |  | 545d? | 2007-02-05 A | 2009-03-06 A | 100% | 2007-02-05 | 2009-03-06 | 545d? | finish no earlier than 2009-03-06 | C1 | 4360h | 4360h | SAES-SA-FP_n3GPP | Nokia Siemens Networks | robert.zaus@nsn.com | Rel-8 | CP-38 | Frederic |  | 24.008, 24.301 | PCG-21 |  |
| 3644 | 959.5.8 | Stage 2 for Optimized Dual-Radio Handover with WiMAX |  | 249d? | 2007-06-25 A | 2008-06-05 A | 100% | 2007-06-25 | 2008-06-05 | 249d? | finish no earlier than 2008-06-09 | S2 | 1992h | 1992h | SAES-SA-FP_n3GPP-OptWIMAX | Motorola | Irfan.Ali@motorola.com | Rel-8 |  | Maurice | SAES-SA-FP_n3GPP-OptWIMAX | 23.402 |  |  |
| 3645 | 959.5.9 | Stage 2 Security aspects for non-3GPP Access |  | 197d? | 2008-03-12 A | 2008-12-11 A | 100% | 2008-03-12 | 2008-12-11 | 197d? | finish no earlier than 2008-12-11 | S3 | 1576h | 1576h | SAES-SA-FP_n3GPP | Nokia Siemens Networks | marc.blommaert.ext@nsn.com | Rel-8 | SP-39 | Mirko |  | 33.402, 33.210, 33.310 | PCG-21 |  |
| 3646 | 959.5.10 | Stage 3 security aspects for DSMIPv6 Access |  | 480d? | 2007-02-05 A | 2008-12-05 A | 100% | 2007-02-05 | 2008-12-05 | 480d? | finish no earlier than 2008-12-05 | C1 | 3840h | 3840h | SAES-SA-FP_n3GPP | Nokia Siemens Networks | robert.zaus@nsn.com | Rel-8 | CP-37 | Frederic |  | 24.303 |  |  |
| 3647 | 959.5.11 | Stage 3 security aspects for MIPv4 Access |  | 480d? | 2007-02-05 A | 2008-12-05 A | 100% | 2007-02-05 | 2008-12-05 | 480d? | finish no earlier than 2008-12-05 | C1 | 3840h | 3840h | SAES-SA-FP_n3GPP | Nokia Siemens Networks | robert.zaus@nsn.com | Rel-8 | CP-39 | Frederic |  | 24.304 | PCG-21 |  |
| 3648 | 959.5.12 | Stage 3 for Access to the EPC via non-3GPP access networks |  | 545d? | 2007-02-05 A | 2009-03-06 A | 100% | 2007-02-05 | 2009-03-06 | 545d? | finish no earlier than 2009-03-06 | C1 | 4360h | 4360h | SAES-SA-FP_n3GPP | Nokia Siemens Networks | robert.zaus@nsn.com | Rel-8 |  | Frederic |  | 24.302, 24.312 |  |  |
| 3649 | 959.5.13 | Stage 3 for interfaces within EPC |  | 383d? | 2007-09-19 A | 2009-03-06 A | 100% | 2007-09-19 | 2009-03-06 | 383d? | finish no earlier than 2009-03-06 | C4 | 3064h | 3064h | SAES-SA-FP_n3GPP | Huawei | shahab.lavasani@huawei.com | Rel-8 | CP-37 | Kimmo |  | 29.274, 29.281 |  |  |
| 3650 | 959.5.14 | Stage 3 for Interfaces EPC - non-3GPP IP access |  | 545d? | 2007-02-05 A | 2009-03-06 A | 100% | 2007-02-05 | 2009-03-06 | 545d? | finish no earlier than 2009-03-06 | C4 | 4360h | 4360h | SAES-SA-FP_n3GPP | Huawei | shahab.lavasani@huawei.com | Rel-8 | TSG-34 | Kimmo |  | 29.273, 29.275 |  |  |
| 3651 | 959.5.15 | (IETF) Stage 3 for Interfaces EPC - non-3GPP IP access |  | 1224.6d? | 2007-02-05 A | 2012-06-15 A | 100% | 2007-02-05 | 2012-06-15 | 1224.6d? | finish no earlier than 2012-06-15 | C4-IETF | 9788.8h | 9788.8h | SAES-SA-FP_n3GPP | Lionel Morand |  | Rel-8 | CP-52 | Kimmo |  | RFC 6611 (was draft-ietf-mip6-bootstrapping-integrated) | PCG-27 |  |
| 3652 | 959.5.16 | Stage 3 for AAA/HSS related |  | 480d? | 2007-02-05 A | 2008-12-05 A | 100% | 2007-02-05 | 2008-12-05 | 480d? | finish no earlier than 2008-12-05 | C4 | 3840h | 3840h | SAES-SA-FP_n3GPP | Huawei | shahab.lavasani@huawei.com | Rel-8 | TSG-34 | Kimmo |  | 29.273 |  |  |
| 3653 | 959.5.17 | Stage 3 for EPC - AAA interface |  | 480d? | 2007-02-05 A | 2008-12-05 A | 100% | 2007-02-05 | 2008-12-05 | 480d? | finish no earlier than 2008-12-05 | C4 | 3840h | 3840h | SAES-SA-FP_n3GPP | Huawei | shahab.lavasani@huawei.com | Rel-8 | TSG-34 | Kimmo |  | 29.273 |  |  |
| 3654 | 959.5.18 | Deleted (already covered) SAES-SA-FP_n3GPP Optimized Handover with CDMA | milestone | 0d? | 2007-06-25 A | 2007-06-25 A | 100% | 2007-06-25 | 2007-06-25 | 0d? | finish no earlier than 2007-06-25 | S2 |  |  | SAES-SA-FP_n3GPP-OptCDMA | Nokia Siemens Networks |  | Rel-8 |  | Maurice | SAES-SA-FP_n3GPP-OptCDMA |  |  | SP-37 |

Notes:
- 3625: CP#43 completed
- 3626: SP#41 completed
- 3627: CP#43 completed
- 3628: SP#41 completed
- 3629: SP#41 completed
- 3630: CP#43 completed
- 3631: CP#43 completed
- 3632: CP#43 completed
- 3633: SP#41 completed (except: Handover of multiple PDNs=>Rel-9)
- 3634: CP#43 completed
- 3635: CP#43 completed
- 3636: CP#43 completed. SP#39 retained in Rel-8 (in addition to the essential functionality defined in SP-070699). Replaces UID_340037
- 3637: SP#40 completed
- 3638: SP#41 completed
- 3639: CP#42 completed
- 3640: CP#56 completed
- 3641: SP#53/IETF#81 completed
- 3642: CP#42 completed
- 3643: CP#43 completed
- 3644: SP#40 completed
- 3645: SP#42 completed
- 3646: CP#42 completed
- 3647: CP#42 completed
- 3648: CP#43 completed
- 3649: CP#43 completed
- 3650: CP#43 completed
- 3651: CP#56 completed
- 3652: CP#42 completed
- 3653: CP#42 completed
- 3654: SP#37 stopped

| ID | WBS | Task | Type | Duration | Start | Finish | Complete | Baseline start | Baseline finish | Baseline duration | Constraint | Resources | Work | Actual work | Acronym | WI rapporteur name | Release | MCC resp | Acronym_3GU_Export | Impacted TSs and TRs | PCG approved | TSG approved | PCG stopped | TSG stopped | Special Focus Doc |
| --- | --- | --- | --- | --- | --- | --- | --- | --- | --- | --- | --- | --- | --- | --- | --- | --- | --- | --- | --- | --- | --- | --- | --- | --- | --- |
| 3655 | 959.6 | **Single Radio Voice Call Continuity for 3GPP (SRVCC)** |  | 569d? | 2007-01-02 A | 2009-03-06 A | 100% | 2007-01-02 | 2009-03-06 | 569d? |  | S2; C1; C4 | 19856h | 19856h | SAES-SRVCC | Nokia Siemens Networks | Rel-8 | Maurice | SAES-SRVCC |  |  |  |  |  |  |
| 3656 | 959.6.1 | Stage 2 for 2G/3G SRVCC |  | 448d? | 2007-01-02 A | 2008-09-18 A | 100% | 2007-01-02 | 2008-09-18 | 448d? | finish no earlier than 2008-09-15 | S2 | 3584h | 3584h | SAES-SRVCC | Nokia Siemens Networks | Rel-8 | Maurice |  | New 23.216 |  |  |  |  |  |
| 3657 | 959.6.2 | Stage 3 for SRVCC in EPS |  | 201d? | 2008-05-30 A | 2009-03-06 A | 100% | 2008-05-30 | 2009-03-06 | 201d? | finish no earlier than 2009-03-06 | C1 | 1608h | 1608h | SAES-SRVCC | Nokia Siemens Networks | Rel-8 | Frederic |  | 23.009, 24.008, New 24.301 | PCG-21 | CP-41 |  |  |  |
| 3658 | 959.6.3 | MME to MSC interface for SRVCC |  | 126d? | 2008-09-12 A | 2009-03-06 A | 100% | 2008-09-12 | 2009-03-06 | 126d? | finish no earlier than 2009-03-06 | C4 | 1008h | 1008h | SAES-SRVCC | Nokia Siemens Networks | Rel-8 | Kimmo |  | 23.003, 23.008, New (29.274, 29.277, 29.280) | PCG-21 | CP-41 |  |  |  |
| 3659 | 959.7 | Voice Call Continuity for CDMA2000 1X |  | 249d? | 2007-06-25 A | 2008-06-05 A | 100% | 2007-06-25 | 2008-06-05 | 249d? | finish no earlier than 2008-06-13 | S2 | 1992h | 1992h | SAES-VCC_1X | Nokia Siemens Networks | Rel-8 | Maurice | SAES-VCC_1X |  |  |  |  |  |  |
| 3660 | 959.8 | SAE impacts on IMS |  | 373d? | 2007-01-02 A | 2008-06-05 A | 100% | 2007-01-02 | 2008-06-05 | 373d? | finish no earlier than 2008-06-13 | S2 | 2984h | 2984h | SAES-SA_IMS | Nokia Siemens Networks | Rel-8 | Maurice | SAES-SA_IMS |  |  |  |  |  |  |
| 3661 | 959.9 | **CS Fallback in EPS** |  | 258d? | 2008-03-12 A | 2009-03-06 A | 100% | 2008-03-12 | 2009-03-06 | 258d? |  | S2; C1; C4 | 9384h | 9384h | SAES-CSFB | T-Mobile, Vodafone | Rel-8 | Maurice | SAES-CSFB |  | PCG-21 | SP-39 |  |  |  |
| 3662 | 959.9.1 | Stage 2 for CS Fallback in EPS |  | 62d? | 2008-03-12 A | 2008-06-05 A | 100% | 2008-03-12 | 2008-06-05 | 62d? | finish no earlier than 2008-12-05 | S2 | 496h | 496h | SAES-CSFB | T-Mobile, Vodafone | Rel-8 | Maurice |  | New (23.272, 23.401) | PCG-21 | SP-40 |  |  |  |
| 3663 | 959.9.2 | CT1 part of Stage 3 for CS Fallback in EPS |  | 201d? | 2008-05-30 A | 2009-03-06 A | 100% | 2008-05-30 | 2009-03-06 | 201d? | finish no earlier than 2009-03-06 | C1 | 1608h | 1608h | SAES-CSFB | NEC | Rel-8 | Frederic |  | 24.007, 24.008, 24.011, 29.018, New (24.301, 24.801, 29.118) | PCG-21 | CP-40 |  |  |  |
| 3664 | 959.9.3 | CT4 part of Stage 3 for CS Fallback in EPS |  | 136d? | 2008-05-30 A | 2008-12-05 A | 100% | 2008-05-30 | 2008-12-05 | 136d? | finish no earlier than 2008-12-05 | C4 | 1088h | 1088h | SAES-CSFB | NEC | Rel-8 | Kimmo |  | 23.007, 23.008, 29.274, New 29.277 | PCG-21 | CP-40 |  |  |  |
| 3665 | 959.10 | System enhancements for the use of IMS services in local breakout |  | 62d? | 2008-03-12 A | 2008-06-05 A | 100% | 2008-03-12 | 2008-06-05 | 62d? | finish no earlier than 2008-06-05 | S2 | 496h | 496h | SAES-IMS_LBO | Telecom Italia | Rel-8 | Maurice | SAES-IMS_LBO | 23.228, 23.221, 23.203 | PCG-21 | SP-39 |  |  |  |
| 3666 | 959.11 | **EPC Data Definitions** |  | 309d? | 2008-01-07 A | 2009-03-12 A | 100% | 2008-01-07 | 2009-03-12 | 309d? |  | S5 | 7144h | 7144h | EPC-OAM |  | Rel-8 | Mirko | EPC-OAM |  | PCG-21 | SP-39 |  |  |  |
| 3667 | 959.11.1 | EPC Network Resource Model (NRM) Integration Reference Point (IRP) |  | 309d? | 2008-01-07 A | 2009-03-12 A | 100% | 2008-01-07 | 2009-03-12 | 309d? | finish no earlier than 2009-03-12 | S5 | 2472h | 2472h | EPC-OAM | Huawei | Rel-8 | Mirko |  | New (32.751, 32.752, 32.753, 32.755) | PCG-21 | SP-38 |  |  |  |
| 3668 | 959.11.2 | Performance measurements for EPC |  | 275d? | 2008-02-22 A | 2009-03-12 A | 100% | 2008-02-22 | 2009-03-12 | 275d? | finish no earlier than 2009-03-12 | S5 | 2200h | 2200h | EPC-OAM | China Mobile | Rel-8 | Mirko |  | New 32.426 | PCG-21 | SP-39 |  |  |  |
| 3669 | 959.12 | EPC Charging |  | 309d? | 2008-01-07 A | 2009-03-12 A | 100% | 2008-01-07 | 2009-03-12 | 309d? | finish no earlier than 2009-03-12 | S5 | 2472h | 2472h | EPC-CH | Nokia Siemens Networks | Rel-8 | Mirko | EPC-CH | 32.240, 32.296, 32.251, 32.252, 32.298, 32.299 | PCG-21 | SP-38 |  |  |  |
| 3670 | 959.13 | Domain Name System Procedures for Evolved Packet System (DEPS) |  | 179.75d? | 2008-05-30 A | 2009-03-06 A | 100% | 2008-05-30 | 2009-03-06 | 179.75d? | finish no earlier than 2009-03-06 | C4 | 1438h | 1438h | SAES-DEPS | TeliaSonera | Rel-8 | Kimmo | SAES-DEPS | 23.003, New 29.303 | PCG-21 | CP-40 |  |  |  |
| 3671 | 959.14 | InterWorking Function (IWF) between MAP based and Diameter based interfaces |  | 126d? | 2008-09-12 A | 2009-03-06 A | 100% | 2008-09-12 | 2009-03-06 | 126d? | finish no earlier than 2009-03-06 | C4 | 1008h | 1008h | SAES-MAP2Diam | Huawei | Rel-8 | Kimmo | SAES-MAP2Diam | New 29.305 | PCG-21 | CP-41 |  |  |  |
| 3672 | 959.15 | **CT6 aspects of SAE** |  | 847d? | 2008-03-07 A | 2011-06-03 A | 100% | 2008-03-07 | 2011-06-03 | 847d? |  | C6 | 13480h | 13480h | SAES | Nokia | Rel-8 | Xavier |  |  | PCG-21 | SP-39 |  |  |  |
| 3673 | 959.15.1 | Core specification for CT6 aspects of SAE |  | 321d? | 2008-03-07 A | 2009-05-29 A | 100% | 2008-03-07 | 2009-05-29 | 321d? | finish no earlier than 2009-05-29 | C6 | 2568h | 2568h | SAES | Nokia | Rel-8 | Xavier |  | 31.102, 31.111 | PCG-21 | CP-39 |  |  |  |
| 3674 | 959.15.2 | Test interworking of LTE Terminals with the USIM |  | 526d? | 2008-12-05 A | 2010-12-10 A | 100% | 2008-12-05 | 2010-12-10 | 526d? | finish no earlier than 2010-12-10 | C6 | 4208h | 4208h | SAES-USIM_LTE-Test | Comprion | Rel-8 | Xavier | SAES-USIM_LTE-Test | 31.121, 31.124 | PCG-22 | CP-42 |  |  |  |
| 3675 | 959.15.3 | Test interworking of IP Multimedia Services Identity Module (ISIM) terminals with IP Multimedia Subsystem (IMS) |  | 186d? | 2010-09-17 A | 2011-06-03 A | 100% | 2010-09-17 | 2011-06-03 | 186d? | finish no earlier than 2011-06-03 | C6 | 1488h | 1488h | SAES-ISIM_IMS_Test | Comprion | Rel-8 | Xavier | SAES-ISIM_IMS_Test | 31.121, 31.124, New TS 31.134 | PCG-25 | CP-49 |  |  |  |
| 3676 | 959.16 | Issues for CT1 TR 24.801 |  | 420d? | 2007-01-04 A | 2008-12-05 A | 100% | 2007-01-04 | 2008-12-05 | 420d? | finish no earlier than 2008-12-05 | C1 | 3360h | 3360h | SAES | Nokia Siemens Networks | Rel-8 | Frederic |  | 24.801 | PCG-21 | CP-39 |  |  |  |
| 3677 | 959.17 | Issues for CT3 TR 29.804 |  | 420d? | 2007-02-05 A | 2008-09-12 A | 100% | 2007-02-05 | 2008-09-12 | 420d? | finish no earlier than 2008-12-12 | C3 | 3360h | 3360h | SAES | Ericsson | Rel-8 | Adrian |  | 29.804 | PCG-21 | CP-39 |  |  |  |
| 3678 | 959.18 | Deleted - Issues for CT4 TR 29.803 |  | 420d? | 2007-01-04 A | 2008-09-12 A | 100% | 2007-01-04 | 2008-09-12 | 420d? | finish no earlier than 2008-12-11 | C4 | 3360h | 3360h | SAES | Huawei | Rel-8 | Kimmo |  | 29.803 | PCG-21 | CP-39 | PCG-21 | CP-41 |  |
| 3679 | 959.19 | Deleted (covered by 380068): Functions and procedures for SAE to support LCS | milestone | 0d? | 2008-03-03 A | 2008-03-03 A | 100% | 2008-03-03 | 2008-03-03 | 0d? | finish no earlier than 2008-03-03 | S2 |  |  | SAES-SA-FP_LCS | Nokia Siemens Networks | Rel-8 | Maurice | SAES-SA-FP_LCS |  |  |  |  | SP-37 |  |
| 3680 | 959.20 | Deleted (covered by 380064): SAE aspects of Emergency Calls | milestone | 0d? | 2008-03-03 A | 2008-03-03 A | 100% | 2008-03-03 | 2008-03-03 | 0d? | start no earlier than 2008-03-03 | S2 |  |  | SAES-SA-EmCall | Nokia Siemens Networks | Rel-8 | Maurice | SAES-SA-EmCall |  |  |  |  | SP-37 | Public Safety (I-A) |

Notes:
- 3655: CP#43 completed. SP#38 WID approved (extract from SAE WID SP-070817). / WI rapporteur e-mail: curt.c.wong@nokia.com
- 3656: SP#41 completed. SP#38 WID approved / WI rapporteur e-mail: curt.c.wong@nokia.com
- 3657: CP#43 completed / WI rapporteur e-mail: robert.zaus@nsn.com
- 3658: CP#43 completed / WI rapporteur e-mail: Giorgi Gulbani
- 3659: SP#40 completed / WI rapporteur e-mail: balazs.bertenyi@nsn.com
- 3660: SP#40 completed / WI rapporteur e-mail: balazs.bertenyi@nsn.com
- 3661: CP#43 completed / WI rapporteur e-mail: sabine.demel@t-mobile.at, chris.pudney@vodafone.com
- 3662: SP#40 completed / WI rapporteur e-mail: sabine.demel@t-mobile.at, chris.pudney@vodafone.com
- 3663: CP#43 completed / WI rapporteur e-mail: yannick.lair@nectech.fr
- 3664: CP#42 completed / WI rapporteur e-mail: yannick.lair@nectech.fr
- 3665: SP#40 completed / WI rapporteur e-mail: mario.madella@telecomitalia.it
- 3666: SP#43 completed
- 3667: SP#43 completed / WI rapporteur e-mail: WANG, Xuelong
- 3668: SP#43 completed / WI rapporteur e-mail: Li Jian (lijian@chinamobile.com), Liang Shuangchun (liangshuangchun@cmdi.chinamobile.com)
- 3669: SP#43 completed / WI rapporteur e-mail: Gerald.Goermer@nsn.com
- 3670: CP#43 completed / WI rapporteur e-mail: jouni.korhonen@teliasonera.com
- 3671: CP#43 completed. Triggered by UID_380023 (FS_MAP2Diam) / WI rapporteur e-mail: liming49985@huawei.com
- 3672: CP#44 completed core specification / WI rapporteur e-mail: Rune Lindholm
- 3673: CP#44 completed (specified Network Measurement Results collection via USAT) / WI rapporteur e-mail: Rune Lindholm
- 3674: CP#50 completed. Steering of Roaming test cases have been introduced. Remaining issues CSG display testing (Provide Local Information, Call Control for EPS/PDN, Event Download (Access Technology Change - Multiple Access Technologies) / WI rapporteur e-mail: Udo Willenbrink (uwillenbrink@comprion.com )
- 3675: CP#52 completed. Linked to R5 UID_1273 Provisioning of IP-based multimedia services (24.229, 31.103), R8 UID_390021 CT6 aspects of SAE, UID_420018 Test interworking of LTE Terminals with the USIM, R UID_450018 Testing SMS over IMS in E-UTRAN (34.229). / WI rapporteur e-mail: Udo Willenbrink (uwillenbrink@comprion.com )
- 3676: CP#43 completed / WI rapporteur e-mail: robert.zaus@nsn.com
- 3677: CP#41 completed / WI rapporteur e-mail: j.javier.pastor@ericsson.com
- 3678: CP#41 Work stopped and continued in Normative specifications
- 3679: SP#37 stopped
- 3680: SP#37 stopped

| ID | WBS | Task | Type | Duration | Start | Finish | Complete | Baseline start | Baseline finish | Baseline duration | Constraint | Resources | Work | Actual work | Acronym | Release | TSG approved | MCC resp | TSG stopped | Acronym_3GU_Export | WI rapporteur name | WI rapporteur e-mail | PCG approved | Status Report | PCG stopped |
| --- | --- | --- | --- | --- | --- | --- | --- | --- | --- | --- | --- | --- | --- | --- | --- | --- | --- | --- | --- | --- | --- | --- | --- | --- | --- |
| 3681 | 959.21 | **Deleted - CT aspects of SAES** |  | 138d? | 2007-09-04 A | 2008-03-14 A | 100% | 2007-09-04 | 2008-03-14 | 138d? |  | C3; C1; C4 | 3312h | 1104h | SAES-St3 | Rel-8 | TSG-34 | Frederic | SP-37 | SAES-St3 |  |  |  |  |  |
| 3682 | 959.21.1 | Deleted - CT1 aspects of SAES | milestone | 0d? | 2007-09-04 A | 2007-09-04 A | 100% | 2007-09-04 | 2007-09-04 | 0d? | start no earlier than 2007-09-04 | C1 |  |  | SAES-St3 | Rel-8 |  | Frederic | SP-37 |  |  |  |  |  |  |
| 3683 | 959.21.2 | Deleted - Interoperability | milestone | 0d? | 2008-03-14 A | 2008-03-14 A | 100% | 2008-03-14 | 2008-03-14 | 0d? | start no earlier than 2008-03-14 | C1 |  |  | SAES-St3-interop | Rel-8 | TSG-34 | Frederic | SP-37 | SAES-St3-interop |  |  |  |  |  |
| 3684 | 959.21.3 | Deleted - CT3 aspects of SAES | milestone | 0d? | 2007-09-04 A | 2007-09-04 A | 100% | 2007-09-04 | 2007-09-04 | 0d? | start no earlier than 2007-09-04 | C3 |  |  | SAES | Rel-8 |  | Adrian | SP-37 |  |  |  |  |  |  |
| 3685 | 959.21.4 | Deleted - CT4 aspects of SAES | milestone | 0d? | 2007-09-04 A | 2007-09-04 A | 100% | 2007-09-04 | 2007-09-04 | 0d? | start no earlier than 2007-09-04 | C4 |  |  | SAES | Rel-8 |  | Kimmo | SP-37 |  |  |  |  |  |  |
| 3686 | 959.21.5 | Deleted - UE to EPC NAS signalling (incl. MBMS and QoS aspects) | milestone | 0d? | 2008-03-14 A | 2008-03-14 A | 100% | 2008-03-14 | 2008-03-14 | 0d? | start no earlier than 2008-03-14 | C1 |  |  | SAES-St3-sig | Rel-8 | TSG-34 | Frederic | SP-37 | SAES-St3-sig |  |  |  |  |  |
| 3687 | 959.21.6 | Deleted - User and Control plane protocols | milestone | 0d? | 2007-09-21 A | 2007-09-21 A | 100% | 2007-09-21 | 2007-09-21 | 0d? | start no earlier than 2007-09-21 | C4 |  |  | SAES-St3-prot | Rel-8 | TSG-34 | Kimmo | SP-37 | SAES-St3-prot |  |  |  |  |  |
| 3688 | 959.22 | Deleted - Architecture enhancements for non-3GPP accesses | milestone | 0d? | 2007-09-04 A | 2007-09-04 A | 100% | 2007-09-04 | 2007-09-04 | 0d? | start no earlier than 2007-09-04 | S2 |  |  | SAES-non_3GPP | Rel-8 | TSG-34 | Maurice | SP-34 | SAES-non_3GPP | Motorola | Irfan.Ali@motorola.com |  |  |  |
| 3689 | 959.23 | Deleted - Stage 2 of architecture for the 3GPP System Architecture Evolution | milestone | 0d? | 2007-10-02 A | 2007-10-02 A | 100% | 2007-10-02 | 2007-10-02 | 0d? | start no earlier than 2007-10-02 | S2 |  |  | SAES-St2 | Rel-8 |  | Maurice | SP-34 | SAES-St2 | Vodafone | chris.pudney@vodafone.com |  |  |  |
| 3690 | 959.24 | Deleted - SA aspects of System Architecture Evolution |  | 384d? | 2006-04-12 A | 2007-10-01 A | 100% | 2006-04-12 | 2007-10-01 | 384d? | finish no earlier than 2007-10-02 | S2 | 3072h | 3072h | SAES-SA | Rel-8 |  | Maurice | SP-34 | SAES-SA |  |  |  |  |  |
| 3691 | 960 | Conformance Test Aspects – Mobility management based on DSMIPv6 (Dual-Stack Mobile IPv6) |  | 261d? | 2009-09-18 A | 2010-09-17 A | 100% | 2009-09-18 | 2010-09-17 | 261d? | finish no earlier than 2010-09-17 | R5 | 2088h | 2088h | DSMIPv6_UEConTest | Rel-8 | RP-45 | Ingbert |  | DSMIPv6_UEConTest | Qualcomm | Lena Chaponniere (lchaponn@qualcomm.com) | PCG-23 | RP-100738 |  |
| 3692 | 961 | **IMS Centralized Service control** |  | 2392.1d? | 2005-11-01 A | 2014-12-09 A | 100% | 2005-11-01 | 2014-12-05 | 2387.1d? |  | S1; S2; C1; C3; C4; IETF | 239598h | 239598h | ICSRA | Rel-8 | SP-37 | Alain |  | ICSRA | AT&T | Randolph Wohlert (rwohlert@tri.sbc.com) |  |  |  |
| 3693 | 961.1 | Stage 1 for ICS Requirement and Architecture |  | 138d? | 2007-09-03 A | 2008-03-12 A | 100% | 2007-09-03 | 2008-03-12 | 138d? | finish no earlier than 2007-12-14 | S1 | 1104h | 1104h | ICSRA | Rel-8 | SP-38 | Alain |  |  | AT&T | Randolph Wohlert (rwohlert@tri.sbc.com) | PCG-21 |  |  |
| 3694 | 961.2 | Stage 2 for ICS Requirement and Architecture |  | 125d? | 2007-12-14 A | 2008-06-05 A | 100% | 2007-12-14 | 2008-06-05 | 125d? | start no earlier than 2007-12-14 | S2 | 1000h | 1000h | ICSRA-St2 | Rel-8 | SP-38 | Maurice |  | ICSRA-St2 | Alcatel-Lucent |  | PCG-21 |  |  |
| 3695 | 961.3 | **Stage 3 for ICSRA – Protocol, Addressing, Subscriber Data** |  | 2392.1d? | 2005-11-01 A | 2014-12-09 A | 100% | 2005-11-01 | 2014-12-05 | 2387.1d? |  | C1; C3; C4; IETF | 122674h | 122674h | ICSRA | Rel-8 |  | Frederic |  |  | Ericsson | sean.schneyer@ericsson.com |  |  |  |
| 3696 | 961.3.1 | CT1 aspects - Stage 3 for ICSRA |  | 201d? | 2008-05-30 A | 2009-03-06 A | 100% | 2008-05-30 | 2009-03-06 | 201d? | finish no earlier than 2009-03-06 | C1 | 1608h | 1608h | ICSRA | Rel-8 | CP-40 | Frederic |  |  | Ericsson | Sean Schneyer | PCG-21 |  |  |
| 3697 | 961.3.2 | (IETF) CT1 aspects - Stage 3 for ICSRA (draft-ietf-salud-alert-info-urns) |  | 1244d? | 2008-05-30 A | 2014-12-09 A | 100% | 2008-05-30 | 2014-12-05 | 1242d? | finish no earlier than 2014-12-09 | C1-IETF | 9952h | 9952h | ICSRA | Rel-8 | CP-52 | Frederic |  |  | Roland Jesske | Roland Jesske | PCG-27 |  |  |
| 3698 | 961.3.3 | (IETF) CT1 aspects - Stage 3 for ICSRA (RFC 6871) |  | 779d? | 2008-05-30 A | 2013-03-01 A | 100% | 2008-05-30 | 2013-03-01 | 779d? | finish no earlier than 2013-02-28 | C1-IETF | 6232h | 6232h | ICSRA | Rel-8 | CP-52 | Frederic |  |  | Andrew Allen |  | PCG-27 |  |  |
| 3699 | 961.3.4 | (IETF) CT1 aspects - Stage 3 for ICSRA (RFC 7195) |  | 1117d? | 2008-05-30 A | 2014-06-13 A | 100% | 2008-05-30 | 2014-06-13 | 1117d? | finish no earlier than 2014-06-13 | C1-IETF | 8936h | 8936h | ICSRA | Rel-8 | CP-52 | Frederic |  |  | Andrew Allen |  | PCG-27 |  |  |
| 3700 | 961.3.5 | (IETF) CT1 aspects - Stage 3 for ICSRA (RFC 7006) |  | 977d? | 2008-06-03 A | 2013-12-06 A | 100% | 2008-06-03 | 2013-12-06 | 977d? | finish no earlier than 2013-12-06 | C1-IETF | 7816h | 7816h | ICSRA | Rel-8 | CP-52 | Frederic |  |  | Andrew Allen |  | PCG-27 |  |  |
| 3701 | 961.3.6 | CT3 aspects - Stage 3 for ICSRA |  | 201d? | 2008-05-30 A | 2009-03-06 A | 100% | 2008-05-30 | 2009-03-06 | 201d? | finish no earlier than 2009-03-06 | C3 | 1608h | 1608h | ICSRA | Rel-8 | CP-40 | Adrian |  |  | Mavenir | Brett Wallis ( brett@mavenir.com) | PCG-21 |  |  |
| 3702 | 961.3.7 | CT4 aspects - Stage 3 for ICSRA |  | 136d? | 2008-05-30 A | 2008-12-05 A | 100% | 2008-05-30 | 2008-12-05 | 136d? | start no earlier than 2008-05-30 | C4 | 1088h | 1088h | ICSRA | Rel-8 | CP-40 | Kimmo |  |  | Ericsson | Sean Schneyer | PCG-21 |  |  |
| 3703 | 961.3.8 | (IETF) CT4 aspects - Stage 3 for ICSRA (RFC 7254) |  | 1034.8d? | 2005-11-01 A | 2014-06-13 A | 100% | 2005-11-01 | 2014-06-13 | 1034.8d? | finish no earlier than 2014-06-13 | C4-IETF | 8278.4h | 8278.4h | ICSRA | Rel-8 | CP-52 | Kimmo |  |  | Andrew Allen |  | PCG-27 |  |  |
| 3704 | 961.3.9 | Deleted - Stage 3 for ICSRA – I1 interface |  | 76d? | 2008-05-30 A | 2008-09-12 A | 100% | 2008-05-30 | 2008-09-12 | 76d? | finish no earlier than 2008-09-12 | C1 | 608h | 608h | ICSRA | Rel-8 | CP-40 | Frederic | CP-41 |  | Huawei | xupeili@huawei.com | PCG-21 |  | PCG-21 |

Notes:
- 3681: SP#37 stopped
- 3682: SP#37 stopped
- 3683: SP#37 stopped
- 3684: SP#37 stopped
- 3685: SP#37 stopped / Impacted TSs and TRs: 29.803
- 3686: SP#37 stopped
- 3687: SP#37 stopped
- 3688: SP#34 stopped. Replaced by UID_350027 and its children / Impacted TSs and TRs: 23.402
- 3689: SP#34 stopped. Replaced by UIDs 340018 and 340037. (SP#34 report discussion of SP-060917.) / Impacted TSs and TRs: 23.002, 23.060, 23.107, 23.203, 23.228, 23.234, 23.246, 23.271, 23.279
- 3690: SP#34 stopped
- 3691: RP#49 completed. Testing for CT1's UID_360022 (24.303) under Rel-8 Feature SAES / Impacted TSs and TRs: 36.508, 36.523-1, 36.523-2, 36.523-3
- 3692: CP#46 completed
- 3693: SP#39 completed / Impacted TSs and TRs: 22.101
- 3694: SP#40 completed / Impacted TSs and TRs: 23.292, 23.206
- 3695: CP#46 completed
- 3696: CP#46 completed / Impacted TSs and TRs: 24.229, new (24.292, 24.286)
- 3697: In RFC Editors Queue. Dec.14: 75->90; 7/3/16: 90%->100 / Impacted TSs and TRs: draft-ietf-salud-alert-info-urns
- 3698: CP#59 completed / Impacted TSs and TRs: RFC 6871 (was draft-ietf-mmusic-sdp-media-capabilities)
- 3699: CP#64 complete / Impacted TSs and TRs: RFC 7195 (was draft-ietf-mmusic-sdp-cs)
- 3700: CP#62 completed / Impacted TSs and TRs: RFC7006 (was draft-ietf-mmusic-sdp-miscellaneous-caps)
- 3701: CP#43 completed / Impacted TSs and TRs: new 29.292
- 3702: CP#42 completed / Impacted TSs and TRs: 23.003, 29.232, 23.018, 29.002
- 3703: CP#64 complete / Impacted TSs and TRs: RFC 7254 (was draft-montemurro-gsma-imei-urn)
- 3704: CP#41 work stopped / Impacted TSs and TRs: 24.293

| ID | WBS | Task | Duration | Start | Finish | Complete | Baseline start | Baseline finish | Baseline duration | Constraint | Resources | Work | Actual work | Acronym | Release | TSG approved | MCC resp | Acronym_3GU_Export | WI rapporteur name | WI rapporteur e-mail | PCG approved |
| --- | --- | --- | --- | --- | --- | --- | --- | --- | --- | --- | --- | --- | --- | --- | --- | --- | --- | --- | --- | --- | --- |
| 3705 | 962 | **IMS Multimedia Telephony and Supplementary Services** | 2002d? | 2007-05-02 A | 2014-12-09 A | 100% | 2007-05-02 | 2014-12-05 | 1997d? |  | S1; S5; C1; C3; C4; IETF | 272222h | 272222h | IMSTSS | Rel-8 | SP-37 | Alain | IMSTSS |  |  |  |
| 3706 | 962.1 | **General aspects of IMS Sup Services** | 395d? | 2007-09-03 A | 2009-03-06 A | 100% | 2007-09-03 | 2009-03-06 | 395d? |  | S1; C1; C3; C4 | 19232h | 19232h | IMSSS-Gal | Rel-8 | SP-37 | Alain | IMSSS-Gal | Ericsson | Susana Sabater |  |
| 3707 | 962.1.1 | Service and Capability for Core IMS - inclusion of TISPAN requirements | 75d? | 2007-09-03 A | 2007-12-14 A | 100% | 2007-09-03 | 2007-12-14 | 75d? | finish no earlier than 2007-12-14 | S1 | 600h | 600h | TISCAPR8 | Rel-8 | SP-37 | Alain | TISCAPR8 | Ericsson | Susana Sabater |  |
| 3708 | 962.1.2 | Documentation of TISPAN R1 and R2 in CT1 | 208d? | 2007-11-28 A | 2008-09-12 A | 100% | 2007-11-28 | 2008-09-12 | 208d? | finish no earlier than 2008-09-12 | C1 | 1664h | 1664h | REDOC_TIS-C1 | Rel-8 | CP-38 | Frederic | REDOC_TIS-C1 | Nokia Siemens Networks | peter.leis@nsn.com | PCG-21 |
| 3709 | 962.1.3 | Documentation of TISPAN R1 and R2 in CT3 | 333d? | 2007-11-28 A | 2009-03-06 A | 100% | 2007-11-28 | 2009-03-06 | 333d? | finish no earlier than 2009-03-06 | C3 | 2664h | 2664h | REDOC_TIS-C3 | Rel-8 | CP-38 | Adrian | REDOC_TIS-C3 | Nokia Siemens Networks | peter.leis@nsn.com | PCG-21 |
| 3710 | 962.1.4 | Documentation of TISPAN R1 and R2 in CT4 | 208d? | 2007-11-28 A | 2008-09-12 A | 100% | 2007-11-28 | 2008-09-12 | 208d? | finish no earlier than 2008-09-12 | C4 | 1664h | 1664h | REDOC_TIS-C4 | Rel-8 | CP-38 | Kimmo | REDOC_TIS-C4 | Nokia Siemens Networks | peter.leis@nsn.com | PCG-21 |
| 3711 | 962.2 | **IMS Multimedia Telephony Service** | 394d? | 2007-09-10 A | 2009-03-12 A | 100% | 2007-09-10 | 2009-03-12 | 394d? |  | S1; S5 | 9296h | 9296h | IMS-MMTel | Rel-8 | SP-37 | Alain | IMS-MMTel |  |  |  |
| 3712 | 962.2.1 | Merging TISPAN MMTel [requirements] for Common IMS | 65d? | 2007-09-10 A | 2007-12-07 A | 100% | 2007-09-10 | 2007-12-07 | 65d? | finish no earlier than 2007-12-07 | S1 | 520h | 520h | TMMTEL | Rel-8 | SP-37 | Alain | TMMTEL | Nokia Siemens Networks |  |  |
| 3713 | 962.2.2 | Multimedia Telephony Service and Supplementary Services (MMTel) offline Charging | 309d? | 2008-01-07 A | 2009-03-12 A | 100% | 2008-01-07 | 2009-03-12 | 309d? | finish no earlier than 2009-03-12 | S5 | 2472h | 2472h | MMTel-CH | Rel-8 | SP-38 | Mirko | MMTel-CH | Alcatel-Lucent | maryse.gardella@alcatel-lucent.com | PCG-21 |
| 3714 | 962.3 | **Call Completion on Busy Subscriber (CCBS)/Call Completion on Non-Reachable (CCNR) on IMS** | 1608d? | 2007-05-02 A | 2013-06-14 A | 100% | 2007-05-02 | 2013-06-14 | 1608d? |  | C1; C3; IETF | 71528h | 71528h | CCBS_CCNR | Rel-8 | SP-38 | Frederic | CCBS_CCNR | Deutsche Telekom | martin.huelsemann@telekom.de | PCG-21 |
| 3715 | 962.3.1 | CT1 part of Stage 3 CCBS_CCNR | 483d? | 2007-05-02 A | 2009-03-06 A | 100% | 2007-05-02 | 2009-03-06 | 483d? | finish no earlier than 2009-03-06 | C1 | 3864h | 3864h | CCBS_CCNR | Rel-8 | CP-38 | Frederic |  | Deutsche Telekom | martin.huelsemann@telekom.de | PCG-21 |
| 3716 | 962.3.2 | CT3 part of Stage 3 CCBS_CCNR | 418d? | 2007-05-02 A | 2008-12-05 A | 100% | 2007-05-02 | 2008-12-05 | 418d? | finish no earlier than 2008-12-05 | C3 | 3344h | 3344h | CCBS_CCNR | Rel-8 | CP-38 | Adrian |  | Deutsche Telekom | martin.huelsemann@telekom.de | PCG-21 |
| 3717 | 962.3.3 | (IETF) Stage 3 CCBS_CCNR [RFC 6910 (was draft-ietf-bliss-call-completion)] | 1608d? | 2007-05-02 A | 2013-06-14 A | 100% | 2007-05-02 | 2013-06-14 | 1608d? | finish no earlier than 2013-06-10 | C1-IETF; C3-IETF | 25728h | 25728h | CCBS_CCNR | Rel-8 | CP-52 | Frederic |  | Roland Jesske |  | PCG-27 |
| 3718 | 962.4 | **Flexible Alerting** | 288d? | 2008-01-30 A | 2009-03-06 A | 100% | 2008-01-30 | 2009-03-06 | 288d? |  | S1; C1 | 7582.4h | 7582.4h | FA | Rel-8 | SP-39 | Alain | FA | Nortel | milanpa@nortel.com | PCG-21 |
| 3719 | 962.4.1 | Stage 1 FA | 92d? | 2008-01-30 A | 2008-06-05 A | 100% | 2008-01-30 | 2008-06-05 | 92d? |  | S1 | 670.4h | 670.4h | FA | Rel-8 | SP-39 | Alain |  | Telecom Italia |  | PCG-21 |
| 3720 | 962.4.2 | Stage 3 FA | 288d? | 2008-01-30 A | 2009-03-06 A | 100% | 2008-01-30 | 2009-03-06 | 288d? | finish no earlier than 2009-03-06 | C1 | 2304h | 2304h | FA | Rel-8 | CP-39 | Frederic |  | Nortel | milanpa@nortel.com | PCG-21 |
| 3721 | 962.5 | **Communication Wait on IMS** | 1965d? | 2007-06-22 A | 2014-12-09 A | 100% | 2007-06-22 | 2014-12-05 | 1960d? |  | C1; C3; IETF | 61880h | 61880h | CW_IMS | Rel-8 | SP-38 | Frederic | CW_IMS | Deutsche Telekom | martin.huelsemann@telekom.de | PCG-21 |
| 3722 | 962.5.1 | CT1 part of Stage 3 CW-IMS | 331d? | 2007-11-30 A | 2009-03-06 A | 100% | 2007-11-30 | 2009-03-06 | 331d? | finish no earlier than 2009-03-06 | C1 | 2648h | 2648h | CW_IMS | Rel-8 | CP-38 | Frederic |  | Deutsche Telekom | martin.huelsemann@telekom.de | PCG-21 |
| 3723 | 962.5.2 | (IETF) Stage 3 CW-IMS (salud-alert-info-urns) | 1244d? | 2007-06-22 A | 2014-12-09 A | 100% | 2007-06-22 | 2014-12-05 | 1242d? | finish no earlier than 2014-12-09 | C1-IETF | 9952h | 9952h | CW_IMS | Rel-8 | CP-52 | Frederic |  | Roland Jesske | Roland Jesske | PCG-27 |
| 3724 | 962.5.3 | CT3 part of Stage 3 CW-IMS | 265d? | 2007-11-30 A | 2008-12-04 A | 100% | 2007-11-30 | 2008-12-04 | 265d? | finish no earlier than 2008-12-05 | C3 | 2120h | 2120h | CW_IMS | Rel-8 | CP-38 | Adrian |  | Deutsche Telekom | martin.huelsemann@telekom.de | PCG-21 |
| 3725 | 962.6 | **IMS Charging** | 389d? | 2007-09-17 A | 2009-03-12 A | 100% | 2007-09-17 | 2009-03-12 | 389d? |  | S5 | 6608h | 6608h | CH8_IMS | Rel-8 | SP-37 | Mirko | CH8 | Alcatel-Lucent | maryse.gardella@alcatel-lucent.com |  |
| 3726 | 962.6.1 | Add Interconnection Border Control Function (IBCF) to IMS Charging | 128d? | 2007-09-17 A | 2008-03-12 A | 100% | 2007-09-17 | 2008-03-12 | 128d? | finish no earlier than 2008-03-12 | S5 | 1024h | 1024h | CH8_IMS | Rel-8 | SP-37 | Mirko |  | Alcatel-Lucent | maryse.gardella@alcatel-lucent.com |  |
| 3727 | 962.6.2 | Advice of Charge (AoC) support in IMS Charging | 309d? | 2008-01-07 A | 2009-03-12 A | 100% | 2008-01-07 | 2009-03-12 | 309d? | finish no earlier than 2009-03-12 | S5 | 2472h | 2472h | CH8_IMS | Rel-8 | SP-38 | Mirko |  | Nokia Siemens Networks | Gerald.Goermer@nsn.com | PCG-21 |
| 3728 | 963 | **3GPP2 Input to Common IMS** | 200d? | 2008-03-07 A | 2008-12-11 A | 100% | 2008-03-07 | 2008-12-11 | 200d? |  | S1; S2; S3; C1; C3; C4 | 21453.2h | 21453.2h | CIMS_3GPP2 | Rel-8 | SP-39 | Alain | CIMS_3GPP2, IMS_Common | Nortel | Amar Deol (deola@nortelnetworks.com) | PCG-21 |
| 3729 | 963.1 | Stage 1 CIMS_3GPP2 | 30.65d? | 2008-03-12 A | 2008-06-05 A | 100% | 2008-03-12 | 2008-06-05 | 30.65d? | finish no earlier than 2008-06-12 | S1 | 245.2h | 245.2h | CIMS_3GPP2 | Rel-8 | SP-39 | Alain |  | Nortel | Amar Deol (deola@nortelnetworks.com) | PCG-21 |
| 3730 | 963.2 | Stage 2 CIMS_3GPP2 | 62d? | 2008-03-12 A | 2008-06-05 A | 100% | 2008-03-12 | 2008-06-05 | 62d? | finish no earlier than 2008-09-11 | S2 | 496h | 496h | CIMS_3GPP2 | Rel-8 | SP-39 | Maurice |  | Nortel | Amar Deol (deola@nortelnetworks.com) | PCG-21 |
| 3731 | 963.3 | Security CIMS_3GPP2 | 197d? | 2008-03-12 A | 2008-12-11 A | 100% | 2008-03-12 | 2008-12-11 | 197d? | finish no earlier than 2008-12-11 | S3 | 1576h | 1576h | CIMS_3GPP2 | Rel-8 | SP-39 | Mirko |  | Nortel | Amar Deol (deola@nortelnetworks.com) | PCG-21 |

Notes:
- 3705: SP#43 completed
- 3706: CP#43 completed
- 3707: SP#39 completed / Impacted TSs and TRs: 22.228, 22.115, 22.101
- 3708: CP#41 completed / Impacted TSs and TRs: 24.141, 24.147, 24.173, 24.229, 24.247, 24.341, 24.604, 24.605, 24.606, 24.607, 24.608, 24.610, 24.611, 24.616, 24.623, 24.628, 24.629, 24.647, 24.654
- 3709: CP#43 completed / Impacted TSs and TRs: 29.162, 29.163, 29.658
- 3710: CP#41 completed / Impacted TSs and TRs: 29.228, 29.229
- 3711: SP#43 completed
- 3712: SP#38 completed / Impacted TSs and TRs: 22.173
- 3713: CP#43 completed / Impacted TSs and TRs: 32.275, 32.298/299
- 3714: CP#43 completed
- 3715: CP#43 completed / Impacted TSs and TRs: 24.642, 24.229, 24.173
- 3716: CP#42 completed / Impacted TSs and TRs: 29.163
- 3717: CP#60 completed / Impacted TSs and TRs: RFC 6910 (was draft-ietf-bliss-call-completion)
- 3718: CP#43 completed
- 3719: SP#40 completed / Impacted TSs and TRs: 22.173
- 3720: CP#43 completed / Impacted TSs and TRs: 24.239, 24.173
- 3721: CP#43 completed
- 3722: CP#43 completed / Impacted TSs and TRs: 24.615, 24.229, 24.173
- 3723: In RFC Editors Queue. Dec.14: 75->90; 7/3/16: 90%->100 / Impacted TSs and TRs: draft-ietf-salud-alert-info-urns
- 3724: CP#42 completed / Impacted TSs and TRs: 29.163
- 3725: SP#39 completed / Impacted TSs and TRs: 32.260, 32.298
- 3726: SP#39 completed / Impacted TSs and TRs: 32.260, 32.298
- 3727: SP#43 completed / Impacted TSs and TRs: 32.240, 32.260, 32.296, 32.298, 32.299, new 32.280
- 3728: TSG#42 completed. Acronym changed from "CIMS_3GPP2, IMS_Common"
- 3729: SP#40 completed. Acronym changed from "CIMS_3GPP2, IMS_Common" / Impacted TSs and TRs: 22.228, 22.173, 22.101, 22.153
- 3730: SP#40 completed. Acronym changed from "CIMS_3GPP2, IMS_Common" / Impacted TSs and TRs: 23.002, 23.141, 23.203, 23.167, 23.228
- 3731: SP#42 completed [issues addressed under UID_370078 (IMS-Sec)]. Acronym changed from "CIMS_3GPP2, IMS_Common" / Impacted TSs and TRs: 33.141, 33.203, 33.210

| ID | WBS | Task | Duration | Start | Finish | Complete | Baseline start | Baseline finish | Baseline duration | Constraint | Resources | Work | Actual work | Acronym | PCG approved | WI rapporteur name | WI rapporteur e-mail | Release | TSG approved | MCC resp | Acronym_3GU_Export | TSG stopped |
| --- | --- | --- | --- | --- | --- | --- | --- | --- | --- | --- | --- | --- | --- | --- | --- | --- | --- | --- | --- | --- | --- | --- |
| 3732 | 963.4 | **Stage 3 CIMS_3GPP2** | 200d? | 2008-03-07 A | 2008-12-11 A | 100% | 2008-03-07 | 2008-12-11 | 200d? |  | C1; C3; C4 | 9536h | 9536h | REDOC_3GPP2 | PCG-21 | Alcatel-Lucent | orsic@alcatel-lucent.com | Rel-8 | CP-39 | Frederic | REDOC_3GPP2 |  |
| 3733 | 963.4.1 | Stage 3 CIMS_3GPP2 (CT1) | 196d? | 2008-03-07 A | 2008-12-05 A | 100% | 2008-03-07 | 2008-12-05 | 196d? | finish no earlier than 2008-12-11 | C1 | 1568h | 1568h | REDOC_3GPP2 | PCG-21 | Alcatel-Lucent | orsic@alcatel-lucent.com | Rel-8 | CP-39 | Frederic |  |  |
| 3734 | 963.4.2 | Stage 3 CIMS_3GPP2 (CT3) | 196d? | 2008-03-07 A | 2008-12-05 A | 100% | 2008-03-07 | 2008-12-05 | 196d? | finish no earlier than 2008-12-05 | C3 | 1568h | 1568h | REDOC_3GPP2 | PCG-21 | Alcatel-Lucent | orsic@alcatel-lucent.com | Rel-8 | CP-39 | Adrian |  |  |
| 3735 | 963.4.3 | Stage 3 CIMS_3GPP2 (CT4) | 200d? | 2008-03-07 A | 2008-12-11 A | 100% | 2008-03-07 | 2008-12-11 | 200d? | finish no earlier than 2008-12-11 | C4 | 1600h | 1600h | REDOC_3GPP2 | PCG-21 | Alcatel-Lucent | orsic@alcatel-lucent.com | Rel-8 | CP-39 | Kimmo |  |  |
| 3736 | 964 | **IMS Enhancements for support of Packet Cable access** | 388d? | 2006-12-06 A | 2008-05-30 A | 100% | 2006-12-06 | 2008-05-30 | 388d? |  | S2; S3; C1; C3; C4 | 58616h | 58616h | PktCbl |  | Cablelabs | Bernie McKibben (b.mckibben@cablelabs.com) | Rel-8 | TSG-35 | Maurice | PktCbl |  |
| 3737 | 964.1 | **IMS Enhancements for Cable Client Types and Deployment Models** | 345d? | 2007-02-05 A | 2008-05-30 A | 100% | 2007-02-05 | 2008-05-30 | 345d? |  | S2; C1 | 9752h | 9752h | PktCbl-Deploy |  | Cablelabs | Bernie McKibben (b.mckibben@cablelabs.com) | Rel-8 |  | Maurice | PktCbl-Deploy |  |
| 3738 | 964.1.1 | Architecture aspects of PktCbl-Deploy | 219d? | 2007-02-05 A | 2007-12-06 A | 100% | 2007-02-05 | 2007-12-06 | 219d? | finish no earlier than 2007-12-03 | S2 | 1752h | 1752h | PktCbl-Deploy |  | Cablelabs | Bernie McKibben (b.mckibben@cablelabs.com) | Rel-8 |  | Maurice |  |  |
| 3739 | 964.1.2 | CT1 aspects of PktCbl-Deploy | 310d? | 2007-03-26 A | 2008-05-30 A | 100% | 2007-03-26 | 2008-05-30 | 310d? | finish no earlier than 2008-06-15 | C1 | 2480h | 2480h | PktCbl-Deploy |  | Cablelabs | D.Hancock@CableLabs.com | Rel-8 |  | Frederic |  |  |
| 3740 | 964.2 | **IMS Inter-working aspects in Support of Cable Regulatory requirements** | 290d? | 2007-02-05 A | 2008-03-14 A | 100% | 2007-02-05 | 2008-03-14 | 290d? |  | S2; C1; C3 | 12320h | 12320h | PktCbl-Intw |  | Cablelabs | B.McKibben@CableLabs.com | Rel-8 |  | Maurice | PktCbl-Intw |  |
| 3741 | 964.2.1 | Architecture aspects of PktCbl-Interwork | 160d? | 2007-02-05 A | 2007-09-14 A | 100% | 2007-02-05 | 2007-09-14 | 160d? | start no earlier than 2007-02-05 | S2 | 1280h | 1280h | PktCbl-Intw |  | Cablelabs | B.McKibben@CableLabs.com | Rel-8 |  | Maurice |  |  |
| 3742 | 964.2.2 | CT1,CT3 aspects of PktCbl-Interwork | 255d? | 2007-03-26 A | 2008-03-14 A | 100% | 2007-03-26 | 2008-03-14 | 255d? | finish no earlier than 2008-03-15 | C1; C3 | 4080h | 4080h | PktCbl-Intw |  | Cablelabs | D.Hancock@CableLabs.com | Rel-8 |  | Frederic |  |  |
| 3743 | 964.3 | **IMS Enhancements for Security Requirements in Support of Cable Deployments** | 388d? | 2006-12-06 A | 2008-05-30 A | 100% | 2006-12-06 | 2008-05-30 | 388d? |  | S3; C1; C3; C4 | 21024h | 21024h | PktCbl-Sec |  | Cablelabs | s.dotson@cablelabs.com | Rel-8 | TSG-34 | Mirko | PktCbl-Sec |  |
| 3744 | 964.3.1 | SA3 aspects of PktCbl-Sec | 331d? | 2006-12-06 A | 2008-03-12 A | 100% | 2006-12-06 | 2008-03-12 | 331d? | finish no earlier than 2007-12-20 | S3 | 2648h | 2648h | PktCbl-Sec |  | Cablelabs | s.dotson@cablelabs.com | Rel-8 |  | Mirko |  |  |
| 3745 | 964.3.2 | CT1 aspects of PktCbl-Sec | 310d? | 2007-03-26 A | 2008-05-30 A | 100% | 2007-03-26 | 2008-05-30 | 310d? | finish no earlier than 2008-06-06 | C1 | 2480h | 2480h | PktCbl-Sec |  | Cablelabs | D.Hancock@CableLabs.com | Rel-8 |  | Frederic |  |  |
| 3746 | 964.3.3 | CT3 aspects of PktCbl-Sec | 180d? | 2007-03-26 A | 2007-11-30 A | 100% | 2007-03-26 | 2007-11-30 | 180d? | finish no earlier than 2008-03-15 | C3 | 1440h | 1440h | PktCbl-Sec | PCG-21 | Cablelabs | D.Hancock@CableLabs.com | Rel-8 | CP-38 | Adrian |  |  |
| 3747 | 964.3.4 | CT4 aspects of PktCbl-Sec | 255d? | 2007-03-26 A | 2008-03-14 A | 100% | 2007-03-26 | 2008-03-14 | 255d? | finish no earlier than 2008-03-14 | C4 | 2040h | 2040h | PktCbl-Sec |  | Cablelabs | D.Hancock@CableLabs.com | Rel-8 |  | Kimmo |  |  |
| 3748 | 965 | **IMS System enhancements for corporate network access** | 1901d? | 2007-06-22 A | 2014-09-12 A | 100% | 2007-06-22 | 2014-12-05 | 1960d? |  | S2; S1; C1; C4; IETF | 91240.9h | 91240.9h | IMS_Corp |  | Orange | Delphin Barankanira | Rel-8 |  | Maurice | IMS_Corp |  |
| 3749 | 965.1 | SA1 aspects of IMS_Corp | 23.6d? | 2008-03-12 A | 2008-06-05 A | 100% | 2008-03-12 | 2008-06-05 | 23.6d? | finish no earlier than 2008-06-05 | S1 | 188.8h | 188.8h | IMS_Corp | PCG-21 | Telecom Italia |  | Rel-8 | SP-39 | Alain |  |  |
| 3750 | 965.2 | SA2 aspects of IMS_Corp | 325d? | 2007-06-22 A | 2008-09-18 A | 100% | 2007-06-22 | 2008-09-18 | 325d? | finish no earlier than 2008-12-25 | S2 | 2600h | 2600h | IMS_Corp |  | Orange | Delphin Barankanira | Rel-8 |  | Maurice |  |  |
| 3751 | 965.3 | CT1 aspects of IMS_Corp | 532d? | 2008-03-07 A | 2010-03-19 A | 100% | 2008-03-07 | 2010-03-19 | 532d? | finish no earlier than 2010-03-19 | C1 | 4244.09h | 4244.09h | IMS_Corp | PCG-21 | Alcatel-Lucent | Keith Drage (drage@alcatel-lucent.com) | Rel-8 | CP-39 | Frederic |  |  |
| 3752 | 965.4 | (IETF) CT1 aspects of IMS_Corp (RFC 7316) | 825d? | 2011-06-29 A | 2014-09-12 A | 100% | 2011-06-29 | 2014-12-05 | 885d? | finish no earlier than 2014-09-12 | C1-IETF | 6600h | 6600h | IMS_Corp | PCG-27 | Keith Drage | Keith Drage (drage@alcatel-lucent.com) | Rel-8 | CP-53 | Frederic |  |  |
| 3753 | 965.5 | CT4 aspects of IMS_Corp | 196d? | 2008-02-26 A | 2008-12-05 A | 100% | 2008-02-26 | 2008-12-05 | 196d? | finish no earlier than 2008-12-11 | C4 | 1568h | 1568h | IMS_Corp | PCG-21 | Alcatel-Lucent | Keith Drage (drage@alcatel-lucent.com) | Rel-8 | CP-39 | Kimmo |  |  |
| 3754 | 966 | **Maintenance of TISPAN documentation** | 1829d? | 2007-07-02 A | 2014-06-13 A | 100% | 2007-07-02 | 2014-06-13 | 1829d? |  | S2; C1; C3; C4; IETF | 85904h | 85904h | MAINTISP | PCG-21 |  |  | Rel-8 | SP-38 | Maurice | MAINTISP |  |
| 3755 | 966.1 | Maintenance of TISPAN R2 | 86d? | 2007-11-09 A | 2008-03-07 A | 100% | 2007-11-09 | 2008-03-07 | 86d? | start no earlier than 2007-11-09 | C1; C3; C4 | 2064h | 2064h | MAINT_R2 | PCG-21 | Alcatel-Lucent | Keith Drage (drage@alcatel-lucent.com) | Rel-8 | CP-38 | Frederic | MAINT_R2 |  |
| 3756 | 966.2 | Deleted - (IETF) Maintenance of TISPAN R2 (avasarala-dispatch-comm-div-notification) | 1117d? | 2007-11-09 A | 2014-06-13 A | 100% | 2007-11-09 | 2014-06-13 | 1117d? | finish no earlier than 2014-06-13 | C1-IETF | 8936h | 8936h | MAINT_R2_IETF | PCG-27 | Andrew Allen |  | Rel-8 | CP-52 | Frederic | MAINT_R2_IETF | SP-69 |
| 3757 | 966.3 | Documentation of TISPAN NGN R1 and R2 in 3GPP SA2 | 104d? | 2008-01-14 A | 2008-06-05 A | 100% | 2008-01-14 | 2008-06-05 | 104d? | finish no earlier than 2008-06-20 | S2 | 832h | 832h | IMS_Comm_Doc | PCG-21 | Nokia Siemens Networks | jozsef.varga@nsn.com | Rel-8 | SP-38 | Maurice | IMS_Comm_Doc |  |
| 3758 | 966.4 | Maintenance of TISPAN release 2 common IMS | 114d? | 2007-07-02 A | 2007-12-06 A | 100% | 2007-07-02 | 2007-12-06 | 114d? | finish no earlier than 2007-12-06 | S2 | 912h | 912h | IMS_Comm_Mtce8 | PCG-21 | Telecom Italia | antonio.ascolese@telecomitalia.it | Rel-8 | SP-38 | Maurice | IMS_Comm_Mtce8 |  |

Notes:
- 3732: -
- 3733: CP#42 completed / Impacted TSs and TRs: 23.218, 24.141, 24.147, 24.173, 24.229, 24.238, 24.247, 24.604, 24.605, 24.606, 24.607, 24.608, 24.610, 24.611, 24.629, 24.930
- 3734: CP#42 completed / Impacted TSs and TRs: 29.163, 29.212, 29.213, 29.214
- 3735: CP#42 completed / Impacted TSs and TRs: 29.228, 29.229, 29.328, 29.329
- 3736: CP#40 completed
- 3737: CP#40 completed
- 3738: SP#38 completed / Impacted TSs and TRs: 23.228
- 3739: CP#40 completed
- 3740: CP#39 completed
- 3741: SP#37 completed / Impacted TSs and TRs: 23.228
- 3742: CP#39 completed / Impacted TSs and TRs: 24.229
- 3743: CP#40 completed
- 3744: SP#39 completed / Impacted TSs and TRs: 33.203, 33.210, 33.220
- 3745: CP#40 completed / Impacted TSs and TRs: 24.229
- 3746: CP#38 completed / Impacted TSs and TRs: 29.163
- 3747: CP#39 completed / Impacted TSs and TRs: 29.228, 29.229, 23.008
- 3748: CP#47 completed
- 3749: SP#40 completed
- 3750: no Stage 2 impacts / Impacted TSs and TRs: 23.228
- 3751: CP#47 completed / Impacted TSs and TRs: 24.229, 24.503
- 3752: CP#65 completed / Impacted TSs and TRs: RFC 7316 (was draft-vanelburg-dispatch-private-network-ind)
- 3753: CP#42 completed / Impacted TSs and TRs: 29.228, 29.229, 23.003, 23.008, 29.433
- 3754: SP#40 completed
- 3755: CP#39 completed / Impacted TSs and TRs: 24.406, 24.407, 24.410, 24.411, 24.423, 24.430, 24.447, 24.451, 24.454, 24.503, 24.505, 24.508, 24.516, 24.528, 24.529, 29.412, 29.421, 29.433, 29.458, 29.527, 29.624
- 3756: CP#64 Draft removed from 3GPP documentation / Impacted TSs and TRs: draft-avasarala-dispatch-comm-div-notification
- 3757: SP#40 completed / Impacted TSs and TRs: 23.228, 23.204, 23.167
- 3758: SP#38 completed / Impacted TSs and TRs: 23.506, 23.507,23.517, 23.521

| ID | WBS | Task | Type | Duration | Start | Finish | Complete | Baseline start | Baseline finish | Baseline duration | Constraint | Resources | Work | Actual work | Acronym | PCG approved | WI rapporteur name | WI rapporteur e-mail | Release | TSG approved | MCC resp | Acronym_3GU_Export | Impacted TSs and TRs |
| --- | --- | --- | --- | --- | --- | --- | --- | --- | --- | --- | --- | --- | --- | --- | --- | --- | --- | --- | --- | --- | --- | --- | --- |
| 3759 | 967 | **IMS Service Continuity** |  | 318d? | 2008-03-12 A | 2009-05-29 A | 100% | 2008-03-12 | 2009-05-29 | 318d? |  | S2; S1; C1 | 10712h | 10712h | IMS-Cont | PCG-21 | LG Electronics | JaeSeung SONG (anthonys@lge.com) | Rel-8 | SP-39 | Maurice | IMS-Cont |  |
| 3760 | 967.1 | Stage 1 IMS Service Continuity |  | 62d? | 2008-03-12 A | 2008-06-05 A | 100% | 2008-03-12 | 2008-06-05 | 62d? | start no earlier than 2008-03-12 | S1 | 496h | 496h | IMS-Cont | PCG-21 | LG Electronics | JaeSeung SONG (anthonys@lge.com) | Rel-8 | SP-39 | Alain |  |  |
| 3761 | 967.2 | Stage 2 IMS Service Continuity |  | 62d? | 2008-03-12 A | 2008-06-05 A | 100% | 2008-03-12 | 2008-06-05 | 62d? | finish no earlier than 2008-06-05 | S2 | 496h | 496h | IMS-Cont | PCG-21 | LG Electronics | JaeSeung SONG (anthonys@lge.com) | Rel-8 | SP-39 | Maurice |  | 23.237, 23.292 |
| 3762 | 967.3 | Stage 3 IMS Service Continuity |  | 261d? | 2008-05-30 A | 2009-05-29 A | 100% | 2008-05-30 | 2009-05-29 | 261d? | finish no earlier than 2009-05-29 | C1 | 2088h | 2088h | IMS-Cont | PCG-21 | Huawei | Lili Yang (kadyyang@huawei.com) | Rel-8 | CP-40 | Frederic |  | 24.237, 24.229, 24.216 |
| 3763 | 968 | **Security Enhancements for IMS** |  | 643.3d? | 2006-09-19 A | 2009-03-06 A | 100% | 2006-09-19 | 2009-03-06 | 643.3d? |  | S3; C1; C4 | 29847.2h | 29847.2h | IMS-Sec |  | Ericsson | Bengt.Sahlin@ericsson.com | Rel-8 | SP-37 | Mirko | IMS-Sec |  |
| 3764 | 968.1 | Stage 2 for IMS-Sec |  | 466d? | 2007-03-01 A | 2008-12-11 A | 100% | 2007-03-01 | 2008-12-11 | 466d? | finish no earlier than 2008-12-11 | S3 | 3728h | 3728h | IMS-Sec |  | Ericsson | Bengt.Sahlin@ericsson.com | Rel-8 |  | Mirko |  | 33.203, 33.141, 33.803 |
| 3765 | 968.2 | CT1 part of Stage 3 for IMS-Sec |  | 392d? | 2006-09-19 A | 2008-12-05 A | 100% | 2006-09-19 | 2008-12-05 | 392d? | finish no earlier than 2008-12-05 | C1 | 3136h | 3136h | IMS-Sec | PCG-21 | Ericsson |  | Rel-8 | CP-39 | Frederic |  |  |
| 3766 | 968.3 | CT4 part of Stage 3 for IMS-Sec |  | 457d? | 2007-06-07 A | 2009-03-06 A | 100% | 2007-06-07 | 2009-03-06 | 457d? | finish no earlier than 2009-03-06 | C4 | 3656h | 3656h | IMS-Sec | PCG-21 | Ericsson |  | Rel-8 | CP-39 | Kimmo |  |  |
| 3767 | 968.4 | CT1 part of Network Attachment Subsystem (NASS) Bundled Authentication |  | 343d? | 2007-11-14 A | 2009-03-06 A | 100% | 2007-11-14 | 2009-03-06 | 343d? | finish no earlier than 2009-03-06 | C1 | 2744h | 2744h | NBA | PCG-21 | Alcatel-Lucent | Keith Drage (drage@alcatel-lucent.com) | Rel-8 | CP-39 | Frederic | NBA | 24.229 |
| 3768 | 968.5 | CT4 part of Network Attachment Subsystem (NASS) Bundled Authentication |  | 143d? | 2007-11-14 A | 2008-05-30 A | 100% | 2007-11-14 | 2008-05-30 | 143d? | start no earlier than 2007-11-14 | C4 | 1144h | 1144h | NBA-CT4 | PCG-21 | Alcatel-Lucent |  | Rel-8 | CP-39 | Kimmo | NBA-CT4 | 29.229, 29.228, 23.008 |
| 3769 | 969 | **IMS initiated and controlled PSS and MBMS User Service** |  | 924d? | 2008-03-12 A | 2011-09-21 A | 100% | 2008-03-12 | 2011-09-21 | 924d? |  | S4; S3; IETF | 28108.8h | 28108.8h | IMS_PSS_MBMS_US |  | FT, Ericsson | olle.franceschi@ericsson.com | Rel-8 |  | Paolo | IMS_PSS_MBMS_US |  |
| 3770 | 969.1 | SA4, SA3 part of IMS initiated and controlled PSS and MBMS User Service | milestone | 0d? | 2008-03-12 A | 2008-03-12 A | 100% | 2008-03-12 | 2008-03-12 | 0d? | finish no earlier than 2009-03-12 | S4; S3 |  |  | IMS_PSS_MBMS_US |  | FT, Ericsson | olle.franceschi@ericsson.com | Rel-8 |  | Paolo |  | 26.234, 26.346, 33.246, New 26.237 |
| 3771 | 969.2 | (IETF) IMS initiated and controlled PSS and MBMS User Service (RFC 6080) |  | 743.6d? | 2008-03-12 A | 2011-09-21 A | 100% | 2008-03-12 | 2011-09-21 | 743.6d? | finish no earlier than 2011-09-21 | S4-IETF | 5932.8h | 5932.8h | IMS_PSS_MBMS_US | PCG-27 | Ericsson |  | Rel-8 | SP-52 | Paolo |  | RFC 6080 (was draft-ietf-sipping-config-framework) |
| 3772 | 970 | **Multimedia interworking between IMS and CS networks** |  | 836d? | 2005-09-23 A | 2008-12-05 A | 100% | 2005-09-23 | 2008-12-05 | 836d? |  | C3; C4 | 22800h | 22800h | MIW-IMS | PCG-36 | Vodafone | nico.gabriele@vodafone.com | Rel-8 | TSG#71 | Adrian | MIW-IMS |  |
| 3773 | 970.1 | Stage 1 and 2 defined in earlier Releases |  | 49d? | 2005-09-23 A | 2005-11-30 A | 100% | 2005-09-23 | 2005-11-30 | 49d? | start no earlier than 2005-09-23 | S2 | 392h | 392h | MIW-IMS |  | Vodafone | nico.gabriele@vodafone.com | Rel-8 |  | Maurice |  |  |
| 3774 | 970.2 | Stage 3 of MW-IMS |  | 571d? | 2005-09-23 A | 2007-11-30 A | 100% | 2005-09-23 | 2007-11-30 | 571d? | finish no earlier than 2007-09-14 | C3 | 4568h | 4568h | MIW-IMS-St3C3 |  | Vodafone | nico.gabriele@vodafone.com | Rel-8 |  | Adrian | MIW-IMS-St3 | 29.863, 29.163 |
| 3775 | 970.3 | Stage 3 for MW-IMS, MONA extension |  | 285d? | 2007-11-05 A | 2008-12-05 A | 100% | 2007-11-05 | 2008-12-05 | 285d? | finish no earlier than 2008-12-05 | C3 | 2280h | 2280h | MIW-IMS-St3C3_MONA | PCG-21 | Vodafone | Christer.Holmberg@ericsson.com | Rel-8 | CP-38 | Adrian |  | 29.863, 29.163 |
| 3776 | 970.4 | Mn interface (MGCF – IM MGW) |  | 273d? | 2007-11-21 A | 2008-12-05 A | 100% | 2007-11-21 | 2008-12-05 | 273d? | finish no earlier than 2008-12-19 | C4 | 2184h | 2184h | MIW-IMS-St3C4 | PCG-21 | Vodafone | Christer.Holmberg@ericsson.com | Rel-8 | CP-38 | Kimmo |  | 29.332 |
| 3777 | 971 | **IMS Stage 3 IETF Protocol Alignment - phase 2** |  | 1965d? | 2007-06-22 A | 2014-12-09 A | 100% | 2007-06-22 | 2014-12-05 | 1960d? |  | C1; IETF | 55368h | 55368h | IMSProtoc2 |  | Alcatel-Lucent | Keith Drage (drage@alcatel-lucent.com) | Rel-8 |  | Frederic | IMSProtoc2 |  |
| 3778 | 971.1 | CT1 aspects of IMS Stage 3 IETF Protocol Alignment - phase 2 |  | 446d? | 2007-06-22 A | 2009-03-06 A | 100% | 2007-06-22 | 2009-03-06 | 446d? | finish no earlier than 2009-03-06 | C1 | 3568h | 3568h | IMSProtoc2 |  | Alcatel-Lucent | Keith Drage (drage@alcatel-lucent.com) | Rel-8 |  | Frederic |  | 23.218, 24.229, 24.930 |
| 3779 | 971.2 | (IETF) IMS Stage 3 IETF Protocol Alignment (draft-bakker-sipping-3gpp-ims-xml-body-handling) |  | 715d? | 2007-06-22 A | 2012-12-07 A | 100% | 2007-06-22 | 2012-12-07 | 715d? | finish no earlier than 2012-12-07 | C1-IETF | 5720h | 5720h | IMSProtoc2 | PCG-27 | Andrew Allen |  | Rel-8 | CP-52 | Frederic |  | draft-bakker-sipping-3gpp-ims-xml-body-handling |
| 3780 | 971.3 | (IETF) IMS Stage 3 IETF Protocol Alignment (RFC 6544) |  | 587d? | 2007-06-22 A | 2012-06-15 A | 100% | 2007-06-22 | 2012-06-15 | 587d? | finish no earlier than 2012-04-20 | C1-IETF | 4688h | 4688h | IMSProtoc2 | PCG-27 | Keith Drage |  | Rel-8 | CP-52 | Frederic |  | RFC 6544 (was draft-ietf-mmusic-ice-tcp) |
| 3781 | 971.4 | (IETF) IMS Stage 3 IETF Protocol Alignment (draft-ietf-salud-alert-info-urns) |  | 1244d? | 2007-06-22 A | 2014-12-09 A | 100% | 2007-06-22 | 2014-12-05 | 1242d? | finish no earlier than 2014-12-09 | C1-IETF | 9952h | 9952h | IMSProtoc2 | PCG-27 | Roland Jesske | Roland Jesske | Rel-8 | CP-52 | Frederic |  | draft-ietf-salud-alert-info-urns |
| 3782 | 972 | **Interworking between User-to-User Signalling (UUS) and SIP** |  | 1850d? | 2007-11-30 A | 2014-12-09 A | 100% | 2007-11-30 | 2014-12-05 | 1845d? |  | C1; C3; IETF | 68624.4h | 68624.4h | UUSIW | PCG-21 | Huawei | Lili Yang (kadyyang@huawei.com) | Rel-8 | CP-38 | Kimmo | UUSIW |  |
| 3783 | 972.1 | CT1 part of Stage 3 MGCF UUSIW |  | 266d? | 2007-11-30 A | 2008-12-05 A | 100% | 2007-11-30 | 2008-12-05 | 266d? | finish no earlier than 2008-12-05 | C1 | 2128h | 2128h | UUSIW | PCG-21 | Huawei | Lili Yang (kadyyang@huawei.com) | Rel-8 | CP-38 | Frederic |  | 24.279, 24.229 |
| 3784 | 972.2 | (IETF) Stage 3 MGCF UUSIW (cuss-sip-uui) |  | 227.03d? | 2007-11-30 A | 2014-12-09 A | 100% | 2007-11-30 | 2014-12-05 | 225.03d? | finish no earlier than 2014-12-09 | C1-IETF; C3-IETF | 3632.4h | 3632.4h | UUSIW | PCG-27 | Roland Jesske | Roland Jesske | Rel-8 | CP-52 | Frederic |  | RFC 7433 |
| 3785 | 972.3 | (IETF) Stage 3 MGCF UUSIW (cuss-sip-uui-isdn) |  | 986.5d? | 2011-03-17 A | 2014-12-09 A | 100% | 2011-03-17 | 2014-12-05 | 984.5d? | finish no earlier than 2014-12-09 | C1-IETF; C3-IETF | 15784h | 15784h | UUSIW | PCG-28 | Keith Drage | Keith Drage (drage@alcatel-lucent.com) | Rel-8 | CP-55 | Frederic |  | RFC 7434 |
| 3786 | 972.4 | CT3 part of Stage 3 MGCF UUSIW |  | 335d? | 2007-11-30 A | 2009-03-12 A | 100% | 2007-11-30 | 2009-03-12 | 335d? | finish no earlier than 2009-03-12 | C3 | 2680h | 2680h | UUSIW | PCG-21 | Huawei | Lili Yang (kadyyang@huawei.com) | Rel-8 | CP-38 | Adrian |  | 29.163 |

Notes:
- 3759: CP#44 completed
- 3760: SP#40 completed
- 3761: SP#40 completed
- 3762: CP#44 completed
- 3763: CP#43 completed
- 3764: SP#42 completed. SP#46 withdrawn draft 33.178-100 and 33.978 from Rel-8 onwards
- 3765: CP#42 completed
- 3766: CP#43 completed
- 3767: CP#43 completed
- 3768: CP#40 completed
- 3769: SP#39 WID approved
- 3770: SP#43 completed
- 3771: SP#53/IETF#81 completed
- 3772: CP#42 completed
- 3773: SP#31 Moved from FS section Feb 2006
- 3774: Moved from Rel-7. Feature extended in Rel-8 by including Stage 3 covering MONA UID_380021
- 3775: CP#42 completed
- 3776: CP#42 completed
- 3777: CP#43 completed
- 3778: CP#43 completed
- 3779: CP#58 completed. ietf-draft discontinued. Documented within 3GPP
- 3780: CP#56 completed
- 3781: In RFC Editors Queue. Dec.14: 75->90; 7/3/16: 90%->100
- 3782: CP#43 completed
- 3783: CP#42 completed
- 3784: In RFC Editors Queue. Mar15: 90->100%. RFC updated (was draft-ietf-cuss-sip-uui). June 2015: RFC 7433 (was draft-ietf-cuss-sip-uui)
- 3785: In RFC Editors Queue. Dec.14: 75->90. Mar15: 90->100%. RFC updated (was draft-ietf-cuss-sip-uui-isdn). June 2015: RFC 7434 (was draft-ietf-cuss-sip-uui-isdn)
- 3786: CP#43 completed

| ID | WBS | Task | Type | Duration | Start | Finish | Complete | Baseline start | Baseline finish | Baseline duration | Constraint | Resources | Work | Actual work | Acronym | PCG approved | WI rapporteur name | WI rapporteur e-mail | Release | TSG approved | MCC resp | Acronym_3GU_Export | Impacted TSs and TRs | Special Focus Doc | Status Report |
| --- | --- | --- | --- | --- | --- | --- | --- | --- | --- | --- | --- | --- | --- | --- | --- | --- | --- | --- | --- | --- | --- | --- | --- | --- | --- |
| 3787 | 973 | **Support of Overlap signalling** |  | 331d? | 2007-11-30 A | 2009-03-06 A | 100% | 2007-11-30 | 2009-03-06 | 331d? |  | C3; C1; C4 | 15304.2h | 15304.2h | Overlap | PCG-21 | Deutsche Telekom | r.jesske@telekom.de | Rel-8 | CP-38 | Adrian | Overlap |  |  |  |
| 3788 | 973.1 | Stage 3 Overlap (CT1) |  | 331d? | 2007-11-30 A | 2009-03-06 A | 100% | 2007-11-30 | 2009-03-06 | 331d? | finish no earlier than 2009-03-06 | C1 | 2648h | 2648h | Overlap | PCG-21 | Deutsche Telekom | r.jesske@telekom.de | Rel-8 | CP-38 | Frederic |  | 24.229 |  |  |
| 3789 | 973.2 | Stage 3 Overlap (CT3) |  | 331d? | 2007-11-30 A | 2009-03-06 A | 100% | 2007-11-30 | 2009-03-06 | 331d? | finish no earlier than 2009-03-06 | C3 | 2648h | 2648h | Overlap | PCG-21 | Deutsche Telekom | r.jesske@telekom.de | Rel-8 | CP-38 | Adrian |  | 29.163 |  |  |
| 3790 | 973.3 | Stage 3 Overlap (CT4) |  | 258.02d? | 2007-11-30 A | 2008-12-05 A | 100% | 2007-11-30 | 2008-12-05 | 258.02d? | start no earlier than 2007-11-30 | C4 | 2064.16h | 2064.16h | Overlap | PCG-21 | Deutsche Telekom | r.jesske@telekom.de | Rel-8 | CP-38 | Kimmo |  | 29.228, 29.229 |  |  |
| 3791 | 974 | **AS/MRFC Stage 2 and 3** |  | 1203d? | 2007-11-14 A | 2012-06-15 A | 100% | 2007-11-14 | 2012-06-15 | 1203d? |  | C1; IETF | 28384h | 28384h | MRFC_TS | PCG-21 | Hewlett-Packard | mark.syrett@hp.com | Rel-8 | CP-38 | Frederic | MRFC_TS |  |  |  |
| 3792 | 974.1 | AS/MRFC Stage 2 |  | 278d? | 2007-11-14 A | 2008-12-05 A | 100% | 2007-11-14 | 2008-12-05 | 278d? | finish no earlier than 2008-12-05 | C1 | 2224h | 2224h | MRFC_TS | PCG-21 | Hewlett-Packard | mark.syrett@hp.com | Rel-8 | CP-38 | Frederic |  | 23.218 |  |  |
| 3793 | 974.2 | AS/MRFC Stage 3 |  | 278d? | 2007-11-14 A | 2008-12-05 A | 100% | 2007-11-14 | 2008-12-05 | 278d? | finish no earlier than 2008-12-05 | C1 | 2224h | 2224h | MRFC_TS | PCG-21 | Hewlett-Packard | mark.syrett@hp.com | Rel-8 | CP-38 | Frederic |  | 24.229, 24.147, 24.247 |  |  |
| 3794 | 974.3 | (IETF) AS/MRFC Stage 2 and 3 (RFC 6505) |  | 590d? | 2007-11-14 A | 2012-06-15 A | 100% | 2007-11-14 | 2012-06-15 | 590d? | finish no earlier than 2012-06-15 | C1-IETF | 4688h | 4688h | MRFC_TS | PCG-27 | Keith Drage |  | Rel-8 | CP-52 | Frederic |  | RFC 6505 (was draft-ietf-mediactrl-mixer-control-package) |  |  |
| 3795 | 975 | **IMS Restoration Procedures** |  | 201d? | 2008-05-30 A | 2009-03-06 A | 100% | 2008-05-30 | 2009-03-06 | 201d? |  | C4; C1 | 6432h | 6432h | IMS_RP | PCG-21 | Ericsson | german.blanco@ericsson.com | Rel-8 | SP-40 | Kimmo | IMS_RP |  |  |  |
| 3796 | 975.1 | IMS Restoration Procedures (CT4) |  | 201d? | 2008-05-30 A | 2009-03-06 A | 100% | 2008-05-30 | 2009-03-06 | 201d? | finish no earlier than 2009-03-06 | C4 | 1608h | 1608h | IMS_RP | PCG-21 | Ericsson | german.blanco@ericsson.com | Rel-8 | SP-40 | Kimmo |  | 23.380, 29.228, 29.229, 29.230, 23.008 |  |  |
| 3797 | 975.2 | IMS Restoration Procedures (CT1) |  | 201d? | 2008-05-30 A | 2009-03-06 A | 100% | 2008-05-30 | 2009-03-06 | 201d? | finish no earlier than 2009-03-06 | C1 | 1608h | 1608h | IMS_RP | PCG-21 | Ericsson | german.blanco@ericsson.com | Rel-8 | SP-40 | Frederic |  | 24.229 |  |  |
| 3798 | 976 | IMS Application Server Service Data Descriptions for AS interoperability |  | 125d? | 2008-09-12 A | 2009-03-06 A | 100% | 2008-09-12 | 2009-03-06 | 125d? | finish no earlier than 2009-03-06 | C4 | 1000h | 1000h | IMS_ASIO | PCG-21 | Alcatel-Lucent | nhberry@alcatel-lucent.com | Rel-8 | CP-41 | Kimmo | IMS_ASIO | 29.328, 29.329, 29.364 |  |  |
| 3799 | 977 | **I-WLAN Network Selection Principle (NSP)** |  | 451d? | 2007-06-14 A | 2009-03-06 A | 100% | 2007-06-14 | 2009-03-06 | 451d? |  | S1; C1; C6 | 13859.2h | 13859.2h | IWLANNSP |  | Telefónica O2 | chris.friel@O2.com | Rel-8 | TSG-34 | Alain | IWLANNSP |  | WLAN |  |
| 3800 | 977.1 | Stage 1 for I-WLAN NSP | milestone | 0d? | 2007-06-14 A | 2007-06-14 A | 100% | 2007-06-14 | 2007-06-14 | 0d? |  | S1 |  |  | IWLANNSP | PCG-21 | Telefónica O2 | chris.friel@O2.com | Rel-8 | SP-39 | Alain |  | 22.234 | WLAN |  |
| 3801 | 977.2 | CT1 part of Stage 3 for I-WLAN NSP |  | 261d? | 2008-03-07 A | 2009-03-06 A | 100% | 2008-03-07 | 2009-03-06 | 261d? | finish no earlier than 2008-12-05 | C1 | 2088h | 2088h | IWLANNSP | PCG-21 | Research In Motion | Adrian Buckley (abuckley@rim.com) | Rel-8 | CP-39 | Frederic |  | 24.234 | WLAN |  |
| 3802 | 977.3 | CT6 part of Stage 3 for I-WLAN NSP |  | 118.4d? | 2008-03-07 A | 2008-12-11 A | 100% | 2008-03-07 | 2008-12-11 | 118.4d? | finish no earlier than 2008-12-11 | C6 | 947.2h | 947.2h | IWLANNSP | PCG-21 | Research In Motion | Adrian Buckley (abuckley@rim.com) | Rel-8 | CP-39 | Xavier |  | 31.102, 31.111 | WLAN |  |
| 3803 | 978 | **Mobility between 3GPP-WLAN Interworking and 3GPP Systems** |  | 386d? | 2007-09-14 A | 2009-03-06 A | 100% | 2007-09-14 | 2009-03-06 | 386d? |  | S2; C1 | 9304h | 9304h | IWLAN_Mob |  | Orange | xiaobao.chen@orange-ftgroup.com | Rel-8 | SP-37 | Maurice | IWLAN_Mob |  | WLAN |  |
| 3804 | 978.1 | Stage 2 for Mobility between 3GPP-WLAN Interworking and 3GPP Systems |  | 190d? | 2007-09-14 A | 2008-06-05 A | 100% | 2007-09-14 | 2008-06-05 | 190d? | finish no earlier than 2008-09-08 | S2 | 1520h | 1520h | IWLAN_Mob | PCG-21 | Orange | xiaobao.chen@orange-ftgroup.com | Rel-8 | SP-38 | Maurice |  | new 23.327 | WLAN |  |
| 3805 | 978.2 | CT1 aspects of Mobility between 3GPP-WLAN Interworking and 3GPP Systems |  | 201d? | 2008-05-30 A | 2009-03-06 A | 100% | 2008-05-30 | 2009-03-06 | 201d? | finish no earlier than 2009-03-06 | C1 | 1608h | 1608h | IWLAN_Mob | PCG-21 | Orange | reina.nader@orange-ftgroup.com | Rel-8 | CP-40 | Frederic |  | 24.303, new 24.327 | WLAN |  |
| 3806 | 979 | Conformance Test Aspects – Mobility between 3GPP WLAN Interworking and 3GPP Systems |  | 206d? | 2009-12-04 A | 2010-09-17 A | 100% | 2009-12-04 | 2010-09-17 | 206d? | finish no earlier than 2010-09-17 | R5 | 1648h | 1648h | IWLAN_Mob_UEConTest | PCG-24 | Qualcomm | Patrick Stupar (pstupar@qualcomm.com) | Rel-8 | RP-46 | Ingbert | IWLAN_Mob_UEConTest | 34.108, 34.123-1, 34.123-2, 34.123-3 | WLAN | RP-100740 |
| 3807 | 980 | **Enhancements for Voice Group Call Service (VGCS) Applications (EVA)** |  | 919d? | 2006-03-15 A | 2009-09-18 A | 100% | 2006-03-15 | 2009-09-18 | 919d? |  | S1; C1; C4; G2 | 45559.5h | 45559.5h | EVA |  | Nortel | Amar Deol (deola@nortelnetworks.com) | Rel-8 |  | Alain | EVA |  |  |  |
| 3808 | 980.1 | SA1 aspects of EVA |  | 191d? | 2006-03-15 A | 2006-12-06 A | 100% | 2006-03-15 | 2006-12-06 | 191d? | finish no earlier than 2006-12-06 | S1 | 1528h | 1528h | EVA |  | Nortel | Amar Deol (deola@nortelnetworks.com) | Rel-8 |  | Alain |  | 42.068 |  |  |
| 3809 | 980.2 | VGCS/VBS and GPRS Interactions |  | 145d? | 2007-09-03 A | 2008-03-21 A | 100% | 2007-09-03 | 2008-03-21 | 145d? | finish no earlier than 2008-03-21 | S1 | 1160h | 1160h | EVA |  | Huawei | Ling Liu | Rel-8 | SP-37 | Alain |  | 42.068, 42.069 |  |  |
| 3810 | 980.3 | CT1 aspects of EVA |  | 862d? | 2006-06-02 A | 2009-09-18 A | 100% | 2006-06-02 | 2009-09-18 | 862d? | finish no earlier than 2009-12-04 | C1 | 6887.53h | 6887.53h | EVA |  | Nortel | milanpa@nortel.com | Rel-8 |  | Frederic |  | 43.068, 44.068 |  |  |
| 3811 | 980.4 | CT4 aspects of EVA |  | 391d? | 2006-06-02 A | 2007-11-30 A | 100% | 2006-06-02 | 2007-11-30 | 391d? | finish no earlier than 2007-06-01 | C4 | 3128h | 3128h | EVA |  | Nortel |  | Rel-8 |  | Kimmo |  | 29.002 |  |  |
| 3812 | 980.5 | GERAN2 aspects of EVA |  | 431d? | 2006-06-30 A | 2008-02-22 A | 100% | 2006-06-30 | 2008-02-22 | 431d? | finish no earlier than 2008-02-22 | G2 | 3448h | 3448h | EVA |  | Nortel | frank.billenkamp@nortel.com | Rel-8 |  | Gert |  | 44.018, 48.008 |  |  |

Notes:
- 3787: CP#43 completed
- 3788: CP#43 completed
- 3789: CP#43 completed
- 3790: CP#42 completed
- 3791: Triggered by Study UID_7048 (MRFC)
- 3792: CP#42 completed
- 3793: CP#42 completed
- 3794: CP#56 completed
- 3795: CP#43 completed. Triggered by Study TR 23.820 (FS_IMS_RP) UID_350018
- 3796: CP#43 completed
- 3797: CP#43 completed
- 3798: CP#43 completed. Triggered by UID_360030 (FS_IMS_ASIO)
- 3799: CP#43 completed
- 3800: SP#36 completed
- 3801: CP#43 completed
- 3802: CP#42 completed
- 3803: CP#43 completed
- 3804: SP#40 completed
- 3805: CP#43 completed
- 3806: RP#49 completed. Testing for Rel-8 UID_400013 CT1 aspects of mobility between 3GPP WLAN Interworking and 3GPP Systems (24.327)
- 3807: CP#45 completed
- 3808: SP#38 completed
- 3809: SP#39 completed
- 3810: CP#45 completed
- 3811: CP#38 completed
- 3812: GP#37 completed

| ID | WBS | Task | Type | Duration | Start | Finish | Complete | Baseline start | Baseline finish | Baseline duration | Constraint | Resources | Work | Actual work | Acronym | WI rapporteur name | WI rapporteur e-mail | Release | MCC resp | Acronym_3GU_Export | Impacted TSs and TRs | TSG stopped | Special Focus Doc | TSG approved | PCG approved | Status Report |
| --- | --- | --- | --- | --- | --- | --- | --- | --- | --- | --- | --- | --- | --- | --- | --- | --- | --- | --- | --- | --- | --- | --- | --- | --- | --- | --- |
| 3813 | 981 | **Personal Network Management** |  | 955d? | 2005-07-11 A | 2009-03-06 A | 100% | 2005-07-11 | 2009-03-06 | 955d? |  | S1; C1; S3 | 46368h | 46368h | PNM | Vodafone | armin.toepfer@vodafone.com | Rel-8 | Alain | PNM |  |  |  |  |  |  |
| 3814 | 981.1 | Stage 1 for PNM |  | 276d? | 2005-07-11 A | 2006-07-31 A | 100% | 2005-07-11 | 2006-07-31 | 276d? | start no earlier than 2005-07-11 | S1 | 2208h | 2208h | PNM | Vodafone | armin.toepfer@vodafone.com | Rel-8 | Alain |  | 22.259 |  |  |  |  |  |
| 3815 | 981.2 | Stage 2 for PNM |  | 445d? | 2007-03-26 A | 2008-12-05 A | 100% | 2007-03-26 | 2008-12-05 | 445d? | finish no earlier than 2008-12-05 | C1 | 3560h | 3560h | PNM | Vodafone | yang.lu@vodafone.com | Rel-8 | Frederic |  | 23.259 |  |  |  |  |  |
| 3816 | 981.3 | **Stage 3 for PNM** |  | 510d? | 2007-03-26 A | 2009-03-06 A | 100% | 2007-03-26 | 2009-03-06 | 510d? |  | C1; C4 | 15800h | 15800h | PNM | Vodafone | yang.lu@vodafone.com | Rel-8 | Frederic |  |  |  |  |  |  |  |
| 3817 | 981.3.1 | CT1 aspects of Stage 3 PNM |  | 510d? | 2007-03-26 A | 2009-03-06 A | 100% | 2007-03-26 | 2009-03-06 | 510d? | finish no earlier than 2008-12-05 | C1 | 4080h | 4080h | PNM | Vodafone | yang.lu@vodafone.com | Rel-8 | Frederic |  | 24.259, 24.229 |  |  |  |  |  |
| 3818 | 981.3.2 | Deleted - CT4 aspects of Stage 3 PNM |  | 445d? | 2007-03-26 A | 2008-12-05 A | 100% | 2007-03-26 | 2008-12-05 | 445d? | finish no earlier than 2008-12-11 | C4 | 3560h | 3560h | PNM | Vodafone | yang.lu@vodafone.com | Rel-8 | Kimmo |  |  | CP-42 |  |  |  |  |
| 3819 | 981.4 | Key establishment between a UICC hosting device and a remote device |  | 235d? | 2006-12-06 A | 2007-10-30 A | 100% | 2006-12-06 | 2007-10-30 | 235d? | finish no earlier than 2007-10-30 | S3 | 1880h | 1880h | PNM | Ericsson | Vesa.Lehtovirta@ericsson.com | Rel-8 | Mirko |  | 33.259 |  |  |  |  |  |
| 3820 | 981.5 | Deleted - Actual Requirements of PNM | milestone | 0d? | 2007-03-26 A | 2007-03-26 A | 100% | 2007-03-26 | 2007-03-26 | 0d? | finish no earlier than 2007-03-26 | C1 |  |  | PNM | Ericsson |  | Rel-8 | Frederic |  |  | SP-37 |  |  |  |  |
| 3821 | 982 | **eCall Data Transfer** |  | 637d? | 2006-09-28 A | 2009-03-06 A | 100% | 2006-09-28 | 2009-03-06 | 637d? |  | S1; C1 | 14840h | 14840h | EData | Airbiquity | rrobinson@airbiquity.com | Rel-8 | Alain | EData |  |  | Public Safety (I-A) |  |  |  |
| 3822 | 982.1 | eData Requirements |  | 380d? | 2006-09-28 A | 2008-03-12 A | 100% | 2006-09-28 | 2008-03-12 | 380d? | finish no earlier than 2006-12-07 | S1 | 3040h | 3040h | EData | Airbiquity | rrobinson@airbiquity.com | Rel-8 | Alain |  | 22.101, 22.105 |  | Public Safety (I-A) | SP-37 |  |  |
| 3823 | 982.2 | Transfer of data during an emergency call |  | 201d? | 2008-05-30 A | 2009-03-06 A | 100% | 2008-05-30 | 2009-03-06 | 201d? | finish no earlier than 2009-03-06 | C1 | 1608h | 1608h | EData | T-Mobile | Dieter Jacobsohn | Rel-8 | Frederic |  | 24.008 |  | Public Safety (I-A) | SP-40 | PCG-21 |  |
| 3824 | 983 | eCall data transfer Phase 2: Comparison of alternative in-band modem solutions and standardization of one in-band modem solution |  | 472d? | 2007-12-06 A | 2009-09-24 A | 100% | 2007-12-06 | 2009-09-24 | 472d? | finish no earlier than 2009-09-24 | S4 | 3768.09h | 3768.09h | eCall_Phase2 | Airbiquity | lhong@airbiquity.com & rrobinson@airbiquity.com | Rel-8 | Paolo | eCall_Phase2 | 26.267, 26.268, 26.269, 26.967, 26.969 |  | Public Safety (I-A) |  |  |  |
| 3825 | 984 | eCall Conformance Testing |  | 261d? | 2009-09-04 A | 2010-09-03 A | 100% | 2009-09-04 | 2010-09-03 | 261d? | finish no earlier than 2010-09-03 | G3new | 2088h | 2088h | eCall_MSTest | Ericsson, Qualcomm | Vikrant Jain (vikrantj@qualcomm.com) | Rel-8 | Ingbert | eCall_MSTest | 51.010-1, 51.010-2 |  | Public Safety (I-A) | GP-45 | PCG-23 |  |
| 3826 | 985 | Conformance Test Aspects – non-modem procedures of eCall sessions in UTRA |  | 186d? | 2009-09-18 A | 2010-06-04 A | 100% | 2009-09-18 | 2010-06-04 | 186d? | finish no earlier than 2010-06-04 | R5 | 1488h | 1488h | UMTS_eCall_UEConTest | Ericsson, Qualcomm | Shubhang Vora (svora@qualcomm.com) | Rel-8 | Ingbert | UMTS_eCall_UEConTest | 34.108, 34.123-1, 34.123-2, 34.123-3 |  | Public Safety (I-A) | RP-45 | PCG-23 | RP-100489 |
| 3827 | 986 | **IP Interconnection of Services** |  | 668d? | 2006-08-16 A | 2009-03-06 A | 100% | 2006-08-16 | 2009-03-06 | 668d? |  | S1; S2; S5; C3 | 44240h | 44240h | IPinterc | Telefónica O2 | chris.friel@O2.com | Rel-8 | Alain | IPinterc |  |  |  | SP-38 | PCG-21 |  |
| 3828 | 986.1 | Stage 1 for IPinterc |  | 70d? | 2007-12-06 A | 2008-03-12 A | 100% | 2007-12-06 | 2008-03-12 | 70d? | start no earlier than 2007-12-06 | S1 | 560h | 560h | IPinterc | Telefónica O2 | chris.friel@O2.com | Rel-8 | Alain |  | 22.101, 22.228 |  |  | SP-38 | PCG-21 |  |
| 3829 | 986.2 | **System enhancements for interconnection interfaces between two IMSs** |  | 668d? | 2006-08-16 A | 2009-03-06 A | 100% | 2006-08-16 | 2009-03-06 | 668d? |  | S2; S5; C3 | 22304h | 22304h | IMS_NNI | Telecom Italia | Mario Madella (mario.madella@telecomitalia.it) | Rel-8 | Maurice | IMS_NNI |  |  |  |  |  |  |
| 3830 | 986.2.1 | Stage 2 for IMS_NNI |  | 120d? | 2007-06-22 A | 2007-12-06 A | 100% | 2007-06-22 | 2007-12-06 | 120d? | finish no earlier than 2007-12-21 | S2 | 960h | 960h | IMS_NNI | Telecom Italia | Mario Madella (mario.madella@telecomitalia.it) | Rel-8 | Maurice |  | 23.002, 23.228 |  |  |  |  |  |
| 3831 | 986.2.2 | IMS inter-operator service interconnection interface |  | 461d? | 2007-06-01 A | 2009-03-06 A | 100% | 2007-06-01 | 2009-03-06 | 461d? | finish no earlier than 2009-03-06 | C3 | 3688h | 3688h | FBI2-IOPSI | Telecom Italia | antonio.ascolese@telecomitalia.it | Rel-8 | Adrian | FBI2-IOPSI | 29.865, 29.165 |  |  |  |  |  |
| 3832 | 986.2.3 | Charging harmonization for NGN between 3GPP and ATIS-TMOC |  | 51d? | 2006-09-28 A | 2006-12-07 A | 100% | 2006-09-28 | 2006-12-07 | 51d? | finish no earlier than 2006-12-07 | S5 | 408h | 408h | FBI2-TISP2-CH | Amdocs | yishai.brown@amdocs.com | Rel-8 | Mirko | FBI2-TISP2-CH | 32.297 |  |  |  |  |  |
| 3833 | 986.2.4 | Deleted - Protocol impact of FBI for TISPAN R2 |  | 152d? | 2006-08-16 A | 2007-03-15 A | 100% | 2006-08-16 | 2007-03-15 | 152d? | finish no earlier than 2007-03-15 | C1 | 1216h | 1216h | FBI2-TISP2-c1 | Ericsson |  | Rel-8 | Frederic | FBI2-TISP2-c1 |  | SP-38 |  |  |  |  |
| 3834 | 986.2.5 | Deleted (never approved) - Stage 2 of FBI for TISPAN R2 - Rel 8 | milestone | 0d? | 2007-11-30 A | 2007-11-30 A | 100% | 2007-11-30 | 2007-11-30 | 0d? | finish no earlier than 2007-11-30 | S2 |  |  | FBI2-TISP2-s2 | Nokia Siemens Networks |  | Rel-8 | Maurice | FBI2-TISP2-s2 |  | SP-36 |  |  |  |  |
| 3835 | 987 | **Support of (G)MSC-S – (G)MSC-S Nc Interface based on the SIP-I protocol** |  | 386d? | 2007-09-14 A | 2009-03-06 A | 100% | 2007-09-14 | 2009-03-06 | 386d? |  | C4; C3 | 14960h | 14960h | SIP_Nc | Vodafone | David.Hutton@vodafone.com | Rel-8 | Kimmo | SIP_Nc |  |  |  |  |  |  |
| 3836 | 987.1 | Stage 1 for SIP_Nc (covered by Feature IPinterc) |  | 70d? | 2007-12-06 A | 2008-03-12 A | 100% | 2007-12-06 | 2008-03-12 | 70d? | start no earlier than 2007-12-06 | S1 | 560h | 560h | SIP_Nc | Telefónica O2 | chris.friel@O2.com | Rel-8 | Alain |  | 22.101, 22.228 |  |  | CP-41 | PCG-21 |  |
| 3837 | 987.2 | SIP-I based circuit-switched core network; Stage 2 |  | 321d? | 2007-09-14 A | 2008-12-05 A | 100% | 2007-09-14 | 2008-12-05 | 321d? | finish no earlier than 2008-12-11 | C4 | 2568h | 2568h | SIP_Nc-St2 | Vodafone | David.Hutton@vodafone.com | Rel-8 | Kimmo | SIP_Nc-St2 | 23.231, 23.153, 23.205 |  |  |  |  |  |
| 3838 | 987.3 | Application of SIP-I Protocols to Circuit Switched (CS) core network architecture; Stage 3 |  | 321d? | 2007-09-14 A | 2008-12-05 A | 100% | 2007-09-14 | 2008-12-05 | 321d? | finish no earlier than 2008-12-11 | C4 | 2568h | 2568h | SIP_Nc-St3C4 | Vodafone | David.Hutton@vodafone.com | Rel-8 | Kimmo | SIP_Nc-St3 | 29.231, 29.232, 29.332 |  |  |  |  |  |
| 3839 | 987.4 | Interworking between the 3GPP CS domain with SIP-I as signalling protocol and other networks |  | 386d? | 2007-09-14 A | 2009-03-06 A | 100% | 2007-09-14 | 2009-03-06 | 386d? | finish no earlier than 2009-03-06 | C3 | 3088h | 3088h | SIP_Nc-St3C3 | Nokia Siemens Networks | Thomas.Belling@nsn.com | Rel-8 | Adrian |  | 29.235, 23.172, 23.202, 29.007, 29.163, 29.414 |  |  |  |  |  |

Notes:
- 3813: CP#43 completed
- 3814: SP#31 completed
- 3815: CP#42 completed
- 3816: CP#43 completed
- 3817: CP#43 completed
- 3818: CP#42 no impact on CT4 specs
- 3819: SP#37 completed
- 3820: SP#37 stopped
- 3821: SP#39 completed. Linked to SA4 Feature UID_34042 (eCall_Phase2)
- 3822: SP#39 completed
- 3823: CP#43 completed
- 3824: SP#45 completed. Triggered by Study UID_360015 (eCALLIBMS). Linked to SA1 Feature UID_330005 (EData)
- 3825: GP#47 completed. GP#43 WID approved. Testing for Rel-8 eCall_Phase2 (UID_34042) and EData (UID_330005)
- 3826: RP#48 completed. Testing for Rel-8 eCall_Phase2 (UID_34042) and Edata (UID_330005)
- 3827: SP#43 completed
- 3828: SP#39 completed.
- 3829: CP#43 completed
- 3830: SP#38 completed
- 3831: CP#43 completed
- 3832: SP#34 completed
- 3833: SP#38 stopped
- 3834: SP#36 stopped
- 3835: CP#43 completed. Stage 1 in Feature UID_380060 (IPinterc). CP#40 updated WID CP-070517=>CP-080282
- 3836: 22/07/08 Created. Stage 1 for SIP_Nc (covered by SA1 Feature UID_380060 Ipinterc)
- 3837: CP#42 completed
- 3838: CP#42 completed
- 3839: CP#43 completed. CP#42 target 12/08=>03/09

| ID | WBS | Task | Type | Duration | Start | Finish | Complete | Baseline start | Baseline finish | Baseline duration | Constraint | Resources | Work | Actual work | Acronym | WI rapporteur name | WI rapporteur e-mail | Release | TSG approved | MCC resp | Special Focus Doc | Acronym_3GU_Export | Impacted TSs and TRs | PCG approved | Status Report |
| --- | --- | --- | --- | --- | --- | --- | --- | --- | --- | --- | --- | --- | --- | --- | --- | --- | --- | --- | --- | --- | --- | --- | --- | --- | --- |
| 3840 | 988 | **Earthquake and Tsunami Warning System** |  | 440d? | 2007-09-10 A | 2009-05-15 A | 100% | 2007-09-10 | 2009-05-15 | 440d? |  | S1; S2; C1; C4; G2 | 21280h | 21280h | ETWS | NTT DoCoMo | kitaharar@nttdocomo.co.jp | Rel-8 | SP-37 | Alain | Public Safety (I-A) | ETWS |  |  |  |
| 3841 | 988.1 | Stage 1 for ETWS |  | 133d? | 2007-09-10 A | 2008-03-12 A | 100% | 2007-09-10 | 2008-03-12 | 133d? | finish no earlier than 2008-03-12 | S1 | 1064h | 1064h | ETWS | NTT DoCoMo | kitaharar@nttdocomo.co.jp | Rel-8 | SP-37 | Alain | Public Safety (I-A) |  | 22.168 |  |  |
| 3842 | 988.2 | SA2 aspects of ETWS |  | 179d? | 2008-01-14 A | 2008-09-18 A | 100% | 2008-01-14 | 2008-09-18 | 179d? | finish no earlier than 2008-09-08 | S2 | 1432h | 1432h | ETWS | NTT DoCoMo | tanakai@nttdocomo.co.jp | Rel-8 | SP-38 | Maurice | Public Safety (I-A) |  | 23.828, 23.401 | PCG-21 |  |
| 3843 | 988.3 | CT1 aspects of ETWS |  | 50.5d? | 2008-05-30 A | 2008-12-05 A | 100% | 2008-05-30 | 2008-12-05 | 50.5d? | finish no earlier than 2008-12-05 | C1 | 404h | 404h | ETWS | NTT DoCoMo | yamashitahi@s1.nttdocomo.co.jp | Rel-8 | CP-40 | Frederic | Public Safety (I-A) |  | 23.041 | PCG-21 |  |
| 3844 | 988.4 | CT4 aspects of ETWS |  | 50.5d? | 2008-09-26 A | 2008-12-05 A | 100% | 2008-09-26 | 2008-12-05 | 50.5d? | finish no earlier than 2008-12-05 | C4 | 404h | 404h | ETWS | NTT DoCoMo | yamashitahi@s1.nttdocomo.co.jp | Rel-8 | CP-40 | Kimmo | Public Safety (I-A) |  | 29.168 | PCG-21 |  |
| 3845 | 988.5 | ETWS primary notification message definition in GERAN |  | 47d? | 2009-03-12 A | 2009-05-15 A | 100% | 2009-03-12 | 2009-05-15 | 47d? | finish no earlier than 2009-05-15 | G2 | 376h | 376h | ETWS | Ericsson | claes-goran.persson@ericsson.com | Rel-8 | SP-43 | Gert | Public Safety (I-A) |  | 44.018, 44.060 | PCG-22 |  |
| 3846 | 989 | Conformance Test Aspects – UMTS Earthquake and Tsunami Warning System (ETWS) FDD |  | 207d? | 2009-05-29 A | 2010-03-12 A | 100% | 2009-05-29 | 2010-03-12 | 207d? | finish no earlier than 2010-03-12 | R5 | 1656h | 1656h | ETWS_UMTS_UEConTestFDD | NTT DoCoMo | Makoto Ito (itohm@nttdocomo.co.jp) | Rel-8 | RP-44 | Ingbert | Public Safety (I-A) | ETWS_UMTS_UEConTestFDD | 34.108, 34.123-1, 34.123-2 | PCG-23 | RP-100068 |
| 3847 | 990 | **In Case of Emergency numbers storage and easy access on UICC** |  | 519d? | 2007-03-13 A | 2009-03-06 A | 100% | 2007-03-13 | 2009-03-06 | 519d? |  | S1; C6 | 14552h | 14552h | ICE | Vodafone | armin.toepfer@vodafone.com | Rel-8 | SP-38 | Alain |  | ICE |  | PCG-21 |  |
| 3848 | 990.1 | Stage 1 for ICE |  | 262d? | 2007-03-13 A | 2008-03-12 A | 100% | 2007-03-13 | 2008-03-12 | 262d? | finish no earlier than 2008-03-12 | S1 | 2096h | 2096h | ICE | Vodafone | armin.toepfer@vodafone.com | Rel-8 | SP-38 | Alain |  |  | 22.030, 22.101 | PCG-21 |  |
| 3849 | 990.2 | CT6 aspects of ICE |  | 519d? | 2007-03-13 A | 2009-03-06 A | 100% | 2007-03-13 | 2009-03-06 | 519d? | finish no earlier than 2009-03-06 | C6 | 4152h | 4152h | ICE | Vodafone | armin.toepfer@vodafone.com | Rel-8 | SP-38 | Xavier |  |  | 31.102 | PCG-21 |  |
| 3850 | 991 | Local Charging Zone Requirements |  | 380d? | 2006-09-28 A | 2008-03-12 A | 100% | 2006-09-28 | 2008-03-12 | 380d? | finish no earlier than 2006-12-07 | S1 | 3040h | 3040h | LCZR | China Mobile | liuhongyfw@chinamobile.com | Rel-8 |  | Alain |  | LCZR | 22.115 |  |  |
| 3851 | 992 | **Customized Alerting Tone (CAT) service** |  | 729d? | 2006-12-06 A | 2009-09-18 A | 100% | 2006-12-06 | 2009-09-18 | 729d? |  | S1; C1; C3; C4 | 39854h | 39854h | CAT | China Mobile | fenglingjuan@chinamobile.com | Rel-8 | TSG-34 | Alain |  | CAT |  |  |  |
| 3852 | 992.1 | Stage 1 for CAT |  | 207d? | 2006-12-06 A | 2007-09-20 A | 100% | 2006-12-06 | 2007-09-20 | 207d? | start no earlier than 2006-12-06 | S1 | 1656h | 1656h | CAT | China Mobile | fenglingjuan@chinamobile.com | Rel-8 | SP-37 | Alain |  |  | 22.182 |  |  |
| 3853 | 992.2 | TISPAN requirements for customized multimedia information services |  | 71d? | 2007-09-03 A | 2007-12-10 A | 100% | 2007-09-03 | 2007-12-10 | 71d? | finish no earlier than 2007-12-10 | S1 | 568h | 568h | TISCMI | China Mobile | fenglingjuan@chinamobile.com | Rel-8 | SP-37 | Alain |  | TISCMI | 22.182 |  |  |
| 3854 | 992.3 | **IMS CAT Supplementary Service** |  | 399d? | 2008-03-12 A | 2009-09-18 A | 100% | 2008-03-12 | 2009-09-18 | 399d? |  | C1; C3 | 10814.4h | 10814.4h | CAT-SS | Nortel | milanpa@nortel.com | Rel-8 | CP-39 | Frederic |  | CAT-SS |  | PCG-21 |  |
| 3855 | 992.3.1 | IMS CAT SS |  | 164d? | 2008-04-21 A | 2008-12-04 A | 100% | 2008-04-21 | 2008-12-04 | 164d? | finish no earlier than 2008-12-05 | C1 | 1312h | 1312h | CAT-SS | Nortel | milanpa@nortel.com | Rel-8 | CP-39 | Frederic |  |  | 24.182 | PCG-21 |  |
| 3856 | 992.3.2 | CAT solution for voice and video call in CS domain |  | 389.8d? | 2008-03-12 A | 2009-09-18 A | 100% | 2008-03-12 | 2009-09-18 | 389.8d? | finish no earlier than 2009-09-11 | C3 | 3118.4h | 3118.4h | CAT-SS | Nortel | milanpa@nortel.com | Rel-8 | CP-39 | Adrian |  |  | 29.163 | PCG-21 |  |
| 3857 | 992.4 | **CAT Service in 3GPP CS domain** |  | 126d? | 2008-09-12 A | 2009-03-06 A | 100% | 2008-09-12 | 2009-03-06 | 126d? |  | C4; C1 | 3487.6h | 3487.6h | CAT-3G_CS | China Mobile | zhaoyuyi@chinamobile.com | Rel-8 | CP-41 | Kimmo |  | CAT-3G_CS | 23.205, 23.231, 29.002 | PCG-21 |  |
| 3858 | 992.4.1 | CT4 part of CAT Service in 3GPP CS domain |  | 126d? | 2008-09-12 A | 2009-03-06 A | 100% | 2008-09-12 | 2009-03-06 | 126d? | finish no earlier than 2009-03-06 | C4 | 1008h | 1008h | CAT-3G_CS | China Mobile | zhaoyuyi@chinamobile.com | Rel-8 | CP-41 | Kimmo |  |  | 23.205, 23.231, 29.002 | PCG-21 |  |
| 3859 | 992.4.2 | CT1 part of CAT Service in 3GPP CS domain |  | 57.95d? | 2008-09-12 A | 2008-12-05 A | 100% | 2008-09-12 | 2008-12-05 | 57.95d? | start no earlier than 2008-09-12 | C1 | 463.6h | 463.6h | CAT-3G_CS | China Mobile | zhaoyuyi@chinamobile.com | Rel-8 | CP-41 | Frederic |  |  | 24.008, 23.014 | PCG-21 |  |
| 3860 | 993 | **Service-Level Interworking for Messaging Services** |  | 509d? | 2007-03-26 A | 2009-03-06 A | 100% | 2007-03-26 | 2009-03-06 | 509d? |  | S1; S2; C3; C1 | 20800h | 20800h | MESSIW | Huawei | ling.liu@huawei.com; duanxiaoqin@huawei.com | Rel-8 | TSG-34 | Alain |  | MESSIW |  |  |  |
| 3861 | 993.1 | Stage 1 for MESSIW | milestone | 0d? | 2007-03-26 A | 2007-03-26 A | 100% | 2007-03-26 | 2007-03-26 | 0d? | finish no earlier than 2007-12-01 | S1 |  |  | MESSIW | Huawei | ling.liu@huawei.com | Rel-8 |  | Alain |  |  | 22.105, 22.340 |  |  |
| 3862 | 993.2 | Stage 2 for MESSIW |  | 227d? | 2007-04-26 A | 2008-03-07 A | 100% | 2007-04-26 | 2008-03-07 | 227d? | finish no earlier than 2008-03-07 | S2 | 1816h | 1816h | MESSIW | Huawei | patrice.hede@huawei.com | Rel-8 |  | Maurice |  |  | 23.811, 23.204 |  |  |
| 3863 | 993.3 | CT3 part of Stage 3 for MESSIW |  | 201d? | 2008-05-30 A | 2009-03-06 A | 100% | 2008-05-30 | 2009-03-06 | 201d? | finish no earlier than 2008-12-05 | C3 | 1608h | 1608h | MESSIW | Huawei | xupeili@huawei.com | Rel-8 | CP-40 | Adrian |  |  | 29.311 | PCG-21 |  |
| 3864 | 993.4 | CT1 part of Stage 3 for MESSIW |  | 136d? | 2008-05-30 A | 2008-12-05 A | 100% | 2008-05-30 | 2008-12-05 | 136d? | finish no earlier than 2008-12-12 | C1 | 1088h | 1088h | MESSIW | Huawei | xupeili@huawei.com | Rel-8 | CP-40 | Frederic |  |  | 24.229 | PCG-21 |  |

Notes:
- 3840: SP#43 Larger scope Feature UID_380057 (PWS) moved to Rel-9
- 3841: SP#39 completed
- 3842: SP#41 completed
- 3843: CP#42 completed
- 3844: CP#42 completed
- 3845: SP#44 completed with CT1 help (GERAN2 LS_in SP-090154)
- 3846: RP#47 completed. Testing for Rel-8 ETWS UID_370051
- 3847: CP#43 completed (ICE Graphics not included in Rel-8)
- 3848: SP#39 Stage 1 completed
- 3849: CP#43 completed (ICE Graphics not in Rel-8 / not explicitly in SA1 WID either)
- 3850: SP#39 Stage 1 completed
- 3851: CP#45 completed
- 3852: -
- 3853: SP#38 completed
- 3854: -
- 3855: CP#42 completed
- 3856: CP#45 completed. Triggered by Study UID_360031 (TR 29.882)
- 3857: -
- 3858: CP#43 completed. Triggered by Study UID_360031 (TR 29.882)
- 3859: CP#42 completed. Triggered by Study UID_360031 (TR 29.882)
- 3860: CP#43 completed
- 3861: SP#35 completed
- 3862: SP#39 completed
- 3863: CP#43 completed
- 3864: CP#42 completed

| ID | WBS | Task | Duration | Start | Finish | Complete | Baseline start | Baseline finish | Baseline duration | Constraint | Resources | Work | Actual work | Acronym | WI rapporteur name | WI rapporteur e-mail | Release | TSG approved | MCC resp | Special Focus Doc | Acronym_3GU_Export | Impacted TSs and TRs | PCG stopped | TSG stopped | PCG approved |
| --- | --- | --- | --- | --- | --- | --- | --- | --- | --- | --- | --- | --- | --- | --- | --- | --- | --- | --- | --- | --- | --- | --- | --- | --- | --- |
| 3865 | 994 | **Multimedia Priority Service** | 858d? | 2006-06-08 A | 2009-09-18 A | 100% | 2006-06-08 | 2009-09-18 | 858d? |  | S1; C1; C3; C4 | 43016h | 43016h | PRIOR_EMR | Telcordia | jgarraha@telcordia.com | Rel-8 | SP-34 | Alain | Public Safety (I-A) | PRIOR |  |  |  |  |
| 3866 | 994.1 | Service Requirements for PRIOR | 391d? | 2006-06-08 A | 2007-12-06 A | 100% | 2006-06-08 | 2007-12-06 | 391d? | finish no earlier than 2007-11-30 | S1 | 3128h | 3128h | PRIOR_EMR | Telcordia | jgarraha@telcordia.com | Rel-8 | SP-32 | Alain | Public Safety (I-A) | PRIOR-EMR | New 22.153 |  |  |  |
| 3867 | 994.2 | CT1 part of Stage 3 for PRIOR | 732d? | 2006-12-01 A | 2009-09-18 A | 100% | 2006-12-01 | 2009-09-18 | 732d? | finish no earlier than 2009-09-18 | C1 | 5856h | 5856h | PRIOR_EMR | Alcatel-Lucent | Keith Drage (drage@alcatel-lucent.com) | Rel-8 | CP-34 | Frederic | Public Safety (I-A) |  | 24.229 |  |  |  |
| 3868 | 994.3 | CT4 part of Stage 3 for PRIOR | 381d? | 2007-09-21 A | 2009-03-06 A | 100% | 2007-09-21 | 2009-03-06 | 381d? | finish no earlier than 2009-03-06 | C4 | 3048h | 3048h | PRIOR_EMR | Alcatel-Lucent | Keith Drage (drage@alcatel-lucent.com) | Rel-8 | CP-37 | Kimmo | Public Safety (I-A) |  | 23.008, 29.228, 29.229 |  |  |  |
| 3869 | 994.4 | Deleted - Stage 3 for PRIOR | 441d? | 2007-09-21 A | 2009-05-29 A | 100% | 2007-09-21 | 2009-05-29 | 441d? | finish no earlier than 2009-05-29 | C3 | 3528h | 3528h | PRIOR-EMR | Alcatel-Lucent | Keith Drage (drage@alcatel-lucent.com) | Rel-8 | CP-37 | Adrian | Public Safety (I-A) |  | 29.212, 29.213, 29.214, 29.163 | PCG-23 | CP-44 |  |
| 3870 | 995 | **Open Service Access (OSA) Rel-8** | 202d? | 2007-08-23 A | 2008-05-30 A | 100% | 2007-08-23 | 2008-05-30 | 202d? |  | S1; C5 | 25528h | 25528h | OSA8 | Orange | Song Dong | Rel-8 |  | Alain |  | OSA8 |  |  |  |  |
| 3871 | 995.1 | OSA Stage 1 - Service Requirements | 145d? | 2007-08-23 A | 2008-03-12 A | 100% | 2007-08-23 | 2008-03-12 | 145d? | finish no earlier than 2007-12-04 | S1 | 1160h | 1160h | OSA8 | Orange, AePONA | Song Dong | Rel-8 |  | Alain |  |  | 22.127 |  |  |  |
| 3872 | 995.2 | OSA Stage 1 - NGN Service Requirement | 140d? | 2007-09-03 A | 2008-03-14 A | 100% | 2007-09-03 | 2008-03-14 | 140d? | finish no earlier than 2008-03-14 | S1 | 1120h | 1120h | OSA8-IMSReq | Orange | Song Dong | Rel-8 | SP-37 | Alain |  | OSA8-IMS | 22.127 |  |  |  |
| 3873 | 995.3 | **Rel-8 OSA Stage 2/3 enhancements** | 157d? | 2007-10-25 A | 2008-05-30 A | 100% | 2007-10-25 | 2008-05-30 | 157d? |  | C5 | 20016h | 20016h | OSA8-IMS | Alcatel-Lucent | unmehopa@alcatel-lucent.com | Rel-8 |  | Kimmo |  |  | 23.198, 29.198, 29.199 |  |  |  |
| 3874 | 995.3.1 | Deleted - Ensure Parlay-X composable with identity management frameworks, in particular Liberty Alliance | 157d? | 2007-10-25 A | 2008-05-30 A | 100% | 2007-10-25 | 2008-05-30 | 157d? | finish no earlier than 2008-12-25 | C5 | 1256h | 1256h |  | Ericsson | catherine.mulligan@ericsson.com | Rel-8 | CP-37 | Kimmo |  |  | existing 29.199-xy | PCG-21 | CP-40 | PCG-21 |
| 3875 | 995.3.2 | Parlay-X Content Management web service (store/manage meta-data) | 157d? | 2007-10-25 A | 2008-05-30 A | 100% | 2007-10-25 | 2008-05-30 | 157d? | finish no earlier than 2008-12-04 | C5 | 1256h | 1256h | OSA8-IMS | Alcatel-Lucent | unmehopa@alcatel-lucent.com | Rel-8 | CP-37 | Kimmo |  |  | 29.199-21 |  |  |  |
| 3876 | 995.3.3 | Parlay-X Policy web service | 157d? | 2007-10-25 A | 2008-05-30 A | 100% | 2007-10-25 | 2008-05-30 | 157d? | finish no earlier than 2008-12-04 | C5 | 1256h | 1256h | OSA8-IMS | Alcatel-Lucent | unmehopa@alcatel-lucent.com | Rel-8 | CP-37 | Kimmo |  |  | 29.199-22 |  |  |  |
| 3877 | 995.3.4 | Parlay-X Terminal status web service | 157d? | 2007-10-25 A | 2008-05-30 A | 100% | 2007-10-25 | 2008-05-30 | 157d? | finish no earlier than 2008-05-30 | C5 | 1256h | 1256h | OSA8-IMS | Alcatel-Lucent | unmehopa@alcatel-lucent.com | Rel-8 | CP-37 | Kimmo |  |  | 29.199-08 |  |  |  |
| 3878 | 995.3.5 | Deleted - Identify communication format used by a particular application | 157d? | 2007-10-25 A | 2008-05-30 A | 100% | 2007-10-25 | 2008-05-30 | 157d? | finish no earlier than 2008-05-30 | C5 | 1256h | 1256h |  | Ericsson | catherine.mulligan@ericsson.com | Rel-8 | CP-37 | Kimmo |  |  | existing 29.199-xy | PCG-21 | CP-40 | PCG-21 |
| 3879 | 995.3.6 | Deleted - Security on User Profile Management - reuse GUP API (22.127 CR 0084 S1-071794) | 128d? | 2007-12-05 A | 2008-05-30 A | 100% | 2007-12-05 | 2008-05-30 | 128d? | finish no earlier than 2008-12-25 | C5 | 1024h | 1024h |  | Telecom Italia | vincenzo.amorino@telecomitalia.it | Rel-8 | CP-38 | Kimmo |  |  | PXWS Framework | PCG-21 | CP-40 | PCG-21 |
| 3880 | 995.3.7 | Deleted - Privacy on Subscriber Identity (Liberty Alliance, OASIS) (22.127 CR 0085 S1-071835) | 128d? | 2007-12-05 A | 2008-05-30 A | 100% | 2007-12-05 | 2008-05-30 | 128d? | finish no earlier than 2008-12-25 | C5 | 1024h | 1024h |  | Telecom Italia | vincenzo.amorino@telecomitalia.it | Rel-8 | CP-38 | Kimmo |  |  | PXWS Framework | PCG-21 | CP-40 | PCG-21 |
| 3881 | 995.3.8 | Deleted - Topology Hiding (22.127 CR 0086 S1-071838) | 128d? | 2007-12-05 A | 2008-05-30 A | 100% | 2007-12-05 | 2008-05-30 | 128d? | finish no earlier than 2008-12-25 | C5 | 1024h | 1024h |  | Telecom Italia | vincenzo.amorino@telecomitalia.it | Rel-8 | CP-38 | Kimmo |  |  | PXWS Framework | PCG-21 | CP-40 | PCG-21 |
| 3882 | 995.3.9 | Deleted - Subscriber event notification (22.127 CR 0087 S1-071836) | 128d? | 2007-12-05 A | 2008-05-30 A | 100% | 2007-12-05 | 2008-05-30 | 128d? | finish no earlier than 2008-12-25 | C5 | 1024h | 1024h |  | Telecom Italia | vincenzo.amorino@telecomitalia.it | Rel-8 | CP-38 | Kimmo |  |  | PXWS Framework | PCG-21 | CP-40 | PCG-21 |
| 3883 | 995.3.10 | Deleted - Event notification (22.127 CR 0088 S1-071762) | 128d? | 2007-12-05 A | 2008-05-30 A | 100% | 2007-12-05 | 2008-05-30 | 128d? | finish no earlier than 2008-12-25 | C5 | 1024h | 1024h |  | Telecom Italia | vincenzo.amorino@telecomitalia.it | Rel-8 | CP-38 | Kimmo |  |  | PXWS Framework | PCG-21 | CP-40 | PCG-21 |
| 3884 | 995.3.11 | Deleted - Access policy (22.127 CR 0089 S1-071763) | 128d? | 2007-12-05 A | 2008-05-30 A | 100% | 2007-12-05 | 2008-05-30 | 128d? | finish no earlier than 2008-12-25 | C5 | 1024h | 1024h |  | Telecom Italia | vincenzo.amorino@telecomitalia.it | Rel-8 | CP-38 | Kimmo |  |  | PXWS Framework | PCG-21 | CP-40 | PCG-21 |
| 3885 | 995.3.12 | Deleted - API usage accounting (22.127 CR 0090 S1-071792) | 128d? | 2007-12-05 A | 2008-05-30 A | 100% | 2007-12-05 | 2008-05-30 | 128d? | finish no earlier than 2008-12-25 | C5 | 1024h | 1024h |  | Telecom Italia | vincenzo.amorino@telecomitalia.it | Rel-8 | CP-38 | Kimmo |  |  | PXWS Framework | PCG-21 | CP-40 | PCG-21 |
| 3886 | 995.3.13 | Presence alignment with OMA and IETF (22.127 CR 0092 S1-071764) | 128d? | 2007-12-05 A | 2008-05-30 A | 100% | 2007-12-05 | 2008-05-30 | 128d? | finish no earlier than 2008-05-30 | C5 | 1024h | 1024h | OSA8-IMS | Alcatel-Lucent | unmehopa@alcatel-lucent.com | Rel-8 | CP-38 | Kimmo |  |  | 29.199-14/13 |  |  | PCG-21 |
| 3887 | 995.3.14 | Deleted - Service identification (22.127 CR 0095 S1-071837) | 128d? | 2007-12-05 A | 2008-05-30 A | 100% | 2007-12-05 | 2008-05-30 | 128d? | finish no earlier than 2008-05-30 | C5 | 1024h | 1024h |  | Ericsson | catherine.mulligan@ericsson.com | Rel-8 | CP-38 | Kimmo |  |  | existing 29.199-xy | PCG-21 | CP-40 | PCG-21 |
| 3888 | 995.3.15 | Framework Enterprise Operator (Service Subscription function) | 102d? | 2008-01-10 A | 2008-05-30 A | 100% | 2008-01-10 | 2008-05-30 | 102d? | finish no earlier than 2008-05-30 | C5 | 816h | 816h | OSA8-IMS | Alcatel-Lucent | unmehopa@alcatel-lucent.com | Rel-8 | CP-39 | Kimmo |  |  | 29.198-03 |  |  | PCG-21 |
| 3889 | 995.3.16 | Mobility Emergency Location | 102d? | 2008-01-10 A | 2008-05-30 A | 100% | 2008-01-10 | 2008-05-30 | 102d? | finish no earlier than 2008-05-30 | C5 | 816h | 816h | OSA8-IMS | Alcatel-Lucent | unmehopa@alcatel-lucent.com | Rel-8 | CP-39 | Kimmo |  |  | 29.198-06 |  |  | PCG-21 |
| 3890 | 995.3.17 | Connectivity Manager SCF | 102d? | 2008-01-10 A | 2008-05-30 A | 100% | 2008-01-10 | 2008-05-30 | 102d? |  | C5 | 816h | 816h | OSA8-IMS | Alcatel-Lucent | unmehopa@alcatel-lucent.com | Rel-8 | CP-39 | Kimmo |  |  | 29.198-10 |  |  | PCG-21 |
| 3891 | 995.3.18 | PAM Presence Agent | 102d? | 2008-01-10 A | 2008-05-30 A | 100% | 2008-01-10 | 2008-05-30 | 102d? | finish no earlier than 2008-05-30 | C5 | 816h | 816h | OSA8-IMS | Alcatel-Lucent | unmehopa@alcatel-lucent.com | Rel-8 | CP-39 | Kimmo |  |  | 29.198-14 |  |  | PCG-21 |

Notes:
- 3865: CP#45 completed
- 3866: SP#38 completed
- 3867: CP#45 completed
- 3868: CP#43 completed
- 3869: CP#44 stopped (Reason: No Rel-8 solution expected (LS sent to SA2, but not prioritized in SA2)
- 3870: SP#40 maintenance & new OSA work moved to OMA. Rel-9 onwards 3GPP references to 22.127 changed to OMA Parlay Service Access Requirements (OMA-RD-Parlay_Service_Access-V1_0-20100427-A).
- 3871: SP#40 maintenance & new OSA work moved to OMA. Rel-9 onwards 3GPP references to 22.127 changed to OMA Parlay Service Access Requirements (OMA-RD-Parlay_Service_Access-V1_0-20100427-A).
- 3872: SP#40 maintenance & new OSA work moved to OMA
- 3873: SP#40 maintenance & new OSA work moved to OMA
- 3874: CP#40: Work moved to OMA
- 3875: CP#40 completed
- 3876: CP#40 completed
- 3877: CP#40 completed
- 3878: CP#40: Work moved to OMA
- 3879: SP#38 SP-070853 R8 CRs 22.127 OSA Stage 1. CP#40: Work moved to OMA
- 3880: SP#38 SP-070853 R8 CRs 22.127 OSA Stage 1. CP#40: Work moved to OMA
- 3881: SP#38 SP-070853 R8 CRs 22.127 OSA Stage 1. CP#40: Work moved to OMA
- 3882: SP#38 SP-070853 R8 CRs 22.127 OSA Stage 1. CP#40: Work moved to OMA
- 3883: SP#38 SP-070853 R8 CRs 22.127 OSA Stage 1. CP#40: Work moved to OMA
- 3884: SP#38 SP-070853 R8 CRs 22.127 OSA Stage 1. CP#40: Work moved to OMA
- 3885: SP#38 SP-070853 R8 CRs 22.127 OSA Stage 1. CP#40: Work moved to OMA
- 3886: CP#40 completed
- 3887: SP#38 SP-070853 R8 CRs 22.127 OSA Stage 1. CP#40: Work moved to OMA
- 3888: CP#40 completed
- 3889: CP#40 completed
- 3890: CP#40 completed
- 3891: CP#40 completed

| ID | WBS | Task | Duration | Start | Finish | Complete | Remaining | Baseline start | Baseline finish | Baseline duration | Total slack | Constraint | Resources | Work | Actual work | Acronym | WI rapporteur name | Release | MCC resp | Acronym_3GU_Export | TSG approved | PCG approved | Status Report | Special Focus Doc |
| --- | --- | --- | --- | --- | --- | --- | --- | --- | --- | --- | --- | --- | --- | --- | --- | --- | --- | --- | --- | --- | --- | --- | --- | --- |
| 3892 | 996 | **Paging Permission with Access Control (PPACR)** | 389d? | 2007-06-12 A | 2008-12-05 A | 100% |  | 2007-06-12 | 2008-12-05 | 389d? |  |  | S1; C1 | 9000h | 9000h | PPACR | NTT DoCoMo | Rel-8 | Alain | PPACR |  |  |  |  |
| 3893 | 996.1 | Stage 1 for PPACR | 69d? | 2007-06-12 A | 2007-09-14 A | 100% |  | 2007-06-12 | 2007-09-14 | 69d? |  | finish no earlier than 2007-09-14 | S1 | 552h | 552h | PPACR-S1 | NTT DoCoMo | Rel-8 | Alain | PPACR-S1 | SP-37 |  |  |  |
| 3894 | 996.2 | Stage 3 for PPACR (CT1) | 278d? | 2007-11-14 A | 2008-12-05 A | 100% |  | 2007-11-14 | 2008-12-05 | 278d? |  | finish no earlier than 2008-12-05 | C1 | 2224h | 2224h | PPACR-CT1 | NTT DoCoMo | Rel-8 | Frederic | PPACR-CT1 | CP-38 | PCG-21 |  |  |
| 3895 | 997 | Conformance Test Aspects – Paging Permission with Access Control (PPAC) | 61d? | 2010-09-17 A | 2010-12-10 A | 100% |  | 2010-09-17 | 2010-12-10 | 61d? |  | finish no earlier than 2010-12-10 | R5 | 488h | 488h | PPAC_UEConTest | NTT DoCoMo | Rel-8 | Ingbert | PPAC_UEConTest | RP-49 | PCG-25 | RP-101074 |  |
| 3896 | 998 | **Charging for multi-phases services** | 70d? | 2007-12-06 A | 2008-03-12 | 99% | 0d? | 2007-12-06 | 2008-03-12 | 70d? | 0d |  | S1 | 560h | 560h | CHRGMPH | Telecom Italia | Rel-8 | Alain | CHRGMPH | SP-38 | PCG-21 |  |  |
| 3897 | 998.1 | Stage 1 for CHRGMPH | 70d? | 2007-12-06 A | 2008-03-12 A | 100% |  | 2007-12-06 | 2008-03-12 | 70d? |  | start no earlier than 2007-12-06 | S1 | 560h | 560h | CHRGMPH-s1 | Telecom Italia | Rel-8 | Alain | CHRGMPH-s1 | SP-38 | PCG-21 |  |  |
| 3898 | 999 | **Home NodeB / eNodeB** | 327d? | 2007-12-06 A | 2009-03-06 A | 100% |  | 2007-12-06 | 2009-03-06 | 327d? |  |  | S1; C1; C4 | 10952h | 10952h | HomeNB | Vodafone | Rel-8 | Alain | HomeNB | SP-38 | PCG-21 |  | HNB |
| 3899 | 999.1 | Stage 1 for Home NodeB / eNodeB | 70d? | 2007-12-06 A | 2008-03-12 A | 100% |  | 2007-12-06 | 2008-03-12 | 70d? |  | start no earlier than 2007-12-06 | S1 | 560h | 560h | HomeNB-S1 | Vodafone | Rel-8 | Alain | HomeNB-S1 | SP-38 | PCG-21 |  | HNB |
| 3900 | 999.2 | Support of Closed Subscriber Group (CSG) | 66d? | 2008-12-05 A | 2009-03-06 A | 100% |  | 2008-12-05 | 2009-03-06 | 66d? |  | finish no earlier than 2009-03-06 | C4 | 528h | 528h |  | CT#42 | Rel-8 | Kimmo |  | CP-42 | PCG-22 |  | HNB |
| 3901 | 999.3 | CSG and Idle Mode Mobility for LTE Home eNodeB | 126d? | 2008-09-12 A | 2009-03-06 A | 100% |  | 2008-09-12 | 2009-03-06 | 126d? |  | finish no earlier than 2009-03-06 | C1 | 1008h | 1008h | HomeNB-LTE | Huawei | Rel-8 | Frederic | HomeNB-LTE | CP-41 | PCG-21 |  | HNB |
| 3902 | 999.4 | CSG and Idle Mode Mobility for 3G Home NodeB | 126d? | 2008-09-12 A | 2009-03-06 A | 100% |  | 2008-09-12 | 2009-03-06 | 126d? |  | finish no earlier than 2009-03-06 | C1 | 1008h | 1008h | HomeNB-3G | Qualcomm | Rel-8 | Frederic | HomeNB-3G | CP-41 | PCG-21 |  | HNB |
| 3903 | 1000 | **UTRA HNB** | 326d? | 2008-03-07 A | 2009-06-04 A | 100% |  | 2008-03-07 | 2009-06-04 | 326d? |  |  | RP; S5 | 11008h | 11008h | HNB |  | Rel-8 | Issam | HNB | SP-39 | PCG-21 |  | HNB |
| 3904 | 1000.1 | Support of UTRA HNB | 201d? | 2008-05-30 A | 2009-03-06 A | 100% |  | 2008-05-30 | 2009-03-06 | 201d? |  | finish no earlier than 2009-03-06 | R2 | 1608h | 1608h | HNB-supp | Huawei | Rel-8 | Yong-Jun | HNB-supp | SP-40 | PCG-21 | RP-090040 | HNB |
| 3905 | 1000.2 | UTRAN Architecture for 3G HNB | 136d? | 2008-05-30 A | 2008-12-05 A | 100% |  | 2008-05-30 | 2008-12-05 | 136d? |  | finish no earlier than 2008-12-05 | R3 | 1088h | 1088h | HNB-arch | Alcatel-Lucent | Rel-8 | Juha | HNB-arch | SP-40 | PCG-21 | RP-090042 | HNB |
| 3906 | 1000.3 | FDD Home NodeB RF requirements | 261d? | 2008-03-07 A | 2009-03-06 A | 100% |  | 2008-03-07 | 2009-03-06 | 261d? |  | finish no earlier than 2009-03-06 | R4 | 2088h | 2088h | HNB-RF | Motorola | Rel-8 | Issam | HNB-RF | SP-39 | PCG-21 | RP-090041 | HNB |
| 3907 | 1000.4 | 3G Home NodeB OAM&P Type 1 Management Interface | 127d? | 2008-12-11 A | 2009-06-04 A | 100% |  | 2008-12-11 | 2009-06-04 | 127d? |  | finish no earlier than 2009-06-04 | S5 | 1008h | 1008h | HNB-3G_OAM | Huawei | Rel-8 | Mirko | HNB-3G_OAM | SP-42 | PCG-22 |  | HNB |
| 3908 | 1001 | **UTRA HNB – UE Conformance Testing** | 327d? | 2009-03-06 A | 2010-06-04 A | 100% |  | 2009-03-06 | 2010-06-04 | 327d? |  |  | R5 | 5224h | 5224h | HNB-UEConTest |  | Rel-8 | Ingbert | HNB-UEConTest | RP-43 | PCG-22 |  | HNB |
| 3909 | 1001.1 | Conformance Test Aspects – UTRA HNB (FDD) | 326d? | 2009-03-06 A | 2010-06-04 A | 100% |  | 2009-03-06 | 2010-06-04 | 326d? |  | finish no earlier than 2010-06-04 | R5 | 2608h | 2608h | HNB-UEConTestFDD | Huawei | Rel-8 | Ingbert | HNB-UEConTestFDD | RP-43 | PCG-22 | RP-100482 | HNB |
| 3910 | 1002 | Lawful Interception in the 3GPP Rel-8 | 524d? | 2007-03-12 A | 2009-03-12 A | 100% |  | 2007-03-12 | 2009-03-12 | 524d? |  | finish no earlier than 2009-03-12 | S3 | 4192h | 4192h | LI8 | BMWI, Verizon | Rel-8 | Mirko | LI8 |  |  |  |  |
| 3911 | 1003 | **Generic Bootstrapping Architecture Push Function** | 258d? | 2008-03-12 A | 2009-03-06 A | 100% |  | 2008-03-12 | 2009-03-06 | 258d? |  |  | S3; C1; C4 | 10596.8h | 10596.8h | GBAPush | Ericsson | Rel-8 | Mirko | GBAPush | SP-39 | PCG-21 |  |  |
| 3912 | 1003.1 | SA3 part of GBAPush (33.223) | 193d? | 2008-03-12 A | 2008-12-05 A | 100% |  | 2008-03-12 | 2008-12-05 | 193d? |  | finish no earlier than 2008-12-05 | S3 | 1544h | 1544h | GBAPush | Ericsson | Rel-8 | Mirko |  | SP-39 | PCG-21 |  |  |
| 3913 | 1003.2 | CT1 part of GBAPush | 178.8d? | 2008-03-12 A | 2009-03-06 A | 100% |  | 2008-03-12 | 2009-03-06 | 178.8d? |  | finish no earlier than 2009-03-06 | C1 | 1430.4h | 1430.4h | GBAPush | Ericsson | Rel-8 | Frederic |  | SP-39 | PCG-21 |  |  |
| 3914 | 1003.3 | CT4 part of GBAPush | 178.8d? | 2008-03-12 A | 2009-03-06 A | 100% |  | 2008-03-12 | 2009-03-06 | 178.8d? |  | finish no earlier than 2009-03-06 | C4 | 1430.4h | 1430.4h | GBAPush | Ericsson | Rel-8 | Kimmo |  | SP-39 | PCG-21 |  |  |
| 3915 | 1004 | Requirements and Test methods for Wideband Terminals | 197d? | 2008-03-12 A | 2008-12-11 A | 100% |  | 2008-03-12 | 2008-12-11 | 197d? |  | start no earlier than 2008-03-12 | S4 | 1576h | 1576h | RETEM_WB_T | FT, Ericsson | Rel-8 | Paolo | RETEM_WB_T |  |  |  |  |
| 3916 | 1005 | Extending PSS and MBMS User Services for optimized Mobile TV | 266d? | 2007-12-06 A | 2008-12-11 A | 100% |  | 2007-12-06 | 2008-12-11 | 266d? |  | finish no earlier than 2008-12-11 | S4 | 2128h | 2128h | PSS_MBMS_OMTV | Ericsson | Rel-8 | Paolo | PSS_MBMS_OMTV |  |  |  |  |

Notes:
- 3892: CP#42 completed. Triggered by Study UID_330016 (PPAC). / WI rapporteur e-mail: Morita Takashi
- 3893: SP#37 completed / Impacted TSs and TRs: 22.011 / WI rapporteur e-mail: Morita Takashi
- 3894: CP#42 completed / Impacted TSs and TRs: 24.008, 23.122, 24.301
- 3895: RP#50 completed / Impacted TSs and TRs: UTRA 34.108, 34.123-1, 34.123-2, 34.123-3 / WI rapporteur e-mail: Takao.Shimizu.rp@nttdocomo.com
- 3896: SP#39 Stage 1 completed / Impacted TSs and TRs: 22.115 / WI rapporteur e-mail: Marco.DeLuca1@telecomitalia.it
- 3897: SP#39 completed / Impacted TSs and TRs: 22.115 / WI rapporteur e-mail: Marco.DeLuca1@telecomitalia.it
- 3898: CP#43 completed / WI rapporteur e-mail: John Watson
- 3899: SP#39 completed / Impacted TSs and TRs: 22.011, 22.115 / WI rapporteur e-mail: John Watson
- 3900: CP#43 completed. SP#42 SP-080874 22.011CR0141 confirmed Requirement to support roaming subscribers with CSG home network subscription but did NOT confirmed requirement for home network independent support of roamers in CSG / Impacted TSs and TRs: 29.002, 29.272, 23.008, 23.003 / WI rapporteur e-mail: Hannu Hietalahti
- 3901: CP#43 completed / Impacted TSs and TRs: 23.122, new (24.285, 24.301, 24.801) / WI rapporteur e-mail: zhang.peng@huawei.com
- 3902: CP#43 completed / Impacted TSs and TRs: 23.122, 24.008, new 24.285 / WI rapporteur e-mail: Osok Song
- 3903: SP#44 completed
- 3904: RP#43 completed / Impacted TSs and TRs: 25.304, 25.306, 25.331, new 25.367 / WI rapporteur e-mail: Yang Xudong (yangxudong@huawei.com)
- 3905: RP#42 completed / Impacted TSs and TRs: 25.401, 25.410, 25.412, 25.413, 25.414, 25.415, new (25.467, 25.468, 25.469) / WI rapporteur e-mail: Martin Warner (mw15@alcatel-lucent.com)
- 3906: RP#43 completed / Impacted TSs and TRs: 25.104, 25.141, new 25.967 / WI rapporteur e-mail: Ying Cai (yingcai@motorola.com)
- 3907: SP#44 completed. Complements work in BroadBand Forum / Impacted TSs and TRs: new (32.581, 32.582, 32.583, 32.584) / WI rapporteur e-mail: Zou Lan (zlan@huawei.com)
- 3908: RP#48 FDD completed. Testing for Feature UID_390033 UTRA HNB
- 3909: RP#48 completed / Impacted TSs and TRs: 34.108, 34.123-1, 34.123-2, 34.123-3 / WI rapporteur e-mail: Trica Li (trica_li@huawei.com)
- 3910: SP#43 completed / Impacted TSs and TRs: 33.106, 33.107, 33.108 / WI rapporteur e-mail: berthold.wilhelm@bnetza.de, ron_ryan@verizon.net
- 3911: CP#43 completed / WI rapporteur e-mail: Rolf Blom
- 3912: SP#42 completed 33.223 as Rel-8. TS 33.224 moved to Rel-9 under new UID_420039 / Impacted TSs and TRs: 33.223 / WI rapporteur e-mail: Rolf Blom
- 3913: CP#43 completed / Impacted TSs and TRs: 24.109 / WI rapporteur e-mail: Rolf Blom
- 3914: CP#43 completed / Impacted TSs and TRs: 29.109 / WI rapporteur e-mail: Rolf Blom
- 3915: SP#42 completed. SP#39 WID approved. / Impacted TSs and TRs: 26.131, 26.132 / WI rapporteur e-mail: stephane.ragot@orange-ftgroup.com, wanqing.shi@sonyericsson.com
- 3916: SP#42 completed. SP#38 WID approved. / Impacted TSs and TRs: 26.234, 26.346, 26.946 / WI rapporteur e-mail: thorsten.lohmar@ericsson.com

| ID | WBS | Task | Duration | Start | Finish | Complete | Baseline start | Baseline finish | Baseline duration | Constraint | Resources | Work | Actual work | Acronym | PCG approved | WI rapporteur name | Release | TSG approved | MCC resp | Acronym_3GU_Export | TSG stopped | PCG stopped |
| --- | --- | --- | --- | --- | --- | --- | --- | --- | --- | --- | --- | --- | --- | --- | --- | --- | --- | --- | --- | --- | --- | --- |
| 3917 | 1006 | **Encoding formats, transport formats and media description signalling for interworking, QoE, and other enhancements to MTSI-MHI** | 331d? | 2007-12-06 A | 2009-03-12 A | 100% | 2007-12-06 | 2009-03-12 | 331d? |  | S4; C3; C4 | 14936h | 14936h | MTSI_eMHI | PCG-21 | Ericsson, Qualcomm | Rel-8 | SP-40 | Paolo | MTSI_eMHI |  |  |
| 3918 | 1006.1 | MTSI Video - Dynamic Rate Adaptation/Signalling of Image Size | 331d? | 2007-12-06 A | 2009-03-12 A | 100% | 2007-12-06 | 2009-03-12 | 331d? | finish no earlier than 2009-03-12 | S4 | 2648h | 2648h | MTSI_eMHI-DRASIS |  | Qualcomm, Samsung | Rel-8 |  | Paolo | MTSI_eMHI-DRASIS |  |  |
| 3919 | 1006.2 | CT3 part of Enhancement of interworking between MTSI and CS networks | 201d? | 2008-05-30 A | 2009-03-06 A | 100% | 2008-05-30 | 2009-03-06 | 201d? | finish no earlier than 2009-03-06 | C3 | 1608h | 1608h | MTSI_eMHI | PCG-21 | Huawei | Rel-8 | CP-40 | Adrian |  |  |  |
| 3920 | 1006.3 | CT4 part of Enhancement of interworking between MTSI and CS networks | 201d? | 2008-05-30 A | 2009-03-06 A | 100% | 2008-05-30 | 2009-03-06 | 201d? | finish no earlier than 2009-03-06 | C4 | 1608h | 1608h | MTSI_eMHI | PCG-21 | Huawei | Rel-8 | CP-40 | Kimmo |  |  |  |
| 3921 | 1006.4 | Deleted - CT1 part of Enhancement of interworking between MTSI and CS networks | 141d? | 2008-05-30 A | 2008-12-12 A | 100% | 2008-05-30 | 2008-12-12 | 141d? | start no earlier than 2008-05-30 | C1 | 1128h | 1128h | MTSI_eMHI | PCG-21 | Huawei | Rel-8 | CP-40 | Frederic |  | CP-42 |  |
| 3922 | 1007 | **Rel-8 Operations, Administration, Maintenance and Provisioning (OAM&P)** | 1445d? | 2007-06-07 A | 2012-12-07 A | 100% | 2007-06-07 | 2012-12-07 | 1445d? |  | S5; C1; C4; IETF | 120270h | 120270h | OAM8 |  |  | Rel-8 | TSG-34 | Mirko | OAM8 |  |  |
| 3923 | 1007.1 | **Rel-8 Network Infrastructure Management** | 653d? | 2007-06-07 A | 2009-12-04 A | 100% | 2007-06-07 | 2009-12-04 | 653d? |  | S5 | 19464h | 19464h | OAM8-NIM |  |  | Rel-8 | TSG-34 | Mirko | OAM8-NIM |  |  |
| 3924 | 1007.1.1 | Telecom Management Methodology | 461d? | 2007-06-07 A | 2009-03-12 A | 100% | 2007-06-07 | 2009-03-12 | 461d? | finish no earlier than 2009-03-12 | S5 | 3688h | 3688h | OAM8-NIM |  | Ericsson | Rel-8 |  | Mirko |  |  |  |
| 3925 | 1007.1.2 | Advanced Alarming on Itf-N | 266d? | 2007-06-07 A | 2008-06-12 A | 100% | 2007-06-07 | 2008-06-12 | 266d? | finish no earlier than 2008-12-11 | S5 | 2128h | 2128h | OAM8-NIM |  | Nokia Siemens Networks | Rel-8 |  | Mirko |  |  |  |
| 3926 | 1007.1.3 | CN CS Bearer Transport Network (BTN) relative NRM | 266d? | 2007-06-07 A | 2008-06-12 A | 100% | 2007-06-07 | 2008-06-12 | 266d? | finish no earlier than 2008-12-11 | S5 | 2128h | 2128h | OAM8-NIM |  | China Mobile | Rel-8 |  | Mirko |  |  |  |
| 3927 | 1007.1.4 | Alignment with eTOM and M.3060 architectural concepts | 210d? | 2008-02-22 A | 2008-12-11 A | 100% | 2008-02-22 | 2008-12-11 | 210d? | start no earlier than 2008-02-22 | S5 | 1680h | 1680h | OAM8-NIM | PCG-21 | TeliaSonera | Rel-8 | SP-39 | Mirko |  |  |  |
| 3928 | 1007.1.5 | IRP SOAP Solution Sets | 201d? | 2008-06-05 A | 2009-03-12 A | 100% | 2008-06-05 | 2009-03-12 | 201d? | finish no earlier than 2009-03-12 | S5 | 1608h | 1608h | OAM8-NIM | PCG-21 | Ericsson | Rel-8 | SP-40 | Mirko |  |  |  |
| 3929 | 1007.1.6 | Create missing specifications for IRP XML definitions | 52d? | 2009-09-24 A | 2009-12-04 A | 100% | 2009-09-24 | 2009-12-04 | 52d? | finish no earlier than 2010-03-12 | S5 | 416h | 416h | OAM8-NIM | PCG-23 | ZTE | Rel-8 | SP-45 | Mirko |  |  |  |
| 3930 | 1007.1.7 | Deleted - End point modelling for reference point | 324d? | 2007-09-17 A | 2008-12-11 A | 100% | 2007-09-17 | 2008-12-11 | 324d? | finish no earlier than 2008-12-11 | S5 | 2592h | 2592h | OAM8-NIM |  | Motorola | Rel-8 | SP-37 | Mirko |  | SP-41 | PCG-21 |
| 3931 | 1007.2 | **Rel-8 Performance Management** | 461d? | 2007-06-07 A | 2009-03-12 A | 100% | 2007-06-07 | 2009-03-12 | 461d? |  | S5 | 13712h | 13712h | OAM8-PM |  |  | Rel-8 | TSG-34 | Mirko | OAM8-PM |  |  |
| 3932 | 1007.2.1 | IP bearer network Performance measurement definitions | 396d? | 2007-06-07 A | 2008-12-11 A | 100% | 2007-06-07 | 2008-12-11 | 396d? | finish no earlier than 2008-12-11 | S5 | 3168h | 3168h | OAM8-PM |  | China Mobile | Rel-8 |  | Mirko |  |  |  |
| 3933 | 1007.2.2 | HSUPA performance measurements | 396d? | 2007-06-07 A | 2008-12-11 A | 100% | 2007-06-07 | 2008-12-11 | 396d? | finish no earlier than 2008-12-11 | S5 | 3168h | 3168h | OAM8-PM |  | China Mobile | Rel-8 |  | Mirko |  |  |  |
| 3934 | 1007.2.3 | Key Performance Indicators (KPIs) for UMTS and GSM | 461d? | 2007-06-07 A | 2009-03-12 A | 100% | 2007-06-07 | 2009-03-12 | 461d? | finish no earlier than 2009-03-12 | S5 | 3688h | 3688h | OAM8-PM |  | China Mobile | Rel-8 |  | Mirko |  |  |  |
| 3935 | 1007.3 | **Rel-8 Trace Management** | 1249d? | 2008-03-07 A | 2012-12-07 A | 100% | 2008-03-07 | 2012-12-07 | 1249d? |  | C1; C4; IETF | 40854.4h | 40854.4h | OAM8-Trace |  |  | Rel-8 | TSG-34 | Mirko | OAM8-Trace |  |  |
| 3936 | 1007.3.1 | CT1 part of Service Level Tracing in IMS | 196d? | 2008-03-07 A | 2008-12-05 A | 100% | 2008-03-07 | 2008-12-05 | 196d? | finish no earlier than 2008-12-05 | C1 | 1568h | 1568h | OAM8-Trace |  | Vodafone | Rel-8 |  | Frederic |  |  |  |
| 3937 | 1007.3.2 | (IETF) Service Level Tracing in IMS (draft-dawes-sipping-debug) | 717d? | 2008-03-07 A | 2012-12-07 A | 100% | 2008-03-07 | 2012-12-07 | 717d? | finish no earlier than 2012-12-07 | C1-IETF | 5736h | 5736h | OAM8-Trace | PCG-27 | Peter Dawes | Rel-8 | CP-52 | Frederic |  |  |  |
| 3938 | 1007.3.3 | (IETF) Service Level Tracing in IMS (draft-dawes-sipping-debug-event) | 98d? | 2008-03-07 A | 2011-12-09 A | 100% | 2008-03-07 | 2011-12-09 | 98d? | finish no earlier than 2011-12-09 | C1-IETF | 768.04h | 768.04h | OAM8-Trace | PCG-27 | Peter Dawes | Rel-8 | CP-53 | Frederic |  |  |  |
| 3939 | 1007.3.4 | CT4 part of Service Level Tracing in IMS | 175.4d? | 2008-03-07 A | 2008-12-05 A | 100% | 2008-03-07 | 2008-12-05 | 175.4d? | finish no earlier than 2008-12-05 | C4 | 1403.2h | 1403.2h | OAM8-Trace | PCG-21 | Vodafone | Rel-8 | CP-40 | Frederic |  |  |  |
| 3940 | 1007.3.5 | Deleted - CT3 part of Service Level Tracing in IMS | 175.4d? | 2008-03-07 A | 2008-12-05 A | 100% | 2008-03-07 | 2008-12-05 | 175.4d? | finish no earlier than 2008-12-05 | C3 | 1403.2h | 1403.2h | OAM8-Trace | PCG-21 | Vodafone | Rel-8 | CP-40 | Adrian |  | CP-42 | PCG-22 |

Notes:
- 3917: TSG#43 completed / WI rapporteur e-mail: olle.franceschi@ericsson.com, nleung@qualcomm.com
- 3918: SP#43 completed / Impacted TSs and TRs: 26.114 / WI rapporteur e-mail: nleung@qualcomm.com & kyunghun.jung@samsung.com
- 3919: CP#43 completed / Impacted TSs and TRs: 29.163 / WI rapporteur e-mail: Tingfang Tang (tagna_online@huawei.com)
- 3920: CP#43 completed / Impacted TSs and TRs: 29.332 / WI rapporteur e-mail: Tingfang Tang (tagna_online@huawei.com)
- 3921: CP#42 stopped (No CT1-impact). WID updated CP-080422=>CP-080774 / WI rapporteur e-mail: Tingfang Tang (tagna_online@huawei.com)
- 3922: OAM8 is an umbrella Feature also for OAM&P related TEI8 type of changes that are not part of any other dedicated feature/WI / Impacted TSs and TRs: TR 30.818
- 3923: -
- 3924: SP#43 completed / Impacted TSs and TRs: 32.155, 32.153 / WI rapporteur e-mail: thomas.tovinger@ericsson.com
- 3925: SP#40 completed / Impacted TSs and TRs: 32.121, 32.122, 32.123 / WI rapporteur e-mail: SUERBAUM, Clemens
- 3926: SP#40 completed / Impacted TSs and TRs: 32.632, 32.633, 32.635 / WI rapporteur e-mail: Li Jian (lijian@chinamobile.com)
- 3927: SP#42 completed / Impacted TSs and TRs: 32.101/2, 32-series / WI rapporteur e-mail: tommy.berggren@teliasonera.com
- 3928: SP#43 completed / Impacted TSs and TRs: 32.111-7, 32.617, 32.417, 32.367, 32.347, 32.111-1, 32.111-2, 32.111-3, 32.111-5, 32.307, 32.317, 32.341, 32.342, 32.343, 32.345, 32.361, 32.362, 32.363, 32.365, 32.411, 32.412, 32.413, 32.415, 32.611, 32.612, 32.613, 32.615, 32.625 / WI rapporteur e-mail: edwin.tse@ericsson.com
- 3929: SP#46 completed. Create missing XML definitions specs for IRPs (Advanced Alarm Management, Communication Surveillance, Self-Configuration of Network Elements, Software Management) needed for implementation of Rel-8 Notification Log IRP (TS 32.33x) / Impacted TSs and TRs: new (32.125, 32.355, 32.505, 32.535), 32.150, 32.153, 32.335 / WI rapporteur e-mail: Shuqiang Huang (huangsq@zte.com.cn)
- 3930: SP#41 Work stopped. Contributions related to E-UTRAN/EPC to be submitted to UID_380036 E-UTRAN NRM IRP/ UID_380037 EPC NRM IRP / Impacted TSs and TRs: 32.152, 32.62/3/4x, 32.73x / WI rapporteur e-mail: Yizhi Yao (yzyao@motorola.com)
- 3931: - / WI rapporteur e-mail: Li Jian (lijian@chinamobile.com)
- 3932: SP#42 completed / Impacted TSs and TRs: 32.321, 32.322, 32.323, 32.325 / WI rapporteur e-mail: lilianyuan@chinamobile.com
- 3933: SP#42 completed / Impacted TSs and TRs: 32.405 / WI rapporteur e-mail: Li Jian (lijian@chinamobile.com)
- 3934: SP#43 completed / Impacted TSs and TRs: 32.410 / WI rapporteur e-mail: Li Jian (lijian@chinamobile.com), Liang Shuangchun (liangshuangchun@cmdi.chinamobile.com)
- 3935: -
- 3936: CP#42 completed / Impacted TSs and TRs: 24.323, 24.229 / WI rapporteur e-mail: peter.dawes@vodafone.com
- 3937: CP#58 Removed from Rel-8, Rel-9 and Rel-10 (Not completed internet-draft) / Impacted TSs and TRs: Rel-11 remains draft-dawes-dispatch-debug / WI rapporteur e-mail: peter.dawes@vodafone.com
- 3938: CP#54 Draft removed from 3GPP documentation, covered by draft-dawes-sipping-debug / Impacted TSs and TRs: draft-dawes-sipping-debug-event / WI rapporteur e-mail: peter.dawes@vodafone.com
- 3939: CP#42 completed / Impacted TSs and TRs: 29.228, 29.229 / WI rapporteur e-mail: peter.dawes@vodafone.com
- 3940: CP#42 stopped (No CT3-impact) / WI rapporteur e-mail: peter.dawes@vodafone.com

| ID | WBS | Task | Type | Duration | Start | Finish | Complete | Baseline start | Baseline finish | Baseline duration | Constraint | Resources | Work | Actual work | Acronym | Release | MCC resp | Acronym_3GU_Export | WI rapporteur name | WI rapporteur e-mail | PCG approved | TSG approved | PCG stopped | TSG stopped | Status Report |
| --- | --- | --- | --- | --- | --- | --- | --- | --- | --- | --- | --- | --- | --- | --- | --- | --- | --- | --- | --- | --- | --- | --- | --- | --- | --- |
| 3941 | 1008 | **Rel-8 Charging Management small Enhancements** |  | 716d? | 2006-03-16 A | 2008-12-11 A | 100% | 2006-03-16 | 2008-12-11 | 716d? |  | S5 | 12544h | 12544h | CH8 | Rel-8 | Mirko | CH8 |  |  |  |  |  |  |  |
| 3942 | 1008.1 | Online charging correlation |  | 457d? | 2006-03-16 A | 2007-12-14 A | 100% | 2006-03-16 | 2007-12-14 | 457d? | start no earlier than 2006-03-16 | S5 | 3656h | 3656h | CH8 | Rel-8 | Mirko |  | Orange | Chahine, Rony |  |  |  |  |  |
| 3943 | 1008.2 | SMS online charging |  | 137d? | 2007-06-07 A | 2007-12-14 A | 100% | 2007-06-07 | 2007-12-14 | 137d? | finish no earlier than 2007-12-14 | S5 | 1096h | 1096h | CH8 | Rel-8 | Mirko |  | Vodafone | Gavin.Wong@vodafone.com |  |  |  |  |  |
| 3944 | 1008.3 | Introduce Online Charging from SMS-SC into the SMS Charging Specifications |  | 61d? | 2008-09-18 A | 2008-12-11 A | 100% | 2008-09-18 | 2008-12-11 | 61d? | finish no earlier than 2008-12-11 | S5 | 488h | 488h | CH8 | Rel-8 | Mirko |  | Acision | erik.gebler@acision.com | PCG-21 | SP-41 |  |  |  |
| 3945 | 1008.4 | Deleted - WLAN Offline Charging |  | 244d? | 2008-01-07 A | 2008-12-11 A | 100% | 2008-01-07 | 2008-12-11 | 244d? | finish no earlier than 2008-12-11 | S5 | 1952h | 1952h | CH8 | Rel-8 | Mirko |  | Alcatel-Lucent | maryse.gardella@alcatel-lucent.com | PCG-21 | SP-38 | PCG-22 | SP-42 |  |
| 3946 | 1009 | **Conferencing enhancements for Mp interface** |  | 266d? | 2007-11-30 A | 2008-12-05 A | 100% | 2007-11-30 | 2008-12-05 | 266d? |  | C4 | 6384h | 6384h | eMp | Rel-8 | Kimmo | eMp | Huawei | Chencheng@huawei.com | PCG-21 |  |  |  |  |
| 3947 | 1009.1 | Stage 2 for eMp |  | 266d? | 2007-11-30 A | 2008-12-05 A | 100% | 2007-11-30 | 2008-12-05 | 266d? | finish no earlier than 2008-12-11 | C4 | 2128h | 2128h | eMp | Rel-8 | Kimmo |  | Huawei | Chencheng@huawei.com | PCG-21 | CP-38 |  |  |  |
| 3948 | 1009.2 | Stage 3 for eMp |  | 266d? | 2007-11-30 A | 2008-12-05 A | 100% | 2007-11-30 | 2008-12-05 | 266d? | finish no earlier than 2008-12-05 | C4 | 2128h | 2128h | eMp | Rel-8 | Kimmo |  | Huawei | Chencheng@huawei.com | PCG-21 | CP-38 |  |  |  |
| 3949 | 1010 | **Contact Manager for 3GPP UICC applications** |  | 642d? | 2006-06-22 A | 2008-12-05 A | 100% | 2006-06-22 | 2008-12-05 | 642d? |  | C6 | 13352h | 13352h | eUPHBOOK | Rel-8 | Xavier | eUPHBOOK | Gemalto | Jacques.seif@gemalto.com |  |  |  |  |  |
| 3950 | 1010.1 | Requirements for Contact Manager |  | 392d? | 2006-06-22 A | 2007-12-21 A | 100% | 2006-06-22 | 2007-12-21 | 392d? | finish no earlier than 2007-12-21 | C6 | 3136h | 3136h | eUPHBOOK-St1 | Rel-8 | Xavier | eUPHBOOK-St1 | Gemalto | Jacques.seif@gemalto.com |  |  |  |  |  |
| 3951 | 1010.2 | External interface for eUPHBOOK |  | 220d? | 2007-05-07 A | 2008-03-07 A | 100% | 2007-05-07 | 2008-03-07 | 220d? | finish no earlier than 2008-03-07 | C6 | 1760h | 1760h | eUPHBOOK-Ext_Spec | Rel-8 | Xavier | eUPHBOOK-Ext_Spec | Gemalto | Jacques.seif@gemalto.com |  |  |  |  |  |
| 3952 | 1010.3 | Internal interface for eUPHBOOK |  | 415d? | 2007-05-07 A | 2008-12-05 A | 100% | 2007-05-07 | 2008-12-05 | 415d? | finish no earlier than 2008-12-05 | C6 | 3320h | 3320h | eUPHBOOK-Int_Spec | Rel-8 | Xavier | eUPHBOOK-Int_Spec | Gemalto | Jacques.seif@gemalto.com |  | CP-37 |  |  |  |
| 3953 | 1010.4 | Deleted - Implementation of eUPHBOOK | milestone | 0d? | 2007-06-21 A | 2007-06-21 A | 100% | 2007-06-21 | 2007-06-21 | 0d? | start no earlier than 2007-06-21 | C6 |  |  | eUPHBOOK-St23 | Rel-8 | Xavier | eUPHBOOK-St23 | Giesecke & Devrient | Claus Dietze |  |  |  | SP-33 |  |
| 3954 | 1011 | **Rel-8 LTE – 3G Long Term Evolution - Evolved Packet System RAN part** |  | 644d? | 2006-09-25 A | 2009-03-12 A | 100% | 2006-09-25 | 2009-03-12 | 644d? |  | RP; S5 | 50048h | 50048h | LTE | Rel-8 |  | LTE | NTT DoCoMo | Takehiro Nakamura (nakamurata@nttdocomo.co.jp) |  |  |  |  | RP-080741 |
| 3955 | 1011.1 | LTE – Physical Layer |  | 380d? | 2006-09-25 A | 2008-03-07 A | 100% | 2006-09-25 | 2008-03-07 | 380d? | finish no earlier than 2007-09-14 | R1 | 3040h | 3040h | LTE-Phys | Rel-8 | Patrick | LTE-Phys | NTT DoCoMo | Sadayuki Abeta |  |  |  |  | RP-080741 |
| 3956 | 1011.2 | LTE – Radio Interface Layer 2 and 3 Protocol Aspect |  | 575d? | 2006-09-25 A | 2008-12-05 A | 100% | 2006-09-25 | 2008-12-05 | 575d? | finish no earlier than 2008-12-11 | R2 | 4600h | 4600h | LTE-L23 | Rel-8 | Yong-Jun | LTE-L23 | Nokia Siemens Networks | benoist.sebire@nokia.com |  |  |  |  | RP-080741 |
| 3957 | 1011.3 | LTE – eUTRAN Interfaces |  | 575d? | 2006-09-25 A | 2008-12-05 A | 100% | 2006-09-25 | 2008-12-05 | 575d? | finish no earlier than 2008-12-11 | R3 | 4600h | 4600h | LTE-interfaces | Rel-8 | Juha | LTE-interfaces | Ericsson | Martin Israelsson |  |  |  |  | RP-080741 |
| 3958 | 1011.4 | LTE – Evolved UTRA and UTRAN RF Radio Transmission/Reception, System Performance Requirements and Conformance Testing |  | 575d? | 2006-09-25 A | 2008-12-05 A | 100% | 2006-09-25 | 2008-12-05 | 575d? | finish no earlier than 2008-12-11 | R4 | 4600h | 4600h | LTE-RF | Rel-8 | Issam | LTE-RF | Nokia Siemens Networks | Tuomo Saynajakangas |  |  |  |  | RP-080741 |
| 3959 | 1011.5 | LTE – FDD repeaters |  | 386d? | 2007-09-14 A | 2009-03-06 A | 100% | 2007-09-14 | 2009-03-06 | 386d? | finish no earlier than 2009-03-06 | R4 | 3088h | 3088h | LTE-Repeaters | Rel-8 | Issam | LTE-Repeaters | Powerwave Technologies, Andrew Wireless | ralf.michanikl@andrew.com, Alf.Ahlstrom@pwav.com |  | RP-37 |  |  | RP-090037 |
| 3960 | 1011.6 | **E-UTRAN Data Definitions** |  | 389d? | 2007-09-17 A | 2009-03-12 A | 100% | 2007-09-17 | 2009-03-12 | 389d? |  | S5 | 13096h | 13096h | E-UTRAN-OAM | Rel-8 | Mirko | E-UTRAN-OAM |  |  | PCG-21 | SP-39 |  |  |  |
| 3961 | 1011.6.1 | Subscriber and Equipment Trace for E-UTRAN and EPC |  | 389d? | 2007-09-17 A | 2009-03-12 A | 100% | 2007-09-17 | 2009-03-12 | 389d? | finish no earlier than 2009-03-12 | S5 | 3112h | 3112h | E-UTRAN-OAM | Rel-8 | Mirko |  | Ericsson | robert.petersen@ericsson.com |  | SP-37 |  |  |  |
| 3962 | 1011.6.2 | E-UTRAN Network Resource Model (NRM) Integration Reference Point (IRP) |  | 309d? | 2008-01-07 A | 2009-03-12 A | 100% | 2008-01-07 | 2009-03-12 | 309d? | finish no earlier than 2009-03-12 | S5 | 2472h | 2472h | E-UTRAN-OAM | Rel-8 | Mirko |  | Ericsson | ELMDAHL, Per | PCG-21 | SP-38 |  |  |  |
| 3963 | 1011.6.3 | Performance measurements for E-UTRAN |  | 275d? | 2008-02-22 A | 2009-03-12 A | 100% | 2008-02-22 | 2009-03-12 | 275d? | finish no earlier than 2009-03-12 | S5 | 2200h | 2200h | E-UTRAN-OAM | Rel-8 | Mirko |  | Motorola, Huawei | Yizhi Yao (yzyao@motorola.com) | PCG-21 | SP-39 |  |  |  |
| 3964 | 1011.6.4 | Key Performance Indicators (KPIs) for E-UTRAN |  | 275d? | 2008-02-22 A | 2009-03-12 A | 100% | 2008-02-22 | 2009-03-12 | 275d? | finish no earlier than 2009-03-12 | S5 | 2200h | 2200h | E-UTRAN-OAM | Rel-8 | Mirko |  | Ericsson | ulf.hubinette@ericsson.com | PCG-21 | SP-39 |  |  |  |

Notes:
- 3941: CH8 is an umbrella Feature also for OAM&P related TEI8 type of changes that are not part of any other dedicated feature/WI / Impacted TSs and TRs: TR 30.818
- 3942: SP#38 completed / Impacted TSs and TRs: 32.296
- 3943: SP#38 completed / Impacted TSs and TRs: 32.240, 32.299, new 32.274
- 3944: SP#42 completed. Linked to SA2 UID 32081 (Support of SMS over IP networks) and CT4 UID 340016 (Routeing of MT-SMS via the HPLMN). / Impacted TSs and TRs: 32.274, 32.299
- 3945: SP#42 stopped / Impacted TSs and TRs: 32.252, 32.298, 32.299
- 3946: CP#42 completed
- 3947: CP#42 completed / Impacted TSs and TRs: 23.333
- 3948: CP#42 completed / Impacted TSs and TRs: 29.333
- 3949: CP#42 completed. CP#40: WID updated CP-070622=>CP-080382. aka Enhanced USIM phonebook
- 3950: CP#38 completed / Impacted TSs and TRs: 21.111
- 3951: CP#39 completed / Impacted TSs and TRs: new 31.220
- 3952: CP#42 completed / Impacted TSs and TRs: new 31.221
- 3953: SP#33 stopped / Impacted TSs and TRs: 31.102
- 3954: RP#43 completed. Role model for SAE/LTE system wide project management by SA2 in SP-060166 / Impacted TSs and TRs: LTE 36.300, 36.938
- 3955: RP#39 completed / Impacted TSs and TRs: 36.201, 36.211, 36.212, 36.213, 36.214, 25.215, 25.225
- 3956: RP#42 completed / Impacted TSs and TRs: 36.302, 36.304, 36.306, 36.314, 36.321, 36.322, 36.323, 36.331, 25.302, 25.304, 25.331
- 3957: RP#42 completed / Impacted TSs and TRs: 36.401, 36.410, 36.411, 36.412, 36.413, 36.414, 36.420, 36.421, 36.422, 36.423, 36.424, 25.413
- 3958: RP#42 completed. RP#47 abandoned draft 36.801, 36.803, 36.804 / Impacted TSs and TRs: 36.101, 36.104, 36.113, 36.124, 36.133, 36.141, 36.942, 25.123, 25.133
- 3959: RP#43 completed. RP#47 create Rel-9 TR 36.956 (see R4-100386, RP-100320_RAN4 Report) / Impacted TSs and TRs: 36.106, 36.143, 25.113
- 3960: SP#43 completed
- 3961: SP#43 completed / Impacted TSs and TRs: 32.421, 2.422, 32.423, 2.441, 32.442, 32.443, 32.445
- 3962: SP#43 completed / Impacted TSs and TRs: new (32.761, 32.762, 32.763, 32.765)
- 3963: SP#43 completed / Impacted TSs and TRs: new 32.425
- 3964: SP#43 completed / Impacted TSs and TRs: new (32.450, 32.451)

| ID | WBS | Task | Duration | Start | Finish | Complete | Baseline start | Baseline finish | Baseline duration | Constraint | Resources | Work | Actual work | Acronym | PCG approved | WI rapporteur name | WI rapporteur e-mail | Release | TSG approved | MCC resp | Special Focus Doc | Acronym_3GU_Export | Status Report | PCG stopped | TSG stopped |
| --- | --- | --- | --- | --- | --- | --- | --- | --- | --- | --- | --- | --- | --- | --- | --- | --- | --- | --- | --- | --- | --- | --- | --- | --- | --- |
| 3965 | 1011.7 | **Self-Organizing Networks (SON)** | 210d? | 2008-02-22 A | 2008-12-11 A | 100% | 2008-02-22 | 2008-12-11 | 210d? |  | S5 | 6720h | 6720h | LTE_SON-OAM | PCG-21 | Vodafone | GOMPAKIS, Panagiotis | Rel-8 | SP-39 | Mirko | SON | LTE_SON-OAM |  |  |  |
| 3966 | 1011.7.1 | SON Concepts and requirements | 210d? | 2008-02-22 A | 2008-12-11 A | 100% | 2008-02-22 | 2008-12-11 | 210d? |  | S5 | 1680h | 1680h | LTE_SON-OAM | PCG-21 | Vodafone | GOMPAKIS, Panagiotis | Rel-8 | SP-39 | Mirko |  |  |  |  |  |
| 3967 | 1011.7.2 | Self-Establishment of eNBs, including automated Software Management | 210d? | 2008-02-22 A | 2008-12-11 A | 100% | 2008-02-22 | 2008-12-11 | 210d? | start no earlier than 2008-02-22 | S5 | 1680h | 1680h | LTE_SON-OAM | PCG-21 | Nokia Siemens Networks | SUERBAUM, Clemens | Rel-8 | SP-39 | Mirko |  |  |  |  |  |
| 3968 | 1011.7.3 | SON Automatic Neighbour Relations (ANR) List Management | 210d? | 2008-02-22 A | 2008-12-11 A | 100% | 2008-02-22 | 2008-12-11 | 210d? | finish no earlier than 2008-12-11 | S5 | 1680h | 1680h | LTE_SON-OAM | PCG-21 | Ericsson | edwin.tse@ericsson.com | Rel-8 | SP-39 | Mirko |  |  |  |  |  |
| 3969 | 1012 | **Rel-8 LTE – Terminal Conformance Test Specification** | 657d? | 2007-06-01 A | 2009-12-04 A | 100% | 2007-06-01 | 2009-12-04 | 657d? |  | R5 | 14336h | 14336h | LTE-UEConTest |  |  |  | Rel-8 |  | Ingbert |  | LTE-UEConTest |  |  |  |
| 3970 | 1012.1 | 3G LTE – Terminal Protocol Conformance Test Specifications | 657d? | 2007-06-01 A | 2009-12-04 A | 100% | 2007-06-01 | 2009-12-04 | 657d? | finish no earlier than 2009-12-04 | R5 | 5256h | 5256h | LTE-UEConTest_SIG |  | NEC, Motorola | david.lecompte@nectech.fr, Jacob.John@motorola.com | Rel-8 |  | Ingbert |  | LTE-UEConTest_SIG | RP-091060 |  |  |
| 3971 | 1012.2 | LTE – Terminal Radio Transmission and Reception Conformance Test Specifications | 657d? | 2007-06-01 A | 2009-12-04 A | 100% | 2007-06-01 | 2009-12-04 | 657d? |  | R5 | 5256h | 5256h | LTE-UEConTest_RF |  | Agilent | andrea_leonardi@agilent.com | Rel-8 |  | Ingbert |  | LTE-UEConTest_RF | RP-091059 |  |  |
| 3972 | 1013 | **Rel-8 Improvements of the Radio Interface** | 525d? | 2007-03-05 A | 2009-03-06 A | 100% | 2007-03-05 | 2009-03-06 | 525d? |  | RP | 18152h | 18152h | RInImp8 |  |  |  | Rel-8 |  | Issam |  | RInImp8 |  |  |  |
| 3973 | 1013.1 | UMTS 1500 MHz | 140d? | 2007-03-05 A | 2007-09-14 A | 100% | 2007-03-05 | 2007-09-14 | 140d? | finish no earlier than 2007-09-14 | R4 | 1120h | 1120h | RInImp8-UMTS1500 |  | NTT DoCoMo | Takehiro Nakamura (nakamurata@nttdocomo.co.jp) | Rel-8 |  | Issam |  | RInImp8-UMTS1500 | RP-070526 |  |  |
| 3974 | 1013.2 | UMTS 700 MHz FDD | 325d? | 2007-03-05 A | 2008-05-30 A | 100% | 2007-03-05 | 2008-05-30 | 325d? | finish no earlier than 2008-06-12 | R4 | 2600h | 2600h | RInImp8-UMTS700 |  | Nokia | Tuomo Saynajakangas | Rel-8 |  | Issam |  | RInImp8-UMTS700 | RP-080260 |  |  |
| 3975 | 1013.3 | UMTS 1880 MHz TDD | 126d? | 2008-09-12 A | 2009-03-06 A | 100% | 2008-09-12 | 2009-03-06 | 126d? | finish no earlier than 2009-03-09 | R4 | 1008h | 1008h | RInImp9-UMTS1880TDD | PCG-21 | CATT | Yuexia Song (songyuexia@catt.cn) | Rel-8 | RP-41 | Issam |  | RInImp9-UMTS1880TDD | RP-090044 |  |  |
| 3976 | 1013.4 | UMTS 2300 MHz TDD LCR | 195d? | 2007-12-17 A | 2008-09-12 A | 100% | 2007-12-17 | 2008-09-12 | 195d? | finish no earlier than 2008-09-12 | R4 | 1560h | 1560h | RInImp8-UMTS2300TDD | PCG-21 | CATT | Yuexia Song (songyuexia@catt.cn) | Rel-8 | RP-38 | Issam |  | RInImp8-UMTS2300TDD | RP-080517 |  |  |
| 3977 | 1013.5 | Further Improved Minimum Performance Requirements for HSDPA UE (FDD) - Two-Branch Interference Cancellation | 265d? | 2007-03-05 A | 2008-03-07 A | 100% | 2007-03-05 | 2008-03-07 | 265d? | finish no earlier than 2008-03-12 | R4 | 2120h | 2120h | RInImp8-2BIC |  | AT&T | Marc Grant | Rel-8 |  | Issam |  | RInImp8-2BIC | RP-080041 |  |  |
| 3978 | 1013.6 | CS Voice Service over HSPA | 167d? | 2007-07-19 A | 2008-03-07 A | 100% | 2007-07-19 | 2008-03-07 | 167d? |  | R2 | 1336h | 1336h | RInImp8-CsHspa |  | Nokia Siemens Networks | woonhee.hwang@nsn.com | Rel-8 | RP-37 | Yong-Jun |  | RInImp8-CsHspa | RP-080042 |  |  |
| 3979 | 1013.7 | Performance requirements for 15 code reception with 16QAM/QPSK (FDD) | 126d? | 2007-06-11 A | 2008-03-07 A | 100% | 2007-06-11 | 2008-03-07 | 126d? | finish no earlier than 2008-06-12 | R4 | 1008h | 1008h | RInImp8-Hsdpa15codes |  | Vodafone | tim.frost@vodafone.com | Rel-8 | RP-37 | Issam |  | RInImp8-Hsdpa15codes | RP-080043 |  |  |
| 3980 | 1013.8 | Deleted - UMTS 2300 MHz FDD/TDD | 400d? | 2007-03-05 A | 2008-09-12 A | 100% | 2007-03-05 | 2008-09-12 | 400d? | finish no earlier than 2008-12-11 | R4 | 3200h | 3200h | RInImp8-UMTS2300 |  | AT&T | Marc Grant | Rel-8 |  | Issam |  | RInImp8-UMTS2300 | RP-080515 | PCG-21 | RP-41 |
| 3981 | 1014 | **Rel-8 Improvements of the Radio Interface - UE Conformance Testing** | 396d? | 2007-06-01 A | 2008-12-05 A | 100% | 2007-06-01 | 2008-12-05 | 396d? |  | R5 | 6256h | 6256h |  |  |  |  | Rel-8 |  | Ingbert |  |  |  |  |  |
| 3982 | 1014.1 | Conformance Test Aspects – CS Voice Service over HSPA | 336d? | 2007-06-01 A | 2008-09-12 A | 100% | 2007-06-01 | 2008-09-12 | 336d? | finish no earlier than 2008-09-12 | R5 | 2688h | 2688h | RInImp8-CsHspa_UEConTest |  | Huawei | baoyi@huawei.com | Rel-8 |  | Ingbert |  | RInImp8-CsHspa_UEConTest | RP-080542 |  |  |
| 3983 | 1014.2 | Conformance Test Aspects – Performance requirements for 15 code reception with 16QAM/QPSK (FDD) | 195d? | 2008-03-07 A | 2008-12-05 A | 100% | 2008-03-07 | 2008-12-05 | 195d? | finish no earlier than 2008-12-05 | R5 | 1560h | 1560h | RInImp8-UEConTest_Hsdpa15codes | PCG-21 | Ericsson | Mikael.Ziren@Ericsson.com | Rel-8 | RP-40 | Ingbert |  | RInImp8-UEConTest_ Hsdpa15codes | RP-080818 |  |  |
| 3984 | 1015 | **Rel-8 RAN improvements** | 520d? | 2007-06-04 A | 2009-05-29 A | 100% | 2007-06-04 | 2009-05-29 | 520d? |  | RP | 37481.6h | 37481.6h |  |  |  |  | Rel-8 |  |  |  |  |  |  |  |
| 3985 | 1015.1 | Combination of 64QAM and MIMO for HSDPA (FDD) | 205d? | 2007-06-04 A | 2008-09-12 A | 100% | 2007-06-04 | 2008-09-12 | 205d? | finish no earlier than 2008-09-12 | R1 | 1640h | 1640h | RANimp-64QamMimoHsdpa |  | Ericsson | Johan.Bergman@ericsson.com | Rel-8 |  | Patrick |  | RANimp-64QamMimoHsdpa | RP-080518 |  |  |
| 3986 | 1015.2 | Improved L2 for uplink | 186d? | 2007-09-14 A | 2008-05-30 A | 100% | 2007-09-14 | 2008-05-30 | 186d? | finish no earlier than 2008-05-30 | R2 | 1488h | 1488h | RANimp-UplinkL2dataRates |  | Ericsson | Janne.Peisa@ericsson.com | Rel-8 | RP-37 | Yong-Jun |  | RANimp-UplinkL2dataRates | RP-080265 |  |  |
| 3987 | 1015.3 | Enhanced Uplink for CELL_FACH State in FDD | 321d? | 2007-09-14 A | 2008-12-05 A | 100% | 2007-09-14 | 2008-12-05 | 321d? | finish no earlier than 2008-12-12 | R2 | 2568h | 2568h | RANimp-UplinkEnhState |  | Nokia Siemens Networks | markus.wimmer@nsn.com | Rel-8 | RP-37 | Yong-Jun |  | RANimp-UplinkEnhState | RP-080804 |  |  |
| 3988 | 1015.4 | Enhanced UE Discontinuous Reception (DRX) for FDD | 261d? | 2007-09-14 A | 2008-09-12 A | 100% | 2007-09-14 | 2008-09-12 | 261d? | finish no earlier than 2008-09-12 | R2 | 2088h | 2088h | RANimp-DRX |  | Nokia | luis.barreto@nokia.com | Rel-8 | RP-37 | Yong-Jun |  | RANimp-DRX | RP-080520 |  |  |
| 3989 | 1015.5 | Enhancements for Serving Radio Network Subsystem (SRNS) Relocation Procedure | 261d? | 2007-09-14 A | 2008-09-12 A | 100% | 2007-09-14 | 2008-09-12 | 261d? | finish no earlier than 2008-09-12 | R3 | 2088h | 2088h | RANimp-SrnsReloc |  | Nokia Siemens Networks | masatoshi.nakamata@nsn.com | Rel-8 | RP-37 | Juha |  | RANimp-SrnsReloc | RP-080521 |  |  |
| 3990 | 1015.6 | Enhancements for FDD HSPA Evolution | 321d? | 2007-09-14 A | 2008-12-05 A | 100% | 2007-09-14 | 2008-12-05 | 321d? | finish no earlier than 2008-12-05 | R3; R2 | 5136h | 5136h | RANimp-HSPAEvo |  | Nokia Siemens Networks | masatoshi.nakamata@nsn.com | Rel-8 | RP-37 | Juha |  | RANimp-HSPAEvo | RP-080805 |  |  |
| 3991 | 1015.7 | 64QAM for 1.28 Mcps TDD HSDPA | 264d? | 2007-12-04 A | 2008-12-05 A | 100% | 2007-12-04 | 2008-12-05 | 264d? | finish no earlier than 2008-12-05 | R1 | 2112h | 2112h | RANimp-64Qam1.28TDD | PCG-21 | ZTE | zfmail@zte.com.cn | Rel-8 | RP-38 | Patrick |  | RANimp-64Qam1.28TDD | RP-080806 |  |  |
| 3992 | 1015.8 | Enhanced CELL_FACH state in 1.28 Mcps TDD | 264d? | 2007-12-04 A | 2008-12-05 A | 100% | 2007-12-04 | 2008-12-05 | 264d? | finish no earlier than 2008-12-12 | R2 | 2112h | 2112h | RANimp-EnhState1.28TDD | PCG-21 | ZTE | zhang.yincheng@zte.com.cn | Rel-8 | RP-38 | Yong-Jun |  | RANimp-EnhState1.28TDD | RP-080807 |  |  |
| 3993 | 1015.9 | Continuous Connectivity for packet data users for 1.28 Mcps TDD | 321d? | 2008-03-07 A | 2009-05-29 A | 100% | 2008-03-07 | 2009-05-29 | 321d? | finish no earlier than 2009-05-29 | R1 | 2568h | 2568h | RANimp-LCRCPC | PCG-21 | TD Tech | chenying@td-tech.com | Rel-8 | RP-39 | Patrick |  | RANimp-LCRCPC | RP-090394 |  |  |
| 3994 | 1015.10 | HSPA VoIP to WCDMA/GSM CS continuity | 261d? | 2008-03-07 A | 2009-03-06 A | 100% | 2008-03-07 | 2009-03-06 | 261d? | finish no earlier than 2009-03-06 | R2 | 2088h | 2088h | RANimp-HSPAVoIP | PCG-21 | Nokia | Simone.Provvedi@nokia.com | Rel-8 | RP-39 | Yong-Jun |  | RANimp-HSPAVoIP | RP-090050 |  |  |
| 3995 | 1015.11 | HS-DSCH Serving Cell Change Enhancements | 196d? | 2008-03-07 A | 2008-12-05 A | 100% | 2008-03-07 | 2008-12-05 | 196d? | finish no earlier than 2008-12-12 | R2 | 1568h | 1568h | RANimp-HSDSCH | PCG-21 | Ericsson | henrik.enbuske@ericsson.com | Rel-8 | RP-39 | Yong-Jun |  | RANimp-HSDSCH | RP-080811 |  |  |
| 3996 | 1015.12 | MIMO for 1.28 Mcps TDD. Linked to Rel-8 Study on Scope of future HSPA Evolution for 1.28 Mcps TDD (UID_370041) TR 25.824 | 351.6d? | 2008-01-24 A | 2009-05-29 A | 100% | 2008-01-24 | 2009-05-29 | 351.6d? | finish no earlier than 2009-05-29 | R1; R4 | 5625.6h | 5625.6h | RANimp-MIMOLCR | PCG-21 | CATT | wangke@datangmobile.cn | Rel-8 | RP-40 | Patrick |  | RANimp-MIMOLCR | RP-090313 |  |  |
| 3997 | 1015.13 | Dual-Cell HSDPA operation on adjacent carriers | 140d? | 2008-11-17 A | 2009-05-29 A | 100% | 2008-11-17 | 2009-05-29 | 140d? | finish no earlier than 2009-05-29 | R1; R4 | 2240h | 2240h | RANimp-DCHSDPA | PCG-21 | Ericsson | johan.bergman@ericsson.com | Rel-8 | RP-40 | Patrick |  | RANimp-DCHSDPA | RP-080814 |  |  |

Notes:
- 3965: SP#42 completed (WT UID_390007 moved to Rel-9)
- 3966: SP#42 completed / Impacted TSs and TRs: new 32.500
- 3967: SP#42 completed / Impacted TSs and TRs: new (32.501, 32.502, 32.503, 32.531, 32.532, 32.533)
- 3968: SP#42 completed / Impacted TSs and TRs: 32.761, 32.762, 32.763, 32.765, new 32.511
- 3969: Testing for Feature UID_20068 (LTE)
- 3970: RP#46 completed / Impacted TSs and TRs: 36.521-1, 36.521-2, 36.508, 36.509, 36.523-1, 36.523-2, 36.523-3
- 3971: RP#46 completed. RP#50 TR 36.903 v100 for Approval / Impacted TSs and TRs: 36.521-1, 36.521-2, 36.521-3, new TR 36.903
- 3972: -
- 3973: RP#37 completed / Impacted TSs and TRs: 25.101, 25.104, 25.133, 25.141, 25.331, 25.942, 25.306, 25.307, 34.121
- 3974: RP#40 completed / Impacted TSs and TRs: 25.101, 25.104, 25.133, 25.141, 25.331, 25.942, 25.306, 25.307, 34.121
- 3975: RP#43 completed / Impacted TSs and TRs: 25.102, 25.105, 25.113, 25.123, 25.142, 34.124, 25.307
- 3976: RP#41 completed. RP#47 abandoned draft 25.828 / Impacted TSs and TRs: 25.102, 25.105, 25.113, 25.123, 25.142, 34.124, 25.306, 25.331, 34.122
- 3977: RP#39 completed / Impacted TSs and TRs: 25.101
- 3978: RP#39 completed / Impacted TSs and TRs: 25.323, 25.331, 25.322
- 3979: RP#39 completed / Impacted TSs and TRs: 25.101
- 3980: RP#41 stopped / Impacted TSs and TRs: 25.101, 25.104, 25.133, 25.141, 25.331, 25.942, 25.306, 25.307, 34.121
- 3981: 05/08: Linked to Feature UID_20028 (RInImp)
- 3982: RP#41 completed / Impacted TSs and TRs: 34.108, 34.123-1, 34.123-2, 34.123-3
- 3983: RP#42 completed / Impacted TSs and TRs: 34.121-1, 34.121-2
- 3984: -
- 3985: RP#41 completed / Impacted TSs and TRs: 25.308, 25.211, 25.212, 25.213, 25.306, 25.331, 25.433, 25.435, 25.423, 25.425, 25.101, 25.104, 25.141
- 3986: RP#40 completed. Linked to UID_370037 Enhanced Uplink for CELL_FACH State in FDD / Impacted TSs and TRs: 25.319, 25.301, 25.306, 25.321, 25.331, 25.433, 25.435, 25.423, 25.425, 25.427
- 3987: RP#42 completed. Linked to UID_370036 Improved L2 for uplink / Impacted TSs and TRs: 25.309, 25.211, 25.214, 25.321, 25.331, 25.423, 25.433
- 3988: RP#41 completed. Continuation of Rel-7 work item "Continuous connectivity for packet data users" UID_20046. / Impacted TSs and TRs: 25.306, 25.308, 25.321, 25.331, 25.423
- 3989: RP#41 completed. Linked to UID_370040 Enhancements for FDD HSPA Evolution / Impacted TSs and TRs: 25.306, 25.308, 25.321, 25.331, 25.423, 25.433, 25.214, 25.133
- 3990: RP#42 completed. Triggered by Rel-7 Study on Scope of future FDD HSPA Evolution (UID_20065) TR 25.999 / Impacted TSs and TRs: 25.401, 25.413, 25.420, 25.423, 25.427, 25.433, 25.446, 25.301, 25.346
- 3991: RP#42 completed. Linked to Rel-8 Study on Scope of future HSPA Evolution for 1.28 Mcps TDD (UID_370041) TR 25.824 / Impacted TSs and TRs: 25.102, 25.105, 25.123, 25.142, 25.201, 25.221, 25.222, 25.223, 25.224, 25.306, 25.308, 25.321, 25.331, 25.423, 25.433
- 3992: RP#42 completed. Linked to Rel-8 Study on Scope of future HSPA Evolution for 1.28 Mcps TDD (UID_370041) TR 25.824 / Impacted TSs and TRs: 25.123, 25.221, 25.222, 25.224, 25.301, 25.302, 25.304, 25.306, 25.308, 25.319, 25.321, 25.331, 25.401, 25.423, 25.425, 25.433, 25.435
- 3993: RP#44 completed. Linked to Rel-8 Study on Scope of future HSPA Evolution for 1.28 Mcps TDD (UID_370041) TR 25.824 / Impacted TSs and TRs: 25.929, 25.308, 25.319
- 3994: RP#43 completed / Impacted TSs and TRs: 25.331, 25.413
- 3995: RP#42 completed / Impacted TSs and TRs: 25.101, 25.104, 25.133, 25.212, 25.214, 25.308, 25.321, 25.331, 25.423, 25.433
- 3996: RP#43 completed / Impacted TSs and TRs: 25.201, 25.221, 25.222, 25.223, 25.224, 25.306, 25.308, 25.321, 25.331, 25.423, 25.433, 25.102, 25.105, 25.142
- 3997: RP#42 completed. Triggered by UID_390032 Study on Dual-Cell HSDPA (withdrawn TR 25.825 v100). / Impacted TSs and TRs: 25.101, 25.104, 25.133, 25.141, 25.211, 25.212, 25.213, 25.214, 25.215, 25.306, 25.308, 25.321, 25.331, 25.423, 25.433

| ID | WBS | Task | Duration | Start | Finish | Complete | Baseline start | Baseline finish | Baseline duration | Constraint | Resources | Work | Actual work | Release | MCC resp | Acronym | PCG approved | WI rapporteur name | TSG approved | Status Report | Acronym_3GU_Export |
| --- | --- | --- | --- | --- | --- | --- | --- | --- | --- | --- | --- | --- | --- | --- | --- | --- | --- | --- | --- | --- | --- |
| 3998 | 1016 | **Rel-8 RAN improvements - UE Conformance Testing** | 602d? | 2008-05-30 A | 2010-09-17 A | 100% | 2008-05-30 | 2010-09-17 | 602d? |  | R5 | 29391.2h | 29391.2h | Rel-8 | Ingbert |  |  |  |  |  |  |
| 3999 | 1016.1 | Conformance Test Aspects – Combination of 64QAM and MIMO for HSDPA (FDD) | 322d? | 2008-09-12 A | 2009-12-04 A | 100% | 2008-09-12 | 2009-12-04 | 322d? | finish no earlier than 2009-12-04 | R5 | 2576h | 2576h | Rel-8 | Ingbert | RANimp-UEConTest_64QamMimoHsdpa | PCG-21 | Ericsson | RP-41 | RP-091058 | RANimp-UEConTest_64QamMimoHsdpa |
| 4000 | 1016.2 | Conformance Test Aspects – Improved L2 for uplink | 341d? | 2008-05-30 A | 2009-09-18 A | 100% | 2008-05-30 | 2009-09-18 | 341d? | finish no earlier than 2009-09-18 | R5 | 2728h | 2728h | Rel-8 | Ingbert | RANimp-UEConTest_UplinkL2dataRates | PCG-21 | Ericsson | RP-40 | RP-090712 | RANimp-UEConTest_UplinkL2dataRates |
| 4001 | 1016.3 | Conformance Test Aspects – 1.28 Mcps TDD Improved L2 support for high data rates | 342d? | 2009-05-29 A | 2010-09-17 A | 100% | 2009-05-29 | 2010-09-17 | 342d? | finish no earlier than 2010-09-17 | R5 | 2736h | 2736h | Rel-8 | Ingbert | RANimp-UEConTest_ImprovedL2LCRTDD | PCG-23 | CATT | RP-44 | RP-100737 | RANimp-UEConTest_ImprovedL2LCRTDD |
| 4002 | 1016.4 | Conformance Test Aspects – 64QAM for 1.28 Mcps TDD HSDPA | 261d? | 2008-05-30 A | 2009-05-29 A | 100% | 2008-05-30 | 2009-05-29 | 261d? | finish no earlier than 2009-05-29 | R5 | 2088h | 2088h | Rel-8 | Ingbert | RANimp-UEConTest_64Qam1.28TDD | PCG-21 | ZTE | RP-40 | RP-090415 | RANimp-UEConTest_64Qam1.28TDD |
| 4003 | 1016.5 | Conformance Test Aspects – Dual-Cell HSDPA operation on adjacent carriers | 391d? | 2008-12-05 A | 2010-06-04 A | 100% | 2008-12-05 | 2010-06-04 | 391d? | finish no earlier than 2010-06-04 | R5 | 3128h | 3128h | Rel-8 | Ingbert | RANimp-UEConTest_DCHSDPA | PCG-22 | Qualcomm | RP-42 | RP-100479 | RANimp-UEConTest_DCHSDPA |
| 4004 | 1016.6 | Conformance Test Aspects – Enhanced Uplink for CELL_FACH State in FDD | 326d? | 2009-03-06 A | 2010-06-04 A | 100% | 2009-03-06 | 2010-06-04 | 326d? | finish no earlier than 2010-06-04 | R5 | 2608h | 2608h | Rel-8 | Ingbert | RANimp-UEConTest_EnhancedRACHCellFACHState | PCG-22 | Nokia | RP-43 | RP-100483 | RANimp-UEConTest_EnhancedRACHCellFACHState |
| 4005 | 1016.7 | Conformance Test Aspects – Receiver Type3i | 196d? | 2009-03-06 A | 2009-12-04 A | 100% | 2009-03-06 | 2009-12-04 | 196d? | finish no earlier than 2009-12-04 | R5 | 1568h | 1568h | Rel-8 | Ingbert | RANimp-UEConTest_ReceiverType3i | PCG-22 | Qualcomm | RP-43 | RP-091066 | RANimp-UEConTest_ReceiverType3i |
| 4006 | 1016.8 | Conformance Test Aspects – Enhanced CELL_FACH State in LCR TDD | 341d? | 2009-05-30 A | 2010-09-17 A | 100% | 2009-05-30 | 2010-09-17 | 341d? | finish no earlier than 2010-09-17 | R5 | 2728h | 2728h | Rel-8 | Ingbert | RANimp-UEConTest_EnhancedCellFACHStateLCRTDD | PCG-23 | CATT | RP-44 | RP-100735 | RANimp-UEConTest_EnhancedCellFACHStateLCRTDD |
| 4007 | 1016.9 | Conformance Test Aspects – Continuous Connectivity for packet data users for 1.28 Mcps TDD | 261d? | 2009-09-18 A | 2010-09-17 A | 100% | 2009-09-18 | 2010-09-17 | 261d? | finish no earlier than 2010-09-17 | R5 | 2088h | 2088h | Rel-8 | Ingbert | RANimp-UEConTest_CPCLCRTDD | PCG-23 | ZTE | RP-45 | RP-100739 | RANimp-UEConTest_CPCLCRTDD |
| 4008 | 1016.10 | Conformance Test Aspects – MIMO for 1.28 Mcps TDD | 186d? | 2009-09-18 A | 2010-06-04 A | 100% | 2009-09-18 | 2010-06-04 | 186d? | finish no earlier than 2010-06-04 | R5 | 1488h | 1488h | Rel-8 | Ingbert | RANimp-UEConTest_MIMOLCRTDD | PCG-23 | ZTE | RP-45 | RP-100660 | RANimp-UEConTest_MIMOLCRTDD |
| 4009 | 1016.11 | Conformance Test Aspects – HS-DSCH Serving Cell Change Enhancements | 131d? | 2009-09-18 A | 2010-03-19 A | 100% | 2009-09-18 | 2010-03-19 | 131d? | finish no earlier than 2010-03-12 | R5 | 1048h | 1048h | Rel-8 | Ingbert | HSDSCH_UEConTest | PCG-23 | Qualcomm | RP-45 | RP-100077 | HSDSCH_UEConTest |
| 4010 | 1017 | 3.84 Mcps TDD MBMS over a Single Frequency Network (MBSFN) Integrated Mobile Broadcast | 395d? | 2007-06-04 A | 2008-12-05 A | 100% | 2007-06-04 | 2008-12-05 | 395d? |  | R1 | 3160h | 3160h | Rel-8 | Patrick | MBSFN-DOB |  | Ericsson |  | RP-080218 | MBSFN-DOB |
| 4011 | 1018 | Conformance Test Aspects – 3.84 Mcps TDD MBMS over a Single Frequency Network (MBSFN) Integrated Mobile Broadcast | 211d? | 2009-05-30 A | 2010-03-19 A | 100% | 2009-05-30 | 2010-03-19 | 211d? | finish no earlier than 2010-03-19 | R5 | 1688h | 1688h | Rel-8 | Ingbert | MBSFN_IMB_UEConTest | PCG-23 | IPwireless | RP-44 | RP-100070 | MBSFN_IMB_UEConTest |
| 4012 | 1019 | **GERAN support for GERAN - 3G Long Term Evolution interworking** | 1365d? | 2006-09-08 A | 2011-11-25 A | 100% | 2006-09-08 | 2011-11-25 | 1365d? |  | GP; G1; C1; G3new | 69960h | 69960h | Rel-8 | Paolo | GELTE |  | Nokia, Nokia Siemens Networks |  |  | GELTE |
| 4013 | 1019.1 | G1 part of GERAN support for GERAN - 3G Long Term Evolution interworking | 641d? | 2006-09-08 A | 2009-02-20 A | 100% | 2006-09-08 | 2009-02-20 | 641d? | finish no earlier than 2009-02-20 | G1 | 5128h | 5128h | Rel-8 | Paolo | GELTE |  | Nokia, Nokia Siemens Networks |  |  |  |
| 4014 | 1019.2 | G2 part of GERAN support for GERAN - 3G Long Term Evolution interworking | 641d? | 2006-09-08 A | 2009-02-20 A | 100% | 2006-09-08 | 2009-02-20 | 641d? | finish no earlier than 2009-02-20 | G2 | 5128h | 5128h | Rel-8 | Paolo | GELTE |  | Nokia, Nokia Siemens Networks |  |  |  |
| 4015 | 1019.3 | CT1 part of GERAN support for GERAN - 3G Long Term Evolution interworking | 641d? | 2006-09-08 A | 2009-02-20 A | 100% | 2006-09-08 | 2009-02-20 | 641d? | finish no earlier than 2009-02-20 | C1 | 5128h | 5128h | Rel-8 | Paolo | GELTE |  | Nokia, Nokia Siemens Networks |  |  |  |
| 4016 | 1019.4 | Testing for GERAN support for GERAN - 3G Long Term Evolution interworking | 1363d? | 2006-09-08 A | 2011-11-25 A | 100% | 2006-09-08 | 2011-11-25 | 1363d? | finish no earlier than 2011-11-25 | G3new | 10896h | 10896h | Rel-8 | Ingbert | GELTE |  | Renesas Mobile |  |  |  |
| 4017 | 1020 | U-TDOA Enhancement | 131d? | 2007-05-18 A | 2007-11-16 A | 100% | 2007-05-18 | 2007-11-16 | 131d? | finish no earlier than 2007-05-18 | GP | 1048h | 1048h | Rel-8 | Paolo | GUTEN |  | TruePosition |  |  | GUTEN |
| 4018 | 1021 | **GAN Enhancements** | 604.2d? | 2007-05-15 A | 2009-09-04 A | 100% | 2007-05-15 | 2009-09-04 | 604.2d? |  | GP | 9432h | 9432h | Rel-8 | Paolo | GANENH |  | T-Mobile |  |  | GANENH |
| 4019 | 1021.1 | Update to GAN specifications | 126d? | 2007-08-31 A | 2008-02-22 A | 100% | 2007-08-31 | 2008-02-22 | 126d? | finish no earlier than 2008-02-22 | GP | 1008h | 1008h | Rel-8 | Paolo | GANENH-SPEC |  | T-Mobile |  |  | GANENH-SPEC |
| 4020 | 1021.2 | Update TS 51.010 Mobile Station (MS) Conformance Specification for GAN Enhancements | 526d? | 2007-05-15 A | 2009-09-04 A | 100% | 2007-05-15 | 2009-09-04 | 526d? | finish no earlier than 2009-09-04 | G3new | 4208h | 4208h | Rel-8 | Ingbert | GANENH-MStest |  | T-Mobile |  |  | GANENH-MStest |
| 4021 | 1022 | **AoIP (A-interface over IP)** | 2335d? | 2000-01-03 A | 2008-12-11 A | 100% | 2000-01-03 | 2008-12-11 | 2335d? |  | GP; S4; C4; C1; C3 | 119396h | 119396h | Rel-8 | Paolo | AoIP | PCG-21 | China Mobile, Ericsson |  |  | AoIP |
| 4022 | 1022.1 | GERAN aspects of AoIP | 2321d? | 2000-01-03 A | 2008-11-21 A | 100% | 2000-01-03 | 2008-11-21 | 2321d? | finish no earlier than 2008-11-21 | GP | 18560h | 18560h | Rel-8 | Paolo | AoIP | PCG-21 | China Mobile, Ericsson | SP-40 |  |  |
| 4023 | 1022.2 | Media Requirements for CS over IP based User Plane | 267d? | 2007-12-05 A | 2008-12-11 A | 100% | 2007-12-05 | 2008-12-11 | 267d? | finish no earlier than 2008-12-11 | S4 | 1996.09h | 1996.09h | Rel-8 | Paolo | AoIP-CSoIP | PCG-21 | China Mobile, Ericsson | SP-40 |  | AoIP-CSoIP |

Notes:
- 3998: Linked to Feature UID_20029 (RANimp)
- 3999: RP#46 completed. Testing for UID_360013 / Impacted TSs and TRs: 34.108, 34.121-1, 34.121-2, 34.123-1, 34.123-2 / WI rapporteur e-mail: leif.mattisson@ericsson.com
- 4000: RP#45 completed. Testing for UID_370036 / Impacted TSs and TRs: 34.108, 34.123-1, 34.123-2, 34.123-3 / WI rapporteur e-mail: leif.mattisson@ericsson.com
- 4001: RP#49 completed. Testing for Rel-7 UID_340039 Improved L2 support for high data rates and Rel-8 UID_370036 Improved L2 for uplink / Impacted TSs and TRs: 34.108, 34.123-1, 34.123-2, 34.123-3 / WI rapporteur e-mail: Xiaozhong Chen (chenxiaozhong@datangmobile.cn)
- 4002: RP#44 completed. Testing for UID_380075 / Impacted TSs and TRs: 34.108, 34.122, 34.123-1, 34.123-2, 34.123-3 / WI rapporteur e-mail: ma.zijiang@zte.com.cn
- 4003: RP#48 completed. Testing for UID_400052 / Impacted TSs and TRs: 34.108, 34.121-1, 34.121-2, 34.123-1, 34.123-2, 34.123-3 / WI rapporteur e-mail: Shubhang Vora (svora@qualcomm.com)
- 4004: RP#48 completed. Testing for UID_370037 / Impacted TSs and TRs: 34.108, 34.121-1, 34.121-2, 34.123-1, 34.123-2, 34.123-3 / WI rapporteur e-mail: jarkko.hellsten@nokia.com
- 4005: RP#46 completed. Testing for Receiver Type3i in 25.101 UE radio Tx and Rx FDD / Impacted TSs and TRs: 34.108, 34.121-1, 34.121-2 / WI rapporteur e-mail: Ashok Kumar Narayanaswamy (anarayan@qualcomm.com)
- 4006: RP#49 completed. Testing for UID_380076 / Impacted TSs and TRs: 34.108, 34.123-1, 34.123-2, 34.123-3 / WI rapporteur e-mail: Xiaozhong Chen (chenxiaozhong@datangmobile.cn)
- 4007: RP#49 completed. Testing for UID_390028 / Impacted TSs and TRs: 34.108, 34.123-1, 34.123-2, 34.123-3 / WI rapporteur e-mail: huang.he4@zte.com.cn
- 4008: PR#48 completed. Testing for UID_400050 / Impacted TSs and TRs: 34.108, 34.122, 34.123-1, 34.123-2, 34.123-3 / WI rapporteur e-mail: huang.chun2@zte.com.cn
- 4009: RP#47 completed. Testing for UID_390030 / Impacted TSs and TRs: 34.108, 34.121-1, 34.121-2, 34.123-1, 34.123-2, 34.123-3 / WI rapporteur e-mail: Shubhang Vora (svora@qualcomm.com)
- 4010: RP#42 completed. WID updated RP-070493=>RP-081124 (changed WI title "MBSFN Downlink Optimized Broadcast (DOB) 3.84 Mcps TDD" => "3.84Mcps TDD MBSFN Integrated Mobile Broadcast"). / Impacted TSs and TRs: 25.102, 25.105, 25.123, 25.201, 25.221, 25.222, 25.223, 25.224, 25.304, 25.306, 25.331, 25.346, 25.402, 25.433 / WI rapporteur e-mail: Lars.Lindbom@ericsson.com
- 4011: RP#47 completed. Testing for Rel-8 MBSFN-DOB UID_360008 / Impacted TSs and TRs: 34.108, 34.122, 34.123-1, 34.123-2, 34.123-3 / WI rapporteur e-mail: Phil Young (pyoung@ipwireless.com)
- 4012: GP#41 completed. GP#52 completed MS conformance testing / Impacted TSs and TRs: 44.018, 44.060, 45.002, 45.008, 45.010, 48.008, 48.018, 51.010 / WI rapporteur e-mail: sergio.parolari@nsn.com, vlora.rexhepi@nokia.com
- 4013: GP#41 completed / Impacted TSs and TRs: 43.055, 43.129, 43.246, 45.002, 45.008, 45.010 / WI rapporteur e-mail: sergio.parolari@nsn.com, vlora.rexhepi@nokia.com
- 4014: GP#41 completed / Impacted TSs and TRs: 44.018, 44.060, 48.008, 48.018 / WI rapporteur e-mail: sergio.parolari@nsn.com, vlora.rexhepi@nokia.com
- 4015: - / Impacted TSs and TRs: 24.008 / WI rapporteur e-mail: sergio.parolari@nsn.com, vlora.rexhepi@nokia.com
- 4016: GP#52 completed / Impacted TSs and TRs: 51.010 / WI rapporteur e-mail: deepa.kamath@renesasmobile.com
- 4017: GP#36 completed U-TDOA (Uplink Time Difference of Arrival) / Impacted TSs and TRs: 43.059, 45.008, 48.071 / WI rapporteur e-mail: Terry Brooks (terri.brooks@trueposition.com)
- 4018: GP#37 completed. GP#43 completed Testing / WI rapporteur e-mail: mohammed.versi@t-mobile.com
- 4019: GP#37 completed / Impacted TSs and TRs: 43.318, 44.318 / WI rapporteur e-mail: mohammed.versi@t-mobile.com
- 4020: GP#43 completed / Impacted TSs and TRs: 51.010 / WI rapporteur e-mail: mohammed.versi@t-mobile.com
- 4021: GP#40/TSG#42 completed . Triggered by TR 43.903 Study on A-interface over IP (AINTIP) UID_50589. / WI rapporteur e-mail: wangshuaiyu@chinamobile.com, paul.schliwa-bertling@ericsson.com
- 4022: GP#40 completed. GP#39 updated WID GP-080901=>GP-081362. / Impacted TSs and TRs: 48.001, 48.002, 48.008, 48.020, 49.008, 48.103 / WI rapporteur e-mail: wangshuaiyu@chinamobile.com, paul.schliwa-bertling@ericsson.com
- 4023: SP#42 completed / Impacted TSs and TRs: 26.102, 26.103, 26.202 / WI rapporteur e-mail: Karl.Hellwig@Ericsson.com

| ID | WBS | Task | Type | Duration | Start | Finish | Complete | Baseline start | Baseline finish | Baseline duration | Constraint | Resources | Work | Actual work | Acronym | PCG approved | WI rapporteur name | Release | TSG approved | MCC resp | Acronym_3GU_Export | Impacted TSs and TRs | Status Report | TSG stopped | Special Focus Doc | PCG stopped |
| --- | --- | --- | --- | --- | --- | --- | --- | --- | --- | --- | --- | --- | --- | --- | --- | --- | --- | --- | --- | --- | --- | --- | --- | --- | --- | --- |
| 4024 | 1022.3 | **Core Network Impacts for A-Interface User Plane over IP** |  | 136d? | 2008-05-30 A | 2008-12-05 A | 100% | 2008-05-30 | 2008-12-05 | 136d? |  | C4; C1; C3 | 5440h | 5440h | AoIP-CN | PCG-21 | Ericsson | Rel-8 | CP-40 | Kimmo | AoIP-CN |  |  |  |  |  |
| 4025 | 1022.3.1 | CT4 part of Core Network Impacts for A-Interface User Plane over IP |  | 136d? | 2008-05-30 A | 2008-12-05 A | 100% | 2008-05-30 | 2008-12-05 | 136d? | start no earlier than 2008-05-30 | C4 | 1088h | 1088h | AoIP-CN | PCG-21 | Ericsson | Rel-8 | CP-40 | Kimmo |  | 23.205, 23.153, 23.231, 29.232 |  |  |  |  |
| 4026 | 1022.3.2 | CT1 part of Core Network Impacts for A-Interface User Plane over IP |  | 68d? | 2008-05-30 A | 2008-12-05 A | 100% | 2008-05-30 | 2008-12-05 | 68d? | finish no earlier than 2008-12-05 | C1 | 544h | 544h | AoIP-CN | PCG-21 | Ericsson | Rel-8 | CP-40 | Frederic |  | 23.009 |  |  |  |  |
| 4027 | 1022.3.3 | CT3 part of Core Network Impacts for A-Interface User Plane over IP |  | 68d? | 2008-05-30 A | 2008-12-05 A | 100% | 2008-05-30 | 2008-12-05 | 68d? | finish no earlier than 2008-12-05 | C3 | 544h | 544h | AoIP-CN | PCG-21 | Ericsson | Rel-8 | CP-40 | Adrian |  | 29.007 |  |  |  |  |
| 4028 | 1023 | New multicarrier BTS class |  | 261d? | 2007-08-31 A | 2008-08-29 A | 100% | 2007-08-31 | 2008-08-29 | 261d? | finish no earlier than 2008-08-29 | G1 | 2088h | 2088h | MCBTS |  | Alcatel-Lucent | Rel-8 |  | Paolo | MCBTS | 45.005, 45.050, 51.021 |  |  |  |  |
| 4029 | 1024 | **Support for Additional Navigation Satellite Systems (ANSS) for LCS** |  | 150d? | 2008-05-16 A | 2008-12-11 A | 100% | 2008-05-16 | 2008-12-11 | 150d? |  | S1; G2; R2 | 5784h | 5784h | ANSS |  | Qualcomm | Rel-8 |  | Paolo | ANSS |  |  |  |  |  |
| 4030 | 1024.1 | Stage 1 for ANSS for LCS |  | 1d? | 2008-12-11 A | 2008-12-11 A | 100% | 2008-12-11 | 2008-12-11 | 1d? | start no earlier than 2008-12-11 | S1 | 8h | 8h | ANSS | PCG-22 |  | Rel-8 | SP-42 | Alain |  | 22.071 |  |  |  |  |
| 4031 | 1024.2 | GERAN2 part of Support for Additional Navigation Satellite Systems (ANSS) for LCS |  | 136d? | 2008-05-16 A | 2008-11-21 A | 100% | 2008-05-16 | 2008-11-21 | 136d? | start no earlier than 2008-05-16 | G2 | 1088h | 1088h | ANSS |  | Qualcomm | Rel-8 |  | Paolo |  | 43.059, 44.031, 49.031, 44.071, 48.031, 51.010 |  |  |  |  |
| 4032 | 1024.3 | RAN2 part of Support for Additional Navigation Satellite Systems (ANSS) for LCS |  | 136d? | 2008-05-30 A | 2008-12-05 A | 100% | 2008-05-30 | 2008-12-05 | 136d? | finish no earlier than 2008-12-08 | R2 | 1088h | 1088h | RANimp-ANSS | PCG-21 | Qualcomm | Rel-8 | RP-40 | Yong-Jun | RANimp-ANSS | 25.305, 25.306, 25.331, 25.413, 25.423, 25.433, 25.453 | RP-080813 |  |  |  |
| 4033 | 1025 | **Conformance testing for the Latency Reductions feature** |  | 532d? | 2008-02-22 A | 2010-03-05 A | 100% | 2008-02-22 | 2010-03-05 | 532d? |  | G1; G3new | 14848h | 14848h | CTLATRED | PCG-21 | Ericsson | Rel-8 |  | Paolo | CTLATRED |  |  |  |  |  |
| 4034 | 1025.1 | MS conformance testing for the Latency Reductions feature |  | 532d? | 2008-02-22 A | 2010-03-05 A | 100% | 2008-02-22 | 2010-03-05 | 532d? | finish no earlier than 2010-03-05 | G3new | 4248h | 4248h | CTLATRED-MStest | PCG-21 | Ericsson | Rel-8 |  | Ingbert | CTLATRED-MStest | 51.010 |  |  |  |  |
| 4035 | 1025.2 | BTS conformance testing for the Latency Reductions feature |  | 261d? | 2008-02-22 A | 2009-02-20 A | 100% | 2008-02-22 | 2009-02-20 | 261d? | finish no earlier than 2009-02-20 | G1 | 2088h | 2088h | CTLATRED-BTStest | PCG-21 | Ericsson | Rel-8 |  | Paolo | CTLATRED-BTStest | 51.021 |  |  |  |  |
| 4036 | 1026 | MS conformance testing of changes introduced by WI "Support of Packet-switched Handover for GERAN A/Gb mode" |  | 196d? | 2008-02-22 A | 2008-11-21 A | 100% | 2008-02-22 | 2008-11-21 | 196d? | finish no earlier than 2008-11-21 | G3new | 1568h | 1568h | PSHCT-MStest | PCG-21 | Rohde & Schwarz | Rel-8 |  | Ingbert | PSHCT-MStest | 51.010 |  |  |  |  |
| 4037 | 1027 | (Small) Technical Enhancements and Improvements for Rel-8 |  | 509d? | 2007-01-01 A | 2008-12-11 A | 100% | 2007-01-01 | 2008-12-11 | 509d? | finish no earlier than 2008-12-11 | SP; CP; RP; GP | 16288h | 16288h | TEI8 |  |  | Rel-8 |  | All | TEI8 |  |  |  |  |  |
| 4038 | 1028 | (IETF) (Small) Technical Enhancements and Improvements for Rel-8 |  | 650d? | 2007-01-01 A | 2012-09-07 A | 100% | 2007-01-01 | 2012-09-07 | 650d? | finish no earlier than 2012-09-07 | C1-IETF | 5200h | 5200h | TEI8_IETF | PCG-27 | christer.holmberg@ericsson.com | Rel-8 | CP-52 | Frederic | TEI8_IETF | RFC 6714 (was draft-ietf-simple-msrp-cema) |  |  |  |  |
| 4039 | 1029 | Test - (Small) Technical Enhancements and Improvements for Rel-8 |  | 993.6d? | 2007-03-07 A | 2010-12-24 A | 100% | 2007-03-07 | 2010-12-24 | 993.6d? | finish no earlier than 2010-12-24 | R5; G3new | 15897.6h | 15897.6h | TEI8_Test | PCG-21 |  | Rel-8 | RP-40 | Ingbert | TEI8_Test |  |  |  |  |  |
| 4040 | 1030 | **Deleted - All-IP Network** |  | 448d? | 2004-06-28 A | 2006-03-15 A | 100% | 2004-06-28 | 2006-03-15 | 448d? |  | S1 | 7168h | 7168h | AIPN |  | NTT DoCoMo | Rel-8 |  | Alain | AIPN |  |  | SP-38 |  |  |
| 4041 | 1030.1 | Deleted - Stage 1 |  | 448d? | 2004-06-28 A | 2006-03-15 A | 100% | 2004-06-28 | 2006-03-15 | 448d? | finish no earlier than 2006-03-15 | S1 | 3584h | 3584h | AIPN |  | NTT DoCoMo | Rel-8 |  | Alain |  | 22.258 |  | SP-38 |  |  |
| 4042 | 1031 | Deleted - was Rel-7 - LCS for 3GPP Interworking WLAN | milestone | 0d? | 2007-09-28 A | 2007-09-28 A | 100% | 2007-09-28 | 2007-09-28 | 0d? | start no earlier than 2007-09-28 | S2 |  |  | LCS4_IWLAN |  | LG Electronics | Rel-8 | TSG-34 | Maurice | LCS4_IWLAN | 23.234, 23.271, 23.167 |  | SP-35 | WLAN |  |
| 4043 | 1032 | Deleted - never approved- FBI Phase 2 | milestone | 0d | 2007-09-28 A | 2007-09-28 A | 100% | 2007-09-28 | 2007-09-28 | 0d | start no earlier than 2007-09-28 | S2 |  |  | FBI2 |  | Nokia Siemens Networks | Rel-8 |  | Maurice | FBI2 |  |  | SP-38 |  |  |
| 4044 | 1033 | Deleted -Enhancements to BS30 Bearer service for Videotelephony | milestone | 0d? | 2007-03-15 A | 2007-03-15 A | 100% | 2007-03-15 | 2007-03-15 | 0d? | finish no earlier than 2007-03-15 | S1 |  |  | BS30 |  |  | Rel-8 |  | Alain | BS30 | 22.002, 22.004, 22.101, 22.105, 24.008 |  | SP-38 |  |  |
| 4045 | 1034 | Deleted - IMS Enhancements Rel-8 |  | 75d? | 2007-09-03 A | 2007-12-14 A | 100% | 2007-09-03 | 2007-12-14 | 75d? |  | S1 | 600h | 600h | IMS8 |  | Telecom Italia | Rel-8 | SP-37 | Alain | IMS8 |  |  | SP-38 |  |  |
| 4046 | 1035 | **Deleted - Contact Manager Conformance Test specifications** |  | 471d? | 2008-06-02 A | 2010-03-19 A | 100% | 2008-06-02 | 2010-03-19 | 471d? |  | C6 | 11304h | 11304h | eUPHBOOK-Test | PCG-21 | Comprion, Gemalto | Rel-8 | CP-40 | Xavier | eUPHBOOK-Test |  |  | CP-47 |  | PCG-24 |
| 4047 | 1035.1 | Deleted - Contact Manager for 3GPP UICC applications test specifications |  | 471d? | 2008-06-02 A | 2010-03-19 A | 100% | 2008-06-02 | 2010-03-19 | 471d? | finish no earlier than 2010-03-19 | C6 | 3768h | 3768h | eUPHBOOK-Test | PCG-21 | Comprion | Rel-8 | CP-40 | Xavier |  | 31.320 (external interface for communication with the ME) |  | CP-47 |  | PCG-24 |
| 4048 | 1035.2 | Deleted - Contact Manager API for Java™ Card test specification |  | 471d? | 2008-06-02 A | 2010-03-19 A | 100% | 2008-06-02 | 2010-03-19 | 471d? | finish no earlier than 2010-03-19 | C6 | 3768h | 3768h | eUPHBOOK-Test | PCG-21 | Gemalto | Rel-8 | CP-40 | Xavier |  | 31.321 (internal interface (API)) |  | CP-47 |  | PCG-24 |
| 4049 | 1036 | Deleted - MS conformance testing of Support of Conversational Services in A/Gb mode via the PS domain |  | 401d? | 2008-02-25 A | 2009-09-04 A | 100% | 2008-02-25 | 2009-09-04 | 401d? | finish no earlier than 2009-09-04 | G3new | 3208h | 3208h | SCSAGBCT-MStest | PCG-21 | Nokia | Rel-8 |  | Ingbert | SCSAGBCT-MStest | 51.010 |  | GP-43 |  | PCG-23 |
| 4050 | 1037 | Release 8 Studies | milestone | 0d? | 2005-10-07 A | 2005-10-07 A | 100% | 2005-10-07 | 2010-11-12 | 1332d? | start no earlier than 2000-01-03 | CP; GP; RP; SP |  |  |  |  |  | Rel-8 |  | All |  |  |  |  |  |  |
| 4051 | 1038 | Study on Customised Alerting Tone (CAT) Requirements |  | 245d? | 2005-10-07 A | 2006-09-14 A | 100% | 2005-10-07 | 2006-09-14 | 245d? | start no earlier than 2005-10-07 | S1 | 1960h | 1960h | FS_CAT |  | China Mobile | Rel-8 |  | Alain | FS_CAT | 22.982 |  |  |  |  |
| 4052 | 1039 | Study on Facilitating Machine to Machine Communication in GSM and UMTS (M2M) |  | 350d? | 2005-11-04 A | 2007-03-08 A | 100% | 2005-11-04 | 2007-03-08 | 350d? | finish no earlier than 2006-06-16 | S1 | 2800h | 2800h | FS_M2M |  | Siemens | Rel-8 |  | Alain | FS_M2M | 22.868 |  |  | MTC, M2M |  |
| 4053 | 1040 | Study on Network Composition |  | 526d? | 2005-12-07 A | 2007-12-12 A | 100% | 2005-12-07 | 2007-12-12 | 526d? | finish no earlier than 2006-09-27 | S1 | 4208h | 4208h | FS_NetComp |  | Nokia Siemens Networks | Rel-8 |  | Alain | FS_NetComp | 22.980 |  |  |  |  |
| 4054 | 1041 | Study on Requirements of IMS Multimedia Conferencing |  | 330d? | 2006-06-08 A | 2007-09-12 A | 100% | 2006-06-08 | 2007-09-12 | 330d? | finish no earlier than 2007-03-21 | S1 | 2640h | 2640h | FS_IMSconf |  | China Mobile | Rel-8 |  | Alain | FS_IMSconf | 22.948 |  |  |  |  |
| 4055 | 1042 | Study on support of a Public Warning System |  | 140d? | 2007-09-03 A | 2008-03-14 A | 100% | 2007-09-03 | 2008-03-14 | 140d? |  | S1 | 1120h | 1120h | FS_PWS |  | T-Mobile | Rel-8 |  | Alain | FS_PWS | 22.968 |  |  | Public Safety (I-A) |  |
| 4056 | 1043 | Study on Paging Permission with Access Control |  | 256d? | 2006-09-28 A | 2007-09-20 A | 100% | 2006-09-28 | 2007-09-20 | 256d? | finish no earlier than 2007-09-20 | S1 | 2048h | 2048h | FS_PPAC |  | NTT DoCoMo | Rel-8 |  | Alain | FS_PPAC | 22.908 |  |  |  |  |
| 4057 | 1044 | Study on Non-3GPP access Network Selection Principles (NSP) |  | 392d? | 2006-12-06 A | 2008-06-05 A | 100% | 2006-12-06 | 2008-06-05 | 392d? | finish no earlier than 2007-11-19 | S1 | 3136h | 3136h | FS_N3GtoNSP |  | Telefónica O2 | Rel-8 | TSG-34 | Alain | FS_N3GtoNSP | 22.912 |  |  |  |  |
| 4058 | 1045 | Study on Value Added Services for Short Message Service |  | 263d? | 2006-12-06 A | 2007-12-07 A | 100% | 2006-12-06 | 2007-12-07 | 263d? | finish no earlier than 2007-12-07 | S1 | 2104h | 2104h | FS_VAS4SMS |  | China Mobile | Rel-8 | TSG-34 | Alain | FS_VAS4SMS | 22.942 |  |  |  |  |
| 4059 | 1046 | Study on Service continuity between mobile and WLAN networks |  | 262d? | 2006-12-06 A | 2007-12-06 A | 100% | 2006-12-06 | 2007-12-06 | 262d? | finish no earlier than 2008-12-25 | S1 | 2096h | 2096h | FS_SMLSWLAN |  | NEC | Rel-8 | TSG-34 | Alain | FS_SMLSWLAN | 22.937 |  |  | WLAN |  |
| 4060 | 1047 | Study on Services Alignment and Migration |  | 331d? | 2006-12-06 A | 2008-03-12 A | 100% | 2006-12-06 | 2008-03-12 | 331d? | finish no earlier than 2007-09-20 | S1 | 2648h | 2648h | FS_ServAl |  | Telefónica O2 | Rel-8 | SP-37 | Alain | FS_ServAl | 22.983 |  |  |  |  |

Notes:
- 4024: CP#42 completed. Updated WID CP-080278=>CP-080722 / WI rapporteur e-mail: philip.hodges@ericsson.com
- 4025: CP#42 completed. Updated WID CP-080278=>CP-080722 / WI rapporteur e-mail: philip.hodges@ericsson.com
- 4026: CP#42 completed. Updated WID CP-080278=>CP-080722 / WI rapporteur e-mail: philip.hodges@ericsson.com
- 4027: CP#42 completed. Updated WID CP-080278=>CP-080722 / WI rapporteur e-mail: philip.hodges@ericsson.com
- 4028: GP#39 completed / WI rapporteur e-mail: thomas.bitzer@alcatel-lucent.de
- 4029: GP#40 completed / WI rapporteur e-mail: Mungal Dhanda
- 4030: SP#42 completed by 22.071 CR0077
- 4031: GP#40 completed / WI rapporteur e-mail: Mungal Dhanda
- 4032: RP#42 WI closed at 95%. Considers Rel-9 performance requirements / WI rapporteur e-mail: Etienne Chaponniere (echaponn@qualcomm.com)
- 4033: GP#45 completed / WI rapporteur e-mail: mats.y.samuelsson@ericsson.com, hakan.e.grunditz@ericsson.com
- 4034: GP#45 completed / WI rapporteur e-mail: hakan.e.grunditz@ericsson.com
- 4035: GP#41 completed / WI rapporteur e-mail: mats.y.samuelsson@ericsson.com
- 4036: GP#40 completed / WI rapporteur e-mail: Franz.Segerer@ROHDE-SCHWARZ.COM
- 4037: SP#42 completed
- 4038: CP#57 completed / WI rapporteur e-mail: christer.holmberg@ericsson.com
- 4039: -
- 4040: SP#38 stopped. 25/07/08 Moved UID_31059 Study on All-IP Network (FS_AIPN/was AIPFS) to Rel-7 out of the stopped Rel-8 Feature UID_31067 Deleted - All-IP Network (AIPN) / WI rapporteur e-mail: c.masyu@nttdocomo.co.jp
- 4041: 22.258 withdrawn, superseded by 22.278 (UID 320022). SP#38 stopped / WI rapporteur e-mail: c.masyu@nttdocomo.co.jp
- 4042: SP#35 stopped / WI rapporteur e-mail: dhshim@lge.com
- 4043: SP#38 stopped
- 4044: SP#38 stopped (no support) / WI rapporteur e-mail: andre.jarvis@three.co.uk
- 4045: SP#38 stopped
- 4046: CP#47 work stopped/abandoned / WI rapporteur e-mail: Udo Willenbrink, Jacques Seif
- 4047: CP#47 work stopped/abandoned / WI rapporteur e-mail: Udo Willenbrink (uwillenbrink@comprion.com )
- 4048: CP#47 work stopped/abandoned / WI rapporteur e-mail: jacques.seif@gemalto.com
- 4049: GP#43 work stopped/abandoned (completion 0%) / WI rapporteur e-mail: arsi.heino@nokia.com
- 4050: -
- 4051: Spin-off Rel-8 Feature Customized Alerting Tone (CAT) Service UID_340029 / WI rapporteur e-mail: Qing Huang (huangqing@chinamobile.com)
- 4052: SP#35 completed. Spin-off SA3 Study on Security Aspects of Remote Provisioning and Change of Subscription for M2M (UID_370053). SP#40 Spin-off new Feature UID_410030 (NIMTC) / WI rapporteur e-mail: Juergen Merkel
- 4053: SP#38 completed / WI rapporteur e-mail: joerg.swetina@neclab.eu
- 4054: SP#37 completed. Spin-off New Feature UID_370026 Value-Added Services for Short Message Service (VAS4SMS) / WI rapporteur e-mail: Qing Huang (huangqing@chinamobile.com)
- 4055: SP#39 completed. Spin-off Rel-9 Feature UID_380057 (PWS) / WI rapporteur e-mail: mark.younge@t-mobile.com
- 4056: SP#37 completed. Spin-off new Feature UID_370084 (PPACR) / WI rapporteur e-mail: Katsuhiro NOGUCHI (noguchi@nttdocomo.co.jp)
- 4057: SP#38 completed. Spin-off New Feature UID_380062 (N3GTONSP). SP#40 WID updated SP-060930=>SP-080318. TR re-approved with new # 22.812=>22.912 / WI rapporteur e-mail: chris.friel@O2.com
- 4058: SP#38 completed. Spin-off New Feature UID_370026 (VAS4SM) / WI rapporteur e-mail: Qing Huang (huangqing@chinamobile.com)
- 4059: SP#38 completed / WI rapporteur e-mail: joerg.swetina@neclab.eu
- 4060: SP#39 completed. Spin-off Rel-9 Feature UID_330017 Services Alignment and Migration (ServAl) / WI rapporteur e-mail: chris.friel@O2.com

| ID | WBS | Task | Duration | Start | Finish | Complete | Baseline start | Baseline finish | Baseline duration | Constraint | Resources | Work | Actual work | Acronym | WI rapporteur name | WI rapporteur e-mail | Release | MCC resp | Acronym_3GU_Export | Impacted TSs and TRs | PCG approved | TSG approved | Special Focus Doc | Status Report | PCG stopped | TSG stopped |
| --- | --- | --- | --- | --- | --- | --- | --- | --- | --- | --- | --- | --- | --- | --- | --- | --- | --- | --- | --- | --- | --- | --- | --- | --- | --- | --- |
| 4061 | 1048 | **Study on 3GPP System Architecture Evolution** | 1115d? | 2004-12-03 A | 2009-03-12 A | 100% | 2004-12-03 | 2009-03-12 | 1115d? |  | S2; S3 | 34064h | 34064h | FS_SAE | Vodafone | chris.pudney@vodafone.com | Rel-8 | Maurice | FS_SAE |  |  |  |  |  |  |  |
| 4062 | 1048.1 | Stage 2 Interim conclusion for RAN Work to start | 990d? | 2004-12-03 A | 2008-09-18 A | 100% | 2004-12-03 | 2008-09-18 | 990d? | finish no earlier than 2005-09-23 | S2 | 7920h | 7920h | FS_SAE | Vodafone | chris.pudney@vodafone.com | Rel-8 | Maurice |  | 23.882 |  |  |  |  |  |  |
| 4063 | 1048.2 | Stage 2 study on 3GPP architectural development | 704d? | 2006-01-09 A | 2008-09-18 A | 100% | 2006-01-09 | 2008-09-18 | 704d? | finish no earlier than 2007-09-28 | S2 | 5632h | 5632h | FS_SAE | Vodafone | chris.pudney@vodafone.com | Rel-8 | Maurice |  | 23.882 |  |  |  |  |  |  |
| 4064 | 1048.3 | Security study for Inter-access mobility between non-3GPP and 3GPP system | 334d? | 2007-09-03 A | 2009-03-12 A | 100% | 2007-09-03 | 2009-03-12 | 334d? | finish no earlier than 2009-03-12 | S3 | 2672h | 2672h | FS_SAE | Nokia | dajiang.zhang@nokia.com | Rel-8 | Mirko |  | 33.821, 33.822 |  |  |  |  |  |  |
| 4065 | 1049 | Study on Stage 2 aspects of IMS Service Brokering | 589d? | 2006-06-19 A | 2008-09-18 A | 100% | 2006-06-19 | 2008-09-18 | 589d? | finish no earlier than 2008-09-18 | S2 | 4712h | 4712h | FS_ISB_ST2 | Telcordia | raquel@research.telcordia.com | Rel-8 | Maurice | FS_ISB_ST2 | 23.810 |  |  |  |  |  |  |
| 4066 | 1050 | Study on IMS utilizing multicast bearer services | 447d? | 2006-03-22 A | 2007-12-06 A | 100% | 2006-03-22 | 2007-12-06 | 447d? | finish no earlier than 2007-12-03 | S2 | 3576h | 3576h | FS_MLTICAST-IMS | Nokia Siemens Networks |  | Rel-8 | Maurice | FS_MLTICAST-IMS | 23.847 |  |  |  |  |  |  |
| 4067 | 1051 | Study on Multimedia Session Continuity | 291d? | 2007-04-26 A | 2008-06-05 A | 100% | 2007-04-26 | 2008-06-05 | 291d? | finish no earlier than 2008-06-05 | S2 | 2328h | 2328h | FS_MMSC | LG Electronics |  | Rel-8 | Maurice | FS_MMSC | 23.893 |  |  |  |  |  |  |
| 4068 | 1052 | **Study on centralized IMS service control** | 363d? | 2006-10-23 A | 2008-03-12 A | 100% | 2006-10-23 | 2008-03-12 | 363d? |  | S2; S1 | 10856h | 10856h | FS_ICS | Ericsson | peter.bleckert@ericsson.com | Rel-8 | Alain | FS_ICS |  | PCG-21 | SP-38 |  |  |  |  |
| 4069 | 1052.1 | Study on centralized IMS services requirements | 268d? | 2007-03-05 A | 2008-03-12 A | 100% | 2007-03-05 | 2008-03-12 | 268d? | start no earlier than 2007-03-05 | S1 | 2144h | 2144h | FS_ICS-S1 | NEC | joerg.swetina@neclab.eu | Rel-8 | Alain | FS_ICS-S1 | 22.892 |  | SP-37 |  |  |  |  |
| 4070 | 1052.2 | Study on centralized IMS services control | 363d? | 2006-10-23 A | 2008-03-12 A | 100% | 2006-10-23 | 2008-03-12 | 363d? | finish no earlier than 2008-02-21 | S2 | 2904h | 2904h | FS_IMS_CSC | Alcatel-Lucent | andy.bennett@alcatel-lucent.com | Rel-8 | Maurice | FS_IMS_CSC | 23.892 |  |  |  |  |  |  |
| 4071 | 1053 | Study on Architecture of IMS based Customized Alerting Tone (CAT) | 208d? | 2007-12-04 A | 2008-09-18 A | 100% | 2007-12-04 | 2008-09-18 | 208d? | finish no earlier than 2008-09-08 | S2 | 1664h | 1664h | FS_CAT-St2 | China Mobile | WANG, Jing (wangjing@chinamobilecom) | Rel-8 | Maurice | FS_CAT-St2 | 23.872 | PCG-21 | SP-38 |  |  |  |  |
| 4072 | 1054 | Study on Home (e)NodeB Security | 321d? | 2007-12-20 A | 2009-03-12 A | 100% | 2007-12-20 | 2009-03-12 | 321d? | finish no earlier than 2009-03-10 | S3 | 2568h | 2568h | FS_HNB_Sec | Huawei | yangyanmei@huawei.com | Rel-8 | Mirko | FS_HNB_Sec | 33.820 | PCG-21 | SP-38 | HNB |  |  |  |
| 4073 | 1055 | Study on Transferring of emergency call data – in-band modem solution | 265d? | 2006-12-07 A | 2007-12-12 A | 100% | 2006-12-07 | 2007-12-12 | 265d? | finish no earlier than 2008-09-18 | S4 | 2120h | 2120h | eCALLIBMS | Airbiquity | lhong@airbiquity.com | Rel-8 | Paolo | eCALLIBMS | 26.967 |  |  | Public Safety (I-A) |  |  |  |
| 4074 | 1056 | Study on Element Operations Systems Function (EOSF) definition | 266d? | 2007-06-07 A | 2008-06-12 A | 100% | 2007-06-07 | 2008-06-12 | 266d? | finish no earlier than 2008-12-11 | S5 | 2128h | 2128h | OAM7-NIM-EOSF | China Mobile | Li Jian (lijian@chinamobile.com) | Rel-8 | Mirko | OAM7-NIM-EOSF | 32.819 |  |  |  |  |  |  |
| 4075 | 1057 | Study on SA5 MTOSI XML Harmonization | 351d? | 2006-05-10 A | 2007-09-12 A | 100% | 2006-05-10 | 2007-09-12 | 351d? | finish no earlier than 2007-12-14 | S5 | 2808h | 2808h | OAM8-NIM-XML | Nortel | jduguay@nortel.com | Rel-8 | Mirko | OAM8-NIM-XML | 32.818 |  |  |  |  |  |  |
| 4076 | 1058 | Study on Common Profile Storage (CPS) Framework of User Data for network services and management | 244d? | 2006-07-03 A | 2007-06-07 A | 100% | 2006-07-03 | 2007-06-07 | 244d? | finish no earlier than 2007-06-07 | S5 | 1952h | 1952h | OAM7-CPS | T-Mobile | istvan.aba@t-mobile.at | Rel-8 | Mirko | OAM7-CPS | 32.808 |  |  |  |  |  |  |
| 4077 | 1059 | Study on Management for LTE and SAE | 526d? | 2006-12-07 A | 2008-12-11 A | 100% | 2006-12-07 | 2008-12-11 | 526d? | finish no earlier than 2008-12-11 | S5 | 4208h | 4208h | FS_OAM_LTE_SAE | Ericsson | robert.petersen@ericsson.com | Rel-8 | Mirko | FS_OAM_LTE_SAE | 32.816 |  | TSG-34 |  |  |  |  |
| 4078 | 1060 | Study on Charging Aspects of 3GPP System Evolution | 179d? | 2007-04-02 A | 2007-12-06 A | 100% | 2007-04-02 | 2007-12-06 | 179d? | finish no earlier than 2007-12-06 | S5 | 1432h | 1432h | FS_SAEcharg | Nokia Siemens Networks | Gerald.Goermer@nsn.com | Rel-8 | Mirko | FS_SAEcharg | 32.820 |  |  |  |  |  |  |
| 4079 | 1061 | Study on AS-MRFC media server control protocol | 583d? | 2006-03-22 A | 2008-06-13 A | 100% | 2006-03-22 | 2008-06-13 | 583d? | finish no earlier than 2008-06-13 | C1 | 4664h | 4664h | MRFC | Hewlett-Packard | mark.syrett@hp.com | Rel-8 | Frederic | MRFC | 24.880 |  |  |  |  |  |  |
| 4080 | 1062 | Study on IMS Restoration Procedures | 310d? | 2007-03-26 A | 2008-05-30 A | 100% | 2007-03-26 | 2008-05-30 | 310d? | finish no earlier than 2008-05-30 | C4 | 2480h | 2480h | FS_IMS_RP | Ericsson | german.blanco@ericsson.com | Rel-8 | Kimmo | FS_IMS_RP | 23.820 |  |  |  |  |  |  |
| 4081 | 1063 | Study on IMS Application Server Service Data Descriptions for AS interoperability | 261d? | 2007-09-14 A | 2008-09-12 A | 100% | 2007-09-14 | 2008-09-12 | 261d? | finish no earlier than 2008-09-12 | C4 | 2088h | 2088h | FS_IMS_ASIO | Alcatel-Lucent | Jean-Jacques Trottin | Rel-8 | Kimmo | FS_IMS_ASIO | 29.864 |  |  |  |  |  |  |
| 4082 | 1064 | Study on Customized Alerting Tone (CAT) solution for voice and video call in CS domain | 261d? | 2007-09-14 A | 2008-09-12 A | 100% | 2007-09-14 | 2008-09-12 | 261d? |  | C4 | 626.4h | 626.4h | FS_CAT_VVC_CS | China Mobile | zhanghao@chinamobile.com | Rel-8 | Kimmo | FS_CAT_VVC_CS | 29.882 |  |  |  |  |  |  |
| 4083 | 1065 | Study on InterWorking Function between MAP based and Diameter based interfaces | 266d? | 2007-11-30 A | 2008-12-05 A | 100% | 2007-11-30 | 2008-12-05 | 266d? | finish no earlier than 2008-12-05 | C4 | 2128h | 2128h | FS_MAP2Diam | Huawei | liming49985@huawei.com | Rel-8 | Kimmo | FS_MAP2Diam | 29.805 | PCG-21 | CP-38 |  |  |  |  |
| 4084 | 1066 | Study on Scope of future HSPA Evolution for 1.28 Mcps TDD | 186d? | 2007-09-14 A | 2008-05-30 A | 100% | 2007-09-14 | 2008-05-30 | 186d? | finish no earlier than 2008-05-30 | R1 | 1488h | 1488h | FS_RAN-LCRTDDHSPAEvo | RITT | Xu Fei | Rel-8 | Patrick | FS_RAN-LCRTDDHSPAEvo | 25.824 |  | RP-37 |  | RP-080290 |  |  |
| 4085 | 1067 | Study on Synchronized E-DCH for UTRA FDD | 126d? | 2007-09-14 A | 2008-03-07 A | 100% | 2007-09-14 | 2008-03-07 | 126d? | finish no earlier than 2008-03-14 | R1 | 1008h | 1008h | FS_RAN-UplinkSync | Nokia Siemens Networks | Karri.Ranta-aho@nsn.com | Rel-8 | Patrick | FS_RAN-UplinkSync | 25.823 |  | RP-37 |  | RP-080068 |  |  |
| 4086 | 1068 | Study on Improved network controlled mobility between LTE and 3GPP2/mobile WiMAX radio technologies | 131d? | 2007-06-04 A | 2007-12-03 A | 100% | 2007-06-04 | 2007-12-03 | 131d? | finish no earlier than 2007-12-03 | R4 | 1048h | 1048h | FS_RAN-LTEmob | Motorola | hao.bi@Motorola.com | Rel-8 | Issam | FS_RAN-LTEmob | 36.938 |  |  |  | RP-070827 |  |  |
| 4087 | 1069 | Study on 3G Home NodeB/eNodeB | 325d? | 2007-03-05 A | 2008-05-30 A | 100% | 2007-03-05 | 2008-05-30 | 325d? | finish no earlier than 2008-05-30 | R4 | 2600h | 2600h | FS_RAN-HNBeNB | Motorola | howard.thomas@motorola.com | Rel-8 | Issam | FS_RAN-HNBeNB | 25.820 |  |  | HNB | RP-080289 |  |  |
| 4088 | 1070 | Study on A-interface over IP | 126d? | 2007-08-31 A | 2008-02-22 A | 100% | 2007-08-31 | 2008-02-22 | 126d? | finish no earlier than 2008-02-22 | GP | 1008h | 1008h | AINTIP | China Mobile, Ericsson | paul.schliwa-bertling@ericsson.com | Rel-8 | Paolo | AINTIP | 43.903 |  |  |  |  |  |  |
| 4089 | 1071 | Study on Multi-User Reusing-One-Slot | 782d? | 2007-11-16 A | 2010-11-12 A | 100% | 2007-11-16 | 2010-11-12 | 782d? | finish no earlier than 2010-11-12 | GP | 6248h | 6248h | MUROS | Nokia Siemens Networks | juergen.hofmann@nsn.com | Rel-8 | Paolo | MUROS | 45.914 |  |  |  |  |  |  |
| 4090 | 1072 | Study on Optimized Transmit Pulse Shape for Downlink EGPRS2-B | 657d? | 2007-11-16 A | 2010-05-21 A | 100% | 2007-11-16 | 2010-05-21 | 657d? | finish no earlier than 2010-05-27 | G1 | 5248.44h | 5248.44h | WIDER | Research In Motion, Nokia Siemens Networks | jdwyer@RIM.COM and eddie.riddington@nsn.com | Rel-8 | Paolo | WIDER | 45.913 |  |  |  |  |  |  |
| 4091 | 1073 | Deleted - Study on Mobility between 3GPP-WLAN Interworking and 3GPP Systems | 393d? | 2007-03-20 A | 2008-09-18 A | 100% | 2007-03-20 | 2008-09-18 | 393d? | finish no earlier than 2008-09-18 | S2 | 3144h | 3144h | FS_SM3GWLAN | Orange |  | Rel-8 | Maurice | FS_SM3GWLAN | withdrawn 23.827 |  |  | WLAN |  | PCG-21 | SP-41 |
| 4092 | 1074 | Deleted - equals 340035 -FS on Service continuity between mobile and WLAN networks | 75d? | 2007-09-03 A | 2007-12-14 A | 100% | 2007-09-03 | 2007-12-14 | 75d? | finish no earlier than 2007-12-14 | S1 | 600h | 600h | FSSCMobToW | BT | mike.meyerstein@bt.com | Rel-8 | Alain | FSSCMobToW | 22.937 |  | SP-37 |  |  | PCG-21 | SP-39 |
| 4093 | 1075 | Deleted - Study on Evaluation of LCS Control Plane Solution for EPS | 100d? | 2008-01-14 A | 2008-05-30 A | 100% | 2008-01-14 | 2008-05-30 | 100d? | finish no earlier than 2009-03-20 | S2 | 800h | 800h | FS_LCS_EPS | SiRF |  | Rel-8 | Maurice | FS_LCS_EPS | 23.891 |  | SP-38 |  |  | PCG-21 | SP-40 |
| 4094 | 1076 | Deleted - Study on HS-PDSCH serving cell change enhancements | 60d? | 2007-12-17 A | 2008-03-07 A | 100% | 2007-12-17 | 2008-03-07 | 60d? | finish no earlier than 2008-06-12 | R4 | 480h | 480h | FS_RAN-HSPDSCH | Qualcomm |  | Rel-8 | Issam | FS_RAN-HSPDSCH | none | PCG-21 | RP-38 |  | RP-080070 | PCG-21 | RP-39 |
| 4095 | 1077 | Deleted - Study on Dual-Cell HSDPA operation | 261d? | 2007-08-15 A | 2009-03-06 A | 100% | 2007-08-15 | 2009-03-06 | 261d? | finish no earlier than 2009-03-06 | R1 | 2088h | 2088h | FS_RAN-DCHS | Qualcomm | Josef Blanz | Rel-8 | Patrick | FS_RAN-DCHS | withdrawn 25.825 v100 | PCG-21 | RP-39 |  | RP-090066 | PCG-22 | RP-43 |
| 4096 | 1078 | Release 7 Features | 679d? | 2005-05-02 A | 2007-12-06 A | 100% | 2005-05-02 | 2007-12-06 | 679d? | start no earlier than 2000-01-01 | CP; GP; RP; SP | 21728h | 21728h |  |  |  | Rel-7 | All |  |  |  |  |  |  |  |  |

Notes:
- 4061: SP#43 completed
- 4062: SP#41 completed
- 4063: SP#41 completed
- 4064: SP#43 completed
- 4065: SP#41 completed. No spin-off activity proposed. [Note: IMS Service Brokering enhancements UID_31088 moved back from R8 to R7 to give a home to 22228CR0036_(Rel-7)_S1-051232. Hence, Rel-7 ISB has Stage 1 only (and is misaligned with Rel-7 Stages 2/3.]
- 4066: SP#38 completed
- 4067: SP#40 completed
- 4068: SP#39 completed
- 4069: SP#39 completed
- 4070: SP#39 completed
- 4071: SP#41 completed as Rel-8
- 4072: SP#43 completed. Linked to RAN4 Study on 3G Home NodeB/eNodeB (UID_350039) and to SA5 Study on Self-Organizing Networks (SON) related OAM interfaces for Home NodeB (UID_360007)
- 4073: SP#38 completed. Spin-off WID UID_34042 (eCall_Phase2)
- 4074: SP#40 completed. WID updated SP-050608=>SP-070307
- 4075: SP#37 completed. WID updated SP-050295=>SP-070305
- 4076: SP#36 completed. Spin-off New Feature UID_400034 User Data Convergence (UDC)
- 4077: SP#42 completed
- 4078: SP#38 completed
- 4079: CP#40 completed. Spin-off New Feature UID_380035 (MRFC_TS)
- 4080: CP#40 completed. Spin-off WID UID_400012 (IMS_RP)
- 4081: CP#41 completed. Linked to SA5 Study on Common Profile Storage framework UID_320006. Spin-off WID UID_410003 (IMS_ASIO)
- 4082: CP#41 completed. Spin-off WID under Feature CAT UID_340029
- 4083: CP#42 completed. Spin-off implementation Building Block UID_410007 (MAP2Diam) under the SAES Feature UID_320005
- 4084: RP#40 completed
- 4085: RP#39 completed
- 4086: RP#38 completed
- 4087: RP#40 completed
- 4088: GP#37 completed. Spin-off implementation Feature AoIP (A-interface over IP) UID_50591
- 4089: GP#48 completed as Rel-8. Spin-off implementation WI UID_420002 VAMOS (Voice services over Adaptive Multi-user channels on One Slot)
- 4090: GP#46 completed
- 4091: SP#41 stopped. Draft TR 23.827 content implemented in TS 23.327.
- 4092: SP#39 stopped
- 4093: SP#40 spin-off Feature UID_400038 (LCS_CPS_EPS). SP#40 FS stopped
- 4094: RP#39 stopped (no TR produced). Spin-off HS-DSCH Serving Cell Change Enhancements (UID_39003)
- 4095: RP#43 stopped (draft TR 25.825 v100 withdrawn). Conclusions in RP-090318 (RAN1 findings of the UTRA Multi-Carrier Evolution study). RP#42 New WI approved on Dual-Cell HSDPA operation on adjacent carriers (UID_400052)
- 4096: -

| ID | WBS | Task | Type | Duration | Start | Finish | Complete | Remaining | Baseline start | Baseline finish | Baseline duration | Total slack | Constraint | Resources | Work | Actual work | Acronym | WI rapporteur name | WI rapporteur e-mail | Release | MCC resp | Acronym_3GU_Export | TSG stopped | PCG approved | TSG approved | Status Report | Special Focus Doc |
| --- | --- | --- | --- | --- | --- | --- | --- | --- | --- | --- | --- | --- | --- | --- | --- | --- | --- | --- | --- | --- | --- | --- | --- | --- | --- | --- | --- |
| 4097 | 1079 | **Identification of Communication Services in IMS** |  | 620d? | 2005-05-02 A | 2007-09-14 A | 100% |  | 2005-05-02 | 2007-09-14 | 620d? |  |  | S2; S1; C1; S5 | 29048h | 29048h | ServID | Ericsson | stephen.terrill@ericsson.com | Rel-7 | Maurice | ServID |  |  |  |  |  |
| 4098 | 1079.1 | TR on ServID |  | 232d? | 2005-05-02 A | 2006-03-21 A | 100% |  | 2005-05-02 | 2006-03-21 | 232d? |  | finish no earlier than 2006-03-20 | S2 | 1856h | 1856h | ServID | Ericsson | stephen.terrill@ericsson.com | Rel-7 | Maurice |  |  |  |  |  |  |
| 4099 | 1079.2 | Stage 1,2 of ServID |  | 144d? | 2005-11-11 A | 2006-05-31 A | 100% |  | 2005-11-11 | 2006-05-31 | 144d? |  | start no earlier than 2005-11-11 | S1; S2 | 2304h | 2304h | ServID | Ericsson | stephen.terrill@ericsson.com | Rel-7 | Maurice |  |  |  |  |  |  |
| 4100 | 1079.3 | Stage 3 of ServID |  | 250d? | 2006-03-31 A | 2007-03-15 A | 100% |  | 2006-03-31 | 2007-03-15 | 250d? |  | finish no earlier than 2007-03-15 | C1 | 2000h | 2000h | ServID | Ericsson | christer.holmberg@ericsson.com | Rel-7 | Frederic |  |  |  |  |  |  |
| 4101 | 1079.4 | Charging of ServID |  | 381d? | 2006-03-31 A | 2007-09-14 A | 100% |  | 2006-03-31 | 2007-09-14 | 381d? |  | finish no earlier than 2007-09-14 | S5 | 3048h | 3048h | ServID | Orange | alain.bibas@orange-ft.com | Rel-7 | Mirko |  |  |  |  |  |  |
| 4102 | 1080 | **Supporting Globally Routable User Agent URIs in IMS** |  | 415d? | 2005-11-14 A | 2007-06-15 A | 100% |  | 2005-11-14 | 2007-06-15 | 415d? |  |  | S2; S1; C1 | 14920h | 14920h | GRUU | Research In Motion | Adrian Buckley (abuckley@rim.com) | Rel-7 | Maurice | GRUU |  |  |  |  |  |
| 4103 | 1080.1 | Deleted - TR on GRUU |  | 219d? | 2005-11-14 A | 2006-09-14 A | 100% |  | 2005-11-14 | 2006-09-14 | 219d? |  | finish no earlier than 2006-09-14 | S2 | 1752h | 1752h | GRUU | Research In Motion | Adrian Buckley (abuckley@rim.com) | Rel-7 | Maurice |  | SP-32 |  |  |  |  |
| 4104 | 1080.2 | Stage 1,2 of GRUU |  | 65d? | 2006-07-03 A | 2006-09-29 A | 100% |  | 2006-07-03 | 2006-09-29 | 65d? |  | start no earlier than 2006-07-03 | S1; S2 | 1040h | 1040h | GRUU | Research In Motion | Adrian Buckley (abuckley@rim.com) | Rel-7 | Maurice |  |  |  |  |  |  |
| 4105 | 1080.3 | Stage 3 of GRUU |  | 271d? | 2006-06-02 A | 2007-06-15 A | 100% |  | 2006-06-02 | 2007-06-15 | 271d? |  | finish no earlier than 2007-06-15 | C1 | 2168h | 2168h | GRUU | CableLabs | Bernie McKibben (b.mckibben@cablelabs.com) | Rel-7 | Frederic |  |  |  |  |  |  |
| 4106 | 1081 | **Multimedia Telephony Service for IMS** |  | 2919d? | 2006-02-01 A | 2017-03-15 | 99% | 0d? | 2006-02-01 | 2007-06-15 | 357d? | 0d |  | S1; C1; S4 | 81952h | 20464h | MTSI | Ericsson | peter.bleckert@ericsson.com | Rel-7 | Alain | MTSI |  | PCG-35 | RP-69 |  |  |
| 4107 | 1081.1 | Stage 1 of MTSI |  | 173d? | 2006-02-01 A | 2006-09-29 A | 100% |  | 2006-02-01 | 2006-09-29 | 173d? |  | start no earlier than 2006-02-01 | S1 | 1384h | 1384h | MTSI-REQ | Ericsson | peter.bleckert@ericsson.com | Rel-7 | Alain | MTSI-REQ |  |  |  |  |  |
| 4108 | 1081.2 | Stage 3 of MTSI |  | 330d? | 2006-03-10 A | 2007-06-14 A | 100% |  | 2006-03-10 | 2007-06-14 | 330d? |  | finish no earlier than 2007-06-15 | C1 | 2640h | 2640h | MTSI | Ericsson | christer.holmberg@ericsson.com | Rel-7 | Frederic | MTSI |  |  |  |  |  |
| 4109 | 1081.3 | Media handling and interaction in MTSI |  | 262d? | 2006-03-15 A | 2007-03-15 A | 100% |  | 2006-03-15 | 2007-03-15 | 262d? |  | finish no earlier than 2007-03-15 | S4 | 2096h | 2096h | MTSI-MHI | Ericsson | olle.franceschi@ericsson.com | Rel-7 | Paolo | MTSI-MHI |  |  |  |  |  |
| 4110 | 1081.4 | UE Conformance Test Aspects - Multimedia Telephony Services for IMS (MTSI) over fixed access |  | 393d? | 2015-09-15 A | 2017-03-15 A | 100% |  |  |  |  |  | finish no earlier than 2017-03-15 | R5 | 3144h | 3144h | MTSI_FIXED_ACCESS-UEConTest | Telecom Italia |  | Rel-7 |  |  |  | PCG-35 | RP-69 |  |  |
| 4111 | 1081.5 | UE Conformance Test Aspects – Multimedia Telephony Services for IMS (MTSI) over WLAN |  | 329d? | 2015-09-15 A | 2016-12-15 A | 100% |  |  |  |  |  | finish no earlier than 2016-12-15 | R5 | 2632h | 2632h | MTSI_WLAN-UEConTest | Ericsson |  | Rel-7 |  |  |  | PCG-35 | RP-69 |  |  |
| 4112 | 1081.6 | Deleted - duplicates UID7039 - IMS Multimedia Telephony Service | milestone | 0d? | 2007-06-15 A | 2007-06-15 A | 100% |  | 2007-06-15 | 2007-06-15 | 0d? |  | start no earlier than 2007-06-15 | S1 |  |  | MMTEL | Ericsson | peter.bleckert@ericsson.com | Rel-7 | Alain | MMTEL | SP-32 |  |  |  |  |
| 4113 | 1082 | Multimedia Telephony Service for IMS (MTSI) - UE Conformance Testing |  | 387d | 2007-09-19 A | 2009-03-12 A | 100% |  | 2007-09-19 | 2009-03-12 | 387d |  | finish no earlier than 2009-03-13 | R5 | 1664h | 1664h | MTSI-UEConTest | Ericsson, Motorola | Leif.Mattisson@ericsson.com, Jacob.John@motorola.com | Rel-7 | Ingbert | MTSI-UEConTest |  |  |  | RP-090056 |  |
| 4114 | 1083 | TISPAN requirements for Multimedia Telephony with PSTN/ISDN simulation services |  | 58d? | 2007-09-18 A | 2007-12-06 A | 100% |  | 2007-09-18 | 2007-12-06 | 58d? |  | start no earlier than 2007-09-18 | S1 | 464h | 464h | TMMTEL7 |  |  | Rel-7 | Alain | TMMTEL7 |  |  | SP-37 |  |  |
| 4115 | 1084 | **Maintenance of TISPAN release 1 common IMS** |  | 180d? | 2007-07-02 A | 2008-03-07 A | 100% |  | 2007-07-02 | 2008-03-07 | 180d? |  |  | S2 | 5808h | 5808h | MCIMSTR1 | Ericsson | Raymond Forbes | Rel-7 | Maurice | MCIMSTR1 |  | PCG-21 | SP-38 |  |  |
| 4116 | 1084.1 | SA1 aspects of MCIMSTR1 |  | 58d? | 2007-09-18 A | 2007-12-06 A | 100% |  | 2007-09-18 | 2007-12-06 | 58d? |  | finish no earlier than 2007-12-06 | S1 | 464h | 464h | MCIMSTR1-S1 | Telecom Italia | Marco.DeLuca1@telecomitalia.it | Rel-7 | Alain | MCIMSTR1-S1 |  | PCG-21 | SP-38 |  |  |
| 4117 | 1084.2 | SA2 aspects of MCIMSTR1 |  | 58d? | 2007-09-18 A | 2007-12-06 A | 100% |  | 2007-09-18 | 2007-12-06 | 58d? |  | finish no earlier than 2007-12-06 | S2 | 464h | 464h | MCIMSTR1-S2 | Ericsson | Raymond Forbes | Rel-7 | Maurice | MCIMSTR1-S2 |  | PCG-21 | SP-38 |  |  |
| 4118 | 1084.3 | SA1,SA2 part of Maintenance of TISPAN release 1 common IMS |  | 114d? | 2007-07-02 A | 2007-12-06 A | 100% |  | 2007-07-02 | 2007-12-06 | 114d? |  | finish no earlier than 2007-12-06 | S2; S1 | 1824h | 1824h | IMS_Comm_Mtce7 | BT, Ericsson | Dick Knight, Raymond Forbes | Rel-7 | Maurice | IMS_Comm_Mtce7 |  | PCG-21 | SP-38 |  |  |
| 4119 | 1084.4 | Maintenance of TISPAN R1 |  | 86d? | 2007-11-09 A | 2008-03-07 A | 100% |  | 2007-11-09 | 2008-03-07 | 86d? |  | start no earlier than 2007-11-09 | C1; C3; C4 | 2064h | 2064h | MAINT_R1 | Alcatel-Lucent | Keith Drage (drage@alcatel-lucent.com) | Rel-7 | Frederic | MAINT_R1 |  | PCG-21 | CP-38 |  |  |
| 4120 | 1085 | **PS domain and IMS impacts for supporting IMS Emergency calls (EMC1)** |  | 2934d? | 2000-09-18 A | 2011-12-09 A | 100% |  | 2000-09-18 | 2011-12-09 | 2934d? |  |  | S2; S1; C1; C4; IETF | 185422h | 185422h | EMC1 | Siemens | Rainer Liebhart | Rel-7 | Maurice | EMC1 |  |  |  |  | Public Safety (I-A) |
| 4121 | 10.1.1 | Service Requirements for IP-based emergency calls |  | 985d | 2000-09-18 A | 2004-06-25 A | 100% |  | 2000-09-18 | 2004-06-25 | 985d |  | finish no earlier than 2004-06-25 | S1 | 7880h | 7880h | EMC1 | Siemens | Rainer Liebhart | Rel-7 | Alain |  |  |  |  |  | Public Safety (I-A) |
| 4122 | 1085.2 | Study on Stage 2 for IMS-level solution |  | 668d? | 2003-02-26 A | 2005-09-16 A | 100% |  | 2003-02-26 | 2005-09-16 | 668d? |  | finish no earlier than 2005-09-16 | S2 | 5344h | 5344h | EMC1 | Siemens | Rainer Liebhart | Rel-7 | Maurice |  |  |  |  |  | Public Safety (I-A) |
| 4123 | 1085.3 | Study on Stage 2 for GPRS-level solution |  | 301d? | 2004-10-14 A | 2005-12-08 A | 100% |  | 2004-10-14 | 2005-12-08 | 301d? |  | finish no earlier than 2005-12-08 | S2 | 2408h | 2408h | EMC1 | Siemens | Rainer Liebhart | Rel-7 | Maurice |  |  |  |  |  | Public Safety (I-A) |
| 4124 | 1085.4 | Stage 2 Specification Phase - IMS-level |  | 200d? | 2005-09-05 A | 2006-06-09 A | 100% |  | 2005-09-05 | 2006-06-09 | 200d? |  | finish no earlier than 2006-06-09 | S2 | 1600h | 1600h | EMC1 | Siemens | Rainer Liebhart | Rel-7 | Maurice |  |  |  |  |  | Public Safety (I-A) |
| 4125 | 1085.5 | Deleted - Stage 2 Specification Phase - GPRS-level | milestone | 0d? | 2007-03-02 A | 2007-03-02 A | 100% |  | 2007-03-02 | 2007-03-02 | 0d? |  | start no earlier than 2007-03-02 | S2 |  |  | EMC1 | Siemens | Rainer Liebhart | Rel-7 | Maurice |  | SP-32 |  |  |  | Public Safety (I-A) |

Notes:
- 4097: WID approved SP#28. WID updated SP#32
- 4098: - / Impacted TSs and TRs: 23.816
- 4099: - / Impacted TSs and TRs: 22.228, 23.228, 23.203
- 4100: CP#32 approved WID / Impacted TSs and TRs: 23.218, 24.229
- 4101: - / Impacted TSs and TRs: 32.260, 32.298, 32.299
- 4102: SP#29 approved WID
- 4103: Abandoned
- 4104: SP#29 approved WID / Impacted TSs and TRs: 22.228, 23.228, 23.218, 24.229
- 4105: CP#32 approved WID / Impacted TSs and TRs: 24.229
- 4106: -
- 4107: - / Impacted TSs and TRs: 22.173
- 4108: - / Impacted TSs and TRs: 24.173
- 4109: - / Impacted TSs and TRs: 26.114
- 4110: tested: REL-7 SA/CT WI MTSI;1/1/16: Compl:0%->5%; 22/3/16: Compl:5%->15%1/7/16: Compl:15%->30% ; 21/...
- 4111: tested: REL-7 WI MTSI; 1/1/16: Compl:0%->5%1/1/16: WID: RP-151334->RP-15177022/3/16: Compl:5%->10%
- 4112: - / Impacted TSs and TRs: 22.173
- 4113: RP#43 completed. Linked UID_7038 (MTSI) / Impacted TSs and TRs: 34.123-1, 34.123-2, 34.123-3, 34.229-1, 34.229-2
- 4114: - / Impacted TSs and TRs: 22.273 (EI 181 002 maintenance)
- 4115: - / Impacted TSs and TRs: http://www.3gpp.org/specs/TISPAN-IMS-ansfer.htm
- 4116: - / Impacted TSs and TRs: 22.173, 22.273
- 4117: - / Impacted TSs and TRs: 23.406, 23.417, 23.508,23.509, 23.511
- 4118: SP#38 completed / Impacted TSs and TRs: 22.173, 22.273, 22.401, 23.406, 23.417, 23.508, 23.509, 23.511
- 4119: CP#39 completed / Impacted TSs and TRs: 24.404, 24.405, 24.406, 24.407, 24.408, 24.410, 24.411, 24.416, 29.421, 24.423, 24.428, 24.429, 29.433, 24.441, 24.403, 29.427, 24.430, 29.412
- 4120: - / Impacted TSs and TRs: EMC1
- 4121: - / Impacted TSs and TRs: 22.101
- 4122: - / Impacted TSs and TRs: 23.867
- 4123: - / Impacted TSs and TRs: 23.867
- 4124: - / Impacted TSs and TRs: 23.060, 23.167, 23.203, 23.221, 23.228, 23.234, 23.271, 23.406
- 4125: -

| ID | WBS | Task | Type | Duration | Start | Finish | Complete | Baseline start | Baseline finish | Baseline duration | Constraint | Resources | Work | Actual work | Acronym | WI rapporteur name | WI rapporteur e-mail | Release | MCC resp | Special Focus Doc | Impacted TSs and TRs | PCG approved | TSG approved | TSG stopped | Acronym_3GU_Export | Created at | Status Report |
| --- | --- | --- | --- | --- | --- | --- | --- | --- | --- | --- | --- | --- | --- | --- | --- | --- | --- | --- | --- | --- | --- | --- | --- | --- | --- | --- | --- |
| 4126 | 10.1 | **Emergency Call Enhancements for IP& PS Based Calls – stage 3** |  | 1549d? | 2006-01-09 A | 2011-12-09 A | 100% | 2006-01-09 | 2011-12-09 | 1549d? |  | C1; C4; IETF | 50829.8h | 50829.8h | EMC1 | Ericsson | alf.heidermark@ericsson.com | Rel-7 | Frederic | Public Safety (I-A) |  |  |  |  |  |  |  |
| 4127 | 10.1.2 | CT1 IMS aspects to support IMS Emergency sessions |  | 350.82d | 2006-01-09 A | 2007-06-15 A | 100% | 2006-01-09 | 2007-06-15 | 350.82d | finish no earlier than 2007-06-15 | C1 | 2806.57h | 2806.57h | EMC1 | Ericsson | alf.heidermark@ericsson.com | Rel-7 | Frederic | Public Safety (I-A) | 24.229 |  |  |  |  |  |  |
| 4128 | 1085.6.2 | (IETF) CT1 IMS aspects to support IMS Emergency sessions |  | 452d? | 2006-01-09 A | 2011-12-09 A | 100% | 2006-01-09 | 2011-12-09 | 452d? | finish no earlier than 2011-12-09 | C1-IETF | 3608h | 3608h | EMC1 | Keith Drage |  | Rel-7 | Frederic | Public Safety (I-A) | RFC 6442 (was draft-ietf-sipcore-location-conveyance) | PCG-27 | CP-52 |  |  |  |  |
| 4129 | 10.1.2 | Deleted - CT3 IMS aspects to support IMS Emergency sessions |  | 95d | 2006-05-08 A | 2006-09-15 A | 100% | 2006-05-08 | 2006-09-15 | 95d | finish no earlier than 2006-09-15 | C3 | 760h | 760h | EMC1 | Ericsson | alf.heidermark@ericsson.com | Rel-7 | Adrian | Public Safety (I-A) | 29.163 |  |  | CP-33 |  |  |  |
| 4130 | 10.1.5 | Deleted - CT3 PS domain aspects to support IMS Emergency sessions |  | 95d | 2006-05-08 A | 2006-09-15 A | 100% | 2006-05-08 | 2006-09-15 | 95d | start no earlier than 2006-05-08 | C3 | 760h | 760h | EMC1 | Ericsson | alf.heidermark@ericsson.com | Rel-7 | Adrian | Public Safety (I-A) | 29.061 |  |  | CP-33 |  |  |  |
| 4131 | 10.1.5 | CT1 PS domain aspects to support IMS Emergency sessions |  | 349.9d | 2006-01-09 A | 2007-06-15 A | 100% | 2006-01-09 | 2007-06-15 | 349.9d | finish no earlier than 2007-06-15 | C1 | 2799.2h | 2799.2h | EMC1 | Ericsson | alf.heidermark@ericsson.com | Rel-7 | Frederic | Public Safety (I-A) | 24.008, 24.234 |  |  |  |  |  |  |
| 4132 | 10.1.5 | CT4 PS domain aspects to support IMS Emergency sessions |  | 365d | 2006-01-09 A | 2007-06-01 A | 100% | 2006-01-09 | 2007-06-01 | 365d | finish no earlier than 2007-06-01 | C4 | 2920h | 2920h | EMC1-GPRSc4 | Ericsson | alf.heidermark@ericsson.com | Rel-7 | Kimmo | Public Safety (I-A) | 29.060 |  |  |  | EMC1-GPRSc4 |  |  |
| 4133 | 1086 | IMS Support of Conferencing |  | 355d? | 2005-11-04 A | 2007-03-15 A | 100% | 2005-11-04 | 2007-03-15 | 355d? | finish no earlier than 2007-03-15 | C1 | 2840h | 2840h | IMSconf | Alcatel-Lucent | Keith Drage (drage@alcatel-lucent.com) | Rel-7 | Frederic |  | 24.147, 24.229 |  |  |  | IMSconf |  |  |
| 4134 | 1087 | Performance Characterization of VoIMS over HSDPA\EUL channels |  | 713d? | 2005-03-15 A | 2007-12-06 A | 100% | 2005-03-15 | 2007-12-06 | 713d? | finish no earlier than 2007-12-06 | S4 | 5704h | 5704h | VoIMS-PCVoIMS | Alcatel-Lucent | mcgowan@alcatel-lucent.com | Rel-7 | Paolo |  | 26.935 |  |  |  | VoIMS-PCVoIMS |  |  |
| 4135 | 1088 | **WLAN-UMTS Interworking Phase 2** |  | 371d? | 2004-01-05 A | 2005-06-07 A | 100% | 2004-01-05 | 2005-06-07 | 371d? |  | S1; S2 | 6856h | 6856h | WLAN2 | Telenor | frederic.paint@telenor.com | Rel-7 | Alain | WLAN | 33.234 (SP-36 SA3 CRs approved) |  |  |  | WLAN2, WLAN-SC |  |  |
| 4136 | 1088.1 | Stage 1 on Session Continuity |  | 115d? | 2004-01-05 A | 2004-06-11 A | 100% | 2004-01-05 | 2004-06-11 | 115d? | start no earlier than 2004-01-05 | S1 | 920h | 920h | WLAN2 |  |  | Rel-7 | Alain | WLAN | 22.234 |  |  |  |  | SP-24 |  |
| 4137 | 1088.2 | Stage 2 on Session Continuity: covered by SAE | milestone | 0d? | 2005-06-07 A | 2005-06-07 A | 100% | 2005-06-07 | 2005-06-07 | 0d? | finish no earlier than 2005-06-07 | S2 |  |  | WLAN2 |  |  | Rel-7 | Maurice | WLAN |  |  |  |  |  |  |  |
| 4138 | 1089 | **WLAN Interworking – Private Network access from WLAN 3GPP IP Access** |  | 252d? | 2005-10-10 A | 2006-09-26 A | 100% | 2005-10-10 | 2006-09-26 | 252d? |  | S2; C1; C3; C4 | 17704h | 17704h | WLANPNA | NEC | Toshiyuki Tamura (tamurato@aj.jp.nec.com) | Rel-7 | Maurice | WLAN |  |  |  |  | WLANPNA |  |  |
| 4139 | 1089.1 | WLAN-PNA - Stage 2 |  | 185d? | 2005-10-10 A | 2006-06-23 A | 100% | 2005-10-10 | 2006-06-23 | 185d? | start no earlier than 2005-10-10 | S2 | 1480h | 1480h | WLANPNA-st2 | NEC | Toshiyuki Tamura (tamurato@aj.jp.nec.com) | Rel-7 | Maurice | WLAN | 23.234, 33.234 |  |  |  | WLANPNA-st2 |  |  |
| 4140 | 1089.2 | **WLAN-PNA - Stage 3** |  | 170d? | 2006-02-01 A | 2006-09-26 A | 100% | 2006-02-01 | 2006-09-26 | 170d? |  | C1; C3; C4 | 8160h | 8160h | WLANPNA-st3 | NEC |  | Rel-7 | Frederic | WLAN |  |  |  |  | WLANPNA-st3 |  |  |
| 4141 | 1089.2.1 | CT1 aspets for WLAN-PNA |  | 170d? | 2006-02-01 A | 2006-09-26 A | 100% | 2006-02-01 | 2006-09-26 | 170d? | start no earlier than 2006-02-01 | C1 | 1360h | 1360h | WLANPNA-st3 | NEC |  | Rel-7 | Frederic | WLAN | 24.234 |  |  |  |  |  |  |
| 4142 | 1089.2.2 | CT3 aspets for WLAN-PNA |  | 170d? | 2006-02-01 A | 2006-09-26 A | 100% | 2006-02-01 | 2006-09-26 | 170d? | start no earlier than 2006-02-01 | C3 | 1360h | 1360h | WLANPNA-st3 | NEC |  | Rel-7 | Adrian | WLAN | 29.161 |  |  |  |  |  |  |
| 4143 | 1089.2.3 | Deleted - CT4 aspets for WLAN-PNA |  | 170d? | 2006-02-01 A | 2006-09-26 A | 100% | 2006-02-01 | 2006-09-26 | 170d? | start no earlier than 2006-02-01 | C4 | 1360h | 1360h | WLANPNA-st3 | NEC |  | Rel-7 | Kimmo | WLAN | 29.234 |  |  | CP-32 |  |  |  |
| 4144 | 1090 | **Enhancements to support QoS provisioning over 3GPP/WLAN Interworking** |  | 520d? | 2005-03-14 A | 2007-03-09 A | 100% | 2005-03-14 | 2007-03-09 | 520d? |  | S2; C4; C1 | 16680h | 16680h | WLANQOS | Samsung |  | Rel-7 | Maurice | WLAN |  |  |  |  | WLANQOS |  |  |
| 4145 | 1090.1 | Deleted - TR on support of QoS on WLAN |  | 232d? | 2005-03-14 A | 2006-01-31 A | 100% | 2005-03-14 | 2006-01-31 | 232d? | start no earlier than 2005-03-14 | S2 | 1856h | 1856h | WLANQOS | Samsung |  | Rel-7 | Maurice | WLAN | 23.836 |  |  | SP-32 |  |  |  |
| 4146 | 1090.2 | Stage 2 on support of QoS over 3GPP/WLAN interworking |  | 108d? | 2006-02-01 A | 2006-06-30 A | 100% | 2006-02-01 | 2006-06-30 | 108d? | start no earlier than 2006-02-01 | S2 | 864h | 864h | WLANQOS | Samsung |  | Rel-7 | Maurice | WLAN | 23.234 |  |  |  |  |  |  |
| 4147 | 1090.3 | Stage 3 CT4 on support of QoS over 3GPP/WLAN Interworking |  | 121d? | 2006-09-22 A | 2007-03-09 A | 100% | 2006-09-22 | 2007-03-09 | 121d? | finish no earlier than 2007-03-09 | C4 | 968h | 968h | WLANQOS | Huawei | zhang.peng@huawei.com | Rel-7 | Kimmo | WLAN | 29.234, 23.008 |  |  |  |  |  |  |
| 4148 | 1090.4 | Stage 3 CT1 on support of QoS over 3GPP/WLAN Interworking |  | 64d? | 2006-09-04 A | 2006-11-30 A | 100% | 2006-09-04 | 2006-11-30 | 64d? | finish no earlier than 2006-11-30 | C1 | 512h | 512h | WLANQOS | Huawei | zhang.peng@huawei.com | Rel-7 | Frederic | WLAN | 24.234 |  | TSG-34 |  |  |  |  |
| 4149 | 1091 | **Location Services enhancements** |  | 906d? | 2004-06-28 A | 2007-12-17 A | 100% | 2004-06-28 | 2007-12-17 | 906d? |  | S1; S2; GP; C4; R2 | 81525.6h | 81525.6h | LCS3 |  |  | Rel-7 | Alain |  |  |  |  |  | LCS3 |  |  |
| 4150 | 1091.1 | Stage 2 for LCS3 (including IMS emergency location aspects) |  | 446d? | 2004-12-31 A | 2006-09-15 A | 100% | 2004-12-31 | 2006-09-15 | 446d? | finish no earlier than 2006-09-15 | S2 | 3568h | 3568h | LCS3 | SiRF | brodilitz@sirf.com | Rel-7 | Maurice |  | 23.271 |  |  |  |  |  |  |
| 4151 | 1091.2 | LCS Enhancements related to Location-Based Services |  | 695d? | 2005-01-03 A | 2007-08-31 A | 100% | 2005-01-03 | 2007-08-31 | 695d? | finish no earlier than 2007-08-31 | GP | 5560h | 5560h | LCS3-LBS | SiRF | kjudge@sirf.com | Rel-7 | Paolo |  | 43.059, 44.031, 48.008, 49.031 |  |  |  | LCS3-LBS |  |  |
| 4152 | 1091.3 | CT4 aspects for LCS UEPos-LBS |  | 240d? | 2006-01-02 A | 2006-12-01 A | 100% | 2006-01-02 | 2006-12-01 | 240d? | finish no earlier than 2006-12-01 | C4 | 1920h | 1920h | LCS3-UEPos-LBS | SiRF | brodilitz@sirf.com | Rel-7 | Kimmo |  | 24.030, 24.080, 29.002 |  |  |  | LCS3-UEPos-LBS |  |  |
| 4153 | 1091.4 | UE positioning - Velocity |  | 394d? | 2005-03-15 A | 2006-09-15 A | 100% | 2005-03-15 | 2006-09-15 | 394d? | finish no earlier than 2006-09-15 | R2 | 3152h | 3152h | LCS3-UEPos-Velocity | SiRF | BRodilitz@SiRF.com | Rel-7 | Yong-Jun |  | 25.305, 25.331, 25.410, 25.413, 25.453 |  |  |  | LCS3-UEPos-Velocity |  | RP-060459 |
| 4154 | 1091.5 | Inclusion of Uplink TDOA UE positioning method in the UTRAN specifications |  | 849d? | 2004-09-15 A | 2007-12-17 A | 100% | 2004-09-15 | 2007-12-17 | 849d? | finish no earlier than 2007-12-17 | R2 | 6792h | 6792h | LCS3-UEPos-UTDOA | TruePosition | Robert Gross (rgross@polariswireless.com) | Rel-7 | Yong-Jun |  | 25.305, 25.453, new TS 25.111 |  |  |  | LCS3-UEPos-UTDOA |  | RP-070797 |

Notes:
- 4126: -
- 4127: -
- 4128: CP#54 completed
- 4129: Cancelled for Rel-7 and there is no corresponding Rel-8 WI
- 4130: Cancelled for Rel-7 and there is no corresponding Rel-8 WI
- 4131: -
- 4132: -
- 4133: CP#35 revised WID
- 4134: -
- 4135: Created at SP#27 because of WLAN items belonging to Rel-7. Acronym changed from "WLAN2, WLAN-SC"
- 4136: Acronym changed from "WLAN2, WLAN-SC"
- 4137: Acronym changed from "WLAN2, WLAN-SC"
- 4138: -
- 4139: Approved at SP#29
- 4140: Approved at CP#29
- 4141: Approved at CP#29
- 4142: Approved at CP#29
- 4143: CT4#31; no impacts identified, therefore completed. CP-32 stopped
- 4144: Moved from FS section Feb 06. SP-30 updated WID
- 4145: SP#32 stopped
- 4146: SP#30 updated WID
- 4147: CP#33 approved WID
- 4148: CP#33 approved WID
- 4149: -
- 4150: SP#27 approved WID
- 4151: -
- 4152: -
- 4153: -
- 4154: -

| ID | WBS | Task | Duration | Start | Finish | Complete | Baseline start | Baseline finish | Baseline duration | Constraint | Resources | Work | Actual work | Acronym | WI rapporteur name | WI rapporteur e-mail | Release | MCC resp | Special Focus Doc | Acronym_3GU_Export | TSG stopped | TSG approved | Status Report | PCG approved |
| --- | --- | --- | --- | --- | --- | --- | --- | --- | --- | --- | --- | --- | --- | --- | --- | --- | --- | --- | --- | --- | --- | --- | --- | --- |
| 4155 | 1091.6 | **LCS for 3GPP Interworking WLAN** | 700d? | 2004-06-28 A | 2007-03-02 A | 100% | 2004-06-28 | 2007-03-02 | 700d? |  | S1; S2 | 17501.6h | 17501.6h | LCS3-IWLAN | Telcordia | Mike Loushine | Rel-7 | Alain | WLAN | LCS3-IWLAN |  |  |  |  |
| 4156 | 1091.6.1 | FS on 3GPP system to WLAN Interworking with LCS | 512.7d? | 2004-06-28 A | 2006-06-30 A | 100% | 2004-06-28 | 2006-06-30 | 512.7d? | finish no earlier than 2005-09-29 | S1 | 4101.6h | 4101.6h | LCS3-IWLAN-FSs1 | Telcordia | Mike Loushine | Rel-7 | Alain |  | LCS3-IWLAN-FSs1 |  |  |  |  |
| 4157 | 1091.6.2 | Deleted - Study of work on an LCS architecture for I-WLAN. | 180d? | 2006-06-26 A | 2007-03-02 A | 100% | 2006-06-26 | 2007-03-02 | 180d? | finish no earlier than 2007-03-02 | S2 | 1440h | 1440h | LCS3-IWLAN-FSs2 | LG Electronics | dhshim@lge.com ; phede@lge.com | Rel-7 | Maurice |  | LCS3-IWLAN-FSs2 | SP-35 |  |  |  |
| 4158 | 1091.6.3 | Stage 2 for LCS architecture for I-WLAN | 95d? | 2006-10-23 A | 2007-03-02 A | 100% | 2006-10-23 | 2007-03-02 | 95d? | finish no earlier than 2007-03-02 | S2 | 760h | 760h | LCS3-IWLAN | LG Electronics | dhshim@lge.com ; phede@lge.com | Rel-7 | Maurice |  | LCS3-IWLAN |  | TSG-34 |  |  |
| 4159 | 1091.7 | Deleted - UE positioning Rel-7 | 849d? | 2004-09-15 A | 2007-12-17 A | 100% | 2004-09-15 | 2007-12-17 | 849d? |  | RP | 6792h | 6792h | LCS3-UEpos |  |  | Rel-7 | Yong-Jun |  | LCS3-UEpos | RP-38 |  |  |  |
| 4160 | 1092 | **MBMS Enhancements** | 625d? | 2005-07-11 A | 2007-11-30 A | 100% | 2005-07-11 | 2007-11-30 | 625d? |  | S1; R1; C3 | 20844.6h | 20844.6h | MBMSE | China Mobile | liuhongyfw@chinamobile.com | Rel-7 | Alain |  | MBMSE |  |  |  |  |
| 4161 | 1092.1 | Stage 1 of MBMSE | 109d? | 2005-07-11 A | 2005-12-08 A | 100% | 2005-07-11 | 2005-12-08 | 109d? | finish no earlier than 2005-12-08 | S1 | 872h | 872h | MBMSE | China Mobile | liuhongyfw@chinamobile.com | Rel-7 | Alain |  |  |  | TSG-34 |  |  |
| 4162 | 1092.2 | MBMS FDD Physical layer Enhancements | 117.29d? | 2006-12-15 A | 2007-06-04 A | 100% | 2006-12-15 | 2007-06-04 | 117.29d? | finish no earlier than 2007-06-04 | R1 | 938.32h | 938.32h | MBMSE-RANPhysFDD | Ericsson | Lars.Lindbom@ericsson.com | Rel-7 | Patrick |  | MBMSE-RANPhysFDD |  | TSG-34 | RP-070290 |  |
| 4163 | 1092.3 | MBMS TDD Physical layer Enhancements | 117.29d? | 2006-12-15 A | 2007-06-04 A | 100% | 2006-12-15 | 2007-06-04 | 117.29d? | finish no earlier than 2007-06-04 | R1 | 938.32h | 938.32h | MBMSE-RANPhysTDD | IPWireless | Nicholas Anderson | Rel-7 | Patrick |  | MBMSE-RANPhysTDD |  | TSG-34 | RP-070291 |  |
| 4164 | 1092.4 | MBMS Low Chip Rate TDD Physical Layer Enhancement | 127d? | 2007-03-16 A | 2007-09-10 A | 100% | 2007-03-16 | 2007-09-10 | 127d? | finish no earlier than 2007-09-10 | R1 | 1016h | 1016h | MBMSE-RANPhysLCRTDD | RITT | Lin Hui | Rel-7 | Patrick |  | MBMSE-RANPhysLCRTDD |  |  | RP-070292 |  |
| 4165 | 1092.5 | MBMS Mz interface | 260d? | 2006-12-04 A | 2007-11-30 A | 100% | 2006-12-04 | 2007-11-30 | 260d? | finish no earlier than 2007-05-11 | C3 | 2080h | 2080h | MBMSMz | Huawei | Deng Tingting (ttdeng@huawei.com) | Rel-7 | Adrian |  | MBMSMz |  | TSG-34 |  |  |
| 4166 | 1093 | **MBMS - UE Conformance Testing** | 657d? | 2007-06-01 A | 2009-12-04 A | 100% | 2007-06-01 | 2009-12-04 | 657d? |  | R5 | 13848h | 13848h | MBMSE_UEConTest |  |  | Rel-7 | Ingbert |  | MBMSE_UEConTest |  | SP-40 |  | PCG-21 |
| 4167 | 1093.1 | Conformance Test Aspects – MBMS TDD Physical layer Enhancements – MBSFN for HCR and VHCR TDD | 336d? | 2007-06-01 A | 2008-09-12 A | 100% | 2007-06-01 | 2008-09-12 | 336d? | start no earlier than 2007-06-01 | R5 | 2688h | 2688h | MBMSE-RANPhysTDD_UEConTest | IPWireless | tspeight@ipwireless.com | Rel-7 | Ingbert |  | MBMSE-RANPhysTDD_UEConTest |  |  | RP-080541 |  |
| 4168 | 1093.2 | Conformance Test Aspects – MBMS LCR TDD Physical Layer Enhancement | 342d? | 2008-05-30 A | 2009-09-18 A | 100% | 2008-05-30 | 2009-09-18 | 342d? | finish no earlier than 2009-09-18 | R5 | 2728h | 2728h | MBMSE-RANPhysLCRTDD_UEConTest | CATT | chenxiaozhong@datangmobile.cn | Rel-7 | Ingbert |  | MBMSE-RANPhysLCRTDD_UEConTest |  | RP-40 | RP-090715 | PCG-21 |
| 4169 | 1093.3 | Conformance Test Aspects – MBSFN for FDD | 397d? | 2008-05-30 A | 2009-12-04 A | 100% | 2008-05-30 | 2009-12-04 | 397d? | finish no earlier than 2009-12-04 | R5 | 3176h | 3176h | MBMSE-UEConTest_RANPhysFDD | Huawei | Xiang Li (trica_li@huawei.com) | Rel-7 | Ingbert |  | MBMSE-UEConTest_RANPhysFDD |  | RP-40 | RP-091214 | PCG-21 |
| 4170 | 1094 | MBMS User Service Extensions | 392d? | 2005-12-07 A | 2007-06-07 A | 100% | 2005-12-07 | 2007-06-07 | 392d? | finish no earlier than 2007-06-07 | S4 | 3136h | 3136h | MBMSUSE | Ericsson | Thorsten.Lohmar@ericsson.com | Rel-7 | Paolo |  | MBMSUSE |  |  |  |  |
| 4171 | 1095 | **Advanced Global Navigation Satellite System (AGNSS) concept** | 830d? | 2004-06-28 A | 2007-08-31 A | 100% | 2004-06-28 | 2007-08-31 | 830d? |  | S1; S2; GP; R2 | 36129.6h | 36129.6h | LCS3-AGNSS | Alcatel | Michel.monnerat@thalesaleniaspace.com | Rel-7 | Alain |  | LCS3-AGNSS |  |  |  |  |
| 4172 | 1095.1 | Stage 1/2 for Towards AGNSS Concept | 1d? | 2007-02-16 A | 2007-02-16 A | 100% | 2007-02-16 | 2007-02-16 | 1d? | start no earlier than 2007-02-16 | S1; S2 | 16h | 16h | AGNSS | Alcatel | richard.couty@space.alcatel.fr | Rel-7 | Alain |  | AGNSS |  |  |  |  |
| 4173 | 1095.2 | Towards AGNSS Concept | 811.2d? | 2004-06-28 A | 2007-08-31 A | 100% | 2004-06-28 | 2007-08-31 | 811.2d? | finish no earlier than 2007-08-31 | GP | 6489.6h | 6489.6h | AGNSS-GP | Alcatel | richard.couty@space.alcatel.fr | Rel-7 | Paolo |  | AGNSS-GP |  |  |  |  |
| 4174 | 1095.3 | Global Navigation Satellite System (GNSS) in UTRAN | 383d? | 2005-12-15 A | 2007-06-04 A | 100% | 2005-12-15 | 2007-06-04 | 383d? | finish no earlier than 2007-06-04 | R2 | 3064h | 3064h | LCS3-GNSS-UTRAN | France Telecom | alain.abinakhoul@francetelecom.com | Rel-7 | Yong-Jun |  | LCS3-GNSS-UTRAN |  |  | RP-070482 |  |
| 4175 | 1096 | A-GPS Minimum Performance | 351d? | 2006-04-28 A | 2007-08-31 A | 100% | 2006-04-28 | 2007-08-31 | 351d? | finish no earlier than 2007-08-31 | G1; G3 | 5616h | 5616h | GAGR | Spirent | richard.catmur@spirentcom.com | Rel-7 | Paolo |  | GAGR |  |  |  |  |
| 4176 | 1097 | **Unstructured Supplementary Service Data (USSD) message delivery and transfer to USIM** | 376d? | 2004-03-05 A | 2005-08-12 A | 100% | 2004-03-05 | 2005-08-12 | 376d? |  | S1; C6 | 8778.4h | 8778.4h | USSD-USIM | Axalto | Christophe Dubois (cdubois@axalto.com) | Rel-7 | Alain |  | USSD-USIM |  |  |  |  |
| 4177 | 1097.1 | Stage 1 for USSD message delivery and transfer to USIM | 152d? | 2004-03-18 A | 2004-10-15 A | 100% | 2004-03-18 | 2004-10-15 | 152d? | start no earlier than 2004-03-18 | S1 | 1216h | 1216h | USSD-USIM | Axalto | Christophe Dubois (cdubois@axalto.com) | Rel-7 | Alain |  |  |  |  |  |  |
| 4178 | 1097.2 | Alignment with requirements regarding USSD usage | 193.3d? | 2004-03-05 A | 2005-08-12 A | 100% | 2004-03-05 | 2005-08-12 | 193.3d? | finish no earlier than 2005-08-12 | C6 | 1546.4h | 1546.4h | USSD-USIM | Axalto | Christophe Dubois (cdubois@axalto.com) | Rel-7 | Xavier |  |  |  |  |  |  |

Notes:
- 4155: -
- 4156: - / Impacted TSs and TRs: new TR 22.935
- 4157: SP#41 TR withdrawn. All work transferred to specs / Impacted TSs and TRs: 23.837
- 4158: - / Impacted TSs and TRs: 23.234, 23.271, 23.167
- 4159: -
- 4160: -
- 4161: - / Impacted TSs and TRs: 22.146, 22.246, 22.228
- 4162: - / Impacted TSs and TRs: 25.211, 25.212, 25.213, 25.101, 25.104, 25.331, 25.433, 25.346, 25.306
- 4163: - / Impacted TSs and TRs: 25.346, 25.221, 25.222, 25.223, 25.224, 25.306, 25.331, 25.402, 25.433, 25.102, 25.105, 25.123
- 4164: - / Impacted TSs and TRs: 25.346, 25.221, 25.222, 25.223, 25.224, 25.306, 25.331, 25.402, 25.433, 25.102, 25.105, 25.123
- 4165: - / Impacted TSs and TRs: 29.061
- 4166: Linked to Rel-7 Feature UID_31084 (MBMSE)
- 4167: RP#41 completed / Impacted TSs and TRs: 34.108, 34.122, 34.123-1/2/3
- 4168: RP#45 completed / Impacted TSs and TRs: 34.108, 34.123-1
- 4169: RP#46 completed / Impacted TSs and TRs: 34.108, 34.109, 34.121-1, 34.121-2, 34.123-1, 34.123-2, 34.123-3
- 4170: - / Impacted TSs and TRs: 26.346, 26.946
- 4171: -
- 4172: - / Impacted TSs and TRs: 22.071, 23.271
- 4173: GP#36 completed / Impacted TSs and TRs: 43.030, 43.059, 44.031, 44.035, 44.071, 48.008, 48.018, 48.031, 49.031
- 4174: - / Impacted TSs and TRs: 25.305, 25.331, 25.306, 25.413, 25.423, 25.433, 25.453, 25.302, 25.215, 25.401, 25.402, 25.450, 25.452
- 4175: - / Impacted TSs and TRs: 45.005, 51.010
- 4176: -
- 4177: - / Impacted TSs and TRs: 22.090
- 4178: - / Impacted TSs and TRs: 31.111, 31.115, 31.130

| ID | WBS | Task | Type | Duration | Start | Finish | Complete | Baseline start | Baseline finish | Baseline duration | Constraint | Resources | Work | Actual work | Acronym | WI rapporteur name | WI rapporteur e-mail | Release | MCC resp | Acronym_3GU_Export | Impacted TSs and TRs | TSG stopped |
| --- | --- | --- | --- | --- | --- | --- | --- | --- | --- | --- | --- | --- | --- | --- | --- | --- | --- | --- | --- | --- | --- | --- |
| 4179 | 1098 | **Combinational Services** |  | 296d? | 2005-01-17 A | 2006-03-06 A | 100% | 2005-01-17 | 2006-03-06 | 296d? |  | S1; S2; C1; S4 | 14648h | 14648h | CSICS | TeliaSonera | Robert.Frank@teliasonera.com | Rel-7 | Alain | CSICS |  |  |
| 4180 | 1098.1 | Stage 1 for CSICS |  | 104d? | 2005-01-17 A | 2005-06-09 A | 100% | 2005-01-17 | 2005-06-09 | 104d? | start no earlier than 2005-01-17 | S1 | 832h | 832h | CSICS | TeliaSonera | Robert.Frank@teliasonera.com | Rel-7 | Alain |  | 22.279 |  |
| 4181 | 1098.2 | Stage 2 for CSICS |  | 130d? | 2005-01-17 A | 2005-07-15 A | 100% | 2005-01-17 | 2005-07-15 | 130d? | start no earlier than 2005-01-17 | S2 | 1040h | 1040h | CSICS | TeliaSonera | Robert.Frank@teliasonera.com | Rel-7 | Maurice |  | 23.279 |  |
| 4182 | 1098.3 | Stage 3 for CSICS CN aspects |  | 221d? | 2005-05-02 A | 2006-03-06 A | 100% | 2005-05-02 | 2006-03-06 | 221d? | finish no earlier than 2006-03-06 | C1 | 1768h | 1768h | CSICS | Vodafone | peter.dawes@vodafone.com | Rel-7 | Frederic |  | 24.879, 24.279, 24.229, 24.008 |  |
| 4183 | 1098.4 | Stage 3 for codec aspects |  | 192d? | 2005-03-15 A | 2005-12-07 A | 100% | 2005-03-15 | 2005-12-07 | 192d? | finish no earlier than 2005-12-07 | S4 | 1536h | 1536h | CSICS-Codec | Ericsson | Per.Frojdh@ericsson.com | Rel-7 | Paolo | CSICS-Codec | 26.141, 26.235 |  |
| 4184 | 1099 | **CAMEL Trunk Triggers** |  | 251d? | 2004-12-17 A | 2005-12-05 A | 100% | 2004-12-17 | 2005-12-05 | 251d? |  | S1; C4 | 8032h | 8032h | TTCAMEL | Nortel | Amar Deol (deola@nortelnetworks.com) | Rel-7 | Alain | TTCAMEL |  |  |
| 4185 | 1099.1 | Stage 1 for CAMEL Trunk Triggers |  | 251d? | 2004-12-17 A | 2005-12-05 A | 100% | 2004-12-17 | 2005-12-05 | 251d? |  | S1 | 2008h | 2008h | TTCAMEL | Nortel | Amar Deol (deola@nortelnetworks.com) | Rel-7 | Alain |  | 22.078 |  |
| 4186 | 1099.2 | CAMEL Trunk Originated Trigger Detection Points |  | 251d? | 2004-12-17 A | 2005-12-05 A | 100% | 2004-12-17 | 2005-12-05 | 251d? | start no earlier than 2004-12-17 | C4 | 2008h | 2008h | CamelR7 | Nortel | David Hutton (dhutton@nortel.com) | Rel-7 | Kimmo | CamelR7 |  |  |
| 4187 | 1100 | **IMS Service Brokering enhancements** |  | 69d? | 2005-12-07 A | 2006-03-13 A | 100% | 2005-12-07 | 2006-03-13 | 69d? |  | S1 | 1104h | 1104h | ISB | Telcordia | jbakker@telcordia.com | Rel-7 | Alain | ISB | 22.228 |  |
| 4188 | 1100.1 | Stage 1 for ISB |  | 69d? | 2005-12-07 A | 2006-03-13 A | 100% | 2005-12-07 | 2006-03-13 | 69d? | finish no earlier than 2006-03-13 | S1 | 552h | 552h | ISB-s1 | Telcordia | jbakker@telcordia.com | Rel-7 | Alain | ISB-s1 | 22.228 |  |
| 4189 | 1101 | **Enhancements of VGCS for public authority officials** |  | 731d? | 2004-08-27 A | 2007-06-15 A | 100% | 2004-08-27 | 2007-06-15 | 731d? |  | S1; C1; C4; G2 | 49312h | 49312h | EVGCS |  |  | Rel-7 | Alain | EVGCS | 43.068, 44.068, 24.008, 29.002 |  |
| 4190 | 1101.1 | Stage 1 for Enhancements of VGCS for public authority officials | milestone | 0d? | 2004-08-27 A | 2004-08-27 A | 100% | 2004-08-27 | 2004-08-27 | 0d? | finish no earlier than 2004-08-27 | S1 |  |  | EVGCS | Siemens | joerg.swetina@neclab.eu | Rel-7 | Alain |  | 42.068, 43.068 |  |
| 4191 | 1101.2 | **Architecture and protocol aspects** |  | 731d? | 2004-08-27 A | 2007-06-15 A | 100% | 2004-08-27 | 2007-06-15 | 731d? |  | C1; C4 | 20752h | 20752h | EVGCS | Siemens | robert.zaus@nsn.com | Rel-7 | Frederic |  | 43.068, 44.068 |  |
| 4192 | 1101.2.1 | CT1 aspects of EVGCS |  | 731d? | 2004-08-27 A | 2007-06-15 A | 100% | 2004-08-27 | 2007-06-15 | 731d? | finish no earlier than 2006-09-15 | C1 | 5848h | 5848h | EVGCS | Siemens | robert.zaus@nsn.com | Rel-7 | Frederic |  | 43.068, 44.068, 24.008 |  |
| 4193 | 1101.2.2 | CT4 aspects of EVGCS |  | 401d? | 2004-08-27 A | 2006-03-10 A | 100% | 2004-08-27 | 2006-03-10 | 401d? | finish no earlier than 2006-03-10 | C4 | 3208h | 3208h | EVGCS | Siemens | robert.zaus@nsn.com | Rel-7 | Kimmo |  | 29.002 |  |
| 4194 | 1101.3 | GERAN2 aspects of EVGCS |  | 646d? | 2004-08-27 A | 2007-02-16 A | 100% | 2004-08-27 | 2007-02-16 | 646d? | finish no earlier than 2007-02-16 | G2 | 5168h | 5168h | EVGCS | Siemens | kenneth.isaacs@roke.co.uk | Rel-7 | Gert |  |  |  |
| 4195 | 1102 | **Improvements of VGCS for parallel use of services** |  | 523d? | 2005-03-15 A | 2007-03-15 A | 100% | 2005-03-15 | 2007-03-15 | 523d? |  | S1 | 12230.2h | 12230.2h | IVGCS |  |  | Rel-7 | Alain | IVGCS |  |  |
| 4196 | 1102.1 | Service Requirements for VGCS improvements |  | 62d? | 2005-03-15 A | 2005-06-08 A | 100% | 2005-03-15 | 2005-06-08 | 62d? | finish no earlier than 2005-06-08 | S1 | 496h | 496h | IVGCS | T-Mobile | kurt.bischinger@t-mobile.at | Rel-7 | Alain |  | 42.068 |  |
| 4197 | 1102.2 | Stage 2 modifications for VGCS improvements |  | 335d? | 2005-12-01 A | 2007-03-14 A | 100% | 2005-12-01 | 2007-03-14 | 335d? | start no earlier than 2005-12-01 | C1 | 2680h | 2680h | IVGCS | T-Mobile | kurt.bischinger@t-mobile.at | Rel-7 | Frederic |  | 43.068 |  |
| 4198 | 1102.3 | **Protocol aspects** |  | 336d? | 2005-12-01 A | 2007-03-15 A | 100% | 2005-12-01 | 2007-03-15 | 336d? |  | C1 | 5376h | 5376h | IVGCS | T-Mobile | Dieter Jacobsohn | Rel-7 | Frederic |  | 44.068 |  |
| 4199 | 1102.3.1 | CT1 aspects of IVGCS |  | 336d? | 2005-12-01 A | 2007-03-15 A | 100% | 2005-12-01 | 2007-03-15 | 336d? | finish no earlier than 2007-03-15 | C1 | 2688h | 2688h | IVGCS | T-Mobile |  | Rel-7 | Frederic |  | 43.068, 44.068 |  |
| 4200 | 1102.3.2 | Deleted - CT4 aspects of IVGCS | milestone | 0d? | 2007-03-09 A | 2007-03-09 A | 100% | 2007-03-09 | 2007-03-09 | 0d? | finish no earlier than 2007-03-09 | C4 |  |  | IVGCS-St3-c4 | T-mobile |  | Rel-7 | Kimmo | IVGCS-St3-c4 | 29.002 | CP-35 |
| 4201 | 1103 | **Open Service Access (OSA) Rel-7** |  | 584d? | 2005-03-15 A | 2007-06-08 A | 100% | 2005-03-15 | 2007-06-08 | 584d? |  | S1; C5 | 29776h | 29776h | OSA7 | AePONA | eamonn.murray@aepona.com | Rel-7 | Alain | OSA7 |  |  |
| 4202 | 1103.1 | **OSA Service Broker** |  | 449d? | 2005-03-15 A | 2006-12-01 A | 100% | 2005-03-15 | 2006-12-01 | 449d? |  | S1; C5 | 10176h | 10176h | OSA7-SB | AePONA | eamonn.murray@aepona.com | Rel-7 | Alain | OSA7-SB |  |  |
| 4203 | 1103.1.1 | Service Requirements for OSA Service Broker |  | 62d? | 2005-03-15 A | 2005-06-08 A | 100% | 2005-03-15 | 2005-06-08 | 62d? | finish no earlier than 2005-06-08 | S1 | 496h | 496h | OSA7 | AePONA | eamonn.murray@aepona.com | Rel-7 | Alain |  | 22.127 |  |
| 4204 | 1103.1.2 | Stage 2 OSA API Service Brokering |  | 156d? | 2006-04-28 A | 2006-12-01 A | 100% | 2006-04-28 | 2006-12-01 | 156d? |  | C5 | 1248h | 1248h | OSA7 | AePONA | damian.oneill@aepona.com | Rel-7 | Kimmo |  | 23.198 |  |
| 4205 | 1103.1.3 | Stage 3 OSA API Service Brokering |  | 156d? | 2006-04-28 A | 2006-12-01 A | 100% | 2006-04-28 | 2006-12-01 | 156d? | finish no earlier than 2006-12-01 | C5 | 1248h | 1248h | OSA7 | AePONA | damian.oneill@aepona.com | Rel-7 | Kimmo |  | 29.198-16 |  |

Notes:
- 4179: -
- 4180: -
- 4181: -
- 4182: -
- 4183: -
- 4184: -
- 4185: -
- 4186: -
- 4187: No CR submitted in rel-8 (according to CR database).
- 4188: No Rel-8 changes
- 4189: Moved from Rel-6 UID_50563 Enhancements of VGCS in public networks for communication of public authority officials
- 4190: Voice Group Call Service
- 4191: -
- 4192: -
- 4193: -
- 4194: -
- 4195: Voice Group Call Service
- 4196: -
- 4197: -
- 4198: Previous name (before CT32) was Architecture and protocol aspects
- 4199: -
- 4200: CT4#33 stage 2 solution is still open.
- 4201: -
- 4202: -
- 4203: -
- 4204: -
- 4205: -

| ID | WBS | Task | Type | Duration | Start | Finish | Complete | Baseline start | Baseline finish | Baseline duration | Constraint | Resources | Work | Actual work | Acronym | Impacted TSs and TRs | WI rapporteur name | WI rapporteur e-mail | Release | MCC resp | TSG approved | Acronym_3GU_Export | TSG stopped | Status Report |
| --- | --- | --- | --- | --- | --- | --- | --- | --- | --- | --- | --- | --- | --- | --- | --- | --- | --- | --- | --- | --- | --- | --- | --- | --- |
| 4206 | 1103.2 | **Rel-7 OSA Stage 2/3 enhancements** |  | 291d? | 2006-04-28 A | 2007-06-08 A | 100% | 2006-04-28 | 2007-06-08 | 291d? |  | C5 | 10256h | 10256h | OSA7 | 29.198/9, 23.198 | AePONA | damian.oneill@aepona.com | Rel-7 | Kimmo |  |  |  |  |
| 4207 | 1103.2.1 | Parlay X Message Broadcast Web Service |  | 156d? | 2006-04-28 A | 2006-12-01 A | 100% | 2006-04-28 | 2006-12-01 | 156d? | finish no earlier than 2006-12-01 | C5 | 1248h | 1248h | OSA7 | 29.199-15, 23.198 | ETRI |  | Rel-7 | Kimmo |  |  |  |  |
| 4208 | 1103.2.2 | Parlay X Geocoding Web Service |  | 156d? | 2006-04-28 A | 2006-12-01 A | 100% | 2006-04-28 | 2006-12-01 | 156d? | finish no earlier than 2006-12-01 | C5 | 1248h | 1248h | OSA7 | 29.199-16, 23.198 | ETRI |  | Rel-7 | Kimmo |  |  |  |  |
| 4209 | 1103.2.3 | Parlay X Application driven QoS Web Service |  | 226d? | 2006-04-28 A | 2007-03-09 A | 100% | 2006-04-28 | 2007-03-09 | 226d? | finish no earlier than 2007-03-09 | C5 | 1808h | 1808h | OSA7 | 29.199-17, 23.198 | BT |  | Rel-7 | Kimmo |  |  |  |  |
| 4210 | 1103.2.4 | Parlay-X Device Capabilities and Configuration |  | 162d? | 2006-10-26 A | 2007-06-08 A | 100% | 2006-10-26 | 2007-06-08 | 162d? | finish no earlier than 2007-06-09 | C5 | 1296h | 1296h | OSA7 | 29.199-18, 23.198 | Telenor |  | Rel-7 | Kimmo | TSG-34 |  |  |  |
| 4211 | 1103.2.5 | Parlay-X Multimedia Streaming Session Management Web Service |  | 97d? | 2006-10-26 A | 2007-03-09 A | 100% | 2006-10-26 | 2007-03-09 | 97d? | start no earlier than 2006-10-26 | C5 | 776h | 776h | OSA7 | 29.199-19, 23.198 | Telenor |  | Rel-7 | Kimmo | TSG-34 |  |  |  |
| 4212 | 1103.2.6 | Parlay-X Multimedia Multicast Control Web Service |  | 97d? | 2006-10-26 A | 2007-03-09 A | 100% | 2006-10-26 | 2007-03-09 | 97d? | start no earlier than 2006-10-26 | C5 | 776h | 776h | OSA7 | 29.199-20, 23.198 | ETRI |  | Rel-7 | Kimmo | TSG-34 |  |  |  |
| 4213 | 1103.2.7 | OSA API Conference Call Control SCF |  | 97d? | 2006-10-26 A | 2007-03-09 A | 100% | 2006-10-26 | 2007-03-09 | 97d? | start no earlier than 2006-10-26 | C5 | 776h | 776h | OSA7 | 29.198-04-5, 23.198 | Ericsson |  | Rel-7 | Kimmo | TSG-34 |  |  |  |
| 4214 | 1104 | **Selective Disabling of UE Capabilities** |  | 624.36d? | 2005-01-24 A | 2007-06-15 A | 100% | 2005-01-24 | 2007-06-15 | 624.36d? |  | S1; S2; C1 | 22341.5h | 22341.5h | SDoUE |  | Motorola |  | Rel-7 | Alain |  | SDoUE |  |  |
| 4215 | 1104.1 | Stage 1 of SDoUE |  | 393.6d? | 2005-01-24 A | 2006-12-08 A | 100% | 2005-01-24 | 2006-12-08 | 393.6d? | finish no earlier than 2006-12-08 | S1 | 3148.8h | 3148.8h | SDoUE-CR | 22.011 | Motorola |  | Rel-7 | Alain |  | SDoUE-CR |  |  |
| 4216 | 1104.2 | Deleted - TR on different possible architectures |  | 195d? | 2005-03-21 A | 2005-12-16 A | 100% | 2005-03-21 | 2005-12-16 | 195d? | finish no earlier than 2005-12-16 | S2 | 1560h | 1560h | SDoUE-FS | 23.805 abandonned at SP-30; descendant C1 24.305 | Vodafone | Gavin.Wong@vodafone.com | Rel-7 | Maurice |  | SDoUE-FS | SP-30 |  |
| 4217 | 1104.3 | Stage 3 of SDoUE |  | 331d? | 2006-03-10 A | 2007-06-15 A | 100% | 2006-03-10 | 2007-06-15 | 331d? | finish no earlier than 2007-06-15 | C1 | 2648h | 2648h | SDoUE | 24.305 | Ericsson | christian.herrero@ericsson.com | Rel-7 | Frederic |  |  |  |  |
| 4218 | 1105 | **Network selection enhancements (NSP)** |  | 328d? | 2006-03-15 A | 2007-06-15 A | 100% | 2006-03-15 | 2007-06-15 | 328d? |  | S1 | 6320h | 6320h | NSP |  | O2 | chris.friel@O2.com | Rel-7 | Alain |  | NSP |  |  |
| 4219 | 1105.1 | Stage 1 of NSP |  | 191d? | 2006-03-15 A | 2006-12-06 A | 100% | 2006-03-15 | 2006-12-06 | 191d? | start no earlier than 2006-03-15 | S1 | 1528h | 1528h | NSP-TS | 22.101, 22.011, 23.122, 24.008, 25.304, 31.102, 45.008 | O2 | chris.friel@O2.com | Rel-7 | Alain |  | NSP-TS |  |  |
| 4220 | 1105.2 | Procedural aspects of NSP |  | 271d? | 2006-06-02 A | 2007-06-15 A | 100% | 2006-06-02 | 2007-06-15 | 271d? | finish no earlier than 2007-06-15 | C1 | 2168h | 2168h | NSP-CR | 23.122, 24.008, 31.102 | Motorola | Andrew Howell | Rel-7 | Frederic |  | NSP-CR |  |  |
| 4221 | 1106 | Network selection enhancements (NSP) - UE Conformance Testing |  | 396d? | 2007-06-01 A | 2008-12-05 A | 100% | 2007-06-01 | 2008-12-05 | 396d? | finish no earlier than 2008-12-05 | R5 | 3168h | 3168h | NSP-CR_UEConTest | 34.108, 34.123-1, 34.123-2, 34.123-3 | Nokia | jarkko.hellsten@nokia.com | Rel-7 | Ingbert |  | NSP-CR_UEConTest |  | RP-080819 |
| 4222 | 1107 | **Access Class Barring and Overload Protection** |  | 650d? | 2004-03-15 A | 2006-09-08 A | 100% | 2004-03-15 | 2006-09-08 | 650d? |  | S2; C1 | 13968h | 13968h | ACBOP | 23.898 | Vodafone | chris.pudney@vodafone.com | Rel-7 | Maurice |  | ACBOP |  |  |
| 4223 | 1107.1 | TR on Stage 2 |  | 274d? | 2004-03-15 A | 2005-03-31 A | 100% | 2004-03-15 | 2005-03-31 | 274d? | finish no earlier than 2005-03-31 | S2 | 2192h | 2192h | ACBOP | 23.898 | NTT DoCoMo | Jean-Jacques Davidian (davidian@docomo.fr) | Rel-7 | Maurice |  |  |  |  |
| 4224 | 1107.2 | Stage 3 CN aspects of ACBOP |  | 172d? | 2005-06-06 A | 2006-01-31 A | 100% | 2005-06-06 | 2006-01-31 | 172d? | start no earlier than 2005-06-06 | C1 | 1376h | 1376h | ACBOP | 24.008 |  |  | Rel-7 | Frederic |  |  |  |  |
| 4225 | 1107.3 | Deleted - Potential impact on Iu interface Overload functionality | milestone | 0d? | 2004-03-15 A | 2004-03-15 A | 100% | 2004-03-15 | 2004-03-15 | 0d? | finish no earlier than 2004-03-15 | RP |  |  | ACBOP | 25.413 |  |  | Rel-7 | Issam |  |  | RP-25 |  |
| 4226 | 1107.4 | Deleted - Extra ACBOP information in RAN | milestone | 0d? | 2004-03-15 A | 2004-03-15 A | 100% | 2004-03-15 | 2004-03-15 | 0d? | finish no earlier than 2004-03-15 | RP |  |  | ACBOP | 25.331 |  |  | Rel-7 | Issam |  |  | RP-25 |  |
| 4227 | 1107.5 | Deleted - Extra ACBOP information in GERAN | milestone | 0d? | 2006-09-08 A | 2006-09-08 A | 100% | 2006-09-08 | 2006-09-08 | 0d? | start no earlier than 2006-09-08 | GP |  |  | ACBOP | 44.018 |  |  | Rel-7 | Paolo |  |  | RP-33 |  |
| 4228 | 1108 | **System enhancements for Fixed Broadband access to IMS** |  | 2117d? | 2003-11-05 A | 2011-12-09 A | 100% | 2003-11-05 | 2011-12-09 | 2117d? |  | S2; S3; S5; C1; C3; C4; IETF | 369944h | 369944h | FBI |  |  |  | Rel-7 | Maurice |  | FBI |  |  |
| 4229 | 1108.1 | **TISPAN Rel 1 related aspects** |  | 2117d? | 2003-11-05 A | 2011-12-09 A | 100% | 2003-11-05 | 2011-12-09 | 2117d? |  | S2; S3; C1; C3; C4; IETF | 239320h | 239320h | FBI-TIS1 |  |  |  | Rel-7 | Maurice |  | FBI-TIS1 |  |  |
| 4230 | 1108.1.1 | Stage 2 of FBI for TISPAN R1 |  | 365d? | 2004-10-14 A | 2006-03-08 A | 100% | 2004-10-14 | 2006-03-08 | 365d? | start no earlier than 2004-10-14 | S2 | 2920h | 2920h |  |  |  |  | Rel-7 | Maurice |  |  |  |  |

Notes:
- 4206: CP#34 updated WID CP-060607=>CP-070200
- 4207: -
- 4208: -
- 4209: -
- 4210: -
- 4211: -
- 4212: -
- 4213: -
- 4214: Moved from FS section Feb 06
- 4215: Moved from FS section Feb 06
- 4216: Moved from FS section Feb 06. Abandoned at SP-30
- 4217: -
- 4218: -
- 4219: -
- 4220: -
- 4221: RP#42 completed. Testing for Feature UID_7041 (NSP-CR)
- 4222: -
- 4223: -
- 4224: -
- 4225: -
- 4226: -
- 4227: -
- 4228: -
- 4229: -
- 4230: -

| ID | WBS | Task | Duration | Start | Finish | Complete | Baseline start | Baseline finish | Baseline duration | Constraint | Resources | Work | Actual work | WI rapporteur name | WI rapporteur e-mail | Release | MCC resp | PCG approved | TSG approved | Acronym | Acronym_3GU_Export | Special Focus Doc | TSG stopped |
| --- | --- | --- | --- | --- | --- | --- | --- | --- | --- | --- | --- | --- | --- | --- | --- | --- | --- | --- | --- | --- | --- | --- | --- |
| 4231 | 1108.1.2 | **Protocol impact of FBI for TISPAN R1** | 2117d? | 2003-11-05 A | 2011-12-09 A | 100% | 2003-11-05 | 2011-12-09 | 2117d? |  | S3; C1; C3; C4; IETF | 133840h | 133840h | Siemens | peter.leis@nsn.com | Rel-7 | Frederic |  |  |  |  |  |  |
| 4232 | 1108.1.2.1 | (IETF) CT aspects of FBI for TISPAN R1 | 2117d? | 2003-11-05 A | 2011-12-09 A | 100% | 2003-11-05 | 2011-12-09 | 2117d? | start no earlier than 2003-11-05 | C1-IETF; C3-IETF | 33872h | 33872h | Roland Jesske |  | Rel-7 | Frederic | PCG-27 | CP-52 |  |  |  |  |
| 4233 | 1108.1.2.2 | CT1 aspects of FBI for TISPAN R1 | 802d? | 2003-11-05 A | 2006-11-30 A | 100% | 2003-11-05 | 2006-11-30 | 802d? | finish no earlier than 2006-11-30 | C1 | 6416h | 6416h | Siemens | peter.leis@nsn.com | Rel-7 | Frederic |  |  |  |  |  |  |
| 4234 | 1108.1.2.3 | CT3 aspects of FBI for TISPAN R1 | 808d? | 2003-11-05 A | 2006-12-08 A | 100% | 2003-11-05 | 2006-12-08 | 808d? | finish no earlier than 2006-12-08 | C3 | 6464h | 6464h | Siemens | peter.leis@nsn.com | Rel-7 | Adrian |  |  |  |  |  |  |
| 4235 | 1108.1.2.4 | CT4 aspects of FBI for TISPAN R1 | 301d? | 2006-01-13 A | 2007-03-09 A | 100% | 2006-01-13 | 2007-03-09 | 301d? | finish no earlier than 2007-03-09 | C4 | 2408h | 2408h | Siemens | peter.leis@nsn.com | Rel-7 | Kimmo |  |  | FBI-TIS1-st3-c4 | FBI-TIS1-st3-c4 |  |  |
| 4236 | 1108.1.3 | Security Enhancements for FBI | 118d? | 2005-06-28 A | 2005-12-08 A | 100% | 2005-06-28 | 2005-12-08 | 118d? | start no earlier than 2005-06-28 | S3 | 944h | 944h | Ericsson | Bengt.Sahlin@ericsson.com | Rel-7 | Mirko |  |  | FBI-ISE | FBI-ISE |  |  |
| 4237 | 1108.2 | **PacketCable Related aspects** | 291d? | 2006-02-01 A | 2007-03-14 A | 100% | 2006-02-01 | 2007-03-14 | 291d? |  | S2; S5; C1 | 12072h | 12072h | CableLabs | Bernie McKibben (b.mckibben@cablelabs.com) | Rel-7 | Maurice |  |  | FBI-PCBL | FBI-PCBL |  |  |
| 4238 | 1108.2.1 | Stage 1,2 of FBI for PacketCable | 228d? | 2006-02-01 A | 2006-12-15 A | 100% | 2006-02-01 | 2006-12-15 | 228d? | finish no earlier than 2006-12-15 | S2 | 1824h | 1824h | CableLabs | Bernie McKibben (b.mckibben@cablelabs.com) | Rel-7 | Maurice |  |  |  |  |  |  |
| 4239 | 1108.2.2 | Protocol impact of FBI for PacketCable | 228d? | 2006-05-01 A | 2007-03-14 A | 100% | 2006-05-01 | 2007-03-14 | 228d? | finish no earlier than 2007-03-15 | C1 | 1824h | 1824h |  |  | Rel-7 | Frederic |  |  |  |  |  |  |
| 4240 | 1108.2.3 | SA5 Charging aspects of FBI for PacketCable | 180d? | 2006-03-31 A | 2006-12-07 A | 100% | 2006-03-31 | 2006-12-07 | 180d? | finish no earlier than 2006-12-07 | S5 | 1440h | 1440h | CableLabs | Bernie McKibben (b.mckibben@cablelabs.com) | Rel-7 | Mirko |  |  | FBI-PCBL-CH | FBI-PCBL-CH |  |  |
| 4241 | 1109 | **Support of SMS over generic 3GPP IP access** | 696d? | 2004-10-14 A | 2007-06-14 A | 100% | 2004-10-14 | 2007-06-14 | 696d? |  | S2; C4; C1 | 37544h | 37544h | Huawei | zhangwenlin@huawei.com | Rel-7 | Maurice |  |  | SMSIP | SMSIP | WLAN |  |
| 4242 | 1109.1 | FS on SMSIP | 173d? | 2004-10-14 A | 2005-06-13 A | 100% | 2004-10-14 | 2005-06-13 | 173d? | start no earlier than 2004-10-14 | S2 | 1384h | 1384h | Huawei | zhangwenlin@huawei.com | Rel-7 | Maurice |  |  |  |  | WLAN |  |
| 4243 | 1109.2 | Stage 2 for SMSIP | 333d? | 2005-06-08 A | 2006-09-15 A | 100% | 2005-06-08 | 2006-09-15 | 333d? | finish no earlier than 2006-09-15 | S2 | 2664h | 2664h | Huawei | zhangwenlin@huawei.com | Rel-7 | Maurice |  |  |  |  | WLAN |  |
| 4244 | 1109.3 | **Stage 3 for SMSIP** | 527d? | 2005-06-08 A | 2007-06-14 A | 100% | 2005-06-08 | 2007-06-14 | 527d? |  | C4; C1 | 16792h | 16792h | Nokia | jari.jansson@nokia.com | Rel-7 | Kimmo |  |  | SMSIP-St3 | SMSIP-St3 | WLAN |  |
| 4245 | 1109.3.1 | CT1 aspects for SMSIP | 527d? | 2005-06-08 A | 2007-06-14 A | 100% | 2005-06-08 | 2007-06-14 | 527d? | finish no earlier than 2007-06-15 | C1 | 4216h | 4216h | Nokia | jari.jansson@nokia.com | Rel-7 | Frederic |  |  |  |  | WLAN |  |
| 4246 | 1109.3.2 | CT4 aspects for SMSIP | 518d? | 2005-06-08 A | 2007-06-01 A | 100% | 2005-06-08 | 2007-06-01 | 518d? | finish no earlier than 2007-06-01 | C4 | 4144h | 4144h | Nokia | jari.jansson@nokia.com | Rel-7 | Kimmo |  |  | SMSIP-St3-c4 | SMSIP-St3-c4 | WLAN |  |
| 4247 | 1110 | **Evolution of Policy Control and Charging** | 817d? | 2004-10-14 A | 2007-11-30 A | 100% | 2004-10-14 | 2007-11-30 | 817d? |  | S2; S5; C3; C1 | 54112h | 54112h | Nokia | balazs.bertenyi@nsn.com | Rel-7 | Maurice |  |  | PCC | PCC |  |  |
| 4248 | 1110.1 | Deleted - TR for PCC | 315d? | 2004-10-14 A | 2005-12-29 A | 100% | 2004-10-14 | 2005-12-29 | 315d? | finish no earlier than 2005-12-28 | S2 | 2520h | 2520h | Nokia | balazs.bertenyi@nsn.com | Rel-7 | Maurice |  |  |  |  |  | SP-33 |
| 4249 | 1110.2 | Stage 2 for PCC | 315d? | 2005-07-04 A | 2006-09-15 A | 100% | 2005-07-04 | 2006-09-15 | 315d? | finish no earlier than 2006-09-15 | S2 | 2520h | 2520h | Nokia | balazs.bertenyi@nsn.com | Rel-7 | Maurice |  |  |  |  |  |  |
| 4250 | 1110.3 | Evolution of policy control and flow based bearer level charging | 109d? | 2006-08-01 A | 2006-12-29 A | 100% | 2006-08-01 | 2006-12-29 | 109d? | start no earlier than 2006-08-01 | S2 | 872h | 872h | Nokia | balazs.bertenyi@nsn.com | Rel-7 | Maurice |  |  |  |  |  |  |
| 4251 | 1110.4 | SA5 Charging aspects of PCC | 316d? | 2006-03-31 A | 2007-06-15 A | 100% | 2006-03-31 | 2007-06-15 | 316d? | finish no earlier than 2007-06-15 | S5 | 2528h | 2528h | Orange | alain.bibas@orange-ft.com | Rel-7 | Mirko |  |  | PCC-CH | PCC-CH |  |  |
| 4252 | 1110.5 | Gx reference point for Policy and Charging Control | 521d? | 2005-12-02 A | 2007-11-30 A | 100% | 2005-12-02 | 2007-11-30 | 521d? | finish no earlier than 2007-09-14 | C3 | 4168h | 4168h | Siemens | Thomas.Belling@nsn.com | Rel-7 | Adrian |  |  | PCC-Gx | PCC-Gx |  |  |
| 4253 | 1110.6 | **Rx reference point for PCC CT3 aspects** | 521d? | 2005-12-02 A | 2007-11-30 A | 100% | 2005-12-02 | 2007-11-30 | 521d? |  | C3; C1 | 15360h | 15360h | Ericsson | j.javier.pastor@ericsson.com | Rel-7 | Adrian |  |  | PCC-Rx | PCC-Rx |  |  |
| 4254 | 1110.6.1 | PCC-Rx CT3 aspects | 521d? | 2005-12-02 A | 2007-11-30 A | 100% | 2005-12-02 | 2007-11-30 | 521d? | finish no earlier than 2007-09-14 | C3 | 4168h | 4168h | Ericsson | j.javier.pastor@ericsson.com | Rel-7 | Adrian |  |  | PCC-Rx-c3 | PCC-Rx-c3 |  |  |
| 4255 | 1110.6.2 | PCC-Rx CT1 aspects | 357d? | 2005-12-02 A | 2007-06-15 A | 100% | 2005-12-02 | 2007-06-15 | 357d? | finish no earlier than 2007-06-15 | C1 | 2856h | 2856h | Ericsson | j.javier.pastor@ericsson.com | Rel-7 | Frederic |  |  | PCC-Rx-Gx-c1 | PCC-Rx-Gx-c1 |  |  |

Notes:
- 4231: -
- 4232: CP#54 completed / Impacted TSs and TRs: RFC 6432 (was draft-jesske-dispatch-update3326-reason-responses)
- 4233: - / Impacted TSs and TRs: 24.819, 24.229
- 4234: - / Impacted TSs and TRs: 29.163, 29.209
- 4235: CT4#32: a set of CRs on FBI for cable labs / Impacted TSs and TRs: 29.229
- 4236: Duplicated entry ("ACCSEC2", "Access Security Enhancements", SP-040865) deleted by A.Sultan / Impacted TSs and TRs: 33.203
- 4237: -
- 4238: - / Impacted TSs and TRs: 22.228, 23.228
- 4239: -
- 4240: 03/2006 SP#31 WID approved / Impacted TSs and TRs: 32.240, 32.260, 32.298, 32.299
- 4241: SP#33 updated WID (removed MMS)
- 4242: SP#33 updated WID / Impacted TSs and TRs: 23.804
- 4243: SP#33 updated WID / Impacted TSs and TRs: 23.204
- 4244: CP#34 updated WID
- 4245: CP#34 updated WID / Impacted TSs and TRs: 23.040, 24.229
- 4246: CP#34 updated WID / Impacted TSs and TRs: 23.008, 29.002
- 4247: SP-29 approved WID. SP-31 updated WID adding SA5 charging. 23.125 will be discontinued from Rel-7.
- 4248: SP-30: S2 has no intention for TR completion / Impacted TSs and TRs: 23.803
- 4249: SP-29 approved WID. SP-31 updated WID. 23.125 will be discontinued from Rel-7. / Impacted TSs and TRs: 23.203
- 4250: SP-29 approved WID. SP-31 updated WID. 23.125 will be discontinued from Rel-7. / Impacted TSs and TRs: 23.207, 23.002, 23.228
- 4251: SP-31 updated WID with SA5 charging. / Impacted TSs and TRs: 32.250, 32.251, 32.298, 32.299
- 4252: - / Impacted TSs and TRs: 29.212 (not progressed to Rel-7: 29.210, 29.207, 29.208)
- 4253: WID approved at CP#30, Revised at CP#31, Revised at CP#33
- 4254: - / Impacted TSs and TRs: 29.213, 29.214 (not progressed to Rel-7: 29.209, 29.211)
- 4255: - / Impacted TSs and TRs: 24.229

| ID | WBS | Task | Type | Duration | Start | Finish | Complete | Baseline start | Baseline finish | Baseline duration | Constraint | Resources | Work | Actual work | Acronym | WI rapporteur name | WI rapporteur e-mail | Release | MCC resp | Special Focus Doc | Acronym_3GU_Export | Impacted TSs and TRs | TSG stopped | TSG approved |
| --- | --- | --- | --- | --- | --- | --- | --- | --- | --- | --- | --- | --- | --- | --- | --- | --- | --- | --- | --- | --- | --- | --- | --- | --- |
| 4256 | 1111 | **Voice Call Continuity between CS and IMS (incl. I-WLAN)** |  | 641d? | 2004-12-31 A | 2007-06-15 A | 100% | 2004-12-31 | 2007-06-15 | 641d? |  | S2; S1; S5; C1; C4 | 43592h | 43592h | VCC | Alcatel-Lucent | Keith Drage (drage@alcatel-lucent.com) | Rel-7 | Maurice | WLAN | VCC |  |  |  |
| 4257 | 1111.1 | TR for Voice Call Continuity between CS and IMS (incl. I-WLAN) |  | 245d? | 2004-12-31 A | 2005-12-08 A | 100% | 2004-12-31 | 2005-12-08 | 245d? | finish no earlier than 2005-12-08 | S2 | 1960h | 1960h |  | Alcatel-Lucent | andy.bennett@alcatel-lucent.com | Rel-7 | Maurice | WLAN |  | 23.806 |  |  |
| 4258 | 1111.2 | Stage 1 for Voice Call Continuity between CS and IMS (incl. I-WLAN) |  | 140d? | 2005-03-17 A | 2005-09-28 A | 100% | 2005-03-17 | 2005-09-28 | 140d? | finish no earlier than 2005-09-28 | S1 | 1120h | 1120h |  | Alcatel-Lucent | andy.bennett@alcatel-lucent.com | Rel-7 | Alain | WLAN |  | 22.101 |  |  |
| 4259 | 1111.3 | Stage 2 for Voice Call Continuity between CS and IMS (incl. I-WLAN) |  | 264d? | 2005-09-06 A | 2006-09-08 A | 100% | 2005-09-06 | 2006-09-08 | 264d? | finish no earlier than 2006-09-08 | S2 | 2112h | 2112h |  | Alcatel-Lucent | andy.bennett@alcatel-lucent.com | Rel-7 | Maurice | WLAN |  | 23.206 |  |  |
| 4260 | 1111.4 | SA5 Charging for Voice Call Continuity between CS and IMS (incl. I-WLAN) |  | 325d? | 2006-03-17 A | 2007-06-14 A | 100% | 2006-03-17 | 2007-06-14 | 325d? | finish no earlier than 2007-06-14 | S5 | 2600h | 2600h | VCC-CH | Orange | alain.bibas@orange-ft.com | Rel-7 | Mirko | WLAN | VCC-CH | 32.250, 32.260 |  |  |
| 4261 | 1111.5 | **Stage 3 for Voice Call Continuity between CS and IMS (incl. I-WLAN)** |  | 358d? | 2006-02-01 A | 2007-06-15 A | 100% | 2006-02-01 | 2007-06-15 | 358d? |  | C1; C4 | 10160h | 10160h |  | Alcatel-Lucent | Keith Drage (drage@alcatel-lucent.com) | Rel-7 | Frederic | WLAN |  |  |  |  |
| 4262 | 1111.5.1 | CT1 aspects of Stage 3 for Voice Call Continuity between CS and IMS (incl. I-WLAN) |  | 358d? | 2006-02-01 A | 2007-06-15 A | 100% | 2006-02-01 | 2007-06-15 | 358d? | finish no earlier than 2007-06-15 | C1 | 2864h | 2864h |  | Alcatel-Lucent | Keith Drage (drage@alcatel-lucent.com) | Rel-7 | Frederic | WLAN |  | 24.206, 24.216 |  |  |
| 4263 | 1111.5.2 | CT4 aspects of Stage 3 for Voice Call Continuity between CS and IMS (incl. I-WLAN) |  | 196d? | 2006-06-09 A | 2007-03-09 A | 100% | 2006-06-09 | 2007-03-09 | 196d? | start no earlier than 2006-06-09 | C4 | 1568h | 1568h | VCC-St3-c4 | Alcatel-Lucent | Keith Drage (drage@alcatel-lucent.com) | Rel-7 | Kimmo | WLAN | VCC-St3-c4 | 23.003 |  |  |
| 4264 | 1111.5.3 | Deleted - CT3 aspects of Stage 3 for Voice Call Continuity between CS and IMS (incl. I-WLAN) | milestone | 0d? | 2006-11-02 A | 2006-11-02 A | 100% | 2006-11-02 | 2006-11-02 | 0d? | finish no earlier than 2006-11-02 | C3 |  |  |  | Alcatel-Lucent | Keith Drage (drage@alcatel-lucent.com) | Rel-7 | Adrian | WLAN |  | 29.163 | CP-33 |  |
| 4265 | 1112 | **One Tunnel solution for optimization of Packet Data Traffic** |  | 418d? | 2006-03-27 A | 2007-10-31 A | 100% | 2006-03-27 | 2007-10-31 | 418d? |  | S2 | 7048h | 7048h | OPTUNEL | Nokia | antti.j.pasanen@nokia.com | Rel-7 | Maurice |  | OPTUNEL |  |  |  |
| 4266 | 1112.1 | Deleted - Study on Stage 2 for One Tunnel solution |  | 125d? | 2006-03-27 A | 2006-09-15 A | 100% | 2006-03-27 | 2006-09-15 | 125d? | finish no earlier than 2005-09-12 | S2 | 1000h | 1000h | OPTUNEL-Study | Nokia | antti.j.pasanen@nokia.com | Rel-7 | Maurice |  | OPTUNEL-Study | 23.809 | SP-34 |  |
| 4267 | 1112.2 | One Tunnel Deployment Guideline |  | 268d? | 2006-10-23 A | 2007-10-31 A | 100% | 2006-10-23 | 2007-10-31 | 268d? | finish no earlier than 2007-10-31 | S2 | 2144h | 2144h | OPTUNEL-Guide | Huawei | lan.liu@huawei.com | Rel-7 | Maurice |  | OPTUNEL-Guide | 23.919 |  | TSG-34 |
| 4268 | 1112.3 | Stage 2 specification for One Tunnel solution |  | 70d? | 2006-09-11 A | 2006-12-15 A | 100% | 2006-09-11 | 2006-12-15 | 70d? | finish no earlier than 2006-12-15 | S2 | 560h | 560h | OPTUNEL-Stage2 | Nokia | antti.j.pasanen@nokia.com | Rel-7 | Maurice |  | OPTUNEL-Stage2 | 23.060 |  |  |
| 4269 | 1113 | **CSI Terminating Session handling** |  | 267d? | 2006-06-08 A | 2007-06-15 A | 100% | 2006-06-08 | 2007-06-15 | 267d? |  | S2; C1 | 6864h | 6864h | CSItermS | Samsung | Osok Song | Rel-7 | Maurice |  | CSItermS |  |  |  |
| 4270 | 1113.1 | Stage 2 of CStermS |  | 192d? | 2006-06-08 A | 2007-03-02 A | 100% | 2006-06-08 | 2007-03-02 | 192d? | start no earlier than 2006-06-08 | S2 | 1536h | 1536h |  | Samsung | Osok Song | Rel-7 | Maurice |  |  | 23.279 |  | TSG-34 |
| 4271 | 1113.2 | Stage 3 of CStermS |  | 132d? | 2006-12-14 A | 2007-06-15 A | 100% | 2006-12-14 | 2007-06-15 | 132d? | finish no earlier than 2007-06-15 | C1 | 1056h | 1056h |  | Samsung | chenho.chin@samsung.com | Rel-7 | Frederic |  |  | 24.229, 24.279 |  | TSG-34 |
| 4272 | 1113.3 | Deleted - duplicated with UID 340015 -Stage 3 CSI Terminating Session handling | milestone | 0d? | 2007-03-09 A | 2007-03-09 A | 100% | 2007-03-09 | 2007-03-09 | 0d? | start no earlier than 2007-03-09 | C1 |  |  |  | Samsung | chenho.chin@samsung.com | Rel-7 | Frederic |  |  | 24.229, 24.179, 24.279 | CP-34 | TSG-34 |
| 4273 | 1114 | Liberty Alliance and 3GPP Security Interworking |  | 451d? | 2005-03-10 A | 2006-11-30 A | 100% | 2005-03-10 | 2006-11-30 | 451d? | finish no earlier than 2006-11-30 | S3 | 3608h | 3608h | LibSec | Nokia | Silke.Holtmanns@nokia.com | Rel-7 | Mirko |  | LibSec | 33.980 |  |  |
| 4274 | 1115 | Trust Requirements for Open Platforms in 3GPP |  | 499d? | 2005-01-03 A | 2006-11-30 A | 100% | 2005-01-03 | 2006-11-30 | 499d? | finish no earlier than 2006-11-30 | S3 | 3992h | 3992h | TrustOP | Nokia | Silke.Holtmanns@nokia.com | Rel-7 | Mirko |  | TrustOP | 33.905 |  |  |
| 4275 | 1116 | Development of UEA2 and UIA2 |  | 268d? | 2004-12-01 A | 2005-12-09 A | 100% | 2004-12-01 | 2005-12-09 | 268d? | finish no earlier than 2005-12-09 | S3 | 2144h | 2144h | AlgUEA2 | TeliaSonera | per.christoffersson@teliasonera.com | Rel-7 | Mirko |  | AlgUEA2 | 35.919, 35.215, 35.216, 35.217, 35.218 |  |  |
| 4276 | 1117 | Lawful Interception in the 3GPP Rel-7 architecture |  | 118d? | 2005-06-28 A | 2005-12-08 A | 100% | 2005-06-28 | 2005-12-08 | 118d? | start no earlier than 2005-06-28 | S3 | 944h | 944h | LI-7A | BMWI | berthold.wilhelm@regtp.de | Rel-7 | Mirko |  | LI-7A | 33.106, 33.107, 33.108 |  |  |
| 4277 | 1118 | Key establishment between a UICC and a terminal |  | 201.45d? | 2005-12-07 A | 2006-09-28 A | 100% | 2005-12-07 | 2006-09-28 | 201.45d? | finish no earlier than 2006-09-28 | S3 | 1611.6h | 1611.6h | KeyEstUTerm | Gemalto | mireille.pauliac@gemplus.com | Rel-7 | Mirko |  | KeyEstUTerm | 33.110 |  |  |
| 4278 | 1119 | NDS Authentication Framework Extension for Transport Layer Security |  | 50d? | 2006-09-28 A | 2006-12-06 A | 100% | 2006-09-28 | 2006-12-06 | 50d? | finish no earlier than 2006-09-28 | S3 | 400h | 400h | NDSAFTLS | Nokia | tiina.s.koskinen@nokia.com | Rel-7 | Mirko |  | NDSAFTLS | 33.310 |  |  |
| 4279 | 1120 | **Security enhancements** |  | 319d? | 2005-09-12 A | 2006-11-30 A | 100% | 2005-09-12 | 2006-11-30 | 319d? |  | S3; C1; C4 | 16376h | 16376h | SEC7 |  |  | Rel-7 | Mirko |  | SEC7 |  |  |  |
| 4280 | 1120.1 | HTTPS connection between a UICC and a NAF |  | 1d? | 2005-09-12 A | 2005-09-12 A | 100% | 2005-09-12 | 2005-09-12 | 1d? | start no earlier than 2005-09-12 | S3; C1 | 16h | 16h | SEC7-HSUN | Gemalto | JSeif@axalto.com, mireille.pauliac@gemplus.com | Rel-7 | Mirko |  | SEC7-HSUN | 33.918, 33.222, 24.109 |  |  |
| 4281 | 1120.2 | 2G GBA: 2G SIM usage in 3GPP GAA framework |  | 61d? | 2005-09-12 A | 2005-12-05 A | 100% | 2005-09-12 | 2005-12-05 | 61d? | finish no earlier than 2005-12-05 | S3 | 488h | 488h | SEC7-2GGBA | Nokia | Silke.Holtmanns@nokia.com | Rel-7 | Mirko |  | SEC7-2GGBA | 33.920, 33.220 |  |  |
| 4282 | 1120.3 | Generic Authentication Architecture usage extensions and optimizations |  | 319d? | 2005-09-12 A | 2006-11-30 A | 100% | 2005-09-12 | 2006-11-30 | 319d? | finish no earlier than 2006-11-30 | S3 | 2552h | 2552h | SEC7-GAA2 | Nokia | Silke.Holtmanns@nokia.com | Rel-7 | Mirko |  | SEC7-GAA2 | 33.220, 29.109, 24.109, (33.223 goes to R8) |  |  |

Notes:
- 4256: WID approved SP#27; updated SP#28; updated SP#32
- 4257: -
- 4258: -
- 4259: -
- 4260: 03/2006 SP#31 WID approved
- 4261: -
- 4262: -
- 4263: -
- 4264: -
- 4265: -
- 4266: TR for Info SP-33. SP-34: S2 Report intention to discontinue TR
- 4267: -
- 4268: -
- 4269: Triggered by the abandoned Study UID_32117
- 4270: -
- 4271: CP-34 approved WID. CP-35 updated WID
- 4272: CP-34 approved WID
- 4273: WID approved SP#27.
- 4274: WID approved SP#26.
- 4275: WID approved SP#26, Dependant on Funding Availability.
- 4276: -
- 4277: -
- 4278: TLS profile is moved to Rel-8
- 4279: -
- 4280: -
- 4281: -
- 4282: 33.223 goes to R8

| ID | WBS | Task | Duration | Start | Finish | Complete | Baseline start | Baseline finish | Baseline duration | Constraint | Resources | Work | Actual work | Acronym | WI rapporteur name | WI rapporteur e-mail | Release | MCC resp | Acronym_3GU_Export | Impacted TSs and TRs | PCG approved | TSG approved | TSG stopped |
| --- | --- | --- | --- | --- | --- | --- | --- | --- | --- | --- | --- | --- | --- | --- | --- | --- | --- | --- | --- | --- | --- | --- | --- |
| 4283 | 1120.4 | **SS7 TCAP security Gateway** | 241d? | 2005-09-12 A | 2006-08-14 A | 100% | 2005-09-12 | 2006-08-14 | 241d? |  | S3; C4 | 5664h | 5664h | SEC7-NDS-TCAPsec | Siemens | marc.blommaert.ext@nsn.com | Rel-7 | Mirko | SEC7-NDS-TCAPsec |  |  |  |  |
| 4284 | 1120.4.1 | SA3 aspects of SEC7-NDS-TCAPsec | 130d? | 2005-09-12 A | 2006-03-10 A | 100% | 2005-09-12 | 2006-03-10 | 130d? | finish no earlier than 2006-03-10 | S3 | 1040h | 1040h | SEC7-NDS-TCAPsec-SA3 | Siemens | marc.blommaert.ext@nsn.com | Rel-7 | Mirko | SEC7-NDS-TCAPsec-SA3 | 33.204 |  |  |  |
| 4285 | 1120.4.2 | TCAPsec Gateway | 96d? | 2006-04-03 A | 2006-08-14 A | 100% | 2006-04-03 | 2006-08-14 | 96d? | start no earlier than 2006-04-01 | C4 | 768h | 768h | SEC7-TCAP | Siemens | Ulrich.wiehe@gksag.de | Rel-7 | Kimmo | SEC7-TCAP | 29.204, 29.002 |  |  |  |
| 4286 | 1121 | IMS Stage 3 IETF Protocol Alignment | 589d? | 2004-12-10 A | 2007-03-14 A | 100% | 2004-12-10 | 2007-03-14 | 589d? | finish no earlier than 2007-03-15 | C1 | 4712h | 4712h | IMSProtoc |  |  | Rel-7 | Frederic | IMSProtoc | 24.930 | PCG-36 | TSG#71 |  |
| 4287 | 1122 | **Interoperability between VGCS/VBS and A/Gb flexibility** | 253d? | 2006-03-22 A | 2007-03-09 A | 100% | 2006-03-22 | 2007-03-09 | 253d? |  | C1; C4 | 7344h | 7344h | VGCSFlex | Siemens | robert.zaus@nsn.com | Rel-7 | Frederic | VGCSFlex |  |  |  |  |
| 4288 | 1122.1 | CT1 aspects of VGCSFlex | 159d? | 2006-03-22 A | 2006-10-30 A | 100% | 2006-03-22 | 2006-10-30 | 159d? | finish no earlier than 2006-10-30 | C1 | 1272h | 1272h |  | Siemens | robert.zaus@nsn.com | Rel-7 | Frederic |  | 43.068, 43.069 |  |  |  |
| 4289 | 1122.2 | CT4 aspects of VGCSFlex | 253d? | 2006-03-22 A | 2007-03-09 A | 100% | 2006-03-22 | 2007-03-09 | 253d? | finish no earlier than 2007-03-09 | C4 | 2024h | 2024h | VGCSFlex-c4 | Siemens | robert.zaus@nsn.com | Rel-7 | Kimmo | VGCSFlex-c4 | 29.002 |  |  |  |
| 4290 | 1123 | DIAMETER on the GGSN Gi interface | 586d? | 2004-09-10 A | 2006-12-08 A | 100% | 2004-09-10 | 2006-12-08 | 586d? | finish no earlier than 2006-12-08 | C3 | 4688h | 4688h | DIAMGi | Vodafone | Nico.Gabriele@vodafone.com | Rel-7 | Adrian | DIAMGi | 29.061 |  |  |  |
| 4291 | 1124 | DIAMETER on the PDG Wi interface | 586d? | 2004-09-10 A | 2006-12-08 A | 100% | 2004-09-10 | 2006-12-08 | 586d? | finish no earlier than 2006-12-08 | C3 | 4688h | 4688h | DIAMWi | Vodafone | Nico.Gabriele@vodafone.com | Rel-7 | Adrian | DIAMWi | 29.161 |  |  |  |
| 4292 | 1125 | Interworking between the 3GPP CS domain with BICC or ISUP as signalling protocol and external SIP-I networks | 478d? | 2006-09-22 A | 2008-07-22 A | 100% | 2006-09-22 | 2008-07-22 | 478d? | finish no earlier than 2007-09-14 | C3 | 3824h | 3824h | ExtSIPI | Siemens | Thomas.Belling@nsn.com | Rel-7 | Adrian | ExtSIPI | 29.164 |  |  |  |
| 4293 | 1126 | PDU multiplexing at Nb Interface with IP transport | 427d? | 2006-12-04 A | 2008-07-22 A | 100% | 2006-12-04 | 2008-07-22 | 427d? | start no earlier than 2006-12-04 | C3 | 3416h | 3416h | NbIPMux | Alcatel-Lucent | Jean.Rzeznik@alcatel-lucent.fr | Rel-7 | Adrian | NbIPMux | 29.414 |  | TSG-34 |  |
| 4294 | 1127 | **Mp (MRFC - MRFP) interface** | 345d? | 2006-02-13 A | 2007-06-08 A | 100% | 2006-02-13 | 2007-06-08 | 345d? |  | C4; C1 | 9904h | 9904h | Mp | Ericsson | philip.hodges@ericsson.com | Rel-7 | Kimmo | Mp |  |  |  |  |
| 4295 | 1127.1 | CT1 aspects of Mp | 1d | 2006-02-13 A | 2006-02-13 A | 100% | 2006-02-13 | 2006-02-13 | 1d | finish no earlier than 2006-02-13 | C1 | 8h | 8h |  | Ericsson | philip.hodges@ericsson.com | Rel-7 | Frederic |  | 24.229 |  |  |  |
| 4296 | 1127.2 | Deleted - CT3 aspects of Mp | 1d | 2006-09-22 A | 2006-09-22 A | 100% | 2006-09-22 | 2006-09-22 | 1d | start no earlier than 2006-09-22 | C3 | 8h | 8h |  | Ericsson | philip.hodges@ericsson.com | Rel-7 | Adrian |  | 29.162 |  |  | CP-33 |
| 4297 | 1127.3 | Procedures description | 201d? | 2006-06-02 A | 2007-03-09 A | 100% | 2006-06-02 | 2007-03-09 | 201d? | finish no earlier than 2007-03-09 | C4 | 1608h | 1608h | Mp-PROCc4 | Huawei | Chencheng@huawei.com | Rel-7 | Kimmo | Mp-PROCc4 | 23.333 |  |  |  |
| 4298 | 1127.4 | Stage 3 for Mp (MRFC - MRFP) interface | 345d | 2006-02-13 A | 2007-06-08 A | 100% | 2006-02-13 | 2007-06-08 | 345d | finish no earlier than 2007-06-08 | C4 | 2760h | 2760h | Mp-St3c4 | Ericsson | philip.hodges@ericsson.com | Rel-7 | Kimmo | Mp-St3c4 | 29.333 |  |  |  |
| 4299 | 1128 | Routeing of MT-SMS via the HPLMN | 71d? | 2006-12-01 A | 2007-03-09 A | 100% | 2006-12-01 | 2007-03-09 | 71d? | finish no earlier than 2007-03-09 | C4; C1 | 1136h | 1136h | SMSviaH | Vodafone | Nick.Russell@vodafone.com | Rel-7 | Kimmo | SMSviaH | 23.040, 29.002 |  | TSG-34 |  |
| 4300 | 1129 | Mobile Termination whilst the MS is moving to another MSC | 60d? | 2007-03-09 A | 2007-05-31 A | 100% | 2007-03-09 | 2007-05-31 | 60d? | start no earlier than 2007-03-09 | C4 | 480h | 480h | MTmovMS | Alcatel-Lucent | bruno.landais@alcatel-lucent.fr | Rel-7 | Kimmo | MTmovMS | 23.008, 23.012, 23.018, 23.078, 23.079, 29.002 |  |  |  |
| 4301 | 1130 | ISIM API for Java Card | 620d? | 2005-03-14 A | 2007-07-27 A | 100% | 2005-03-14 | 2007-07-27 | 620d? | finish no earlier than 2007-07-27 | C6 | 4960h | 4960h | APIJAVA | Sun | Sebastian Hans | Rel-7 | Xavier | APIJAVA | 31.103, 102 241 |  |  |  |
| 4302 | 1131 | Rel-7 (U)SIM API Testing (TS 31.213) | 211d? | 2009-05-30 A | 2010-03-19 A | 100% | 2009-05-30 | 2010-03-19 | 211d? | finish no earlier than 2010-03-12 | C6 | 1688h | 1688h | USIM_API_Test | Sagem Orga | gerrit.hartbrod@sagem-orga.com | Rel-7 | Xavier | USIM_API_Test | 31.213 | PCG-23 | CP-44 |  |
| 4303 | 1132 | High speed interface between the UICC and the ME | 311d? | 2006-09-22 A | 2007-11-30 A | 100% | 2006-09-22 | 2007-11-30 | 311d? | finish no earlier than 2007-11-30 | C6 | 2488h | 2488h | HSI | Gemalto | jacques.seif@GEMALTO.COM | Rel-7 | Xavier | HSI | 31.101 |  |  |  |
| 4304 | 1133 | Video Codec Performance Requirements | 634d? | 2005-01-03 A | 2007-06-07 A | 100% | 2005-01-03 | 2007-06-07 | 634d? | finish no earlier than 2007-06-07 | S4 | 5072h | 5072h | VICPer | Siemens | juergen.pandel@siemens.com | Rel-7 | Paolo | VICPer | 26.234, 26.235, 26.346, 26.140, 26.902 |  |  |  |
| 4305 | 1134 | Dynamic and Interactive Multimedia Scenes | 583d? | 2005-03-15 A | 2007-06-07 A | 100% | 2005-03-15 | 2007-06-07 | 583d? | finish no earlier than 2007-06-07 | S4 | 4664h | 4664h | DIMS | Streamezzo | gaelle.martin-cocher@streamezzo.com | Rel-7 | Paolo | DIMS | 26.140, 26.142, 26.234, 26.244, 23.346 |  |  |  |
| 4306 | 1135 | 3G-324M Video Telephony Call Setup Times Improvements | 341d? | 2005-06-08 A | 2006-09-27 A | 100% | 2005-06-08 | 2006-09-27 | 341d? | finish no earlier than 2006-09-27 | S4 | 2728h | 2728h | VTCSTI | Vodafone | edward.hall@vodafone.co.uk | Rel-7 | Paolo | VTCSTI | 26.911 |  |  |  |

Notes:
- 4283: -
- 4284: -
- 4285: -
- 4286: TR 24.930: Signalling flows for the session setup in the IM CN subsystem based on Session Initiation Protocol (SIP)
- 4287: Voice Group Call Service
- 4288: -
- 4289: -
- 4290: -
- 4291: -
- 4292: -
- 4293: -
- 4294: -
- 4295: -
- 4296: CP#34: CT3 not involved in Mp interface definition
- 4297: -
- 4298: -
- 4299: WID approved in CP#34
- 4300: -
- 4301: -
- 4302: CP#47 completed. Update of Rel-6 (U)SIM API for Java Card Testing UID_43007 under Rel-6 UICC/USIM enhancements and interworking UID_1800
- 4303: Following ETSI publication of TS 102 600, expected to be completed at CT6 meeting 45
- 4304: -
- 4305: -
- 4306: -

| ID | WBS | Task | Duration | Start | Finish | Complete | Baseline start | Baseline finish | Baseline duration | Constraint | Resources | Work | Actual work | Acronym | WI rapporteur name | WI rapporteur e-mail | Release | MCC resp | Acronym_3GU_Export | TSG stopped |
| --- | --- | --- | --- | --- | --- | --- | --- | --- | --- | --- | --- | --- | --- | --- | --- | --- | --- | --- | --- | --- |
| 4307 | 1136 | **Optimizations for Multimedia Telephony over IMS** | 2d? | 2005-09-28 A | 2005-09-29 A | 100% | 2005-09-28 | 2005-09-28 | 0d? |  | S4 | 32h | 32h | OMTIMS | Ericsson | olle.franceschi@ericsson.com | Rel-7 | Paolo | OMTIMS |  |
| 4308 | 1136.1 | Deleted - Characterisation of Adaptive Jitter Management Performance for VoIP Services | 2d? | 2005-09-28 A | 2005-09-29 A | 100% | 2005-09-28 | 2005-09-28 | 0d? | finish no earlier than 2005-09-29 | S4 | 16h | 16h | OMTIMS-CAJMP | Lucent | dhuo@lucent.com | Rel-7 | Paolo | OMTIMS-CAJMP | SP-35 |
| 4309 | 1137 | End-to-End Multimedia Services Performance Metrics | 382d? | 2005-09-28 A | 2007-03-15 A | 100% | 2005-09-28 | 2007-03-15 | 382d? | finish no earlier than 2007-03-15 | S4 | 3056h | 3056h | E2EMSPM | China Mobile | zhangyanyf@chinamobile.com | Rel-7 | Paolo | E2EMSPM |  |
| 4310 | 1138 | Packet Switched Streaming Enhancements | 261d? | 2006-06-08 A | 2007-06-07 A | 100% | 2006-06-08 | 2007-06-07 | 261d? | finish no earlier than 2007-06-07 | S4 | 2088h | 2088h | PSSe | Ericsson | olle.franceschi@ericsson.com | Rel-7 | Paolo | PSSe |  |
| 4311 | 1139 | **Rel-7 Operations, Administration, Maintenance and Provisioning (OAM&P)** | 472.86d? | 2005-09-02 A | 2007-06-26 A | 100% | 2005-09-02 | 2007-06-26 | 472.86d? |  | S5 | 82725.8h | 82725.8h | OAM7 | Huawei | Christian.Toche@huawei.com | Rel-7 | Mirko | OAM7 |  |
| 4312 | 1139.1 | **Rel-7 Network Infrastructure Management** | 465d? | 2005-09-02 A | 2007-06-14 A | 100% | 2005-09-02 | 2007-06-14 | 465d? |  | S5 | 41800h | 41800h | OAM7-NIM |  |  | Rel-7 | Mirko | OAM7-NIM |  |
| 4313 | 1139.1.1 | Enhance NRM to accommodate NGN (IMS as basis of the Next Generation Network) | 465d? | 2005-09-02 A | 2007-06-14 A | 100% | 2005-09-02 | 2007-06-14 | 465d? | finish no earlier than 2007-06-14 | S5 | 3720h | 3720h |  | Motorola |  | Rel-7 | Mirko |  |  |
| 4314 | 1139.1.2 | Co-operative Element Management interface (CO-OP) (Study + Implementation) | 400d? | 2005-09-02 A | 2007-03-15 A | 100% | 2005-09-02 | 2007-03-15 | 400d? | finish no earlier than 2007-03-15 | S5 | 3200h | 3200h |  | Motorola |  | Rel-7 | Mirko |  |  |
| 4315 | 1139.1.3 | Network Management (NM) Itf-N performance criteria | 465d? | 2005-09-02 A | 2007-06-14 A | 100% | 2005-09-02 | 2007-06-14 | 465d? | finish no earlier than 2007-06-14 | S5 | 3720h | 3720h |  | China Mobile |  | Rel-7 | Mirko |  |  |
| 4316 | 1139.1.4 | Delta synchronization between IRP Manager and IRP Agent (Study + Implementation) | 465d? | 2005-09-02 A | 2007-06-14 A | 100% | 2005-09-02 | 2007-06-14 | 465d? | finish no earlier than 2007-06-14 | S5 | 3720h | 3720h |  | Siemens |  | Rel-7 | Mirko |  |  |
| 4317 | 1139.1.5 | Subscription Management (SuM) IRP Solution Sets | 330d? | 2005-09-02 A | 2006-12-07 A | 100% | 2005-09-02 | 2006-12-07 | 330d? | finish no earlier than 2006-12-07 | S5 | 2640h | 2640h |  | Ericsson |  | Rel-7 | Mirko |  |  |
| 4318 | 1139.1.6 | Integration Reference Point (IRP) Security Management | 400d? | 2005-09-02 A | 2007-03-15 A | 100% | 2005-09-02 | 2007-03-15 | 400d? | finish no earlier than 2007-03-15 | S5 | 3200h | 3200h |  | Huawei | Christian.Toche@huawei.com | Rel-7 | Mirko |  |  |
| 4319 | 1139.1.7 | Partial suspension of Itf-N during maintenance/testing (Study + Implementation) | 465d? | 2005-09-02 A | 2007-06-14 A | 100% | 2005-09-02 | 2007-06-14 | 465d? | finish no earlier than 2007-06-14 | S5 | 3720h | 3720h |  | Siemens |  | Rel-7 | Mirko |  |  |
| 4320 | 1139.1.8 | Deleted - Management of Legacy Equipment | 336d? | 2005-09-02 A | 2006-12-15 A | 100% | 2005-09-02 | 2006-12-15 | 336d? | finish no earlier than 2006-12-15 | S5 | 2688h | 2688h |  | Siemens |  | Rel-7 | Mirko |  | SP-35 |
| 4321 | 1139.1.9 | Deleted - Rules for Vendor Specific Extensions | 400d? | 2005-09-02 A | 2007-03-15 A | 100% | 2005-09-02 | 2007-03-15 | 400d? | finish no earlier than 2007-03-15 | S5 | 3200h | 3200h |  | Siemens |  | Rel-7 | Mirko |  | SP-35 |
| 4322 | 1139.1.10 | Backward and Forward Compatibility of IRP systems | 465d? | 2005-09-02 A | 2007-06-14 A | 100% | 2005-09-02 | 2007-06-14 | 465d? | finish no earlier than 2007-06-14 | S5 | 3720h | 3720h |  | Ericsson |  | Rel-7 | Mirko |  |  |
| 4323 | 1139.1.11 | Repeater Network Resource Model (NRM) definition | 214d? | 2006-02-13 A | 2006-12-07 A | 100% | 2006-02-13 | 2006-12-07 | 214d? | finish no earlier than 2006-12-07 | S5 | 1712h | 1712h |  | China Mobile |  | Rel-7 | Mirko |  |  |
| 4324 | 1139.1.12 | UTRAN radio channel power monitoring | 284d? | 2006-02-13 A | 2007-03-15 A | 100% | 2006-02-13 | 2007-03-15 | 284d? | finish no earlier than 2007-03-15 | S5 | 2272h | 2272h |  | China Mobile |  | Rel-7 | Mirko |  |  |
| 4325 | 1139.1.13 | Notification XML Schema | 71d? | 2006-12-07 A | 2007-03-15 A | 100% | 2006-12-07 | 2007-03-15 | 71d? | finish no earlier than 2007-03-15 | S5 | 568h | 568h |  | Huawei | Christian.Toche@huawei.com | Rel-7 | Mirko |  |  |
| 4326 | 1139.2 | **Rel-7 Performance Management** | 465d? | 2005-09-02 A | 2007-06-14 A | 100% | 2005-09-02 | 2007-06-14 | 465d? |  | S5 | 22992h | 22992h | OAM7-PM |  |  | Rel-7 | Mirko | OAM7-PM |  |
| 4327 | 1139.2.1 | Performance measurements definition for CN CS | 400d? | 2005-09-02 A | 2007-03-15 A | 100% | 2005-09-02 | 2007-03-15 | 400d? | finish no earlier than 2007-03-15 | S5 | 3200h | 3200h |  | China Mobile |  | Rel-7 | Mirko |  |  |
| 4328 | 1139.2.2 | Enhancement UTRAN performance measurements definition | 465d? | 2005-09-02 A | 2007-06-14 A | 100% | 2005-09-02 | 2007-06-14 | 465d? | finish no earlier than 2007-06-14 | S5 | 3720h | 3720h |  | China Mobile |  | Rel-7 | Mirko |  |  |
| 4329 | 1139.2.3 | Add TDD specific counters in Performance measurement | 330d? | 2005-09-02 A | 2006-12-07 A | 100% | 2005-09-02 | 2006-12-07 | 330d? | finish no earlier than 2006-12-15 | S5 | 2640h | 2640h |  | CATT |  | Rel-7 | Mirko |  |  |
| 4330 | 1139.2.4 | ATM bearer network Performance measurements | 400d? | 2005-09-02 A | 2007-03-15 A | 100% | 2005-09-02 | 2007-03-15 | 400d? | finish no earlier than 2007-03-15 | S5 | 3200h | 3200h |  | ZTE |  | Rel-7 | Mirko |  |  |
| 4331 | 1139.2.5 | Performance measurements definition for IMS | 465d? | 2005-09-02 A | 2007-06-14 A | 100% | 2005-09-02 | 2007-06-14 | 465d? | finish no earlier than 2007-06-14 | S5 | 3720h | 3720h |  | China Mobile |  | Rel-7 | Mirko |  |  |
| 4332 | 1139.2.6 | HSDPA performance measurements | 349d? | 2006-02-13 A | 2007-06-14 A | 100% | 2006-02-13 | 2007-06-14 | 349d? | finish no earlier than 2007-06-14 | S5 | 2792h | 2792h |  | China Mobile |  | Rel-7 | Mirko |  |  |

Notes:
- 4307: Aug2015: 99%->100 / Impacted TSs and TRs: 26.235, 26.236
- 4308: SP-35 stopped
- 4309: - / Impacted TSs and TRs: 26.944
- 4310: - / Impacted TSs and TRs: 26.234, 26.244
- 4311: OAM7 is an umbrella Feature also for OAM&P related TEI7 type of changes that are not part of any other dedicated feature/WI / Impacted TSs and TRs: TR 30.817
- 4312: -
- 4313: - / Impacted TSs and TRs: 32.731/2/3/5, 32.631/2/3/5
- 4314: - / Impacted TSs and TRs: 32.806, 32.814, 32.101
- 4315: - / Impacted TSs and TRs: 32.811
- 4316: - / Impacted TSs and TRs: 32.391/2/3/5
- 4317: - / Impacted TSs and TRs: 32.307/317/607/667/665, 32.101, 32.175
- 4318: - / Impacted TSs and TRs: 32.372/3/5, 32.111,32.30x,32.32x,32.33x,32.34x,32.35x,32.36x,32.41x,32.60x,32.61x,32.66x
- 4319: - / Impacted TSs and TRs: 32.381/2/3/5
- 4320: Request to TSG#35 to STOP the WI / Impacted TSs and TRs: new 32.xxx
- 4321: Request to TSG#35 to STOP the WI / Impacted TSs and TRs: 32.62n; For n = 1 to 5
- 4322: - / Impacted TSs and TRs: 32.154
- 4323: - / Impacted TSs and TRs: 32.721/2/3/5
- 4324: - / Impacted TSs and TRs: 32.405, 32.64n; For n = 1 to 5
- 4325: 12/2006 SP#34 WID approved / Impacted TSs and TRs: New 32.325/345/365/415, CR to 32.335/615/665
- 4326: -
- 4327: - / Impacted TSs and TRs: 32.407, 32.408
- 4328: - / Impacted TSs and TRs: 32.405
- 4329: - / Impacted TSs and TRs: 32.405
- 4330: - / Impacted TSs and TRs: No impact on 32.404, 32.405, 32.406, 32.407
- 4331: - / Impacted TSs and TRs: 32.404,32.409,32.437, 32.632/3/4/5
- 4332: - / Impacted TSs and TRs: 32.405

| ID | WBS | Task | Type | Duration | Start | Finish | Complete | Baseline start | Baseline finish | Baseline duration | Constraint | Resources | Work | Actual work | Acronym | WI rapporteur name | Release | MCC resp | Acronym_3GU_Export | TSG stopped | WI rapporteur e-mail | Status Report |
| --- | --- | --- | --- | --- | --- | --- | --- | --- | --- | --- | --- | --- | --- | --- | --- | --- | --- | --- | --- | --- | --- | --- |
| 4333 | 44.5 | **Rel-7 Trace Management** |  | 472.86d? | 2005-09-02 A | 2007-06-26 A | 100% | 2005-09-02 | 2007-06-26 | 472.86d? |  | S5 | 14150.9h | 14150.9h | OAM7-Trace | Vodafone | Rel-7 | Mirko | OAM7-Trace |  |  |  |
| 4334 | 1139.3.1 | End-to-end Service Level tracing for IMS |  | 350d? | 2005-11-11 A | 2007-03-15 A | 100% | 2005-11-11 | 2007-03-15 | 350d? | finish no earlier than 2007-03-15 | S5 | 2800h | 2800h |  | Vodafone | Rel-7 | Mirko |  | SP-31 |  |  |
| 4335 | 1139.3.2 | Trace record content for UTRAN TDD |  | 330d? | 2005-09-02 A | 2006-12-07 A | 100% | 2005-09-02 | 2006-12-07 | 330d? | finish no earlier than 2006-12-07 | S5 | 2640h | 2640h |  | Nokia | Rel-7 | Mirko |  |  |  |  |
| 4336 | 1139.3.3 | IRP for Subscriber and Equipment Trace Management |  | 465d? | 2005-09-02 A | 2007-06-14 A | 100% | 2005-09-02 | 2007-06-14 | 465d? | finish no earlier than 2007-06-14 | S5 | 3720h | 3720h |  | Nokia | Rel-7 | Mirko |  |  |  |  |
| 4337 | 1139.3.4 | Deleted - SIP enhancements for trace | milestone | 0d? | 2007-06-15 A | 2007-06-26 A | 100% | 2007-06-15 | 2007-06-26 | 0d? | start no earlier than 2007-06-15 | C1 |  |  |  |  | Rel-7 | Frederic |  | CP-32 |  |  |
| 4338 | 1139.3.5 | Deleted - duplicated with UID 35063 - IRP for Subscriber and Equipment Trace Management |  | 336d? | 2005-09-02 A | 2006-12-15 A | 100% | 2005-09-02 | 2006-12-15 | 336d? | finish no earlier than 2006-12-15 | S5 | 2688h | 2688h |  | Nokia | Rel-7 | Mirko |  | SP-33 |  |  |
| 4339 | 1140 | **Rel-7 Charging Management small Enhancements** |  | 279d? | 2006-05-22 A | 2007-06-14 A | 100% | 2006-05-22 | 2007-06-14 | 279d? |  | S5 | 5952h | 5952h | CH7 | Orange | Rel-7 | Mirko | CH7 |  | alain.bibas@orange-ft.com |  |
| 4340 | 1140.1 | Alternate Charged Party (ACP) for IMS |  | 279d? | 2006-05-22 A | 2007-06-14 A | 100% | 2006-05-22 | 2007-06-14 | 279d? | finish no earlier than 2007-06-14 | S5 | 2232h | 2232h | CH7-IMS-ACP | Lucent | Rel-7 | Mirko | CH7-IMS-ACP |  | njmazzarella@alcatel-lucent.com |  |
| 4341 | 1140.2 | Align 3GPP Charging with OMA PoC Enabler Release 2.0 |  | 186d? | 2006-09-28 A | 2007-06-14 A | 100% | 2006-09-28 | 2007-06-14 | 186d? | finish no earlier than 2007-06-14 | S5 | 1488h | 1488h | CH7-PoC | Siemens | Rel-7 | Mirko | CH7-PoC |  | Gerald.Goermer@nsn.com |  |
| 4342 | 8.5 | **Multiple-Input Multiple-Output (MIMO) antennas** |  | 1301d? | 2003-03-14 A | 2008-03-07 A | 100% | 2003-03-14 | 2008-03-07 | 1301d? |  | R1; R5 | 55848h | 55848h | MIMO | Alcatel-Lucent | Rel-7 | Patrick | MIMO |  | hchuang@Alcatel-Lucent.com |  |
| 4343 | 1141.1 | MIMO - Physical layer |  | 915d? | 2003-09-12 A | 2007-03-15 A | 100% | 2003-09-12 | 2007-03-15 | 915d? | finish no earlier than 2007-03-15 | R1 | 7320h | 7320h | MIMO-Phys | Alcatel-Lucent | Rel-7 | Patrick | MIMO-Phys |  | hchuang@Alcatel-Lucent.com | RP-070037 |
| 4344 | 1141.2 | MIMO - Layer 2,3 aspects |  | 915d? | 2003-09-12 A | 2007-03-15 A | 100% | 2003-09-12 | 2007-03-15 | 915d? | finish no earlier than 2007-03-15 | R2 | 7320h | 7320h | MIMO-L23 | Alcatel-Lucent | Rel-7 | Yong-Jun | MIMO-L23 |  | hchuang@Alcatel-Lucent.com | RP-070037 |
| 4345 | 1141.3 | MIMO - Iub/Iur Protocol Aspects |  | 1045d? | 2003-03-14 A | 2007-03-15 A | 100% | 2003-03-14 | 2007-03-15 | 1045d? | finish no earlier than 2007-03-15 | R3 | 8360h | 8360h | MIMO-IurIub | Alcatel-Lucent | Rel-7 | Juha | MIMO-IurIub |  | hchuang@Alcatel-Lucent.com | RP-070037 |
| 4346 | 1141.4 | MIMO - RF Radio Transmission/Reception, System Performance Requirements and Conformance Testing |  | 982d? | 2003-12-12 A | 2007-09-17 A | 100% | 2003-12-12 | 2007-09-17 | 982d? | finish no earlier than 2007-09-17 | R4 | 7856h | 7856h | MIMO-RF | Alcatel-Lucent | Rel-7 | Issam | MIMO-RF |  | ngm@Alcatel-Lucent.com | RP-070531 |
| 4347 | 1141.5 | **UE Conformance Testing for Multiple Input Multiple Output antennas (MIMO)** |  | 261d? | 2007-03-09 A | 2008-03-07 A | 100% | 2007-03-09 | 2008-03-07 | 261d? |  | R5 | 4176h | 4176h | MIMO-UEConTest | Qualcomm | Rel-7 | Ingbert | MIMO-UEConTest |  | svora@qualcomm.com |  |
| 4348 | 1141.5.1 | Conformance Test Aspects – Multiple Input Multiple Output Antennas (MIMO) for FDD |  | 261d? | 2007-03-09 A | 2008-03-07 A | 100% | 2007-03-09 | 2008-03-07 | 261d? | finish no earlier than 2008-03-07 | R5 | 2088h | 2088h | MIMO-UEConTest_FDD | Qualcomm | Rel-7 | Ingbert | MIMO-UEConTest_FDD |  | svora@qualcomm.com |  |
| 4349 | 1142 | **Rel-7 Improvements of the Radio Interface** |  | 709d? | 2004-09-15 A | 2007-06-04 A | 100% | 2004-09-15 | 2007-06-04 | 709d? |  | RP; GP | 40520h | 40520h |  |  | Rel-7 | Issam |  |  |  |  |
| 4350 | 1142.1 | Extended UMTS 1.7/2.1 GHz |  | 198d? | 2006-03-15 A | 2006-12-15 A | 100% | 2006-03-15 | 2006-12-15 | 198d? | finish no earlier than 2006-12-15 | R4 | 1584h | 1584h | RInImp-UMTS1721Ext | Ericsson | Rel-7 | Issam | RInImp-UMTS1721Ext |  | johan.skold@ericsson.com | RP-060681 |
| 4351 | 1142.2 | UMTS 2.6 GHz 7.68 Mcps TDD |  | 67d? | 2006-06-15 A | 2006-09-15 A | 100% | 2006-06-15 | 2006-09-15 | 67d? | finish no earlier than 2006-09-15 | R4 | 536h | 536h | RInImp-UMTS26VHCRTDD | IPWireless | Rel-7 | Issam | RInImp-UMTS26VHCRTDD |  | Shin Horng Wong (shwong@ipwireless.com) | RP-060451 |
| 4352 | 1142.3 | UMTS 2.6 GHz |  | 195d? | 2004-09-15 A | 2005-06-14 A | 100% | 2004-09-15 | 2005-06-14 | 195d? | finish no earlier than 2005-06-14 | R4 | 1560h | 1560h | RInImp-UMTS2600 | Nokia | Rel-7 | Issam | RInImp-UMTS2600 |  | jussi.numminen@nokia.com | RP-050184 |
| 4353 | 1142.4 | UMTS 2.6 GHz TDD |  | 261d? | 2004-12-15 A | 2005-12-14 A | 100% | 2004-12-15 | 2005-12-14 | 261d? | finish no earlier than 2005-12-15 | R4 | 2088h | 2088h | RInImp-UMTS2600TDD | IPWireless | Rel-7 | Issam | RInImp-UMTS2600TDD |  | Shin Horng Wong (shwong@ipwireless.com) | RP-050661 |
| 4354 | 1142.5 | UMTS 900 MHz |  | 261d? | 2004-12-15 A | 2005-12-14 A | 100% | 2004-12-15 | 2005-12-14 | 261d? | finish no earlier than 2005-12-15 | R4 | 2088h | 2088h | RInImp-UMTS900 | Nortel | Rel-7 | Issam | RInImp-UMTS900 |  | Yannick Li (yli@nortelnetworks.com) | RP-050662 |
| 4355 | 1142.6 | UMTS 1700 MHz |  | 197d? | 2005-03-15 A | 2005-12-14 A | 100% | 2005-03-15 | 2005-12-14 | 197d? | finish no earlier than 2005-12-15 | R4 | 1576h | 1576h | RInImp-UMTS1700 | NTT DoCoMo | Rel-7 | Issam | RInImp-UMTS1700 |  | Takehiro Nakamura (nakamurata@nttdocomo.co.jp) | RP-050824 |
| 4356 | 1142.7 | UE Antenna Performance Evaluation Method and Requirements |  | 644d? | 2004-12-15 A | 2007-06-04 A | 100% | 2004-12-15 | 2007-06-04 | 644d? | finish no earlier than 2007-06-04 | R4; GP | 10304h | 10304h | RInImp-UEAnt | TeliaSonera | Rel-7 | Issam | RInImp-UEAnt |  | Christian.Bergljung@TeliaSonera.com | RP-070281 |
| 4357 | 1142.8 | Improved Performance Requirements for HSDPA UE based on Rx Diversity (type 1) & LMMSE equalizer (type 2) | milestone | 0d? | 2005-03-15 A | 2005-03-15 A | 100% | 2005-03-15 | 2005-03-15 | 0d? | finish no earlier than 2005-03-15 | R4 |  |  | RInImp-HSPerf-Type3 | Cingular | Rel-7 | Issam | RInImp-HSPerf-Type3 |  | Marc Grant | RP-060015 |

Notes:
- 4333: -
- 4334: 07/2005: OMA (Stage 1), Stage 2/3 SA5, CT1/3/4 / Impacted TSs and TRs: 32.101, 32.421, 32.422, 32.423
- 4335: - / Impacted TSs and TRs: 32.421, 32.422, 32.423
- 4336: - / Impacted TSs and TRs: 32.441, 32.442, 32.443, 32.445, 32.632, 32.633, 32.635
- 4337: combined with UID 11067
- 4338: - / Impacted TSs and TRs: 32.421,32.422,32.423. 3 new 32.4x1,2,3
- 4339: CH7 is an umbrella Feature also for OAM&P related TEI7 type of changes that are not part of any other dedicated feature/WI / Impacted TSs and TRs: TR 30.817
- 4340: - / Impacted TSs and TRs: 32.240, 32.260, 32.298, 32.299
- 4341: 09/2006 SP#33 WID approved / Impacted TSs and TRs: 32.240, 32.272, 32.299, 32.298
- 4342: Completed Sep 2007; SR in RP-070037and RP-070531 / Impacted TSs and TRs: 25.876, 25.996
- 4343: Completed Sep 2007; SR in RP-070037 / Impacted TSs and TRs: 25.211, 25.212, 25.213, 25.214, 25.215, 25.221
- 4344: Completed Sep 2007; SR in RP-070037 / Impacted TSs and TRs: 25.876
- 4345: Completed Sep 2007; SR in RP-070037
- 4346: Completed Sep 2007; SR in RP-070531
- 4347: BB place holder for a number of RAN5 Tasks
- 4348: - / Impacted TSs and TRs: TS 34.108, TS 34.109, TS 34.121-1, TS 34.121-2, TS 34.123-1, TS 34.123-2, TS 34.123-3
- 4349: Generic feature
- 4350: RP#34 completed. Introduction of Band X (Extended UMTS 1.7/2.1 GHz) in 25.307 / Impacted TSs and TRs: 25.806, 25.101, 25.104, 25.133, 24.141, 25.331, 25.306, 25.307, 25.423, 25.461, 25.463, 34.121
- 4351: RP#33 completed / Impacted TSs and TRs: 25.102, 25.105, 25.123, 25.113, 25.142, 34.124
- 4352: RP#28 completed / Impacted TSs and TRs: 25.101, 25.104, 25.133, 25.141, 25.331, 25.942, 25.306, 25.307, 34.121
- 4353: RP#30 completed / Impacted TSs and TRs: 25.102, 25.105, 25.113, 25.123, 25.142, 25.331, 25.942, 25.306, 25.307, 34.122, 34.124
- 4354: RP#30 completed / Impacted TSs and TRs: 25.101, 25.104, 25.113, 25.133, 25.141, 25.331, 25.942, 25.306, 25.307, 34.121
- 4355: RP#30 completed / Impacted TSs and TRs: 25.101, 25.104, 25.113, 25.133, 25.141, 25.306, 25.307, 25.331, 34.121
- 4356: RP#36 completed / Impacted TSs and TRs: 25.101, new TR (25.914, 25.963)
- 4357: RP#27 completed / Impacted TSs and TRs: 25.101

| ID | WBS | Task | Type | Duration | Start | Finish | Complete | Baseline start | Baseline finish | Baseline duration | Constraint | Deadline | Resources | Work | Actual work | Acronym | WI rapporteur name | WI rapporteur e-mail | Release | MCC resp | Acronym_3GU_Export | Status Report | TSG stopped | PCG stopped | Created at |
| --- | --- | --- | --- | --- | --- | --- | --- | --- | --- | --- | --- | --- | --- | --- | --- | --- | --- | --- | --- | --- | --- | --- | --- | --- | --- |
| 4358 | 1142.9 | **Additional minimum UE performance requirement for non-HSDPA channels based on type 1 enhanced receiver (Rx Diversity)** |  | 327d? | 2005-09-15 A | 2006-12-15 A | 100% | 2005-09-15 | 2006-12-15 | 327d? |  |  | R4 | 7344h | 7344h | RInImp-RxDiv | Qualcomm | Serge Willenegger (sergew@qualcomm.com) | Rel-7 | Issam | RInImp-RxDiv |  |  |  |  |
| 4359 | 1142.9.1 | Additional minimum UE performance requirement for DL physical channels in support of DCH/HS-DSCH operation based on type 1 enhanced receiver (RX-Diversity) |  | 195d? | 2005-09-15 A | 2006-06-14 A | 100% | 2005-09-15 | 2006-06-14 | 195d? | finish no earlier than 2006-06-15 |  | R4 | 1560h | 1560h | RInImp-RxDiv-DCH | Cingular | Marc Grant | Rel-7 | Issam | RInImp-RxDiv-DCH | RP-060235 |  |  |  |
| 4360 | 1142.9.2 | Additional minimum UE performance requirement for downlink physical channels in support of MTCH and MCCH operation based on type 1 enhanced receiver (Rx-Diversity) |  | 198d? | 2006-03-15 A | 2006-12-15 A | 100% | 2006-03-15 | 2006-12-15 | 198d? | finish no earlier than 2006-12-15 |  | R4 | 1584h | 1584h | RInImp-RxDiv-MBMS | Qualcomm | Serge Willenegger (sergew@qualcomm.com) | Rel-7 | Issam | RInImp-RxDiv-MBMS | RP-060678 |  |  |  |
| 4361 | 1142.9.3 | Additional minimum UE performance requirement for downlink physical channels in support of E-DCH operation based on type 1 enhanced receiver (Rx-Diversity) |  | 198d? | 2006-03-15 A | 2006-12-15 A | 100% | 2006-03-15 | 2006-12-15 | 198d? | finish no earlier than 2006-12-15 |  | R4 | 1584h | 1584h | RInImp-RxDiv-EDCH | Qualcomm | Serge Willenegger (sergew@qualcomm.com) | Rel-7 | Issam | RInImp-RxDiv-EDCH | RP-060679 |  |  |  |
| 4362 | 1142.10 | Deleted Improved support of gaming over HSDPA/EDCH |  | 262d? | 2005-12-15 A | 2006-12-15 A | 100% | 2005-12-15 | 2006-12-15 | 262d? | finish no earlier than 2006-12-15 |  | R2 | 2096h | 2096h | RInImp-Gaming | Cingular | Don Zelmer (dz1069@att.com) | Rel-7 | Yong-Jun | RInImp-Gaming | RP-060680 | RP-34 |  |  |
| 4363 | 1142.11 | Deleted (not approved at PCG) - UMTS 2.6 GHz FDD DL External | milestone | 0d? | 2005-09-15 A | 2005-09-15 A | 100% | 2005-09-15 | 2005-09-15 | 0d? | finish no earlier than 2005-09-15 |  | R4 |  |  | RInImp-UMTS2600Ext | T-mobile | han.van.bussel@t-mobile.de | Rel-7 | Issam | RInImp-UMTS2600Ext |  | RP-31 | PCG-16 |  |
| 4364 | 1143 | **Rel-7 Improvements of the Radio Interface - UE Conformance Testing** |  | 741d? | 2005-11-11 A | 2008-09-12 A | 100% | 2005-11-11 | 2008-09-12 | 741d? |  |  | R5 | 17568h | 17568h |  |  |  | Rel-7 | Ingbert |  |  |  |  |  |
| 4365 | 16.5.1 | UE Conformance Test for UMTS 2600 MHz |  | 146d | 2005-11-11 A | 2006-06-02 A | 100% | 2005-11-11 | 2006-06-02 | 146d | finish no earlier than 2006-06-02 | 2006-06-02 | R5 | 1168h | 1168h | RInImp-UMTS2600_Test | Nokia | Aleksi.Heino@nokia.com | Rel-7 | Ingbert | RInImp-UMTS2600_Test |  |  |  | Fri 7/11/05 |
| 4366 | 16.5.1 | UE Conformance Test for UMTS 900 MHz (band VIII) |  | 146d | 2005-11-11 A | 2006-06-02 A | 100% | 2005-11-11 | 2006-06-02 | 146d | finish no earlier than 2006-06-02 | 2006-06-02 | R5 | 1168h | 1168h | RInImp-UMTS900_Test | Qualcomm | hanye@qualcomm.com | Rel-7 | Ingbert | RInImp-UMTS900_Test |  |  |  | Fri 11/03/05 |
| 4367 | 1143.3 | Conformance Test Aspects – Improved Performance of HSDPA Receiver type 3 |  | 191d? | 2006-03-10 A | 2006-12-01 A | 100% | 2006-03-10 | 2006-12-01 | 191d? | finish no earlier than 2006-12-01 |  | R5 | 1528h | 1528h | RInImp-HSPerf-Type3_Test | Motorola | carolyn.taylor@motorola.com | Rel-7 | Ingbert | RInImp-HSPerf-Type3_Test |  |  |  |  |
| 4368 | 1143.4 | UE antenna Over The Air (OTA) conformance testing |  | 518d? | 2006-09-20 A | 2008-09-12 A | 100% | 2006-09-20 | 2008-09-12 | 518d? | finish no earlier than 2008-09-12 |  | R5 | 4144h | 4144h | RInImp-UEAnt_Test | Nokia | Aleksi.Heino@nokia.com | Rel-7 | Ingbert | RInImp-UEAnt_Test | RP-080535 |  |  |  |
| 4369 | 1143.5 | UE conformance testing for FDD Inter-Band Operation |  | 131d? | 2006-06-02 A | 2006-12-01 A | 100% | 2006-06-02 | 2006-12-01 | 131d? | finish no earlier than 2006-12-01 |  | R5 | 1048h | 1048h | RInImp-InterBand_Test | NEC, Motorola | Jacob.John@motorola.com | Rel-7 | Ingbert | RInImp-InterBand_Test |  |  |  |  |
| 4370 | 1143.6 | Conformance Test Aspects – Extended UMTS 1.7/2.1 GHz |  | 131d? | 2006-12-01 A | 2007-06-01 A | 100% | 2006-12-01 | 2007-06-01 | 131d? | finish no earlier than 2007-06-01 |  | R5 | 1048h | 1048h | RInImp-UEConTest_UMTS1721Ext | Motorola | carolyn.taylor@motorola.com | Rel-7 | Ingbert | RInImp-UEConTest_UMTS1721Ext | RP-070312 |  |  |  |
| 4371 | 1143.7 | Conformance Test Aspects – Minimum UE performance requirement for downlink physical channels in support of E-DCH operation based on type 1 enhanced receiver (Rx-Diversity) |  | 136d? | 2007-06-01 A | 2007-12-07 A | 100% | 2007-06-01 | 2007-12-07 | 136d? | finish no earlier than 2007-12-07 |  | R5 | 1088h | 1088h | RInImp-UEConTest_RxDivEDCH | Motorola | carolyn.taylor@motorola.com | Rel-7 | Ingbert | RInImp-UEConTest_RxDivEDCH | RP-070810 |  |  |  |
| 4372 | 1143.8 | Conformance Test Aspects – Minimum UE performance requirement for downlink physical channels in support of MTCGH and MCCH operation based on type 1 enhanced receiver (Rx-Diversity) |  | 201d? | 2007-06-01 A | 2008-03-07 A | 100% | 2007-06-01 | 2008-03-07 | 201d? | finish no earlier than 2008-03-07 |  | R5 | 1608h | 1608h | RInImp-UEConTest_RxDivMBMS | Ericsson | leif.mattisson@ericsson.com | Rel-7 | Ingbert | RInImp-UEConTest_RxDivMBMS | RP-080056 |  |  |  |
| 4373 | 1144 | **Rel-7 RAN improvements** |  | 653d? | 2004-12-15 A | 2007-06-15 A | 100% | 2004-12-15 | 2007-06-15 | 653d? |  |  | RP; S5 | 39512h | 39512h |  |  |  | Rel-7 |  |  |  |  |  |  |
| 4374 | 1144.1 | Optimization of channelisation code utilisation for 1.28 Mcps TDD |  | 523d? | 2004-12-15 A | 2006-12-15 A | 100% | 2004-12-15 | 2006-12-15 | 523d? | finish no earlier than 2006-12-15 |  | R1 | 4184h | 4184h | RANimp-RABSE-CodOptLCRTDD | UTStarcom | Ka Leong Lo (kaleong.lo@UTSTAR.COM) | Rel-7 | Patrick | RANimp-RABSE-CodOptLCRTDD | RP-060682 |  |  |  |
| 4375 | 1144.2 | Delay optimization for procedures applicable to CS and PS Connections |  | 394d? | 2005-03-15 A | 2006-09-15 A | 100% | 2005-03-15 | 2006-09-15 | 394d? | finish no earlier than 2006-09-15 |  | R2 | 3152h | 3152h | RANimp-DelayOpt | Nokia | juho.pirskanen@nokia.com | Rel-7 | Yong-Jun | RANimp-DelayOpt | RP-060453 |  |  |  |
| 4376 | 1144.3 | Improved support of IMS Realtime Services using HSDPA/HSUPA |  | 197d? | 2005-03-15 A | 2005-12-14 A | 100% | 2005-03-15 | 2005-12-14 | 197d? | start no earlier than 2005-03-15 |  | R2 | 1576h | 1576h | RANimp-IMSRealTime | Cingular | Don Zelmer (dz1069@att.com) | Rel-7 | Yong-Jun | RANimp-IMSRealTime | RP-050667 |  |  |  |
| 4377 | 1144.4 | UE Performance Requirements for MBMS (TDD) |  | 328d? | 2005-03-15 A | 2006-06-15 A | 100% | 2005-03-15 | 2006-06-15 | 328d? | finish no earlier than 2006-06-15 |  | R4 | 2624h | 2624h | MBMS-RAN-RF-TDD | IPwireless | shwong@ipwireless.com | Rel-7 | Issam | MBMS-RAN-RF-TDD | RP-060477 |  |  |  |
| 4378 | 1144.5 | Continuous connectivity for packet data users |  | 524d? | 2005-03-14 A | 2007-03-15 A | 100% | 2005-03-14 | 2007-03-15 | 524d? | finish no earlier than 2007-03-15 |  | R1 | 4192h | 4192h | RANimp-CPC | Siemens | Joern.Krause@siemens.com | Rel-7 | Patrick | RANimp-CPC | RP-070033 |  |  |  |
| 4379 | 1144.6 | Extended WCDMA Cell Range |  | 198d? | 2006-03-15 A | 2006-12-15 A | 100% | 2006-03-15 | 2006-12-15 | 198d? | finish no earlier than 2006-12-15 |  | R3 | 1584h | 1584h | RANimp-ExtCell | Ericsson | Muhammad Kazmi | Rel-7 | Juha | RANimp-ExtCell | RP-060685 |  |  |  |
| 4380 | 1144.7 | 7.68 Mcps TDD Enhanced Uplink |  | 198d? | 2006-03-15 A | 2006-12-15 A | 100% | 2006-03-15 | 2006-12-15 | 198d? | finish no earlier than 2006-12-15 |  | R1 | 1584h | 1584h | RANimp-VHCRTDD-EDCH | IPwireless | nanderson@ipwireless.com | Rel-7 | Patrick | RANimp-VHCRTDD-EDCH | RP-060684 |  |  |  |
| 4381 | 1144.8 | Enhanced CELL_FACH State in FDD |  | 181d? | 2006-09-25 A | 2007-06-04 A | 100% | 2006-09-25 | 2007-06-04 | 181d? | finish no earlier than 2007-06-04 |  | R2 | 1448h | 1448h | RANimp-EnhState | Nokia | juho.pirskanen@nokia.com | Rel-7 | Yong-Jun | RANimp-EnhState | RP-070286 |  |  |  |
| 4382 | 1144.9 | 64QAM for HSDPA (FDD) |  | 110d? | 2006-12-15 A | 2007-06-04 A | 100% | 2006-12-15 | 2007-06-04 | 110d? | finish no earlier than 2007-06-04 |  | R1 | 880h | 880h | RANimp-64QamDownlink | Ericsson | Johan.Bergman@ericsson.com | Rel-7 | Patrick | RANimp-64QamDownlink | RP-070287 |  |  |  |
| 4383 | 1144.10 | Improved L2 support for high data rates |  | 122d? | 2006-12-15 A | 2007-06-04 A | 100% | 2006-12-15 | 2007-06-04 | 122d? | finish no earlier than 2007-06-04 |  | R2 | 976h | 976h | RANimp-L2DataRates | Ericsson | Janne.Peisa@ericsson.com | Rel-7 | Yong-Jun | RANimp-L2DataRates | RP-070289 |  |  |  |
| 4384 | 1144.11 | Introduction of 16QAM in HSUPA (FDD) |  | 110d? | 2006-12-15 A | 2007-06-04 A | 100% | 2006-12-15 | 2007-06-04 | 110d? | finish no earlier than 2007-06-04 |  | R1 | 880h | 880h | RANimp-16QamUplink | Nokia | Karri.Ranta-aho@nsn.com | Rel-7 | Patrick | RANimp-16QamUplink | RP-070288 |  |  |  |

Notes:
- 4358: - / Impacted TSs and TRs: 25.101
- 4359: RP#32 completed / Impacted TSs and TRs: 25.101
- 4360: RP#34 completed / Impacted TSs and TRs: 25.101
- 4361: RP#34 completed / Impacted TSs and TRs: 25.101
- 4362: RP#34 stopped. SR in RP-060680
- 4363: This item was conditionnaly approved pending decision of PCG#16 who decided not to approve it / Impacted TSs and TRs: 25.101, 25.104, 25.133, 25.141, 25.331, 25.942, 25.306, 25.307, 34.121
- 4364: Linked to Feature UID_20028 (RInImp)
- 4365: RP#32 completed / Impacted TSs and TRs: 34.108, 34.121
- 4366: RP#32 completed / Impacted TSs and TRs: 34.108, 34.121
- 4367: RP#34 completed / Impacted TSs and TRs: 34.121, 34.108
- 4368: RP#41 completed (GERAN aspects might need to be included later) / Impacted TSs and TRs: 34.114
- 4369: RP#34 completed / Impacted TSs and TRs: 34.108, 34.123-1, 34.123-2, 34.123-3
- 4370: RP#36 completed / Impacted TSs and TRs: 34.108, 34.121-1, 34.121-2
- 4371: RP#38 completed
- 4372: RP#39 completed / Impacted TSs and TRs: 34.121-1, 34.121-2
- 4373: Generic feature
- 4374: RP#34 completed
- 4375: RP#33 completed / Impacted TSs and TRs: 25.815, 25.321, 25.322, 25.331
- 4376: RP#30 completed
- 4377: RP#32 completed / Impacted TSs and TRs: 25.102, 25.123
- 4378: RP#35 completed / Impacted TSs and TRs: 25.903, 25.201, 25.211, 25.212, 25.214, 25.308, 25.321, 25.331, 25.423, 25.433, 25.101, 25.133
- 4379: RP#34 completed / Impacted TSs and TRs: 25.133, 25.423, 25.425, 25.433, 25.435, 25.453, 25.331
- 4380: RP#34 completed / Impacted TSs and TRs: 25.201, 25.202, 25.221, 25.222, 25.223, 25.224, 25.225, 25.331, 23.321, 25.306, 25.302, 25.401, 25.420, 25.423, 25.427, 25.433, 25.102, 25.105, 25.142
- 4381: RP#36 completed / Impacted TSs and TRs: 25.308, 25.304, 25.306, 25.321, 25.331, 25.433, 25.435, 25.423, 25.425,
- 4382: RP#36 completed / Impacted TSs and TRs: 25.308, 25.211, 25.212, 25.213, 25.306, 25.331, 25.433, 25.435, 25.423, 25.425, 25.101, 25.104, 25.141
- 4383: RP#36 completed / Impacted TSs and TRs: 25.301, 25.308,25.306, 25.321, 25.322, 25.331, 25.433, 25.435, 25.423, 25.425, 25.999
- 4384: RP#36 completed / Impacted TSs and TRs: 25.319, 25.101, 25.104, 25.133, 25.141, 25.211, 25.212, 25.213, 25.214, 25.306, 25.321, 25.331, 25.423, 25.433

| ID | WBS | Task | Duration | Start | Finish | Complete | Baseline start | Baseline finish | Baseline duration | Constraint | Resources | Work | Actual work | Acronym | WI rapporteur name | WI rapporteur e-mail | Release | MCC resp | Status Report | Acronym_3GU_Export | PCG approved | TSG approved |
| --- | --- | --- | --- | --- | --- | --- | --- | --- | --- | --- | --- | --- | --- | --- | --- | --- | --- | --- | --- | --- | --- | --- |
| 4385 | 1144.12 | **Interface to control Tower Mounted Amplifiers (TMAs)** | 271d? | 2006-06-02 A | 2007-06-15 A | 100% | 2006-06-02 | 2007-06-15 | 271d? |  | R3; S5 | 5984h | 5984h | RANImp-TMA | Vodafone | alexej.kulakov@vodafone.com | Rel-7 | Juha | RP-070140 | RANImp-TMA |  |  |
| 4386 | 1144.12.1 | RAN3 part of Interface to control Tower Mounted Amplifiers (TMAs) | 206d? | 2006-06-02 A | 2007-03-16 A | 100% | 2006-06-02 | 2007-03-16 | 206d? |  | R3 | 840h | 840h |  | Vodafone | alexej.kulakov@vodafone.com | Rel-7 | Juha | RP-070140 |  |  |  |
| 4387 | 1144.12.2 | OAM aspects to Interface to control TMAs | 101d? | 2007-01-26 A | 2007-06-15 A | 100% | 2007-01-26 | 2007-06-15 | 101d? | finish no earlier than 2007-06-15 | S5 | 808h | 808h | RANImp-TMA-OAM | Vodafone | Adrian.Neal@vodafone.com | Rel-7 | Mirko |  | RANImp-TMA-OAM |  |  |
| 4388 | 1145 | **Rel-7 RAN improvements - UE Conformance Testing** | 784d? | 2006-09-20 A | 2009-09-18 A | 100% | 2006-09-20 | 2009-09-18 | 784d? |  | R5 | 25472h | 25472h |  |  |  | Rel-7 | Ingbert |  |  |  |  |
| 4389 | 1145.1 | Conformance Test Aspects - 3.84 Mcps and 7.68 Mcps TDD Enhanced Uplink | 518d? | 2006-09-20 A | 2008-09-12 A | 100% | 2006-09-20 | 2008-09-12 | 518d? | finish no earlier than 2008-09-12 | R5 | 4144h | 4144h | RANimp-UEConTest_EDCHTDH | IPWireless | tspeight@ipwireless.com | Rel-7 | Ingbert | RP-080536 | RANimp-UEConTest_EDCHTDH |  |  |
| 4390 | 1145.2 | Conformance Test Aspects – 64QAM for HSDPA (FDD) | 257d? | 2007-03-09 A | 2008-03-03 A | 100% | 2007-03-09 | 2008-03-03 | 257d? | finish no earlier than 2008-03-03 | R5 | 2056h | 2056h | RANimp-UEConTest_64QamDownlink | Ericsson | leif.mattisson@ericsson.com | Rel-7 | Ingbert | RP-080059 | RANimp-UEConTest_64QamDownlink |  |  |
| 4391 | 1145.3 | Conformance Test Aspects – 16QAM for HSUPA (FDD) | 321d? | 2007-03-09 A | 2008-05-30 A | 100% | 2007-03-09 | 2008-05-30 | 321d? | finish no earlier than 2008-05-30 | R5 | 2568h | 2568h | RANimp-UEConTest_16QamUplink | Motorola | carolyn.taylor@motorola.com | Rel-7 | Ingbert | RP-080281 | RANimp-UEConTest_16QamUplink |  |  |
| 4392 | 1145.4 | Conformance Test Aspects – Improved L2 support for high data rates | 321d? | 2007-03-09 A | 2008-05-30 A | 100% | 2007-03-09 | 2008-05-30 | 321d? | finish no earlier than 2008-05-30 | R5 | 2568h | 2568h | RANimp-UEConTest_L2DataRates | Ericsson | leif.mattisson@ericsson.com | Rel-7 | Ingbert | RP-080256 | RANimp-UEConTest_L2DataRates |  |  |
| 4393 | 1145.5 | Conformance Test Aspects – Continuous connectivity for packet data users | 321d? | 2007-03-09 A | 2008-05-30 A | 100% | 2007-03-09 | 2008-05-30 | 321d? | finish no earlier than 2008-05-30 | R5 | 2568h | 2568h | RANimp-UEConTest_CPC | Nokia | jarkko.hellsten@nokia.com | Rel-7 | Ingbert | RP-080282 | RANimp-UEConTest_CPC |  |  |
| 4394 | 1145.6 | Conformance Test Aspects – Enhanced CELL_FACH state in FDD | 662d? | 2007-03-09 A | 2009-09-18 A | 100% | 2007-03-09 | 2009-09-18 | 662d? | finish no earlier than 2009-09-18 | R5 | 5296h | 5296h | RANimp-UEConTest_EnhancedCellFACHState | Nokia | jarkko.hellsten@nokia.com | Rel-7 | Ingbert | RP-090711 | RANimp-UEConTest_EnhancedCellFACHState |  |  |
| 4395 | 1146 | **7.68 Mcps TDD option** | 783d? | 2004-09-15 A | 2007-09-14 A | 100% | 2004-09-15 | 2007-09-14 | 783d? |  | R1; R2; R3; R4; R5 | 49552h | 49552h | VHCRTDD | IPwireless | Martin Beale (mbeale@ipwireless.com) | Rel-7 | Patrick | RP-060684 | VHCRTDD |  |  |
| 4396 | 1146.1 | VHCRTDD: Stage 2 | 391d? | 2004-09-15 A | 2006-03-15 A | 100% | 2004-09-15 | 2006-03-15 | 391d? | finish no earlier than 2006-03-15 | R1 | 3128h | 3128h | VHCRTDD-Stage2 | IPwireless | Martin Beale (mbeale@ipwireless.com) | Rel-7 | Patrick | RP-060684 | VHCRTDD-Stage2 |  |  |
| 4397 | 1146.2 | VHCRTDD: Physical Layer | 391d? | 2004-09-15 A | 2006-03-15 A | 100% | 2004-09-15 | 2006-03-15 | 391d? | finish no earlier than 2006-03-15 | R1 | 3128h | 3128h | VHCRTDD-Phys | IPwireless | Martin Beale (mbeale@ipwireless.com) | Rel-7 | Patrick | RP-060684 | VHCRTDD-Phys |  |  |
| 4398 | 1146.3 | VHCRTDD: Layer 2 and layer 3 protocol aspects | 391d? | 2004-09-15 A | 2006-03-15 A | 100% | 2004-09-15 | 2006-03-15 | 391d? | finish no earlier than 2006-03-15 | R2 | 3128h | 3128h | VHCRTDD-L23 | IPwireless | drichards@ipwireless.com | Rel-7 | Yong-Jun | RP-060684 | VHCRTDD-L23 |  |  |
| 4399 | 1146.4 | VHCRTDD: UTRAN Iub/Iur Protocol Aspects | 391d? | 2004-09-15 A | 2006-03-15 A | 100% | 2004-09-15 | 2006-03-15 | 391d? | finish no earlier than 2006-03-15 | R3 | 3128h | 3128h | VHCRTDD-IurIub | IPwireless | Peter Legg (plegg@ipwireless.com) | Rel-7 | Juha | RP-060684 | VHCRTDD-IurIub |  |  |
| 4400 | 1146.5 | VHCRTDD: RF Radio Transmission/ Reception, System Performance Requirements and Conformance Testing | 457d? | 2004-09-15 A | 2006-06-15 A | 100% | 2004-09-15 | 2006-06-15 | 457d? | finish no earlier than 2006-06-15 | R4 | 3656h | 3656h | VHCRTDD-RF | IPwireless | Shin Horng Wong (shwong@ipwireless.com) | Rel-7 | Issam | RP-060684 | VHCRTDD-RF |  |  |
| 4401 | 1146.6 | Conformance Test Aspects - 7.68 Mcps TDD | 258d? | 2006-09-20 A | 2007-09-14 A | 100% | 2006-09-20 | 2007-09-14 | 258d? | finish no earlier than 2007-09-10 | R5 | 2064h | 2064h | VHCRTDD-UEConTest | IPWireless | tspeight@ipwireless.com | Rel-7 | Ingbert | RP-070307 | VHCRTDD-UEConTest |  |  |
| 4402 | 1147 | **3.84 Mcps TDD Enhanced Uplink** | 394d? | 2005-03-15 A | 2006-09-15 A | 100% | 2005-03-15 | 2006-09-15 | 394d? |  | RP | 18384h | 18384h | EDCHTDD | IPwireless | nanderson@ipwireless.com | Rel-7 |  | RP-060462 | EDCHTDD |  |  |
| 4403 | 1147.1 | EDCHTDD: Stage 2 | 328d? | 2005-03-15 A | 2006-06-15 A | 100% | 2005-03-15 | 2006-06-15 | 328d? | finish no earlier than 2006-06-15 | R2 | 2624h | 2624h | EDCHTDD-Stage2 | IPwireless | nanderson@ipwireless.com | Rel-7 | Yong-Jun | RP-060462 | EDCHTDD-Stage2 |  |  |
| 4404 | 1147.2 | EDCHTDD: Physical Layer | 394d? | 2005-03-15 A | 2006-09-15 A | 100% | 2005-03-15 | 2006-09-15 | 394d? | finish no earlier than 2006-09-15 | R1 | 3152h | 3152h | EDCHTDD-Phys | IPwireless | nanderson@ipwireless.com | Rel-7 | Patrick | RP-060462 | EDCHTDD-Phys |  |  |
| 4405 | 1147.3 | EDCHTDD: Layer 2 and 3 Protocol Aspects | 394d? | 2005-03-15 A | 2006-09-15 A | 100% | 2005-03-15 | 2006-09-15 | 394d? | finish no earlier than 2006-09-15 | R2 | 3152h | 3152h | EDCHTDD-L23 | IPwireless | drichards@ipwireless.com | Rel-7 | Yong-Jun | RP-060462 | EDCHTDD-L23 |  |  |
| 4406 | 1147.4 | EDCHTDD: UTRAN Iub/Iur Protocol Aspects | 394d? | 2005-03-15 A | 2006-09-15 A | 100% | 2005-03-15 | 2006-09-15 | 394d? | finish no earlier than 2006-09-15 | R3 | 3152h | 3152h | EDCHTDD-IurIub | Interdigital | jim.miller@interdigital.com | Rel-7 | Juha | RP-060462 | EDCHTDD-IurIub |  |  |
| 4407 | 1147.5 | EDCHTDD: RF Radio Transmission/ Reception, System Performance Requirements and Conformance Testing | 394d? | 2005-03-15 A | 2006-09-15 A | 100% | 2005-03-15 | 2006-09-15 | 394d? | finish no earlier than 2006-09-15 | R4 | 3152h | 3152h | EDCHTDD-RF | IPwireless | Shin Horng Wong (shwong@ipwireless.com) | Rel-7 | Issam | RP-060462 | EDCHTDD-RF |  |  |
| 4408 | 1148 | **1.28 Mcps TDD Enhanced Uplink** | 653d? | 2006-03-15 A | 2008-09-12 A | 100% | 2006-03-15 | 2008-09-12 | 653d? |  | R1; R2; R3; R4; R5 | 35656h | 35656h | LCRTDD-EDCH | CATT | Haijing Hu | Rel-7 | Patrick | RP-070296 | LCRTDD-EDCH |  |  |
| 4409 | 1148.1 | 1.28 Mcps TDD Enhanced Uplink: Physical Layer | 262d? | 2006-03-15 A | 2007-03-15 A | 100% | 2006-03-15 | 2007-03-15 | 262d? | finish no earlier than 2007-03-15 | R1 | 2096h | 2096h | LCRTDD-EDCH-Phys | CATT | Ke Wang | Rel-7 | Patrick | RP-070038 | LCRTDD-EDCH-Phys |  |  |
| 4410 | 1148.2 | 1.28 Mcps TDD Enhanced Uplink: Layer 2 and 3 Protocol Aspects | 262d? | 2006-03-15 A | 2007-03-15 A | 100% | 2006-03-15 | 2007-03-15 | 262d? | finish no earlier than 2007-03-15 | R2 | 2096h | 2096h | LCRTDD-EDCH-L23 | CATT | Haiyang Quan | Rel-7 | Yong-Jun | RP-070038 | LCRTDD-EDCH-L23 |  |  |
| 4411 | 1148.3 | 1.28 Mcps TDD Enhanced Uplink: UTRAN Iub/Iur Protocol Aspects | 262d? | 2006-03-15 A | 2007-03-15 A | 100% | 2006-03-15 | 2007-03-15 | 262d? | finish no earlier than 2007-03-15 | R3 | 2096h | 2096h | LCRTDD-EDCH-IubIur | CATT | Yincheng Zhang | Rel-7 | Juha | RP-070038 | LCRTDD-EDCH-IubIur |  |  |
| 4412 | 1148.4 | 1.28 Mcps TDD Enhanced Uplink: RF Radio Transmission/ Reception, System Performance Requirements and Conformance Testing | 328d? | 2006-03-15 A | 2007-06-15 A | 100% | 2006-03-15 | 2007-06-15 | 328d? | finish no earlier than 2007-06-15 | R4 | 2624h | 2624h | LCRTDD-EDCH-RF | CATT | Yuexia Song (songyuexia@catt.cn) | Rel-7 | Issam | RP-070296 | LCRTDD-EDCH-RF |  |  |
| 4413 | 1148.5 | 1.28 Mcps TDD Enhanced Uplink - UE Conformance Testing | 257d? | 2007-09-20 A | 2008-09-12 A | 100% | 2007-09-20 | 2008-09-12 | 257d? | finish no earlier than 2008-09-11 | R5 | 624h | 624h | LCRTDD-EDCH-UEConTest | CATT | chenxiaozhong@datangmobile.cn | Rel-7 | Ingbert | RP-080539 | LCRTDD-EDCH-UEConTest |  |  |
| 4414 | 1149 | Conformance Test Aspects – Multiple Band and Multiple Frequency operation for LCR TDD | 263d? | 2010-09-17 A | 2011-09-16 A | 100% | 2010-09-17 | 2011-09-16 | 263d? | finish no earlier than 2011-12-09 | R5 | 2091.37h | 2091.37h | LCRTDD_MB_MF_UEConTest | CATR | Ms Jun Chen (chenjun@catr.cn) | Rel-7 | Ingbert | RP-110968 | LCRTDD_MB_MF_UEConTest | PCG-25 | RP-49 |
| 4415 | 1150 | MS Antenna Performance Evaluation Method and Requirements | 731d? | 2005-01-28 A | 2007-11-16 A | 100% | 2005-01-28 | 2007-11-16 | 731d? | finish no earlier than 2007-11-16 | GP | 5848h | 5848h | APEMR | TeliaSonera | Ulf.Tegth@teliasonera.com | Rel-7 | Paolo |  | APEMR |  |  |

Notes:
- 4385: RP#35 completed
- 4386: RP#35 completed
- 4387: SP#36 completed / Impacted TSs and TRs: 32.642, 32.643, 32.645 – Align with RAN 25.466
- 4388: Linked to Feature UID_20029 (RANimp)
- 4389: RP#41 completed / Impacted TSs and TRs: 34.108, 34.122, 34.123-1, 34.123-2, 34.123-3
- 4390: RP#39 completed / Impacted TSs and TRs: 34.108, 34.121-1, 34.121-2, 34.123-1, 34.123-2, 34.123-3
- 4391: RP#40 completed / Impacted TSs and TRs: 34.108, 34.121-1, 34.121-2, 34.123-1, 34.123-2, 34.123-3
- 4392: RP#40 completed / Impacted TSs and TRs: 34.108, 34.123-1, 34.123-2, 34.123-3
- 4393: RP#40 completed / Impacted TSs and TRs: 34.108, 34.121-1, 34.121-2, 34.123-1, 34.123-2, 34.123-3
- 4394: RP#45 completed / Impacted TSs and TRs: 34.108, 34.123-1, 34.123-2, 34.123-3
- 4395: RP#31 completed
- 4396: RP#31 completed / Impacted TSs and TRs: 25.202
- 4397: RP#31 completed / Impacted TSs and TRs: 25.221, 25.222, 25.223, 25.224,25.225
- 4398: RP#31 completed / Impacted TSs and TRs: 25.301, 25.302, 25.305, 25.306, 25.321, 25.331
- 4399: RP#31 completed / Impacted TSs and TRs: 25.401, 25.420, 25.423, 25.425, 25.427, 25.430, 25.433, 25.435
- 4400: RP#32 completed / Impacted TSs and TRs: 25.102, 25.105, 25.123, 25.133, 25.142
- 4401: RP#37 completed / Impacted TSs and TRs: 34.108, 34.122, 34.123-1, 34.123-2, 34.123-3
- 4402: RP#33 completed
- 4403: RP#33 completed
- 4404: RP#33 completed / Impacted TSs and TRs: 25.201, 25.221,25.222, 25.223, 25.224, 25.225
- 4405: RP#33 completed / Impacted TSs and TRs: 25.301, 25.302, 25.306, 25.321, 25.331
- 4406: RP#33 completed / Impacted TSs and TRs: 25.401, 25.420, 25.423, 25.427, 25.430, 25.433, 25.435
- 4407: RP#33 completed / Impacted TSs and TRs: 25.102, 25.105, 25.123, 25.142
- 4408: RP#35 completed
- 4409: RP#35 completed / Impacted TSs and TRs: 25.201, 25.221, 25.222, 25.223, 25.224, 25.225
- 4410: RP#35 completed / Impacted TSs and TRs: 25.301, 25.302, 25.306, 25.321, 25.331
- 4411: RP#35 completed / Impacted TSs and TRs: 25.401, 25.420, 25.423, 25.425, 25.427, 25.430, 25.433, 25.435
- 4412: RP#36 completed / Impacted TSs and TRs: 25.102, 25.105, 25.123, 25.142
- 4413: RP#41 completed / Impacted TSs and TRs: 34.108, 34.122, 34.123-1/2/3
- 4414: RP#53 completed. Core specification was introduced via Rel-7 CR under TEI7 (RP#37 RP-070650) and via 2 Rel-8 work items: RInImp9-UMTS1880TDD and RInImp8-UMTS2300TDD. / Impacted TSs and TRs: UTRA 34.108, 34.123-1, 34.123-2, 34.123-3
- 4415: GP#36 completed for R7 / Impacted TSs and TRs: 25.914, 25.144, 45.005

| ID | WBS | Task | Type | Duration | Start | Finish | Complete | Baseline start | Baseline finish | Baseline duration | Constraint | Resources | Work | Actual work | Acronym | WI rapporteur name | WI rapporteur e-mail | Release | MCC resp | Acronym_3GU_Export | TSG stopped |
| --- | --- | --- | --- | --- | --- | --- | --- | --- | --- | --- | --- | --- | --- | --- | --- | --- | --- | --- | --- | --- | --- |
| 4416 | 1151 | **Lower 700 MHz Inclusion in the GERAN Specifications** |  | 390d? | 2005-01-03 A | 2006-06-30 A | 100% | 2005-01-03 | 2006-06-30 | 390d? |  | GP | 11112h | 9372h | GSM710 | UTC | dcotton@mtview.union-tel.com | Rel-7 | Paolo | GSM710 |  |
| 4417 | 1151.1 | Inclusion of the 698 – 746 MHz band into GERAN core specifications |  | 129d? | 2005-01-03 A | 2005-06-30 A | 100% | 2005-01-03 | 2005-06-30 | 129d? | finish no earlier than 2005-06-30 | G1 | 1032h | 1032h | GSM710-core |  |  | Rel-7 | Paolo | GSM710-core |  |
| 4418 | 1151.2 | **Aspects of GSM710** |  | 217.5d? | 2005-08-31 A | 2006-06-30 A | 100% | 2005-08-31 | 2006-06-30 | 217.5d? |  | G1; G3new | 6960h | 5220h | GSM-710-test |  |  | Rel-7 | Paolo | GSM-710-test |  |
| 4419 | 1151.2.1 | G1 aspects of GSM710 |  | 217.5d? | 2005-08-31 A | 2006-06-30 A | 100% | 2005-08-31 | 2006-06-30 | 217.5d? | finish no earlier than 2006-06-30 | G1 | 1740h | 1740h |  |  |  | Rel-7 | Paolo |  |  |
| 4420 | 1151.2.2 | G3 aspects of GSM710 |  | 217.5d? | 2005-08-31 A | 2006-06-30 A | 100% | 2005-08-31 | 2006-06-30 | 217.5d? | finish no earlier than 2006-06-30 | G3new | 1740h | 1740h |  |  |  | Rel-7 | Ingbert |  |  |
| 4421 | 1152 | **Support of Conversational Services in A/Gb mode via the PS domain** |  | 626d? | 2005-04-08 A | 2007-08-31 A | 100% | 2005-04-08 | 2007-08-31 | 626d? |  | GP | 15442.8h | 15442.8h | SCSAGB | Ericsson | gunnar.hedby@ericsson.com | Rel-7 | Paolo | SCSAGB |  |
| 4422 | 1152.1 | Minimise the transfer delay between the SGSN and the MS |  | 604.95d? | 2005-04-08 A | 2007-08-31 A | 100% | 2005-04-08 | 2007-08-31 | 604.95d? | finish no earlier than 2007-08-31 | GP | 4839.6h | 4839.6h | SCSAGB-MTD | Ericsson | gunnar.hedby@ericsson.com | Rel-7 | Paolo | SCSAGB-MTD |  |
| 4423 | 1152.2 | Definition of radio resource management functionality for Support of Conversational Services in A/Gb mode via the PS domain |  | 626d? | 2005-04-08 A | 2007-08-31 A | 100% | 2005-04-08 | 2007-08-31 | 626d? | finish no earlier than 2007-08-31 | G1 | 5008h | 5008h | SCSAGB-RRM | Ericsson | gunnar.hedby@ericsson.com | Rel-7 | Paolo | SCSAGB-RRM |  |
| 4424 | 1152.3 | Support of Conversational Services in A/Gb mode via the PS domain – RLC Non-Persistent mode |  | 101d? | 2006-06-30 A | 2006-11-17 A | 100% | 2006-06-30 | 2006-11-17 | 101d? | finish no earlier than 2006-11-17 | G2 | 808h | 808h | SCSAGB-RLCNP | Ericsson | gunnar.hedby@ericsson.com | Rel-7 | Gert | SCSAGB-RLCNP |  |
| 4425 | 1152.4 | Deleted- Radio Channel Support | milestone | 0d? | 2006-07-17 A | 2006-07-17 A | 100% | 2006-07-17 | 2006-07-17 | 0d? | start no earlier than 2006-07-17 | G2 |  |  | SCSAGB-RCHS | Ericsson | gunnar.hedby@ericsson.com | Rel-7 | Gert | SCSAGB-RCHS | SP-32 |
| 4426 | 1152.5 | Deleted- Modifications to FLO | milestone | 0d? | 2006-07-17 A | 2006-07-17 A | 100% | 2006-07-17 | 2006-07-17 | 0d? | start no earlier than 2006-07-17 | G2 |  |  | SCSAGB-FLO | Ericsson | gunnar.hedby@ericsson.com | Rel-7 | Gert | SCSAGB-FLO | SP-32 |
| 4427 | 1153 | **Addition of new frequency band to GSM (T-GSM810)** |  | 626d? | 2005-04-08 A | 2007-08-31 A | 100% | 2005-04-08 | 2007-08-31 | 626d? |  | GP | 12112h | 12112h | TGSM810 | Huawei | chende@huawei.com | Rel-7 | Paolo | TGSM810 |  |
| 4428 | 1153.1 | Changes to core specification |  | 106d? | 2005-04-08 A | 2005-09-02 A | 100% | 2005-04-08 | 2005-09-02 | 106d? | finish no earlier than 2005-09-02 | GP | 848h | 848h | TGSM810-Core | Huawei | chende@huawei.com | Rel-7 | Paolo | TGSM810-Core |  |
| 4429 | 1153.2 | Changes to MS testing specification |  | 626d? | 2005-04-08 A | 2007-08-31 A | 100% | 2005-04-08 | 2007-08-31 | 626d? | finish no earlier than 2007-08-31 | G3new | 5008h | 5008h | TGSM810-MStest | Huawei | chende@huawei.com | Rel-7 | Ingbert | TGSM810-MStest |  |
| 4430 | 1153.3 | Changes to BTS testing specification |  | 156d? | 2005-04-08 A | 2005-11-11 A | 100% | 2005-04-08 | 2005-11-11 | 156d? | finish no earlier than 2005-11-11 | G1 | 1248h | 1248h | TGSM810-BTStest | Huawei | chende@huawei.com | Rel-7 | Paolo | TGSM810-BTStest |  |
| 4431 | 1154 | **Handover of dedicated and shared resources while in Dual Transfer Mode** |  | 421d? | 2005-04-08 A | 2006-11-17 A | 100% | 2005-04-08 | 2006-11-17 | 421d? |  | GP | 12672h | 12672h | HODSRDTM | Nokia | rami.vaittinen@nokia.com | Rel-7 | Paolo | HODSRDTM |  |
| 4432 | 1154.1 | GERAN2 part of Handover of dedicated and shared resources while in Dual Transfer Mode |  | 321d? | 2005-04-08 A | 2006-06-30 A | 100% | 2005-04-08 | 2006-06-30 | 321d? | finish no earlier than 2006-06-30 | G2 | 2568h | 2568h | HODSRDTM-G2 | Nokia | rami.vaittinen@nokia.com | Rel-7 | Gert | HODSRDTM-G2 |  |
| 4433 | 1154.2 | Deleted - MS Conformance Testing |  | 421d? | 2005-04-08 A | 2006-11-17 A | 100% | 2005-04-08 | 2006-11-17 | 421d? | finish no earlier than 2006-11-17 | G3new | 3368h | 3368h | HODSRDTM-MStest | Nokia | rami.vaittinen@nokia.com | Rel-7 | Ingbert | HODSRDTM-MStest | GP-32 |
| 4434 | 1154.3 | Deleted - BTS conformance testing |  | 421d? | 2005-04-08 A | 2006-11-17 A | 100% | 2005-04-08 | 2006-11-17 | 421d? | finish no earlier than 2006-11-17 | G1 | 3368h | 3368h | HODSRDTM-BTStest | Nokia | rami.vaittinen@nokia.com | Rel-7 | Paolo | HODSRDTM-BTStest | GP-32 |
| 4435 | 1155 | **Mobile Station Receive Diversity (DARP Phase II)** |  | 526d? | 2005-11-11 A | 2007-11-16 A | 100% | 2005-11-11 | 2007-11-16 | 526d? |  | GP | 16360h | 16360h | MSRD2 | Nokia | kent.pedersen@nokia.com | Rel-7 | Paolo | MSRD2 |  |
| 4436 | 1155.1 | Performance Requirements for Mobile Station Receive Diversity, DARP Phase II |  | 331d? | 2005-11-11 A | 2007-02-16 A | 100% | 2005-11-11 | 2007-02-16 | 331d? | finish no earlier than 2007-02-16 | GP | 2648h | 2648h | MSRD2-PerfReq | Nokia | kent.pedersen@nokia.com | Rel-7 | Paolo | MSRD2-PerfReq |  |
| 4437 | 1155.2 | Capability signalling of Mobile Station Receive Diversity, DARP Phase II |  | 331d? | 2005-11-11 A | 2007-02-16 A | 100% | 2005-11-11 | 2007-02-16 | 331d? | finish no earlier than 2007-02-16 | GP | 2648h | 2648h | MSRD2-CapSig | Nokia | kent.pedersen@nokia.com | Rel-7 | Paolo | MSRD2-CapSig |  |
| 4438 | 1155.3 | Test Scenarios for Mobile Station Receive Diversity, DARP Phase II |  | 331d? | 2005-11-11 A | 2007-02-16 A | 100% | 2005-11-11 | 2007-02-16 | 331d? | finish no earlier than 2007-02-16 | GP | 2648h | 2648h | MSRD2-TestSc | Nokia | kent.pedersen@nokia.com | Rel-7 | Paolo | MSRD2-TestSc |  |
| 4439 | 1155.4 | MS conformance test of DARP Phase II (MSRD) |  | 526d? | 2005-11-11 A | 2007-11-16 A | 100% | 2005-11-11 | 2007-11-16 | 526d? | finish no earlier than 2007-11-16 | GP | 4208h | 4208h | MSRD2-Msconf | Nokia | kent.pedersen@nokia.com | Rel-7 | Ingbert | MSRD2-Msconf |  |

Notes:
- 4416: -
- 4417: Completed / Impacted TSs and TRs: 24.008, 43.022, 44.018, 44.118, 45, 001, 45.005,
- 4418: -
- 4419: - / Impacted TSs and TRs: 51.021
- 4420: - / Impacted TSs and TRs: 51.010
- 4421: Originally started Nov. 2003 as GP-030443
- 4422: -
- 4423: -
- 4424: - / Impacted TSs and TRs: 43.955, 43.064, 44.060, 45.001, 45.002, 45.003, 45.005, 45.010, 51.010, 51.021
- 4425: -
- 4426: -
- 4427: - / Impacted TSs and TRs: 45.005, 45.050, 24.008, 45.008, 45.001, 43.022, 43.030, 44.018, 44.060, 51.010-1, 51.021
- 4428: - / Impacted TSs and TRs: 45.005, 45.050, 24.008, 45.008, 45.001, 43.022, 43.030, 44.018, 44.060
- 4429: - / Impacted TSs and TRs: 51010-1
- 4430: - / Impacted TSs and TRs: 51021
- 4431: GP#30 completed. Started at GP#24
- 4432: GP#30 completed / Impacted TSs and TRs: 43.055, 44.018, 44.060
- 4433: Stopped, no work done. 12/2008 Marked as stopped ("deleted") / Impacted TSs and TRs: 51-010
- 4434: Stopped, no work done. 12/2008 Marked as stopped ("deleted") / Impacted TSs and TRs: 51.026
- 4435: GP#36 completed
- 4436: GP#33 completed / Impacted TSs and TRs: 45.005
- 4437: GP#33 completed / Impacted TSs and TRs: 24.008
- 4438: GP#33 completed / Impacted TSs and TRs: 45.005
- 4439: GP#36 completed / Impacted TSs and TRs: 51.010

| ID | WBS | Task | Type | Duration | Start | Finish | Complete | Remaining | Baseline start | Baseline finish | Baseline duration | Total slack | Constraint | Resources | Work | Actual work | Acronym | WI rapporteur name | WI rapporteur e-mail | Release | MCC resp | Acronym_3GU_Export | TSG stopped |
| --- | --- | --- | --- | --- | --- | --- | --- | --- | --- | --- | --- | --- | --- | --- | --- | --- | --- | --- | --- | --- | --- | --- | --- |
| 4440 | 1156 | **Downlink Dual Carrier** |  | 947d? | 2006-01-20 A | 2009-09-04 A | 100% |  | 2006-01-20 | 2009-09-04 | 947d? |  |  | GP | 15446.6h | 15446.6h | GDCDL | Nokia Siemens Networks | leonardo.provvedi@roke.co.uk | Rel-7 | Paolo | GDCDL |  |
| 4441 | 1156.1 | Downlink Dual Carrier Stage 2 |  | 116d? | 2006-01-20 A | 2006-06-30 A | 100% |  | 2006-01-20 | 2006-06-30 | 116d? |  | finish no earlier than 2006-06-30 | G1 | 928h | 928h | GDCDL-Stage2 | Nokia Siemens Networks | leonardo.provvedi@roke.co.uk | Rel-7 | Paolo | GDCDL-Stage2 |  |
| 4442 | 1156.2 | Downlink Dual Carrier Stage 3 |  | 421d? | 2006-01-20 A | 2007-08-31 A | 100% |  | 2006-01-20 | 2007-08-31 | 421d? |  | finish no earlier than 2007-08-31 | G1 | 3368h | 3368h | GDCDL-Stage3 | Nokia Siemens Networks | leonardo.provvedi@roke.co.uk | Rel-7 | Paolo | GDCDL-Stage3 |  |
| 4443 | 1156.3 | Downlink Dual Carrier – MS Conformance Test |  | 446.82d? | 2006-01-20 A | 2009-09-04 A | 100% |  | 2006-01-20 | 2009-09-04 | 446.82d? |  | finish no earlier than 2009-09-04 | G3new | 3574.6h | 3574.6h | GDCDL-MStest | Nokia Siemens Networks | leonardo.provvedi@roke.co.uk | Rel-7 | Ingbert | GDCDL-MStest |  |
| 4444 | 1157 | Support of SIGTRAN in GERAN |  | 116d? | 2006-01-20 A | 2006-06-30 A | 100% |  | 2006-01-20 | 2006-06-30 | 116d? |  | finish no earlier than 2006-06-30 | GP | 928h | 928h | GSIGT | Ericsson | peter.ostrup@ericsson.com | Rel-7 | Ingbert | GSIGT |  |
| 4445 | 1158 | **Latency Reductions** |  | 306d? | 2006-06-30 A | 2007-08-31 A | 100% |  | 2006-06-30 | 2007-08-31 | 306d? |  |  | GP | 7344h | 7344h | LATRED | Ericsson | Hakan.Persson@Ericsson.com | Rel-7 | Paolo | LATRED |  |
| 4446 | 1158.1 | Improved Ack/Nack reporting |  | 306d? | 2006-06-30 A | 2007-08-31 A | 100% |  | 2006-06-30 | 2007-08-31 | 306d? |  | finish no earlier than 2007-08-31 | G2 | 2448h | 2448h | LATRED-ACKNAR | Ericsson | Hakan.Persson@Ericsson.com | Rel-7 | Gert | LATRED-ACKNAR |  |
| 4447 | 1158.2 | Reduced TTI |  | 306d? | 2006-06-30 A | 2007-08-31 A | 100% |  | 2006-06-30 | 2007-08-31 | 306d? |  | finish no earlier than 2007-08-31 | G2 | 2448h | 2448h | LATRED-REDTTI | Ericsson | Hakan.Persson@Ericsson.com | Rel-7 | Gert | LATRED-REDTTI |  |
| 4448 | 1159 | PS Handover between GERAN/UTRAN mode and GAN Mode |  | 166d? | 2006-06-30 A | 2007-02-16 A | 100% |  | 2006-06-30 | 2007-02-16 | 166d? |  | finish no earlier than 2007-02-16 | G2 | 1328h | 1328h | GUGAN | Ericsson | John.Diachina@Ericsson.com | Rel-7 | Gert | GUGAN |  |
| 4449 | 1160 | **Higher Uplink performance for GERAN Evolution** |  | 1227d? | 2006-09-08 A | 2011-05-20 A | 100% |  | 2006-09-08 | 2011-05-20 | 1227d? |  |  | GP | 37184h | 37184h | HUGE | Nokia Siemens Networks, Ericsson | eddie.riddington@nokia.com, stefan.g.eriksson@ericsson.com | Rel-7 | Paolo | HUGE |  |
| 4450 | 1160.1 | Stage 2 for HUGE |  | 261d? | 2006-09-08 A | 2007-09-07 A | 100% |  | 2006-09-08 | 2007-09-07 | 261d? |  | finish no earlier than 2007-09-07 | G1 | 2088h | 2088h | HUGE-Stage2 | Nokia Siemens Networks, Ericsson | eddie.riddington@nokia.com, stefan.g.eriksson@ericsson.com | Rel-7 | Paolo | HUGE-Stage2 |  |
| 4451 | 1160.2 | Layer 1 Support for HUGE |  | 381d? | 2006-09-08 A | 2008-02-22 A | 100% |  | 2006-09-08 | 2008-02-22 | 381d? |  | finish no earlier than 2008-02-22 | G1 | 3048h | 3048h | HUGE-Layer1 | Nokia Siemens Networks, Ericsson | eddie.riddington@nokia.com, stefan.g.eriksson@ericsson.com | Rel-7 | Paolo | HUGE-Layer1 |  |
| 4452 | 1160.3 | Layer 2/3 Support for HUGE |  | 256d? | 2006-09-08 A | 2007-08-31 A | 100% |  | 2006-09-08 | 2007-08-31 | 256d? |  | finish no earlier than 2007-08-31 | G2 | 2048h | 2048h | HUGE-Layer23 | Nokia Siemens Networks, Ericsson | eddie.riddington@nokia.com, stefan.g.eriksson@ericsson.com | Rel-7 | Gert | HUGE-Layer23 |  |
| 4453 | 1160.4 | Performance requirements for HUGE |  | 516d? | 2006-09-08 A | 2008-08-29 A | 100% |  | 2006-09-08 | 2008-08-29 | 516d? |  | finish no earlier than 2008-08-29 | G1 | 4128h | 4128h | HUGE-Perfreq | Nokia Siemens Networks, Ericsson | eddie.riddington@nokia.com, stefan.g.eriksson@ericsson.com | Rel-7 | Paolo | HUGE-Perfreq |  |
| 4454 | 1160.5 | BTS Conformance Test for HUGE |  | 782d? | 2006-09-08 A | 2009-09-04 A | 100% |  | 2006-09-08 | 2009-09-04 | 782d? |  | finish no earlier than 2009-09-04 | G1 | 6248h | 6248h | HUGE-BTStest | Nokia Siemens Networks, Ericsson | eddie.riddington@nokia.com, stefan.g.eriksson@ericsson.com | Rel-7 | Paolo | HUGE-BTStest |  |
| 4455 | 1160.6 | MS Conformance Test for HUGE |  | 1226d? | 2006-09-08 A | 2011-05-20 A | 100% |  | 2006-09-08 | 2011-05-20 | 1226d? |  | finish no earlier than 2011-05-20 | G3new | 9808h | 9808h | HUGE-Mstest | Nokia Siemens Networks, Ericsson | eddie.riddington@nokia.com, stefan.g.eriksson@ericsson.com | Rel-7 | Ingbert | HUGE-Mstest |  |
| 4456 | 1161 | **REduced symbol Duration, Higher Order modulation and Turbo coding (RED HOT) for downlink** |  | 1177d? | 2006-11-17 A | 2011-05-20 A | 100% |  | 2006-11-17 | 2011-05-20 | 1177d? |  |  | GP | 28808h | 28808h | REDHOT | Ericsson, Nokia Siemens Networks, Marvell | stefan.g.eriksson@ericsson.com | Rel-7 | Paolo | REDHOT |  |
| 4457 | 1161.1 | Stage 2 for REDHOT |  | 206d? | 2006-11-17 A | 2007-08-31 A | 100% |  | 2006-11-17 | 2007-08-31 | 206d? |  | finish no earlier than 2007-08-31 | G1 | 1648h | 1648h | REDHOT-Stage2 | Ericsson, Nokia Siemens Networks, Marvell | stefan.g.eriksson@ericsson.com | Rel-7 | Paolo | REDHOT-Stage2 |  |
| 4458 | 1161.2 | Stage 3 for REDHOT |  | 391d? | 2006-11-17 A | 2008-05-16 A | 100% |  | 2006-11-17 | 2008-05-16 | 391d? |  | finish no earlier than 2008-05-16 | G1 | 3128h | 3128h | REDHOT-Stage3 | Ericsson, Nokia Siemens Networks, Marvell | stefan.g.eriksson@ericsson.com | Rel-7 | Paolo | REDHOT-Stage3 |  |
| 4459 | 1161.3 | BTS Conformance Tests for REDHOT |  | 651d? | 2006-11-17 A | 2009-05-15 A | 100% |  | 2006-11-17 | 2009-05-15 | 651d? |  | finish no earlier than 2009-05-15 | G1 | 5208h | 5208h | REDHOT-BTStest | Ericsson, Nokia Siemens Networks, Marvell | stefan.g.eriksson@ericsson.com | Rel-7 | Paolo | REDHOT-BTStest |  |
| 4460 | 1161.4 | MS Conformance Tests for REDHOT |  | 1176d? | 2006-11-17 A | 2011-05-20 A | 100% |  | 2006-11-17 | 2011-05-20 | 1176d? |  | finish no earlier than 2011-05-20 | G3new | 9408h | 9408h | REDHOT-Mstest | Ericsson, Nokia Siemens Networks, Marvell | stefan.g.eriksson@ericsson.com | Rel-7 | Ingbert | REDHOT-Mstest |  |
| 4461 | 1162 | (Small) Technical Enhancements and Improvements for Rel-7 | milestone | 0d? | 2007-03-26 A | 2007-03-26 A | 100% |  | 2007-03-26 | 2007-03-26 | 0d? |  | start no earlier than 2007-03-26 | SP; CP; RP; GP |  |  | TEI7 |  |  | Rel-7 | All | TEI7 |  |
| 4462 | 1163 | Test - (Small) Technical Enhancements and Improvements for Rel-7 |  | 389d? | 2006-06-02 A | 2007-11-28 A | 100% |  | 2006-06-02 | 2007-11-28 | 389d? |  | finish no earlier than 2010-06-04 | R5 | 3112h | 3112h | TEI7_Test |  |  | Rel-7 | Ingbert | TEI7_Test |  |
| 4463 | 1164 | **Deleted - PS domain and IMS support for IMS Emergency sessions** |  | 63.69d? | 2006-06-23 A | 2006-09-21 | 99% | 0d? | 2006-06-23 | 2006-09-21 | 63.69d? | 0d |  | S2 |  |  | IMS-EMER | Nokia | curt.c.wong@nokia.com | Rel-7 | Maurice | IMS-EMER | SP-30 |
| 4464 | 1164.1 | Deleted - IMS aspects to support IMS Emergency sessions | milestone | 0d? | 2006-06-23 A | 2006-09-21 A | 100% |  | 2006-06-23 | 2006-09-21 | 0d? |  | start no earlier than 2006-06-23 | S2 |  |  |  | Nokia | curt.c.wong@nokia.com | Rel-7 | Maurice |  | SP-30 |
| 4465 | 1164.2 | Deleted - PS domain aspects to support IMS Emergency sessions | milestone | 0d? | 2006-06-23 A | 2006-09-21 A | 100% |  | 2006-06-23 | 2006-09-21 | 0d? |  | start no earlier than 2006-06-23 | S2 |  |  |  | Nokia | curt.c.wong@nokia.com | Rel-7 | Maurice |  | SP-30 |

Notes:
- 4440: GP#35 completed
- 4441: GP#30 completed / Impacted TSs and TRs: 43.055, 43.064
- 4442: GP#35 completed / Impacted TSs and TRs: 24.008, 44.018, 44.060, 45.001, 45.002, 45.005, 45.008
- 4443: GP#43 completed / Impacted TSs and TRs: 51.010
- 4444: GP#30 completed / Impacted TSs and TRs: 48.001, 48.006, 43.059, 49.031
- 4445: GP#35 completed / Impacted TSs and TRs: 45.001, 45.002, 45.003, 45.005, 45.010, 43.055, 43.064, 44.060, 51.010-1, 51.021
- 4446: GP#35 completed / Impacted TSs and TRs: 45.001, 45.002, 45.003, 45.005, 45.010, 43.055, 43.064, 44.060, 51.010-1, 51.021
- 4447: GP#35 completed / Impacted TSs and TRs: 45.001, 45.002, 45.003, 45.005, 45.010, 43.055, 43.064, 44.060, 51.010-1, 51.021
- 4448: GP#33 completed / Impacted TSs and TRs: 43.318, 44.318, 43.129, 25.306, 24.008, 44.060, 25.331, 51.010
- 4449: GP#39 completed
- 4450: GP#35 completed / Impacted TSs and TRs: 43.055, 43.064
- 4451: GP#37 completed / Impacted TSs and TRs: 45.001, 45.002, 45.003, 45.004, 45.008
- 4452: GP#35 completed / Impacted TSs and TRs: 24.008, 44.018, 44.060
- 4453: GP#39 completed / Impacted TSs and TRs: 45.005
- 4454: GP#43 completed / Impacted TSs and TRs: 51.021
- 4455: GP#50 completed / Impacted TSs and TRs: 51.010
- 4456: GP#38 completed
- 4457: GP#35 completed / Impacted TSs and TRs: 43.055, 43.064
- 4458: GP#38 completed / Impacted TSs and TRs: 24.008, 44.018, 44.060, 45.001, 45.002, 45.003, 45.004, 45.005, 45.008
- 4459: GP#42 completed / Impacted TSs and TRs: 51.021
- 4460: GP#50 completed / Impacted TSs and TRs: 51.010
- 4461: -
- 4462: -
- 4463: Approved at SP#29 / Impacted TSs and TRs: 23.867, 23.abc, 23.060, 23.002, 23.271
- 4464: Approved at SP#29 / Impacted TSs and TRs: 23.867, 23.abc, 23.060, 23.002, 23.271
- 4465: Approved at SP#29 / Impacted TSs and TRs: 23.867, 23.abc, 23.060, 23.002, 23.271

| ID | WBS | Task | Type | Duration | Start | Finish | Complete | Remaining | Baseline start | Baseline finish | Baseline duration | Total slack | Constraint | Resources | Work | Actual work | Acronym | Impacted TSs and TRs | Release | MCC resp | TSG stopped | Acronym_3GU_Export | WI rapporteur name | WI rapporteur e-mail | PCG approved | TSG approved | Special Focus Doc |
| --- | --- | --- | --- | --- | --- | --- | --- | --- | --- | --- | --- | --- | --- | --- | --- | --- | --- | --- | --- | --- | --- | --- | --- | --- | --- | --- | --- |
| 4466 | 16.7 | **Deleted - IMS Local services** |  | 0d? | 2006-01-06 A | 2006-01-06 | 99% | 0d? | 2006-01-06 | 2006-01-06 | 0d? | 0d |  | S2 |  |  | IMSLocal | 23.228 | Rel-7 | Maurice | SP-28 | IMSLocal |  |  |  |  |  |
| 4467 | 16.7.1 | Deleted - Stage 2 | milestone | 0d | 2006-01-06 A | 2006-01-06 A | 100% |  | 2006-01-06 | 2006-01-06 | 0d |  | start no earlier than 2006-01-06 | S2 |  |  |  |  | Rel-7 | Maurice | SP-26 |  |  |  |  |  |  |
| 4468 | 1165.2 | Deleted - Stage 3 for IMS Local services | milestone | 0d? | 2006-01-06 A | 2006-01-06 A | 100% |  | 2006-01-06 | 2006-01-06 | 0d? |  | finish no earlier than 2006-01-06 | C1 |  |  |  |  | Rel-7 | Frederic | SP-25 |  | Lucent | Keith Drage (drage@alcatel-lucent.com) |  |  |  |
| 4469 | 1166 | Deleted - IMS Phase 3 | milestone | 0d? | 2006-01-06 A | 2006-01-06 A | 100% |  | 2006-01-06 | 2006-01-06 | 0d? |  | start no earlier than 2006-01-06 | S2 |  |  |  |  | Rel-7 | Maurice | SP-25 |  |  |  |  |  |  |
| 4470 | 1167 | Deleted - Improvements of Radio Interface | milestone | 0d? | 2004-09-15 A | 2004-09-15 A | 100% |  | 2004-09-15 | 2004-09-15 | 0d? |  | start no earlier than 2004-09-15 | RP |  |  |  |  | Rel-7 | Issam | SP-24 |  |  |  | PCG-36 | RP-70 |  |
| 4471 | 1168 | Deleted: Generic User Profile Phase 2 | milestone | 0d | 2005-08-08 A | 2006-06-30 A | 100% |  | 2005-08-08 | 2006-06-30 | 0d |  |  | C4 |  |  |  |  | Rel-7 | Kimmo | SP-27 |  |  |  |  |  |  |
| 4472 | 30.4 | Deleted - Stage 3 - Common objects | milestone | 0d | 2005-08-08 A | 2006-06-30 A | 100% |  | 2005-08-08 | 2006-06-30 | 0d |  | finish no earlier than 2006-06-30 | C4 |  |  |  | 24.241 | Rel-7 | Kimmo | SP-27 |  |  |  |  |  |  |
| 4473 | 1170 | Release 7 Studies |  | 841d? | 2004-06-28 A | 2007-09-17 A | 100% |  | 2004-06-28 | 2007-09-17 | 841d? |  |  | CP; GP; RP; SP | 26912h | 26912h |  |  | Rel-7 | All |  |  |  |  |  |  |  |
| 4474 | 1171 | Study on Multimedia Telephony Capabilities for IMS |  | 276d? | 2005-07-11 A | 2006-07-31 A | 100% |  | 2005-07-11 | 2006-07-31 | 276d? |  |  | S1 | 2145.6h | 2145.6h | MITE | 22.973 | Rel-7 | Alain |  | MITE | Ericsson | peter.bleckert@ericsson.com |  |  |  |
| 4475 | 1172 | Study on Behaviour of Multi system UEs |  | 384d? | 2004-06-28 A | 2005-12-15 A | 100% |  | 2004-06-28 | 2005-12-15 | 384d? |  | start no earlier than 2004-06-28 | S1 | 3072h | 3072h | BMSU | 22.936 | Rel-7 | Alain |  | BMSU | Qualcomm | dwilliams@qualcomm.com |  |  |  |
| 4476 | 1173 | Study on Combining CS calls and IMS sessions |  | 189d? | 2004-06-28 A | 2005-03-17 A | 100% |  | 2004-06-28 | 2005-03-17 | 189d? |  | start no earlier than 2004-06-28 | S1 | 1512h | 1512h | IRTSD-CS_IMS | 22.979 | Rel-7 | Alain |  | IRTSD-CS_IMS | TeliaSonera | robert.frank@teliasonera.com |  |  |  |
| 4477 | 1174 | Study on All-IP Network |  | 188d? | 2004-06-28 A | 2005-03-16 A | 100% |  | 2004-06-28 | 2005-03-16 | 188d? |  | start no earlier than 2004-06-28 | S1 | 1504h | 1504h | FS_AIPN | 22.978 | Rel-7 | Alain |  | FS_AIPN | NTT DoCoMo | Shin-ichi Isobe (isobes@nttdocomo.co.jp) |  |  |  |
| 4478 | 1175 | Study on Videotelephony teleservice |  | 231d? | 2005-03-01 A | 2006-01-17 A | 100% |  | 2005-03-01 | 2006-01-17 | 231d? |  |  | S1 | 1848h | 1848h | VidTel | 22.903 | Rel-7 | Alain |  | VidTel | T-Mobile | michael.kurz@t-mobile.at |  |  |  |
| 4479 | 1176 | Study on Network Selection Principles |  | 193d? | 2005-03-15 A | 2005-12-08 A | 100% |  | 2005-03-15 | 2005-12-08 | 193d? |  |  | S1 | 1544h | 1544h | NetSel | 22.811 | Rel-7 | Alain |  | NetSel | O2 | chris.friel@O2.com |  |  |  |
| 4480 | 1177 | Study on Multimedia Priority Service |  | 851d? | 2003-03-28 A | 2006-06-30 A | 100% |  | 2003-03-28 | 2006-06-30 | 851d? |  | finish no earlier than 2005-12-16 | S1 | 6808h | 6808h | PRIOR-MM | 22.953 | Rel-7 | Alain |  | PRIOR-MM | Telcordia | James Garrahan (jgarraha@telcordia.com) |  |  | Public Safety (I-A) |
| 4481 | 1178 | Study on Transferring of emergency Call data |  | 190d? | 2005-07-11 A | 2006-03-31 A | 100% |  | 2005-07-11 | 2006-03-31 | 190d? |  | finish no earlier than 2005-12-08 | S1 | 1520h | 1520h | eCALL | 22.967 | Rel-7 | Alain |  | eCALL | Motorola | jian.j.wu@motorola.com |  |  | Public Safety (I-A) |
| 4482 | 1179 | Study on Enhancement of E2E QoS |  | 281.4d? | 2004-06-28 A | 2005-09-15 A | 100% |  | 2004-06-28 | 2005-09-15 | 281.4d? |  | finish no earlier than 2005-12-01 | S2 | 2251.2h | 2251.2h | QoS7 | 23.802 | Rel-7 | Maurice |  | QoS7 | Huawei | Robert Jaksa |  |  |  |
| 4483 | 1180 | Study on SOAP/HTTP IRP Solution Sets |  | 330d? | 2005-09-02 A | 2006-12-07 A | 100% |  | 2005-09-02 | 2006-12-07 | 330d? |  | finish no earlier than 2006-12-07 | S5 | 2640h | 2640h | OAM7-NIM-XML | 32.809 | Rel-7 | Mirko |  | OAM7-NIM-XML | Nortel | Suzèle Lariven (lariven@nortel.com) |  |  |  |
| 4484 | 1181 | Study on Itf-N Implementation Conformance Statement (ICS) template |  | 400d? | 2005-09-02 A | 2007-03-15 A | 100% |  | 2005-09-02 | 2007-03-15 | 400d? |  | finish no earlier than 2007-03-15 | S5 | 3200h | 3200h | OAM7-NIM-ICS | 32.812 | Rel-7 | Mirko |  | OAM7-NIM-ICS | China Mobile | Li Yewen (liyewen@chinamobile.com) |  |  |  |
| 4485 | 1182 | Study on IRP Information Model |  | 400d? | 2005-09-02 A | 2007-03-15 A | 100% |  | 2005-09-02 | 2007-03-15 | 400d? |  | finish no earlier than 2007-03-15 | S5 | 3200h | 3200h | OAM7-NIM-IM | 32.810 | Rel-7 | Mirko |  | OAM7-NIM-IM | Motorola | trevor.pirt@motorola.com |  |  |  |
| 4486 | 1183 | Study on Bandwidth Saving at Nb Interface with IP transport |  | 261d? | 2006-03-10 A | 2007-03-09 A | 100% |  | 2006-03-10 | 2007-03-09 | 261d? |  | finish no earlier than 2007-03-09 | C3 | 2088h | 2088h | BSNbIP | 29.814 | Rel-7 | Adrian |  | BSNbIP | Siemens | Thomas.Belling@siemens.com |  |  |  |
| 4487 | 1184 | Study on Routeing of MT-SMS via the HPLMN |  | 301d? | 2005-10-07 A | 2006-12-01 A | 100% |  | 2005-10-07 | 2006-12-01 | 301d? |  | finish no earlier than 2006-12-01 | C4 | 2408h | 2408h | SMS7 | 23.840 | Rel-7 | Kimmo |  | SMS7 | Vodafone | Nick.Russell@vodafone.com |  |  |  |
| 4488 | 1185 | Feasibility Study on the TCAPsec Gateway concept |  | 96d? | 2005-10-28 A | 2006-03-10 A | 100% |  | 2005-10-28 | 2006-03-10 | 96d? |  | finish no earlier than 2006-03-10 | C4 | 768h | 768h | FS_SEC7-TCAP | 29.800 | Rel-7 | Kimmo |  | FS_SEC7-TCAP | Siemens | Ulrich.wiehe@gksag.de |  |  |  |
| 4489 | 1186 | Study on using M2PA in 3GPP network |  | 318d? | 2006-03-22 A | 2007-06-08 A | 100% |  | 2006-03-22 | 2007-06-08 | 318d? |  | finish no earlier than 2007-06-08 | C4 | 2544h | 2544h | FS-M2PA | 29.801 | Rel-7 | Kimmo |  | FS-M2PA | China Mobile | zhaoyuyi@chinamobile.com |  |  |  |

Notes:
- 4466: -
- 4467: DAB - Not yet required in SA2 as it exists in previous releases
- 4468: -
- 4469: -
- 4470: Stage 2 description of Interim conclusion
- 4471: Created at TSG#27 by A. Sultan because of the move to Rel-7 of "Common Objects".
- 4472: No progress in CN4#26. This have to be moved to Rel-7. It was deleted from WID
- 4473: -
- 4474: Spin-off Feature UID_7038 (MTSI)
- 4475: -
- 4476: -
- 4477: 07/08 Moved to Rel-7 as Study out of stopped Rel-8 Feature UID_31067 All-IP Network (AIPN)
- 4478: -
- 4479: Spin-off Feature Network selection enhancements (NSP-CR) UID_7041
- 4480: Spin-off Feature PRIOR UID_340044
- 4481: -
- 4482: -
- 4483: SP#34 completed
- 4484: SP#35 completed
- 4485: SP#35 completed
- 4486: Moved to FS at CT32 (in line with slides)
- 4487: Previously known as "Study of a SMS Centre for MT SMS"
- 4488: TR 29.800 content moved to TS 29.204 under implementation WI UID_310005 TCAPsec Gateway
- 4489: -

| ID | WBS | Task | Type | Duration | Start | Finish | Complete | Baseline start | Baseline finish | Baseline duration | Constraint | Resources | Work | Actual work | Acronym | Impacted TSs and TRs | WI rapporteur name | WI rapporteur e-mail | Release | MCC resp | Acronym_3GU_Export | Status Report | TSG stopped | Special Focus Doc |
| --- | --- | --- | --- | --- | --- | --- | --- | --- | --- | --- | --- | --- | --- | --- | --- | --- | --- | --- | --- | --- | --- | --- | --- | --- |
| 4490 | 1187 | **Study on Support of (G)MSC-S - (G)MSC-S Nc Interface based on the SIP-I protocol** |  | 350d? | 2006-05-15 A | 2007-09-14 A | 100% | 2006-05-15 | 2007-09-14 | 350d? |  | C4; C3 | 10600h | 10600h | NcSIP | 29.802 | Vodafone | david.hutton@vodafone.com | Rel-7 | Kimmo | NcSIP |  |  |  |
| 4491 | 1187.1 | CT4 aspects of NcSIP |  | 275d? | 2006-05-15 A | 2007-06-01 A | 100% | 2006-05-15 | 2007-06-01 | 275d? | finish no earlier than 2007-06-01 | C4 | 2200h | 2200h |  | 29.802 | Vodafone | david.hutton@vodafone.com | Rel-7 | Kimmo |  |  |  |  |
| 4492 | 1187.2 | CT3 aspects of NcSIP |  | 350d? | 2006-05-15 A | 2007-09-14 A | 100% | 2006-05-15 | 2007-09-14 | 350d? | finish no earlier than 2007-09-14 | C3 | 2800h | 2800h |  | 29.802 | Ericsson | ragnar.huslende@ericsson.com | Rel-7 | Adrian |  |  |  |  |
| 4493 | 1188 | Study on Evolved UTRA and UTRAN |  | 458d? | 2004-12-15 A | 2006-09-15 A | 100% | 2004-12-15 | 2006-09-15 | 458d? | finish no earlier than 2006-09-15 | RP | 3664h | 3664h | RANFS-Evo | 25.912 | NTT DoCoMo | nakamurata@NTTDOCOMO.CO.JP | Rel-7 | Issam | RANFS-Evo | RP-060472 |  |  |
| 4494 | 1189 | Study on Performance Evaluation of the UE behaviour in high speed trains with speeds up to 350 kmph |  | 328d? | 2005-03-15 A | 2006-06-15 A | 100% | 2005-03-15 | 2006-06-15 | 328d? | finish no earlier than 2006-06-15 | R4 | 2624h | 2624h | RANFS-HSTrains | none | Vodafone | Mike.vogel@vodafone.com,tim.frost@vodafone.com | Rel-7 | Issam | RANFS-HSTrains | RP-060412 |  |  |
| 4495 | 1190 | Study on UTRA Tower Mounted Amplifier (FDD) |  | 195d? | 2005-06-15 A | 2006-03-14 A | 100% | 2005-06-15 | 2006-03-14 | 195d? | finish no earlier than 2006-03-15 | R4 | 1560h | 1560h | RANFS-TMA | 25.818 | Ericsson | Klas.Sjerling@ericsson.com | Rel-7 | Issam | RANFS-TMA | RP-060035 |  |  |
| 4496 | 1191 | Study on Continuous connectivity for packet data users |  | 132d? | 2005-03-15 A | 2005-09-14 A | 100% | 2005-03-15 | 2005-09-14 | 132d? | finish no earlier than 2005-09-15 | R1 | 1056h | 1056h | RANFS-cont-packet | none | Siemens | joerg.gustrau@siemens.com | Rel-7 | Patrick | RANFS-cont-packet | RP-050427 |  |  |
| 4497 | 1192 | Study on Improvement of the Multimedia Broadcast Multicast Service (MBMS) in UTRAN |  | 262d? | 2005-12-15 A | 2006-12-15 A | 100% | 2005-12-15 | 2006-12-15 | 262d? | finish no earlier than 2006-12-15 | R2 | 2096h | 2096h | RANFS-MBMSImp | 25.905 | LG Electronics | leego@lge.com | Rel-7 | Yong-Jun | RANFS-MBMSImp | RP-060692 |  |  |
| 4498 | 1193 | Deleted - Study on Performance Improvements in Small Cells using HSDPA/EDCH |  | 131d? | 2005-12-15 A | 2006-06-15 A | 100% | 2005-12-15 | 2006-06-15 | 131d? | finish no earlier than 2006-06-15 | R1; R4 | 2096h | 2096h | SMALLCELLS | none | Cingular | Marc Grant | Rel-7 | Issam | SMALLCELLS | RP-060263 | SP-69 | Small cell |
| 4499 | 1194 | Study on Further Improved Performance Requirements for UMTS/HSDPA UE (FDD) |  | 383d? | 2005-12-15 A | 2007-06-04 A | 100% | 2005-12-15 | 2007-06-04 | 383d? | finish no earlier than 2007-06-04 | R4 | 3064h | 3064h | RANFS-IC | 25.963 | Cingular | Marc Grant | Rel-7 | Issam | RANFS-IC | RP-070499 |  |  |
| 4500 | 1195 | Study on Scope of future FDD HSPA Evolution |  | 394d? | 2006-03-15 A | 2007-09-17 A | 100% | 2006-03-15 | 2007-09-17 | 394d? | finish no earlier than 2007-09-17 | RP | 3152h | 3152h | RANFS-HSPAEvo | 25.999 | Cingular | Don Zelmer (dz1069@att.com) | Rel-7 | Issam | RANFS-HSPAEvo | RP-070533 |  |  |
| 4501 | 1196 | Study on Dynamically reconfiguring a FDD UE receiver to reduce power consumption when desired Quality of Service is met | milestone | 0d? | 2007-06-22 A | 2007-06-22 A | 100% | 2007-06-22 | 2007-06-22 | 0d? |  | R4 |  |  | FSUEPow | 25.906 | Nokia | Chris.callender@nokia.com, tiina.s.koskinen@nokia.com | Rel-7 | Issam | FSUEPow | RP-070534 |  |  |
| 4502 | 1197 | Study on Future GERAN Evolution |  | 486d? | 2005-04-08 A | 2007-02-16 A | 100% | 2005-04-08 | 2007-02-16 | 486d? | finish no earlier than 2007-02-16 | GP | 3888h | 3888h | FGE | 45.912 | Nokia | eddie.riddington@nokia.com | Rel-7 | Paolo | FGE |  |  |  |
| 4503 | 1198 | Study on GAN Enhancements | milestone | 0d? | 2007-08-31 A | 2007-08-31 A | 100% | 2007-08-31 | 2007-08-31 | 0d? | start no earlier than 2007-08-31 | GP |  |  | EGAN | 43.902 | T-Mobile | janne.linkola@t-mobile.com | Rel-7 | Paolo | EGAN |  |  |  |
| 4504 | 1199 | Deleted - Study on IMS with real time services deployment |  | 316d? | 2004-06-28 A | 2005-09-12 A | 100% | 2004-06-28 | 2005-09-12 | 316d? |  | S1 | 2528h | 2528h | IRTSD |  |  |  | Rel-7 | Alain | IRTSD |  | SP-30 |  |
| 4505 | 1200 | Deleted - Covered by SI - Personal Network (PN) and Personal Area Network (PAN) | milestone | 0d? | 2005-12-08 A | 2005-12-20 A | 100% | 2005-12-08 | 2005-12-20 | 0d? | start no earlier than 2005-12-08 | S1 |  |  | PNPAN |  | Vodafone | armin.toepfer@vodafone.com | Rel-7 | Alain | PNPAN |  | SP-30 |  |
| 4506 | 1201 | Deleted - Study on Customised Alerting Tone (CAT) Requirements (was duplicated) | milestone | 0d? | 2006-06-30 A | 2006-06-30 A | 100% | 2006-06-30 | 2006-06-30 | 0d? | start no earlier than 2006-06-30 | S1 |  |  |  |  |  |  | Rel-7 | Alain |  |  | SP-31 |  |
| 4507 | 1202 | Deleted - IMS security extensions (covered by UID33027) | milestone | 0d? | 2005-12-08 A | 2005-12-08 A | 100% | 2005-12-08 | 2005-12-08 | 0d? | start no earlier than 2005-12-08 | S3 |  |  | IMS-SE |  | Ericsson | Bengt.Sahlin@ericsson.com | Rel-7 | Mirko | IMS-SE |  | SP-30 |  |
| 4508 | 1203 | **Deleted - Study on applicability of GALILEO for LCS** |  | 0d? | 2005-06-30 A | 2005-06-30 A | 100% | 2005-06-30 | 2005-06-30 | 0d? |  | S2 |  |  | Galileo |  |  |  | Rel-7 | Maurice | Galileo |  | SP-25 |  |
| 4509 | 1203.1 | Deleted - TR on Stage 2 | milestone | 0d? | 2005-06-30 A | 2005-06-30 A | 100% | 2005-06-30 | 2005-06-30 | 0d? | finish no earlier than 2005-06-30 | S2 |  |  |  |  |  |  | Rel-7 | Maurice |  |  | SP-25 |  |
| 4510 | 1203.2 | Deleted - GERAN review of the TR | milestone | 0d? | 2005-06-30 A | 2005-06-30 A | 100% | 2005-06-30 | 2005-06-30 | 0d? | start no earlier than 2005-06-30 | GP |  |  |  |  |  |  | Rel-7 | Paolo |  |  | SP-26 |  |
| 4511 | 1204 | Deleted - Study on Stage 2 (IMS services using CS bearers) |  | 316d? | 2004-06-28 A | 2005-09-12 A | 100% | 2004-06-28 | 2005-09-12 | 316d? | finish no earlier than 2005-09-12 | S2 | 2528h | 2528h | IRTSD-IMSCS | 23.899 | Nortel | Mark Watson | Rel-7 | Maurice | IRTSD-IMSCS |  | SP-30 |  |
| 4512 | 1205 | **Deleted - VoIMS bearer related enhancements** |  | 0d? | 2006-07-21 A | 2006-07-21 A | 100% | 2006-07-21 | 2006-07-21 | 0d? |  | S2 |  |  | VoIMS |  |  |  | Rel-7 | Maurice | VoIMS |  | SP-32 |  |
| 4513 | 1205.1 | Deleted - Study on enhancement of radio performance for VoIMS | milestone | 0d? | 2006-07-21 A | 2006-07-21 A | 100% | 2006-07-21 | 2006-07-21 | 0d? | start no earlier than 2006-07-21 | S2 |  |  |  | 23.807 | Nortel | Laurence Lautier (lautierl@nortel.com) | Rel-7 | Maurice |  |  | SP-32 |  |
| 4514 | 1206 | Deleted - Study on IMS enhancements and optimizations for real time communication. |  | 430d? | 2005-10-10 A | 2007-06-01 A | 100% | 2005-10-10 | 2007-06-01 | 430d? | finish no earlier than 2007-06-01 | S2 | 3440h | 3440h | IMS-RT | 23.818 | Ericsson | stephen.terrill@ericsson.com | Rel-7 | Maurice | IMS-RT |  | SP-35 |  |
| 4515 | 1207 | Deleted - Study on Terminating Session handling |  | 255d? | 2006-01-09 A | 2006-12-29 A | 100% | 2006-01-09 | 2006-12-29 | 255d? | finish no earlier than 2006-12-29 | S2 | 2040h | 2040h | CSIterm | 23.819 | Samsung |  | Rel-7 | Maurice | CSIterm |  | SP-32 |  |
| 4516 | 1208 | Deleted eCALLIBMS - Study on Transferring of emergency call data – in-band modem solution (moved to Rel-8) | milestone | 0d? | 2007-06-22 A | 2007-06-22 A | 100% | 2007-06-22 | 2007-06-22 | 0d? | start no earlier than 2007-06-22 | S4 |  |  |  | 26.967 | Airbiquity | lhong@airbiquity.com | Rel-7 | Paolo |  |  | SP-38 | Public Safety (I-A) |
| 4517 | 1209 | Deleted - Study on IRP usage scenarios |  | 330d? | 2005-09-02 A | 2006-12-07 A | 100% | 2005-09-02 | 2006-12-07 | 330d? | finish no earlier than 2006-12-07 | S5 | 2640h | 2640h | OAM-Study | 32.8xy | Lucent |  | Rel-7 | Mirko | OAM-Study |  | SP-32 |  |
| 4518 | 1210 | Deleted - Study on Interference Cancellation for UTRA FDD UE (covered by UID 20053) |  | 1d? | 2007-03-28 A | 2007-03-28 A | 100% | 2007-03-28 | 2007-03-28 | 1d? | start no earlier than 2007-03-28 | R4 | 8h | 8h | RANFS-InterfCanc |  |  |  | Rel-7 | Issam | RANFS-InterfCanc |  | SP-38 |  |
| 4519 | 1211 | Deleted - Study on enhanced support of Video Telephony | milestone | 0d? | 2006-06-30 A | 2006-06-30 A | 100% | 2006-06-30 | 2006-06-30 | 0d? | start no earlier than 2006-06-30 | GP |  |  | VIDGER |  | Ericsson | stefan.g.eriksson@ericsson.com | Rel-7 | Paolo | VIDGER |  | SP-32 |  |
| 4520 | 1212 | Release 6 Features |  | 915d? | 2002-06-28 A | 2005-12-30 A | 100% | 2002-06-28 | 2005-12-30 | 915d? |  | NP; GP; RP; SP; TP | 36600h | 36600h |  |  |  |  | Rel-6 | All |  |  |  |  |

Notes:
- 4490: -
- 4491: -
- 4492: -
- 4493: RP#33 (Sep 2006) completed. SR in RP-060472
- 4494: RP#32 (Jun 2006) completed. SR in RP-060412
- 4495: RP#31 (Mar 2006) completed. SR in RP-060035
- 4496: RP#29 (Sep 2006) completed. SR in RP-050427
- 4497: RP#34 completed
- 4498: RP#32 (Jun 2006) stopped at 0% completion
- 4499: RP#36 (May 2007) completed. SR in RP-070499
- 4500: RP#37 (Sep 2007) completed. SR in RP-070533
- 4501: RP#37 (Sep 2007) completed. SR in RP-070534
- 4502: GP#33 completed
- 4503: GP#35 completed
- 4504: -
- 4505: -
- 4506: Awaiting MCC SA3 input
- 4507: -
- 4508: -
- 4509: -
- 4510: -
- 4511: SP-30: S2 has no intention for TR completion
- 4512: Created by MCC to group all VoIMS related items, after consultation of chairs
- 4513: WID approved SP#28. SA2#52 stopped
- 4514: abandoned at 65%
- 4515: SP#32 Jun 2006 Study abandoned => spin-off Implementation work UID_320029
- 4516: SP-38 stopped
- 4517: -
- 4518: Deleted. Same as FS on Further Improved Performance Requirements for UMTS/HSDPA UE (FDD)
- 4519: FS CLOSED at G#28 (no input)
- 4520: -

| ID | WBS | Task | Type | Duration | Start | Finish | Complete | Baseline start | Baseline finish | Baseline duration | Constraint | Resources | Work | Actual work | Release | Acronym | WI rapporteur name | WI rapporteur e-mail | MCC resp | Acronym_3GU_Export | Impacted TSs and TRs | Created at | TSG stopped |
| --- | --- | --- | --- | --- | --- | --- | --- | --- | --- | --- | --- | --- | --- | --- | --- | --- | --- | --- | --- | --- | --- | --- | --- |
| 4521 | 8 | **Rel-6 Improvements of Radio Interface** |  | 1645d? | 2000-08-14 A | 2006-12-01 A | 100% | 2000-08-14 | 2006-12-01 | 1645d? |  | R2; R4; R5 | 87632h | 87632h | Rel-6 |  |  |  |  |  |  |  |  |
| 4522 | 1213.1 | Improved support of IMS Realtime Services using HSDPA/EDCH |  | 197d? | 2005-03-15 A | 2005-12-14 A | 100% | 2005-03-15 | 2005-12-14 | 197d? | finish no earlier than 2005-12-14 | R2 | 1576h | 1576h | Rel-6 | RInImp-IMSRealTime | Cingular | Don Zelmer (dz1069@att.com) | Yong-Jun | RInImp-IMSRealTime |  |  |  |
| 4523 | 1213.2 | Improving Receiver Performance Requirements for the FDD UE |  | 401d | 2002-03-08 A | 2003-09-19 A | 100% | 2002-03-08 | 2003-09-19 | 401d | start no earlier than 2002-03-08 | R4 | 3208h | 3208h | Rel-6 | RInImp-UERecPerf | Intel | shimon.moshavi@INTEL.COM | Issam | RInImp-UERecPerf | 25.101 |  |  |
| 4524 | 8.2 | **Base station classification for FDD** |  | 603d | 2000-08-14 A | 2002-12-04 A | 100% | 2000-08-14 | 2002-12-04 | 603d |  | R4 | 9648h | 9648h | Rel-6 | RInImp-BSClass-FDD |  |  | Issam | RInImp-BSClass-FDD |  |  |  |
| 4525 | 8.2.1 | FDD Base station classification |  | 603d | 2000-08-14 A | 2002-12-04 A | 100% | 2000-08-14 | 2002-12-04 | 603d | finish no earlier than 2002-12-04 | R4 | 4824h | 4824h | Rel-6 |  | Nokia | antti.toskala@nokia.com | Issam |  | 25.104, 25.141 |  |  |
| 4526 | 1213.4 | UMTS-850 |  | 266d | 2002-12-06 A | 2003-12-12 A | 100% | 2002-12-06 | 2003-12-12 | 266d | finish no earlier than 2003-12-15 | R4 | 2128h | 2128h | Rel-6 | RInImp-UMTS850 | Cingular | Don Zelmer (dz1069@att.com) | Issam | RInImp-UMTS850 | 25.101, 25.104, 25.133, 25.141, 25.307, 25.331, 25.942 |  |  |
| 4527 | 1213.5 | DS-CDMA introduction in the 800 MHz band |  | 196d | 2003-03-14 A | 2003-12-12 A | 100% | 2003-03-14 | 2003-12-12 | 196d | finish no earlier than 2003-12-15 | R4 | 1568h | 1568h | Rel-6 | RInImp-UMTS800 | NTT DoCoMo | Takehiro Nakamura (nakamurata@nttdocomo.co.jp) | Issam | RInImp-UMTS800 | 25.101, 25.104, 25.133, 25.141, 25.307, 25.331 |  |  |
| 4528 | 1213.6 | UMTS 1.7/2.1 GHz | milestone | 0d? | 2003-03-14 A | 2003-03-14 A | 100% | 2003-03-14 | 2003-03-14 | 0d? |  | R4 |  |  | Rel-6 | RInImp-UMTS1721 | Nokia | jussi.numminen@NOKIA.COM | Issam | RInImp-UMTS1721 | 25.101, 25.104, 25.133, 25.141, 25.307, 25.331 |  |  |
| 4529 | 1213.7 | Conformance Test Aspects – UMTS 1.7/2.1 GHz Band |  | 191d? | 2006-03-10 A | 2006-12-01 A | 100% | 2006-03-10 | 2006-12-01 | 191d? | finish no earlier than 2006-12-01 | R5 | 1528h | 1528h | Rel-6 | RInImp-UMTS1721_Test | Motorola | carolyn.taylor@motorola.com | Ingbert | RInImp-UMTS1721_Test | TS34.121, TS34.108 |  |  |
| 4530 | 1213.8 | **Improved Receiver Performance Requirements for HSDPA** |  | 711d | 2003-09-19 A | 2006-06-09 A | 100% | 2003-09-19 | 2006-06-09 | 711d |  | R4; R5 | 28496h | 28496h | Rel-6 | RInImp-HSPerf | Nokia | jussi.numminen@NOKIA.COM | Issam | RInImp-HSPerf |  |  |  |
| 4531 | 1213.8.1 | Improved Minimum Performance Requirements for HSDPA UE categories 7 and 8 |  | 453d | 2004-09-15 A | 2006-06-09 A | 100% | 2004-09-15 | 2006-06-09 | 453d |  | R4 | 3624h | 3624h | Rel-6 | RInImp-HSPerf-10code | Nokia | jussi.numminen@nokia.com | Issam | RInImp-HSPerf-10code | 25.101 |  |  |
| 4532 | 1213.8.2 | Testing of Improved Minimum Performance for HSDPA |  | 650d | 2003-09-19 A | 2006-03-16 A | 100% | 2003-09-19 | 2006-03-16 | 650d | finish no earlier than 2006-03-16 | R5 | 5200h | 5200h | Rel-6 | RInImp-HSPerf-10Code_Test | Motorola | carolyn.taylor@motorola.com | Ingbert | RInImp-HSPerf-10Code_Test | 34.108, 34.121, 34.122, 34.123-1, 34.123-2, 34.123-3 | 19/9/2003 |  |
| 4533 | 1213.8.3 | Performance Requirements of Receive Diversity for HSDPA |  | 387d | 2003-12-15 A | 2005-06-07 A | 100% | 2003-12-15 | 2005-06-07 | 387d |  | R4 | 3096h | 3096h | Rel-6 | RInImp-HSPerf-RxDiv | NTT DoCoMo | Takehiro Nakamura (nakamurata@nttdocomo.co.jp) | Issam | RInImp-HSPerf-RxDiv | 25.101 |  |  |
| 4534 | 1213.8.4 | Testing of Performance of Receiver diversity for HSDPA |  | 650d | 2003-09-19 A | 2006-03-16 A | 100% | 2003-09-19 | 2006-03-16 | 650d | finish no earlier than 2006-03-16 | R5 | 5200h | 5200h | Rel-6 | RInImp-HSPerf-RxDiv_Test | Motorola | carolyn.taylor@motorola.com | Ingbert | RInImp-HSPerf-RxDiv_Test | 34.108, 34.121, 34.122, 34.123-1, 34.123-2, 34.123-3 | 19/9/2003 |  |
| 4535 | 1214 | **Rel-6 RAN Feasibility Studies** |  | 1196d? | 2000-08-14 A | 2005-03-14 A | 100% | 2000-08-14 | 2005-03-14 | 1196d? |  | RP | 43048h | 43048h | Rel-6 |  |  |  |  |  |  |  |  |
| 4536 | 1214.1 | FS of the improved access to UE measurement data for CRNC to support TDD RRM |  | 270d? | 2002-12-06 A | 2003-12-18 A | 100% | 2002-12-06 | 2003-12-18 | 270d? | finish no earlier than 2003-09-19 | R3 | 2160h | 2160h | Rel-6 | RANimp-RRMopt-FSUEMsD | Interdigital | jim.miller@interdigital.com | Juha | RANimp-RRMopt-FSUEMsD | 25.801, 25.423 | SP-24 |  |
| 4537 | 1214.2 | FS on Radio link performance enhancements |  | 1067d | 2000-08-14 A | 2004-09-14 A | 100% | 2000-08-14 | 2004-09-14 | 1067d | finish no earlier than 2004-09-14 | R1 | 8536h | 8536h | Rel-6 | RInImp-Rlperf | Nokia | antti.toskala@nokia.com | Patrick | RInImp-Rlperf | 25.899 |  |  |
| 4538 | 1214.3 | FS on Improvement of inter-frequency and inter-system measurements for 1.28 Mcps TDD |  | 461d | 2001-12-14 A | 2003-09-19 A | 100% | 2001-12-14 | 2003-09-19 | 461d | start no earlier than 2001-12-14 | R1 | 3688h | 3688h | Rel-6 | RInImp-IfIsMLCR | Samsung | Li Xiao Qiang (xqli@samsung.co.kr) | Patrick | RInImp-IfIsMLCR | 25.888 |  |  |
| 4539 | 1214.4 | FS for the analysis of OFDM for UTRAN enhancement |  | 526d | 2002-06-10 A | 2004-06-14 A | 100% | 2002-06-10 | 2004-06-14 | 526d | start no earlier than 2002-06-10 | R1 | 4208h | 4208h | Rel-6 | RInImp-FSOFDM | Nortel | Sarah Boumendil | Patrick | RInImp-FSOFDM | 25.892 |  |  |
| 4540 | 1214.5 | FS on Uplink Enhancements for Dedicated Transport Channels |  | 396d | 2002-09-06 A | 2004-03-12 A | 100% | 2002-09-06 | 2004-03-12 | 396d | finish no earlier than 2004-03-12 | R1 | 3168h | 3168h | Rel-6 | RInImp-FSUpDTrCh | Nokia | Karri.Ranta-aho@nsn.com | Patrick | RInImp-FSUpDTrCh | 25.896 |  |  |
| 4541 | 1214.6 | FS on Analysis on Higher Chip Rates for UTRA TDD evolutions |  | 528d | 2002-09-06 A | 2004-09-14 A | 100% | 2002-09-06 | 2004-09-14 | 528d | finish no earlier than 2004-09-14 | R1 | 4224h | 4224h | Rel-6 | RInImp-FSVHCRTDD | IPWireless | mbeale@ipwireless.com | Patrick | RInImp-FSVHCRTDD | 25.895 |  |  |
| 4542 | 1214.7 | FS on Low Output Powers for general purpose FDD BSs |  | 128d | 2003-06-13 A | 2004-03-12 A | 100% | 2003-06-13 | 2004-03-12 | 128d | finish no earlier than 2004-03-12 | R3 | 1024h | 1024h | Rel-6 | RInImp-FSLoPw | Telefónica | Ana Burgos (burgos_a@tsm.es) | Juha | RInImp-FSLoPw | 25.807 |  |  |
| 4543 | 1214.8 | FS on Uplink enhancements for UTRA TDD |  | 462d | 2003-06-06 A | 2005-03-14 A | 100% | 2003-06-06 | 2005-03-14 | 462d | finish no earlier than 2005-03-14 | R1 | 3696h | 3696h | Rel-6 | RInImp-FSUpEnhTDD | Interdigital | Marian.Rudolf@InterDigital.com | Patrick | RInImp-FSUpEnhTDD | 25.804 |  |  |
| 4544 | 8.8 | FS on UE antenna efficiency test methods performance requirements (2) |  | 131d | 2002-03-08 A | 2002-09-06 A | 100% | 2002-03-08 | 2002-09-06 | 131d | finish no earlier than 2002-09-06 | R4 | 1048h | 1048h | Rel-6 | RInImp-UEAnTM2 | Allgon | Alf Ahlström (alf.ahlstrom@pwav.com) | Issam | RInImp-UEAnTM2 |  |  |  |
| 4545 | 9.4 | Deleted - FS on the evolution of the UTRAN architecture |  | 592d | 2002-09-09 A | 2004-12-14 A | 100% | 2002-09-09 | 2004-12-14 | 592d | finish no earlier than 2004-12-15 | R3 | 4736h | 4736h | Rel-6 | RANimp-FSEvo | Nokia | woonhee.hwang@nsn.com, Antti.Toskala@nokia.com | Juha | RANimp-FSEvo |  |  | RP-26 |

Notes:
- 4521: -
- 4522: -
- 4523: -
- 4524: -
- 4525: -
- 4526: Introduction of UMTS850 (Band V) in 25.307
- 4527: Introduction of UMTS800 in 25.307
- 4528: Introduction of UMTS1700/2100 (Band IV)
- 4529: -
- 4530: -
- 4531: Approved at RP#25 as RP-040375
- 4532: -
- 4533: -
- 4534: -
- 4535: -
- 4536: -
- 4537: Study finished at RP#25
- 4538: -
- 4539: -
- 4540: -
- 4541: Study finished at RP#25
- 4542: -
- 4543: -
- 4544: The RInImp-UEAnTM FS was re-opened at TSG RP#15 upon request from WG4
- 4545: Study Closed, work will continue within the FS on evolved UTRA and UTRAN

| ID | WBS | Task | Type | Duration | Start | Finish | Complete | Baseline start | Baseline finish | Baseline duration | Constraint | Deadline | Resources | Work | Actual work | Acronym | WI rapporteur name | WI rapporteur e-mail | Release | MCC resp | Acronym_3GU_Export | Impacted TSs and TRs | Created at | TSG stopped |
| --- | --- | --- | --- | --- | --- | --- | --- | --- | --- | --- | --- | --- | --- | --- | --- | --- | --- | --- | --- | --- | --- | --- | --- | --- |
| 4546 | 1215 | **FDD Enhanced Uplink** |  | 915d | 2004-03-15 A | 2007-09-14 A | 100% | 2004-03-15 | 2007-09-14 | 915d |  |  | R2; R1; R3; R4; R5 | 49800h | 49800h | EDCH | Ericsson | Joakim Bergström | Rel-6 | Yong-Jun | EDCH |  |  |  |
| 4547 | 1215.1 | FDD Enhanced Uplink - Stage 2 |  | 197d | 2004-03-15 A | 2004-12-14 A | 100% | 2004-03-15 | 2004-12-14 | 197d | finish no earlier than 2004-12-14 |  | R2 | 1576h | 1576h | EDCH-Stage2 |  |  | Rel-6 | Yong-Jun | EDCH-Stage2 | 25.309 |  |  |
| 4548 | 1215.2 | FDD Enhanced Uplink - Physical Layer |  | 261d | 2004-03-15 A | 2005-03-14 A | 100% | 2004-03-15 | 2005-03-14 | 261d | finish no earlier than 2005-03-14 |  | R1 | 2088h | 2088h | EDCH-Phys | Nokia | Karri.Ranta-aho@nsn.com | Rel-6 | Patrick | EDCH-Phys | 25.211, 25.212, 25.213, 25.214, 25.215 |  |  |
| 4549 | 1215.3 | FDD Enhanced Uplink - Layer 2 and 3 Protocol Aspects |  | 261d | 2004-03-15 A | 2005-03-14 A | 100% | 2004-03-15 | 2005-03-14 | 261d | finish no earlier than 2005-03-14 |  | R2 | 2088h | 2088h | EDCH-L23 | Ericsson | Joakim Bergström | Rel-6 | Yong-Jun | EDCH-L23 | 25.301, 25.302, 25.306, 25.321, 25.331 |  |  |
| 4550 | 1215.4 | FDD Enhanced Uplink - UTRAN Iub/Iur Protocol Aspects |  | 261d | 2004-03-15 A | 2005-03-14 A | 100% | 2004-03-15 | 2005-03-14 | 261d | finish no earlier than 2005-03-14 |  | R3 | 2088h | 2088h | EDCH-IurIub | Nortel | Saso Stojanovski | Rel-6 | Juha | EDCH-IurIub | 25.401, 25.420, 25.423, 25.430, 25.433 |  |  |
| 4551 | 1215.5 | FDD Enhanced Uplink - RF Radio Transmission/ Reception, System Performance Requirements and Conformance Testing |  | 74d | 2004-03-15 A | 2004-06-24 A | 100% | 2004-03-15 | 2004-06-24 | 74d |  |  | R4 | 592h | 592h | EDCH-RF | Ericsson | thomas.unshelm@ericsson.com | Rel-6 | Issam | EDCH-RF | 25.101, 25.104, 25.133, 25.141 |  |  |
| 4552 | 1215.6 | Conformance Test Aspects – FDD Enhanced Uplink |  | 596d | 2005-06-03 A | 2007-09-14 A | 100% | 2005-06-03 | 2007-09-14 | 596d | finish no earlier than 2007-09-14 | 2006-06-02 | R5 | 4768h | 4768h | EDCH_Test | Ericsson | Leif.Mattisson@ericsson.com | Rel-6 | Ingbert | EDCH_Test | 34.108, 34.109, 34.121, 34.123-1, 34.123-2, 34.123-3 | Fri 03/06/05 |  |
| 4553 | 1216 | **Rel-6 RAN improvements** |  | 656d? | 2002-09-09 A | 2005-03-14 A | 100% | 2002-09-09 | 2005-03-14 | 656d? |  |  | RP; S5 | 36720h | 36720h |  |  |  | Rel-6 |  |  |  |  |  |
| 4554 | 9.2 | **RAB support enhancement** |  | 522d? | 2003-03-14 A | 2005-03-14 A | 100% | 2003-03-14 | 2005-03-14 | 522d? |  |  | R2 | 9360h | 9360h |  | Nokia | Jussi Kähtävä (juha.mikola@nokia.com) | Rel-6 | Yong-Jun |  | 25.862 |  |  |
| 4555 | 1216.1.1 | Optimization of downlink channelisation code utilisation |  | 262d | 2004-03-12 A | 2005-03-14 A | 100% | 2004-03-12 | 2005-03-14 | 262d | finish no earlier than 2005-03-14 |  | R1 | 2096h | 2096h | RANimp-RABSE-CodeOptFDD | Nortel | Sarah Boumendil | Rel-6 | Patrick | RANimp-RABSE-CodeOptFDD |  |  |  |
| 4556 | 1216.1.2 | optimization of channelisation code utilisation for 3.84 Mcps TDD |  | 261d | 2004-03-15 A | 2005-03-14 A | 100% | 2004-03-15 | 2005-03-14 | 261d | finish no earlier than 2005-03-15 |  | R1 | 2088h | 2088h | RANimp-RABSE-CodOptTDD | IPWireless | Nicholas Anderson | Rel-6 | Patrick | RANimp-RABSE-CodOptTDD |  |  |  |
| 4557 | 1216.1.3 | HS-DPCCH ACK/NACK Enhancement |  | 65d? | 2004-09-15 A | 2004-12-14 A | 100% | 2004-09-15 | 2004-12-14 | 65d? | finish no earlier than 2004-12-15 |  | R1 | 520h | 520h | RANimp-RABSE-ACKNACK | Nokia | Jussi Kähtävä (juha.mikola@nokia.com) | Rel-6 | Patrick | RANimp-RABSE-ACKNACK | 25.212, 25.214, 24.331, 25.433 |  |  |
| 4558 | 1216.1.4 | Deleted - Iu enhancements for IMS support in RAN |  | 320d? | 2003-03-14 A | 2004-06-03 A | 100% | 2003-03-14 | 2004-06-03 | 320d? | start no earlier than 2003-03-14 |  | R3 | 2560h | 2560h | RANimp-RABSE-IuEnhIMS | Nortel | Philippe.Godin@nortelnetworks.com | Rel-6 | Juha | RANimp-RABSE-IuEnhIMS |  |  | RP-24 |
| 4559 | 1216.1.5 | Deleted - Improvement of RRM across RNS and RNS/BSS | milestone | 0d? | 2003-12-05 A | 2003-12-05 A | 100% | 2003-12-05 | 2003-12-05 | 0d? | finish no earlier than 2003-12-05 |  | R3 |  |  | RANimp-RRM1 | Nokia | antti.toskala@nokia.com | Rel-6 | Juha | RANimp-RRM1 |  |  | RP-23 |
| 4560 | 9.1 | Beamforming Enhancements |  | 66d | 2003-09-19 A | 2003-12-19 A | 100% | 2003-09-19 | 2003-12-19 | 66d | finish no earlier than 2004-03-12 |  | R1 | 528h | 528h | RANimp-BFE | Nokia | Jussi Kähtävä (juha.mikola@nokia.com) | Rel-6 | Patrick | RANimp-BFE | 24.215, 25.423, 25.425, 25.433, 25.435 |  |  |
| 4561 | 1216.3 | **Rel-6 RRM optimization for Iur and Iub** |  | 126d | 2003-09-19 A | 2004-03-12 A | 100% | 2003-09-19 | 2004-03-12 | 126d |  |  | R3 | 2016h | 2016h | RANimp-RRMopt-UEMsD | Ericsson | Gert-Jan.van.Lieshout@eln.ericsson.se | Rel-6 | Juha | RANimp-RRMopt-UEMsD |  |  |  |
| 4562 | 1216.3.1 | Improved access to UE measurement data for CRNC to support TDD RRM |  | 126d | 2003-09-19 A | 2004-03-12 A | 100% | 2003-09-19 | 2004-03-12 | 126d | finish no earlier than 2004-03-15 |  | R3 | 1008h | 1008h |  | Interdigital | jim.miller@interdigital.com | Rel-6 | Juha |  | 25.423 |  | RP-22 |
| 4563 | 1216.4 | **Remote Control of Electrical Tilting Antennas** |  | 395d? | 2003-03-14 A | 2004-09-16 A | 100% | 2003-03-14 | 2004-09-16 | 395d? |  |  | R3; S5 | 10624h | 10624h | RANimp-TiltAnt | Vodafone | Andreas.Hauser@vodafone.com | Rel-6 | Juha | RANimp-TiltAnt |  |  |  |
| 4564 | 1216.4.1 | Tilting Antenna - RAN aspects |  | 393d? | 2003-03-14 A | 2004-09-14 A | 100% | 2003-03-14 | 2004-09-14 | 393d? | finish no earlier than 2004-09-14 |  | R3 | 3144h | 3144h |  | Vodafone | Andreas.Hauser@vodafone.com | Rel-6 | Juha |  | 25.460, 25.461, 25.462, 25.463 |  |  |
| 4565 | 1216.4.2 | OAM&P impacts |  | 145d | 2004-02-27 A | 2004-09-16 A | 100% | 2004-02-27 | 2004-09-16 | 145d | finish no earlier than 2004-09-16 |  | S5 | 1160h | 1160h | RANimp-TiltAnt-OAM | Vodafone | Adrian.Neal@vodafone.com | Rel-6 | Mirko | RANimp-TiltAnt-OAM | 32.804, 32.64x | SP-24 |  |
| 4566 | 1216.5 | Network Assisted Cell Change (NACC) from UTRAN to GERAN - network-side aspects |  | 462d? | 2002-09-09 A | 2004-06-15 A | 100% | 2002-09-09 | 2004-06-15 | 462d? | finish no earlier than 2004-06-15 |  | R3 | 3696h | 3696h | RANimp-NACC | Vodafone | Brendan.McWilliams@gb.vodafone.co.uk | Rel-6 | Juha | RANimp-NACC |  |  |  |
| 4567 | 12 | **Location Services enhancements 2** |  | 1024d? | 2001-01-15 A | 2004-12-16 A | 100% | 2001-01-15 | 2004-12-16 | 1024d? |  |  | S2; S5; N4; R2; R4; R5; OMA | 175184h | 175184h | LCS2 | Nokia | Jan Kåll | Rel-6 | Maurice | LCS2 |  |  |  |
| 4568 | 12.1 | **Improvement on Le interface** |  | 653d? | 2002-06-17 A | 2004-12-15 A | 100% | 2002-06-17 | 2004-12-15 | 653d? |  |  | S2; OMA | 15096h | 15096h |  | Nokia | Jan Kåll | Rel-6 | Maurice |  |  |  |  |
| 4569 | 1217.1.1 | Stage 2 for Improvement on Le interface |  | 331d? | 2002-06-17 A | 2003-09-22 A | 100% | 2002-06-17 | 2003-09-22 | 331d? | start no earlier than 2002-06-17 |  | S2 | 2648h | 2648h |  | Nokia | Jan Kåll | Rel-6 | Maurice |  | 23.002,23.271 |  |  |
| 4570 | 1217.1.2 | Stage 3 - impacts MLP (Mobile Location Protocol) |  | 250d? | 2004-01-01 A | 2004-12-15 A | 100% | 2004-01-01 | 2004-12-15 | 250d? | finish no earlier than 2004-12-15 |  | OMA | 2000h | 2000h |  | OMA | OMA-LIAISON@mail.openmobilealliance.org | Rel-6 |  |  |  |  |  |

Notes:
- 4546: -
- 4547: -
- 4548: -
- 4549: -
- 4550: -
- 4551: -
- 4552: -
- 4553: Generic feature
- 4554: building block without particular end date
- 4555: -
- 4556: WIDS modified in RP#26, RP-040551
- 4557: Approved at RP#25 as RP-040390
- 4558: Closed RP#24 due to the lack of progress
- 4559: abandoned RP-23
- 4560: -
- 4561: -
- 4562: -
- 4563: -
- 4564: Finished at RP#25
- 4565: SP#25 09/2004 completed
- 4566: -
- 4567: -
- 4568: -
- 4569: -
- 4570: -

| ID | WBS | Task | Type | Duration | Start | Finish | Complete | Baseline start | Baseline finish | Baseline duration | Constraint | Resources | Work | Actual work | WI rapporteur name | WI rapporteur e-mail | Release | MCC resp | Acronym | Acronym_3GU_Export | TSG stopped |
| --- | --- | --- | --- | --- | --- | --- | --- | --- | --- | --- | --- | --- | --- | --- | --- | --- | --- | --- | --- | --- | --- |
| 4571 | 12.2 | **Enhanced support for anonymity and user privacy** |  | 638d? | 2002-07-08 A | 2004-12-15 A | 100% | 2002-07-08 | 2004-12-15 | 638d? |  | S2; OMA | 14248h | 14248h | Nokia | Jan Kåll | Rel-6 | Maurice |  |  |  |
| 4572 | 1217.2.1 | Stage 2 for Enhanced support for anonymity and user privacy |  | 255d? | 2002-07-08 A | 2003-06-27 A | 100% | 2002-07-08 | 2003-06-27 | 255d? | finish no earlier than 2003-06-27 | S2 | 2040h | 2040h | Nokia | Jan Kåll | Rel-6 | Maurice |  |  |  |
| 4573 | 1217.2.2 | Stage 3 - impacts MLP and RLP |  | 250d? | 2004-01-01 A | 2004-12-15 A | 100% | 2004-01-01 | 2004-12-15 | 250d? | finish no earlier than 2004-12-15 | OMA | 2000h | 2000h | OMA | OMA-LIAISON@mail.openmobilealliance.org | Rel-6 |  |  |  |  |
| 4574 | 12.3 | **Enhanced inter-GMLC interface** |  | 648d? | 2002-06-24 A | 2004-12-15 A | 100% | 2002-06-24 | 2004-12-15 | 648d? |  | S2; OMA | 14888h | 14888h | Nokia | Jan Kåll | Rel-6 | Maurice |  |  |  |
| 4575 | 1217.3.1 | Stage 2 for Enhanced inter-GMLC interface |  | 315d? | 2002-06-24 A | 2003-09-05 A | 100% | 2002-06-24 | 2003-09-05 | 315d? | finish no earlier than 2003-09-05 | S2 | 2520h | 2520h | Nokia | Jan Kåll | Rel-6 | Maurice |  |  |  |
| 4576 | 1217.3.2 | Stage 3 - definition of RLP and PCP |  | 250d? | 2004-01-01 A | 2004-12-15 A | 100% | 2004-01-01 | 2004-12-15 | 250d? | finish no earlier than 2004-12-15 | OMA | 2000h | 2000h | OMA | OMA-LIAISON@mail.openmobilealliance.org | Rel-6 |  |  |  |  |
| 4577 | 12.4 | **Location Services support for IMS public identities** |  | 473d? | 2003-02-24 A | 2004-12-15 A | 100% | 2003-02-24 | 2004-12-15 | 473d? |  | S2; OMA | 11488h | 11488h | Nokia | Jan Kåll | Rel-6 | Maurice |  |  |  |
| 4578 | 1217.4.1 | Stage 2 for Location Services support for IMS public identities |  | 240d? | 2003-02-24 A | 2004-01-23 A | 100% | 2003-02-24 | 2004-01-23 | 240d? | finish no earlier than 2004-01-23 | S2 | 1920h | 1920h | Nokia | Jan Kåll | Rel-6 | Maurice |  |  |  |
| 4579 | 1217.4.2 | OMA Stage 3 for Location Services support for IMS public identities - impacts MLP, RLP and PCP |  | 250d? | 2004-01-01 A | 2004-12-15 A | 100% | 2004-01-01 | 2004-12-15 | 250d? | finish no earlier than 2004-12-15 | OMA | 2000h | 2000h | OMA | OMA-LIAISON@mail.openmobilealliance.org | Rel-6 |  |  |  |  |
| 4580 | 12.5 | **New area event for location service triggering reports** |  | 663d? | 2002-06-03 A | 2004-12-15 A | 100% | 2002-06-03 | 2004-12-15 | 663d? |  | S2; N4; OMA | 22024h | 22024h | Nokia | Jan Kåll | Rel-6 | Maurice |  |  |  |
| 4581 | 1217.5.1 | Stage 2 for New area event for location service triggering reports |  | 280d? | 2002-06-03 A | 2003-06-27 A | 100% | 2002-06-03 | 2003-06-27 | 280d? | finish no earlier than 2003-06-27 | S2 | 2240h | 2240h | Nokia | Jan Kåll | Rel-6 | Maurice |  |  |  |
| 4582 | 1217.5.2 | Stage 3 for UE-CN signalling |  | 234d? | 2003-10-09 A | 2004-08-31 A | 100% | 2003-10-09 | 2004-08-31 | 234d? | start no earlier than 2003-10-09 | N4 | 1872h | 1872h | Nokia |  | Rel-6 | Kimmo |  |  |  |
| 4583 | 1217.5.3 | Stage 3 for New area event for location service triggering reports - impacts MLP, RLP and PCP |  | 250d? | 2004-01-01 A | 2004-12-15 A | 100% | 2004-01-01 | 2004-12-15 | 250d? | finish no earlier than 2004-12-15 | OMA | 2000h | 2000h | OMA | OMA-LIAISON@mail.openmobilealliance.org | Rel-6 |  |  |  |  |
| 4584 | 12.7 | **UE positioning for Location Services enhancements 2** |  | 957d? | 2001-01-15 A | 2004-09-14 A | 100% | 2001-01-15 | 2004-09-14 | 957d? |  | R2; R4; R5 | 36456h | 36456h |  |  | Rel-6 | Issam | LCS2-UEpos | LCS2-UEpos |  |
| 4585 | 12.8 | Open SMLC-SRNC Interface within the UTRAN to support UTRAN Rel-4 positioning methods |  | 700d? | 2001-01-15 A | 2003-09-19 A | 100% | 2001-01-15 | 2003-09-19 | 700d? | finish no earlier than 2003-09-19 | R2 | 5600h | 5600h | Siemens | Meik.Kottkamp@siemens.com | Rel-6 | Yong-Jun | LCS-Rel4Pos | LCS-Rel4Pos |  |
| 4586 | 1217.6.2 | A-GPS minimum performance specification |  | 333d? | 2003-06-06 A | 2004-09-14 A | 100% | 2003-06-06 | 2004-09-14 | 333d? | finish no earlier than 2004-09-14 | R4; R5 | 5328h | 5328h | AT&T Wireless | donglin.shen@attws.com | Rel-6 | Issam | LCS-UEPos-AGPSPerf | LCS-UEPos-AGPSPerf |  |
| 4587 | 12.7.2 | Deleted - FS on Enhancements to OTDOA Positioning using advanced blanking methods |  | 320d | 2002-07-01 A | 2003-09-19 A | 100% | 2002-07-01 | 2003-09-19 | 320d | finish no earlier than 2003-09-19 | R2 | 2560h | 2560h | Cambridge Positioning Systems | david.bartlett@cursor-system.com | Rel-6 | Yong-Jun | LCS2-UEpos-FSBlank | LCS2-UEpos-FSBlank | RP-38 |
| 4588 | 1217.6.4 | Deleted - UE positioning enhancements - other methods | milestone | 0d? | 2003-09-26 A | 2003-09-26 A | 100% | 2003-09-26 | 2003-09-26 | 0d? | finish no earlier than 2003-09-26 | R2 |  |  | Siemens | Meik.Kottkamp@siemens.com | Rel-6 | Yong-Jun | LCS2-UEpos-enh | LCS2-UEpos-enh | RP-24 |
| 4589 | 1217.7 | LCS charging |  | 455d? | 2003-03-21 A | 2004-12-16 A | 100% | 2003-03-21 | 2004-12-16 | 455d? | start no earlier than 2003-03-21 | S5 | 3640h | 3640h | France Telecom | alain.bibas@orange-ft.com | Rel-6 | Mirko | LCS2-CH | LCS2-CH |  |
| 4590 | 14 | **Rel-6 Security enhancements** |  | 1018d? | 2001-01-03 A | 2004-11-26 A | 100% | 2001-01-03 | 2004-11-26 | 1018d? |  | S3 | 28824h | 28824h | Vodafone | Peter.Howard@vodafone.com | Rel-6 | Mirko | SEC16 | SEC1, Rel-6 |  |
| 4591 | 14.1 | **Enhanced HE control of security (including positive authentication reporting)** |  | 712d | 2001-01-03 A | 2003-09-25 A | 100% | 2001-01-03 | 2003-09-25 | 712d |  | S3 | 14064h | 14064h | Vodafone | Peter.Howard@vodafone.com | Rel-6 | Mirko |  |  |  |
| 4592 | 14.1.1 | Deleted - SEC1 Stage 2 (Enhanced HE control of security) |  | 378d | 2001-01-03 A | 2002-06-14 A | 100% | 2001-01-03 | 2002-06-14 | 378d | finish no earlier than 2002-06-14 | S3 | 3024h | 3024h |  |  | Rel-6 | Mirko |  |  | SP-16 |
| 4593 | 14.1.3 | **Rel-6 Network Domain Security** |  | 334d | 2002-06-17 A | 2003-09-25 A | 100% | 2002-06-17 | 2003-09-25 | 334d |  | S3 | 5344h | 5344h | Telenor | Geir-myrdahl.koien@telenor.com | Rel-6 | Mirko | SEC1-NDS | SEC1-NDS |  |
| 4594 | 14.1.3.1 | Rel-6 IP network layer security (NDS/IP) |  | 334d | 2002-06-17 A | 2003-09-25 A | 100% | 2002-06-17 | 2003-09-25 | 334d | finish no earlier than 2003-09-25 | S3 | 2672h | 2672h |  |  | Rel-6 | Mirko | SEC1-NDS-IP | SEC1-NDS-IP |  |
| 4595 | 1218.2 | Network Domain Security; Authentication Framework (NDS/AF) |  | 521d? | 2002-02-15 A | 2004-02-13 A | 100% | 2002-02-15 | 2004-02-13 | 521d? | finish no earlier than 2004-02-13 | S3 | 4168h | 4168h | Nokia | tommi.viitanen@nokia.com | Rel-6 | Mirko | SEC1-NDS-AF | SEC1-NDS-AF |  |
| 4596 | 1218.3 | Key Management of group keys for Voice Group Call Services |  | 306d | 2003-09-26 A | 2004-11-26 A | 100% | 2003-09-26 | 2004-11-26 | 306d | finish no earlier than 2004-11-26 | S3 | 2448h | 2448h | Vodafone | benno.tietz@vodafone.com | Rel-6 | Mirko | SECGKYV | SECGKYV |  |
| 4597 | 1219 | Network Domain Security; MAP application layer security (NDS/MAPsec) |  | 127d? | 2004-07-06 A | 2004-12-29 A | 100% | 2004-07-06 | 2004-12-29 | 127d? | finish no earlier than 2003-12-26 | S3 | 1016h | 1016h | Vodafone | Peter.Howard@vodafone.com | Rel-6 | Mirko | MAPSEC | MAPSEC |  |

Notes:
- 4571: -
- 4572: - / Impacted TSs and TRs: 23.002,23.271
- 4573: -
- 4574: -
- 4575: - / Impacted TSs and TRs: 23.002,23.271
- 4576: -
- 4577: -
- 4578: - / Impacted TSs and TRs: 23.002,23.271
- 4579: -
- 4580: -
- 4581: - / Impacted TSs and TRs: 23.002,23.271
- 4582: Current stage 3 fullfills stage 2
- 4583: -
- 4584: -
- 4585: - / Impacted TSs and TRs: 25.305, 25.401, 25.450, 25.452, 25.453
- 4586: RP#25 completed (FDD) / Impacted TSs and TRs: new 25.171, 34.171 (testing)
- 4587: RP#38 Work stopped / Impacted TSs and TRs: new TR 25.894
- 4588: RP#24 Work stopped
- 4589: SP#26 completed / Impacted TSs and TRs: new TS 32.271
- 4590: SP#9 approved WID. Acronym changed from "SEC1, Rel-6"
- 4591: SP#9 approved WID S3-000490 (Enhanced home control of security by HE) / Impacted TSs and TRs: 33.102
- 4592: Marked as stopped 12/2008
- 4593: SP#9 approved WID S3-000606 (Network Domain Security) / Impacted TSs and TRs: 33.102, 33.103, 33.105
- 4594: SP#9 approved WID S3-000626 (Access security for IP-based services) / Impacted TSs and TRs: 33.210
- 4595: SP#19 approved WID / Impacted TSs and TRs: 33.810
- 4596: - / Impacted TSs and TRs: 42.068, 43.068, 44.068, 42.069, 43.069, 44.069, 31.102, 24.008, 48.008, 42.009, 43.020, New TSs (55.236, 55.205) MILENAGE algorithms
- 4597: SP#19 approved WID. Marked as closed 12/2008 (was marked 20% complete) / Impacted TSs and TRs: 33.200

| ID | WBS | Task | Type | Duration | Start | Finish | Complete | Baseline start | Baseline finish | Baseline duration | Constraint | Resources | Work | Actual work | Acronym | Release | MCC resp | Acronym_3GU_Export | Impacted TSs and TRs | WI rapporteur name | WI rapporteur e-mail | TSG stopped |
| --- | --- | --- | --- | --- | --- | --- | --- | --- | --- | --- | --- | --- | --- | --- | --- | --- | --- | --- | --- | --- | --- | --- |
| 4598 | 16 | **IMS Phase 2** |  | 1840d? | 2000-08-28 A | 2007-09-14 A | 100% | 2000-08-28 | 2007-09-14 | 1840d? |  | S1; S2; S3; S5; NP; R5 | 210576h | 210576h | IMS2 | Rel-6 | Alain | IMS2 |  |  |  |  |
| 4599 | 1220.1 | Enhancements to the Cx and Sh interfaces |  | 323d? | 2003-06-06 A | 2004-08-31 A | 100% | 2003-06-06 | 2004-08-31 | 323d? | finish no earlier than 2004-08-31 | N4 | 2584h | 2584h | IMS2-CCR | Rel-6 | Kimmo | IMS2-CCR |  |  |  |  |
| 4600 | 1220.2 | Conformance Test Aspects – IMS Call Control Rel-6 enhancements |  | 396d? | 2006-03-10 A | 2007-09-14 A | 100% | 2006-03-10 | 2007-09-14 | 396d? | finish no earlier than 2007-09-14 | R5 | 3168h | 3168h | IMS2_CCR_Test | Rel-6 | Ingbert | IMS2_CCR_Test | 34.229-1, 34.229-2, 34.229-3, 34.108 | Ericsson | Jacob.John@motorola.com, Leif.Mattisson@ericsson.com |  |
| 4601 | 16.12 | **IMS Group Management** |  | 715d? | 2002-03-14 A | 2004-12-08 A | 100% | 2002-03-14 | 2004-12-08 | 715d? |  | S1 | 12680h | 12680h | IMSGM | Rel-6 | Alain | IMSGM |  | Nokia | juha.kalliokulju@nokia.com |  |
| 4602 | 16.12.1 | Stage 1 - TS on IMS group management |  | 193d | 2002-03-14 A | 2002-12-09 A | 100% | 2002-03-14 | 2002-12-09 | 193d | finish no earlier than 2002-12-09 | S1 | 1544h | 1544h |  | Rel-6 | Alain |  |  | Nokia | juha.kalliokulju@nokia.com |  |
| 4603 | 1220.3.2 | Stage 2 for IMS Group Management |  | 158d? | 2003-05-26 A | 2003-12-31 A | 100% | 2003-05-26 | 2003-12-31 | 158d? | finish no earlier than 2003-12-31 | S2 | 1264h | 1264h |  | Rel-6 | Maurice |  | 23.228 |  |  |  |
| 4604 | 1220.3.3 | Stage 3 for IMS Group management (e.g. chat) |  | 519d? | 2002-12-13 A | 2004-12-08 A | 100% | 2002-12-13 | 2004-12-08 | 519d? | finish no earlier than 2004-12-08 | N1 | 4152h | 4152h |  | Rel-6 | Frederic |  |  | Lucent | Keith Drage (drage@alcatel-lucent.com) |  |
| 4605 | 1220.4 | **IMS Conferencing** |  | 548d? | 2002-11-04 A | 2004-12-08 A | 100% | 2002-11-04 | 2004-12-08 | 548d? |  | N1 | 10960h | 10960h |  | Rel-6 | Frederic |  |  |  |  |  |
| 4606 | 1220.4.1 | Stage 2 for IMS Conferencing |  | 303d? | 2002-11-04 A | 2003-12-31 A | 100% | 2002-11-04 | 2003-12-31 | 303d? | finish no earlier than 2003-12-31 | S2 | 2424h | 2424h |  | Rel-6 | Maurice |  | 23.228 |  |  |  |
| 4607 | 1220.4.2 | Stage 3 for IMS Conferencing |  | 519d? | 2002-12-13 A | 2004-12-08 A | 100% | 2002-12-13 | 2004-12-08 | 519d? | finish no earlier than 2004-12-08 | N1 | 4152h | 4152h |  | Rel-6 | Frederic |  |  | Lucent | Keith Drage (drage@alcatel-lucent.com) |  |
| 4608 | 16.11 | **IMS Messaging** |  | 992d? | 2002-03-14 A | 2005-12-30 A | 100% | 2002-03-14 | 2005-12-30 | 992d? |  | S1 | 23912h | 23912h | IMSM | Rel-6 | Alain | IMSM |  | Nokia | juha.kalliokulju@nokia.com |  |
| 4609 | 16.11.1 | TR on support of messaging in the IMS |  | 193d | 2002-03-14 A | 2002-12-09 A | 100% | 2002-03-14 | 2002-12-09 | 193d | finish no earlier than 2002-12-09 | S1 | 1544h | 1544h | IMSM-TR | Rel-6 | Alain | IMSM-TR | New 22.940 | Nokia | juha.kalliokulju@nokia.com |  |
| 4610 | 1220.5.2 | Stage 1 22.340 |  | 23d? | 2002-11-11 A | 2002-12-11 A | 100% | 2002-11-11 | 2002-12-11 | 23d? | finish no earlier than 2002-12-11 | S1 | 184h | 184h | IMSM-TS | Rel-6 | Alain | IMSM-TS | 22.340 | Nokia | juha.kalliokulju@nokia.com |  |
| 4611 | 1220.5.3 | CRs to 22.140 & 22.228 |  | 263d? | 2002-03-14 A | 2003-03-17 A | 100% | 2002-03-14 | 2003-03-17 | 263d? | finish no earlier than 2003-03-17 | S1 | 2104h | 2104h | IMSM-CR | Rel-6 | Alain | IMSM-CR | 22.140,22.228 | Nokia | juha.kalliokulju@nokia.com |  |
| 4612 | 16.11.3 | Stage 2 for IMS Messaging |  | 477d | 2002-11-04 A | 2004-08-31 A | 100% | 2002-11-04 | 2004-08-31 | 477d | finish no earlier than 2004-08-31 | S2 | 3816h | 3816h |  | Rel-6 | Maurice |  | 23.228 |  |  |  |
| 4613 | 1220.5.5 | Stage 3 for IMS Messaging |  | 519d? | 2002-12-13 A | 2004-12-08 A | 100% | 2002-12-13 | 2004-12-08 | 519d? | finish no earlier than 2004-12-08 | N1 | 4152h | 4152h |  | Rel-6 | Frederic |  |  | Lucent | Keith Drage (drage@alcatel-lucent.com) |  |
| 4614 | 1220.5.6 | SIP/SIMPLE Instant messaging |  | 522d? | 2004-01-01 A | 2005-12-30 A | 100% | 2004-01-01 | 2005-12-30 | 522d? | finish no earlier than 2005-06-30 | OMA | 4176h | 4176h |  | Rel-6 |  |  |  |  | OMA-LIAISON@mail.openmobilealliance.org |  |
| 4615 | 1220.6 | **Additional SIP Capabilities support not covered by Rel-5** |  | 680d? | 2002-11-11 A | 2005-06-17 A | 100% | 2002-11-11 | 2005-06-17 | 680d? |  | N1 | 13392h | 13392h |  | Rel-6 | Frederic |  |  |  |  |  |
| 4616 | 1220.6.1 | Stage 2 for add SIP cap (e.g. forking) |  | 335d? | 2002-11-11 A | 2004-02-20 A | 100% | 2002-11-11 | 2004-02-20 | 335d? | finish no earlier than 2004-02-20 | S2 | 2680h | 2680h |  | Rel-6 | Maurice |  | 23.228 |  |  |  |
| 4617 | 1220.6.2 | Stage 3 for Additional SIP Capabilities |  | 454d? | 2002-12-13 A | 2004-09-08 A | 100% | 2002-12-13 | 2004-09-08 | 454d? | finish no earlier than 2004-09-08 | N1 | 3632h | 3632h |  | Rel-6 | Frederic |  |  | Lucent | Keith Drage (drage@alcatel-lucent.com) |  |
| 4618 | 1220.6.3 | Procedured associated with IMS-ALG |  | 205d? | 2004-09-06 A | 2005-06-17 A | 100% | 2004-09-06 | 2005-06-17 | 205d? | start no earlier than 2004-09-06 | N1 | 1640h | 1640h |  | Rel-6 | Frederic |  |  |  |  |  |
| 4619 | 1220.7 | Review additional SIP Capabilities against IMS |  | 454d? | 2002-12-13 A | 2004-09-08 A | 100% | 2002-12-13 | 2004-09-08 | 454d? | finish no earlier than 2004-09-08 | N1 | 3632h | 3632h |  | Rel-6 | Frederic |  |  | Lucent | Keith Drage (drage@alcatel-lucent.com) |  |
| 4620 | 16.5 | **Interworking between IMS and IP networks** |  | 1118d? | 2000-08-28 A | 2004-12-08 A | 100% | 2000-08-28 | 2004-12-08 | 1118d? |  | N3 | 31712h | 31712h | IMS-CCR-IWIP | Rel-6 | Gwiho | IMS-CCR-IWIP | 23.821, 29.061, 29.162 | BT | nigel.holland@bt.com |  |
| 4621 | 16.5.1 | Interworking for 3GPP_SIP and IETF_SIP |  | 730d | 2000-08-28 A | 2003-06-13 A | 100% | 2000-08-28 | 2003-06-13 | 730d | finish no earlier than 2003-06-13 | N3 | 5840h | 5840h |  | Rel-6 | Gwiho |  | New 29.962 | Siemens | Thomas.Belling@nsn.com |  |
| 4622 | 16.5.2 | Interworking for IPv6 to IPv4 |  | 1118d | 2000-08-28 A | 2004-12-08 A | 100% | 2000-08-28 | 2004-12-08 | 1118d | finish no earlier than 2004-12-08 | N3 | 8944h | 8944h |  | Rel-6 | Gwiho |  | 29.163 |  |  |  |
| 4623 | 1220.8.3 | Interworking for IPv6 to IPv4 (SIP / SDP aspects) |  | 87d? | 2004-05-11 A | 2004-09-08 A | 100% | 2004-05-11 | 2004-09-08 | 87d? | finish no earlier than 2004-09-08 | N1 | 696h | 696h |  | Rel-6 | Frederic |  |  |  |  |  |
| 4624 | 16.8.1 | stage 3 of interworking with non-IMS IP networks |  | 911d | 2001-03-14 A | 2004-09-08 A | 100% | 2001-03-14 | 2004-09-08 | 911d | finish no earlier than 2004-09-08 | N1 | 7288h | 7288h |  | Rel-6 | Frederic |  |  |  |  |  |
| 4625 | 16.6.1 | Interworking between IMS and CS networks |  | 929d? | 2000-08-28 A | 2004-03-18 A | 100% | 2000-08-28 | 2004-03-18 | 929d? | finish no earlier than 2004-03-18 | N3 | 7432h | 7432h | IMS-CCR-IWCS | Rel-6 | Gwiho | IMS-CCR-IWCS | 29.163, 29.061, 24.228, and New CN4 specification | Vodafone | Brendan.McWilliams@gb.vodafone.co.uk |  |
| 4626 | 16.10 | Mn interface (IM-MGW to MGCF) enhancements (CN4 Part) |  | 418d | 2001-08-07 A | 2004-09-01 A | 100% | 2001-08-07 | 2004-09-01 | 418d | finish no earlier than 2004-09-01 | N4 | 3344h | 3344h | IMS-CCR-Mn | Rel-6 | Kimmo | IMS-CCR-Mn |  |  |  |  |
| 4627 | 1220.11 | Study of subscriber and operators relationship in IMS and related ISIM requirements for Rel 6” |  | 20d? | 2002-11-15 A | 2002-12-12 A | 100% | 2002-11-15 | 2002-12-12 | 20d? | finish no earlier than 2002-12-12 | S1 | 160h | 160h |  | Rel-6 | Alain |  |  | Nokia | juha.kalliokulju@nokia.com |  |
| 4628 | 1220.12 | Lawful Interception in Rel-6 architecture |  | 269d? | 2002-12-09 A | 2003-12-18 A | 100% | 2002-12-09 | 2003-12-18 | 269d? | finish no earlier than 2003-12-18 | S3 | 2152h | 2152h | SEC1-LI | Rel-6 | Mirko | SEC1-LI, Rel-6 | 33.106, 33.107, 33.108 | Reg TP, Nortel | berthold.wilhelm@regtp.de, Ron Ryan |  |
| 4629 | 1220.13 | IMS Subscription and access scenarios |  | 130d? | 2002-12-16 A | 2003-06-13 A | 100% | 2002-12-16 | 2003-06-13 | 130d? | start no earlier than 2002-12-16 | S1 | 1040h | 1040h |  | Rel-6 | Alain |  | 22.800 | TeliaSonera | FRANK, Robert |  |
| 4630 | 1220.14 | IMS charging |  | 455d? | 2003-03-21 A | 2004-12-16 A | 100% | 2003-03-21 | 2004-12-16 | 455d? | finish no earlier than 2004-12-16 | S5 | 3640h | 3640h | IMS2-CH | Rel-6 | Mirko | IMS2-CH | 32.260 | Ericsson | Patrik TEPPO |  |
| 4631 | 1220.15 | IMS Management objects |  | 306d? | 2004-09-03 A | 2005-11-04 A | 100% | 2004-09-03 | 2005-11-04 | 306d? | finish no earlier than 2005-03-04 | N1 | 2448h | 2448h |  | Rel-6 | Frederic |  | 24.167 |  |  |  |
| 4632 | 1220.16 | Deleted - Stage 2 of IMS Phase 2 | milestone | 0d? | 2003-09-19 A | 2003-09-19 A | 100% | 2003-09-19 | 2003-09-19 | 0d? | finish no earlier than 2003-09-19 | S2 |  |  |  | Rel-6 | Maurice |  |  |  |  | SP-21 |

Notes:
- 4598: -
- 4599: Shared public user identities need to be solved. If email approval CR is accepted. Work 100% done.
- 4600: -
- 4601: -
- 4602: -
- 4603: -
- 4604: Depends on CN decision on CPCP in Rel-6. Complete, if unresolved IETF dependencies are dropped (-> LS to CN plenary)
- 4605: -
- 4606: -
- 4607: Depends on CN decision on IETF dependenciES in CP-150Rel-6. Higher figure if CPCP is dropped (-> LS to CN plenary)
- 4608: -
- 4609: -
- 4610: -
- 4611: -
- 4612: -
- 4613: -
- 4614: Updated according to SP-040232
- 4615: -
- 4616: -
- 4617: -
- 4618: -
- 4619: -
- 4620: [DAB 14.02.02] - end date pushed back to March 2003
- 4621: [DAB - 20.08.03] - CN Part of TR Complete @ CN#20
- 4622: -
- 4623: -
- 4624: -
- 4625: [DAB - 25.05.04] - CN3 consider this work to be complete
- 4626: TISPAN issue is open
- 4627: -
- 4628: Acronym changed from "SEC1-LI, Rel6"
- 4629: -
- 4630: SP#26 12/2004 completed
- 4631: -
- 4632: -

| ID | WBS | Task | Type | Duration | Start | Finish | Complete | Baseline start | Baseline finish | Baseline duration | Constraint | Resources | Work | Actual work | Acronym | WI rapporteur name | WI rapporteur e-mail | Release | MCC resp | Acronym_3GU_Export | Impacted TSs and TRs | Created at | TSG stopped |
| --- | --- | --- | --- | --- | --- | --- | --- | --- | --- | --- | --- | --- | --- | --- | --- | --- | --- | --- | --- | --- | --- | --- | --- |
| 4633 | 1221 | **3GPP Enablers for services like Push to Talk over Cellular (PoC)** |  | 459d? | 2003-09-08 A | 2005-06-09 A | 100% | 2003-09-08 | 2005-06-09 | 459d? |  | S2; S4; S5 | 18040h | 18040h | PoC | Ericsson | Shabnam Sultana | Rel-6 | Maurice | PoC |  |  |  |
| 4634 | 1221.1 | Feasibility Study on 3GPP Enablers for services like Push to Talk over Cellular (PoC) |  | 322d? | 2003-09-08 A | 2004-11-30 A | 100% | 2003-09-08 | 2004-11-30 | 322d? | finish no earlier than 2004-11-30 | S2 | 2576h | 2576h |  | Ericsson | Shabnam Sultana | Rel-6 | Maurice |  | 23.979 | SP-24 |  |
| 4635 | 1221.2 | Dependencies on OMA PoC |  | 303d? | 2004-01-01 A | 2005-02-28 A | 100% | 2004-01-01 | 2005-02-28 | 303d? | finish no earlier than 2004-12-30 | OMA | 2424h | 2424h |  |  | OMA-LIAISON@mail.openmobilealliance.org | Rel-6 |  |  |  | SP-24 |  |
| 4636 | 1221.3 | Selection of one or more PoC codec(s) for PoC |  | 69d? | 2004-09-13 A | 2004-12-16 A | 100% | 2004-09-13 | 2004-12-16 | 69d? | start no earlier than 2004-09-13 | S4 | 552h | 552h |  |  |  | Rel-6 | Paolo |  | 26.235, 26.236 | SP-25 |  |
| 4637 | 1221.4 | PoC charging |  | 184d? | 2004-09-27 A | 2005-06-09 A | 100% | 2004-09-27 | 2005-06-09 | 184d? | finish no earlier than 2005-06-09 | S5 | 1472h | 1472h | PoC-CH | Siemens | Gerald.Goermer@nsn.com | Rel-6 | Mirko | PoC-CH | 32.272 |  |  |
| 4638 | 1222 | Study on Interworking aspects and migration scenarios for IPv4 based IMS Implementations |  | 210d? | 2003-09-08 A | 2004-06-25 A | 100% | 2003-09-08 | 2004-06-25 | 210d? | finish no earlier than 2004-06-25 | S2 | 1680h | 1680h | IPv4IMS | Siemens | Alexander Milinski | Rel-6 | Maurice | IPv4IMS | 23.981 |  |  |
| 4639 | 16.3 | **Interoperability and Commonality between IMS using different IP-connectivity Networks** |  | 325d? | 2002-09-16 A | 2003-12-12 A | 100% | 2002-09-16 | 2003-12-12 | 325d? |  | S2 | 9176h | 9176h | IMSCOOP |  |  | Rel-6 | Maurice | IMSCOOP | 23.864 |  |  |
| 4640 | 16.3.1 | Stage 2 for Interoperability |  | 272d | 2002-09-16 A | 2003-09-30 A | 100% | 2002-09-16 | 2003-09-30 | 272d | finish no earlier than 2003-09-30 | S2 | 2176h | 2176h |  | Nokia | balazs.bertenyi@nsn.com | Rel-6 | Maurice |  | 23.864 |  |  |
| 4641 | 1223.2 | Stage 2 for commonality |  | 265d? | 2002-09-16 A | 2003-09-19 A | 100% | 2002-09-16 | 2003-09-19 | 265d? | start no earlier than 2002-09-16 | S2 | 2120h | 2120h |  | Nokia | balazs.bertenyi@nsn.com | Rel-6 | Maurice |  | 23.864 |  |  |
| 4642 | 16.3.2 | Stage 3 for Interoperability and Commonality between IMS using different IP-connectivity Networks |  | 305d | 2002-10-14 A | 2003-12-12 A | 100% | 2002-10-14 | 2003-12-12 | 305d | finish no earlier than 2003-12-12 | N1 | 2440h | 2440h |  | Lucent | Keith Drage (drage@alcatel-lucent.com) | Rel-6 | Frederic |  |  |  |  |
| 4643 | 17 | **Support of Push Services** |  | 823d | 2001-01-03 A | 2004-02-27 A | 100% | 2001-01-03 | 2004-02-27 | 823d |  | S1 | 11390.6h | 11390.6h | PUSH | NTT Comware | Yoshinori Kitada | Rel-6 | Alain | PUSH | 23.976 |  |  |
| 4644 | 17.1 | Stage 1 for Support of Push Services |  | 378d | 2001-01-03 A | 2002-06-14 A | 100% | 2001-01-03 | 2002-06-14 | 378d | finish no earlier than 2002-06-14 | S1 | 3024h | 3024h |  |  |  | Rel-6 | Alain |  |  |  |  |
| 4645 | 17.3 | TR 23.976 on Push Architecture |  | 340d | 2002-11-11 A | 2004-02-27 A | 100% | 2002-11-11 | 2004-02-27 | 340d | finish no earlier than 2004-02-27 | S2 | 2720h | 2720h |  | Research In Motion | Nick Alfano | Rel-6 | Maurice |  | 23.976 |  |  |
| 4646 | 18 | **Rel-6 Multimedia Messaging (MMS) enhancements** |  | 865d? | 2002-08-15 A | 2005-12-07 A | 100% | 2002-08-15 | 2005-12-07 | 865d? |  | T2; S1; S4; S5; OMA | 59616h | 59616h | MMS6 | Siemens | Josef.Laumen@SAL.SIEMENS.DE | Rel-6 | Kimmo | MMS6 |  |  |  |
| 4647 | 18.1 | **Definition of service requirements for MMS6** |  | 286d? | 2002-11-15 A | 2003-12-19 A | 100% | 2002-11-15 | 2003-12-19 | 286d? |  | S1 | 4576h | 4576h | MMS6-SR |  |  | Rel-6 | Alain | MMS6-SR | 22.140 |  |  |
| 4648 | 1225.1.1 | Definition of service requirements charging |  | 286d? | 2002-11-15 A | 2003-12-19 A | 100% | 2002-11-15 | 2003-12-19 | 286d? | finish no earlier than 2003-12-20 | S1 | 2288h | 2288h |  | Siemens | Josef.Laumen@SAL.SIEMENS.DE | Rel-6 | Alain |  | 22.140 |  |  |
| 4649 | 18.2 | Technical realization of MMS6 |  | 591d | 2002-09-06 A | 2004-12-10 A | 100% | 2002-09-06 | 2004-12-10 | 591d | finish no earlier than 2004-12-10 | T2 | 4728h | 4728h |  | Siemens | Josef.Laumen@SAL.SIEMENS.DE | Rel-6 | Kimmo |  | 23.140 |  |  |
| 4650 | 18.3 | OMA dependencies |  | 446d | 2003-08-15 A | 2005-04-29 A | 100% | 2003-08-15 | 2005-04-29 | 446d | finish no earlier than 2004-12-10 | OMA | 3568h | 3568h |  |  |  | Rel-6 | Kimmo |  | OMA specs |  |  |
| 4651 | 18.4 | MMS formats and codecs for MMS6 |  | 865d | 2002-08-15 A | 2005-12-07 A | 100% | 2002-08-15 | 2005-12-07 | 865d | finish no earlier than 2005-12-07 | S4 | 6920h | 6920h | MMS6-Codec | Nokia | roberto.castagno@nokia.com | Rel-6 | Paolo | MMS6-Codec | 26.140, 26.936 |  |  |
| 4652 | 1225.5 | Handling of private addressing schemes in MMS |  | 263d | 2003-12-10 A | 2004-12-10 A | 100% | 2003-12-10 | 2004-12-10 | 263d | finish no earlier than 2004-12-10 | T2 | 2104h | 2104h |  | T-Mobile | Steffen.Habermann@T-MOBILE.DE | Rel-6 | Kimmo |  | 23.140 |  |  |
| 4653 | 1225.6 | MMS charging |  | 390d? | 2003-03-21 A | 2004-09-16 A | 100% | 2003-03-21 | 2004-09-16 | 390d? | start no earlier than 2003-03-21 | S5 | 3120h | 3120h | MMS6-CH |  |  | Rel-6 | Mirko | MMS6-CH | 32.270 |  |  |
| 4654 | 1225.7 | Deleted - FS Multiple MMS Relay/Server Architecture | milestone | 0d | 2004-12-10 A | 2004-12-10 A | 100% | 2004-12-10 | 2004-12-10 | 0d | finish no earlier than 2004-12-10 | T2 |  |  |  | Telefónica Móviles | Juan Gorospe (gorospe_j@tsm.es) | Rel-6 | Kimmo |  | probably Annex to 23.140 |  | TP-26 |
| 4655 | 19 | **Rel-6 MExE enhancements** |  | 326d | 2002-03-08 A | 2003-06-06 A | 100% | 2002-03-08 | 2003-06-06 | 326d |  | T2 | 7328h | 7328h | MEXE6 |  |  | Rel-6 | Kimmo | MEXE6 |  |  |  |
| 4656 | 19.1 | MExE Rel-6 Improvements and Investigations |  | 264d | 2002-03-08 A | 2003-03-12 A | 100% | 2002-03-08 | 2003-03-12 | 264d | finish no earlier than 2003-03-12 | T2 | 2112h | 2112h | MEXE6-ENHANC | TTPCom | Lars Brenk ( (lsb_ttpcom@HOTMAIL.COM) | Rel-6 | Kimmo | MEXE6-ENHANC |  |  |  |
| 4657 | 19.2 | MExE Run-Time Independent Framework Feasibility Study |  | 326d | 2002-03-08 A | 2003-06-06 A | 100% | 2002-03-08 | 2003-06-06 | 326d | finish no earlier than 2003-06-06 | T2 | 2608h | 2608h | MEXE6-RTIF | Nokia Siemens Networks | balazs.bertenyi@nokia.com | Rel-6 | Kimmo | MEXE6-RTIF | 22.857 |  |  |
| 4658 | 21 | Subscription Management |  | 650d | 2002-09-20 A | 2005-03-17 A | 100% | 2002-09-20 | 2005-03-17 | 650d | finish no earlier than 2005-03-17 | S5 | 5200h | 5200h | SuM | T-Mobile | istvan.aba@t-mobile.at | Rel-6 | Mirko | SuM | 32.140/1, 32.171/2/5, 32.803 |  |  |

Notes:
- 4633: -
- 4634: -
- 4635: Updated according to SP-040232
- 4636: Completed
- 4637: SP#28 06/2005 completed
- 4638: -
- 4639: -
- 4640: No contributions assumed that no more will be done in 3GPP hence work may need to be done in 3GPP2
- 4641: -
- 4642: -
- 4643: Changed from FS to actual support of Push
- 4644: -
- 4645: -
- 4646: -
- 4647: -
- 4648: -
- 4649: -
- 4650: -
- 4651: -
- 4652: -
- 4653: SP#25 09/2004 completed
- 4654: originally it was intended to create a FS TR but most likely the work will become an Annex of 23.140
- 4655: -
- 4656: -
- 4657: -
- 4658: SP#27 03/2005 completed

| ID | WBS | Task | Duration | Start | Finish | Complete | Baseline start | Baseline finish | Baseline duration | Constraint | Resources | Work | Actual work | Acronym | WI rapporteur name | WI rapporteur e-mail | Release | MCC resp | Acronym_3GU_Export |
| --- | --- | --- | --- | --- | --- | --- | --- | --- | --- | --- | --- | --- | --- | --- | --- | --- | --- | --- | --- |
| 4659 | 22 | **Presence Capability** | 1233d? | 2001-03-19 A | 2005-12-07 A | 100% | 2001-03-19 | 2005-12-07 | 1233d? |  | S1; S2; S3; S4; N1; N3; N4; OMA | 111784h | 111784h | PRESNC | Motorola | Mark Cataldo | Rel-6 | Alain | PRESNC |
| 4660 | 22.1 | Stage 1 for Presence Capability | 610d | 2001-03-19 A | 2003-07-18 A | 100% | 2001-03-19 | 2003-07-18 | 610d | finish no earlier than 2003-07-18 | S1 | 4880h | 4880h |  | Motorola | Mark Cataldo | Rel-6 | Alain |  |
| 4661 | 22.2 | Stage 2 for Presence Capability | 268d | 2001-09-12 A | 2002-09-20 A | 100% | 2001-09-12 | 2002-09-20 | 268d | finish no earlier than 2002-09-20 | S2 | 2144h | 2144h |  | Nokia | balazs.bertenyi@nsn.com | Rel-6 | Maurice |  |
| 4662 | 22.3 | Stage 3 for Presence Capability | 703d | 2002-04-01 A | 2004-12-08 A | 100% | 2002-04-01 | 2004-12-08 | 703d | finish no earlier than 2004-12-08 | N1; N4 | 11248h | 11248h |  | Lucent | Keith Drage (drage@alcatel-lucent.com) | Rel-6 | Frederic |  |
| 4663 | 1228.4 | Stage 3 (CN3 Part Pk interface) | 770d? | 2002-04-01 A | 2005-03-11 A | 100% | 2002-04-01 | 2005-03-11 | 770d? | finish no earlier than 2005-03-11 | N3 | 6160h | 6160h |  | Lucent | Keith Drage (drage@alcatel-lucent.com) | Rel-6 | Gwiho |  |
| 4664 | 1228.5 | Media Codecs and Formats for IMS Messaging and Presence | 650d? | 2003-06-12 A | 2005-12-07 A | 100% | 2003-06-12 | 2005-12-07 | 650d? | finish no earlier than 2005-12-07 | S4 | 5200h | 5200h | PRESNC-COFIMP | Nokia | harri.honko@nokia.com | Rel-6 | Paolo | PRESNC-COFIMP |
| 4665 | 22.4 | Security aspects of Presence Capability | 79d | 2002-08-26 A | 2002-12-12 A | 100% | 2002-08-26 | 2002-12-12 | 79d | finish no earlier than 2002-12-12 | S3 | 632h | 632h |  | Ericsson | krister.boman@erv.ericsson.se | Rel-6 | Mirko |  |
| 4666 | 1228.7 | SIMPLE Presence | 326d? | 2004-01-01 A | 2005-03-31 A | 100% | 2004-01-01 | 2005-03-31 | 326d? | finish no earlier than 2004-12-30 | OMA | 2608h | 2608h |  |  | OMA-LIAISON@mail.openmobilealliance.org | Rel-6 |  |  |
| 4667 | 25 | **Enhanced A/Gb feasibility study** | 51d? | 2002-08-30 A | 2002-11-08 A | 100% | 2002-08-30 | 2002-11-08 | 51d? |  | GP | 3264h | 3264h | AGbEnFS | Vodafone | jose-luis.carrizo@vodafone.co.uk | Rel-6 | Paolo | AGbEnFS |
| 4668 | 25.1 | **Feasibility study on A/Gb enhancements** | 51d? | 2002-08-30 A | 2002-11-08 A | 100% | 2002-08-30 | 2002-11-08 | 51d? |  | G2 | 2856h | 2856h | AGbEnFS-FS | Vodafone | jose-luis.carrizo@vodafone.co.uk | Rel-6 | Gert | AGbEnFS-FS |
| 4669 | 25.1.1 | Requirements for the support of conversational services | 51d | 2002-08-30 A | 2002-11-08 A | 100% | 2002-08-30 | 2002-11-08 | 51d | finish no earlier than 2002-11-08 | GP | 408h | 408h |  |  |  | Rel-6 | Paolo |  |
| 4670 | 1229.1.2 | Identification of the different building blocks for the provision of conversational services on the existing A/Gb protocol stack | 51d? | 2002-08-30 A | 2002-11-08 A | 100% | 2002-08-30 | 2002-11-08 | 51d? | finish no earlier than 2002-11-08 | GP | 408h | 408h |  |  |  | Rel-6 | Paolo |  |
| 4671 | 1229.1.3 | Outline of impact and feasibility of these building blocks and their different solutions | 51d? | 2002-08-30 A | 2002-11-08 A | 100% | 2002-08-30 | 2002-11-08 | 51d? | finish no earlier than 2002-11-08 | GP | 408h | 408h |  |  |  | Rel-6 | Paolo |  |
| 4672 | 25.1.4 | Impact on 3GPP architecture and requirement to co-ordinatge with other TSGs (CN, SA) | 51d | 2002-08-30 A | 2002-11-08 A | 100% | 2002-08-30 | 2002-11-08 | 51d | finish no earlier than 2002-11-08 | GP | 408h | 408h |  |  |  | Rel-6 | Paolo |  |
| 4673 | 25.1.5 | Standardisation effort | 51d | 2002-08-30 A | 2002-11-08 A | 100% | 2002-08-30 | 2002-11-08 | 51d | finish no earlier than 2002-11-08 | GP | 408h | 408h |  |  |  | Rel-6 | Paolo |  |
| 4674 | 25.1.6 | Dependency to other features of Enhanced A/Gb feasibility study | 51d | 2002-08-30 A | 2002-11-08 A | 100% | 2002-08-30 | 2002-11-08 | 51d | finish no earlier than 2002-11-08 | GP | 408h | 408h |  |  |  | Rel-6 | Paolo |  |
| 4675 | 26 | **Flexible Layer One for GERAN** | 1171d | 2000-01-03 A | 2004-06-25 A | 100% | 2000-01-03 | 2004-06-25 | 1171d |  | GP; S3 | 86648h | 86648h | FLOGER | Nokia | benoist.sebire@nokia.com | Rel-6 | Paolo | FLOGER |
| 4676 | 26.1 | **Realisation of a Flexible Layer One** | 1126d | 2000-01-03 A | 2004-04-23 A | 100% | 2000-01-03 | 2004-04-23 | 1126d |  | GP | 42816h | 42816h | FLOGER-Real | Nokia | benoist.sebire@nokia.com | Rel-6 | Paolo | FLOGER-Real |
| 4677 | 26.1.1 | Technical Report on Realisation of a Flexible Layer One | 471d | 2002-04-19 A | 2004-02-06 A | 100% | 2002-04-19 | 2004-02-06 | 471d | finish no earlier than 2004-02-06 | GP | 3768h | 3768h |  | Nokia | benoist.sebire@nokia.com | Rel-6 | Paolo |  |
| 4678 | 26.1.2 | Architecture in 45.001 and 43.051 | 526d | 2002-04-19 A | 2004-04-23 A | 100% | 2002-04-19 | 2004-04-23 | 526d | finish no earlier than 2004-04-23 | G1 | 4208h | 4208h |  | Nokia | benoist.sebire@nokia.com | Rel-6 | Paolo |  |
| 4679 | 26.1.3 | Multiplexing in 45.002 | 526d | 2002-04-19 A | 2004-04-23 A | 100% | 2002-04-19 | 2004-04-23 | 526d | finish no earlier than 2004-04-23 | G1 | 4208h | 4208h |  | Nokia | benoist.sebire@nokia.com | Rel-6 | Paolo |  |
| 4680 | 26.1.4 | Channel Coding in 45.003 for Realisation of a Flexible Layer One | 526d | 2002-04-19 A | 2004-04-23 A | 100% | 2002-04-19 | 2004-04-23 | 526d | finish no earlier than 2004-04-23 | G1 | 4208h | 4208h |  | Nokia | benoist.sebire@nokia.com | Rel-6 | Paolo |  |
| 4681 | 26.1.5 | Performance Requirements in 45.005 for Realisation of a Flexible Layer One | 1126d | 2000-01-03 A | 2004-04-23 A | 100% | 2000-01-03 | 2004-04-23 | 1126d | finish no earlier than 2004-04-23 | G1 | 9000h | 9000h |  | Nokia | benoist.sebire@nokia.com | Rel-6 | Paolo |  |
| 4682 | 26.1.6 | Radio subsystem link control in 45.008 for Realisation of a Flexible Layer One | 526d | 2002-04-19 A | 2004-04-23 A | 100% | 2002-04-19 | 2004-04-23 | 526d | finish no earlier than 2004-04-23 | G1 | 4208h | 4208h |  | Nokia | benoist.sebire@nokia.com | Rel-6 | Paolo |  |
| 4683 | 26.1.7 | Requirements in 44.004 | 526d | 2002-04-19 A | 2004-04-23 A | 100% | 2002-04-19 | 2004-04-23 | 526d | finish no earlier than 2004-04-23 | G2 | 4208h | 4208h |  | Nokia | benoist.sebire@nokia.com | Rel-6 | Gert |  |

Notes:
- 4659: merged "Presence Service Enhancements" (UID31028, PRES1) to this feature as no answer was provided on why Presence and Presence Encmts had same target completion date
- 4660: TP#16 moved Stage 1 to Rel-6 TS 22.141 (existed already in Rel-5) / Impacted TSs and TRs: 22.141
- 4661: - / Impacted TSs and TRs: 23.002, 24.229, New 23.141
- 4662: Dependency to 2 IETF drafts, no known work at the moment / Impacted TSs and TRs: New N1 (24.141, 24.841), N4 (29.002, 29.228, 29.230, 29.328)
- 4663: - / Impacted TSs and TRs: 29.061, 29.161
- 4664: - / Impacted TSs and TRs: 26.141, 26.936
- 4665: SP#17 approved WID S3-020429
- 4666: SP#24 OMA LS_in update in SP-040232 OMA dependencies on 3GPP deliverables
- 4667: - / Impacted TSs and TRs: None
- 4668: - / Impacted TSs and TRs: None
- 4669: - / Impacted TSs and TRs: None
- 4670: - / Impacted TSs and TRs: None
- 4671: - / Impacted TSs and TRs: None
- 4672: - / Impacted TSs and TRs: None
- 4673: - / Impacted TSs and TRs: None
- 4674: - / Impacted TSs and TRs: None
- 4675: -
- 4676: -
- 4677: -
- 4678: -
- 4679: -
- 4680: -
- 4681: -
- 4682: -
- 4683: -

| ID | WBS | Task | Type | Duration | Start | Finish | Complete | Baseline start | Baseline finish | Baseline duration | Constraint | Resources | Work | Actual work | Acronym | WI rapporteur name | WI rapporteur e-mail | Release | MCC resp | Acronym_3GU_Export | Impacted TSs and TRs | TSG stopped |
| --- | --- | --- | --- | --- | --- | --- | --- | --- | --- | --- | --- | --- | --- | --- | --- | --- | --- | --- | --- | --- | --- | --- |
| 4684 | 26.2 | **Signalling and protocol support for a Flexible Layer One** |  | 571d | 2002-04-19 A | 2004-06-25 A | 100% | 2002-04-19 | 2004-06-25 | 571d |  | G2 | 13704h | 13704h | FLOGER-SigPro | Nokia | benoist.sebire@nokia.com | Rel-6 | Gert | FLOGER-SigPro |  |  |
| 4685 | 26.2.1 | Modifications to RLC/MAC in 44.060 and 44.160 |  | 571d | 2002-04-19 A | 2004-06-25 A | 100% | 2002-04-19 | 2004-06-25 | 571d | finish no earlier than 2004-06-25 | G2 | 4568h | 4568h |  | Nokia | benoist.sebire@nokia.com | Rel-6 | Gert |  |  |  |
| 4686 | 26.2.2 | Modifications to RRC in 44.118 and 44.018 |  | 571d | 2002-04-19 A | 2004-06-25 A | 100% | 2002-04-19 | 2004-06-25 | 571d | finish no earlier than 2004-06-25 | G2 | 4568h | 4568h |  | Nokia | benoist.sebire@nokia.com | Rel-6 | Gert |  |  |  |
| 4687 | 26.3 | **Security for a Flexible Layer One** |  | 356d | 2002-04-19 A | 2003-08-29 A | 100% | 2002-04-19 | 2003-08-29 | 356d |  | S3; G2 | 11392h | 11392h | FLOGER-SecFLO | Nokia | benoist.sebire@nokia.com | Rel-6 | Mirko | FLOGER-SecFLO |  |  |
| 4688 | 26.3.1 | Ciphering in 44.060, 44.160, 44.018, 44.118 |  | 356d | 2002-04-19 A | 2003-08-29 A | 100% | 2002-04-19 | 2003-08-29 | 356d | finish no earlier than 2003-08-29 | S3; G2 | 5696h | 5696h |  | Nokia | benoist.sebire@nokia.com | Rel-6 | Mirko |  | 44.060, 44.160, 44.018, 44.118 |  |
| 4689 | 26.4 | **Deleted - GERAN MS Conformance test for the Flexible Layer One - DELETE** |  | 0d | 2004-02-06 A | 2004-02-06 A | 100% | 2004-02-06 | 2004-02-06 | 0d |  | G4; G5 |  |  | FLOGER-Msconf | Nokia | benoist.sebire@nokia.com | Rel-6 | Paolo | FLOGER-Msconf |  | GP-27 |
| 4690 | 26.4.1 | Deleted at TSG #27 - MS Test in 51.010 | milestone | 0d | 2004-02-06 A | 2004-02-06 A | 100% | 2004-02-06 | 2004-02-06 | 0d | finish no earlier than 2004-02-06 | G4; G5 |  |  |  | Nokia | benoist.sebire@nokia.com | Rel-6 | Paolo |  |  | GP-22 |
| 4691 | 26.5 | **Deleted - GERAN BTS Conformance test for the Flexible Layer One - DELETE** |  | 0d | 2004-02-06 A | 2004-02-06 A | 100% | 2004-02-06 | 2004-02-06 | 0d |  | G3new |  |  | FLOGER-BTSconf | Nokia | benoist.sebire@nokia.com | Rel-6 | Ingbert | FLOGER-BTSconf |  | GP-27 |
| 4692 | 26.5.1 | Deleted at TGS #27 - BTS Test in 51.021 - DELETE | milestone | 0d | 2004-02-06 A | 2004-02-06 A | 100% | 2004-02-06 | 2004-02-06 | 0d | finish no earlier than 2004-02-06 | G3new |  |  |  | Nokia | benoist.sebire@nokia.com | Rel-6 | Ingbert |  |  | GP-22 |
| 4693 | 27 | Uplink TDOA feasibility study |  | 151d | 2001-11-30 A | 2002-06-28 A | 100% | 2001-11-30 | 2002-06-28 | 151d | finish no earlier than 2002-06-28 | GP | 1208h | 1208h | TDOAF | TruePosition | Bob Gross (rlgross@trueposition.com) | Rel-6 | Paolo | TDOAF | 45.811 |  |
| 4694 | 28 | **Multimedia Broadcast and Multicast Service** |  | 1781d? | 2001-05-11 A | 2008-03-07 A | 100% | 2001-05-11 | 2008-03-07 | 1781d? |  | S1; S2; S3; S4; S5; N1; N3; R2; R4; R5; T1; GP; G2; G3new | 391176h | 391176h | MBMS |  |  | Rel-6 | Alain | MBMS |  |  |
| 4695 | 28.1 | Stage 1 for Multimedia Broadcast and Multicast Service |  | 232d | 2001-05-11 A | 2002-04-01 A | 100% | 2001-05-11 | 2002-04-01 | 232d | finish no earlier than 2002-04-01 | S1 | 1856h | 1856h |  |  |  | Rel-6 | Alain |  | 22.146, 22.101 |  |
| 4696 | 28.2 | **Stage 2 for Multimedia Broadcast and Multicast Service** |  | 648d | 2001-09-24 A | 2004-03-17 A | 100% | 2001-09-24 | 2004-03-17 | 648d |  | S2 | 10408h | 10408h |  |  |  | Rel-6 | Maurice |  |  |  |
| 4697 | 28.2.1 | TR on MBMS Architectural Study |  | 240d | 2001-09-24 A | 2002-08-23 A | 100% | 2001-09-24 | 2002-08-23 | 240d | finish no earlier than 2002-08-23 | S2 | 1920h | 1920h |  |  |  | Rel-6 | Maurice |  | 23.846 |  |
| 4698 | 28.2.2 | Stage 2 MBMS Specification Work |  | 413d | 2002-08-19 A | 2004-03-17 A | 100% | 2002-08-19 | 2004-03-17 | 413d | finish no earlier than 2004-03-17 | S2 | 3304h | 3304h |  |  |  | Rel-6 | Maurice |  | 23.246 |  |
| 4699 | 28.4 | Support of the MBMS in CN protocols |  | 647d | 2002-06-18 A | 2004-12-08 A | 100% | 2002-06-18 | 2004-12-08 | 647d | finish no earlier than 2004-12-08 | N1 | 5176h | 5176h |  |  |  | Rel-6 | Frederic |  |  |  |
| 4700 | 1232.4 | Gmb interface for MBMS (CN3 part) |  | 334d | 2003-08-29 A | 2004-12-08 A | 100% | 2003-08-29 | 2004-12-08 | 334d | finish no earlier than 2004-12-08 | N3 | 2672h | 2672h |  |  |  | Rel-6 | Gwiho |  | 29.061 |  |
| 4701 | 28.5 | Security aspects of MBMS |  | 710d | 2002-07-01 A | 2005-03-18 A | 100% | 2002-07-01 | 2005-03-18 | 710d | finish no earlier than 2005-03-18 | S3 | 5680h | 5680h |  |  | adrian.escott@three.co.uk | Rel-6 | Mirko |  | New 33.246 |  |
| 4702 | 1232.6 | MBMS Charging |  | 108d? | 2005-01-11 A | 2005-06-09 A | 100% | 2005-01-11 | 2005-06-09 | 108d? | start no earlier than 2005-01-11 | S5 | 864h | 864h | MBMS-CH |  |  | Rel-6 | Mirko | MBMS-CH | 32.273 |  |
| 4703 | 28.1 | **MBMS User Services** |  | 743d? | 2003-05-13 A | 2006-03-16 A | 100% | 2003-05-13 | 2006-03-16 | 743d? |  | S1; S4 | 19520h | 19520h |  |  |  | Rel-6 | Alain |  |  |  |
| 4704 | 28.1 | Stage 1 for MBMS User Services |  | 233d | 2003-05-13 A | 2004-04-01 A | 100% | 2003-05-13 | 2004-04-01 | 233d | start no earlier than 2003-05-13 | S1 | 1864h | 1864h |  |  |  | Rel-6 | Alain |  | 22.246 |  |
| 4705 | 1232.7.2 | Definition of MBMS user services, media codecs, formats and transport/application protocols using MBMS |  | 721d? | 2003-06-12 A | 2006-03-16 A | 100% | 2003-06-12 | 2006-03-16 | 721d? | finish no earlier than 2006-03-16 | S4 | 5768h | 5768h | MBMS-TSMBMS | Nokia | igor.curcio@nokia.com | Rel-6 | Paolo | MBMS-TSMBMS | 26.346, 26.936, 26.946 |  |
| 4706 | 28.3 | **Introduction of MBMS in RAN** |  | 967d? | 2002-01-01 A | 2005-09-14 A | 100% | 2002-01-01 | 2005-09-14 | 967d? |  | R2; R4 | 23728h | 23728h | MBMS-RAN | Nokia | juho.pirskanen@nokia.com | Rel-6 | Yong-Jun | MBMS-RAN |  |  |
| 4707 | 1232.8.1 | Introduction of MBMS in RAN (physical & upper layers, access network interfaces) |  | 771d? | 2002-01-01 A | 2004-12-14 A | 100% | 2002-01-01 | 2004-12-14 | 771d? | finish no earlier than 2004-12-14 | R2 | 6168h | 6168h |  | Nokia | juho.pirskanen@nokia.com | Rel-6 | Yong-Jun |  | 25.346, 25.304, 25.321, 25.322, 25.323 |  |
| 4708 | 1232.8.2 | UE Performance Requirements for MBMS |  | 261d? | 2004-09-15 A | 2005-09-14 A | 100% | 2004-09-15 | 2005-09-14 | 261d? | finish no earlier than 2005-09-15 | R4 | 2088h | 2088h | MBMS-RAN-RF | Ericsson | Torgny.Palenius@ericsson.com | Rel-6 | Issam | MBMS-RAN-RF | 25.101, 25.133 |  |

Notes:
- 4684: -
- 4685: -
- 4686: -
- 4687: -
- 4688: -
- 4689: -
- 4690: -
- 4691: -
- 4692: -
- 4693: -
- 4694: SP#13 Title renamed
- 4695: -
- 4696: -
- 4697: -
- 4698: -
- 4699: -
- 4700: -
- 4701: SP#17 approved WID S3-020433
- 4702: SP#28 completed
- 4703: -
- 4704: -
- 4705: -
- 4706: -
- 4707: -
- 4708: RP#25 approved WID RP-040370
